# POM02 sPHENIX WBS 1.x, 2.x May 2021

Schedule from Primavera P6, 2016-09-27 to 2023-01-30, data date 2021-06-01, costs in USD, A marks actual dates.
RG 06.20.19 made copy to swap resources to new set. Also / fixed the Activity Duration vs Res Assgn duration to be in sync. / EMenter 190531 / Copied from ID POM02P004_Other / and changed ID to POM02. / Created BL POM02B as a copy of the current / project. / EMenter 190422 / PCR004 is in this project / EMenter 190330 / Fixed fiscal / boundary issues and calculation errors; reissued iterations of this P6 / Project for the below uses / EMenter 190329 / Project frozen / for the purpose of productions of reports for the 2019 Director's Review and the / generation of P6 Project copies for use in Primavera Risk and / Cobra / EMenter 190326 / This project is the approved preliminary / baseline as of this date; cumulative changes from PCRs 001, 002 and 003 are / included. / EMenter 190211 / This project is for PCR data / entry / EMenter 181118 / This project has FY19EPR / rates / 180924 RFG - Changed Project Name to POM02 sPHENIX / Schedule Prep Prelim BL October 1 2018 Rev 0 from POM01 sPHENIX Schedule Rev K / Draft / 180909 RFG - Changed Project ID to POM02 from / POM02B_K. / 180325 ELM - relabeled as version K, after creating a / baseline as a copy of itself (changed naming convention for this / baseline- name is "POM02 after CD-1 Review 180525") / 180308 ELM - relabeled as version J, after creating a baseline as a copy of / itself (BL is labeled H, since this was version H as used for director's / review) / 180228 ELM copy as BL prior to moving Milestone CD1/3a to / 28-Sep-18 / 180227 IVS made a copy before importing estimate / uncertainty data. / 180214 RFG at the end of the day copied POM02_H Rev / H. Replaced the Nonlabor resources (except Actual budget resources) with / the _sEPR resources. Copy this afterward and replaced as new Rev H. / 180213 RFG copied to PM02B180213 prior to adding new / material resources to resource table / 180211 RFG copied Rev G to G4c for final Sunday Night data / pull for cost review / 180131 ELM copied Rev F to get rid of deleted / activities / 180112 IVS copied Rev E to get rid of deleted / activities / 171206 RFG copied Rev E. This copy has / procurement strings loaded / 171015 RFG Rev D to split M&S, merge milestones, and / fix rate source / 170823 IS changed to Rev C – made copy PO00101B1708 / 170823 RFG rev B was using in the Aug 2017 sPHENIX / Director's Review / 170808 RFG made copy of Rev B, PO00101x001, to / add coding for CEB intgration / 170716 RFG changed to rev B updated with resources, logic / to match 10 July MPP files / 170610 RFG updated with resources and matched up to June / 4 MPP files / 170604 RFG creating copy prior to adding materials to the / working copy / 170507 RFG Created SPHENIX P6 schedule in the restore / database / 180822 ELM values for Resource Assignment UDF / BNL_RAU_Institution / Value / Description / BNL / Brookhaven National Laboratory / GSU / Georgia State University / LANL / Los Alamos National Laboratory / LBNL / Lawrence Berkeley National Laboratory / Lehigh / Lehigh University / MIT / Massachusetts Institute of Technology / POOL / Resource Pool / SBU / Stony Brook University / Temple / Temple University / UCol / University of Colorado / UIUC / University of Illinois Urbana-Champagne / UTAustin / University of Texas Austin / Vanderbilt / Vanderbilt University / Wayne / Wayne University / WIS / University of / Wisconsin

## Calendars

- BNL: Mon-Fri 08:00-16:00; Sat-Sun off. Exceptions (off unless hours are given): 2016-10-10, 2016-11-11, 2016-11-24 to 2016-11-25, 2016-12-26, 2017-01-02, 2017-01-16, 2017-02-20, 2017-05-29, 2017-07-04, 2017-09-04, 2017-10-09, 2017-11-10, 2017-11-23 to 2017-11-24, 2017-12-25, 2018-01-01, 2018-01-15, 2018-02-19, 2018-05-28, 2018-07-04, 2018-09-03, 2018-10-08, 2018-11-12, 2018-11-22 to 2018-11-23, 2018-12-25, 2019-01-01, 2019-01-21, 2019-02-18, 2019-05-27, 2019-07-04, 2019-09-02, 2019-10-14, 2019-11-11, 2019-11-28 to 2019-11-29, 2019-12-25, 2020-01-01, 2020-01-20, 2020-02-17, 2020-05-25, 2020-07-03, 2020-09-07, 2020-10-12, 2020-11-11, 2020-11-26 to 2020-11-27, 2020-12-25, 2021-01-01, 2021-01-18, 2021-02-15, 2021-05-31, 2021-07-05, 2021-09-06, 2021-10-11, 2021-11-11, 2021-11-25 to 2021-11-26, 2021-12-24, 2021-12-31, 2022-01-17, 2022-02-21, 2022-05-30, 2022-07-04, 2022-09-05, 2022-10-10, 2022-11-11, 2022-11-24 to 2022-11-25, 2022-12-26, 2023-01-02, 2023-01-16.

## Resources

| Resource | Group | Rate | Notes |
| --- | --- | --- | --- |
| Actual Labor | labor | 130.6 |  |
| Actual Nonlabor | equipment | 1 | ï»¿ |
| Travel Cost | equipment | 1 | ï»¿ |
| Project Mgmt Specialist - Purchased Services | labor | 124 | ï»¿ |
| PROF5 AD | labor | 129.05 |  |
| SCI 4 PO | labor | 156.25 |  |
| PROF4 PO M | labor | 111.75 |  |
| PROF5 PO M | labor | 129.05 |  |
| SCI2 PO | labor | 113.4 |  |
| PROF2 PO PC | labor | 76.05 |  |
| ADMIN1 PO | labor | 46.1 |  |
| ADMIN7 PO | labor | 171.8 |  |
| SCI3 SBU - Unpaid | labor |  |  |
| TECH3 PO M | labor | 86.6 |  |
| SBU Contracted Purchase <$2M M&S | equipment | 1 | ï»¿ |
| Obligation Resource | equipment | 1 | ï»¿ |
| STUDENT SBU - Unpaid | labor |  |  |
| TECH4 SBU - Unpaid | labor |  |  |
| SCI3 PO | labor | 130.6 |  |
| SCI4 SBU - Unpaid | labor |  |  |
| PROF4 AM | labor | 111.75 |  |
| Material (Purchase (1st $2M) | equipment | 1 | ï»¿ |
| PROF4 PO E | labor | 111.75 |  |
| TECH3 PO E | labor | 86.6 |  |
| PROF2 | labor | 76.05 |  |
| STUDENT Wayne - Unpaid | labor |  |  |
| PROF3 Wayne - Purchased Services | labor | 89.15 |  |
| Wayne Contracted Purchase <$2M M&S | equipment | 1 | ï»¿ |
| TECH3 Wayne - Purchased Services | labor | 55.6 |  |
| SCI3 Wayne - Unpaid | labor |  |  |
| PROF3 Vanderbilt - Unpaid | labor |  |  |
| STUDENT Vanderbilt - Unpaid | labor |  |  |
| Vanderbilt Contracted Purchase <$2M M&S | equipment | 1 | ï»¿ |
| SCI3 Vanderbilt - Unpaid | labor |  |  |
| TECH3 Vanderbilt - Unpaid | labor |  |  |
| TECH3 PO D | labor | 86.6 |  |
| PROF3 PO E | labor | 96 |  |
| PROF3 PO M | labor | 96 |  |
| TECH1 | labor | 58.35 |  |
| PROF3 | labor | 96 |  |
| PROF5 PO S Software | labor | 129.05 |  |
| PROF3 IO E | labor | 96 |  |
| SCI3 WIS - Unpaid | labor |  |  |
| TECH3 WIS - Unpaid | labor |  |  |
| STUDENT WIS - Unpaid | labor |  |  |
| SCI3 Temple - Unpaid | labor |  |  |
| TECH3 Temple - Unpaid | labor |  |  |
| STUDENT Temple - Unpaid | labor |  |  |
| Weizmann Contracted Purchase <$2M M&S | equipment | 1 | ï»¿ |
| Temple Contracted Purchase <$2M M&S | equipment | 1 | ï»¿ |
| UIUC Contracted Purchase <$2M M&S | equipment | 1 | ï»¿ |
| TECH3 UIUC - Purchased Services | labor | 45 |  |
| STUDENT UIUC - Purchased Services | labor | 15.07 |  |
| TECH3 Senior UIUC - Purchased Services | labor | 98.2 |  |
| Material (Purchase (1st $2M) | equipment | 1 | ï»¿ |
| STUDENT Other - Unpaid | labor |  |  |
| SCI3 PO PM | labor | 130.6 |  |
| SCI3 Other - Unpaid | labor |  |  |
| STUDENT GSU OnC - Purchased Services | labor | 15.35 |  |
| STUDENT GSU OffC - Purchased Services | labor | 12.6 |  |
| CRAFT3 | labor | 98.33 |  |
| POSTDOC GSU - Unpaid | labor |  |  |
| FACULTY ISU - Unpaid | labor |  |  |
| STUDENT GSU - Unpaid | labor |  |  |
| STUDENT UCol - Unpaid | labor |  |  |
| SCI3 UCol - Unpaid | labor |  |  |
| POSTDOC ISU - Unpaid | labor |  |  |
| STUDENT UM - Purchased Services | labor | 13.89 |  |
| SCI2 UM - Unpaid | labor |  |  |
| STUDENT GRAD UM - Unpaid | labor |  |  |
| STUDENT GRAD Other - Unpaid | labor |  |  |
| SCI3 UM - Unpaid | labor |  |  |
| UM Contracted Purchase <$2M M&S | equipment | 1 | ï»¿ |
| PROF4 AD | labor | 111.75 |  |
| SCI3 AD | labor | 130.6 |  |
| PROF3 AD | labor | 96 |  |
| PROF6 AD | labor | 146.45 |  |
| TECH3 AD | labor | 86.6 |  |
| TECH3 AM | labor | 86.6 |  |
| PROF2 AD | labor | 76.05 |  |
| TECH4 AD | labor | 99.1 | ï»¿ |
| POSTD LBNL | labor |  |  |
| STAFFPHYS LBNL | labor |  |  |
| SCI3 LANL | labor |  |  |

## Schedule

| ID | WBS | Activity | Type | Duration | Start | Finish | Predecessors | Complete | Planned start | Planned finish | Total float | Free float | Constraint | Resources | Cost | BNL_UDF_Temp Text 01 | BNL_UDF_Percent Complete | BNL_UDF_Old Activity ID 181221 | RG Check | BNL_Activity Status | BNL_Fund Source | BNL_Estimator | BNL_Cost Basis | BNL_EDIA | BNL_CAM | BNL_OPC TEC (deprecated) | BNL_WBS | BNL_Actuals | BNL_FY | BNL_EVT | BNL_WBS_Hierarchical | Completed | BNL_Cobra WP | BNL_Master Control Account | BNL_Account Number | BNL_Cobra Control Account | Indicator - Procurement | BNL_UDF_Status Comments | BNL_Milestone Level | BNL_PCR ID | BNL_UDF_OPC TEC (deprecated) | BNL_UDF_Temp Date 01 | BNL_Institution | BNL_UDF_Adhoc Comments | BNL_Management or Mgmt Travel | Target Milestone Date | Variance | PMP Milestones | Indicator - Float |
| --- | --- | --- | --- | --- | --- | --- | --- | --- | --- | --- | --- | --- | --- | --- | --- | --- | --- | --- | --- | --- | --- | --- | --- | --- | --- | --- | --- | --- | --- | --- | --- | --- | --- | --- | --- | --- | --- | --- | --- | --- | --- | --- | --- | --- | --- | --- | --- | --- | --- |
|  | 01 | **MIE Project** |  |  | 2016-09-27 | 2022-12-29 |  |  |  |  |  |  |  |  |  |  |  |  |  |  |  |  |  |  |  |  |  |  |  |  |  |  |  |  |  |  |  |  |  |  |  |  |  |  |  |  |  |  |  |
|  | 01 | **Project Management** |  |  | 2016-09-27 | 2022-12-29 |  |  |  |  |  |  |  |  |  |  |  |  |  |  |  |  |  |  |  |  |  |  |  |  |  |  |  |  |  |  |  |  |  |  |  |  |  |  |  |  |  |  |  |
| S102100 |  | Actuals - Nonlabor - A - MIE - sPHENIX Project Management FY17 |  | 418d | 2017-02-01 A | 2018-09-28 A | S100090 SS | 100% |  |  |  |  |  |  |  | S102100 | 100 | S342740 | NOCA | Completed | A-OPC | O'Brien, Ed | L1 | Management | Irina Sourikova | OPC | POM02.1.01 | Yes | 2017 | A | 01 | yes |  |  |  |  |  |  |  |  |  |  |  |  |  |  |  |  |  |
| S102200 |  | Actuals - Labor - B - BNL Contributed Labor - sPHENIX Project Management FY17 |  | 169d | 2017-02-01 A | 2017-09-29 A | S100090 SS | 100% |  |  |  |  |  | Actual Labor [2984.34 h] | 498,662 | S102200 | 100 | S100140 | CA | Completed | B | O'Brien, Ed | L1 | Management | Irina Sourikova | null | POM02.1.01 | Yes | 2017 | A | 01 | yes | S102200 | 1.01 | 16708 | 1.01B |  |  |  |  |  |  |  |  |  |  |  |  |  |
| S102300 |  | Actuals - Labor - A - MIE - sPHENIX Project Management FY17 |  | 169d | 2017-02-01 A | 2017-09-29 A | S100090 SS | 100% |  |  |  |  |  | Actual Labor [641 h] | 107,106.54 | S102300 | 100 | S100150 | CA | Completed | A-OPC | O'Brien, Ed | L1 | Management | Irina Sourikova | OPC | POM02.1.01 | Yes | 2017 | A | 01 | yes | S102300 | 1.01 | 16700 | 1.01A |  |  |  |  |  |  |  |  |  |  |  |  |  |
| S102400 |  | Actuals - Labor - A - MIE - sPHENIX Project Management FY18 |  | 249d | 2017-10-02 A | 2018-09-28 A | S102300 | 100% |  |  |  |  |  | Actual Labor [1693.93 h] | 283,043.66 | S102400 | 100 | S100160 | CA | Completed | A-OPC | O'Brien, Ed | L1 | Management | Irina Sourikova | OPC | POM02.1.01 | Yes | 2018 | A | 01 | yes | S102400 | 1.01 | 16700 | 1.01A |  |  |  |  |  |  |  |  |  |  |  |  |  |
| S102500 |  | Actuals - Nonlabor - A - MIE - sPHENIX Project Management FY18 |  | 249d | 2017-10-02 A | 2018-09-28 A | S102100 | 100% |  |  |  |  |  | Actual Nonlabor [547599 h] | 610,909.39 | S102500 | 100 | S100165 | CA | Completed | A-OPC | O'Brien, Ed | L1 | Management | Irina Sourikova | OPC | POM02.1.01 | Yes | 2018 | A | 01 | yes | S102500 | 1.01 | 16700 | 1.01A | UDF_G3 |  |  |  |  |  |  |  |  |  |  |  |  |
| S102600 |  | Actuals - Labor - B - BNL Contributed Labor - sPHENIX Project Management FY18 |  | 249d | 2017-10-02 A | 2018-09-28 A | S102200 | 100% |  |  |  |  |  | Actual Labor [6861.1 h] | 1,146,441.05 | S102600 | 100 | S342780 | CA | Completed | B | O'Brien, Ed | L1 | Management | Irina Sourikova | null | POM02.1.01 | Yes | 2018 | A | 01 | yes | S102600 | 1.01 | 16708 | 1.01B |  |  |  |  |  |  |  |  |  |  |  |  |  |
| S1001839 |  | Actuals - Nonlabor - A - MIE - sPHENIX Project Management FY19M8 |  | 166d | 2018-10-01 A | 2019-05-31 A |  | 100% |  |  |  |  |  | Actual Nonlabor [22509.5 h] | 24,833.89 | S102500 | 100 | S100165 | CA | Completed | A-TEC | O'Brien, Ed | L1 | Management | Irina Sourikova | TEC | POM02.1.01 | Yes | 2019 | A | 01 | yes | S1001839 | 1.01 | 59700 | 1.01A | UDF_G3 |  |  |  |  |  |  |  |  |  |  |  |  |
| S102605 |  | Actuals - Labor - A - MIE - sPHENIX Project Management FY19M8 |  | 166d | 2018-10-01 A | 2019-05-31 A | S102400 | 100% |  |  |  |  |  | Actual Labor [69.22 h] | 11,566.17 | S102400 | 100 | S100160 | CA | Completed | A-OPC | O'Brien, Ed | L1 | Management | Irina Sourikova | OPC | POM02.1.01 | Yes | 2019 | A | 01 | yes | S102605 | 1.01 | 16700 | 1.01A |  |  |  |  |  |  |  |  |  |  |  |  |  |
| S102606 |  | Actuals - Nonlabor - A - MIE - sPHENIX Project Management FY19M8 |  | 166d | 2018-10-01 A | 2019-05-31 A | S102500 | 100% |  |  |  |  |  | Actual Nonlabor [298116 h] | 328,901.5 | S102500 | 100 | S100165 | CA | Completed | A-OPC | O'Brien, Ed | L1 | Management | Irina Sourikova | OPC | POM02.1.01 | Yes | 2019 | A | 01 | yes | S102606 | 1.01 | 16700 | 1.01A | UDF_G3 |  |  |  |  |  |  |  |  |  |  |  |  |
| S102610 |  | Actuals - Labor - B - BNL Contributed Labor - sPHENIX Project Management FY19M8 |  | 166d | 2018-10-01 A | 2019-05-31 A | S102600 | 100% |  |  |  |  |  | Actual Labor [6324.58 h] | 1,056,792.37 | S102600 | 100 | S342780 | CA | Completed | B | O'Brien, Ed | L1 | Management | Irina Sourikova | null | POM02.1.01 | Yes | 2019 | A | 01 | yes | S102610 | 1.01 | 16708 | 1.01B |  |  |  |  |  |  |  |  |  |  |  |  |  |
|  | 01 | **Management Overview** |  |  | 2016-09-27 | 2022-12-29 |  |  |  |  |  |  |  |  |  |  |  |  |  |  |  |  |  |  |  |  |  |  |  |  |  |  |  |  |  |  |  |  |  |  |  |  |  |  |  |  |  |  |  |
| S100000 |  | Start sPHENIX MIE Project | milestone | 0d | 2016-09-27 A | 2016-09-27 A |  | 100% |  |  |  |  |  |  |  | S100010 | 100 | S100010 | NOCA | Completed |  | DOE - HQ |  | Critical Decisions, Key Dates | Irina Sourikova |  | POM02.1.01.01 |  |  |  | 01 | yes |  |  |  |  |  | 190323 ELM Add | L1 | 003 |  |  |  |  |  |  |  |  |  |
| S100010 |  | Approve Mission Need CD-0 | milestone | 0d | 2016-09-27 A | 2016-09-27 A | S100000 | 100% |  |  |  |  |  |  |  | S100010 | 100 | S100010 | NOCA | Completed |  | DOE - HQ |  | Critical Decisions, Key Dates | Irina Sourikova |  | POM02.1.01.01 |  |  |  | 01 | yes |  |  |  |  |  |  | L1 |  |  |  |  |  |  |  |  |  |  |
| S100090 |  | Initial Project Funding Release | milestone | 0d | 2017-02-01 A | 2017-02-01 A | S100010 FS+84d | 100% |  |  |  |  |  |  |  | S100090 | 100 | S100090 | NOCA | Completed |  | O'Brien, Ed |  | Critical Decisions, Key Dates | Irina Sourikova |  | POM02.1.01.01 |  |  |  | 01 | yes |  |  |  |  |  |  | L3 |  |  |  |  |  |  |  |  |  |  |
| S100200 |  | Prepare for CD-1 Review |  | 331d | 2017-02-01 A | 2018-05-25 A | S100090 SS | 100% |  |  |  |  |  |  |  | S100200 | 100 | S100200 | NOCA | Completed |  | O'Brien, Ed |  | Management | Irina Sourikova |  | POM02.1.01.01 |  |  |  | 01 | yes |  |  |  |  |  | 190323 ELM ActType |  | 003 | S100200 | 2018-05-25 | BNL |  |  |  |  |  |  |
| S101008 |  | FY18 funding available | milestone | 0d | 2017-10-02 A | 2017-10-02 A | S100000 SS | 100% |  |  |  |  |  |  |  | S101008 | 100 | S101008 | NOCA | Completed |  | DOE - HQ |  | Management | Irina Sourikova |  | POM02.1.01.01 |  |  |  | 01 | yes |  |  |  |  |  | 190323 ELM Logic | L3 | 003 |  |  |  | 180227 ELM added per GRY |  |  |  |  |  |
| S100300 |  | Prototype 2018 Spending Authorization | milestone | 0d | 2017-12-18 A | 2017-12-18 A | S100090 SF | 100% |  |  |  |  |  |  |  | S100300 | 100 | S100300 | NOCA | Completed |  | O'Brien, Ed |  | Management | Irina Sourikova |  | POM02.1.01.01 |  |  |  | 01 | yes |  |  |  |  |  |  | L3 |  | S100300 |  |  |  |  |  |  |  |  |
| S100340 |  | BNL Prototype Spending Authorization | milestone | 0d | 2018-02-13 A | 2018-02-13 A | S100090 SS | 100% |  |  |  |  |  |  |  | S100340 | 100 | S100340 | NOCA | Completed |  | O'Brien, Ed |  | Management | Irina Sourikova |  | POM02.1.01.01 |  |  |  | 01 | yes |  |  |  |  |  |  | L3 |  |  |  |  |  |  |  |  |  |  |
| S100400 |  | CD-1 Review |  | 3d | 2018-05-23 A | 2018-05-25 A | S100200 FF | 100% |  |  |  |  |  |  |  | S100400 | 100 | S100400 | NOCA | Completed |  | O'Brien, Ed |  | Management | Irina Sourikova |  | POM02.1.01.01 |  |  |  | 01 | yes |  |  |  |  |  | 190323 ELM Logic |  | 003 | S100400 |  | BNL |  |  |  |  |  |  |
| S100700 |  | Start PD-2/3 Review preparation |  | 90d | 2018-05-23 A | 2018-09-28 A | S100400 SS | 100% |  |  |  |  |  |  |  | S100700 | 100 | S100700 | NOCA | Completed |  | O'Brien, Ed |  | Management | Irina Sourikova |  | POM02.1.01.01 |  |  |  | 01 | yes |  |  |  |  |  | 190415 ELM name per GRY;190323 ELM ActType |  | 003,004 | S100700 |  | BNL |  |  |  |  |  |  |
| S100500 |  | Approve Cost Range and Long lead Procurement CD-1/3A | milestone | 0d | 2018-08-17 A | 2018-08-17 A | S100400 FS+27d | 100% |  |  |  |  |  |  |  | S100500 | 100 | S100500 | NOCA | Completed |  | DOE - HQ |  | Critical Decisions, Key Dates | Irina Sourikova |  | POM02.1.01.01 |  |  |  | 01 | yes |  |  |  |  |  |  | L1 |  | S100500 |  | BNL |  |  |  |  |  |  |
| S100750 |  | Prepare for PD-2/3 Review |  | 163d | 2018-09-28 A | 2019-05-24 A | S100700 | 100% |  |  |  |  |  |  |  | S100750 | 40 | S100750 | NOCA | Completed |  | O'Brien, Ed |  | Management | Irina Sourikova |  | POM02.1.01.01 |  |  |  | 01 | yes |  |  |  |  |  | 190415 ELM name per GRY |  | 004 | S100700 |  | BNL |  |  |  |  |  |  |
| S101009 |  | FY19 funding available | milestone | 0d | 2018-11-01 A | 2018-11-01 A | S101008 SS | 100% |  |  |  |  |  |  |  | S101009 | 100 | S101009 | NOCA | Completed |  | DOE - HQ |  | Management | Irina Sourikova |  | POM02.1.01.01 |  |  |  | 01 | yes |  |  |  |  |  | 190323 ELM Logic | L3 | 003 |  |  |  | 180227 ELM added per GRY |  |  |  |  |  |
| S100600 |  | CD-3A Budget Appropriation | milestone | 0d | 2018-11-13 A | 2018-11-13 A | S100500 | 100% |  |  |  |  |  |  |  | S100600 | 100 | S100600 | NOCA | Completed |  | DOE - HQ |  | Critical Decisions, Key Dates | Irina Sourikova |  | POM02.1.01.01 |  |  |  | 01 | yes |  |  |  |  |  |  | L3 |  | S100600 |  |  | 180410 ELM pred per GRY |  |  |  |  |  |
| S100800 |  | PD-2/3 Review |  | 3d | 2019-05-28 A | 2019-05-30 A | S100750 | 100% |  |  |  |  | start on or after 2019-05-23 |  |  | S100800 | 0 | S100800 | NOCA | Completed |  | O'Brien, Ed |  | Management | Irina Sourikova |  | POM02.1.01.01 |  |  |  | 01 | yes |  |  |  |  |  | 190415 ELM name per GRY |  | 004 | S100800 |  | BNL |  |  |  |  |  |  |
| S100900 |  | Transition to PD2/3 |  | 35d | 2019-05-31 A | 2019-09-19 A | S100800 | 100% | 2019-05-31 | 2019-07-19 |  |  |  |  |  | S100900 | 0 | S100900 | NOCA | Completed |  | O'Brien, Ed |  | Management | Irina Sourikova |  | POM02.1.01.01 |  |  |  | 01 |  |  |  |  |  |  | 190415 ELM name per GRY |  | 004 | S100900 |  | BNL |  | Yes |  |  |  |  |
| S101000 |  | Approve Project Baseline and Construction PD2/3 | milestone | 0d | 2019-09-20 A | 2019-09-20 A | S100900 | 100% | 2019-10-01 | 2019-10-01 |  |  | finish on or after 2019-09-12 |  |  | S101000 | 0 | S101000 | NOCA | Completed |  | DOE - HQ |  | Critical Decisions, Key Dates | Irina Sourikova |  | POM02.1.01.01 |  |  |  | 01 |  |  |  |  |  |  | 190415 ELM name per GRY | L1 | 004 | S101000 |  | BNL |  | Yes | 2019-09-30 | 6 | PMP_1x |  |
| S101010 |  | FY20 funding available | milestone | 0d | 2019-10-01 A | 2019-10-01 A | S101009 SS | 100% |  |  |  |  | start on or after 2019-10-01 |  |  | S101010 | 0 | S101010 | NOCA | Completed |  | DOE - HQ |  | Management | Irina Sourikova |  | POM02.1.01.01 |  |  |  | 01 |  |  |  |  |  |  | 190323 ELM Logic | L3 | 003 |  |  |  |  |  |  |  |  |  |
| S101012 |  | IR Ready for Prep | milestone | 0d | 2019-11-29 A | 2019-11-29 A | S100000 SS | 100% | 2019-12-02 | 2019-12-02 |  |  | start on or after 2019-10-01 |  |  | S101012 | 0 | S101012 | NOCA | Completed |  | O'Brien, Ed |  | Critical Decisions, Key Dates | Irina Sourikova |  | POM02.1.01.01 |  |  |  | 01 |  |  |  |  |  |  | 190323 ELM Logic | L3 | 003 |  |  |  |  |  |  |  |  |  |
| S101015 |  | FY21 funding available | milestone | 0d | 2020-10-01 A | 2020-10-01 A | S101010 | 100% | 2020-11-02 | 2020-11-02 |  |  | start on or after 2020-10-01 |  |  | S101015 | 0 | S101015 | NOCA | Not Started |  | DOE - HQ |  | Management | Irina Sourikova |  | POM02.1.01.01 |  |  |  | 01 |  |  |  |  |  | UDF_G3 | 190323 ELM Logic | L3 | 003 |  |  |  | 180221 ELM added activity per GRY |  |  |  |  | UDF_G3 |
| S101016 |  | FY22 funding available | milestone | 0d | 2021-10-01 | 2021-10-01 | S101015 SS |  |  |  | 0d |  | start on or after 2021-10-01 |  |  | S101016 | 0 | S101016 | NOCA | Not Started | A-TEC | DOE - HQ |  | Management | Irina Sourikova |  | POM02.1.01.01 |  |  |  | 01 |  |  |  |  |  | UDF_G3 | 190323 ELM Logic | L3 | 003 |  |  |  | 180221 ELM added activity per GRY | Yes |  |  |  | UDF_G1 |
| S101020 |  | Internal Project Float |  | 0d | 2022-02-07 | 2022-02-07 | S253100, S121900, S197300, S210500, S210400, S253000, S244500, S234300, S148600, S274100, S260800, S268200, S270900, S265400, S200100, S147600 |  |  |  | 0d |  | finish on 2022-02-07 |  |  | S101020 | 0 | S101020 | NOCA | Not Started | A-TEC | O'Brien, Ed |  | Management | Irina Sourikova |  | POM02.1.01.01 |  |  |  | 01 |  |  |  |  |  | UDF_G3 |  | L3 | 020 |  |  |  |  | Yes |  |  |  | UDF_G1 |
| S101022 |  | Early Project Completion | milestone | 0d | 2022-02-07 | 2022-02-07 | S101020 FF, S103400 FF, S104200 FF, S103500 FF, S103510 FF |  |  |  | 0d |  |  |  |  | S101022 | 0 | S101022 | NOCA | Not Started | A-TEC | O'Brien, Ed |  | Critical Decisions, Key Dates | Irina Sourikova |  | POM02.1.01.01 |  |  |  | 01 |  |  |  |  |  | UDF_G3 |  | L2 |  |  |  |  |  | Yes | 2022-02-07 | 0 | PMP_1x | UDF_G1 |
| S101030 |  | WBS 1X Schedule Contingency |  | 225d | 2022-02-07 | 2022-12-29 | S101022 |  |  |  | 0d |  |  |  |  | S101030 | 0 | S101030 | NOCA | Not Started | A-TEC | DOE - HQ |  | Critical Decisions, Key Dates | Irina Sourikova |  | POM02.1.01.01 |  |  |  | 01 |  |  |  |  |  |  |  |  | 020 |  |  |  |  | Yes |  |  |  |  |
| S101040 |  | Approve Project Closeout PD-4 | milestone | 0d | 2022-12-29 | 2022-12-29 | S101030 FF |  |  |  | 0d | 19d | finish on 2022-12-29 |  |  | S101040 | 0 | S101040 | NOCA | Not Started | A-TEC | DOE - HQ |  | Critical Decisions, Key Dates | Irina Sourikova |  | POM02.1.01.01 |  |  |  | 01 |  |  |  |  |  | UDF_G3 | 190415 ELM name per GRY | L1 | 004 |  |  |  |  | Yes | 2022-12-30 | 0 | PMP_1x | UDF_G1 |

Notes:
- 01: 180420 GYoung: concerning ES&H labor - it is / understood some ES&H time is covered in the labor loaded within this / WBS branch
- S102100: BNL_UDF_Old Activity Name 181221: Actuals - Nonlabor - A - MIE - sPHENIX Project Management FY17
- S102200: BNL_UDF_Old Activity Name 181221: Actuals - Labor - B - BNL Contributed Labor - sPHENIX Project Management FY17
- S102300: BNL_UDF_Old Activity Name 181221: Actuals - Labor - A - MIE - sPHENIX Project Management FY17
- S102400: BNL_UDF_Old Activity Name 181221: Actuals - Labor - A - MIE - sPHENIX Project Management FY18
- S102500: BNL_UDF_Old Activity Name 181221: Actuals - Nonlabor - A - MIE - sPHENIX Project Management FY18
- S102600: BNL_UDF_Old Activity Name 181221: Actuals - Labor - B - BNL Contributed Labor - sPHENIX Project Management FY18
- S1001839: BNL_UDF_Old Activity Name 181221: Actuals - Nonlabor - A - MIE - sPHENIX Project Management FY18
- S102605: BNL_UDF_Old Activity Name 181221: Actuals - Labor - A - MIE - sPHENIX Project Management FY18
- S102606: BNL_UDF_Old Activity Name 181221: Actuals - Nonlabor - A - MIE - sPHENIX Project Management FY18
- S102610: BNL_UDF_Old Activity Name 181221: Actuals - Labor - B - BNL Contributed Labor - sPHENIX Project Management FY18
- S100000: BNL_UDF_Old Activity Name 181221: Approve Mission Need CD-0
- S100010: BNL_UDF_Old Activity Name 181221: Approve Mission Need CD-0
- S100090: BNL_UDF_Old Activity Name 181221: Initial Project Funding Release
- S100200: BNL_UDF_Old Activity Name 181221: Prepare for CD-1 Review
- S101008: BNL_UDF_Old Activity Name 181221: FY18 funding available
- S100300: BNL_UDF_Old Activity Name 181221: Prototype 2018 Spending Authorization
- S100340: BNL_UDF_Old Activity Name 181221: BNL Prototype Spending Authorization
- S100400: BNL_UDF_Old Activity Name 181221: CD-1 Review
- S100700: BNL_UDF_Old Activity Name 181221: Start CD-2/3 Review preparation
- S100500: BNL_UDF_Old Activity Name 181221: Approve Cost Range and Long lead Procurement CD-1/3A
- S100750: BNL_UDF_Old Activity Name 181221: Prepare for CD-2/3 Review
- S101009: BNL_UDF_Old Activity Name 181221: FY19 funding available
- S100600: BNL_UDF_Old Activity Name 181221: CD-3A Budget Appropriation
- S100800: BNL_UDF_Old Activity Name 181221: CD-2/3 Review
- S100900: BNL_UDF_Old Activity Name 181221: Transition to CD2/3
- S101000: BNL_UDF_Old Activity Name 181221: Approve Project Baseline and Construction CD2/CD3
- S101010: BNL_UDF_Old Activity Name 181221: FY20 funding available
- S101012: BNL_UDF_Old Activity Name 181221: IR Ready for Prep
- S101015: BNL_UDF_Old Activity Name 181221: FY21 funding available
- S101016: BNL_UDF_Old Activity Name 181221: FY22 funding available
- S101020: BNL_UDF_Old Activity Name 181221: Internal Project Float
- S101022: BNL_UDF_Old Activity Name 181221: Early Project Completion
- S101030: BNL_UDF_Old Activity Name 181221: Schedule Contingency
- S101040: BNL_UDF_Old Activity Name 181221: Approve Project Closeout CD-4

| ID | WBS | Activity | Duration | Start | Finish | Predecessors | Complete | Remaining | Planned start | Planned finish | Total float | Free float | Constraint | Expected finish | Resources | Cost | BNL_UDF_Temp Text 01 | BNL_UDF_Percent Complete | BNL_UDF_Sort Order | BNL_UDF_OPC TEC (deprecated) | BNL_UDF_Old Activity Name 181221 | BNL_UDF_Old Activity ID 181221 | RG Check | BNL_Activity Status | BNL_Estimator | BNL_Location | BNL_EDIA | BNL_CAM | BNL_Institution | BNL_R&D FY18-19 | BNL_WBS | BNL_FY | BNL_Management or Mgmt Travel | BNL_WBS_Hierarchical | Completed | Cost = Awarded Proc or Mgmt | BNL_UDF_Adhoc Comments | BNL_UDF_Temp Date 01 | BNL_Cost Basis | BNL_OPC TEC (deprecated) | BNL_EVT | BNL_UDF_Status Comments | BNL_Fund Source | BNL_Account Number | BNL_PCR ID | Temp | BNL_UDF_Temp Text 02 | BNL_Cobra WP | BNL_Master Control Account | BNL_Cobra Control Account | Indicator - Procurement | Indicator - Float | BNL_UDF_Remaining Tot Cost | BNL_UDF_Percent_remaining |
| --- | --- | --- | --- | --- | --- | --- | --- | --- | --- | --- | --- | --- | --- | --- | --- | --- | --- | --- | --- | --- | --- | --- | --- | --- | --- | --- | --- | --- | --- | --- | --- | --- | --- | --- | --- | --- | --- | --- | --- | --- | --- | --- | --- | --- | --- | --- | --- | --- | --- | --- | --- | --- | --- | --- |
|  | 02 | **Labor by FY** |  | 2017-02-01 | 2022-01-05 |  |  |  |  |  |  |  |  |  |  |  |  |  |  |  |  |  |  |  |  |  |  |  |  |  |  |  |  |  |  |  |  |  |  |  |  |  |  |  |  |  |  |  |  |  |  |  |  |  |
| S102700 |  | Mgmt labor FY17 | 169d | 2017-02-01 A | 2017-09-29 A | S100090 SS | 100% |  |  |  |  |  |  |  |  |  | 01 | 100 | 1000 | S101100 | Mgmt labor FY17 | S101100 | NOCA | Completed | O'Brien, Ed | BNL | Management | Irina Sourikova | BNL | Mgmt R&D FY18 | POM02.1.01.02 | 2017 | Yes | 02 | yes | Yes |  |  |  |  |  |  |  |  |  |  |  |  |  |  |  |  |  |  |
| S102800 |  | Mgmt labor - A - MIE - FY18 | 249d | 2017-10-02 A | 2018-09-28 A | S102700 | 100% |  |  |  |  |  |  |  |  |  | 02 | 100 | 1000 | S101200 | Mgmt labor - A - MIE - FY18 | S101200 | NOCA | Completed | O'Brien, Ed | BNL | Management | Irina Sourikova | BNL | Mgmt R&D FY18 | POM02.1.01.02 | 2018 | Yes | 02 | yes | Yes | 180416 RFG Cost Basis Code was L1 | 2018-09-28 | L2 | OPC | A |  |  |  |  |  |  |  |  |  |  |  |  |  |
| S103600 |  | Mgmt labor - B - BNL Contributed Labor - FY18 | 249d | 2017-10-02 A | 2018-09-28 A | S102700 | 100% |  |  |  |  |  |  |  |  |  | 02 | 100 | 1000 | S101200 | Mgmt labor - B - BNL Contributed Labor - FY18 | S342820 | NOCA | Completed | O'Brien, Ed | BNL | Management | Irina Sourikova | BNL | Mgmt R&D FY18 | POM02.1.01.02 | 2018 | Yes | 02 | yes | Yes | 180416 RFG Cost Basis Code was L1 | 2018-09-28 | L2 | null | A |  |  |  |  |  |  |  |  |  |  |  |  |  |
| S102900 |  | Mgmt labor - A - MIE, Phase 1 - FY19 | 166d | 2018-10-01 A | 2019-05-31 A | S102800, S102400 | 100% |  |  |  |  |  |  |  |  |  | 03 | 8 | 1100 | S101300 | Mgmt labor - A - MIE - FY19 | S101300 | NOCA | Completed | O'Brien, Ed | BNL | Management | Irina Sourikova | BNL | Mgmt FY18 | POM02.1.01.02 | 2019 | Yes | 02 |  | Yes | 180416 RFG Cost Basis Code was L1 | 2019-09-30 | L2 | OPC | A | 190417 ELM name | A-OPC | 16700 | 004 |  |  |  |  |  |  |  |  |  |
| S102910 |  | Mgmt labor - A - MIE, Phase 2 - FY19 | 166d | 2018-10-01 A | 2019-05-31 A | S102800, S102400 | 100% |  |  |  |  |  |  |  |  |  | 03 | 8 | 1100 | S101300 | Mgmt labor - A - MIE - FY19 | S101300 | NOCA | Completed | O'Brien, Ed | BNL | Management | Irina Sourikova | BNL | Mgmt FY18 | POM02.1.01.02 | 2019 | Yes | 02 |  | Yes | 180416 RFG Cost Basis Code was L1 | 2019-09-30 | L2 | OPC | A | 190417 ELM name | A-TEC | 59700 | 004 |  |  |  |  |  |  |  |  |  |
| S103700 |  | Mgmt labor - B - BNL Contributed Labor - FY19 - Physics Resource(s) | 166d | 2018-10-01 A | 2019-05-31 A | S103600, S102610 | 100% |  |  |  |  |  |  |  |  |  | PO&AD | 0 | 1100 | S101300 | Mgmt labor - B - BNL Contributed Labor - FY19 | S342860 | NOCA | Completed | O'Brien, Ed | BNL | Management | Irina Sourikova | BNL | Mgmt FY18 | POM02.1.01.02 | 2019 | Yes | 02 |  | Yes | 180416 RFG Cost Basis Code was L1 | 2019-09-30 | L2 | null | A |  | B | 16708 |  | PO |  |  |  |  |  |  |  |  |
| S103710 |  | Mgmt labor - B - BNL Contributed Labor - FY19 - CA-D Resource(s) | 166d | 2018-10-01 A | 2019-05-31 A | S102610 | 100% |  |  |  |  |  |  |  |  |  | PO&ADS103710 | 0 | 1100 | S101300 | Mgmt labor - B - BNL Contributed Labor - FY19 | S342860 | NOCA | Completed | O'Brien, Ed | BNL | Management | Irina Sourikova | BNL | Mgmt FY18 | POM02.1.01.02 | 2019 | Yes | 02 |  | Yes | 180416 RFG Cost Basis Code was L1 | 2019-09-30 | L2 | null | A |  | B | 16708 |  | C-AD | S103710 |  |  |  |  |  |  |  |
| S102905 |  | Mgmt labor - A - MIE, Phase 1 - FY19 split | 84d | 2019-06-03 A | 2019-09-30 A | S102900 | 100% |  |  |  |  |  |  |  | Project Mgmt Specialist - Purchased Services [464 h] | 71,048.15 | 03 | 8 | 1100 | S101300 | Mgmt labor - A - MIE - FY19 | S101300 | CA | Completed | O'Brien, Ed | BNL | Management | Irina Sourikova | BNL | Mgmt FY18 | POM02.1.01.02 | 2019 | Yes | 02 |  | Yes | 180416 RFG Cost Basis Code was L1 | 2019-09-30 | L2 | OPC | A | 190417 ELM name | A-OPC | 16700 | 004 |  |  | S102905 | 1.01 | 1.01A |  |  |  |  |
| S102915 |  | Mgmt labor - A - MIE, Phase 2 - FY19 split | 84d | 2019-06-03 A | 2019-09-30 A | S102910 | 100% |  |  |  |  |  |  |  | Project Mgmt Specialist - Purchased Services [285 h] | 43,639.49 | 03 | 8 | 1100 | S101300 | Mgmt labor - A - MIE - FY19 | S101300 | CA | Completed | O'Brien, Ed | BNL | Management | Irina Sourikova | BNL | Mgmt FY18 | POM02.1.01.02 | 2019 | Yes | 02 |  | Yes | 180416 RFG Cost Basis Code was L1 | 2019-09-30 | L2 | OPC | A | 190417 ELM name | A-TEC | 59700 | 004 |  |  | S102915 | 1.01 | 1.01A |  |  |  |  |
| S103705 |  | Mgmt labor - B - BNL Contributed Labor - FY19 - Physics Resource(s) Split | 83d | 2019-06-03 A | 2019-09-30 A | S103700 | 100% |  | 2019-06-03 | 2019-09-27 |  |  |  |  | ADMIN1 PO [143 h]; ADMIN7 PO [542 h]; PROF2 PO PC [548 h]; PROF4 PO M [34 h]; PROF5 PO M [157 h]; SCI 4 PO [996 h]; SCI2 PO [637 h] | 503,203.51 | PO&AD | 0 | 1100 | S101300 | Mgmt labor - B - BNL Contributed Labor - FY19 | S342860 | CA | Completed | O'Brien, Ed | BNL | Management | Irina Sourikova | BNL | Mgmt FY18 | POM02.1.01.02 | 2019 | Yes | 02 |  | Yes | 180416 RFG Cost Basis Code was L1 | 2019-09-30 | L2 | null | A |  | B | 16708 |  | PO |  | S103705 | 1.01 | 1.01B |  |  |  |  |
| S103715 |  | Mgmt labor - B - BNL Contributed Labor - FY19 - CA-D Resource(s) Split | 83d | 2019-06-03 A | 2019-09-30 A | S103710 | 100% |  | 2019-06-03 | 2019-09-27 |  |  |  |  | PROF5 AD [296 h] | 48,872.5 | PO&ADS103710 | 0 | 1100 | S101300 | Mgmt labor - B - BNL Contributed Labor - FY19 | S342860 | CA | Completed | O'Brien, Ed | BNL | Management | Irina Sourikova | BNL | Mgmt FY18 | POM02.1.01.02 | 2019 | Yes | 02 |  | Yes | 180416 RFG Cost Basis Code was L1 | 2019-09-30 | L2 | null | A |  | B | 16708 |  | C-AD | S103710 | S103715 | 1.01 | 1.01B |  |  |  |  |
| S103000 |  | Mgmt Labor - A - MIE - FY20 | 251d | 2019-10-01 A | 2020-09-30 A | S102905, S102915 | 100% |  |  |  |  |  |  |  | Project Mgmt Specialist - Purchased Services [1559 h] | 245,877.14 | 04 | 0 |  | S101400 | Mgmt labor FY20 | S101400 | CA | In Progress | O'Brien, Ed | BNL | Management | Irina Sourikova | BNL |  | POM02.1.01.02 | 2020 | Yes | 02 |  | Yes | 180416 RFG Cost Basis Code was L1 |  | L2 | TEC | A | 190320 ELM UPT per CL | A-TEC | 59700 | 003 |  |  | S103000 | 1.01 | 1.01A |  |  |  |  |
| S103100 |  | Mgmt labor - B - BNL Contributed Labor - FY20 - Physics Resource(s) | 251d | 2019-10-01 A | 2020-09-30 A | S103705 | 100% |  |  |  |  |  |  |  | SCI 4 PO [2965 h]; PROF4 PO M [100.6 h]; PROF5 PO M [469.87 h]; SCI2 PO [1896 h]; PROF2 PO PC [1638.53 h]; ADMIN1 PO [427.7 h]; ADMIN7 PO [1619.25 h] | 1,545,367.67 | PO&AD | 0 |  | S101300 | Mgmt labor - B - BNL Contributed Labor - FY19 | S342860 | CA | In Progress | O'Brien, Ed | BNL | Management | Irina Sourikova | BNL | Mgmt FY18 | POM02.1.01.02 | 2019 | Yes | 02 |  | Yes | 180416 RFG Cost Basis Code was L1 | 2019-09-30 | L2 | null | A |  | B | 16708 |  | PO |  | S103100 | 1.01 | 1.01B |  |  |  |  |
| S103110 |  | Mgmt labor - B - BNL Contributed Labor - FY20 - CA-D Resource(s) | 251d | 2019-10-01 A | 2020-09-30 A | S103715 | 100% |  |  |  |  |  |  |  | PROF5 AD [883.52 h] | 150,254.13 | PO&ADS103110 | 0 |  | S101300 | Mgmt labor - B - BNL Contributed Labor - FY19 | S342860 | CA | In Progress | O'Brien, Ed | BNL | Management | Irina Sourikova | BNL | Mgmt FY18 | POM02.1.01.02 | 2020 | Yes | 02 |  | Yes | 180416 RFG Cost Basis Code was L1 | 2019-09-30 | L2 | null | A |  | B | 16708 |  | C-AD | S103110 | S103110 | 1.01 | 1.01B |  |  |  |  |
| S103200 |  | Mgmt Labor - A - MIE - FY21 | 250d | 2020-10-01 A | 2021-09-30 | S103000 | 66% | 86d |  |  | 0d |  | finish on 2021-09-30 | 2021-09-30 | Project Mgmt Specialist - Purchased Services [1050 h] | 170,568.39 | 05 | 0 |  | S101500 | Mgmt labor FY21 | S101500 | CA | Not Started | O'Brien, Ed | BNL | Management | Irina Sourikova | BNL |  | POM02.1.01.02 | 2021 | Yes | 02 |  | Yes | 180416 RFG Cost Basis Code was L1 |  | L2 | TEC | A | 190320 ELM UPT per CL | A-TEC | 59700 | 003 |  |  | S103200 | 1.01 | 1.01A |  |  |  |  |
| S103300 |  | Mgmt labor - B - BNL Contributed Labor - FY21 - Physics Resource(s) | 249d | 2020-10-01 A | 2021-09-30 | S103100 | 65% | 86d | 2020-10-01 | 2021-09-29 | 0d |  | finish on 2021-09-30 | 2021-09-30 | SCI 4 PO [2965 h]; SCI2 PO [1896 h]; PROF4 PO M [100.2 h]; PROF5 PO M [468 h]; PROF2 PO PC [1632 h]; ADMIN1 PO [426 h]; ADMIN7 PO [1612.8 h] | 1,589,055.94 | PO&AD | 0 |  | S101300 | Mgmt labor - B - BNL Contributed Labor - FY19 | S342860 | CA | Not Started | O'Brien, Ed | BNL | Management | Irina Sourikova | BNL | Mgmt FY18 | POM02.1.01.02 | 2019 | Yes | 02 |  | Yes | 180416 RFG Cost Basis Code was L1 | 2019-09-30 | L2 | null | A |  | B | 16708 |  | PO |  | S103300 | 1.01 | 1.01B |  |  |  |  |
| S103310 |  | Mgmt labor - B - BNL Contributed Labor - FY21 - CA-D Resource(s) | 249d | 2020-10-01 A | 2021-09-30 | S103110 | 65% | 86d | 2020-10-01 | 2021-09-29 | 0d |  | finish on 2021-09-30 | 2021-09-30 | PROF5 AD [880 h] | 154,145.17 | PO&ADS103310 | 0 |  | S101300 | Mgmt labor - B - BNL Contributed Labor - FY19 | S342860 | CA | Not Started | O'Brien, Ed | BNL | Management | Irina Sourikova | BNL | Mgmt FY18 | POM02.1.01.02 | 2021 | Yes | 02 |  | Yes | 180416 RFG Cost Basis Code was L1 | 2019-09-30 | L2 | null | A |  | B | 16708 |  | C-AD | S103310 | S103310 | 1.01 | 1.01B |  |  |  |  |
| S103400 |  | Mgmt labor - A - MIE - FY22 | 63d | 2021-10-01 | 2022-01-05 | S101016 SS, S103200 |  |  |  |  | 0d | 21d | start on 2021-10-01 |  | Project Mgmt Specialist - Purchased Services [67.9 h] | 11,360.99 | 05 | 0 |  | S101500 | Mgmt labor FY22 | S101550 | CA | Not Started | O'Brien, Ed | BNL | Management | Irina Sourikova | BNL | Rich | POM02.1.01.02 | 2022 | Yes | 02 |  | Yes | 180416 RFG New Activity |  | L2 | TEC | A | 190330 ELM dur; 190320 ELM UPT per CL | A-TEC | 59700 | 003,004 |  |  | S103400 | 1.01 | 1.01A |  |  |  |  |
| S103500 |  | Mgmt labor - B - BNL Contributed Labor - FY22 - Physics Resource(s) | 63d | 2021-10-01 | 2022-01-05 | S101016 SS, S103300 |  |  |  |  | 0d | 21d | start on 2021-10-01 |  | PROF4 PO M [4.01 h]; PROF5 PO M [18.72 h]; SCI2 PO [75 h]; PROF2 PO PC [65.28 h]; ADMIN1 PO [17.04 h]; ADMIN7 PO [64.51 h]; SCI 4 PO [118 h] | 65,204.69 | PO&AD | 0 |  | S101300 | Mgmt labor - B - BNL Contributed Labor - FY19 | S342860 | CA | Not Started | O'Brien, Ed | BNL | Management | Irina Sourikova | BNL | Mgmt FY18 | POM02.1.01.02 | 2019 | Yes | 02 |  | Yes | 180416 RFG Cost Basis Code was L1 |  | L2 | null | A |  | B | 16708 |  | PO |  | S103500 | 1.01 | 1.01B |  |  |  |  |
| S103510 |  | Mgmt labor - B - BNL Contributed Labor - FY22 - CA-D Resource(s) | 63d | 2021-10-01 | 2022-01-05 | S101016 SS, S103310 |  |  |  |  | 0d | 21d | start on 2021-10-01 |  | PROF5 AD [35.2 h] | 6,350.78 | PO&ADS103510 | 0 |  | S101300 | Mgmt labor - B - BNL Contributed Labor - FY19 | S342860 | CA | Not Started | O'Brien, Ed | BNL | Management | Irina Sourikova | BNL | Mgmt FY18 | POM02.1.01.02 | 2022 | Yes | 02 |  | Yes | 180416 RFG Cost Basis Code was L1 |  | L2 | null | A | 190330 ELM dur | B | 16708 | 004 | C-AD | S103510 | S103510 | 1.01 | 1.01B |  |  |  |  |
|  | 03 | **Management Travel** |  | 2017-02-01 | 2021-09-30 |  |  |  |  |  |  |  |  |  |  |  |  |  |  |  |  |  |  |  |  |  |  |  |  |  |  |  |  |  |  |  |  |  |  |  |  |  |  |  |  |  |  |  |  |  |  |  |  |  |
| S103800 |  | Travel FY17 | 169d | 2017-02-01 A | 2017-09-29 A | S100090 SS | 100% |  |  |  |  |  |  |  |  |  | S103800 | 100 |  | S101700 | Travel FY17 | S101700 | NOCA | Completed | O'Brien, Ed | BNL | Management | Irina Sourikova | BNL |  | POM02.1.01.03 |  | Yes | 03 | yes | Yes |  |  |  |  |  |  |  |  |  |  |  |  |  |  |  |  |  |  |
| S103900 |  | Travel FY18 | 250d | 2017-10-02 A | 2018-10-01 A | S103800 | 100% |  |  |  |  |  |  |  |  |  | S103900 | 100 |  | S101800 | Travel FY18 | S101800 | NOCA | Completed | O'Brien, Ed | BNL | Management | Irina Sourikova | BNL |  | POM02.1.01.03 |  | Yes | 03 | yes | Yes | 180416 RFG Cost Basis Code was L1 |  | M2 | OPC | A | 190315 DurType to align with EVT |  |  | 003 |  |  |  |  |  |  |  |  |  |
| S104000 |  | Travel FY19 | 166d | 2018-10-01 A | 2019-05-31 A | S103900, S102500 | 100% |  |  |  |  |  |  |  |  |  | S104000 | 25 |  | S101900 | Travel FY19 | S101900 | NOCA | Completed | O'Brien, Ed | BNL | Management | Irina Sourikova | BNL |  | POM02.1.01.03 |  | Yes | 03 |  | Yes | 180416 RFG Cost Basis Code was L1 | 2019-09-30 | M2 | OPC | C |  | A-OPC | 16700 |  |  |  |  |  |  |  |  |  |  |
| S104010 |  | Travel FY19 Split | 84d | 2019-06-03 A | 2019-09-30 A | S104000 | 100% |  |  |  |  |  |  |  | Travel Cost [6720 h] | 8,837.55 | S104000 | 25 |  | S101900 | Travel FY19 | S101900 | CA | Completed | O'Brien, Ed | BNL | Management | Irina Sourikova | BNL |  | POM02.1.01.03 |  | Yes | 03 |  | Yes | 180416 RFG Cost Basis Code was L1 | 2019-09-30 | M2 | OPC | C |  | A-OPC | 16700 |  |  |  | S104010 | 1.01 | 1.01A | UDF_G3 |  |  |  |
| S104100 |  | Travel FY20 | 251d | 2019-10-01 A | 2020-09-30 A | S102605, S104010 | 100% |  |  |  |  |  |  |  | Travel Cost [20000 h] | 27,080.2 | S104100 | 0 |  | S102000 | Travel FY20 | S102000 | CA | In Progress | O'Brien, Ed | BNL | Management | Irina Sourikova | BNL |  | POM02.1.01.03 |  | Yes | 03 |  | Yes | 180416 RFG Cost Basis Code was L1 |  | M2 | TEC | C |  | A-TEC | 59700 |  |  |  | S104100 | 1.01 | 1.01A | UDF_G3 | UDF_G1 | 11436.2597609562 | 0.422310757 |
| S104200 |  | Travel FY21 | 250d | 2020-10-01 A | 2021-09-30 | S104100, S102606 | 66% | 86d |  |  | 84d | 0d |  | 2021-09-30 | Travel Cost [5000 h] | 6,905.45 | S104200 | 0 |  | S102100 | Travel FY21 | S102100 | CA | Not Started | O'Brien, Ed | BNL | Management | Irina Sourikova | BNL |  | POM02.1.01.03 |  | Yes | 03 |  | Yes | 180416 RFG Cost Basis Code was L1 |  | M2 | TEC | A |  | A-TEC | 59700 |  |  |  | S104200 | 1.01 | 1.01A | UDF_G3 | UDF_G1 | 6905.45 | 1 |

| ID | WBS | Activity | Type | Duration | Start | Finish | Predecessors | Complete | Planned start | Planned finish | Constraint | Resources | Cost | BNL_UDF_Status Comments | BNL_UDF_Temp Text 01 | BNL_UDF_Percent Complete | BNL_UDF_Old Activity Name 181221 | BNL_UDF_Old Activity ID 181221 | BNL_Cobra WP | RG Check | BNL_Activity Status | BNL_Fund Source | BNL_Estimator | BNL_Cost Basis | BNL_EDIA | BNL_CAM | BNL_OPC TEC (deprecated) | BNL_WBS | BNL_Actuals | BNL_FY | BNL_EVT | BNL_Master Control Account | BNL_Account Number | BNL_PCR ID | BNL_Cobra Control Account | BNL_WBS_Hierarchical | Completed | PMP Summary Part1 | PMP Summary Part2 | Indicator - Procurement | BNL_UDF_OPC TEC (deprecated) | BNL_Location | BNL_Institution | BNL_R&D FY18-19 | BNL_UDF_Adhoc Comments | BNL_UDF_Temp Date 01 | BNL_DOE OPC | BNL_Split Activity | BNL_Proc Sig Phase | BNL_Proc Sig | Cost = Awarded Proc or Mgmt | BNL_Milestone Level | BNL_Obligation | Additional EVT documentation required | Indicator - Float | BNL_UDF_Remaining Tot Cost | BNL_UDF_Percent_remaining | SPH Proc Register |
| --- | --- | --- | --- | --- | --- | --- | --- | --- | --- | --- | --- | --- | --- | --- | --- | --- | --- | --- | --- | --- | --- | --- | --- | --- | --- | --- | --- | --- | --- | --- | --- | --- | --- | --- | --- | --- | --- | --- | --- | --- | --- | --- | --- | --- | --- | --- | --- | --- | --- | --- | --- | --- | --- | --- | --- | --- | --- | --- |
|  | 02 | **TPC** |  |  | 2017-02-01 | 2022-02-02 |  |  |  |  |  |  |  |  |  |  |  |  |  |  |  |  |  |  |  |  |  |  |  |  |  |  |  |  |  |  |  |  |  |  |  |  |  |  |  |  |  |  |  |  |  |  |  |  |  |  |  |  |
| S104400 |  | Actuals - Labor - sPHENIX TPC FY17 |  | 169d | 2017-02-01 A | 2017-09-29 A | S100090 SS | 100% |  |  |  | Actual Labor [1405.35 h] | 234,824 | 190315 DurType to align with EVT | S104400 | 100 | Actuals - Labor - sPHENIX TPC FY17 | S338780 | S104400 | CA | Completed | B | Hemmick,Tom | L1 | Design | Tom Hemmick | null | POM02.1.02 | Yes | 2017 | A | 1.02 | 16709 | 003 | 1.02B | 02 | yes | 1 | 1 |  |  |  |  |  |  |  |  |  |  |  |  |  |  |  |  |  |  |  |
| S104600 |  | Actuals - Nonlabor - sPHENIX TPC FY17 |  | 169d | 2017-02-01 A | 2017-09-29 A | S100090 SS | 100% |  |  |  | Actual Nonlabor [18788.8 h] | 20,960.99 | 190315 DurType to align with EVT | S104600 | 100 | Actuals - Nonlabor - sPHENIX TPC FY17 | S342900 | S104600 | CA | Completed | A-OPC | Hemmick,Tom | M1 | Design | Tom Hemmick | OPC | POM02.1.02 | Yes | 2017 | A | 1.02 | 16701 | 003 | 1.02A | 02 | yes | 1 | 1 | UDF_G3 |  |  |  |  |  |  |  |  |  |  |  |  |  |  |  |  |  |  |
| S104500 |  | Actuals - Labor - sPHENIX TPC FY18 |  | 249d | 2017-10-02 A | 2018-09-28 A | S104400 | 100% |  |  |  | Actual Labor [4287.87 h] | 716,472.6 | 190315 DurType to align with EVT | S104500 | 100 | Actuals - Labor - sPHENIX TPC FY18 | S339100 | S104500 | CA | Completed | B | Hemmick,Tom | L1 | Design | Tom Hemmick | null | POM02.1.02 | Yes | 2018 | A | 1.02 | 16709 | 003 | 1.02B | 02 | yes | 1 | 1 |  |  |  |  |  |  |  |  |  |  |  |  |  |  |  |  |  |  |  |
| S104700 |  | Actuals - Nonlabor - sPHENIX TPC FY18 |  | 249d | 2017-10-02 A | 2018-09-28 A | S104600 | 100% |  |  |  | Actual Nonlabor |  | 190315 DurType to align with EVT | S104700 | 100 | Actuals - Nonlabor - sPHENIX TPC FY18 | S342940 |  | NOCA | Completed | A-OPC | Hemmick,Tom | M1 | Design | Tom Hemmick | OPC | POM02.1.02 | Yes | 2018 | A |  | 16701 | 003 |  | 02 | yes | 1 | 1 |  |  |  |  |  |  |  |  |  |  |  |  |  |  |  |  |  |  |  |
| S104710 |  | Actuals - Nonlabor - sPHENIX TPC FY18 |  | 249d | 2017-10-02 A | 2018-09-28 A | S104700 | 100% |  |  |  | Actual Nonlabor [246200 h] | 274,664.36 | 190315 DurType to align with EVT | S104700 | 100 | Actuals - Nonlabor - sPHENIX TPC FY18 | S342940 | S104710 | CA | Completed | A-OPC | Hemmick,Tom | M1 | Design | Tom Hemmick | OPC | POM02.1.02 | Yes | 2018 | A | 1.02 | 16701 | 003 | 1.02A | 02 | yes | 1 | 1 | UDF_G3 |  |  |  |  |  |  |  |  |  |  |  |  |  |  |  |  |  |  |
| S1000759 |  | Actuals - NonLabor - sPHENIX TPC FY19M8 |  | 166d | 2018-10-01 A | 2019-05-31 A | S104500 | 100% |  |  |  | Actual Nonlabor [390830 h] | 431,189.26 | 190315 DurType to align with EVT | S104500 | 100 | Actuals - Labor - sPHENIX TPC FY18 | S339100 | S1000759 | CA | Completed | A-OPC | Hemmick,Tom | L1 | Design | Tom Hemmick | null | POM02.1.02 | Yes | 2019 | A | 1.02 | 16701 | 003 | 1.02A | 02 | yes | 1 | 1 | UDF_G3 |  |  |  |  |  |  |  |  |  |  |  |  |  |  |  |  |  |  |
| S1000799 |  | Actuals - NonLabor - sPHENIX TPC FY19M8 |  | 166d | 2018-10-01 A | 2019-05-31 A | S104500 | 100% |  |  |  | Actual Nonlabor [140825 h] | 155,367 | 190315 DurType to align with EVT | S104500 | 100 | Actuals - Labor - sPHENIX TPC FY18 | S339100 | S1000799 | CA | Completed | B | Hemmick,Tom | L1 | Design | Tom Hemmick | null | POM02.1.02 | Yes | 2019 | A | 1.02 | 16709 | 003 | 1.02B | 02 | yes | 1 | 1 | UDF_G3 |  |  |  |  |  |  |  |  |  |  |  |  |  |  |  |  |  |  |
| S104510 |  | Actuals - Labor - sPHENIX TPC FY19M8 |  | 166d | 2018-10-01 A | 2019-05-31 A | S104500 | 100% |  |  |  | Actual Labor [2218.18 h] | 370,642.11 | 190315 DurType to align with EVT | S104500 | 100 | Actuals - Labor - sPHENIX TPC FY18 | S339100 | S104510 | CA | Completed | B | Hemmick,Tom | L1 | Design | Tom Hemmick | null | POM02.1.02 | Yes | 2019 | A | 1.02 | 16709 | 003 | 1.02B | 02 | yes | 1 | 1 |  |  |  |  |  |  |  |  |  |  |  |  |  |  |  |  |  |  |  |
|  | 01 | **TPC Mechanics** |  |  | 2017-02-01 | 2022-01-31 |  |  |  |  |  |  |  |  |  |  |  |  |  |  |  |  |  |  |  |  |  |  |  |  |  |  |  |  |  |  |  |  |  |  |  |  |  |  |  |  |  |  |  |  |  |  |  |  |  |  |  |  |
|  | 01 | **TPC v1 Field Cage Prototype** |  |  | 2017-02-01 | 2021-05-28 |  |  |  |  |  |  |  |  |  |  |  |  |  |  |  |  |  |  |  |  |  |  |  |  |  |  |  |  |  |  |  |  |  |  |  |  |  |  |  |  |  |  |  |  |  |  |  |  |  |  |  |  |
| S104800 |  | Produce TPC v1 Field Cage Prototype Conceptual Design |  | 2d | 2017-02-01 A | 2017-02-02 A | S100090 SS | 100% |  |  |  |  |  |  | S104800 | 100 | Produce TPC v1 Field Cage Prototype Conceptual Design | S102200 |  | NOCA | Completed |  | Hemmick,Tom |  | Design | Tom Hemmick |  | POM02.1.02.01.01 |  |  |  |  |  |  |  | 01 | yes | 1 | 1 |  | S102200 | SBU | SBU | TPC v1 FCage |  |  |  |  |  |  |  |  |  |  |  |  |  |  |
| S104900 |  | Produce TPC v1 Mandrel Conceptual Design |  | 2d | 2017-02-01 A | 2017-02-02 A | S100090 SS | 100% |  |  |  |  |  |  | S104900 | 100 | Produce TPC v1 Mandrel Conceptual Design | S102300 |  | NOCA | Completed |  | Hemmick,Tom |  | Design | Tom Hemmick |  | POM02.1.02.01.01 |  |  |  |  |  |  |  | 01 | yes | 1 | 1 |  | S102300 | SBU | SBU | TPC v1 FCage |  |  |  |  |  |  |  |  |  |  |  |  |  |  |
| S105000 |  | Procure TPC v1 Mandrel Parts Labor |  | 2d | 2017-02-01 A | 2017-02-02 A | S100090 SS | 100% |  |  |  |  |  |  | S105000 | 100 | Procure TPC v1 Mandrel Parts Labor | S102400 |  | NOCA | Completed |  | Hemmick,Tom |  | Procurement | Tom Hemmick |  | POM02.1.02.01.01 |  |  |  |  |  |  |  | 01 | yes | 01 | 2 |  | S102400 | SBU | SBU | TPC v1 FCage |  |  |  |  |  |  |  |  |  |  |  |  |  |  |
| S105100 |  | Assemble TPC v1 Mandrel |  | 2d | 2017-02-01 A | 2017-02-02 A | S100090 SS | 100% |  |  |  |  |  |  | S105100 | 100 | Assemble TPC v1 Mandrel | S102500 |  | NOCA | Completed |  | Hemmick,Tom |  | Fab & Assy | Tom Hemmick |  | POM02.1.02.01.01 |  |  |  |  |  |  |  | 01 | yes | 01 | 4 |  | S102500 | SBU | SBU | TPC v1 FCage |  |  |  |  |  |  |  |  |  |  |  |  |  |  |
| S105200 |  | Procure TPC v1 Mandrel Parts M&S |  | 2d | 2017-02-01 A | 2017-02-02 A | S100090 SS | 100% |  |  |  |  |  |  | S105200 | 100 | Procure TPC v1 Mandrel Parts M&S | S102600 |  | NOCA | Completed |  | Hemmick,Tom |  | Fab & Assy | Tom Hemmick |  | POM02.1.02.01.01 |  |  |  |  |  |  |  | 01 | yes | 01 | 4 |  | S102600 | SBU | SBU | TPC v1 FCage |  |  |  |  |  |  |  |  |  |  |  |  |  |  |
| S105300 |  | Produce TPC v1 Outer Field Cage Conceptual Design |  | 2d | 2017-02-01 A | 2017-02-02 A | S100090 SS | 100% |  |  |  |  |  |  | S105300 | 100 | Produce TPC v1 Outer Field Cage Conceptual Design | S102700 |  | NOCA | Completed |  | Hemmick,Tom |  | Design | Tom Hemmick |  | POM02.1.02.01.01 |  |  |  |  |  |  |  | 01 | yes | 1 | 1 |  | S102700 | SBU | SBU | TPC v1 FCage |  |  |  |  |  |  |  |  |  |  |  |  |  |  |
| S105400 |  | Procure TPC v1 Outer Field Cage Parts Labor |  | 168d | 2017-02-01 A | 2017-09-28 A | S100090 SS | 100% |  |  |  |  |  |  | S105400 | 100 | Procure TPC v1 Outer Field Cage Parts Labor | S102800 |  | NOCA | Completed |  | Hemmick,Tom |  | Procurement | Tom Hemmick |  | POM02.1.02.01.01 |  |  |  |  |  |  |  | 01 | yes | 01 | 2 |  | S102800 | SBU | SBU | TPC v1 FCage |  |  |  |  |  |  |  |  |  |  |  |  |  |  |
| S105700 |  | Procure TPC v1 Outer Field Cage Parts M&S |  | 168d | 2017-02-01 A | 2017-09-28 A | S100090 SS | 100% |  |  |  |  |  |  | S105700 | 100 | Procure TPC v1 Outer Field Cage Parts M&S | S103000 |  | NOCA | Completed |  | Hemmick,Tom |  | Fab & Assy | Tom Hemmick |  | POM02.1.02.01.01 |  |  |  |  |  |  |  | 01 | yes | 01 | 4 |  | S103000 | SBU | SBU | TPC v1 FCage |  |  |  |  |  |  |  |  |  |  |  |  |  |  |
| S105800 |  | Produce TPC v1 Inner Field Cage Conceptual Design |  | 2d | 2017-02-01 A | 2017-02-02 A | S100090 SS | 100% |  |  |  |  |  |  | S105800 | 100 | Produce TPC v1 Inner Field Cage Conceptual Design | S103100 |  | NOCA | Completed |  | Hemmick,Tom |  | Design | Tom Hemmick |  | POM02.1.02.01.01 |  |  |  |  |  |  |  | 01 | yes | 1 | 1 |  | S103100 | SBU | SBU | TPC v1 FCage |  |  |  |  |  |  |  |  |  |  |  |  |  |  |
| S105900 |  | Procure TPC v1 Inner Field Cage Parts Labor |  | 168d | 2017-02-01 A | 2017-09-28 A | S100090 SS | 100% |  |  |  |  |  |  | S105900 | 100 | Procure TPC v1 Inner Field Cage Parts Labor | S103200 |  | NOCA | Completed |  | Hemmick,Tom |  | Procurement | Tom Hemmick |  | POM02.1.02.01.01 |  |  |  |  |  |  |  | 01 | yes | 01 | 2 |  | S103200 | SBU | SBU | TPC v1 FCage |  |  |  |  |  |  |  |  |  |  |  |  |  |  |
| S106200 |  | Procure TPC v1 Inner Field Cage Parts M&S |  | 168d | 2017-02-01 A | 2017-09-28 A | S100090 SS | 100% |  |  |  |  |  |  | S106200 | 100 | Procure TPC v1 Inner Field Cage Parts M&S | S103400 |  | NOCA | Completed |  | Hemmick,Tom |  | Fab & Assy | Tom Hemmick |  | POM02.1.02.01.01 |  |  |  |  |  |  |  | 01 | yes | 01 | 4 |  | S103400 | SBU | SBU | TPC v1 FCage |  |  |  |  |  |  |  |  |  |  |  |  |  |  |
| S106300 |  | Design TPC Field Cage Prototype v1 End Rings |  | 4d | 2017-02-01 A | 2017-02-06 A | S100090 SS | 100% |  |  |  |  |  |  | S106300 | 100 | Design TPC Field Cage Prototype v1 End Rings | S103500 |  | NOCA | Completed |  | Hemmick,Tom |  | Design | Tom Hemmick |  | POM02.1.02.01.01 |  |  |  |  |  |  |  | 01 | yes | 1 | 1 |  | S103500 | SBU | SBU | TPC v1 FCage |  |  |  |  |  |  |  |  |  |  |  |  |  |  |
| S106600 |  | Produce TPC v1 End Cap Conceptual Design |  | 150d | 2017-02-01 A | 2017-09-01 A | S100090 SS | 100% |  |  |  |  |  |  | S106600 | 100 | Produce TPC v1 End Cap Conceptual Design | S103800 |  | NOCA | Completed |  | Hemmick,Tom |  | Design | Tom Hemmick |  | POM02.1.02.01.01 |  |  |  |  |  |  |  | 01 | yes | 1 | 1 |  | S103800 | SBU | SBU | TPC v1 FCage |  |  |  |  |  |  |  |  |  |  |  |  |  |  |
| S108000 |  | Produce TPC v1 Central Membrane Conceptual Design |  | 163d | 2017-02-01 A | 2017-09-21 A | S100090 SS | 100% |  |  |  |  |  |  | S108000 | 100 | Produce TPC v1 Central Membrane Conceptual Design | S104400 |  | NOCA | Completed |  | Hemmick,Tom |  | Design | Tom Hemmick |  | POM02.1.02.01.01 |  |  |  |  |  |  |  | 01 | yes | 1 | 1 |  | S104400 | SBU | SBU | TPC v1 FCage |  |  |  |  |  |  |  |  |  |  |  |  |  |  |
| S108300 |  | Design TPC Assembly Fixture |  | 418d | 2017-02-01 A | 2018-09-28 A | S100090 SS | 100% |  |  |  |  |  |  | S108300 | 100 | Design TPC Assembly Fixture | S104600 |  | NOCA | Completed |  | Hemmick,Tom | L5 | Design | Tom Hemmick | null | POM02.1.02.01.01 |  |  | C |  |  |  |  | 01 | yes | 1 | 1 |  | S104600 | SBU | SBU | TPC v1 FCage | 180426 ELM rsrc per EOB | 2018-03-29 |  |  |  |  |  |  |  |  |  |  |  |  |
| S106400 |  | Procure TPC Field Cage Prototype v1 End Rings Labor |  | 40d | 2017-02-07 A | 2017-04-04 A | S106300 | 100% |  |  |  |  |  |  | S106400 | 100 | Procure TPC Field Cage Prototype v1 End Rings Labor | S103600 |  | NOCA | Completed |  | Hemmick,Tom |  | Procurement | Tom Hemmick |  | POM02.1.02.01.01 |  |  |  |  |  |  |  | 01 | yes | 01 | 2 |  | S103600 | SBU | SBU | TPC v1 FCage |  |  |  |  |  |  |  |  |  |  |  |  |  |  |
| S106500 |  | Procure TPC Field Cage Prototype v1 End Rings M&S |  | 40d | 2017-02-07 A | 2017-04-04 A | S106300 | 100% |  |  |  |  |  |  | S106500 | 100 | Procure TPC Field Cage Prototype v1 End Rings M&S | S103700 |  | NOCA | Completed |  | Hemmick,Tom |  | Fab & Assy | Tom Hemmick |  | POM02.1.02.01.01 |  |  |  |  |  |  |  | 01 | yes | 01 | 4 |  | S103700 | SBU | SBU | TPC v1 FCage |  |  |  |  |  |  |  |  |  |  |  |  |  |  |
| S107800 |  | Procure TPC v1 Central Membrane Parts M&S FY18 |  | 267d | 2017-09-22 A | 2018-10-17 A | S108000 | 100% |  |  |  |  |  |  | S107800 | 100 | Procure TPC v1 Central Membrane Parts M&S FY18 | S104300 |  | NOCA | Completed |  | Hemmick,Tom | M5 | Fab & Assy | Tom Hemmick | OPC | POM02.1.02.01.01 |  |  |  |  |  |  |  | 01 | yes | 01 | 4 |  | S104300 | SBU | SBU | TPC v1 FCage |  | 2018-03-09 | OPC000100 | FY18 |  |  |  |  |  |  |  |  |  |  |
| S108100 |  | Procure TPC v1 Central Membrane Parts Labor FY18 |  | 255d | 2017-09-22 A | 2018-09-28 A | S108000 | 100% |  |  |  |  |  |  | S108100 | 100 | Procure TPC v1 Central Membrane Parts Labor FY18 | S104500 |  | NOCA | Completed |  | Hemmick,Tom | L5 | Procurement | Tom Hemmick | null | POM02.1.02.01.01 |  |  |  |  |  |  |  | 01 | yes | 01 | 2 |  | S104500 | SBU | SBU | TPC v1 FCage |  | 2018-03-09 |  | FY18 |  |  |  |  |  |  |  |  |  |  |
| S105500 |  | Assemble TPC v1 Outer Field Cage FY18 |  | 250d | 2017-09-29 A | 2018-09-28 A | S104800, S104900, S105000, S105100, S105300, S105400, S105200, S105700, S113500 FF | 100% |  |  |  |  |  |  | S105500 | 100 | Assemble TPC v1 Outer Field Cage FY18 | S102900 |  | NOCA | Completed |  | Hemmick,Tom | L4 | Fab & Assy | Tom Hemmick | null | POM02.1.02.01.01 |  |  |  |  |  |  |  | 01 | yes | 01 | 4 |  | S102900 | SBU | SBU | TPC v1 FCage |  | 2018-03-16 |  | FY18 |  |  |  |  |  |  |  |  |  |  |
| S106000 |  | Assemble TPC v1 Inner Field Cage FY18 |  | 250d | 2017-09-29 A | 2018-09-28 A | S105800, S105900, S106200, S113500 FF | 100% |  |  |  |  |  |  | S106000 | 100 | Assemble TPC v1 Inner Field Cage FY18 | S103300 |  | NOCA | Completed |  | Hemmick,Tom | L4 | Fab & Assy | Tom Hemmick | null | POM02.1.02.01.01 |  |  |  |  |  |  |  | 01 | yes | 01 | 4 |  | S103300 | SBU | SBU | TPC v1 FCage |  | 2018-02-28 |  | FY18 |  |  |  |  |  |  |  |  |  |  |
| S106700 |  | TPC v1 End Cap Conceptual Design Review |  | 1d | 2018-06-01 A | 2018-06-01 A | S106600 | 100% |  |  |  |  |  |  | S106700 | 100 | TPC v1 End Cap Conceptual Design Review | S103900 |  | NOCA | Completed |  | Hemmick,Tom |  | Management Tech Reviews | Tom Hemmick |  | POM02.1.02.01.01 |  |  |  |  |  |  |  | 01 | yes | 1 | 1 |  | S103900 | SBU | SBU | TPC v1 FCage |  |  |  |  |  |  |  |  |  |  |  |  |  |  |
| S106800 |  | TPC v1 End Cap Production Readiness Review |  | 1d | 2018-06-06 A | 2018-06-06 A | S106700 FS+2d | 100% |  |  |  |  |  |  | S106800 | 100 | TPC v1 End Cap Production Readiness Review | S104000 |  | NOCA | Completed |  | Hemmick,Tom |  | Management Tech Reviews | Tom Hemmick |  | POM02.1.02.01.01 |  |  |  |  |  |  |  | 01 | yes | 1 | 1 |  | S104000 | SBU | SBU | TPC v1 FCage |  |  |  |  |  |  |  |  |  |  |  |  |  |  |
| S106900 |  | Procure TPC v1 End Cap - Provide Requirements to Procurement |  | 5d | 2018-06-07 A | 2018-06-13 A | S106600, S106800 | 100% |  |  |  |  |  |  | S106900 | 100 | Procure TPC v1 End Cap - Provide Requirements to Procurement | S104200 |  | NOCA | Completed |  | Hemmick,Tom | L4 | Procurement | Tom Hemmick | null | POM02.1.02.01.01 |  |  | C |  |  |  |  | 01 | yes | 01 | 2 |  | S104200 | SBU | SBU | TPC v1 FCage |  |  |  |  | PP1 | MP200400 | Yes |  |  |  |  |  |  |  |
| S107000 |  | Procure TPC v1 End Cap - Prepare & Send Solicitation |  | 30d | 2018-06-14 A | 2018-07-26 A | S106900 | 100% |  |  |  |  |  |  | S107000 | 100 | Procure TPC v1 End Cap - Prepare & Send Solicitation | S342160 |  | NOCA | Completed |  | Hemmick,Tom | L4 | Procurement | Tom Hemmick |  | POM02.1.02.01.01 |  |  |  |  |  |  |  | 01 | yes | 01 | 2 |  | S104200 | SBU | SBU | TPC v1 FCage |  |  |  |  | PP2 | MP200400 | Yes |  |  |  |  |  |  |  |
| S107100 |  | Procure TPC v1 End Cap - Vendor Responses |  | 51d | 2018-06-25 A | 2018-09-05 A | S107000 | 100% |  |  |  |  |  |  | S107100 | 100 | Procure TPC v1 End Cap - Vendor Responses | S342200 |  | NOCA | Completed |  | Hemmick,Tom | L4 | Procurement | Tom Hemmick |  | POM02.1.02.01.01 |  |  |  |  |  |  |  | 01 | yes | 01 | 2 |  | S104200 | SBU | SBU | TPC v1 FCage |  |  |  |  | PP3 | MP200400 | Yes |  |  |  |  |  |  |  |
| S107200 |  | Procure TPC v1 End Cap - Vendor Selection |  | 35d | 2018-07-19 A | 2018-09-06 A | S107100 | 100% |  |  |  |  |  |  | S107200 | 100 | Procure TPC v1 End Cap - Vendor Selection | S342240 |  | NOCA | Completed |  | Hemmick,Tom | L4 | Procurement | Tom Hemmick |  | POM02.1.02.01.01 |  |  |  |  |  |  |  | 01 | yes | 01 | 2 |  | S104200 | SBU | SBU | TPC v1 FCage |  |  |  |  | PP4 | MP200400 | Yes |  |  |  |  |  |  |  |
| OBLG107310 |  | Procure TPC v1 End Cap - Obligation Phase 1 |  | 1d | 2018-09-11 A | 2018-09-11 A | S107200 | 100% |  |  |  | Obligation Resource |  |  | S107300 | 100 | Procure TPC v1 End Cap - Contract Award(s) Phase 1 | S342280 |  | NOCA | Completed | A-OPC | Hemmick,Tom | L4 | Procurement | Tom Hemmick |  | POM02.1.02.01.01 |  |  |  |  |  |  |  | 01 | yes | 01 | 2 |  | S104200 | SBU | SBU | TPC v1 FCage |  |  |  |  | PP5 | MP200400 | Yes | L5 | OBLG |  |  |  |  |  |
| OBLG107410 |  | Procure TPC v1 End Cap - Obligation Phase 2 |  | 1d | 2018-09-11 A | 2018-09-11 A | S107200 | 100% |  |  |  | Obligation Resource |  |  | S107400 | 100 | Procure TPC v1 End Cap - Contract Award(s) Phase 2 | S342285 |  | NOCA | Completed | A-OPC | Hemmick,Tom | L4 | Procurement | Tom Hemmick |  | POM02.1.02.01.01 |  |  |  |  |  |  |  | 01 | yes | 01 | 2 |  | S104200 | SBU | SBU | TPC v1 FCage |  |  |  |  | PP5 | MP200410 | Yes | L5 | OBLG |  |  |  |  |  |
| S107300 |  | Procure TPC v1 End Cap - Contract Award(s) Phase 1 | milestone | 0d | 2018-09-11 A | 2018-09-11 A | S107200 | 100% |  |  |  |  |  |  | S107300 | 100 | Procure TPC v1 End Cap - Contract Award(s) Phase 1 | S342280 |  | NOCA | Completed | A-OPC | Hemmick,Tom | L4 | Procurement | Tom Hemmick |  | POM02.1.02.01.01 |  |  |  |  |  |  |  | 01 | yes | 01 | 2 |  | S104200 | SBU | SBU | TPC v1 FCage |  |  |  |  | PP5 | MP200400 | Yes | L5 |  |  |  |  |  |  |
| S107400 |  | Procure TPC v1 End Cap - Contract Award(s) Phase 2 | milestone | 0d | 2018-09-11 A | 2018-09-11 A | S107200 | 100% |  |  |  |  |  |  | S107400 | 100 | Procure TPC v1 End Cap - Contract Award(s) Phase 2 | S342285 |  | NOCA | Completed | A-OPC | Hemmick,Tom | L4 | Procurement | Tom Hemmick |  | POM02.1.02.01.01 |  |  |  |  |  |  |  | 01 | yes | 01 | 2 |  | S104200 | SBU | SBU | TPC v1 FCage |  |  |  |  | PP5 | MP200410 | Yes | L5 |  |  |  |  |  |  |
| S105600 |  | Assemble TPC v1 Outer Field Cage FY19 |  | 60d | 2018-10-01 A | 2018-12-28 A | S105500 | 100% |  |  |  |  |  |  | S105600 | 100 | Assemble TPC v1 Outer Field Cage FY19 | S102950 |  | NOCA | Completed | T | Hemmick,Tom | L4 | Fab & Assy | Tom Hemmick | null | POM02.1.02.01.01 |  |  | C |  |  |  |  | 01 | yes | 01 | 4 |  | S102900 | SBU | SBU | TPC v1 FCage |  | 2018-03-16 |  | FY19 |  |  |  |  |  |  |  |  |  |  |
| S106100 |  | Assemble TPC v1 Inner Field Cage FY19 |  | 204d | 2018-10-01 A | 2019-11-29 A | S106000 | 100% | 2018-10-01 | 2019-07-25 |  | STUDENT SBU - Unpaid [96 h]; SCI4 SBU - Unpaid [96 h]; TECH4 SBU - Unpaid [96 h] |  |  | S106100 | 70 | Assemble TPC v1 Inner Field Cage FY19 | S103350 | S106100 | CA | Completed | T | Hemmick,Tom | L4 | Fab & Assy | Tom Hemmick | null | POM02.1.02.01.01 |  |  | C | 1.02 | NA |  | 1.02B | 01 |  | 01 | 4 |  | S103300 | SBU | SBU | TPC v1 FCage |  | 2019-03-29 |  | FY19 |  |  |  |  |  | Yes |  |  |  |  |
| S107500 |  | Procure TPC v1 End Cap - Contract/PO - Leadtime |  | 103d | 2018-10-01 A | 2019-03-04 A | S107300 SS, S107400 SS, OBLG107310 SS, OBLG107410 SS | 100% |  |  |  |  |  |  | S107500 | 100 | Procure TPC v1 End Cap - Contract/PO - Leadtime | S342320 |  | NOCA | Completed |  | Hemmick,Tom | L4 | Procurement | Tom Hemmick |  | POM02.1.02.01.01 |  |  | C |  |  |  |  | 01 | yes | 01 | 2 |  | S104200 | SBU | SBU | TPC v1 FCage |  |  |  |  | PP6 | MP200400 | Yes |  |  |  |  |  |  |  |
| S108200 |  | Procure TPC v1 Central Membrane Parts Labor FY19 |  | 210d | 2018-10-01 A | 2019-10-30 A | S108100 | 100% | 2018-10-01 | 2019-08-02 |  | TECH4 SBU - Unpaid [256 h] |  |  | S108200 | 70 | Procure TPC v1 Central Membrane Parts Labor FY19 | S104525 | S108200 | CA | Completed | T | Hemmick,Tom | L5 | Procurement | Tom Hemmick | null | POM02.1.02.01.01 |  |  | C | 1.02 | NA |  | 1.02B | 01 |  | 01 | 3 |  | S104500 | SBU | SBU | TPC v1 FCage |  | 2019-02-15 |  | FY19 |  |  |  |  |  | Yes |  |  |  |  |
| S108400 |  | Procure TPC Assembly Fixture Labor |  | 41d | 2018-10-01 A | 2018-11-30 A | S108300 | 100% |  |  |  |  |  |  | S108400 | 100 | Procure TPC Assembly Fixture Labor | S104700 |  | NOCA | Completed | B | Hemmick,Tom | L5 | Procurement | Tom Hemmick | null | POM02.1.02.01.01 |  |  | C |  | 16709 |  |  | 01 | yes | 01 | 2 |  | S104700 | SBU | SBU | TPC v1 FCage |  |  |  |  |  |  |  |  |  |  |  |  |  |  |
| S108500 |  | Procure TPC Assembly Fixture M&S |  | 41d | 2018-10-01 A | 2018-11-30 A | S108300, S126000 SS, OBLG126001 SS | 100% |  |  |  |  |  | 190314 ELM RA per GRY | S108500 | 100 | Procure TPC Assembly Fixture M&S | S104800 |  | NOCA | Completed | A-OPC | Hemmick,Tom | M5 | Fab & Assy | Tom Hemmick | OPC | POM02.1.02.01.01 |  |  | C |  | 16701 | 003 |  | 01 | yes | 01 | 4 |  | S104800 | SBU | SBU | TPC v1 FCage |  |  | OPC000100 |  | PP6 | MP208100 | Yes |  |  |  |  |  |  |  |
| S107900 |  | Procure TPC v1 Central Membrane Parts M&S FY19 |  | 154d | 2018-10-18 A | 2019-05-31 A | S107800, S126000 SS, OBLG126001 SS | 100% |  |  |  |  |  | 190415 ELM BNLU per GRY; 190314 ELM RA per GRY | S107900 | 70 | Procure TPC v1 Central Membrane Parts M&S FY19 | S104350 |  | NOCA | Completed | A-OPC | Hemmick,Tom | M5 | Fab & Assy | Tom Hemmick | OPC | POM02.1.02.01.01 |  |  | C |  | 16701 | 003,004 |  | 01 | yes | 01 | 4 |  | S104300 | SBU | SBU | TPC v1 FCage |  | 2019-02-15 | OPC000100 | FY19 | PP6 | MP208100 | Yes |  |  |  |  |  |  |  |
| S107700 |  | Procure TPC v1 End Cap - Delivery Acceptance Phase 2 |  | 10d | 2019-02-13 A | 2019-02-27 A | S107500 FS+30d | 100% |  |  |  |  |  | 190314 ELM RA per GRY | S107700 | 100 | Procure TPC v1 End Cap - Delivery Acceptance Phase 2 | S104150 |  | NOCA | Completed | A-OPC | Hemmick,Tom | M5 | Fab & Assy | Tom Hemmick | OPC | POM02.1.02.01.01 |  |  | F |  | 16701 | 003 |  | 01 | yes | 01 | 4 |  | S104100 | SBU | SBU | TPC v1 FCage |  |  | OPC000100 |  | PP6 | MP200410 | Yes |  |  |  |  |  |  |  |
| S107600 |  | Procure TPC v1 End Cap - Delivery Acceptance Phase 1 |  | 5d | 2019-02-19 A | 2019-02-25 A | S107500 | 100% |  |  |  |  |  | 190314 ELM RA per GRY | S107600 | 100 | Procure TPC v1 End Cap - Delivery Acceptance Phase 1 | S104100 |  | NOCA | Completed | A-OPC | Hemmick,Tom | M5 | Fab & Assy | Tom Hemmick | OPC | POM02.1.02.01.01 |  |  | F |  | 16701 | 003 |  | 01 | yes | 01 | 4 |  | S104100 | SBU | SBU | TPC v1 FCage |  |  | OPC000100 |  | PP6 | MP200400 | Yes |  |  |  |  |  |  |  |
| S108900 |  | Assemble TPC v1 Central Membrane |  | 10d | 2019-08-14 A | 2019-10-30 A | S108200, S107905 | 100% | 2019-10-01 | 2019-10-15 |  | STUDENT SBU - Unpaid [80 h]; SCI4 SBU - Unpaid [80 h]; TECH4 SBU - Unpaid [80 h] |  |  | S108900 | 0 | Assemble TPC v1 Central Membrane | S104900 | S108900 | CA | Completed | T | Hemmick,Tom | L5 | Fab & Assy | Tom Hemmick | null | POM02.1.02.01.01 |  |  | C | 1.02 | NA |  | 1.02B | 01 |  | 01 | 5 |  | S104900 | SBU | SBU | TPC v1 FCage |  |  |  |  |  |  |  |  |  |  |  |  |  |  |
| S107905 |  | Procure TPC v1 Central Membrane Parts M&S FY19 Split |  | 20d | 2019-09-03 A | 2019-10-31 A | S107900 | 100% | 2019-09-03 | 2019-09-30 | start on or after 2019-06-03 | SBU Contracted Purchase <$2M M&S [2400 h] | 2,647.84 | 190415 ELM BNLU per GRY; 190314 ELM RA per GRY | S107900 | 70 | Procure TPC v1 Central Membrane Parts M&S FY19 | S104350 | S107905 | CA | Completed | A-OPC | Hemmick,Tom | M5 | Fab & Assy | Tom Hemmick | OPC | POM02.1.02.01.01 |  |  | C | 1.02 | 16701 | 003,004 | 1.02A | 01 |  | 01 | 4 | UDF_G1 | S104300 | SBU | SBU | TPC v1 FCage |  | 2019-02-15 | OPC000100 | FY19 | PP6 | MP208100 | Yes |  |  |  |  |  |  |  |
| S109000 |  | Assemble TPC v1 Field Cage Prototype |  | 15d | 2019-12-02 A | 2019-12-23 A | S106400, S108400, S108900, S106500, S107600, S108500, S105600, S106100 | 100% | 2019-12-02 | 2019-12-20 |  | STUDENT SBU - Unpaid [120 h]; SCI4 SBU - Unpaid [120 h]; TECH4 SBU - Unpaid [120 h] |  |  | S109000 | 0 | Assemble TPC v1 Field Cage Prototype | S105000 | S109000 | CA | Not Started | T | Hemmick,Tom | L4 | Fab & Assy | Tom Hemmick | null | POM02.1.02.01.01 |  |  | C | 1.02 | NA |  | 1.02B | 01 |  | 01 | 5 |  | S105000 | SBU | SBU | TPC v1 FCage |  |  |  |  |  |  |  |  |  |  |  |  |  |  |
| S109100 |  | Benchtest TPC v1 Field Cage Prototype |  | 20d | 2020-01-02 A | 2020-02-28 A | S109000, S107700 | 100% | 2020-01-02 | 2020-01-30 |  | STUDENT SBU - Unpaid [40 h]; SCI4 SBU - Unpaid [40 h]; TECH4 SBU - Unpaid [40 h] |  |  | S109100 | 0 | Benchtest TPC v1 Field Cage Prototype | S105100 | S109100 | CA | Not Started | T | Hemmick,Tom | L4 | Test_System | Tom Hemmick | null | POM02.1.02.01.01 |  |  | C | 1.02 | NA |  | 1.02B | 01 |  | 01 | 7 |  | S105100 | SBU | SBU | TPC v1 FCage |  |  |  |  |  |  |  |  |  |  |  |  |  |  |
| S109200 |  | Preliminary Design Review - TPC Field Cage |  | 3d | 2020-01-27 A | 2020-01-30 A | S109100 | 100% | 2020-01-31 | 2020-02-04 |  | PROF4 PO M [4 h]; SCI3 PO [4 h] | 1,277.48 | 190522 IVS name change | S109200 | 0 | Review TPC v1 Field Cage Prototype | S105200 | S109200 | CA | Not Started | B | Hemmick,Tom |  | Fab & Assy | Tom Hemmick |  | POM02.1.02.01.01 |  |  | C | 1.02 | 16709 | 004 | 1.02B | 01 |  | 01 | 5 |  | S105200 | SBU | SBU | TPC v1 FCage |  |  |  |  |  |  |  | L5 |  |  |  |  |  |  |
| S108600 |  | Design TPC Handling Cart |  | 60d | 2020-04-01 A | 2020-04-30 A | S125500 SS, S129500 SS, S133700 SS, S133900 SS, S125505 SS | 100% | 2020-06-24 | 2020-09-17 |  | SCI4 SBU - Unpaid [120 h]; PROF4 AM [120 h] | 17,671.8 |  | S108600 | 0 | Design TPC Handling Cart | S104825 | S108600 | CA | Not Started | B_T | Hemmick,Tom | L5 | Design | Tom Hemmick | null | POM02.1.02.01.01 |  |  | C | 1.02 | 16709 |  | 1.02B | 01 |  | 1 | 1 |  | S104600 | SBU | SBU | TPC v1 FCage | 180426 ELM rsrc per EOB | 2018-03-29 |  |  |  |  |  |  |  |  |  |  |  |  |
| S108700 |  | Procure TPC Handling Cart Labor |  | 40d | 2020-04-01 A | 2020-04-30 A | S108600 | 100% | 2020-09-18 | 2020-11-16 |  | TECH3 PO M [32 h] | 3,736.82 |  | S108700 | 0 | Procure TPC Handling Cart Labor | S104850 | S108700 | CA | Not Started | B | Hemmick,Tom | L5 | Procurement | Tom Hemmick | null | POM02.1.02.01.01 |  |  | C | 1.02 | 16709 |  | 1.02B | 01 |  | 01 | 3 |  | S104700 | SBU | SBU | TPC v1 FCage |  |  |  |  |  |  |  |  |  |  |  |  |  |  |
| S108800 |  | Procure TPC Handling Cart M&S |  | 40d | 2020-04-01 A | 2021-05-28 A | S108600, S126000 SS, OBLG126001 SS | 100% | 2020-09-18 | 2020-11-16 |  | SBU Contracted Purchase <$2M M&S [13000 h] | 15,022.33 | 190314 ELM RA per GRY | S108800 | 0 | Procure TPC Handling Cart M&S | S104875 | S108800 | CA | Not Started | A-TEC | Hemmick,Tom | M5 | Fab & Assy | Tom Hemmick | OPC | POM02.1.02.01.01 |  |  | C | 1.02 | 59702 | 003 | 1.02A | 01 |  | 01 | 5 | UDF_G1 | S104800 | SBU | SBU | TPC v1 FCage |  |  | OPC000100 |  | PP6 | MP208200 |  |  |  |  | UDF_G3 | 13520.0946231 | 0.9 | Combined |

Notes:
- S106800: General Notes: 180420 GYoung: concerning / Production Readiness Review - probably OK to call "production readiness" / as plan to only make this item / once

| ID | WBS | Activity | Type | Duration | Start | Finish | Predecessors | Complete | Remaining | Planned start | Planned finish | Total float | Free float | Expected finish | Resources | Cost | BNL_UDF_Temp Text 01 | BNL_UDF_Adhoc Comments | BNL_UDF_Percent Complete | BNL_UDF_OPC TEC (deprecated) | BNL_UDF_Old Activity ID 181221 | RG Check | BNL_Activity Status | BNL_Fund Source | BNL_Estimator | BNL_Cost Basis | BNL_Location | BNL_EDIA | BNL_CAM | BNL_Institution | BNL_R&D FY18-19 | BNL_OPC TEC (deprecated) | BNL_WBS | BNL_EVT | BNL_Account Number | BNL_WBS_Hierarchical | Completed | PMP Summary Part1 | PMP Summary Part2 | BNL_Cobra WP | BNL_Master Control Account | BNL_Cobra Control Account | BNL_UDF_Status Comments | Indicator - Procurement | Indicator - Float | BNL_Proc Sig Phase | BNL_Proc Sig | BNL_DOE OPC | BNL_PCR ID | Cost = Awarded Proc or Mgmt | BNL_Obligation | SPH Proc Register | BNL_Milestone Level |
| --- | --- | --- | --- | --- | --- | --- | --- | --- | --- | --- | --- | --- | --- | --- | --- | --- | --- | --- | --- | --- | --- | --- | --- | --- | --- | --- | --- | --- | --- | --- | --- | --- | --- | --- | --- | --- | --- | --- | --- | --- | --- | --- | --- | --- | --- | --- | --- | --- | --- | --- | --- | --- | --- |
|  | 02 | **TPC v2 Field Cage** |  |  | 2019-05-21 | 2021-07-23 |  |  |  |  |  |  |  |  |  |  |  |  |  |  |  |  |  |  |  |  |  |  |  |  |  |  |  |  |  |  |  |  |  |  |  |  |  |  |  |  |  |  |  |  |  |  |  |
| S109300 |  | Produce TPC v2 Field Cage Prototype Conceptual Design |  | 8d | 2019-05-21 A | 2019-05-31 A | S109100 SS | 100% |  |  |  |  |  |  |  |  | S109300 | 180426 ELM rsrc per EOB | 0 | S105300 | S105300 | NOCA | Completed | B_T | Hemmick,Tom | L3 | SBU | Design | Tom Hemmick | SBU | TPC v2 FCage | null | POM02.1.02.01.02 | C | 16709 | 02 | yes | 1 | 1 |  |  |  |  |  |  |  |  |  |  |  |  |  |  |
| S109600 |  | Produce TPC v2 Outer Field Cage Conceptual Design |  | 8d | 2019-05-21 A | 2019-05-31 A | S109100 SS | 100% |  |  |  |  |  |  |  |  | S109600 | 180426 ELM rsrc per EOB | 0 | S105600 | S105600 | NOCA | Completed | B_T | Hemmick,Tom | L3 | SBU | Design | Tom Hemmick | SBU | TPC v2 FCage | null | POM02.1.02.01.02 | C | 16709 | 02 | yes | 1 | 1 |  |  |  |  |  |  |  |  |  |  |  |  |  |  |
| S110500 |  | Produce TPC v2 Inner Field Cage Conceptual Design |  | 8d | 2019-05-21 A | 2019-05-31 A |  | 100% |  |  |  |  |  |  |  |  | S110500 | 180426 ELM rsrc per EOB | 0 | S105900 | S105900 | NOCA | Completed | B_T | Hemmick,Tom | L3 | SBU | Design | Tom Hemmick | SBU | TPC v2 FCage | null | POM02.1.02.01.02 | C | 16709 | 02 | yes | 1 | 1 |  |  |  |  |  |  |  |  |  |  |  |  |  |  |
| S111600 |  | Produce TPC v2 Central Membrane Conceptual Design |  | 8d | 2019-05-21 A | 2019-05-31 A | S109100 SS | 100% |  |  |  |  |  |  |  |  | S111600 | 180426 ELM rsrc per EOB | 0 | S106400 | S106400 | NOCA | Completed | B_T | Hemmick,Tom | L3 | SBU | Design | Tom Hemmick | SBU | TPC v2 FCage | null | POM02.1.02.01.02 | C | 16709 | 02 | yes | 1 | 1 |  |  |  |  |  |  |  |  |  |  |  |  |  |  |
| S111605 |  | Produce TPC v2 Central Membrane Conceptual Design Split |  | 65d | 2019-10-01 A | 2019-12-31 A | S111600 | 100% |  | 2019-10-01 | 2020-01-07 |  |  |  | SCI4 SBU - Unpaid [5 h]; TECH3 PO M [5 h]; PROF4 AM [5 h] | 1,306.94 | S111600 | 180426 ELM rsrc per EOB | 0 | S106400 | S106400 | CA | In Progress | B_T | Hemmick,Tom | L3 | SBU | Design | Tom Hemmick | SBU | TPC v2 FCage | null | POM02.1.02.01.02 | C | 16709 | 02 |  | 1 | 1 | S111605 | 1.02 | 1.02B |  |  |  |  |  |  |  |  |  |  |  |
| S111700 |  | Procure TPC v2 Central Membrane Parts Labor |  | 40d | 2019-10-08 A | 2020-02-28 A | S111605 SS | 100% |  | 2020-04-08 | 2020-06-03 |  |  |  | TECH4 SBU - Unpaid [320 h] |  | S111700 | 180410 ELM pred per GRY | 0 | S106500 | S106500 | CA | In Progress | T | Hemmick,Tom | L3 | SBU | Procurement | Tom Hemmick | SBU | TPC v2 FCage | null | POM02.1.02.01.02 | C | NA | 02 |  | 01 | 3 | S111700 | 1.02 | 1.02B |  |  |  |  |  |  |  |  |  |  |  |
| S111800 |  | Procure TPC v2 Central Membrane Parts M&S |  | 40d | 2019-10-10 A | 2020-02-28 A | S126000 SS, OBLG126001 SS, S111605 SS | 100% |  | 2020-04-10 | 2020-06-05 |  |  |  | SBU Contracted Purchase <$2M M&S [8000 h] | 9,103.41 | S111800 |  | 0 | S106600 | S106600 | CA | In Progress | A-OPC | Hemmick,Tom | M5 | SBU | Fab & Assy | Tom Hemmick | SBU | TPC v2 FCage | OPC | POM02.1.02.01.02 | C | 16701 | 02 |  | 01 | 5 | S111800 | 1.02 | 1.02A | 190314 ELM RA per GRY | UDF_G3 | UDF_G3 | PP6 | MP208100 | OPC000200 | 003 | Yes |  |  |  |
| S110505 |  | Produce TPC v2 Inner Field Cage Conceptual Design Split |  | 65d | 2019-11-01 A | 2020-01-29 A | S110500, S109100 FF | 100% |  | 2019-11-01 | 2020-02-07 |  |  |  | SCI4 SBU - Unpaid [2 h]; TECH3 PO M [2 h]; PROF4 AM [2 h] | 522.77 | S110500 | 180426 ELM rsrc per EOB | 0 | S105900 | S105900 | CA | In Progress | B_T | Hemmick,Tom | L3 | SBU | Design | Tom Hemmick | SBU | TPC v2 FCage | null | POM02.1.02.01.02 | C | 16709 | 02 |  | 1 | 1 | S110505 | 1.02 | 1.02B |  |  |  |  |  |  |  |  |  |  |  |
| S109305 |  | Produce TPC v2 Field Cage Prototype Conceptual Design Split |  | 64d | 2020-01-02 A | 2020-01-29 A | S109300 | 100% |  | 2020-01-02 | 2020-04-02 |  |  |  | SCI4 SBU - Unpaid [2 h]; TECH3 PO M [4 h]; PROF4 AM [4 h] | 1,045.55 | S109300 | 180426 ELM rsrc per EOB | 0 | S105300 | S105300 | CA | Not Started | B_T | Hemmick,Tom | L3 | SBU | Design | Tom Hemmick | SBU | TPC v2 FCage | null | POM02.1.02.01.02 | C | 16709 | 02 |  | 1 | 1 | S109305 | 1.02 | 1.02B |  |  |  |  |  |  |  |  |  |  |  |
| S109605 |  | Produce TPC v2 Outer Field Cage Conceptual Design Split |  | 43d | 2020-01-02 A | 2020-01-28 A | S109600 | 100% |  | 2020-01-02 | 2020-03-04 |  |  |  | SCI4 SBU - Unpaid [1 h]; TECH3 PO M [2 h]; PROF4 AM [2 h] | 522.77 | S109600 | 180426 ELM rsrc per EOB | 0 | S105600 | S105600 | CA | Not Started | B_T | Hemmick,Tom | L3 | SBU | Design | Tom Hemmick | SBU | TPC v2 FCage | null | POM02.1.02.01.02 | C | 16709 | 02 |  | 1 | 1 | S109605 | 1.02 | 1.02B |  |  |  |  |  |  |  |  |  |  |  |
| S111400 |  | Design TPC Field Cage Prototype v2 End Rings |  | 20d | 2020-01-03 A | 2020-01-29 A | S109305 | 100% |  | 2020-04-03 | 2020-04-30 |  |  |  | SCI4 SBU - Unpaid [16 h]; TECH3 PO M [16 h]; PROF4 AM [16 h] | 4,182.19 | S111400 | 180426 ELM rsrc per EOB | 0 | S106200 | S106200 | CA | Not Started | B_T | Hemmick,Tom | L3 | SBU | Design | Tom Hemmick | SBU | TPC v2 FCage | null | POM02.1.02.01.02 | C | 16709 | 02 |  | 1 | 1 | S111400 | 1.02 | 1.02B |  |  |  |  |  |  |  |  |  |  |  |
| S109700 |  | Procure TPC v2 Outer Field Cage Parts - Provide Requirements to Procurement |  | 5d | 2020-01-10 A | 2020-01-28 A | S109100, S109605 | 100% |  | 2020-03-05 | 2020-03-11 |  |  |  |  |  | S109700 | 180403 ELM added activity (Proc String) | 0 | S105700 | S105630 | NOCA | Not Started |  | Hemmick,Tom |  | SBU | Procurement | Tom Hemmick | SBU | TPC v2 FCage |  | POM02.1.02.01.02 |  |  | 02 |  | 01 | 3 |  |  |  |  |  |  | PP1 | MP200800 | OPC000200 |  |  |  |  |  |
| S109800 |  | Procure TPC v2 Outer Field Cage Parts - Prepare & Send Solicitation |  | 15d | 2020-01-10 A | 2020-01-28 A | S109700 | 100% |  | 2020-03-12 | 2020-04-01 |  |  |  |  |  | S109800 | 180403 ELM added activity (Proc String) | 0 | S105700 | S105640 | NOCA | Not Started |  | Hemmick,Tom |  | SBU | Procurement | Tom Hemmick | SBU | TPC v2 FCage |  | POM02.1.02.01.02 |  |  | 02 |  | 01 | 3 |  |  |  |  |  |  | PP2 | MP200800 | OPC000200 |  |  |  |  |  |
| S109900 |  | Procure TPC v2 Outer Field Cage Parts - Vendor Responses |  | 10d | 2020-01-10 A | 2020-01-28 A | S109800 | 100% |  | 2020-04-02 | 2020-04-15 |  |  |  |  |  | S109900 | 180403 ELM added activity (Proc String) | 0 | S105700 | S105650 | NOCA | Not Started |  | Hemmick,Tom |  | SBU | Procurement | Tom Hemmick | SBU | TPC v2 FCage |  | POM02.1.02.01.02 |  |  | 02 |  | 01 | 3 |  |  |  |  |  |  | PP3 | MP200800 | OPC000200 |  |  |  |  |  |
| S110000 |  | Procure TPC v2 Outer Field Cage Parts - Vendor Selection |  | 20d | 2020-01-10 A | 2020-01-28 A | S109900 | 100% |  | 2020-04-16 | 2020-05-13 |  |  |  |  |  | S110000 | 180403 ELM added activity (Proc String) | 0 | S105700 | S105660 | NOCA | Not Started |  | Hemmick,Tom |  | SBU | Procurement | Tom Hemmick | SBU | TPC v2 FCage |  | POM02.1.02.01.02 |  |  | 02 |  | 01 | 3 |  |  |  |  |  |  | PP4 | MP200800 | OPC000200 |  |  |  |  |  |
| S110300 |  | Procure TPC v2 Outer Field Cage Parts - Delivery Acceptance |  | 5d | 2020-01-13 A | 2020-04-30 A | S110200, S109605 | 100% |  | 2020-07-13 | 2020-07-17 |  |  |  | SBU Contracted Purchase <$2M M&S [75827 h] | 86,285.5 | S110300 | 180410 ELM pred per GRY | 0 | S105700 | S105700 | CA | Not Started | A-OPC | Hemmick,Tom | M3 | SBU | Fab & Assy | Tom Hemmick | SBU | TPC v2 FCage | OPC | POM02.1.02.01.02 | C | 16701 | 02 |  | 01 | 5 | S110300 | 1.02 | 1.02A | 190314 ELM RA per GRY | UDF_G1 | UDF_G3 | PP6 | MP200800 | OPC000200 | 003 |  | FAB | Delivery |  |
| S110600 |  | Procure TPC v2 Inner Field Cage Parts - Provide Requirements to Procurement |  | 5d | 2020-01-14 A | 2020-01-28 A | S110505 | 100% |  | 2020-02-10 | 2020-02-14 |  |  |  |  |  | S110600 | 180402 ELM added activity for proc strg | 0 | S106000 | S105930 | NOCA | Not Started |  | Hemmick,Tom |  | SBU | Procurement | Tom Hemmick | SBU | TPC v2 FCage |  | POM02.1.02.01.02 |  |  | 02 |  | 01 | 3 |  |  |  |  |  |  | PP1 | MP200900 | OPC000200 |  |  |  |  |  |
| S110700 |  | Procure TPC v2 Inner Field Cage Parts - Prepare & Send Solicitation |  | 15d | 2020-01-14 A | 2020-01-28 A | S110600 | 100% |  | 2020-02-18 | 2020-03-09 |  |  |  |  |  | S110700 | 180402 ELM added activity for proc strg | 0 | S106000 | S105940 | NOCA | Not Started |  | Hemmick,Tom |  | SBU | Procurement | Tom Hemmick | SBU | TPC v2 FCage |  | POM02.1.02.01.02 |  |  | 02 |  | 01 | 3 |  |  |  |  |  |  | PP2 | MP200900 | OPC000200 |  |  |  |  |  |
| S110800 |  | Procure TPC v2 Inner Field Cage Parts - Vendor Responses |  | 10d | 2020-01-14 A | 2020-01-28 A | S110700 | 100% |  | 2020-03-10 | 2020-03-23 |  |  |  |  |  | S110800 | 180402 ELM added activity for proc strg | 0 | S106000 | S105950 | NOCA | Not Started |  | Hemmick,Tom |  | SBU | Procurement | Tom Hemmick | SBU | TPC v2 FCage |  | POM02.1.02.01.02 |  |  | 02 |  | 01 | 3 |  |  |  |  |  |  | PP3 | MP200900 | OPC000200 |  |  |  |  |  |
| S110900 |  | Procure TPC v2 Inner Field Cage Parts - Vendor Selection |  | 20d | 2020-01-14 A | 2020-01-28 A | S110800 | 100% |  | 2020-03-24 | 2020-04-20 |  |  |  |  |  | S110900 | 180402 ELM added activity for proc strg | 0 | S106000 | S105960 | NOCA | Not Started |  | Hemmick,Tom |  | SBU | Procurement | Tom Hemmick | SBU | TPC v2 FCage |  | POM02.1.02.01.02 |  |  | 02 |  | 01 | 3 |  |  |  |  |  |  | PP4 | MP200900 | OPC000200 |  |  |  |  |  |
| S111000 |  | Procure TPC v2 Inner Field Cage Parts - Contract Award(s) | milestone | 0d | 2020-01-14 A | 2020-01-14 A | S110900 | 100% |  | 2020-04-21 | 2020-04-21 |  |  |  |  |  | S111000 | 180402 ELM added activity for proc strg | 0 | S106000 | S105970 | NOCA | Not Started | A-OPC | Hemmick,Tom |  | SBU | Procurement | Tom Hemmick | SBU | TPC v2 FCage |  | POM02.1.02.01.02 |  |  | 02 |  | 01 | 3 |  |  |  |  |  |  | PP5 | MP200900 | OPC000200 |  |  |  | Contract Award | L5 |
| S111100 |  | Procure TPC v2 Inner Field Cage Parts - Contract/PO - Leadtime |  | 40d | 2020-01-14 A | 2020-01-28 A | S111000 SS, OBLG111010 SS | 100% |  | 2020-04-21 | 2020-06-16 |  |  |  |  |  | S111100 | 180402 ELM added activity for proc strg | 0 | S106000 | S105980 | NOCA | Not Started |  | Hemmick,Tom |  | SBU | Fab & Assy | Tom Hemmick | SBU | TPC v2 FCage |  | POM02.1.02.01.02 |  |  | 02 |  | 01 | 5 |  |  |  |  |  |  | PP6 | MP200900 | OPC000200 |  |  |  |  |  |
| S111200 |  | Procure TPC v2 Inner Field Cage Parts - Delivery Acceptance |  | 5d | 2020-01-14 A | 2020-01-28 A | S111100 | 100% |  | 2020-06-17 | 2020-06-23 |  |  |  | SBU Contracted Purchase <$2M M&S [34559 h] | 39,325.58 | S111200 |  | 0 | S106000 | S106000 | CA | Not Started | A-OPC | Hemmick,Tom | M3 | SBU | Fab & Assy | Tom Hemmick | SBU | TPC v2 FCage | OPC | POM02.1.02.01.02 | C | 16701 | 02 |  | 01 | 5 | S111200 | 1.02 | 1.02A | 190314 ELM RA per GRY | UDF_G2 | UDF_G3 | PP6 | MP200900 | OPC000200 | 003 |  | FAB | Delivery |  |
| S111300 |  | Assemble TPC v2 Inner Field Cage |  | 10d | 2020-01-14 A | 2020-01-28 A | S110400, S109200, S111200, S109305, S110505 | 100% |  | 2020-08-17 | 2020-08-28 |  |  |  | STUDENT SBU - Unpaid [80 h]; SCI4 SBU - Unpaid [80 h]; TECH4 SBU - Unpaid [80 h] |  | S111300 |  | 0 | S106100 | S106100 | CA | Not Started | T | Hemmick,Tom | L3 | SBU | Fab & Assy | Tom Hemmick | SBU | TPC v2 FCage | null | POM02.1.02.01.02 | C | NA | 02 |  | 01 | 5 | S111300 | 1.02 | 1.02B |  |  |  |  |  |  |  |  |  |  |  |
| OBLG110110 |  | Procure TPC v2 Outer Field Cage Parts - Obligation |  | 1d | 2020-03-02 A | 2020-03-02 A | S110000 | 100% |  |  |  |  |  |  | Obligation Resource [86285.5 h] | 86,285.51 | S110100 | 180403 ELM added activity (Proc String) | 0 | S105700 | S105670 |  | Not Started | A-OPC | Hemmick,Tom |  | SBU | Fab & Assy | Tom Hemmick | SBU | TPC v2 FCage |  | POM02.1.02.01.02 |  |  | 02 |  |  |  |  |  |  |  |  |  | PP5 | MP200800 | OPC000200 |  |  | OBLG |  | L5 |
| OBLG111010 |  | Procure TPC v2 Inner Field Cage Parts - Obligation |  | 1d | 2020-03-02 A | 2020-03-02 A | S110900 | 100% |  |  |  |  |  |  | Obligation Resource [39325.6 h] | 39,325.58 | S111000 | 180402 ELM added activity for proc strg | 0 | S106000 | S105970 |  | Not Started | A-OPC | Hemmick,Tom |  | SBU | Procurement | Tom Hemmick | SBU | TPC v2 FCage |  | POM02.1.02.01.02 |  |  | 02 |  |  |  |  |  |  |  |  |  | PP5 | MP200900 | OPC000200 |  |  | OBLG |  | L5 |
| S109400 |  | Procure TPC v2 Mandrel Parts M&S |  | 40d | 2020-04-01 A | 2020-04-30 A | S108900, S109305, S110505 | 100% |  | 2020-04-01 | 2020-05-27 |  |  |  | SBU Contracted Purchase <$2M M&S [10433 h] | 11,871.98 | S109400 |  | 0 | S105400 | S105400 | CA | Not Started | A-OPC | Hemmick,Tom | M3 | SBU | Fab & Assy | Tom Hemmick | SBU | TPC v2 FCage | OPC | POM02.1.02.01.02 | C | 16701 | 02 |  | 01 | 5 | S109400 | 1.02 | 1.02A | 190314 ELM RA per GRY | UDF_G1 | UDF_G3 | PP6 | MP208100 | OPC000200 | 003 | Yes |  |  |  |
| S109500 |  | Assemble TPC v2 Mandrel |  | 15d | 2020-04-01 A | 2020-04-30 A | S109200, S109400, S109305, S110505 | 100% |  | 2020-05-28 | 2020-06-17 |  |  |  | STUDENT SBU - Unpaid [120 h]; SCI4 SBU - Unpaid [20 h]; TECH4 SBU - Unpaid [40 h] |  | S109500 |  | 0 | S105500 | S105500 | CA | Not Started | T | Hemmick,Tom | L3 | SBU | Fab & Assy | Tom Hemmick | SBU | TPC v2 FCage | null | POM02.1.02.01.02 | C | NA | 02 |  | 01 | 5 | S109500 | 1.02 | 1.02B |  |  |  |  |  |  |  |  |  |  |  |
| S111500 |  | Procure TPC Field Cage Prototype v2 End Rings |  | 40d | 2020-04-01 A | 2020-04-30 A | S111400, S109100, S126000 SS, OBLG126001 SS | 100% |  | 2020-04-01 | 2020-05-27 |  |  |  | SBU Contracted Purchase <$2M M&S [20000 h] | 22,758.52 | S111500 |  | 0 | S106300 | S106300 | CA | Not Started | A-OPC | Hemmick,Tom | M3 | SBU | Fab & Assy | Tom Hemmick | SBU | TPC v2 FCage | OPC | POM02.1.02.01.02 | C | 16701 | 02 |  | 01 | 5 | S111500 | 1.02 | 1.02A | 190314 ELM RA per GRY | UDF_G2 | UDF_G3 | PP6 | MP208100 | OPC000200 | 003 | Yes |  |  |  |
| S110200 |  | Procure TPC v2 Outer Field Cage Parts - Contract/PO - Leadtime |  | 40d | 2020-04-14 A | 2020-04-30 A | S110100 SS, OBLG110110 SS | 100% |  | 2020-05-14 | 2020-07-10 |  |  |  |  |  | S110200 | 180403 ELM added activity (Proc String) | 0 | S105700 | S105680 | NOCA | Not Started |  | Hemmick,Tom |  | SBU | Procurement | Tom Hemmick | SBU | TPC v2 FCage |  | POM02.1.02.01.02 |  |  | 02 |  | 01 | 3 |  |  |  |  |  |  | PP6 | MP200800 | OPC000200 |  |  |  |  |  |
| S110100 |  | Procure TPC v2 Outer Field Cage Parts - Contract Award(s) | milestone | 0d | 2020-05-14 A | 2020-05-14 A | S110000 | 100% |  |  |  |  |  |  |  |  | S110100 | 180403 ELM added activity (Proc String) | 0 | S105700 | S105670 | NOCA | Not Started | A-OPC | Hemmick,Tom |  | SBU | Fab & Assy | Tom Hemmick | SBU | TPC v2 FCage |  | POM02.1.02.01.02 |  |  | 02 |  | 01 | 5 |  |  |  |  |  |  | PP5 | MP200800 | OPC000200 |  |  |  | Contract Award | L5 |
| S110400 |  | Assemble TPC v2 Outer Field Cage |  | 20d | 2020-06-01 A | 2021-06-22 | S109500, S109200, S110300, S109605 | 98% | 16d | 2020-06-01 | 2020-06-26 | 23d | 0d | 2021-06-22 | STUDENT SBU - Unpaid [480 h]; SCI4 SBU - Unpaid [80 h]; TECH4 SBU - Unpaid [160 h] |  | S110400 |  | 0 | S105800 | S105800 | CA | Not Started | T | Hemmick,Tom | L3 | SBU | Fab & Assy | Tom Hemmick | SBU | TPC v2 FCage | null | POM02.1.02.01.02 | C | NA | 02 |  | 01 | 5 | S110400 | 1.02 | 1.02B |  |  |  |  |  |  |  |  |  |  |  |
| S111900 |  | Assemble TPC v2 Central Membrane |  | 10d | 2020-06-01 A | 2021-06-22 | S111700, S111400, S109200, S111800, S111605 | 90% | 16d | 2020-06-01 | 2020-06-12 | 23d | 0d | 2021-06-22 | STUDENT SBU - Unpaid [80 h]; SCI4 SBU - Unpaid [80 h]; TECH4 SBU - Unpaid [80 h] |  | S111900 |  | 0 | S106700 | S106700 | CA | Not Started | T | Hemmick,Tom | L3 | SBU | Fab & Assy | Tom Hemmick | SBU | TPC v2 FCage | null | POM02.1.02.01.02 | C | NA | 02 |  | 01 | 5 | S111900 | 1.02 | 1.02B |  |  |  |  |  |  |  |  |  |  |  |
| S112000 |  | Assemble TPC v2 Field Cage Prototype |  | 20d | 2021-05-11 A | 2021-06-30 | S110400, S111300, S111900, S111400, S109200, S111500, S111605 | 15% | 6d | 2021-06-04 | 2021-07-01 | 23d | 0d | 2021-06-11 | STUDENT SBU - Unpaid [160 h]; SCI4 SBU - Unpaid [160 h]; TECH4 SBU - Unpaid [160 h] |  | S112000 |  | 0 | S106800 | S106800 | CA | Not Started | T | Hemmick,Tom | L3 | SBU | Fab & Assy | Tom Hemmick | SBU | TPC v2 FCage | null | POM02.1.02.01.02 | C | NA | 02 |  | 01 | 5 | S112000 | 1.02 | 1.02B |  |  |  |  |  |  |  |  |  |  |  |
| S112100 |  | Benchtest TPC v2 Field Cage |  | 5d | 2021-07-01 | 2021-07-08 | S112000 |  |  |  |  | 28d | 5d |  | SCI3 PO [4 h]; PROF4 PO M [4 h] | 1,315.81 | S112100 |  | 0 | S106900 | S106900 | CA | Not Started | B | Hemmick,Tom |  | SBU | Test_System | Tom Hemmick | SBU |  |  | POM02.1.02.01.02 | C | 16709 | 02 |  | 01 | 7 | S112100 | 1.02 | 1.02B |  |  |  |  |  |  |  |  |  |  |  |
| S112200 |  | TPC Field Cage Safety Review |  | 3d | 2021-07-16 | 2021-07-20 | S112000 FS+10d, S112100 |  |  |  |  | 23d | 0d |  | SCI3 PO [4 h]; PROF4 PO M [4 h] | 1,315.81 | S112200 |  | 0 | S107000 | S107000 | CA | Not Started | B | Hemmick,Tom |  | SBU | Management Safety Reviews | Tom Hemmick | SBU | TPC v2 FCage |  | POM02.1.02.01.02 | C | 16709 | 02 |  | 1 | 1 | S112200 | 1.02 | 1.02B |  |  |  |  |  |  |  |  |  |  |  |
| S112300 |  | Final Design Review - TPC Field Cage |  | 3d | 2021-07-21 | 2021-07-23 | S112200, S112100 |  |  |  |  | 23d | 0d |  | SCI3 PO [4 h]; PROF4 PO M [4 h] | 1,315.81 | S112300 |  | 0 | S107100 | S107100 | CA | Not Started | B | Hemmick,Tom |  | SBU | Management Tech Reviews | Tom Hemmick | SBU | TPC v2 FCage |  | POM02.1.02.01.02 | C | 16709 | 02 |  | 1 | 1 | S112300 | 1.02 | 1.02B | 190522 IVS new name |  |  |  |  |  | 004 |  |  |  |  |

Notes:
- S109300: BNL_UDF_Old Activity Name 181221: Produce TPC v2 Field Cage Prototype Conceptual Design
- S109600: BNL_UDF_Old Activity Name 181221: Produce TPC v2 Outer Field Cage Conceptual Design
- S110500: BNL_UDF_Old Activity Name 181221: Produce TPC v2 Inner Field Cage Conceptual Design
- S111600: BNL_UDF_Old Activity Name 181221: Produce TPC v2 Central Membrane Conceptual Design
- S111605: BNL_UDF_Old Activity Name 181221: Produce TPC v2 Central Membrane Conceptual Design
- S111700: BNL_UDF_Old Activity Name 181221: Procure TPC v2 Central Membrane Parts Labor
- S111800: BNL_UDF_Old Activity Name 181221: Procure TPC v2 Central Membrane Parts M&S
- S110505: BNL_UDF_Old Activity Name 181221: Produce TPC v2 Inner Field Cage Conceptual Design
- S109305: BNL_UDF_Old Activity Name 181221: Produce TPC v2 Field Cage Prototype Conceptual Design
- S109605: BNL_UDF_Old Activity Name 181221: Produce TPC v2 Outer Field Cage Conceptual Design
- S111400: BNL_UDF_Old Activity Name 181221: Design TPC Field Cage Prototype v2 End Rings
- S109700: BNL_UDF_Old Activity Name 181221: Procure TPC v2 Outer Field Cage Parts - Provide Requirements to Procurement
- S109800: BNL_UDF_Old Activity Name 181221: Procure TPC v2 Outer Field Cage Parts - Prepare & Send Solicitation
- S109900: BNL_UDF_Old Activity Name 181221: Procure TPC v2 Outer Field Cage Parts - Vendor Responses
- S110000: BNL_UDF_Old Activity Name 181221: Procure TPC v2 Outer Field Cage Parts - Vendor Selection
- S110300: BNL_UDF_Old Activity Name 181221: Procure TPC v2 Outer Field Cage Parts - Delivery Acceptance
- S110600: BNL_UDF_Old Activity Name 181221: Procure TPC v2 Inner Field Cage Parts - Provide Requirements to Procurement
- S110700: BNL_UDF_Old Activity Name 181221: Procure TPC v2 Inner Field Cage Parts - Prepare & Send Solicitation
- S110800: BNL_UDF_Old Activity Name 181221: Procure TPC v2 Inner Field Cage Parts - Vendor Responses
- S110900: BNL_UDF_Old Activity Name 181221: Procure TPC v2 Inner Field Cage Parts - Vendor Selection
- S111000: BNL_UDF_Old Activity Name 181221: Procure TPC v2 Inner Field Cage Parts - Contract Award(s)
- S111100: BNL_UDF_Old Activity Name 181221: Procure TPC v2 Inner Field Cage Parts - Contract/PO - Leadtime
- S111200: BNL_UDF_Old Activity Name 181221: Procure TPC v2 Inner Field Cage Parts - Delivery Acceptance
- S111300: BNL_UDF_Old Activity Name 181221: Assemble TPC v2 Inner Field Cage
- OBLG110110: BNL_UDF_Old Activity Name 181221: Procure TPC v2 Outer Field Cage Parts - Contract Award(s)
- OBLG111010: BNL_UDF_Old Activity Name 181221: Procure TPC v2 Inner Field Cage Parts - Contract Award(s)
- S109400: BNL_UDF_Old Activity Name 181221: Procure TPC v2 Mandrel Parts M&S
- S109500: BNL_UDF_Old Activity Name 181221: Assemble TPC v2 Mandrel
- S111500: BNL_UDF_Old Activity Name 181221: Procure TPC Field Cage Prototype v2 End Rings
- S110200: BNL_UDF_Old Activity Name 181221: Procure TPC v2 Outer Field Cage Parts - Contract/PO - Leadtime
- S110100: BNL_UDF_Old Activity Name 181221: Procure TPC v2 Outer Field Cage Parts - Contract Award(s)
- S110400: BNL_UDF_Old Activity Name 181221: Assemble TPC v2 Outer Field Cage
- S111900: BNL_UDF_Old Activity Name 181221: Assemble TPC v2 Central Membrane
- S112000: BNL_UDF_Old Activity Name 181221: Assemble TPC v2 Field Cage Prototype
- S112100: BNL_UDF_Old Activity Name 181221: Benchtest TPC v2 Field Cage
- S112200: BNL_UDF_Old Activity Name 181221: TPC Field Cage Safety Review
- S112300: BNL_UDF_Old Activity Name 181221: TPC Field Cage Design Review

| ID | WBS | Activity | Duration | Start | Finish | Predecessors | Complete | Planned start | Planned finish | Constraint | Resources | Cost | BNL_UDF_Temp Text 01 | BNL_UDF_Percent Complete | BNL_UDF_OPC TEC (deprecated) | BNL_UDF_Old Activity Name 181221 | BNL_UDF_Old Activity ID 181221 | BNL_Cobra WP | RG Check | Indicator - Procurement | Indicator - Float | BNL_Activity Status | BNL_Fund Source | BNL_Estimator | BNL_Cost Basis | BNL_Location | BNL_EDIA | BNL_CAM | BNL_Institution | BNL_R&D FY18-19 | BNL_OPC TEC (deprecated) | BNL_WBS | BNL_EVT | BNL_Master Control Account | BNL_Account Number | BNL_PCR ID | BNL_Cobra Control Account | BNL_WBS_Hierarchical | PMP Summary Part1 | PMP Summary Part2 | BNL_UDF_Adhoc Comments | BNL_Milestone Level | BNL_UDF_Status Comments | BNL_UDF_Remaining Tot Cost | BNL_UDF_Percent_remaining | BNL_Proc Sig Phase | BNL_Proc Sig | SPH Proc Register | Completed | BNL_UDF_Temp Date 01 | BNL_DOE OPC |
| --- | --- | --- | --- | --- | --- | --- | --- | --- | --- | --- | --- | --- | --- | --- | --- | --- | --- | --- | --- | --- | --- | --- | --- | --- | --- | --- | --- | --- | --- | --- | --- | --- | --- | --- | --- | --- | --- | --- | --- | --- | --- | --- | --- | --- | --- | --- | --- | --- | --- | --- | --- |
|  | 03 | **TPC Final Field Cage** |  | 2020-12-01 | 2021-04-30 |  |  |  |  |  |  |  |  |  |  |  |  |  |  |  |  |  |  |  |  |  |  |  |  |  |  |  |  |  |  |  |  |  |  |  |  |  |  |  |  |  |  |  |  |  |  |
| S113050 |  | TPC Module technical Support | 105d | 2020-12-01 A | 2021-04-30 A |  | 100% | 2021-01-04 | 2021-06-02 | start on or after 2020-12-01 | Material (Purchase (1st $2M) [80000 h] | 92,854.74 | S113000 | 0 | S107800 | Benchtest TPC Final Field Cage | S107800 | S113050 | CA | UDF_G3 | UDF_G1 | Not Started | A-TEC | Hemmick,Tom | L4 | SBU | Test_System | Tom Hemmick | SBU | TPC Final FCage | null | POM02.1.02.01.03 | C | 1.02 | 59702 | 017 | 1.02A | 03 | 01 | 7 |  |  |  |  |  |  |  |  |  |  |  |
| S112400 |  | Design TPC v2 Field Cage Modifications | 5d | 2021-03-08 A | 2021-03-29 A | S112000, S112300 | 100% | 2021-05-26 | 2021-06-02 |  | SCI4 SBU - Unpaid [16 h]; TECH3 PO M [16 h]; PROF4 AM [16 h] | 4,307.66 | S112400 | 0 | S107200 | Design TPC v2 Field Cage Modifications | S107200 | S112400 | CA |  |  | Not Started | B_T | Hemmick,Tom | L4 | SBU | Design | Tom Hemmick | SBU | TPC Final FCage | null | POM02.1.02.01.03 | C | 1.02 | 16709 |  | 1.02B | 03 | 1 | 1 | 180426 ELM rsrc per EOB |  |  |  |  |  |  |  |  |  |  |
| S112500 |  | TPC Field Cage Safety Review | 1d | 2021-03-30 A | 2021-03-31 A | S112400 | 100% | 2021-06-03 | 2021-06-03 |  | PROF4 PO M [4 h]; SCI3 PO [4 h] | 1,315.81 | S112500 | 0 | S107300 | TPC Field Cage Safety Review | S107300 | S112500 | CA | UDF_G2 | UDF_G3 | Not Started | B | Hemmick,Tom |  | SBU | Management Safety Reviews | Tom Hemmick | SBU |  |  | POM02.1.02.01.03 | C | 1.02 | 16709 |  | 1.02B | 03 | 1 | 1 |  | L5 |  |  |  |  |  |  |  |  |  |
| S112600 |  | Procurement Readiness Review - TPC Field Cage | 1d | 2021-03-30 A | 2021-03-31 A | S112400 | 100% | 2021-06-03 | 2021-06-03 |  | PROF4 PO M [4 h]; SCI3 PO [4 h] | 1,315.81 | S112600 | 0 | S107400 | TPC Field Cage Design Review | S107400 | S112600 | CA | UDF_G2 | UDF_G3 | Not Started | B | Hemmick,Tom |  | SBU | Management Tech Reviews | Tom Hemmick | SBU |  |  | POM02.1.02.01.03 | C | 1.02 | 16709 | 004 | 1.02B | 03 | 1 | 1 |  | L5 | 190522 IVS new name; 190415 ELM name per GRY |  |  |  |  |  |  |  |  |
| S112700 |  | Procure TPC v2 Field Cage Modification Parts Labor | 40d | 2021-03-30 A | 2021-03-31 A | S112400, S112500, S112600 | 100% | 2021-06-04 | 2021-07-30 |  | TECH3 PO M [32 h] | 3,761.47 | S112700 | 0 | S107500 | Procure TPC v2 Field Cage Modification Parts Labor | S107500 | S112700 | CA |  |  | Not Started | B | Hemmick,Tom | L4 | SBU | Procurement | Tom Hemmick | SBU | TPC Final FCage | null | POM02.1.02.01.03 | C | 1.02 | 16709 |  | 1.02B | 03 | 01 | 3 |  |  |  |  |  |  |  |  |  |  |  |
| S112800 |  | Procure TPC v2 Field Cage Modification Parts M&S | 40d | 2021-03-30 A | 2021-03-31 A | S112400, S112500, S112600, S126005 SS, OBLG126011 SS | 100% | 2021-06-04 | 2021-07-30 |  | SBU Contracted Purchase <$2M M&S [6000 h] | 6,964.11 | S112800 | 0 | S107600 | Procure TPC v2 Field Cage Modification Parts M&S | S107600 | S112800 | CA | UDF_G1 | UDF_G1 | Not Started | A-TEC | Hemmick,Tom | M5 | SBU | Fab & Assy | Tom Hemmick | SBU | TPC Final FCage | TEC | POM02.1.02.01.03 | C | 1.02 | 59702 | 003 | 1.02A | 03 | 01 | 5 |  |  | 190314 ELM RA per GRY | 6827.55474 | 1 | PP6 | MP208200 | Combined |  |  |  |
| S112900 |  | Modify TPC v2 Field Cage | 10d | 2021-03-30 A | 2021-03-31 A | S112700, S112800 | 100% | 2021-08-02 | 2021-08-13 |  | STUDENT SBU - Unpaid [80 h]; SCI4 SBU - Unpaid [80 h] |  | S112900 | 0 | S107700 | Modify TPC v2 Field Cage | S107700 | S112900 | CA |  |  | Not Started | T | Hemmick,Tom | L4 | SBU | Fab & Assy | Tom Hemmick | SBU | TPC Final FCage | null | POM02.1.02.01.03 | C | 1.02 | NA |  | 1.02B | 03 | 01 | 5 |  |  |  |  |  |  |  |  |  |  |  |
| S113000 |  | Benchtest TPC Final Field Cage | 10d | 2021-03-30 A | 2021-03-31 A | S112900 | 100% | 2021-08-16 | 2021-08-27 |  | STUDENT SBU - Unpaid [80 h]; SCI4 SBU - Unpaid [80 h] |  | S113000 | 0 | S107800 | Benchtest TPC Final Field Cage | S107800 | S113000 | CA |  |  | Not Started | T | Hemmick,Tom | L4 | SBU | Test_System | Tom Hemmick | SBU | TPC Final FCage | null | POM02.1.02.01.03 | C | 1.02 | NA |  | 1.02B | 03 | 01 | 7 |  |  |  |  |  |  |  |  |  |  |  |
|  | 04 | **TPC v1 Modules** |  | 2017-04-07 | 2019-12-02 |  |  |  |  |  |  |  |  |  |  |  |  |  |  |  |  |  |  |  |  |  |  |  |  |  |  |  |  |  |  |  |  |  |  |  |  |  |  |  |  |  |  |  |  |  |  |
|  | 01 | **TPC v1 Module Gas Enclosure** |  | 2017-04-07 | 2017-09-19 |  |  |  |  |  |  |  |  |  |  |  |  |  |  |  |  |  |  |  |  |  |  |  |  |  |  |  |  |  |  |  |  |  |  |  |  |  |  |  |  |  |  |  |  |  |  |
| S113400 |  | Assemble TPC v1 Module Gas Enclosure | 10d | 2017-04-07 A | 2017-04-20 A | S113200, S113300 | 100% |  |  |  |  |  | S113400 | 100 | S108200 | Assemble TPC v1 Module Gas Enclosure | S108200 |  | NOCA |  |  | Completed |  | Hemmick,Tom | L4 | SBU | Fab & Assy | Tom Hemmick | SBU | TPC v1 Mod | null | POM02.1.02.01.04.01 | C |  |  |  |  | 01 | 01 | 4 |  |  |  |  |  |  |  |  | yes |  |  |
| S113500 |  | Test TPC v1 Module Gas Enclosure | 5d | 2017-04-21 A | 2017-04-27 A | S113400 | 100% |  |  |  |  |  | S113500 | 100 | S108300 | Test TPC v1 Module Gas Enclosure | S108300 |  | NOCA |  |  | Completed |  | Hemmick,Tom | L4 | SBU | Test_Components | Tom Hemmick | SBU | TPC v1 Mod | null | POM02.1.02.01.04.01 | C |  |  |  |  | 01 | 01 | 4 |  |  |  |  |  |  |  |  | yes |  |  |
| S113100 |  | Design TPC v1 Module Gas Enclosure | 10d | 2017-09-05 A | 2017-09-18 A | S106600 | 100% |  |  |  |  |  | S113100 | 100 | S107900 | Design TPC v1 Module Gas Enclosure | S107900 |  | NOCA |  |  | Completed |  | Hemmick,Tom |  | SBU | Design | Tom Hemmick | SBU | TPC v1 Mod |  | POM02.1.02.01.04.01 |  |  |  |  |  | 01 | 1 | 1 |  |  |  |  |  |  |  |  | yes |  |  |
| S113200 |  | Procure TPC v1 Module Gas Enclosure Parts Labor | 0d | 2017-09-19 A | 2017-09-19 A | S113100 | 100% |  |  |  |  |  | S113200 | 100 | S108000 | Procure TPC v1 Module Gas Enclosure Parts Labor | S108000 |  | NOCA |  |  | Completed |  | Hemmick,Tom | L4 | SBU | Procurement | Tom Hemmick | SBU | TPC v1 Mod | null | POM02.1.02.01.04.01 | C |  |  |  |  | 01 | 01 | 2 |  |  |  |  |  |  |  |  | yes | 2018-03-29 |  |
| S113300 |  | Procure TPC v1 Module Gas Enclosure Parts M&S | 0d | 2017-09-19 A | 2017-09-19 A | S113100 | 100% |  |  |  |  |  | S113300 | 100 | S108100 | Procure TPC v1 Module Gas Enclosure Parts M&S | S108100 |  | NOCA |  |  | Completed |  | Hemmick,Tom | M4 | SBU | Fab & Assy | Tom Hemmick | SBU | TPC v1 Mod | OPC | POM02.1.02.01.04.01 | C |  |  |  |  | 01 | 01 | 4 |  |  |  |  |  |  |  |  | yes | 2018-03-29 | OPC000300 |
|  | 02 | **TPC v1 Module Common Mechanics** |  | 2017-09-05 | 2018-05-03 |  |  |  |  |  |  |  |  |  |  |  |  |  |  |  |  |  |  |  |  |  |  |  |  |  |  |  |  |  |  |  |  |  |  |  |  |  |  |  |  |  |  |  |  |  |  |
| S113600 |  | Design TPC v1 Module Strongback | 10d | 2017-09-05 A | 2017-09-18 A | S106600 | 100% |  |  |  |  |  | S113600 | 100 | S108400 | Design TPC v1 Module Strongback | S108400 |  | NOCA |  |  | Completed |  | Hemmick,Tom |  | SBU | Design | Tom Hemmick | SBU | TPC v1 Mod |  | POM02.1.02.01.04.02 |  |  |  |  |  | 02 | 1 | 1 |  |  |  |  |  |  |  |  | yes |  |  |
| S113900 |  | Design TPC v1 Module Frames | 62d | 2017-09-19 A | 2017-12-19 A | S113600 | 100% |  |  |  |  |  | S113900 | 100 | S108700 | Design TPC v1 Module Frames | S108700 |  | NOCA |  |  | Completed |  | Hemmick,Tom |  | SBU | Design | Tom Hemmick | SBU | TPC v1 Mod |  | POM02.1.02.01.04.02 |  |  |  |  |  | 02 | 1 | 1 |  |  |  |  |  |  |  |  | yes |  |  |
| S114200 |  | Design TPC v1 Module Grid | 62d | 2017-09-19 A | 2017-12-19 A | S113600 | 100% |  |  |  |  |  | S114200 | 100 | S109000 | Design TPC v1 Module Grid | S109000 |  | NOCA |  |  | Completed |  | Hemmick,Tom |  | SBU | Design | Tom Hemmick | SBU | TPC v1 Mod |  | POM02.1.02.01.04.02 |  |  |  |  |  | 02 | 1 | 1 |  |  |  |  |  |  |  |  | yes |  |  |
| S113700 |  | Procure TPC v1 Module Strongback - Labor | 20d | 2018-03-23 A | 2018-04-19 A | S113600, S114600 SS | 100% |  |  |  |  |  | S113700 | 100 | S108500 | Procure TPC v1 Module Strongback - Labor | S108500 |  | NOCA |  |  | Completed |  | Hemmick,Tom | L4 | SBU | Procurement | Tom Hemmick | SBU | TPC v1 Mod | null | POM02.1.02.01.04.02 | C |  |  |  |  | 02 | 01 | 2 |  |  |  |  |  |  |  |  | yes | 2018-04-19 |  |
| S113800 |  | Procure TPC v1 Module Strongback - M&S | 20d | 2018-03-23 A | 2018-04-19 A | S113600, S114600 SS | 100% |  |  |  |  |  | S113800 | 100 | S108600 | Procure TPC v1 Module Strongback - M&S | S108600 |  | NOCA |  |  | Completed |  | Hemmick,Tom | M4 | SBU | Fab & Assy | Tom Hemmick | SBU | TPC v1 Mod | OPC | POM02.1.02.01.04.02 | C |  |  |  |  | 02 | 01 | 4 |  |  |  |  |  |  |  |  | yes | 2018-04-19 | OPC000300 |
| S114000 |  | Procure TPC v1 Module Frames Labor | 30d | 2018-03-23 A | 2018-05-03 A | S113900, S114600 SS | 100% |  |  |  |  |  | S114000 | 100 | S108800 | Procure TPC v1 Module Frames Labor | S108800 |  | NOCA |  |  | Completed |  | Hemmick,Tom | L4 | SBU | Procurement | Tom Hemmick | SBU | TPC v1 Mod | null | POM02.1.02.01.04.02 | C |  |  |  |  | 02 | 01 | 2 |  |  |  |  |  |  |  |  | yes | 2018-05-03 |  |
| S114100 |  | Procure TPC v1 Module Frames M&S | 30d | 2018-03-23 A | 2018-05-03 A | S113900, S114600 SS | 100% |  |  |  |  |  | S114100 | 100 | S108900 | Procure TPC v1 Module Frames M&S | S108900 |  | NOCA |  |  | Completed |  | Hemmick,Tom | M4 | SBU | Fab & Assy | Tom Hemmick | SBU | TPC v1 Mod | OPC | POM02.1.02.01.04.02 | C |  |  |  |  | 02 | 01 | 4 |  |  |  |  |  |  |  |  | yes | 2018-05-03 | OPC000300 |
| S114300 |  | Procure TPC v1 Grid Parts Labor | 20d | 2018-03-23 A | 2018-04-19 A | S114200, S114600 SS | 100% |  |  |  |  |  | S114300 | 100 | S109100 | Procure TPC v1 Grid Parts Labor | S109100 |  | NOCA |  |  | Completed |  | Hemmick,Tom | L4 | SBU | Procurement | Tom Hemmick | SBU | TPC v1 Mod | null | POM02.1.02.01.04.02 | C |  |  |  |  | 02 | 01 | 2 |  |  |  |  |  |  |  |  | yes | 2018-04-19 |  |
| S114400 |  | Procure TPC v1 Grid Parts M&S | 20d | 2018-03-23 A | 2018-04-19 A | S114200, S114600 SS | 100% |  |  |  |  |  | S114400 | 100 | S109200 | Procure TPC v1 Grid Parts M&S | S109200 |  | NOCA |  |  | Completed |  | Hemmick,Tom | M4 | SBU | Fab & Assy | Tom Hemmick | SBU | TPC v1 Mod | OPC | POM02.1.02.01.04.02 | C |  |  |  |  | 02 | 01 | 4 |  |  |  |  |  |  |  |  | yes | 2018-04-19 | OPC000300 |
| S114600 |  | Preliminary Design Review - TPC Module | 1d | 2018-03-23 A | 2018-03-23 A | S113600, S113900 FS+63d, S114200 FS+63d | 100% |  |  |  |  |  | S114600 | 100 | S109400 | TPC v1 Module Internal Design Review | S109400 |  | NOCA |  |  | Completed |  | Hemmick,Tom |  | SBU | Management Tech Reviews | Tom Hemmick | SBU | TPC v1 Mod |  | POM02.1.02.01.04.02 |  |  |  | 004 |  | 02 | 1 | 1 |  |  | 190522 IVS new name; 190415 ELM name per GRY |  |  |  |  |  | yes |  |  |
| S114500 |  | Assemble TPC v1 Grid | 10d | 2018-04-20 A | 2018-05-03 A | S114300, S114400 | 100% |  |  |  |  |  | S114500 | 100 | S109300 | Assemble TPC v1 Grid | S109300 |  | NOCA |  |  | Completed |  | Hemmick,Tom | L4 | SBU | Fab & Assy | Tom Hemmick | SBU | TPC v1 Mod | null | POM02.1.02.01.04.02 | C |  |  |  |  | 02 | 01 | 4 |  |  |  |  |  |  |  |  | yes |  |  |

| ID | WBS | Activity | Duration | Start | Finish | Predecessors | Complete | Constraint | Resources | Cost | BNL_UDF_Temp Text 01 | BNL_UDF_Percent Complete | BNL_UDF_OPC TEC (deprecated) | BNL_UDF_Old Activity Name 181221 | BNL_UDF_Old Activity ID 181221 | RG Check | BNL_Activity Status | BNL_Estimator | BNL_Cost Basis | BNL_Location | BNL_EDIA | BNL_CAM | BNL_Institution | BNL_R&D FY18-19 | BNL_OPC TEC (deprecated) | BNL_WBS | BNL_EVT | BNL_WBS_Hierarchical | Completed | PMP Summary Part1 | PMP Summary Part2 | BNL_DOE OPC | BNL_UDF_Adhoc Comments | BNL_Fund Source | BNL_Account Number | BNL_UDF_Status Comments | BNL_Proc Sig Phase | BNL_Proc Sig | BNL_PCR ID | Cost = Awarded Proc or Mgmt | BNL_UDF_Temp Date 01 | BNL_Cobra WP | BNL_Master Control Account | BNL_Cobra Control Account |
| --- | --- | --- | --- | --- | --- | --- | --- | --- | --- | --- | --- | --- | --- | --- | --- | --- | --- | --- | --- | --- | --- | --- | --- | --- | --- | --- | --- | --- | --- | --- | --- | --- | --- | --- | --- | --- | --- | --- | --- | --- | --- | --- | --- | --- |
|  | 03 | **TPC v1a Module Prototype** |  | 2018-03-26 | 2018-07-06 |  |  |  |  |  |  |  |  |  |  |  |  |  |  |  |  |  |  |  |  |  |  |  |  |  |  |  |  |  |  |  |  |  |  |  |  |  |  |  |
| S114700 |  | Design TPC v1a Module Padplane | 10d | 2018-03-26 A | 2018-04-06 A | S106600, S114600 | 100% |  |  |  | S114700 | 100 | S109500 | Design TPC v1a Module Padplane | S109500 | NOCA | Completed | Hemmick,Tom | L4 | SBU | Design | Tom Hemmick | SBU | TPC v1 Mod | null | POM02.1.02.01.04.03 | C | 03 | yes | 1 | 1 |  |  |  |  |  |  |  |  |  |  |  |  |  |
| S114800 |  | Procure TPC v1a Module Padplane Labor | 20d | 2018-04-09 A | 2018-05-04 A | S114700 | 100% |  |  |  | S114800 | 100 | S109600 | Procure TPC v1a Module Padplane Labor | S109600 | NOCA | Completed | Hemmick,Tom | L4 | SBU | Procurement | Tom Hemmick | SBU | TPC v1 Mod | null | POM02.1.02.01.04.03 | C | 03 | yes | 01 | 2 |  |  |  |  |  |  |  |  |  |  |  |  |  |
| S114900 |  | Procure TPC v1a Module Padplane M&S | 20d | 2018-04-09 A | 2018-05-04 A | S114700 | 100% |  |  |  | S114900 | 100 | S109700 | Procure TPC v1a Module Padplane M&S | S109700 | NOCA | Completed | Hemmick,Tom | M5 | SBU | Fab & Assy | Tom Hemmick | SBU | TPC v1 Mod | OPC | POM02.1.02.01.04.03 | C | 03 | yes | 01 | 4 | OPC000300 |  |  |  |  |  |  |  |  |  |  |  |  |
| S115000 |  | Design TPC v1a Module GEMs | 5d | 2018-04-09 A | 2018-04-13 A | S114700 | 100% |  |  |  | S115000 | 100 | S109800 | Design TPC v1a Module GEMs | S109800 | NOCA | Completed | Hemmick,Tom | L4 | SBU | Design | Tom Hemmick | SBU | TPC v1 Mod | null | POM02.1.02.01.04.03 | C | 03 | yes | 1 | 1 |  | 180426 ELM rsrc per EOB |  |  |  |  |  |  |  |  |  |  |  |
| S115100 |  | Procure TPC v1a Module GEMs Labor | 20d | 2018-04-16 A | 2018-05-11 A | S115000 | 100% |  |  |  | S115100 | 100 | S109900 | Procure TPC v1a Module GEMs Labor | S109900 | NOCA | Completed | Hemmick,Tom | L4 | SBU | Procurement | Tom Hemmick | SBU | TPC v1 Mod | null | POM02.1.02.01.04.03 | C | 03 | yes | 01 | 2 |  |  |  |  |  |  |  |  |  |  |  |  |  |
| S115200 |  | Procure TPC v1a Module GEMs M&S | 20d | 2018-04-16 A | 2018-05-11 A | S115000 | 100% |  |  |  | S115200 | 100 | S110000 | Procure TPC v1a Module GEMs M&S | S110000 | NOCA | Completed | Hemmick,Tom | M3 | SBU | Fab & Assy | Tom Hemmick | SBU | TPC v1 Mod | OPC | POM02.1.02.01.04.03 | C | 03 | yes | 01 | 4 | OPC000300 |  |  |  |  |  |  |  |  |  |  |  |  |
| S115300 |  | Test TPC v1a Module GEMS | 5d | 2018-05-14 A | 2018-05-18 A | S115100, S115200 | 100% |  |  |  | S115300 | 100 | S110100 | Test TPC v1a Module GEMS | S110100 | NOCA | Completed | Hemmick,Tom | L4 | SBU | Test_Components | Tom Hemmick | SBU | TPC v1 Mod | null | POM02.1.02.01.04.03 | C | 03 | yes | 01 | 7 |  |  |  |  |  |  |  |  |  |  |  |  |  |
| S115400 |  | Frame TPC v1a Module GEMs | 5d | 2018-05-14 A | 2018-05-18 A | S115300 | 100% |  |  |  | S115400 | 100 | S110200 | Frame TPC v1a Module GEMs | S110200 | NOCA | Completed | Hemmick,Tom | L4 | SBU | Fab & Assy | Tom Hemmick | SBU | TPC v1 Mod | null | POM02.1.02.01.04.03 | C | 03 | yes | 01 | 4 |  |  |  |  |  |  |  |  |  |  |  |  |  |
| S115500 |  | Test TPC v1a Module Framed GEMs | 5d | 2018-05-29 A | 2018-06-04 A | S115400 | 100% |  |  |  | S115500 | 100 | S110300 | Test TPC v1a Module Framed GEMs | S110300 | NOCA | Completed | Hemmick,Tom | L4 | SBU | Test_Components | Tom Hemmick | SBU | TPC v1 Mod | null | POM02.1.02.01.04.03 | C | 03 | yes | 01 | 7 |  |  |  |  |  |  |  |  |  |  |  |  |  |
| S115600 |  | Assemble TPC v1a Module Prototype | 5d | 2018-06-05 A | 2018-06-11 A | S113700, S114000, S114500, S114800, S115500, S113800, S114100, S114900 | 100% |  |  |  | S115600 | 100 | S110400 | Assemble TPC v1a Module Prototype | S110400 | NOCA | Completed | Hemmick,Tom | L4 | SBU | Fab & Assy | Tom Hemmick | SBU | TPC v1 Mod | null | POM02.1.02.01.04.03 | C | 03 | yes | 01 | 4 |  |  |  |  |  |  |  |  |  |  |  |  |  |
| S115700 |  | Test TPC v1a Module Prototype | 18d | 2018-06-12 A | 2018-07-06 A | S113500, S115600 | 100% |  |  |  | S115700 | 100 | S110500 | Test TPC v1a Module Prototype | S110500 | NOCA | Completed | Hemmick,Tom | L4 | SBU | Test_Components | Tom Hemmick | SBU | TPC v1 Mod | null | POM02.1.02.01.04.03 | C | 03 | yes | 01 | 7 |  |  |  |  |  |  |  |  |  |  |  |  |  |
|  | 04 | **TPC v1b Module Prototype** |  | 2018-07-09 | 2019-12-02 |  |  |  |  |  |  |  |  |  |  |  |  |  |  |  |  |  |  |  |  |  |  |  |  |  |  |  |  |  |  |  |  |  |  |  |  |  |  |  |
| S115800 |  | Design TPC v1b Module Padplane | 59d | 2018-07-09 A | 2018-09-28 A | S115700 | 100% |  |  |  | S115800 | 100 | S110600 | Design TPC v1b Module Padplane | S110600 | NOCA | Completed | Hemmick,Tom | L4 | SBU | Design | Tom Hemmick | SBU | TPC v1 Mod | null | POM02.1.02.01.04.04 | C | 04 | yes | 1 | 1 |  |  |  |  |  |  |  |  |  |  |  |  |  |
| S116100 |  | Design TPC v1b Module GEMs | 41d | 2018-07-23 A | 2018-09-18 A | S115800 | 100% |  |  |  | S116100 | 100 | S110900 | Design TPC v1b Module GEMs | S110900 | NOCA | Completed | Hemmick,Tom | L4 | SBU | Design | Tom Hemmick | SBU | TPC v1 Mod | null | POM02.1.02.01.04.04 | C | 04 | yes | 1 | 1 |  | 180426 ELM rsrc per EOB |  |  |  |  |  |  |  |  |  |  |  |
| S115900 |  | Procure TPC v1b Module Padplane Labor | 20d | 2018-10-01 A | 2018-10-29 A | S115800 | 100% |  |  |  | S115900 | 100 | S110700 | Procure TPC v1b Module Padplane Labor | S110700 | NOCA | Completed | Hemmick,Tom | L4 | SBU | Procurement | Tom Hemmick | SBU | TPC v1 Mod | null | POM02.1.02.01.04.04 | C | 04 | yes | 01 | 2 |  |  | B | 16709 |  |  |  |  |  |  |  |  |  |
| S116000 |  | Procure TPC v1b Module Padplane M&S | 20d | 2018-10-01 A | 2018-10-29 A | S115800, S126000 SS, OBLG126001 SS | 100% |  |  |  | S116000 | 100 | S110800 | Procure TPC v1b Module Padplane M&S | S110800 | NOCA | Completed | Hemmick,Tom | M4 | SBU | Fab & Assy | Tom Hemmick | SBU | TPC v1 Mod | OPC | POM02.1.02.01.04.04 | C | 04 | yes | 01 | 4 | OPC000300 |  | A-OPC | 16701 | 190314 ELM RA per GRY | PP6 | MP208100 | 003 | Yes |  |  |  |  |
| S116200 |  | Procure TPC v1b Module GEMs Labor | 41d | 2018-10-01 A | 2018-11-30 A | S116100 | 100% |  |  |  | S116200 | 100 | S111000 | Procure TPC v1b Module GEMs Labor | S111000 | NOCA | Completed | Hemmick,Tom | L4 | SBU | Procurement | Tom Hemmick | SBU | TPC v1 Mod | null | POM02.1.02.01.04.04 | C | 04 | yes | 01 | 2 |  |  | B | 16709 |  |  |  |  |  |  |  |  |  |
| S116300 |  | Procure TPC v1b Module GEMs M&S | 41d | 2018-10-01 A | 2018-11-30 A | S116100, S126000 SS, OBLG126001 SS | 100% |  |  |  | S116300 | 100 | S111100 | Procure TPC v1b Module GEMs M&S | S111100 | NOCA | Completed | Hemmick,Tom | M3 | SBU | Fab & Assy | Tom Hemmick | SBU | TPC v1 Mod | OPC | POM02.1.02.01.04.04 | C | 04 | yes | 01 | 4 | OPC000300 |  | A-OPC | 16701 | 190314 ELM RA per GRY | PP6 | MP208100 | 003 | Yes |  |  |  |  |
| S116400 |  | Test TPC v1b Module GEMS | 20d | 2018-11-30 A | 2018-12-28 A | S116200, S116300 | 100% |  |  |  | S116400 | 100 | S111200 | Test TPC v1b Module GEMS | S111200 | NOCA | Completed | Hemmick,Tom | L4 | SBU | Test_Components | Tom Hemmick | SBU | TPC v1 Mod | null | POM02.1.02.01.04.04 | C | 04 | yes | 01 | 7 |  |  | T |  |  |  |  |  |  |  |  |  |  |
| S116500 |  | Frame TPC v1b Module GEMs | 113d | 2018-12-07 A | 2019-05-20 A | S116400 SS | 100% |  |  |  | S116500 | 20 | S111300 | Frame TPC v1b Module GEMs | S111300 | NOCA | Completed | Hemmick,Tom | L4 | SBU | Fab & Assy | Tom Hemmick | SBU | TPC v1 Mod | null | POM02.1.02.01.04.04 | C | 04 | yes | 01 | 4 |  |  | B_T | 16709 |  |  |  |  |  | 2019-02-11 |  |  |  |
| S116600 |  | Test TPC v1b Module Framed GEMs | 37d | 2019-04-10 A | 2019-05-31 A | S116500 | 100% |  |  |  | S116600 | 0 | S111400 | Test TPC v1b Module Framed GEMs | S111400 | NOCA | Completed | Hemmick,Tom | L4 | SBU | Test_Components | Tom Hemmick | SBU | TPC v1 Mod | null | POM02.1.02.01.04.04 | C | 04 | yes | 01 | 7 |  |  | B_T | 16709 |  |  |  |  |  |  |  |  |  |
| S116700 |  | Assemble TPC v1b Module Prototype | 32d | 2019-04-17 A | 2019-05-31 A | S115900, S116600, S116000 | 100% |  |  |  | S116700 | 0 | S111500 | Assemble TPC v1b Module Prototype | S111500 | NOCA | Completed | Hemmick,Tom | L4 | SBU | Fab & Assy | Tom Hemmick | SBU | TPC v1 Mod | null | POM02.1.02.01.04.04 | C | 04 | yes | 01 | 4 |  |  | T |  |  |  |  |  |  |  |  |  |  |
| S116800 |  | Test TPC v1b Module Prototype and Final Design Review | 73d | 2019-04-24 A | 2019-08-06 A | S116700 | 100% |  | STUDENT SBU - Unpaid [160 h]; TECH4 SBU - Unpaid [160 h] |  | S116800 | 0 | S111600 | Test TPC v1b Module Prototype | S111600 | CA | Completed | Hemmick,Tom | L4 | SBU | Test_Components | Tom Hemmick | SBU | TPC v1 Mod | null | POM02.1.02.01.04.04 | C | 04 |  | 01 | 7 |  |  | T | NA | 190415 ELM name per GRY |  |  | 004 |  |  | S116800 | 1.02 | 1.02B |
| S116801 |  | Final Design Review - TPC Module | 1d | 2019-12-02 A | 2019-12-02 A | S116800 FF | 100% | start on or after 2019-10-09 | PROF4 PO M [4 h]; SCI3 PO [4 h] | 1,277.48 | S116800 | 0 | S111600 | Test TPC v1b Module Prototype | S111600 | CA | Not Started | Hemmick,Tom | L4 | SBU | Test_Components | Tom Hemmick | SBU | TPC v1 Mod | null | POM02.1.02.01.04.04 | C | 04 |  | 01 | 7 |  |  | B | 16709 | 190522 IVS new act. |  |  | 004 |  |  | S116801 | 1.02 | 1.02B |

| ID | WBS | Activity | Duration | Start | Finish | Predecessors | Complete | Planned start | Planned finish | Resources | Cost | BNL_UDF_Temp Text 01 | BNL_UDF_Percent Complete | BNL_UDF_OPC TEC (deprecated) | BNL_UDF_Old Activity Name 181221 | BNL_UDF_Old Activity ID 181221 | BNL_Cobra WP | RG Check | BNL_Activity Status | BNL_Fund Source | BNL_Estimator | BNL_Cost Basis | BNL_Location | BNL_EDIA | BNL_CAM | BNL_Institution | BNL_R&D FY18-19 | BNL_OPC TEC (deprecated) | BNL_WBS | BNL_EVT | BNL_Master Control Account | BNL_Account Number | BNL_Cobra Control Account | BNL_WBS_Hierarchical | PMP Summary Part1 | PMP Summary Part2 | BNL_UDF_Status Comments | Indicator - Procurement | Indicator - Float | BNL_Proc Sig Phase | BNL_Proc Sig | BNL_DOE OPC | BNL_PCR ID | Cost = Awarded Proc or Mgmt | BNL_UDF_Adhoc Comments | BNL_Milestone Level |
| --- | --- | --- | --- | --- | --- | --- | --- | --- | --- | --- | --- | --- | --- | --- | --- | --- | --- | --- | --- | --- | --- | --- | --- | --- | --- | --- | --- | --- | --- | --- | --- | --- | --- | --- | --- | --- | --- | --- | --- | --- | --- | --- | --- | --- | --- | --- |
|  | 05 | **TPC v2 Modules** |  | 2019-07-03 | 2020-10-01 |  |  |  |  |  |  |  |  |  |  |  |  |  |  |  |  |  |  |  |  |  |  |  |  |  |  |  |  |  |  |  |  |  |  |  |  |  |  |  |  |  |
|  | 02 | **TPC v2 Module Common Mechanics** |  | 2020-01-14 | 2020-04-24 |  |  |  |  |  |  |  |  |  |  |  |  |  |  |  |  |  |  |  |  |  |  |  |  |  |  |  |  |  |  |  |  |  |  |  |  |  |  |  |  |  |
| S117600 |  | Procure TPC v2 Module Grid Parts Labor | 20d | 2020-01-14 A | 2020-01-28 A | S117500 | 100% | 2020-02-14 | 2020-03-13 | TECH3 PO M [24 h] | 2,738.93 | S117600 | 0 | S112400 | Procure TPC v2 Module Grid Parts Labor | S112400 | S117600 | CA | Not Started | B | Hemmick,Tom | L3 | SBU | Procurement | Tom Hemmick | SBU | TPC v2 Mod | null | POM02.1.02.01.05.02 | C | 1.02 | 16709 | 1.02B | 02 | 01 | 3 |  |  |  |  |  |  |  |  |  |  |
| S117700 |  | Procure TPC v2 Module Grid Parts M&S | 20d | 2020-01-14 A | 2020-01-28 A | S117500, S126000 SS, OBLG126001 SS | 100% | 2020-02-14 | 2020-03-13 | SBU Contracted Purchase <$2M M&S [500 h] | 568.96 | S117700 | 0 | S112500 | Procure TPC v2 Module Grid Parts M&S | S112500 | S117700 | CA | Not Started | A-OPC | Hemmick,Tom | M4 | SBU | Fab & Assy | Tom Hemmick | SBU | TPC v2 Mod | OPC | POM02.1.02.01.05.02 | F | 1.02 | 16701 | 1.02A | 02 | 01 | 5 | 190314 ELM RA per GRY | UDF_G1 | UDF_G1 | PP6 | MP208100 | OPC000400 | 003 | Yes |  |  |
| S117800 |  | Assemble TPC v2 Module Grid | 10d | 2020-01-14 A | 2020-01-28 A | S117600, S117700 | 100% | 2020-03-16 | 2020-03-27 | TECH3 PO M [80 h] | 9,129.77 | S117800 | 0 | S112600 | Assemble TPC v2 Module Grid | S112600 | S117800 | CA | Not Started | B | Hemmick,Tom | L3 | SBU | Fab & Assy | Tom Hemmick | SBU | TPC v2 Mod | null | POM02.1.02.01.05.02 | C | 1.02 | 16709 | 1.02B | 02 | 01 | 5 |  |  |  |  |  |  |  |  |  |  |
| S117500 |  | Design TPC v2 Module Grid | 10d | 2020-01-15 A | 2020-01-30 A | S109305, S109605, S110505, S111605 | 100% | 2020-01-31 | 2020-02-13 | SCI3 SBU - Unpaid [8 h]; TECH3 PO M [8 h]; PROF4 AM [8 h] | 2,091.1 | S117500 | 0 | S112300 | Design TPC v2 Module Grid | S112300 | S117500 | CA | Not Started | B_T | Hemmick,Tom | L3 | SBU | Design | Tom Hemmick | SBU | TPC v2 Mod | null | POM02.1.02.01.05.02 | C | 1.02 | 16709 | 1.02B | 02 | 1 | 1 |  |  |  |  |  |  |  |  | 180426 ELM rsrc per EOB |  |
| S116900 |  | Design TPC v2 Module Strongback | 10d | 2020-01-31 A | 2020-02-28 A | S109305, S109605, S110505, S111605 | 100% | 2020-01-31 | 2020-02-13 | SCI3 SBU - Unpaid [80 h]; STUDENT SBU - Unpaid [80 h]; PROF4 AM [80 h] | 11,781.2 | S116900 | 0 | S111700 | Design TPC v2 Module Strongback | S111700 | S116900 | CA | Not Started | B_T | Hemmick,Tom | L3 | SBU | Design | Tom Hemmick | SBU | TPC v2 Mod | null | POM02.1.02.01.05.02 | C | 1.02 | 16709 | 1.02B | 02 | 1 | 1 |  |  |  |  |  |  |  |  | 180426 ELM rsrc per EOB |  |
| S117200 |  | Design TPC v2 Module Frames | 10d | 2020-01-31 A | 2020-02-28 A | S109305, S109605, S110505, S111605 | 100% | 2020-01-31 | 2020-02-13 | SCI3 SBU - Unpaid [8 h]; TECH3 PO M [8 h]; PROF4 AM [8 h] | 2,091.1 | S117200 | 0 | S112000 | Design TPC v2 Module Frames | S112000 | S117200 | CA | Not Started | B_T | Hemmick,Tom | L3 | SBU | Design | Tom Hemmick | SBU | TPC v2 Mod | null | POM02.1.02.01.05.02 | C | 1.02 | 16709 | 1.02B | 02 | 1 | 1 |  |  |  |  |  |  |  |  | 180426 ELM rsrc per EOB |  |
| S117400 |  | Procure TPC v2 Module Frames M&S | 30d | 2020-02-04 A | 2020-04-24 A | S117200, S126000 SS, OBLG126001 SS | 100% | 2020-03-16 | 2020-04-24 | SBU Contracted Purchase <$2M M&S [1000 h] | 1,137.93 | S117400 | 0 | S112200 | Procure TPC v2 Module Frames M&S | S112200 | S117400 | CA | Not Started | A-OPC | Hemmick,Tom | M4 | SBU | Fab & Assy | Tom Hemmick | SBU | TPC v2 Mod | OPC | POM02.1.02.01.05.02 | C | 1.02 | 16701 | 1.02A | 02 | 01 | 5 | 190314 ELM RA per GRY | UDF_G2 | UDF_G3 | PP6 | MP208100 | OPC000400 | 003 | Yes |  |  |
| S117000 |  | Procure TPC v2 Module Strongback Labor | 20d | 2020-02-05 A | 2020-02-26 A | S116900 | 100% | 2020-03-16 | 2020-04-10 | TECH3 PO M [16 h] | 1,825.95 | S117000 | 0 | S111800 | Procure TPC v2 Module Strongback Labor | S111800 | S117000 | CA | Not Started | B | Hemmick,Tom | L3 | SBU | Procurement | Tom Hemmick | SBU | TPC v2 Mod | null | POM02.1.02.01.05.02 | C | 1.02 | 16709 | 1.02B | 02 | 01 | 3 |  |  |  |  |  |  |  |  |  |  |
| S117300 |  | Procure TPC v2 Module Frames Labor | 30d | 2020-02-11 A | 2020-02-28 A | S117200 | 100% | 2020-03-16 | 2020-04-24 | TECH3 PO M [24 h] | 2,738.93 | S117300 | 0 | S112100 | Procure TPC v2 Module Frames Labor | S112100 | S117300 | CA | Not Started | B | Hemmick,Tom | L3 | SBU | Procurement | Tom Hemmick | SBU | TPC v2 Mod | null | POM02.1.02.01.05.02 | C | 1.02 | 16709 | 1.02B | 02 | 01 | 3 |  |  |  |  |  |  |  |  |  |  |
| S117100 |  | Procure TPC v2 Module Strongback M&S | 20d | 2020-02-18 A | 2020-03-31 A | S116900, S126000 SS, OBLG126001 SS | 100% | 2020-03-16 | 2020-04-10 | SBU Contracted Purchase <$2M M&S [1200 h] | 1,365.51 | S117100 | 0 | S111900 | Procure TPC v2 Module Strongback M&S | S111900 | S117100 | CA | Not Started | A-OPC | Hemmick,Tom | M4 | SBU | Fab & Assy | Tom Hemmick | SBU | TPC v2 Mod | OPC | POM02.1.02.01.05.02 | F | 1.02 | 16701 | 1.02A | 02 | 01 | 5 | 190314 ELM RA per GRY | UDF_G2 | UDF_G3 | PP6 | MP208100 | OPC000400 | 003 | Yes |  |  |
|  | 03 | **TPC v2a Module Prototype** |  | 2019-07-03 | 2020-10-01 |  |  |  |  |  |  |  |  |  |  |  |  |  |  |  |  |  |  |  |  |  |  |  |  |  |  |  |  |  |  |  |  |  |  |  |  |  |  |  |  |  |
| S118900 |  | Test TPC v2a Module Prototype | 19d | 2019-07-03 A | 2019-07-30 A | S118800 | 100% |  |  | STUDENT SBU - Unpaid [160 h]; TECH4 SBU - Unpaid [160 h] |  | S118900 | 0 | S113700 | Test TPC v2a Module Prototype | S113700 | S118900 | CA | Completed | T | Hemmick,Tom | L3 | SBU | Test_Components | Tom Hemmick | SBU | TPC v2 Mod | null | POM02.1.02.01.05.03 | C | 1.02 | NA | 1.02B | 03 | 01 | 7 |  |  |  |  |  |  |  |  |  |  |
| S117900 |  | Design TPC v2a Module Padplane | 10d | 2020-01-31 A | 2020-03-25 A | S116801, S109305, S109605, S110505, S111605 | 100% | 2020-01-31 | 2020-02-13 | SCI3 SBU - Unpaid [80 h]; PROF4 PO E [80 h]; STUDENT SBU - Unpaid [160 h] | 11,781.2 | S117900 | 0 | S112700 | Design TPC v2a Module Padplane | S112700 | S117900 | CA | Not Started | B_T | Hemmick,Tom | L3 | SBU | Design | Tom Hemmick | SBU | TPC v2 Mod | null | POM02.1.02.01.05.03 | C | 1.02 | 16709 | 1.02B | 03 | 1 | 1 |  |  |  |  |  |  |  |  |  |  |
| S118200 |  | Design TPC v2a Module GEMs | 5d | 2020-02-14 A | 2020-02-28 A | S117900, S116801 | 100% | 2020-02-14 | 2020-02-21 | STUDENT SBU - Unpaid [160 h]; SCI3 SBU - Unpaid [160 h]; PROF4 AM [40 h] | 5,890.6 | S118200 | 0 | S113000 | Design TPC v2a Module GEMs | S113000 | S118200 | CA | Not Started | B_T | Hemmick,Tom | L3 | SBU | Design | Tom Hemmick | SBU | TPC v2 Mod | null | POM02.1.02.01.05.03 | C | 1.02 | 16709 | 1.02B | 03 | 1 | 1 |  |  |  |  |  |  |  |  | 180426 ELM rsrc per EOB |  |
| S118000 |  | Procure TPC v2a Module Padplane Labor | 20d | 2020-03-26 A | 2020-03-31 A | S117900 | 100% | 2020-03-26 | 2020-04-22 | TECH3 PO E [16 h] | 1,825.95 | S118000 | 0 | S112800 | Procure TPC v2a Module Padplane Labor | S112800 | S118000 | CA | Not Started | B | Hemmick,Tom | L3 | SBU | Procurement | Tom Hemmick | SBU | TPC v2 Mod | null | POM02.1.02.01.05.03 | C | 1.02 | 16709 | 1.02B | 03 | 01 | 3 |  |  |  |  |  |  |  |  |  |  |
| S118100 |  | Procure TPC v2a Module Padplane M&S | 20d | 2020-03-26 A | 2020-03-31 A | S117900, S126000 SS, OBLG126001 SS | 100% | 2020-03-26 | 2020-04-22 | SBU Contracted Purchase <$2M M&S [3700 h] | 4,210.33 | S118100 | 0 | S112900 | Procure TPC v2a Module Padplane M&S | S112900 | S118100 | CA | Not Started | A-OPC | Hemmick,Tom | M5 | SBU | Fab & Assy | Tom Hemmick | SBU | TPC v2 Mod | OPC | POM02.1.02.01.05.03 | F | 1.02 | 16701 | 1.02A | 03 | 01 | 5 | 190314 ELM RA per GRY | UDF_G2 | UDF_G3 | PP6 | MP208100 | OPC000400 | 003 | Yes |  |  |
| S118300 |  | Procure TPC v2a Module GEMs Labor | 40d | 2020-03-26 A | 2020-03-31 A | S118200 | 100% | 2020-03-26 | 2020-05-20 | TECH3 PO E [32 h] | 3,651.91 | S118300 | 0 | S113100 | Procure TPC v2a Module GEMs Labor | S113100 | S118300 | CA | Not Started | B | Hemmick,Tom | L3 | SBU | Procurement | Tom Hemmick | SBU | TPC v2 Mod | null | POM02.1.02.01.05.03 | C | 1.02 | 16709 | 1.02B | 03 | 01 | 3 |  |  |  |  |  |  |  |  |  |  |
| S118400 |  | Procure TPC v2a Module GEMs M&S | 40d | 2020-03-26 A | 2020-03-31 A | S118200, S126000 SS, OBLG126001 SS | 100% | 2020-03-26 | 2020-05-20 | SBU Contracted Purchase <$2M M&S [6500 h] | 7,396.52 | S118400 | 0 | S113200 | Procure TPC v2a Module GEMs M&S | S113200 | S118400 | CA | Not Started | A-OPC | Hemmick,Tom | M3 | SBU | Fab & Assy | Tom Hemmick | SBU | TPC v2 Mod | OPC | POM02.1.02.01.05.03 | C | 1.02 | 16701 | 1.02A | 03 | 01 | 5 | 190314 ELM RA per GRY | UDF_G2 | UDF_G3 | PP6 | MP208100 | OPC000400 | 003 | Yes |  |  |
| S118500 |  | Test TPC v2a Module GEMS | 5d | 2020-04-01 A | 2020-04-07 A | S118300, S118400 | 100% |  |  | STUDENT SBU - Unpaid [40 h]; TECH3 PO M [40 h] | 4,564.89 | S118500 | 0 | S113300 | Test TPC v2a Module GEMS | S113300 | S118500 | CA | Not Started | B_T | Hemmick,Tom | L3 | SBU | Test_Components | Tom Hemmick | SBU | TPC v2 Mod | null | POM02.1.02.01.05.03 | C | 1.02 | 16709 | 1.02B | 03 | 01 | 7 |  |  |  |  |  |  |  |  |  |  |
| S118800 |  | Assemble TPC v2a Module Prototype | 5d | 2020-04-02 A | 2020-04-24 A | S117000, S117300, S117800, S118000, S118700, S117100, S117400, S118100 | 100% | 2020-05-01 | 2020-05-07 | STUDENT SBU - Unpaid [40 h]; TECH4 SBU - Unpaid [40 h] |  | S118800 | 0 | S113600 | Assemble TPC v2a Module Prototype | S113600 | S118800 | CA | Not Started | T | Hemmick,Tom | L3 | SBU | Fab & Assy | Tom Hemmick | SBU | TPC v2 Mod | null | POM02.1.02.01.05.03 | C | 1.02 | NA | 1.02B | 03 | 01 | 5 |  |  |  |  |  |  |  |  |  |  |
| S118600 |  | Frame TPC v2a Module GEMs | 5d | 2020-04-08 A | 2020-04-14 A | S118500 | 100% |  |  | TECH3 PO M [40 h] | 4,564.89 | S118600 | 0 | S113400 | Frame TPC v2a Module GEMs | S113400 | S118600 | CA | Not Started | B | Hemmick,Tom | L3 | SBU | Fab & Assy | Tom Hemmick | SBU | TPC v2 Mod | null | POM02.1.02.01.05.03 | C | 1.02 | 16709 | 1.02B | 03 | 01 | 5 |  |  |  |  |  |  |  |  |  |  |
| S118700 |  | Test TPC v2a Module Framed GEMs | 5d | 2020-04-15 A | 2020-04-21 A | S118600 | 100% |  |  | STUDENT SBU - Unpaid [40 h]; TECH4 SBU - Unpaid [40 h] |  | S118700 | 0 | S113500 | Test TPC v2a Module Framed GEMs | S113500 | S118700 | CA | Not Started | T | Hemmick,Tom | L3 | SBU | Test_Components | Tom Hemmick | SBU | TPC v2 Mod | null | POM02.1.02.01.05.03 | C | 1.02 | NA | 1.02B | 03 | 01 | 7 |  |  |  |  |  |  |  |  |  |  |
| S119100 |  | Production Readiness Review - TPC Module | 1d | 2020-05-06 A | 2020-05-06 A | S119000 FS+2d | 100% |  |  | PROF4 PO M [4 h]; SCI3 PO [4 h] | 1,277.48 | S119100 | 0 | S113900 | TPC Module Design Review | S113900 | S119100 | CA | Not Started | B | Hemmick,Tom |  | SBU | Management Tech Reviews | Tom Hemmick | SBU | TPC v2 Mod |  | POM02.1.02.01.05.03 | C | 1.02 | 16709 | 1.02B | 03 | 1 | 1 | 190522 IVS new name; 190415 ELM name per GRY | UDF_G3 | UDF_G3 |  |  |  | 004 |  |  | L5 |
| S119000 |  | TPC Module Safety Review | 1d | 2020-10-01 A | 2020-10-01 A | S118900 FS+2d | 100% |  |  | PROF4 PO M [4 h]; SCI3 PO [4 h] | 1,315.81 | S119000 | 0 | S113800 | TPC Module Safety Review | S113800 | S119000 | CA | Not Started | B | Hemmick,Tom |  | SBU | Management Safety Reviews | Tom Hemmick | SBU | TPC v2 Mod |  | POM02.1.02.01.05.03 | C | 1.02 | 16709 | 1.02B | 03 | 1 | 1 |  | UDF_G3 | UDF_G3 |  |  |  |  |  |  | L5 |

Notes:
- S119000: General Comments: 180420 GYoung: concerning Safety / Review - this is safety check of the production / process

| ID | WBS | Activity | Type | Duration | Start | Finish | Predecessors | Complete | Planned start | Planned finish | Resources | Cost | BNL_UDF_Status Comments | BNL_UDF_Temp Text 01 | BNL_UDF_Percent Complete | BNL_UDF_OPC TEC (deprecated) | BNL_UDF_Old Activity ID 181221 | RG Check | BNL_Activity Status | BNL_Fund Source | BNL_Estimator | BNL_Cost Basis | BNL_Location | BNL_EDIA | BNL_Proc Sig Phase | BNL_Proc Sig | BNL_CAM | BNL_Institution | BNL_OPC TEC (deprecated) | BNL_WBS | BNL_EVT | BNL_PCR ID | BNL_WBS_Hierarchical | PMP Summary Part1 | PMP Summary Part2 | BNL_Cobra WP | BNL_Master Control Account | BNL_Account Number | BNL_Cobra Control Account | Indicator - Procurement | Indicator - Float | BNL_Milestone Level | SPH Proc Register | BNL_UDF_Remaining Tot Cost | BNL_UDF_Percent_remaining | BNL_Obligation | BNL_UDF_Adhoc Comments | Additional EVT documentation required | Target Milestone Date | Variance | PMP Milestones |
| --- | --- | --- | --- | --- | --- | --- | --- | --- | --- | --- | --- | --- | --- | --- | --- | --- | --- | --- | --- | --- | --- | --- | --- | --- | --- | --- | --- | --- | --- | --- | --- | --- | --- | --- | --- | --- | --- | --- | --- | --- | --- | --- | --- | --- | --- | --- | --- | --- | --- | --- | --- |
|  | 06 | **TPC Production GEM Acquisition** |  |  | 2019-08-01 | 2021-04-17 |  |  |  |  |  |  |  |  |  |  |  |  |  |  |  |  |  |  |  |  |  |  |  |  |  |  |  |  |  |  |  |  |  |  |  |  |  |  |  |  |  |  |  |  |  |
| S119200 |  | (Not needed) Train Technician to work in CERN Shop on TPC GEMs |  | 5d | 2019-08-01 A | 2019-08-07 A | S101000 | 100% |  |  |  |  | 190607 ELM review hours | S119200 | 0 | S114000 | S114000 | NOCA | Completed | T | Hemmick,Tom | L4 | SBU | Procurement | PP6 | MP100400 | Tom Hemmick | SBU | null | POM02.1.02.01.06 | C | 005 | 06 | 01 | 2 |  |  |  |  |  |  |  |  |  |  |  |  |  |  |  |  |
| S119300 |  | Procure Trained Technician to work in CERN Shop on TPC GEMs - Provide Requirements to Procurement |  | 5d | 2020-02-03 A | 2020-02-26 A | S119100, S119200, S123800 | 100% | 2020-06-22 | 2020-06-26 | TECH4 SBU - Unpaid [20 h] |  | 190607 ELM review hours | S119300 | 0 | S114300 | S114300 | CA | Not Started | T | Hemmick,Tom | L4 | CERN | Procurement | PP1 | MP100400 | Tom Hemmick | SBU | null | POM02.1.02.01.06 | C | 005 | 06 | 01 | 3 | S119300 | 1.02 | NA | 1.02B |  |  |  |  |  |  |  |  |  |  |  |  |
| S119400 |  | Procure Trained Technician to work in CERN Shop on TPC GEMs - Prepare & Send Solicitation |  | 30d | 2020-02-05 A | 2020-02-26 A | S119300 | 100% | 2020-06-29 | 2020-08-10 |  |  |  | S119400 | 0 | S114400 | S114400 | NOCA | Not Started |  | Hemmick,Tom |  | CERN | Procurement | PP2 | MP100400 | Tom Hemmick | SBU |  | POM02.1.02.01.06 |  |  | 06 | 01 | 3 |  |  |  |  |  |  |  |  |  |  |  |  |  |  |  |  |
| S119500 |  | Procure Trained Technician to work in CERN Shop on TPC GEMs - Vendor Responses |  | 10d | 2020-02-05 A | 2020-02-26 A | S119400 | 100% | 2020-08-11 | 2020-08-24 |  |  |  | S119500 | 0 | S114500 | S114500 | NOCA | Not Started |  | Hemmick,Tom |  | CERN | Procurement | PP3 | MP100400 | Tom Hemmick | SBU |  | POM02.1.02.01.06 |  |  | 06 | 01 | 3 |  |  |  |  |  |  |  |  |  |  |  |  |  |  |  |  |
| S119600 |  | Procure Trained Technician to work in CERN Shop on TPC GEMs - Vendor Selection |  | 20d | 2020-02-05 A | 2020-02-26 A | S119500 | 100% | 2020-08-25 | 2020-09-22 |  |  |  | S119600 | 0 | S114600 | S114600 | NOCA | Not Started |  | Hemmick,Tom |  | CERN | Procurement | PP4 | MP100400 | Tom Hemmick | SBU |  | POM02.1.02.01.06 |  |  | 06 | 01 | 3 |  |  |  |  |  |  |  |  |  |  |  |  |  |  |  |  |
| S119700 |  | Procure Trained Technician to work in CERN Shop on TPC GEMs - Contract Award(s) | milestone | 0d | 2020-05-07 A | 2020-05-07 A | S119600, S101000 | 100% |  |  |  |  |  | S119700 | 0 | S114700 | S114700 | NOCA | Not Started | A-TEC | Hemmick,Tom |  | CERN | Procurement | PP5 | MP100400 | Tom Hemmick | SBU |  | POM02.1.02.01.06 |  |  | 06 | 01 | 3 |  |  |  |  | UDF_G3 | UDF_G3 | L5 | Contract Award |  |  |  |  |  |  |  |  |
| S119900 |  | Procure Trained Technician to work in CERN Shop on TPC GEMs - Contract/PO - Leadtime |  | 5d | 2020-05-07 A | 2020-05-13 A | S119700 SS, S119800 SS, OBLG119710 SS, OBLG119701 SS | 100% |  |  |  |  |  | S119900 | 0 | S114800 | S114800 | NOCA | Not Started |  | Hemmick,Tom |  | CERN | Fab & Assy | PP6 | MP100400 | Tom Hemmick | SBU |  | POM02.1.02.01.06 |  |  | 06 | 01 | 5 |  |  |  |  |  |  |  |  |  |  |  |  |  |  |  |  |
| S120000 |  | Procure Trained Technician to work in CERN Shop on TPC GEMs - Delivery Acceptance |  | 5d | 2020-05-14 A | 2020-05-20 A | S119900 | 100% |  |  | SBU Contracted Purchase <$2M M&S [39080 h] | 44,470.14 | 190314 ELM RA per GRY | S120000 | 0 | S114100 | S114850 | CA | Not Started | A-TEC | Hemmick,Tom | M3 | CERN | Fab & Assy | PP6 | MP100400 | Tom Hemmick | SBU | TEC | POM02.1.02.01.06 | F | 003 | 06 | 01 | 5 | S120000 | 1.02 | 59702 | 1.02A | UDF_G3 | UDF_G3 |  | Delivery | 44470.139873 | 1 | FAB |  |  |  |  |  |
| S119800 |  | Procure Production of TPC GEM foils (includes Technician fees) - Contract Award(s) | milestone | 0d | 2020-05-20 A | 2020-05-20 A | S119600, S101000 | 100% | 2020-06-04 | 2020-06-04 |  |  |  | S119800 | 0 | S114700 | S114750 | NOCA | Not Started | A-TEC | Hemmick,Tom |  | CERN | Procurement | PP5 | MP100410 | Tom Hemmick | SBU |  | POM02.1.02.01.06 |  |  | 06 | 01 | 3 |  |  |  |  | UDF_G3 | UDF_G3 | L5 | Contract Award |  |  |  |  |  |  |  |  |
| S120100 |  | Procure Production of TPC GEM foils (includes Technician fees) - Delivery Acceptance |  | 126d | 2020-05-21 A | 2021-04-17 A | S120000, S119900 | 100% | 2020-05-21 | 2020-11-19 | SBU Contracted Purchase <$2M M&S [133200 h] | 152,389.72 | 190313 ELM BNLUnits, RA per GRY | S120100 | 0 | S114200 | S114870 | CA | Not Started | A-TEC | Hemmick,Tom | M3 | CERN | Fab & Assy | PP6 | MP100410 | Tom Hemmick | SBU | TEC | POM02.1.02.01.06 | C | 003 | 06 | 01 | 5 | S120100 | 1.02 | 59702 | 1.02A | UDF_G2 | UDF_G1 |  | Delivery | 152389.721461 | 1 | FAB | 180410 ELM pred per GRY | Yes |  |  |  |
| OBLG119701 |  | Procure Production of TPC GEM foils (includes Technician fees) - Obligation |  | 1d | 2020-09-04 A | 2020-09-04 A | S119600, S101000 | 100% |  |  | Obligation Resource [154603 h] | 154,603 |  | S119800 | 0 | S114700 | S114750 |  | Not Started | A-TEC | Hemmick,Tom |  | CERN | Procurement | PP5 | MP100410 | Tom Hemmick | SBU |  | POM02.1.02.01.06 |  |  | 06 |  |  |  |  |  |  |  |  | L5 |  |  |  | OBLG |  |  |  |  |  |
| OBLG119710 |  | Procure Train Technician to work in CERN Shop on TPC GEMs - Obligation |  | 1d | 2020-09-04 A | 2020-09-04 A | S119600, S101000 | 100% |  |  | Obligation Resource [45360 h] | 45,360 | 190314 ELM RA per GRY | S119700 | 0 | S114700 | S114700 |  | Not Started | A-TEC | Hemmick,Tom |  | CERN | Procurement | PP5 | MP100400 | Tom Hemmick | SBU |  | POM02.1.02.01.06 |  | 003 | 06 |  |  |  |  |  |  |  |  | L5 |  |  |  | OBLG |  |  |  |  |  |
| S120200 |  | GEM Production Complete | milestone | 0d | 2021-04-17 A | 2021-04-17 A | S120100 | 100% | 2021-05-17 | 2021-05-17 |  |  |  | S120200 | 0 | S114900 | S114900 | NOCA | Not Started |  | Hemmick,Tom |  | CERN | Fab & Assy |  |  | Tom Hemmick | SBU |  | POM02.1.02.01.06 |  |  | 06 | 01 | 5 |  |  |  |  | UDF_G3 | UDF_G3 | L2 |  |  |  |  | 180410 ELM pred per GRY |  | 2021-05-31 | 30 | PMP_1x |
|  | 07 | **TPC High Voltage System** |  |  | 2020-01-08 | 2020-10-30 |  |  |  |  |  |  |  |  |  |  |  |  |  |  |  |  |  |  |  |  |  |  |  |  |  |  |  |  |  |  |  |  |  |  |  |  |  |  |  |  |  |  |  |  |  |
| S120300 |  | Procure TPC Membrane HV Cables - Labor |  | 40d | 2020-01-08 A | 2020-01-27 A | S120600, S120500 | 100% | 2020-06-08 | 2020-08-03 | TECH3 PO M [32 h]; SCI3 SBU - Unpaid [32 h] | 3,651.91 |  | S120300 | 0 | S115300 | S115300 | CA | Not Started | B_T | Hemmick,Tom | L3 | SBU | Procurement |  |  | Tom Hemmick | SBU | null | POM02.1.02.01.07 | C |  | 07 | 01 | 3 | S120300 | 1.02 | 16709 | 1.02B |  |  |  |  |  |  |  | 180327 IVS Added S115000 as pred |  |  |  |  |
| S120400 |  | Procure TPC Membrane HV Cables - M&S |  | 40d | 2020-01-08 A | 2020-01-20 A | S120300 SS | 100% | 2020-06-08 | 2020-08-03 | SBU Contracted Purchase <$2M M&S [600 h] | 682.76 | 190314 ELM RA per GRY | S120400 | 0 | S115100 | S115100 | CA | Not Started | A-TEC | Hemmick,Tom | M3 | SBU | Fab & Assy | PP6 | MP208200 | Tom Hemmick | SBU | TEC | POM02.1.02.01.07 | C | 003 | 07 | 01 | 5 | S120400 | 1.02 | 59702 | 1.02A | UDF_G2 | UDF_G3 |  |  |  |  |  | 180327 IVS Added S115000 as pred |  |  |  |  |
| S120500 |  | Select TPC Membrane HV Power Supply |  | 10d | 2020-04-08 A | 2020-04-30 A | S118900, S119100 | 100% | 2020-05-08 | 2020-05-21 | SCI3 SBU - Unpaid [32 h] |  |  | S120500 | 0 | S115000 | S115000 | CA | Not Started | T | Hemmick,Tom | L3 | SBU | Procurement |  |  | Tom Hemmick | SBU | null | POM02.1.02.01.07 | C |  | 07 | 01 | 3 | S120500 | 1.02 | NA | 1.02B |  |  |  |  |  |  |  |  |  |  |  |  |
| S121200 |  | Procure TPC GEM HV Membrane Power Supply - Contract Award(s) | milestone | 0d | 2020-04-22 A | 2020-04-22 A | S121000, S101000 | 100% | 2020-08-25 | 2020-08-25 |  |  |  | S121200 | 0 | S116500 | S116550 | NOCA | Not Started | A-TEC | Hemmick,Tom |  | SBU | Procurement | PP5 | MP100610 | Tom Hemmick | SBU |  | POM02.1.02.01.07 |  |  | 07 | 01 | 3 |  |  |  |  |  |  | L5 | Contract Award |  |  |  |  |  |  |  |  |
| S121300 |  | Procure TPC GEM HV Power Supplies and Membrane Power Supply - Contract/PO - Leadtime |  | 70d | 2020-05-05 A | 2020-09-30 A | S121100 SS, S121200 SS, OBLG121110 SS, OBLG121210 SS | 100% | 2020-08-24 | 2020-12-04 |  |  |  | S121300 | 0 | S116600 | S116600 | NOCA | Not Started |  | Hemmick,Tom |  | SBU | Fab & Assy | PP6 | MP100600 | Tom Hemmick | SBU |  | POM02.1.02.01.07 |  |  | 07 | 01 | 5 |  |  |  |  |  |  |  |  |  |  |  |  |  |  |  |  |
| S120600 |  | Select TPC GEM HV Power Supplies |  | 10d | 2020-05-07 A | 2020-05-20 A | S118900, S119100 | 100% |  |  | SCI3 SBU - Unpaid [80 h] |  |  | S120600 | 0 | S115200 | S115200 | CA | Not Started | T | Hemmick,Tom | L3 | SBU | Procurement |  |  | Tom Hemmick | SBU | null | POM02.1.02.01.07 | C |  | 07 | 01 | 3 | S120600 | 1.02 | NA | 1.02B |  |  |  |  |  |  |  |  |  |  |  |  |
| S120700 |  | Procure TPC GEM HV Power Supplies and Membrane Power Supply - Provide Requirements to Procurement |  | 5d | 2020-05-21 A | 2020-05-28 A | S120500, S131800, S120600 | 100% |  |  | TECH3 PO M [32 h] | 3,651.91 |  | S120700 | 0 | S115400 | S115400 | CA | Not Started | B | Hemmick,Tom | L3 | SBU | Procurement | PP1 | MP100600 | Tom Hemmick | SBU | null | POM02.1.02.01.07 | C |  | 07 | 01 | 3 | S120700 | 1.02 | 16709 | 1.02B |  |  |  |  |  |  |  |  |  |  |  |  |
| S120800 |  | Procure TPC GEM HV Power Supplies and Membrane Power Supply - Prepare & Send Solicitation |  | 30d | 2020-05-29 A | 2020-06-30 A | S120700 | 100% | 2020-05-29 | 2020-07-10 |  |  |  | S120800 | 0 | S116200 | S116200 | NOCA | Not Started |  | Hemmick,Tom |  | SBU | Procurement | PP2 | MP100600 | Tom Hemmick | SBU |  | POM02.1.02.01.07 |  |  | 07 | 01 | 3 |  |  |  |  |  |  |  |  |  |  |  |  |  |  |  |  |
| S120900 |  | Procure TPC GEM HV Power Supplies and Membrane Power Supply - Vendor Responses |  | 10d | 2020-06-15 A | 2020-06-24 A | S120800 | 100% | 2020-07-13 | 2020-07-24 |  |  |  | S120900 | 0 | S116300 | S116300 | NOCA | Not Started |  | Hemmick,Tom |  | SBU | Procurement | PP3 | MP100600 | Tom Hemmick | SBU |  | POM02.1.02.01.07 |  |  | 07 | 01 | 3 |  |  |  |  |  |  |  |  |  |  |  |  |  |  |  |  |
| S121000 |  | Procure TPC GEM HV Power Supplies and Membrane Power Supply - Vendor Selection |  | 20d | 2020-06-15 A | 2020-06-24 A | S120900 | 100% | 2020-07-27 | 2020-08-21 |  |  |  | S121000 | 0 | S116400 | S116400 | NOCA | Not Started |  | Hemmick,Tom |  | SBU | Procurement | PP4 | MP100600 | Tom Hemmick | SBU |  | POM02.1.02.01.07 |  |  | 07 | 01 | 3 |  |  |  |  |  |  |  |  |  |  |  |  |  |  |  |  |
| S121100 |  | Procure TPC GEM HV Power Supplies - Contract Award(s) | milestone | 0d | 2020-06-15 A | 2020-06-15 A | S121000, S101000 | 100% | 2020-08-24 | 2020-08-24 |  |  |  | S121100 | 0 | S116500 | S116500 | NOCA | Not Started | A-TEC | Hemmick,Tom |  | SBU | Procurement | PP5 | MP100600 | Tom Hemmick | SBU |  | POM02.1.02.01.07 |  |  | 07 | 01 | 3 |  |  |  |  | UDF_G3 | UDF_G3 | L5 | Contract Award |  |  |  |  |  |  |  |  |
| OBLG121110 |  | Procure TPC GEM HV Power Supplies - Obligation |  | 1d | 2020-09-04 A | 2020-09-04 A | S121000, S101000 | 100% |  |  | Obligation Resource [125263 h] | 125,263 | 190314 ELM RA per GRY | S121100 | 0 | S116500 | S116500 |  | Not Started | A-TEC | Hemmick,Tom |  | SBU | Procurement | PP5 | MP100600 | Tom Hemmick | SBU |  | POM02.1.02.01.07 |  | 003 | 07 |  |  |  |  |  |  |  |  | L5 |  |  |  | OBLG |  |  |  |  |  |
| OBLG121210 |  | Procure TPC GEM HV Membrane Power Supply - Obligation |  | 1d | 2020-09-04 A | 2020-09-04 A | S121000, S101000 | 100% |  |  | Obligation Resource [12245.2 h] | 12,245.22 | 190314 ELM RA per GRY | S121200 | 0 | S116500 | S116550 |  | Not Started | A-TEC | Hemmick,Tom |  | SBU | Procurement | PP5 | MP100610 | Tom Hemmick | SBU |  | POM02.1.02.01.07 |  | 003 | 07 |  |  |  |  |  |  |  |  | L5 |  |  |  | OBLG |  |  |  |  |  |
| S121400 |  | Procure TPC GEM HV Power Supplies - Delivery Acceptance |  | 5d | 2020-09-22 A | 2020-10-30 A | S121300 | 100% | 2020-10-06 | 2020-10-13 | SBU Contracted Purchase <$2M M&S [107922 h] | 125,263.37 | 190313 ELM BNLUnits, RA per GRY | S121400 | 0 | S116700 | S116700 | CA | Not Started | A-TEC | Hemmick,Tom | M3 | SBU | Fab & Assy | PP6 | MP100600 | Tom Hemmick | SBU | TEC | POM02.1.02.01.07 | C | 003 | 07 | 01 | 5 | S121400 | 1.02 | 59702 | 1.02A | UDF_G2 | UDF_G3 |  | Delivery | 125263.372104 | 1 | FAB |  |  |  |  |  |
| S121500 |  | Procure TPC GEM HV Membrane Power Supply - Delivery Acceptance |  | 5d | 2020-10-06 A | 2020-10-13 A | S121300 | 100% |  |  | SBU Contracted Purchase <$2M M&S [10550 h] | 12,245.22 | 190313 ELM BNLUnits, RA per GRY | S121500 | 0 | S116000 | S116000 | CA | Not Started | A-TEC | Hemmick,Tom | M3 | SBU | Fab & Assy | PP6 | MP100610 | Tom Hemmick | SBU | TEC | POM02.1.02.01.07 | F | 003 | 07 | 01 | 5 | S121500 | 1.02 | 59702 | 1.02A | UDF_G3 | UDF_G3 |  | Delivery | 12245.219471 | 1 | FAB |  |  |  |  |  |

Notes:
- S119200: BNL_UDF_Old Activity Name 181221: Train Technician to work in CERN Shop on TPC GEMs
- S119300: BNL_UDF_Old Activity Name 181221: Procure TPC GEM Foils - Provide Requirements to Procurement
- S119400: BNL_UDF_Old Activity Name 181221: Procure TPC GEM Foils - Prepare & Send Solicitation
- S119500: BNL_UDF_Old Activity Name 181221: Procure TPC GEM Foils - Vendor Responses
- S119600: BNL_UDF_Old Activity Name 181221: Procure TPC GEM Foils - Vendor Selection
- S119700: BNL_UDF_Old Activity Name 181221: Procure Train Technician to work in CERN Shop on TPC GEMs - Contract Award(s)
- S119900: BNL_UDF_Old Activity Name 181221: Procure TPC GEM Foils - Contract/PO - Leadtime
- S120000: BNL_UDF_Old Activity Name 181221: Procure Train Technician to work in CERN Shop on TPC GEMs - Delivery Acceptance
- S119800: BNL_UDF_Old Activity Name 181221: Procure Production of TPC GEM foils (includes Technician fees) - Contract Award(s)
- S120100: BNL_UDF_Old Activity Name 181221: Procure Production of TPC GEM foils (includes Technician fees) - Delivery Acceptance
- OBLG119701: BNL_UDF_Old Activity Name 181221: Procure Production of TPC GEM foils (includes Technician fees) - Contract Award(s)
- OBLG119710: BNL_UDF_Old Activity Name 181221: Procure Train Technician to work in CERN Shop on TPC GEMs - Contract Award(s)
- S120200: BNL_UDF_Old Activity Name 181221: GEM Production Complete
- S120300: BNL_UDF_Old Activity Name 181221: Procure TPC Membrane HV Cables - Labor
- S120400: BNL_UDF_Old Activity Name 181221: Procure TPC Membrane HV Cables - M&S
- S120500: General Comments: 180420 GYoung: concerning Select / Membrane HVPower Supply - these are commercial items - specifically / customized catalog items / BNL_UDF_Old Activity Name 181221: Select TPC Membrane HV Power Supply
- S121200: BNL_UDF_Old Activity Name 181221: Procure TPC GEM HV Membrane Power Supply - Contract Award(s)
- S121300: BNL_UDF_Old Activity Name 181221: Procure TPC GEM HV Power Supplies and Membrane Power Supply - Contract/PO - Leadtime
- S120600: General Comments: 180420 GYoung: concerning Select / GEM HV Power Supplies - these are commercial items - specifically / customized catalog items / BNL_UDF_Old Activity Name 181221: Select TPC GEM HV Power Supplies
- S120700: BNL_UDF_Old Activity Name 181221: Procure TPC GEM HV Power Supplies and Membrane Power Supply - Provide Requirements to Procurement
- S120800: BNL_UDF_Old Activity Name 181221: Procure TPC GEM HV Power Supplies and Membrane Power Supply - Prepare & Send Solicitation
- S120900: BNL_UDF_Old Activity Name 181221: Procure TPC GEM HV Power Supplies and Membrane Power Supply - Vendor Responses
- S121000: BNL_UDF_Old Activity Name 181221: Procure TPC GEM HV Power Supplies and Membrane Power Supply - Vendor Selection
- S121100: BNL_UDF_Old Activity Name 181221: Procure TPC GEM HV Power Supplies - Contract Award(s)
- OBLG121110: BNL_UDF_Old Activity Name 181221: Procure TPC GEM HV Power Supplies - Contract Award(s)
- OBLG121210: BNL_UDF_Old Activity Name 181221: Procure TPC GEM HV Membrane Power Supply - Contract Award(s)
- S121400: BNL_UDF_Old Activity Name 181221: Procure TPC GEM HV Power Supplies - Delivery Acceptance
- S121500: BNL_UDF_Old Activity Name 181221: Procure TPC GEM HV Membrane Power Supply - Delivery Acceptance

| ID | WBS | Activity | Type | Duration | Start | Finish | Predecessors | Complete | Remaining | Planned start | Planned finish | Total float | Free float | Constraint | Expected finish | Resources | Cost | BNL_UDF_Status Comments | BNL_UDF_Temp Text 01 | BNL_UDF_Percent Complete | BNL_UDF_OPC TEC (deprecated) | BNL_UDF_Old Activity ID 181221 | BNL_Cobra WP | RG Check | Indicator - Procurement | Indicator - Float | BNL_UDF_Remaining Tot Cost | BNL_UDF_Percent_remaining | BNL_Activity Status | BNL_Fund Source | BNL_Estimator | BNL_Cost Basis | BNL_Location | BNL_EDIA | BNL_Proc Sig Phase | BNL_Proc Sig | BNL_CAM | BNL_Institution | BNL_OPC TEC (deprecated) | BNL_WBS | BNL_EVT | BNL_Master Control Account | BNL_Account Number | BNL_PCR ID | BNL_Cobra Control Account | BNL_WBS_Hierarchical | PMP Summary Part1 | PMP Summary Part2 | Target Milestone Date | Variance | BNL_Milestone Level | Additional EVT documentation required | PMP Milestones | BNL_R&D FY18-19 | Completed | Cost = Awarded Proc or Mgmt | BNL_DOE OPC | BNL_UDF_Temp Date 01 |
| --- | --- | --- | --- | --- | --- | --- | --- | --- | --- | --- | --- | --- | --- | --- | --- | --- | --- | --- | --- | --- | --- | --- | --- | --- | --- | --- | --- | --- | --- | --- | --- | --- | --- | --- | --- | --- | --- | --- | --- | --- | --- | --- | --- | --- | --- | --- | --- | --- | --- | --- | --- | --- | --- | --- | --- | --- | --- | --- |
|  | 08 | **TPC Assembly** |  |  | 2021-02-01 | 2022-01-31 |  |  |  |  |  |  |  |  |  |  |  |  |  |  |  |  |  |  |  |  |  |  |  |  |  |  |  |  |  |  |  |  |  |  |  |  |  |  |  |  |  |  |  |  |  |  |  |  |  |  |  |  |
| S121605 |  | TPC Assembly Mechanical Engineering Support |  | 243d | 2021-02-01 A | 2022-01-20 |  | 35% | 159d | 2021-03-01 | 2022-02-16 | 255d | 0d | start on or after 2021-02-01 | 2022-01-20 | PROF2 [1500 h] | 156,597.44 | 190313 ELM add per GRY | S121700 | 0 | S116900 | S116900 | S121605 | CA | UDF_G2 | UDF_G1 | 1279.07411 | 1 | Not Started | A-TEC | Hemmick,Tom | L4 | SBU | Fab & Assy | PP6 | MP208200 | Tom Hemmick | SBU | null | POM02.1.02.01.08 | C | 1.02 | 59702 | 020 | 1.02A | 08 | 01 | 5 |  |  |  |  |  |  |  |  |  |  |
| S121650 |  | Procure Piping Fittings |  | 10d | 2021-05-17 A | 2021-08-10 | S121610 SS, S126005 SS, S121601 | 50% | 11d | 2021-07-28 | 2021-08-10 | 48d | 0d |  | 2021-08-10 | SBU Contracted Purchase <$2M M&S [1102 h] | 1,279.07 | 190313 ELM add per GRY | S121700 | 0 | S116900 | S116900 | S121650 | CA | UDF_G2 | UDF_G1 | 1279.07411 | 1 | Not Started | A-TEC | Hemmick,Tom | L4 | SBU | Fab & Assy | PP6 | MP208200 | Tom Hemmick | SBU | null | POM02.1.02.01.08 | F | 1.02 | 59702 | 003 | 1.02A | 08 | 01 | 5 |  |  |  |  |  |  |  |  |  |  |
| S121950 |  | TPC Assembly technical Support |  | 116d | 2021-06-01 | 2021-11-15 |  |  |  |  |  | 54d | 50d | start on or after 2021-05-03 |  | Material (Purchase (1st $2M) [20000 h] | 23,333.76 |  | S121900 | 0 | S117100 | S117100 | S121950 | NOCA | UDF_G2 | UDF_G1 |  |  | Not Started | A-TEC | Hemmick,Tom |  | SBU | Fab & Assy |  |  | Tom Hemmick | SBU |  | POM02.1.02.01.08 |  |  |  | 017 | 1.02A | 08 | 01 | 5 | 2021-10-29 | 9 | L2 |  |  |  |  |  |  |  |
| S121600 |  | Production Readiness Review for TPC Final Assembly |  | 1d | 2021-07-26 | 2021-07-26 | S113000, S125600 SS+5d, S129600 SS+5d, S133800 SS+5d, S134000 SS+5d, S108700, S108800, S125605 SS+5d |  |  |  |  | 23d | 0d |  |  | SCI3 SBU - Unpaid [8 h]; TECH4 SBU - Unpaid [8 h] |  | 190415 ELM add per GRY | S121600 | 0 | S116800 | S116800 | S121600 | CA |  |  |  |  | Not Started | T | Hemmick,Tom | L4 | SBU | Fab & Assy |  |  | Tom Hemmick | SBU | null | POM02.1.02.01.08 | C | 1.02 | NA | 004 | 1.02B | 08 | 01 | 5 |  |  |  | Yes |  |  |  |  |  |  |
| S121601 |  | Final Design Review and Production Readiness Review - TPC Final Assembly | milestone | 0d | 2021-07-26 | 2021-07-26 | S121600 FF |  |  |  |  | 48d | 0d |  |  |  |  | 190522 IVS new name | S121600 | 0 | S116800 | S116800 |  | NOCA |  |  |  |  | Not Started | T | Hemmick,Tom | L4 | SBU | Fab & Assy |  |  | Tom Hemmick | SBU | null | POM02.1.02.01.08 | C |  |  | 004 |  | 08 | 01 | 5 |  |  |  | Yes |  |  |  |  |  |  |
| S121610 |  | Install TPC Modules into Field Cage |  | 36d | 2021-07-27 | 2021-09-15 | S121600 |  |  |  |  | 23d | 0d | start on or after 2020-01-01 |  | SCI3 SBU - Unpaid [576 h]; STUDENT SBU - Unpaid [4800 h]; TECH4 SBU - Unpaid [1920 h] |  | 190606 ELM need pred 121600 FS | S121600 | 0 | S116800 | S116800 | S121610 | CA |  |  |  |  | Not Started | T | Hemmick,Tom | L4 | SBU | Fab & Assy |  |  | Tom Hemmick | SBU | null | POM02.1.02.01.08 | C | 1.02 | NA | 005 | 1.02B | 08 | 01 | 5 |  |  |  | Yes |  |  |  |  |  |  |
| S121700 |  | Install TPC Electronics |  | 10d | 2021-10-14 | 2021-10-27 | S120200, S121610, S143300 SS+5d, S121650, S121601 |  |  |  |  | 4d | 0d |  |  | STUDENT SBU - Unpaid [400 h]; TECH3 PO M [160 h]; SCI3 SBU - Unpaid [48 h] | 19,371.55 |  | S121700 | 0 | S116900 | S116900 | S121700 | CA |  |  |  |  | Not Started | B_T | Hemmick,Tom | L4 | SBU | Fab & Assy |  |  | Tom Hemmick | SBU | null | POM02.1.02.01.08 | K | 1.02 | 16709 |  | 1.02B | 08 | 01 | 5 |  |  |  |  |  |  |  |  |  |  |
| S121800 |  | Test TPC Prior to Installation |  | 62d | 2021-10-28 | 2022-01-31 | S120300, S121700, S125700, S121400, S120400, S121500, S129700, S134100, S142500, S143400 FF, S147300, S147200, S147360 |  |  |  |  | 4d | 0d |  |  | STUDENT SBU - Unpaid [2600 h]; SCI3 SBU - Unpaid [312 h]; TECH4 SBU - Unpaid [520 h] |  |  | S121800 | 0 | S117000 | S117000 | S121800 | CA |  |  |  |  | Not Started | T | Hemmick,Tom | L4 | SBU | Test_Components |  |  | Tom Hemmick | SBU | null | POM02.1.02.01.08 | K | 1.02 | NA |  | 1.02B | 08 | 01 | 7 |  |  |  |  |  |  |  |  |  |  |
| S121900 |  | TPC Ready to Install (Assembly Complete) | milestone | 0d | 2022-01-31 | 2022-01-31 | S121800, S151100, S154000 FF, S156100, S121950 FF |  |  |  |  | 4d | 0d |  |  |  |  |  | S121900 | 0 | S117100 | S117100 |  | NOCA | UDF_G2 | UDF_G1 |  |  | Not Started |  | Hemmick,Tom |  | SBU | Fab & Assy |  |  | Tom Hemmick | SBU |  | POM02.1.02.01.08 |  |  |  |  |  | 08 | 01 | 5 | 2021-10-29 | -61 | L2 |  | PMP_1x |  |  |  |  |  |
|  | 02 | **TPC R1 Modules** |  |  | 2017-06-09 | 2021-09-20 |  |  |  |  |  |  |  |  |  |  |  |  |  |  |  |  |  |  |  |  |  |  |  |  |  |  |  |  |  |  |  |  |  |  |  |  |  |  |  |  |  |  |  |  |  |  |  |  |  |  |  |  |
|  | 01 | **TPC R1 Module Factory Preparation** |  |  | 2018-10-01 | 2019-07-31 |  |  |  |  |  |  |  |  |  |  |  |  |  |  |  |  |  |  |  |  |  |  |  |  |  |  |  |  |  |  |  |  |  |  |  |  |  |  |  |  |  |  |  |  |  |  |  |  |  |  |  |  |
| S122000 |  | Prepare TPC R1 Factory Clean Facility Labor |  | 26d | 2018-10-01 A | 2018-11-06 A | S114600, S126008 SS, OBLG126002 SS | 100% |  |  |  |  |  |  |  |  |  | 190313 ELM Activity split for fund src | S122000 | 100 | S117200 | S117200 |  | NOCA |  |  |  |  | Completed | A-OPC | Hemmick,Tom | L3 | Wayne | Fab & Assy | PP6 | MP204100 | Tom Hemmick | SBU | null | POM02.1.02.02.01 | C |  | 16701 | 003 |  | 01 | 01 | 4 |  |  |  |  |  | TPC R1-3 Fact.Prep | yes | Yes |  |  |
| S122005 |  | Prepare TPC R1 Factory Clean Facility Labor - Contributed Labor |  | 26d | 2018-10-01 A | 2018-11-06 A | S114600 | 100% |  |  |  |  |  |  |  |  |  | 190313 ELM Activity split for fund src | S122000 | 100 | S117200 | S117200 |  | NOCA |  |  |  |  | Completed | T | Hemmick,Tom | L3 | Wayne | Fab & Assy |  |  | Tom Hemmick | SBU | null | POM02.1.02.02.01 | C |  |  | 003 |  | 01 | 01 | 4 |  |  |  |  |  | TPC R1-3 Fact.Prep | yes |  |  |  |
| S122100 |  | Prepare TPC R1 Factory Clean Facility M&S |  | 26d | 2018-10-01 A | 2018-11-06 A | S114600, S126008 SS | 100% |  |  |  |  |  |  |  |  |  | 190314 ELM rsrc assgn per GRY | S122100 | 100 | S117300 | S117300 |  | NOCA |  |  |  |  | Completed | A-OPC | Hemmick,Tom | M4 | Wayne | Fab & Assy | PP6 | MP204100 | Tom Hemmick | SBU | OPC | POM02.1.02.02.01 | C |  | 16701 | 003 |  | 01 | 01 | 4 |  |  |  |  |  | TPC R1-3 Fact.Prep | yes | Yes | OPC000500 |  |
| S122200 |  | Prepare TPC R1 Factory Tooling Labor |  | 166d | 2018-10-01 A | 2019-05-31 A | S114600, S126008 SS | 100% |  |  |  |  |  |  |  |  |  | 190313 ELM Activity split for fund src | S122200 | 40 | S117400 | S117400 |  | NOCA |  |  |  |  | Completed | A-OPC | Hemmick,Tom | L3 | Wayne | Fab & Assy | PP6 | MP204100 | Tom Hemmick | SBU | null | POM02.1.02.02.01 | C |  | 16701 | 003 |  | 01 | 01 | 4 |  |  |  | Yes |  | TPC R1-3 Fact.Prep | yes | Yes |  | 2019-03-15 |
| S122205 |  | Prepare TPC R1 Factory Tooling Labor - Contributed Labor |  | 208d | 2018-10-01 A | 2019-07-31 A | S114600 | 100% |  |  |  |  |  |  |  | STUDENT Wayne - Unpaid [48 h] |  | 190313 ELM Activity split for fund src | S122200 | 40 | S117400 | S117400 | S122205 | CA |  |  |  |  | Completed | T | Hemmick,Tom | L3 | Wayne | Fab & Assy |  |  | Tom Hemmick | SBU | null | POM02.1.02.02.01 | C | 1.02 | NA | 003 | 1.02B | 01 | 01 | 4 |  |  |  | Yes |  | TPC R1-3 Fact.Prep |  |  |  |  |
| S122300 |  | Prepare TPC R1 Factory Tooling M&S |  | 166d | 2018-10-01 A | 2019-05-31 A | S114600, S126008 SS | 100% |  |  |  |  |  |  |  |  |  | 190314 ELM rsrc assgn per GRY | S122300 | 40 | S117500 | S117500 |  | NOCA |  |  |  |  | Completed | A-OPC | Hemmick,Tom | M4 | Wayne | Fab & Assy | PP6 | MP204100 | Tom Hemmick | SBU | OPC | POM02.1.02.02.01 | C |  | 16701 | 003 |  | 01 | 01 | 4 |  |  |  | Yes |  | TPC R1-3 Fact.Prep | yes | Yes | OPC000500 | 2019-03-15 |
| S122202 |  | Prepare TPC R1 Factory Tooling Labor Split |  | 22d | 2019-07-01 A | 2019-07-31 A | S122200 | 100% |  |  |  |  |  |  |  | PROF3 Wayne - Purchased Services [3 h] | 295.07 | 190313 ELM Activity split for fund src | S122200 | 40 | S117400 | S117400 | S122202 | CA |  |  |  |  | Completed | A-OPC | Hemmick,Tom | L3 | Wayne | Fab & Assy | PP6 | MP204100 | Tom Hemmick | SBU | null | POM02.1.02.02.01 | C | 1.02 | 16701 | 003 | 1.02A | 01 | 01 | 4 |  |  |  | Yes |  | TPC R1-3 Fact.Prep |  | Yes |  | 2019-03-15 |
| S122302 |  | Prepare TPC R1 Factory Tooling M&S Split |  | 22d | 2019-07-01 A | 2019-07-31 A | S122300 | 100% |  |  |  |  |  |  |  | Wayne Contracted Purchase <$2M M&S [2400 h] | 2,647.84 | 190314 ELM rsrc assgn per GRY | S122300 | 40 | S117500 | S117500 | S122302 | CA | UDF_G2 |  |  |  | Completed | A-OPC | Hemmick,Tom | M4 | Wayne | Fab & Assy | PP6 | MP204100 | Tom Hemmick | SBU | OPC | POM02.1.02.02.01 | C | 1.02 | 16701 | 003 | 1.02A | 01 | 01 | 4 |  |  |  | Yes |  | TPC R1-3 Fact.Prep |  | Yes | OPC000500 | 2019-03-15 |
|  | 02 | **TPC R1 Pre-Production Module** |  |  | 2018-10-30 | 2019-12-17 |  |  |  |  |  |  |  |  |  |  |  |  |  |  |  |  |  |  |  |  |  |  |  |  |  |  |  |  |  |  |  |  |  |  |  |  |  |  |  |  |  |  |  |  |  |  |  |  |  |  |  |  |
| S122400 |  | Design TPC R1 Pre-Production Module (strongback, frame, grid, pad, GEMs) |  | 21d | 2018-10-30 A | 2018-11-30 A | S115800, S115900, S116100 | 100% |  |  |  |  |  |  |  |  |  |  | S122400 | 100 | S117600 | S117600 |  | NOCA |  |  |  |  | Completed | B_T | Hemmick,Tom | L4 | BNL | Design |  |  | Tom Hemmick | SBU | null | POM02.1.02.02.02 | C |  | 16709 |  |  | 02 | 1 | 1 |  |  |  |  |  | TPC R1-3 Pre-pro Mod | yes |  |  |  |
| S122900 |  | Procure TPC R1 Pre-Production Module Grids - Labor |  | 20d | 2018-11-30 A | 2018-12-28 A | S122400 | 100% |  |  |  |  |  |  |  |  |  |  | S122900 | 100 | S118600 | S118600 |  | NOCA |  |  |  |  | Completed | B | Hemmick,Tom | L4 | BNL | Procurement |  |  | Tom Hemmick | SBU | null | POM02.1.02.02.02 | C |  | 16709 |  |  | 02 | 01 | 2 |  |  |  |  |  | TPC R1-3 Pre-pro Mod | yes |  |  |  |
| S123000 |  | Procure TPC R1 Pre-Production Module Grids - M&S |  | 20d | 2018-11-30 A | 2018-12-28 A | S122400, S122900 SS, S126000 SS, OBLG126001 SS | 100% |  |  |  |  |  |  |  |  |  | 190314 ELM rsrc assgn per GRY | S123000 | 100 | S118700 | S118700 |  | NOCA |  |  |  |  | Completed | A-OPC | Hemmick,Tom | M4 | BNL | Fab & Assy | PP6 | MP208100 | Tom Hemmick | SBU | OPC | POM02.1.02.02.02 | C |  | 16701 | 003 |  | 02 | 01 | 4 |  |  |  |  |  | TPC R1-3 Pre-pro Mod | yes | Yes | OPC000600 |  |
| S122500 |  | Procure TPC R1 Pre-Production Module Stongbacks - Labor |  | 101d | 2019-01-07 A | 2019-05-30 A | S122400 | 100% |  |  |  |  |  |  |  |  |  |  | S122500 | 5 | S117700 | S117700 |  | NOCA |  |  |  |  | Completed | B | Hemmick,Tom | L4 | BNL | Procurement |  |  | Tom Hemmick | SBU | null | POM02.1.02.02.02 | C |  | 16709 |  |  | 02 | 01 | 2 |  |  |  |  |  | TPC R1-3 Pre-pro Mod | yes |  |  | 2019-04-30 |
| S122600 |  | Procure TPC R1 Pre-Production Module Stongbacks - M&S |  | 101d | 2019-01-07 A | 2019-05-30 A | S122400, S122500 SS, S126000 SS, OBLG126001 SS | 100% |  |  |  |  |  |  |  |  |  | 190314 ELM rsrc assgn per GRY | S122600 | 5 | S117800 | S117800 |  | NOCA |  |  |  |  | Completed | A-OPC | Hemmick,Tom | M4 | BNL | Fab & Assy | PP6 | MP208100 | Tom Hemmick | SBU | OPC | POM02.1.02.02.02 | C |  | 16701 | 003 |  | 02 | 01 | 4 |  |  |  |  |  | TPC R1-3 Pre-pro Mod | yes | Yes | OPC000600 | 2019-04-30 |
| S123100 |  | Procure TPC R1 Pre-Production Module Pad Planes - Labor |  | 80d | 2019-01-07 A | 2019-04-30 A | S122400 | 100% |  |  |  |  |  |  |  |  |  |  | S123100 | 5 | S118800 | S118800 |  | NOCA |  |  |  |  | Completed | B | Hemmick,Tom | L4 | BNL | Procurement |  |  | Tom Hemmick | SBU | null | POM02.1.02.02.02 | C |  | 16709 |  |  | 02 | 01 | 2 |  |  |  |  |  | TPC R1-3 Pre-pro Mod | yes |  |  | 2019-04-30 |
| S123200 |  | Procure TPC R1 Pre-Production Module Pad Planes - M&S |  | 80d | 2019-01-07 A | 2019-04-30 A | S122400, S123100 SS, S126000 SS, OBLG126001 SS | 100% |  |  |  |  |  |  |  |  |  | 190314 ELM rsrc assgn per GRY | S123200 | 5 | S118900 | S118900 |  | NOCA |  |  |  |  | Completed | A-OPC | Hemmick,Tom | M4 | BNL | Fab & Assy | PP6 | MP208100 | Tom Hemmick | SBU | OPC | POM02.1.02.02.02 | C |  | 16701 | 003 |  | 02 | 01 | 4 |  |  |  |  |  | TPC R1-3 Pre-pro Mod | yes | Yes | OPC000600 | 2019-04-30 |
| S122700 |  | Procure TPC R1 Pre-Production Module Frames - Labor |  | 52d | 2019-02-15 A | 2019-04-30 A | S122400 | 100% |  |  |  |  |  |  |  |  |  |  | S122700 | 50 | S117900 | S117900 |  | NOCA |  |  |  |  | Completed | B | Hemmick,Tom | L4 | BNL | Procurement |  |  | Tom Hemmick | SBU | null | POM02.1.02.02.02 | C |  | 16709 |  |  | 02 | 01 | 2 |  |  |  |  |  | TPC R1-3 Pre-pro Mod | yes |  |  | 2019-03-07 |
| S122800 |  | Procure TPC R1 Pre-Production Module Frames - M&S |  | 52d | 2019-02-15 A | 2019-04-30 A | S122400, S122700 SS, S126000 SS, OBLG126001 SS | 100% |  |  |  |  |  |  |  |  |  | 190314 ELM rsrc assgn per GRY | S122800 | 50 | S118500 | S118500 |  | NOCA |  |  |  |  | Completed | A-OPC | Hemmick,Tom | M4 | BNL | Fab & Assy | PP6 | MP208100 | Tom Hemmick | SBU | OPC | POM02.1.02.02.02 | C |  | 16701 | 003 |  | 02 | 01 | 4 |  |  |  |  |  | TPC R1-3 Pre-pro Mod | yes | Yes | OPC000600 | 2019-03-07 |
| S123300 |  | Procure TPC R1 Pre-Production Module GEMs - Labor |  | 74d | 2019-02-15 A | 2019-05-31 A | S122400 | 100% |  |  |  |  |  |  |  |  |  |  | S123300 | 25 | S119000 | S119000 |  | NOCA |  |  |  |  | Completed | B | Hemmick,Tom | L4 | BNL | Procurement |  |  | Tom Hemmick | SBU | null | POM02.1.02.02.02 | C |  | 16709 |  |  | 02 | 01 | 2 |  |  |  |  |  | TPC R1-3 Pre-pro Mod | yes |  |  | 2019-04-30 |
| S123400 |  | Procure TPC R1 Pre-Production Module GEMs - M&S |  | 74d | 2019-02-15 A | 2019-05-31 A | S122400, S123300 SS, S126000 SS, OBLG126001 SS | 100% |  |  |  |  |  |  |  |  |  | 190314 ELM rsrc assgn per GRY | S123400 | 25 | S119100 | S119100 |  | NOCA |  |  |  |  | Completed | A-OPC | Hemmick,Tom | M4 | BNL | Fab & Assy | PP6 | MP208100 | Tom Hemmick | SBU | OPC | POM02.1.02.02.02 | C |  | 16701 | 003 |  | 02 | 01 | 4 |  |  |  |  |  | TPC R1-3 Pre-pro Mod | yes | Yes | OPC000600 | 2019-04-30 |
| S123500 |  | Assemble TPC R1 Pre-Production Module in TPC R1 Factory |  | 22d | 2019-05-01 A | 2019-05-31 A | S122500, S122700, S122900, S123100, S123300, S122600, S122800, S123000, S123200, S123400, S122000, S122100, S122300, S122005, S122205, S126008 SS, S122202, S122302 | 100% |  |  |  |  |  |  |  |  |  | 190313 ELM Activity split for fund src | S123500 | 0 | S119200 | S119200 |  | NOCA |  |  |  |  | Completed | A-OPC | Hemmick,Tom | L4 | Wayne | Fab & Assy | PP6 | MP204100 | Tom Hemmick | SBU | null | POM02.1.02.02.02 | C |  | 16701 | 003 |  | 02 | 01 | 4 |  |  |  |  |  | TPC R1-3 Pre-pro Mod | yes | Yes |  |  |
| S123505 |  | Assemble TPC R1 Pre-Production Module in TPC R1 Factory - Contributed Labor |  | 22d | 2019-05-01 A | 2019-05-31 A | S122500, S122700, S122900, S123100, S123300, S122600, S122800, S123000, S123200, S123400, S122000, S122100, S122300, S122005, S122205, S122202, S122302 | 100% |  |  |  |  |  |  |  |  |  | 190313 ELM Activity split for fund src | S123500 | 0 | S119200 | S119200 |  | NOCA |  |  |  |  | Completed | T | Hemmick,Tom | L4 | Wayne | Fab & Assy |  |  | Tom Hemmick | SBU | null | POM02.1.02.02.02 | C |  |  | 003 |  | 02 | 01 | 4 |  |  |  |  |  | TPC R1-3 Pre-pro Mod | yes |  |  |  |
| S123600 |  | Test TPC R1 Pre-Production Module |  | 6d | 2019-07-01 A | 2019-07-09 A | S123500, S126008 SS | 100% |  |  |  |  |  |  |  | PROF3 Wayne - Purchased Services [80 h] | 7,868.49 | 190313 ELM Activity split for fund src | S123600 | 0 | S119300 | S119300 | S123600 | CA |  |  |  |  | Completed | A-OPC | Hemmick,Tom | L4 | Wayne | Test_Components | PP6 | MP204100 | Tom Hemmick | SBU | null | POM02.1.02.02.02 | C | 1.02 | 16701 | 003 | 1.02A | 02 | 01 | 7 |  |  |  |  |  | TPC R1-3 Pre-pro Mod |  | Yes |  |  |
| S123605 |  | Test TPC R1 Pre-Production Module - Contributed Labor |  | 5d | 2019-07-01 A | 2019-07-08 A | S123505 | 100% |  |  |  |  |  |  |  | STUDENT Wayne - Unpaid [80 h] |  | 190313 ELM Activity split for fund src | S123600 | 0 | S119300 | S119300 | S123605 | CA |  |  |  |  | Completed | T | Hemmick,Tom | L4 | Wayne | Test_Components |  |  | Tom Hemmick | SBU | null | POM02.1.02.02.02 | C | 1.02 | NA | 003 | 1.02B | 02 | 01 | 7 |  |  |  |  |  | TPC R1-3 Pre-pro Mod |  |  |  |  |
| S123700 |  | Common production line & QA certification |  | 80d | 2019-07-25 A | 2019-10-31 A | S123600, S123605, S126008 SS | 100% |  | 2019-08-12 | 2019-12-06 |  |  |  |  | Wayne Contracted Purchase <$2M M&S [95000 h] | 106,662.36 | 190314 ELM rsrc assgn, dur per GRY | S123700 | 0 | S119300 | S119350 | S123700 | CA | UDF_G3 |  |  |  | Completed | A-OPC | Hemmick,Tom | M4 | Wayne | Test_Components | PP6 | MP204100 | Tom Hemmick | SBU | null | POM02.1.02.02.02 | C | 1.02 | 16701 | 003 | 1.02A | 02 | 01 | 7 |  |  |  |  |  | TPC R1-3 Pre-pro Mod |  | Yes |  |  |
| S123800 |  | Production Readiness Review - TPC Module Factories |  | 1d | 2019-12-17 A | 2019-12-17 A | S127800, S131800, S132000, S123600, S123605 | 100% |  | 2019-12-02 | 2019-12-02 |  |  |  |  | PROF4 PO M [4 h]; SCI3 PO [4 h] | 1,277.48 | 190522 IVS new name; 190415 ELM name per GRY | S123800 | 0 | S119400 | S119400 | S123800 | CA |  |  |  |  | Not Started | B | Hemmick,Tom |  | BNL | Management Tech Reviews |  |  | Tom Hemmick | SBU |  | POM02.1.02.02.02 | C | 1.02 | 16709 | 004 | 1.02B | 02 | 1 | 1 | 2019-12-31 | 8 | L2 |  | PMP_1x | TPC R1-3 Pre-pro Mod |  |  |  |  |

Notes:
- S121605: BNL_UDF_Old Activity Name 181221: Install TPC Electronics
- S121650: BNL_UDF_Old Activity Name 181221: Install TPC Electronics
- S121950: BNL_UDF_Old Activity Name 181221: TPC Ready to Install (Assembly Complete)
- S121600: BNL_UDF_Old Activity Name 181221: Install TPC Modules into Field Cage
- S121601: BNL_UDF_Old Activity Name 181221: Install TPC Modules into Field Cage
- S121610: BNL_UDF_Old Activity Name 181221: Install TPC Modules into Field Cage
- S121700: BNL_UDF_Old Activity Name 181221: Install TPC Electronics
- S121800: BNL_UDF_Old Activity Name 181221: Test TPC Prior to Installation
- S121900: BNL_UDF_Old Activity Name 181221: TPC Ready to Install (Assembly Complete)
- S122000: BNL_UDF_Old Activity Name 181221: Prepare TPC R1 Factory Clean Facility Labor
- S122005: BNL_UDF_Old Activity Name 181221: Prepare TPC R1 Factory Clean Facility Labor
- S122100: BNL_UDF_Old Activity Name 181221: Prepare TPC R1 Factory Clean Facility M&S
- S122200: BNL_UDF_Old Activity Name 181221: Prepare TPC R1 Factory Tooling Labor
- S122205: BNL_UDF_Old Activity Name 181221: Prepare TPC R1 Factory Tooling Labor
- S122300: BNL_UDF_Old Activity Name 181221: Prepare TPC R1 Factory Tooling M&S
- S122202: BNL_UDF_Old Activity Name 181221: Prepare TPC R1 Factory Tooling Labor
- S122302: BNL_UDF_Old Activity Name 181221: Prepare TPC R1 Factory Tooling M&S
- S122400: BNL_UDF_Old Activity Name 181221: Design TPC R1 Pre-Production Module (strongback, frame, grid, pad, GEMs)
- S122900: BNL_UDF_Old Activity Name 181221: Procure TPC R1 Pre-Production Module Grids - Labor
- S123000: BNL_UDF_Old Activity Name 181221: Procure TPC R1 Pre-Production Module Grids - M&S
- S122500: BNL_UDF_Old Activity Name 181221: Procure TPC R1 Pre-Production Module Stongbacks - Labor
- S122600: BNL_UDF_Old Activity Name 181221: Procure TPC R1 Pre-Production Module Stongbacks - M&S
- S123100: BNL_UDF_Old Activity Name 181221: Procure TPC R1 Pre-Production Module Pad Planes - Labor
- S123200: BNL_UDF_Old Activity Name 181221: Procure TPC R1 Pre-Production Module Pad Planes - M&S
- S122700: BNL_UDF_Old Activity Name 181221: Procure TPC R1 Pre-Production Module Frames - Labor
- S122800: BNL_UDF_Old Activity Name 181221: Procure TPC R1 Pre-Production Module Frames - M&S
- S123300: BNL_UDF_Old Activity Name 181221: Procure TPC R1 Pre-Production Module GEMs - Labor
- S123400: BNL_UDF_Old Activity Name 181221: Procure TPC R1 Pre-Production Module GEMs - M&S
- S123500: BNL_UDF_Old Activity Name 181221: Assemble TPC R1 Pre-Production Module in TPC R1 Factory
- S123505: BNL_UDF_Old Activity Name 181221: Assemble TPC R1 Pre-Production Module in TPC R1 Factory
- S123600: BNL_UDF_Old Activity Name 181221: Test TPC R1 Pre-Production Module
- S123605: BNL_UDF_Old Activity Name 181221: Test TPC R1 Pre-Production Module
- S123700: BNL_UDF_Old Activity Name 181221: Common production line & QA certification
- S123800: BNL_UDF_Old Activity Name 181221: TPC Module Preproduction Readiness Review

| ID | WBS | Activity | Type | Duration | Start | Finish | Predecessors | Complete | Remaining | Planned start | Planned finish | Total float | Free float | Expected finish | Resources | Cost | BNL_UDF_Temp Text 01 | BNL_UDF_Percent Complete | BNL_UDF_OPC TEC (deprecated) | BNL_UDF_Old Activity ID 181221 | BNL_Cobra WP | RG Check | BNL_Activity Status | BNL_Fund Source | BNL_Estimator | BNL_Cost Basis | BNL_Location | BNL_EDIA | BNL_Proc Sig Phase | BNL_Proc Sig | BNL_CAM | BNL_Institution | BNL_OPC TEC (deprecated) | BNL_WBS | BNL_EVT | BNL_Master Control Account | BNL_Account Number | BNL_Cobra Control Account | BNL_WBS_Hierarchical | PMP Summary Part1 | PMP Summary Part2 | BNL_Milestone Level | SPH Proc Register | BNL_UDF_Status Comments | BNL_Obligation | BNL_PCR ID | Indicator - Procurement | Indicator - Float | BNL_UDF_Remaining Tot Cost | BNL_UDF_Percent_remaining | Additional EVT documentation required |
| --- | --- | --- | --- | --- | --- | --- | --- | --- | --- | --- | --- | --- | --- | --- | --- | --- | --- | --- | --- | --- | --- | --- | --- | --- | --- | --- | --- | --- | --- | --- | --- | --- | --- | --- | --- | --- | --- | --- | --- | --- | --- | --- | --- | --- | --- | --- | --- | --- | --- | --- | --- |
|  | 03 | **TPC R1 Module Production** |  |  | 2019-10-02 | 2021-09-20 |  |  |  |  |  |  |  |  |  |  |  |  |  |  |  |  |  |  |  |  |  |  |  |  |  |  |  |  |  |  |  |  |  |  |  |  |  |  |  |  |  |  |  |  |  |
| S123900 |  | Procure TPC R1 Module Prod. Parts (Frames, Strongbacks, Padplanes, Grids) - Provide Requirements to Procurement |  | 5d | 2019-10-02 A | 2019-10-08 A | S123800 | 100% |  |  |  |  |  |  | TECH3 PO M [128 h]; PROF4 AM [64 h] | 24,032.59 | S123900 | 0 | S119500 | S119500 | S123900 | CA | Completed | B | Hemmick,Tom | L3 | BNL | Procurement | PP1 | MP100800 | Tom Hemmick | SBU | null | POM02.1.02.02.03 | C | 1.02 | 16709 | 1.02B | 03 | 01 | 3 |  |  |  |  |  |  |  |  |  |  |
| S124000 |  | Procure TPC R1 Module Prod. Parts (Frames, Strongbacks, Padplanes, Grids) - Prepare & Send Solicitation |  | 30d | 2019-10-09 A | 2019-12-31 A | S123900 | 100% |  | 2019-10-09 | 2019-11-21 |  |  |  |  |  | S124000 | 0 | S119600 | S119600 |  | NOCA | In Progress |  | Hemmick,Tom |  | BNL | Procurement | PP2 | MP100800 | Tom Hemmick | SBU |  | POM02.1.02.02.03 |  |  |  |  | 03 | 01 | 3 |  |  |  |  |  |  |  |  |  |  |
| S124100 |  | Procure TPC R1 Module Prod. Parts (Frames, Strongbacks, Padplanes, Grids) - Vendor Responses |  | 10d | 2019-11-01 A | 2019-12-31 A | S124000 | 100% |  | 2019-12-19 | 2020-01-03 |  |  |  |  |  | S124100 | 0 | S119700 | S119700 |  | NOCA | In Progress |  | Hemmick,Tom |  | BNL | Procurement | PP3 | MP100800 | Tom Hemmick | SBU |  | POM02.1.02.02.03 |  |  |  |  | 03 | 01 | 3 |  |  |  |  |  |  |  |  |  |  |
| S124200 |  | Procure TPC R1 Module Prod. Parts (Frames, Strongbacks, Padplanes, Grids) - Vendor Selection |  | 20d | 2019-11-06 A | 2020-02-03 A | S124100 | 100% |  | 2020-01-06 | 2020-02-03 |  |  |  |  |  | S124200 | 0 | S119800 | S119800 |  | NOCA | In Progress |  | Hemmick,Tom |  | BNL | Procurement | PP4 | MP100800 | Tom Hemmick | SBU |  | POM02.1.02.02.03 |  |  |  |  | 03 | 01 | 3 |  |  |  |  |  |  |  |  |  |  |
| S124300 |  | Procure TPC R1 Module Parts (Frames) - Contract Award(s) | milestone | 0d | 2020-02-04 A | 2020-02-04 A | S124200, S101000, S101010 | 100% |  |  |  |  |  |  |  |  | S124300 | 0 | S119900 | S119900 |  | NOCA | Not Started | A-TEC | Hemmick,Tom |  | BNL | Procurement | PP5 | MP100810 | Tom Hemmick | SBU |  | POM02.1.02.02.03 |  |  |  |  | 03 | 01 | 3 | L5 | Contract Award |  |  |  |  |  |  |  |  |
| S124400 |  | Procure TPC R1 Module Parts (Frames) - Contract/PO - Leadtime |  | 40d | 2020-02-04 A | 2020-03-31 A | S124300 SS, OBLG124310 SS | 100% |  |  |  |  |  |  |  |  | S124400 | 0 | S120000 | S120000 |  | NOCA | Not Started |  | Hemmick,Tom |  | BNL | Fab & Assy | PP6 | MP100810 | Tom Hemmick | SBU |  | POM02.1.02.02.03 |  |  |  |  | 03 | 01 | 5 |  |  |  |  |  |  |  |  |  |  |
| S124600 |  | Procure TPC R1 Module Parts (Strongbacks) - Contract Award(s) | milestone | 0d | 2020-02-04 A | 2020-02-04 A | S124200, S101000, S101010 | 100% |  |  |  |  |  |  |  |  | S124600 | 0 | S119900 | S120110 |  | NOCA | Not Started | A-TEC | Hemmick,Tom |  | BNL | Procurement | PP5 | MP100820 | Tom Hemmick | SBU |  | POM02.1.02.02.03 |  |  |  |  | 03 | 01 | 3 | L5 | Contract Award |  |  |  |  |  |  |  |  |
| S124700 |  | Procure TPC R1 Module Parts (Strongbacks) - Contract/PO - Leadtime |  | 40d | 2020-02-04 A | 2020-03-31 A | S124600 SS, OBLG124610 SS | 100% |  |  |  |  |  |  |  |  | S124700 | 0 | S120000 | S120120 |  | NOCA | Not Started |  | Hemmick,Tom |  | BNL | Fab & Assy | PP6 | MP100820 | Tom Hemmick | SBU |  | POM02.1.02.02.03 |  |  |  |  | 03 | 01 | 5 |  |  |  |  |  |  |  |  |  |  |
| S125200 |  | Procure TPC R1 Module Parts (Grids) - Contract Award(s) | milestone | 0d | 2020-02-04 A | 2020-02-04 A | S124200, S101000, S101010 | 100% |  |  |  |  |  |  |  |  | S125200 | 0 | S119900 | S120170 |  | NOCA | Not Started | A-TEC | Hemmick,Tom |  | BNL | Procurement | PP5 | MP100840 | Tom Hemmick | SBU |  | POM02.1.02.02.03 |  |  |  |  | 03 | 01 | 3 | L5 | Contract Award |  |  |  |  |  |  |  |  |
| S125300 |  | Procure TPC R1 Module Parts (Grids) - Contract/PO - Leadtime |  | 40d | 2020-02-04 A | 2020-03-31 A | S125200 SS, OBLG125210 SS | 100% |  |  |  |  |  |  |  |  | S125300 | 0 | S120000 | S120180 |  | NOCA | Not Started |  | Hemmick,Tom |  | BNL | Fab & Assy | PP6 | MP100840 | Tom Hemmick | SBU |  | POM02.1.02.02.03 |  |  |  |  | 03 | 01 | 5 |  |  |  |  |  |  |  |  |  |  |
| OBLG124310 |  | Procure TPC R1 Module Parts (Frames) - Obligation |  | 1d | 2020-03-02 A | 2020-03-02 A | S124200, S101000, S101010 | 100% |  |  |  |  |  |  | Obligation Resource [16614.9 h] | 16,614.86 | S124300 | 0 | S119900 | S119900 |  |  | Not Started | A-TEC | Hemmick,Tom |  | BNL | Procurement | PP5 | MP100810 | Tom Hemmick | SBU |  | POM02.1.02.02.03 |  |  |  |  | 03 |  |  | L5 |  | 190315 ELM BNLU | OBLG | 003 |  |  |  |  |  |
| OBLG124610 |  | Procure TPC R1 Module Parts (Strongbacks) - Obligation |  | 1d | 2020-03-02 A | 2020-03-02 A | S124200, S101000, S101010 | 100% |  |  |  |  |  |  | Obligation Resource [9349.2 h] | 9,349.2 | S124600 | 0 | S119900 | S120110 |  |  | Not Started | A-TEC | Hemmick,Tom |  | BNL | Procurement | PP5 | MP100820 | Tom Hemmick | SBU |  | POM02.1.02.02.03 |  |  |  |  | 03 |  |  | L5 |  | 190315 ELM BNLU | OBLG | 003 |  |  |  |  |  |
| OBLG124910 |  | Procure TPC R1 Module Parts (Padplanes) - Obligation |  | 1d | 2020-03-02 A | 2020-03-02 A | S124200, S101000, S101010 | 100% |  |  |  |  |  |  | Obligation Resource [50113.1 h] | 50,113.12 | S124900 | 0 | S119900 | S120140 |  |  | Not Started | A-TEC | Hemmick,Tom |  | BNL | Procurement | PP5 | MP100830 | Tom Hemmick | SBU |  | POM02.1.02.02.03 |  |  |  |  | 03 |  |  | L5 |  | 190315 ELM BNLU | OBLG | 003 |  |  |  |  |  |
| OBLG125210 |  | Procure TPC R1 Module Parts (Grids) - Obligation |  | 1d | 2020-03-02 A | 2020-03-02 A | S124200, S101000, S101010 | 100% |  |  |  |  |  |  | Obligation Resource [11148.3 h] | 11,148.26 | S125200 | 0 | S119900 | S120170 |  |  | Not Started | A-TEC | Hemmick,Tom |  | BNL | Procurement | PP5 | MP100840 | Tom Hemmick | SBU |  | POM02.1.02.02.03 |  |  |  |  | 03 |  |  | L5 |  | 190315 ELM BNLU | OBLG | 003 |  |  |  |  |  |
| S124500 |  | Procure TPC R1 Module Parts (Frames) - Delivery Acceptance |  | 5d | 2020-03-17 A | 2020-05-27 A | S124400 | 100% |  | 2020-05-01 | 2020-05-07 |  |  |  | SBU Contracted Purchase <$2M M&S [14601 h] | 16,614.85 | S124500 | 0 | S120100 | S120100 | S124500 | CA | Not Started | A-TEC | Hemmick,Tom | M4 | BNL | Fab & Assy | PP6 | MP100810 | Tom Hemmick | SBU | TEC | POM02.1.02.02.03 | C | 1.02 | 59703 | 1.02A | 03 | 01 | 5 |  | Delivery | 190314 ELM BNL Units per TH; rsrc assgn per GRY | FAB | 003 | UDF_G2 | UDF_G3 | 5482.9019718 | 0.33 |  |
| S125400 |  | Procure TPC R1 Module Parts (Grids) - Delivery Acceptance |  | 5d | 2020-03-24 A | 2020-03-31 A | S125300 | 100% |  | 2020-04-01 | 2020-04-07 |  |  |  | SBU Contracted Purchase <$2M M&S [9797 h] | 11,148.26 | S125400 | 0 | S120100 | S120190 | S125400 | CA | Not Started | A-TEC | Hemmick,Tom | M4 | BNL | Fab & Assy | PP6 | MP100840 | Tom Hemmick | SBU | TEC | POM02.1.02.02.03 | C | 1.02 | 59703 | 1.02A | 03 | 01 | 5 |  | Delivery | 190314 ELM BNL Units per TH; rsrc assgn per GRY | FAB | 003 | UDF_G3 | UDF_G3 |  |  |  |
| S124800 |  | Procure TPC R1 Module Parts (Strongbacks) - Delivery Acceptance |  | 5d | 2020-03-25 A | 2020-03-31 A | S124700 | 100% |  | 2020-04-01 | 2020-04-07 |  |  |  | SBU Contracted Purchase <$2M M&S [8216 h] | 9,349.2 | S124800 | 0 | S120100 | S120130 | S124800 | CA | Not Started | A-TEC | Hemmick,Tom | M4 | BNL | Fab & Assy | PP6 | MP100820 | Tom Hemmick | SBU | TEC | POM02.1.02.02.03 | C | 1.02 | 59703 | 1.02A | 03 | 01 | 5 |  | Delivery | 190314 ELM BNL Units per TH; rsrc assgn per GRY | FAB | 003 | UDF_G3 | UDF_G3 |  |  |  |
| S125000 |  | Procure TPC R1 Module Parts (Padplanes) - Contract/PO - Leadtime |  | 40d | 2021-01-04 A | 2021-03-31 A | S124900 SS, OBLG124910 SS | 100% |  | 2021-01-04 | 2021-03-02 |  |  |  |  |  | S125000 | 0 | S120000 | S120150 |  | NOCA | Not Started |  | Hemmick,Tom |  | BNL | Fab & Assy | PP6 | MP100830 | Tom Hemmick | SBU |  | POM02.1.02.02.03 |  |  |  |  | 03 | 01 | 5 |  |  |  |  |  |  |  |  |  |  |
| S125500 |  | Build TPC R1 Modules |  | 126d | 2021-01-11 A | 2021-09-03 | S120100 SS+22d, S124500, S124800, S125100, S125400, S123700, S126010 SS, OBLG126012 SS | 85% | 68d | 2021-03-10 | 2021-09-03 | 30d | 0d | 2021-09-03 | TECH3 Wayne - Purchased Services [960 h] | 63,173.4 | S125500 | 0 | S120800 | S120800 | S125500 | CA | Not Started | A-TEC | Hemmick,Tom | L3 | Wayne | Fab & Assy | PP6 | MP204101 | Tom Hemmick | SBU | null | POM02.1.02.02.03 | C | 1.02 | 59703 | 1.02A | 03 | 01 | 5 |  |  | 190313 ELM Activity split for fund src |  | 003 |  |  |  |  | Yes |
| S125505 |  | Build TPC R1 Modules - Contributed Labor |  | 126d | 2021-01-11 A | 2021-09-03 | S120100 SS+22d, S124500, S124800, S125100, S125400, S123700 | 85% | 68d | 2021-03-10 | 2021-09-03 | 30d | 0d | 2021-09-03 | SCI3 Wayne - Unpaid [288 h]; STUDENT Wayne - Unpaid [2400 h] |  | S125500 | 0 | S120800 | S120800 | S125505 | CA | Not Started | T | Hemmick,Tom | L3 | Wayne | Fab & Assy |  |  | Tom Hemmick | SBU | null | POM02.1.02.02.03 | C | 1.02 | NA | 1.02B | 03 | 01 | 5 |  |  | 190313 ELM Activity split for fund src |  | 003 |  |  |  |  | Yes |
| S125600 |  | Test TPC R1 Modules |  | 126d | 2021-01-11 A | 2021-09-20 | S125500 SS+10d, S126010 SS, OBLG126012 SS | 85% | 78d | 2021-03-24 | 2021-09-20 | 30d | 0d | 2021-09-20 | TECH3 Wayne - Purchased Services [960 h] | 63,173.4 | S125600 | 0 | S120900 | S120900 | S125600 | CA | Not Started | A-TEC | Hemmick,Tom | L3 | Wayne | Test_Components | PP6 | MP204101 | Tom Hemmick | SBU | null | POM02.1.02.02.03 | C | 1.02 | 59703 | 1.02A | 03 | 01 | 7 |  |  | 190313 ELM Activity split for fund src |  | 003 |  |  |  |  | Yes |
| S125605 |  | Test TPC R1 Modules - Contributed Labor |  | 126d | 2021-01-11 A | 2021-09-20 | S125505 SS+10d | 85% | 78d | 2021-03-24 | 2021-09-20 | 30d | 0d | 2021-09-20 | SCI3 Wayne - Unpaid [288 h]; STUDENT Wayne - Unpaid [2400 h] |  | S125600 | 0 | S120900 | S120900 | S125605 | CA | Not Started | T | Hemmick,Tom | L3 | Wayne | Test_Components |  |  | Tom Hemmick | SBU | null | POM02.1.02.02.03 | C | 1.02 | NA | 1.02B | 03 | 01 | 7 |  |  | 190313 ELM Activity split for fund src |  | 003 |  |  |  |  | Yes |
| S124900 |  | Procure TPC R1 Module Parts (Padplanes) - Contract Award(s) | milestone | 0d | 2021-01-29 A | 2021-01-29 A | S124200, S101000, S101010 | 100% |  | 2021-01-04 | 2021-01-04 |  |  |  |  |  | S124900 | 0 | S119900 | S120140 |  | NOCA | Not Started | A-TEC | Hemmick,Tom |  | BNL | Procurement | PP5 | MP100830 | Tom Hemmick | SBU |  | POM02.1.02.02.03 |  |  |  |  | 03 | 01 | 3 | L5 | Contract Award |  |  |  | UDF_G2 | UDF_G3 |  |  |  |
| S125100 |  | Procure TPC R1 Module Parts (Padplanes) - Delivery Acceptance |  | 5d | 2021-03-22 A | 2021-03-29 A | S125000 | 100% |  | 2021-04-01 | 2021-04-07 |  |  |  | SBU Contracted Purchase <$2M M&S [44039 h] | 51,115.38 | S125100 | 0 | S120100 | S120160 | S125100 | CA | Not Started | A-TEC | Hemmick,Tom | M4 | BNL | Fab & Assy | PP6 | MP100830 | Tom Hemmick | SBU | TEC | POM02.1.02.02.03 | C | 1.02 | 59703 | 1.02A | 03 | 01 | 5 |  | Delivery | 190314 ELM BNL Units per TH; rsrc assgn per GRY | FAB | 003 | UDF_G1 | UDF_G1 | 50113.113866 | 1 |  |
| S125700 |  | TPC R1 GEM Modules Production Ends | milestone | 0d | 2021-09-20 | 2021-09-20 | S125600, S125605 |  |  |  |  | 30d | 26d |  |  |  | S125700 | 0 | S121000 | S121000 |  | NOCA | Not Started |  | Hemmick,Tom |  | BNL | Fab & Assy |  |  | Tom Hemmick | SBU |  | POM02.1.02.02.03 |  |  |  |  | 03 | 01 | 5 | L2 |  |  |  |  | UDF_G3 | UDF_G3 |  |  |  |

Notes:
- S123900: BNL_UDF_Adhoc Comments: 180426 ELM rsrc per EOB; 180426 ELM rsrc per EOB180410 ELM pred/succ per GRY; 180328 ELM rename per GRY / BNL_UDF_Old Activity Name 181221: Procure TPC R1 Module Prod. Parts (Frames, Strongbacks, Padplanes, Grids) - Provide Requirements to Procurement
- S124000: BNL_UDF_Adhoc Comments: 180328 ELM rename per GRY / BNL_UDF_Old Activity Name 181221: Procure TPC R1 Module Prod. Parts (Frames, Strongbacks, Padplanes, Grids) - Prepare & Send Solicitation
- S124100: BNL_UDF_Adhoc Comments: 180328 ELM rename per GRY / BNL_UDF_Old Activity Name 181221: Procure TPC R1 Module Prod. Parts (Frames, Strongbacks, Padplanes, Grids) - Vendor Responses
- S124200: BNL_UDF_Adhoc Comments: 180328 ELM rename per GRY / BNL_UDF_Old Activity Name 181221: Procure TPC R1 Module Prod. Parts (Frames, Strongbacks, Padplanes, Grids) - Vendor Selection
- S124300: BNL_UDF_Adhoc Comments: 180328 ELM rename per GRY / BNL_UDF_Old Activity Name 181221: Procure TPC R1 Module Parts (Frames) - Contract Award(s)
- S124400: BNL_UDF_Adhoc Comments: 180328 ELM rename per GRY / BNL_UDF_Old Activity Name 181221: Procure TPC R1 Module Parts (Frames) - Contract/PO - Leadtime
- S124600: BNL_UDF_Adhoc Comments: 180328 ELM Add per GRY / BNL_UDF_Old Activity Name 181221: Procure TPC R1 Module Parts (Strongbacks) - Contract Award(s)
- S124700: BNL_UDF_Adhoc Comments: 180328 ELM Add per GRY / BNL_UDF_Old Activity Name 181221: Procure TPC R1 Module Parts (Strongbacks) - Contract/PO - Leadtime
- S125200: BNL_UDF_Adhoc Comments: 180328 ELM Add per GRY / BNL_UDF_Old Activity Name 181221: Procure TPC R1 Module Parts (Grids) - Contract Award(s)
- S125300: BNL_UDF_Adhoc Comments: 180328 ELM Add per GRY / BNL_UDF_Old Activity Name 181221: Procure TPC R1 Module Parts (Grids) - Contract/PO - Leadtime
- OBLG124310: BNL_UDF_Adhoc Comments: 180328 ELM rename per GRY / BNL_UDF_Old Activity Name 181221: Procure TPC R1 Module Parts (Frames) - Contract Award(s)
- OBLG124610: BNL_UDF_Adhoc Comments: 180328 ELM Add per GRY / BNL_UDF_Old Activity Name 181221: Procure TPC R1 Module Parts (Strongbacks) - Contract Award(s)
- OBLG124910: BNL_UDF_Adhoc Comments: 180328 ELM Add per GRY / BNL_UDF_Old Activity Name 181221: Procure TPC R1 Module Parts (Padplanes) - Contract Award(s)
- OBLG125210: BNL_UDF_Adhoc Comments: 180328 ELM Add per GRY / BNL_UDF_Old Activity Name 181221: Procure TPC R1 Module Parts (Grids) - Contract Award(s)
- S124500: BNL_UDF_Adhoc Comments: 180328 ELM rename, pred per GRY / BNL_UDF_Old Activity Name 181221: Procure TPC R1 Module Parts (Frames) - Delivery Acceptance
- S125400: BNL_UDF_Adhoc Comments: 180328 ELM Add per GRY / BNL_UDF_Old Activity Name 181221: Procure TPC R1 Module Parts (Grids) - Delivery Acceptance
- S124800: BNL_UDF_Adhoc Comments: 180328 ELM Add per GRY / BNL_UDF_Old Activity Name 181221: Procure TPC R1 Module Parts (Strongbacks) - Delivery Acceptance
- S125000: BNL_UDF_Adhoc Comments: 180328 ELM Add per GRY / BNL_UDF_Old Activity Name 181221: Procure TPC R1 Module Parts (Padplanes) - Contract/PO - Leadtime
- S125500: BNL_UDF_Adhoc Comments: 180329 ELM pred per GRY / BNL_UDF_Old Activity Name 181221: Build TPC R1 Modules
- S125505: BNL_UDF_Adhoc Comments: 180329 ELM pred per GRY / BNL_UDF_Old Activity Name 181221: Build TPC R1 Modules
- S125600: BNL_UDF_Old Activity Name 181221: Test TPC R1 Modules
- S125605: BNL_UDF_Old Activity Name 181221: Test TPC R1 Modules
- S124900: BNL_UDF_Adhoc Comments: 180328 ELM Add per GRY / BNL_UDF_Old Activity Name 181221: Procure TPC R1 Module Parts (Padplanes) - Contract Award(s)
- S125100: BNL_UDF_Adhoc Comments: 180328 ELM Add per GRY / BNL_UDF_Old Activity Name 181221: Procure TPC R1 Module Parts (Padplanes) - Delivery Acceptance
- S125700: BNL_UDF_Old Activity Name 181221: TPC R1 GEM Modules Production Ends

| ID | WBS | Activity | Type | Duration | Start | Finish | Predecessors | Complete | Planned start | Planned finish | Resources | Cost | BNL_UDF_Exclude | BNL_UDF_Temp Text 01 | BNL_UDF_Adhoc Comments | BNL_UDF_Percent Complete | BNL_UDF_Old Activity ID 181221 | RG Check | BNL_Activity Status | BNL_Estimator | BNL_Location | BNL_EDIA | BNL_Proc Sig Phase | BNL_Proc Sig | BNL_CAM | BNL_Institution | BNL_OPC TEC (deprecated) | BNL_WBS | BNL_PCR ID | BNL_WBS_Hierarchical | Completed | PMP Summary Part1 | PMP Summary Part2 | Cost = Awarded Proc or Mgmt | BNL_Fund Source | BNL_Milestone Level | BNL_Obligation | BNL_UDF_OPC TEC (deprecated) | BNL_Cost Basis | BNL_R&D FY18-19 | BNL_EVT | BNL_DOE OPC | BNL_Account Number | BNL_UDF_Temp Date 01 | BNL_Cobra WP | BNL_Master Control Account | BNL_Cobra Control Account | Additional EVT documentation required | Indicator - Procurement |
| --- | --- | --- | --- | --- | --- | --- | --- | --- | --- | --- | --- | --- | --- | --- | --- | --- | --- | --- | --- | --- | --- | --- | --- | --- | --- | --- | --- | --- | --- | --- | --- | --- | --- | --- | --- | --- | --- | --- | --- | --- | --- | --- | --- | --- | --- | --- | --- | --- | --- |
|  | 04 | **TPC R1 Module Production Procure Contracted Labor and M&S** |  |  | 2017-06-09 | 2020-03-02 |  |  |  |  |  |  |  |  |  |  |  |  |  |  |  |  |  |  |  |  |  |  |  |  |  |  |  |  |  |  |  |  |  |  |  |  |  |  |  |  |  |  |  |
| S125800 |  | TPC R1 Module Production Procure Contracted Labor and M&S SBU - Provide Requirements to Procurement |  | 5d | 2017-06-09 A | 2017-06-15 A | S100090 SS+90d, S126008 SS | 100% |  |  |  |  | MP6LAEXCLUDE | S125800 | 180719 ELM added procurement string | 100 | S343380 | NOCA | Completed | Hemmick,Tom | BNL | Design | PP1 | MP204100 | Tom Hemmick | BNL | null | POM02.1.02.02.04 | 003 | 04 | yes | 1 | 1 | Yes |  |  |  |  |  |  |  |  |  |  |  |  |  |  |  |
| S125900 |  | TPC R1 Module Production Procure Contracted Labor and M&S Wayne - Vendor Selection |  | 30d | 2017-06-16 A | 2017-07-28 A | S125800, S126008 SS | 100% |  |  |  |  | MP6LAEXCLUDE | S125900 | 180719 ELM added procurement string | 100 | S343420 | NOCA | Completed | Hemmick,Tom | BNL | Design | PP4 | MP204100 | Tom Hemmick | BNL | null | POM02.1.02.02.04 | 003 | 04 | yes | 1 | 1 | Yes |  |  |  |  |  |  |  |  |  |  |  |  |  |  |  |
| OBLG126001 |  | TPC R1 Module Production Procure Contracted Labor and M&S SBU, Phase 1 - Obligation |  | 1d | 2017-07-31 A | 2017-07-31 A | S125900, S126000 SS | 100% |  |  | Obligation Resource |  | MP6LAEXCLUDE | S126000 | 180719 ELM added procurement string | 100 | S343460 | NOCA | Completed | Hemmick,Tom | BNL | Design | PP5 | MP208100 | Tom Hemmick | BNL |  | POM02.1.02.02.04 | 003,004 | 04 | yes | 1 | 1 | Yes | A-OPC | L5 |  |  |  |  |  |  |  |  |  |  |  |  |  |
| OBLG126002 |  | TPC R1 Module Production Procure Contracted Labor and M&S Wayne, Phase 1 - Obligation |  | 1d | 2017-07-31 A | 2017-07-31 A | S126008 SS | 100% |  |  | Obligation Resource |  | MP6LAEXCLUDE | S126000 | 180719 ELM added procurement string | 100 | S343460 | NOCA | Completed | Hemmick,Tom | BNL | Design | PP5 | MP204100 | Tom Hemmick | BNL |  | POM02.1.02.02.04 | 003,004 | 04 | yes | 1 | 1 | Yes | A-OPC | L5 |  |  |  |  |  |  |  |  |  |  |  |  |  |
| S126000 |  | TPC R1 Module Production Procure Contracted Labor and M&S SBU, Phase 1 - Contract Award | milestone | 0d | 2017-07-31 A | 2017-07-31 A | S125900 | 100% |  |  |  |  | MP6LAEXCLUDE | S126000 | 180719 ELM added procurement string | 100 | S343460 | NOCA | Completed | Hemmick,Tom | BNL | Design | PP5 | MP208100 | Tom Hemmick | BNL |  | POM02.1.02.02.04 | 003,004 | 04 | yes | 1 | 1 | Yes | A-OPC | L5 |  |  |  |  |  |  |  |  |  |  |  |  |  |
| S126008 |  | TPC R1 Module Production Procure Contracted Labor and M&S Wayne, Phase 1 - Contract Award | milestone | 0d | 2017-07-31 A | 2017-07-31 A | S100090 SS | 100% |  |  |  |  | MP6LAEXCLUDE | S126000 | 180719 ELM added procurement string | 100 | S343460 | NOCA | Completed | Hemmick,Tom | BNL | Design | PP5 | MP204100 | Tom Hemmick | BNL |  | POM02.1.02.02.04 | 003,004 | 04 | yes | 1 | 1 | Yes | A-OPC | L5 |  |  |  |  |  |  |  |  |  |  |  |  |  |
| OBLG126011 |  | TPC R1 Module Production Procure Contracted Labor and M&S SBU, Phase 2 - Obligation |  | 1d | 2019-09-12 A | 2019-09-12 A | S125900, S101000, S126005 SS | 100% |  |  | Obligation Resource [23878.3 h] | 23,878.28 | MP6LAEXCLUDE | S126000 | 180719 ELM added procurement string | 0 | S343460 |  | Completed | Hemmick,Tom | BNL | Design | PP5 | MP208200 | Tom Hemmick | BNL |  | POM02.1.02.02.04 | 003,004 | 04 |  |  |  |  | A-TEC |  | OBLG |  |  |  |  |  |  |  |  |  |  |  |  |
| S126005 |  | TPC R1 Module Production Procure Contracted Labor and M&S SBU, Phase 2 - Contract Award | milestone | 0d | 2019-09-12 A | 2019-09-12 A | S101000, S125900 | 100% |  |  |  |  | MP6LAEXCLUDE | S126000 | 180719 ELM added procurement string | 0 | S343460 | NOCA | Completed | Hemmick,Tom | BNL | Design | PP5 | MP208200 | Tom Hemmick | BNL |  | POM02.1.02.02.04 | 003,004 | 04 |  | 1 | 1 |  | A-TEC | L5 |  |  |  |  |  |  |  |  |  |  |  |  |  |
| S126010 |  | TPC R1 Module Production Procure Contracted Labor and M&S Wayne, Phase 2 - Contract Award | milestone | 0d | 2020-01-02 A | 2020-01-02 A | S125900, S101000, S101010 | 100% |  |  |  |  | MP6LAEXCLUDE | S126000 | 180719 ELM added procurement string | 0 | S343460 | NOCA | Not Started | Hemmick,Tom | BNL | Design | PP5 | MP204101 | Tom Hemmick | BNL |  | POM02.1.02.02.04 | 003,004 | 04 |  | 1 | 1 |  | A-TEC | L5 |  |  |  |  |  |  |  |  |  |  |  |  |  |
| OBLG126012 |  | TPC R1 Module Production Procure Contracted Labor and M&S Wayne, Phase 2 - Obligation |  | 1d | 2020-03-02 A | 2020-03-02 A | S126010 SS, S101010 | 100% |  |  | Obligation Resource [126274 h] | 126,273.84 | MP6LAEXCLUDE | S126000 | 180719 ELM added procurement string | 0 | S343460 |  | Not Started | Hemmick,Tom | BNL | Design | PP5 | MP204101 | Tom Hemmick | BNL |  | POM02.1.02.02.04 | 003,004 | 04 |  |  |  |  | A-TEC |  | OBLG |  |  |  |  |  |  |  |  |  |  |  |  |
|  | 03 | **TPC R2 Modules** |  |  | 2018-10-01 | 2021-06-22 |  |  |  |  |  |  |  |  |  |  |  |  |  |  |  |  |  |  |  |  |  |  |  |  |  |  |  |  |  |  |  |  |  |  |  |  |  |  |  |  |  |  |  |
|  | 01 | **TPC R2 Module Factory Preparation** |  |  | 2018-10-01 | 2019-07-31 |  |  |  |  |  |  |  |  |  |  |  |  |  |  |  |  |  |  |  |  |  |  |  |  |  |  |  |  |  |  |  |  |  |  |  |  |  |  |  |  |  |  |  |
| S126200 |  | Prepare TPC R2 Factory Clean Facility Labor |  | 41d | 2018-10-01 A | 2018-11-30 A | S114600 | 100% |  |  |  |  |  | S126200 |  | 100 | S121100 | NOCA | Completed | Hemmick,Tom | Vandblt | Fab & Assy |  |  | Tom Hemmick | SBU | null | POM02.1.02.03.01 |  | 01 | yes | 01 | 4 |  | T |  |  | S121100 | L4 | TPC R1-3 Fact.Prep | C |  |  |  |  |  |  |  |  |
| S126300 |  | Prepare TPC R2 Factory Clean Facility M&S |  | 41d | 2018-10-01 A | 2018-11-30 A | S114600 | 100% |  |  |  |  |  | S126300 |  | 100 | S121200 | NOCA | Completed | Hemmick,Tom | Vandblt | Fab & Assy |  |  | Tom Hemmick | SBU | OPC | POM02.1.02.03.01 | 003 | 01 | yes | 01 | 4 | Yes | A-OPC |  |  | S121200 | M4 | TPC R1-3 Fact.Prep | C | OPC000500 | 16701 |  |  |  |  |  |  |
| S126400 |  | Prepare TPC R2 Factory Tooling Labor |  | 208d | 2018-10-01 A | 2019-07-31 A | S114600 | 100% |  |  | PROF3 Vanderbilt - Unpaid [160 h]; STUDENT Vanderbilt - Unpaid [480 h] |  |  | S126400 |  | 40 | S121300 | CA | Completed | Hemmick,Tom | Vandblt | Fab & Assy |  |  | Tom Hemmick | SBU | null | POM02.1.02.03.01 |  | 01 |  | 01 | 4 |  | T |  |  | S121300 | L4 | TPC R1-3 Fact.Prep | C |  | NA | 2019-03-15 | S126400 | 1.02 | 1.02B | Yes |  |
| S126500 |  | Prepare TPC R2 Factory Tooling M&S |  | 166d | 2018-10-01 A | 2019-05-31 A | S114600 | 100% |  |  |  |  |  | S126500 |  | 40 | S121400 | NOCA | Completed | Hemmick,Tom | Vandblt | Fab & Assy |  |  | Tom Hemmick | SBU | OPC | POM02.1.02.03.01 | 003 | 01 | yes | 01 | 4 | Yes | A-OPC |  |  | S121400 | M4 | TPC R1-3 Fact.Prep | C | OPC000500 | 16701 | 2019-03-15 |  |  |  | Yes |  |
| S126502 |  | Prepare TPC R2 Factory Tooling M&S Split |  | 22d | 2019-07-01 A | 2019-07-31 A | S126500 | 100% |  |  | Vanderbilt Contracted Purchase <$2M M&S [3600 h] | 3,971.75 |  | S126500 |  | 40 | S121400 | CA | Completed | Hemmick,Tom | Vandblt | Fab & Assy |  |  | Tom Hemmick | SBU | OPC | POM02.1.02.03.01 | 003 | 01 |  | 01 | 4 | Yes | A-OPC |  |  | S121400 | M4 | TPC R1-3 Fact.Prep | C | OPC000500 | 16701 | 2019-03-15 | S126502 | 1.02 | 1.02A | Yes | UDF_G3 |
|  | 02 | **TPC R2 Pre-Production Module** |  |  | 2018-10-30 | 2019-08-30 |  |  |  |  |  |  |  |  |  |  |  |  |  |  |  |  |  |  |  |  |  |  |  |  |  |  |  |  |  |  |  |  |  |  |  |  |  |  |  |  |  |  |  |
| S126600 |  | Design TPC R2 Pre-Production Module (strongback, frame, grid, pad, GEMs) |  | 21d | 2018-10-30 A | 2018-11-30 A | S115800, S115900, S116100 | 100% |  |  |  |  |  | S126600 |  | 100 | S121500 | NOCA | Completed | Hemmick,Tom | BNL | Design |  |  | Tom Hemmick | SBU | null | POM02.1.02.03.02 |  | 02 | yes | 1 | 1 |  | B_T |  |  | S121500 | L4 | TPC R1-3 Pre-pro Mod | C |  | 16709 |  |  |  |  |  |  |
| S126700 |  | Procure TPC R2 Pre-Production Module Stongbacks Labor |  | 82d | 2018-11-30 A | 2019-03-29 A | S126600 | 100% |  |  |  |  |  | S126700 |  | 50 | S121600 | NOCA | Completed | Hemmick,Tom | BNL | Procurement |  |  | Tom Hemmick | SBU | null | POM02.1.02.03.02 |  | 02 | yes | 01 | 2 |  | B |  |  | S121600 | L4 | TPC R1-3 Pre-pro Mod | C |  | 16709 | 2019-01-31 |  |  |  |  |  |
| S126800 |  | Procure TPC R2 Pre-Production Module Stongbacks M&S |  | 82d | 2018-11-30 A | 2019-03-29 A | S126600 | 100% |  |  |  |  |  | S126800 |  | 50 | S121700 | NOCA | Completed | Hemmick,Tom | BNL | Fab & Assy | PP6 | MP208100 | Tom Hemmick | SBU | OPC | POM02.1.02.03.02 | 003 | 02 | yes | 01 | 4 | Yes | A-OPC |  |  | S121700 | M4 | TPC R1-3 Pre-pro Mod | C | OPC000600 | 16701 | 2019-01-31 |  |  |  |  |  |
| S126900 |  | Procure TPC R2 Pre-Production Module Frames - Labor |  | 82d | 2018-11-30 A | 2019-03-29 A | S126600 | 100% |  |  |  |  |  | S126900 | 180328 ELM Act Name, Pred per GRY | 50 | S121800 | NOCA | Completed | Hemmick,Tom | BNL | Procurement |  |  | Tom Hemmick | SBU | null | POM02.1.02.03.02 |  | 02 | yes | 01 | 2 |  | B |  |  | S121800 | L4 | TPC R1-3 Pre-pro Mod | C |  | 16709 | 2019-01-31 |  |  |  |  |  |
| S127000 |  | Procure TPC R2 Pre-production Module frames - M&S |  | 82d | 2018-11-30 A | 2019-03-29 A | S126600, S126900 SS | 100% |  |  |  |  |  | S127000 | 180328 ELM Act Name, Pred per GRY | 50 | S122400 | NOCA | Completed | Hemmick,Tom | BNL | Fab & Assy | PP6 | MP208100 | Tom Hemmick | SBU | OPC | POM02.1.02.03.02 | 003 | 02 | yes | 01 | 4 | Yes | A-OPC |  |  | S122400 | M4 | TPC R1-3 Pre-pro Mod | C | OPC000600 | 16701 | 2019-01-31 |  |  |  |  |  |
| S127100 |  | Procure TPC R2 Pre-Production Module Grids Labor |  | 20d | 2018-11-30 A | 2018-12-28 A | S126600 | 100% |  |  |  |  |  | S127100 |  | 100 | S122500 | NOCA | Completed | Hemmick,Tom | BNL | Procurement |  |  | Tom Hemmick | SBU | null | POM02.1.02.03.02 |  | 02 | yes | 01 | 2 |  | B |  |  | S122500 | L4 | TPC R1-3 Pre-pro Mod | C |  | 16709 |  |  |  |  |  |  |
| S127200 |  | Procure TPC R2 Pre-Production Module Grids M&S |  | 20d | 2018-11-30 A | 2018-12-28 A | S126600 | 100% |  |  |  |  |  | S127200 |  | 100 | S122600 | NOCA | Completed | Hemmick,Tom | BNL | Fab & Assy | PP6 | MP208100 | Tom Hemmick | SBU | OPC | POM02.1.02.03.02 | 003 | 02 | yes | 01 | 4 | Yes | A-OPC |  |  | S122600 | M4 | TPC R1-3 Pre-pro Mod | C | OPC000600 | 16701 |  |  |  |  |  |  |
| S127300 |  | Procure TPC R2 Pre-Production Module Pad Planes Labor |  | 82d | 2018-11-30 A | 2019-04-01 A | S126600 | 100% | 2018-11-30 | 2019-03-29 |  |  |  | S127300 |  | 50 | S122700 | NOCA | Completed | Hemmick,Tom | BNL | Procurement |  |  | Tom Hemmick | SBU | null | POM02.1.02.03.02 |  | 02 | yes | 01 | 2 |  | B |  |  | S122700 | L4 | TPC R1-3 Pre-pro Mod | C |  | 16709 | 2019-01-31 |  |  |  |  |  |
| S127400 |  | Procure TPC R2 Pre-Production Module Pad Planes M&S |  | 82d | 2018-11-30 A | 2019-03-29 A | S126600 | 100% |  |  |  |  |  | S127400 |  | 50 | S122800 | NOCA | Completed | Hemmick,Tom | BNL | Fab & Assy | PP6 | MP208100 | Tom Hemmick | SBU | OPC | POM02.1.02.03.02 | 003 | 02 | yes | 01 | 4 | Yes | A-OPC |  |  | S122800 | M4 | TPC R1-3 Pre-pro Mod | C | OPC000600 | 16701 | 2019-01-31 |  |  |  |  |  |
| S127500 |  | Procure TPC R2 Pre-Production Module GEMs Labor |  | 126d | 2018-11-30 A | 2019-05-31 A | S126600 | 100% |  |  |  |  |  | S127500 |  | 50 | S122900 | NOCA | Completed | Hemmick,Tom | BNL | Procurement |  |  | Tom Hemmick | SBU | null | POM02.1.02.03.02 |  | 02 | yes | 01 | 2 |  | B |  |  | S122900 | L4 | TPC R1-3 Pre-pro Mod | C |  | 16709 | 2019-01-31 |  |  |  |  |  |
| S127600 |  | Procure TPC R2 Pre-Production Module GEMs M&S |  | 126d | 2018-11-30 A | 2019-05-31 A | S126600 | 100% |  |  |  |  |  | S127600 |  | 50 | S123000 | NOCA | Completed | Hemmick,Tom | BNL | Fab & Assy | PP6 | MP208100 | Tom Hemmick | SBU | OPC | POM02.1.02.03.02 | 003 | 02 | yes | 01 | 4 | Yes | A-OPC |  |  | S123000 | M4 | TPC R1-3 Pre-pro Mod | C | OPC000600 | 16701 | 2019-01-31 |  |  |  |  |  |
| S127502 |  | Procure TPC R2 Pre-Production Module GEMs Labor Split |  | 14d | 2019-08-01 A | 2019-08-20 A | S127500 | 100% |  |  |  |  |  | S127500 |  | 50 | S122900 | CA | Completed | Hemmick,Tom | BNL | Procurement |  |  | Tom Hemmick | SBU | null | POM02.1.02.03.02 |  | 02 |  | 01 | 2 |  | B |  |  | S122900 | L4 | TPC R1-3 Pre-pro Mod | C |  | 16709 | 2019-01-31 | S127502 | 1.02 | 1.02B |  |  |
| S127602 |  | Procure TPC R2 Pre-Production Module GEMs M&S Split |  | 14d | 2019-08-01 A | 2019-08-20 A | S127600 | 100% |  |  | SBU Contracted Purchase <$2M M&S [2500 h] | 2,758.16 |  | S127600 |  | 50 | S123000 | CA | Completed | Hemmick,Tom | BNL | Fab & Assy | PP6 | MP208100 | Tom Hemmick | SBU | OPC | POM02.1.02.03.02 | 003 | 02 |  | 01 | 4 | Yes | A-OPC |  |  | S123000 | M4 | TPC R1-3 Pre-pro Mod | C | OPC000600 | 16701 | 2019-01-31 | S127602 | 1.02 | 1.02A |  | UDF_G2 |
| S127800 |  | Test TPC R2 Pre-Production Module |  | 8d | 2019-08-21 A | 2019-08-30 A | S127700 | 100% |  |  | SCI3 Vanderbilt - Unpaid [80 h]; STUDENT Vanderbilt - Unpaid [240 h] |  |  | S127800 |  | 0 | S123200 | CA | Completed | Hemmick,Tom | Vandblt | Test_Components |  |  | Tom Hemmick | SBU | null | POM02.1.02.03.02 |  | 02 |  | 01 | 7 |  | T |  |  | S123200 | L4 | TPC R1-3 Pre-pro Mod | C |  | NA |  | S127800 | 1.02 | 1.02B |  |  |
| S127700 |  | Assemble TPC R2 Pre-Production Module in TPC R2 Factory |  | 8d | 2019-08-21 A | 2019-08-30 A | S126700, S126900, S127100, S127300, S126800, S127000, S127200, S127400, S126200, S126300, S126400, S126502, S127502, S127602 | 100% |  |  | SCI3 Vanderbilt - Unpaid [240 h]; STUDENT Vanderbilt - Unpaid [720 h] |  |  | S127700 |  | 0 | S123100 | CA | Completed | Hemmick,Tom | Vandblt | Fab & Assy |  |  | Tom Hemmick | SBU | null | POM02.1.02.03.02 |  | 02 |  | 01 | 4 |  | T |  |  | S123100 | L4 | TPC R1-3 Pre-pro Mod | C |  | NA |  | S127700 | 1.02 | 1.02B |  |  |

Notes:
- S125800: BNL_UDF_Status Comments: 190314 ELM BNLU, WBS Name / BNL_UDF_Old Activity Name 181221: TPC R1 Module Production Procure Contracted Labor Wayne - Provide Requirements to Procurement
- S125900: BNL_UDF_Status Comments: 190314 ELM BNLU, WBS Name / BNL_UDF_Old Activity Name 181221: TPC R1 Module Production Procure Contracted Labor Wayne - Vendor Selection
- OBLG126001: BNL_UDF_Status Comments: 190417 ELM name; 190314 ELM BNLU, WBS Name / BNL_UDF_Old Activity Name 181221: TPC R1 Module Production Procure Contracted Labor Wayne - Contract Award
- OBLG126002: BNL_UDF_Status Comments: 190417 ELM name; 190314 ELM BNLU, WBS Name / BNL_UDF_Old Activity Name 181221: TPC R1 Module Production Procure Contracted Labor Wayne - Contract Award
- S126000: BNL_UDF_Status Comments: 190417 ELM name; 190314 ELM BNLU, WBS Name / BNL_UDF_Old Activity Name 181221: TPC R1 Module Production Procure Contracted Labor Wayne - Contract Award
- S126008: BNL_UDF_Status Comments: 190417 ELM name; 190317 ELM logic; 190316 ELM Add / BNL_UDF_Old Activity Name 181221: TPC R1 Module Production Procure Contracted Labor Wayne - Contract Award
- OBLG126011: BNL_UDF_Status Comments: 190417 ELM name; 190316 ELM Add / BNL_UDF_Old Activity Name 181221: TPC R1 Module Production Procure Contracted Labor Wayne - Contract Award
- S126005: BNL_UDF_Status Comments: 190417 ELM name; 190316 ELM Add / BNL_UDF_Old Activity Name 181221: TPC R1 Module Production Procure Contracted Labor Wayne - Contract Award
- S126010: BNL_UDF_Status Comments: 190417 ELM name; 190317 ELM logic, remove actuals; 1914 ELM BNLU, WBS Name / BNL_UDF_Old Activity Name 181221: TPC R1 Module Production Procure Contracted Labor Wayne - Contract Award
- OBLG126012: BNL_UDF_Status Comments: 190417 ELM name; 190316 ELM Add / BNL_UDF_Old Activity Name 181221: TPC R1 Module Production Procure Contracted Labor Wayne - Contract Award
- S126200: BNL_UDF_Old Activity Name 181221: Prepare TPC R2 Factory Clean Facility Labor
- S126300: BNL_UDF_Status Comments: 190314 ELM rsrc assgn per GRY / BNL_UDF_Old Activity Name 181221: Prepare TPC R2 Factory Clean Facility M&S
- S126400: BNL_UDF_Old Activity Name 181221: Prepare TPC R2 Factory Tooling Labor
- S126500: BNL_UDF_Status Comments: 190314 ELM rsrc assgn per GRY / BNL_UDF_Old Activity Name 181221: Prepare TPC R2 Factory Tooling M&S
- S126502: BNL_UDF_Status Comments: 190314 ELM rsrc assgn per GRY / BNL_UDF_Old Activity Name 181221: Prepare TPC R2 Factory Tooling M&S
- S126600: BNL_UDF_Old Activity Name 181221: Design TPC R2 Pre-Production Module (strongback, frame, grid, pad, GEMs)
- S126700: BNL_UDF_Old Activity Name 181221: Procure TPC R2 Pre-Production Module Stongbacks Labor
- S126800: BNL_UDF_Status Comments: 190314 ELM rsrc assgn per GRY / BNL_UDF_Old Activity Name 181221: Procure TPC R2 Pre-Production Module Stongbacks M&S
- S126900: BNL_UDF_Old Activity Name 181221: Procure TPC R2 Pre-Production Module Frames - Labor
- S127000: BNL_UDF_Status Comments: 190314 ELM rsrc assgn per GRY / BNL_UDF_Old Activity Name 181221: Procure TPC R2 Pre-production Module frames - M&S
- S127100: BNL_UDF_Old Activity Name 181221: Procure TPC R2 Pre-Production Module Grids Labor
- S127200: BNL_UDF_Status Comments: 190314 ELM rsrc assgn per GRY / BNL_UDF_Old Activity Name 181221: Procure TPC R2 Pre-Production Module Grids M&S
- S127300: BNL_UDF_Old Activity Name 181221: Procure TPC R2 Pre-Production Module Pad Planes Labor
- S127400: BNL_UDF_Status Comments: 190314 ELM rsrc assgn per GRY / BNL_UDF_Old Activity Name 181221: Procure TPC R2 Pre-Production Module Pad Planes M&S
- S127500: BNL_UDF_Old Activity Name 181221: Procure TPC R2 Pre-Production Module GEMs Labor
- S127600: BNL_UDF_Status Comments: 190314 ELM rsrc assgn per GRY / BNL_UDF_Old Activity Name 181221: Procure TPC R2 Pre-Production Module GEMs M&S
- S127502: BNL_UDF_Old Activity Name 181221: Procure TPC R2 Pre-Production Module GEMs Labor
- S127602: BNL_UDF_Status Comments: 190314 ELM rsrc assgn per GRY / BNL_UDF_Old Activity Name 181221: Procure TPC R2 Pre-Production Module GEMs M&S
- S127800: BNL_UDF_Old Activity Name 181221: Test TPC R2 Pre-Production Module
- S127700: BNL_UDF_Old Activity Name 181221: Assemble TPC R2 Pre-Production Module in TPC R2 Factory

| ID | WBS | Activity | Type | Duration | Start | Finish | Predecessors | Complete | Remaining | Planned start | Planned finish | Total float | Free float | Expected finish | Resources | Cost | BNL_UDF_Temp Text 01 | BNL_UDF_Percent Complete | BNL_UDF_OPC TEC (deprecated) | BNL_UDF_Old Activity ID 181221 | BNL_Cobra WP | RG Check | BNL_Activity Status | BNL_Fund Source | BNL_Estimator | BNL_Cost Basis | BNL_Location | BNL_EDIA | BNL_Proc Sig Phase | BNL_Proc Sig | BNL_CAM | BNL_Institution | BNL_OPC TEC (deprecated) | BNL_WBS | BNL_EVT | BNL_Master Control Account | BNL_Account Number | BNL_Cobra Control Account | BNL_WBS_Hierarchical | PMP Summary Part1 | PMP Summary Part2 | BNL_Milestone Level | SPH Proc Register | BNL_Obligation | BNL_UDF_Status Comments | Indicator - Procurement | Indicator - Float | BNL_PCR ID | BNL_UDF_Remaining Tot Cost | BNL_UDF_Percent_remaining | Additional EVT documentation required |
| --- | --- | --- | --- | --- | --- | --- | --- | --- | --- | --- | --- | --- | --- | --- | --- | --- | --- | --- | --- | --- | --- | --- | --- | --- | --- | --- | --- | --- | --- | --- | --- | --- | --- | --- | --- | --- | --- | --- | --- | --- | --- | --- | --- | --- | --- | --- | --- | --- | --- | --- | --- |
|  | 03 | **TPC R2 Module Production** |  |  | 2019-10-02 | 2021-06-22 |  |  |  |  |  |  |  |  |  |  |  |  |  |  |  |  |  |  |  |  |  |  |  |  |  |  |  |  |  |  |  |  |  |  |  |  |  |  |  |  |  |  |  |  |  |
| S127900 |  | Procure TPC R2 Module Prod. Parts (Frames, Strongbacks, Padplanes, Grids) - Provide Requirements to Procurement |  | 5d | 2019-10-02 A | 2019-10-08 A | S123800 | 100% |  |  |  |  |  |  | TECH3 PO M [128 h]; PROF4 AM [64 h] | 24,032.59 | S127900 | 0 | S123300 | S123300 | S127900 | CA | Completed | B | Hemmick,Tom | L3 | BNL | Procurement | PP1 | MP101000 | Tom Hemmick | SBU | null | POM02.1.02.03.03 | C | 1.02 | 16709 | 1.02B | 03 | 01 | 3 |  |  |  |  |  |  |  |  |  |  |
| S128000 |  | Procure TPC R2 Module Prod. Parts (Frames, Strongbacks, Padplanes, Grids) - Prepare & Send Solicitation |  | 30d | 2019-10-09 A | 2019-12-31 A | S127900 | 100% |  | 2019-10-09 | 2019-11-21 |  |  |  |  |  | S128000 | 0 | S123400 | S123400 |  | NOCA | In Progress |  | Hemmick,Tom |  | BNL | Procurement | PP2 | MP101000 | Tom Hemmick | SBU |  | POM02.1.02.03.03 |  |  |  |  | 03 | 01 | 3 |  |  |  |  |  |  |  |  |  |  |
| S128100 |  | Procure TPC R2 Module Prod. Parts (Frames, Strongbacks, Padplanes, Grids) - Vendor Responses |  | 10d | 2019-12-02 A | 2019-12-31 A | S128000 | 100% |  | 2020-01-15 | 2020-01-29 |  |  |  |  |  | S128100 | 0 | S123500 | S123500 |  | NOCA | Not Started |  | Hemmick,Tom |  | BNL | Procurement | PP3 | MP101000 | Tom Hemmick | SBU |  | POM02.1.02.03.03 |  |  |  |  | 03 | 01 | 3 |  |  |  |  |  |  |  |  |  |  |
| S128200 |  | Procure TPC R2 Module Prod. Parts (Frames, Strongbacks, Padplanes, Grids) - Vendor Selection |  | 20d | 2019-12-02 A | 2020-02-03 A | S128100 | 100% |  | 2020-01-30 | 2020-02-27 |  |  |  |  |  | S128200 | 0 | S123600 | S123600 |  | NOCA | Not Started |  | Hemmick,Tom |  | BNL | Procurement | PP4 | MP101000 | Tom Hemmick | SBU |  | POM02.1.02.03.03 |  |  |  |  | 03 | 01 | 3 |  |  |  |  |  |  |  |  |  |  |
| S128300 |  | Procure TPC R2 Module Prod. Parts (Frames) - Contract Award(s) | milestone | 0d | 2020-02-04 A | 2020-02-04 A | S128200, S101000, S101010 | 100% |  |  |  |  |  |  |  |  | S128300 | 0 | S123700 | S123700 |  | NOCA | Not Started | A-TEC | Hemmick,Tom |  | BNL | Procurement | PP5 | MP101010 | Tom Hemmick | SBU |  | POM02.1.02.03.03 |  |  |  |  | 03 | 01 | 3 | L5 | Contract Award |  |  |  |  |  |  |  |  |
| S128400 |  | Procure TPC R2 Module Prod. Parts (Frames) - Contract/PO - Leadtime |  | 40d | 2020-02-04 A | 2020-03-31 A | S128300 SS, OBLG128310 SS | 100% |  |  |  |  |  |  |  |  | S128400 | 0 | S123800 | S123800 |  | NOCA | Not Started |  | Hemmick,Tom |  | BNL | Fab & Assy | PP6 | MP101010 | Tom Hemmick | SBU |  | POM02.1.02.03.03 |  |  |  |  | 03 | 01 | 5 |  |  |  |  |  |  |  |  |  |  |
| S128600 |  | Procure TPC R2 Module Prod. Parts (Strongbacks) - Contract Award(s) | milestone | 0d | 2020-02-04 A | 2020-02-04 A | S128200, S101000, S101010 | 100% |  |  |  |  |  |  |  |  | S128600 | 0 | S123700 | S123910 |  | NOCA | Not Started | A-TEC | Hemmick,Tom |  | BNL | Procurement | PP5 | MP101020 | Tom Hemmick | SBU |  | POM02.1.02.03.03 |  |  |  |  | 03 | 01 | 3 | L5 | Contract Award |  |  |  |  |  |  |  |  |
| S128700 |  | Procure TPC R2 Module Prod. Parts (Strongbacks) - Contract/PO - Leadtime |  | 40d | 2020-02-04 A | 2020-03-31 A | S128600 SS, OBLG128610 SS | 100% |  |  |  |  |  |  |  |  | S128700 | 0 | S123800 | S123920 |  | NOCA | Not Started |  | Hemmick,Tom |  | BNL | Fab & Assy | PP6 | MP101020 | Tom Hemmick | SBU |  | POM02.1.02.03.03 |  |  |  |  | 03 | 01 | 5 |  |  |  |  |  |  |  |  |  |  |
| S129200 |  | Procure TPC R2 Module Prod. Parts (Grids) - Contract Award(s) | milestone | 0d | 2020-02-04 A | 2020-02-04 A | S128200, S101000, S101010 | 100% |  |  |  |  |  |  |  |  | S129200 | 0 | S123700 | S123970 |  | NOCA | Not Started | A-TEC | Hemmick,Tom |  | BNL | Procurement | PP5 | MP101040 | Tom Hemmick | SBU |  | POM02.1.02.03.03 |  |  |  |  | 03 | 01 | 3 | L5 | Contract Award |  |  |  |  |  |  |  |  |
| S129300 |  | Procure TPC R2 Module Prod. Parts (Grids) - Contract/PO - Leadtime |  | 40d | 2020-02-04 A | 2020-03-31 A | S129200 SS, OBLG129210 SS | 100% |  |  |  |  |  |  |  |  | S129300 | 0 | S123800 | S123980 |  | NOCA | Not Started |  | Hemmick,Tom |  | BNL | Fab & Assy | PP6 | MP101040 | Tom Hemmick | SBU |  | POM02.1.02.03.03 |  |  |  |  | 03 | 01 | 5 |  |  |  |  |  |  |  |  |  |  |
| OBLG128310 |  | Procure TPC R2 Module Prod. Parts (Frames) - Obligation |  | 1d | 2020-03-02 A | 2020-03-02 A | S128200, S101000, S101010 | 100% |  |  |  |  |  |  | Obligation Resource [16614.9 h] | 16,614.86 | S128300 | 0 | S123700 | S123700 |  |  | Not Started | A-TEC | Hemmick,Tom |  | BNL | Procurement | PP5 | MP101010 | Tom Hemmick | SBU |  | POM02.1.02.03.03 |  |  |  |  | 03 |  |  | L5 |  | OBLG |  |  |  |  |  |  |  |
| OBLG128610 |  | Procure TPC R2 Module Prod. Parts (Strongbacks) - Obligation |  | 1d | 2020-03-02 A | 2020-03-02 A | S128200, S101000, S101010 | 100% |  |  |  |  |  |  | Obligation Resource [10450.7 h] | 10,450.71 | S128600 | 0 | S123700 | S123910 |  |  | Not Started | A-TEC | Hemmick,Tom |  | BNL | Procurement | PP5 | MP101020 | Tom Hemmick | SBU |  | POM02.1.02.03.03 |  |  |  |  | 03 |  |  | L5 |  | OBLG |  |  |  |  |  |  |  |
| OBLG128910 |  | Procure TPC R2 Module Prod. Parts (Padplanes) - Obligation |  | 1d | 2020-03-02 A | 2020-03-02 A | S128200, S101000, S101010 | 100% |  |  |  |  |  |  | Obligation Resource [60298.7 h] | 60,298.7 | S128900 | 0 | S123700 | S123940 |  |  | Not Started | A-TEC | Hemmick,Tom |  | BNL | Procurement | PP5 | MP101030 | Tom Hemmick | SBU |  | POM02.1.02.03.03 |  |  |  |  | 03 |  |  | L5 |  | OBLG |  |  |  |  |  |  |  |
| OBLG129210 |  | Procure TPC R2 Module Prod. Parts (Grids) - Obligation |  | 1d | 2020-03-02 A | 2020-03-02 A | S128200, S101000, S101010 | 100% |  |  |  |  |  |  | Obligation Resource [11148.3 h] | 11,148.26 | S129200 | 0 | S123700 | S123970 |  |  | Not Started | A-TEC | Hemmick,Tom |  | BNL | Procurement | PP5 | MP101040 | Tom Hemmick | SBU |  | POM02.1.02.03.03 |  |  |  |  | 03 |  |  | L5 |  | OBLG |  |  |  |  |  |  |  |
| S128800 |  | Procure TPC R2 Module Prod. Parts (Strongbacks) - Delivery Acceptance |  | 5d | 2020-03-17 A | 2020-03-31 A | S128700 | 100% |  | 2020-04-01 | 2020-04-07 |  |  |  | SBU Contracted Purchase <$2M M&S [9184 h] | 10,450.71 | S128800 | 0 | S123900 | S123930 | S128800 | CA | Not Started | A-TEC | Hemmick,Tom | M4 | BNL | Fab & Assy | PP6 | MP101020 | Tom Hemmick | SBU | TEC | POM02.1.02.03.03 | C | 1.02 | 59703 | 1.02A | 03 | 01 | 5 |  | Delivery | FAB | 190314 ELM BNL Units per TH; rsrc assgn per GRY | UDF_G3 | UDF_G3 | 003 |  |  |  |
| S128500 |  | Procure TPC R2 Module Prod. Parts (Frames) - Delivery Acceptance |  | 5d | 2020-03-18 A | 2020-05-27 A | S128400 | 100% |  | 2020-04-01 | 2020-04-07 |  |  |  | SBU Contracted Purchase <$2M M&S [14601 h] | 16,614.85 | S128500 | 0 | S123900 | S123900 | S128500 | CA | Not Started | A-TEC | Hemmick,Tom | M4 | BNL | Fab & Assy | PP6 | MP101010 | Tom Hemmick | SBU | TEC | POM02.1.02.03.03 | C | 1.02 | 59703 | 1.02A | 03 | 01 | 5 |  | Delivery | FAB | 190314 ELM BNL Units per TH; rsrc assgn per GRY | UDF_G2 | UDF_G3 | 003 | 5482.9019718 | 0.33 |  |
| S129400 |  | Procure TPC R2 Module Prod. Parts (Grids) - Delivery Acceptance |  | 5d | 2020-03-24 A | 2020-03-31 A | S129300 | 100% |  | 2020-04-01 | 2020-04-07 |  |  |  | SBU Contracted Purchase <$2M M&S [9797 h] | 11,148.26 | S129400 | 0 | S123900 | S123990 | S129400 | CA | Not Started | A-TEC | Hemmick,Tom | M4 | BNL | Fab & Assy | PP6 | MP101040 | Tom Hemmick | SBU | TEC | POM02.1.02.03.03 | C | 1.02 | 59703 | 1.02A | 03 | 01 | 5 |  | Delivery | FAB | 190314 ELM BNL Units per TH; rsrc assgn per GRY | UDF_G3 | UDF_G3 | 003 |  |  |  |
| S128900 |  | Procure TPC R2 Module Prod. Parts (Padplanes) - Contract Award(s) | milestone | 0d | 2020-07-01 A | 2020-07-01 A | S128200, S101000, S101010 | 100% |  |  |  |  |  |  |  |  | S128900 | 0 | S123700 | S123940 |  | NOCA | Not Started | A-TEC | Hemmick,Tom |  | BNL | Procurement | PP5 | MP101030 | Tom Hemmick | SBU |  | POM02.1.02.03.03 |  |  |  |  | 03 | 01 | 3 | L5 | Contract Award |  |  | UDF_G2 | UDF_G3 |  |  |  |  |
| S129000 |  | Procure TPC R2 Module Prod. Parts (Padplanes) - Contract/PO - Leadtime |  | 40d | 2020-07-01 A | 2020-08-31 A | S128900 SS, OBLG128910 SS | 100% |  | 2020-07-01 | 2020-08-26 |  |  |  |  |  | S129000 | 0 | S123800 | S123950 |  | NOCA | Not Started |  | Hemmick,Tom |  | BNL | Fab & Assy | PP6 | MP101030 | Tom Hemmick | SBU |  | POM02.1.02.03.03 |  |  |  |  | 03 | 01 | 5 |  |  |  |  |  |  |  |  |  |  |
| S129100 |  | Procure TPC R2 Module Prod. Parts (Padplanes) - Delivery Acceptance |  | 5d | 2020-08-27 A | 2020-10-29 A | S129000 | 100% |  | 2020-09-16 | 2020-09-22 |  |  |  | SBU Contracted Purchase <$2M M&S [52990 h] | 60,298.69 | S129100 | 0 | S123900 | S123960 | S129100 | CA | Not Started | A-TEC | Hemmick,Tom | M4 | BNL | Fab & Assy | PP6 | MP101030 | Tom Hemmick | SBU | TEC | POM02.1.02.03.03 | C | 1.02 | 59703 | 1.02A | 03 | 01 | 5 |  | Delivery | FAB | 190314 ELM BNL Units per TH; rsrc assgn per GRY | UDF_G1 | UDF_G3 | 003 | 60298.687612 | 1 |  |
| S129500 |  | Build TPC R2 Modules |  | 126d | 2020-11-02 A | 2021-06-22 | S120100 SS+22d, S128500, S128800, S129100, S129400, S123700 | 85% | 16d | 2020-11-02 | 2021-05-05 | 61d | 0d | 2021-06-22 | SCI3 Vanderbilt - Unpaid [288 h]; TECH3 Vanderbilt - Unpaid [960 h]; STUDENT Vanderbilt - Unpaid [2400 h] |  | S129500 | 0 | S124600 | S124600 | S129500 | CA | Not Started | T | Hemmick,Tom | L3 | Vandblt | Fab & Assy |  |  | Tom Hemmick | SBU | null | POM02.1.02.03.03 | C | 1.02 | NA | 1.02B | 03 | 01 | 5 |  |  |  |  |  |  |  |  |  | Yes |
| S129600 |  | Test TPC R2 Modules |  | 126d | 2020-11-17 A | 2021-06-22 | S129500 SS+10d | 85% | 16d | 2020-11-17 | 2021-05-19 | 61d | 0d | 2021-06-22 | SCI3 Vanderbilt - Unpaid [288 h]; STUDENT Vanderbilt - Unpaid [2400 h] |  | S129600 | 0 | S124700 | S124700 | S129600 | CA | Not Started | T | Hemmick,Tom | L3 | Vandblt | Test_Components |  |  | Tom Hemmick | SBU | null | POM02.1.02.03.03 | C | 1.02 | NA | 1.02B | 03 | 01 | 7 |  |  |  |  |  |  |  |  |  | Yes |
| S129700 |  | TPC R2 GEM Modules Production Ends | milestone | 0d | 2021-06-22 | 2021-06-22 | S129600 FF |  |  |  |  | 92d | 88d |  |  |  | S129700 | 0 | S124800 | S124800 |  | NOCA | Not Started |  | Hemmick,Tom |  | Vandblt | Fab & Assy |  |  | Tom Hemmick | SBU |  | POM02.1.02.03.03 |  |  |  |  | 03 | 01 | 5 | L2 |  |  |  | UDF_G3 | UDF_G3 |  |  |  |  |

Notes:
- S127900: BNL_UDF_Adhoc Comments: 180426 ELM rsrc per EOB; 180328 ELM rename per GRY / BNL_UDF_Old Activity Name 181221: Procure TPC R2 Module Prod. Parts (Frames, Strongbacks, Padplanes, Grids) - Provide Requirements to Procurement
- S128000: BNL_UDF_Adhoc Comments: 180328 ELM rename per GRY / BNL_UDF_Old Activity Name 181221: Procure TPC R2 Module Prod. Parts (Frames, Strongbacks, Padplanes, Grids) - Prepare & Send Solicitation
- S128100: BNL_UDF_Adhoc Comments: 180328 ELM rename per GRY / BNL_UDF_Old Activity Name 181221: Procure TPC R2 Module Prod. Parts (Frames, Strongbacks, Padplanes, Grids) - Vendor Responses
- S128200: BNL_UDF_Adhoc Comments: 180328 ELM rename per GRY / BNL_UDF_Old Activity Name 181221: Procure TPC R2 Module Prod. Parts (Frames, Strongbacks, Padplanes, Grids) - Vendor Selection
- S128300: BNL_UDF_Adhoc Comments: 180328 ELM rename per GRY / BNL_UDF_Old Activity Name 181221: Procure TPC R2 Module Prod. Parts (Frames) - Contract Award(s)
- S128400: BNL_UDF_Adhoc Comments: 180328 ELM rename per GRY / BNL_UDF_Old Activity Name 181221: Procure TPC R2 Module Prod. Parts (Frames) - Contract/PO - Leadtime
- S128600: BNL_UDF_Adhoc Comments: 180328 ELM add per GRY / BNL_UDF_Old Activity Name 181221: Procure TPC R2 Module Prod. Parts (Strongbacks) - Contract Award(s)
- S128700: BNL_UDF_Adhoc Comments: 180328 ELM add per GRY / BNL_UDF_Old Activity Name 181221: Procure TPC R2 Module Prod. Parts (Strongbacks) - Contract/PO - Leadtime
- S129200: BNL_UDF_Adhoc Comments: 180328 ELM add per GRY / BNL_UDF_Old Activity Name 181221: Procure TPC R2 Module Prod. Parts (Grids) - Contract Award(s)
- S129300: BNL_UDF_Adhoc Comments: 180328 ELM add per GRY / BNL_UDF_Old Activity Name 181221: Procure TPC R2 Module Prod. Parts (Grids) - Contract/PO - Leadtime
- OBLG128310: BNL_UDF_Adhoc Comments: 180328 ELM rename per GRY / BNL_UDF_Old Activity Name 181221: Procure TPC R2 Module Prod. Parts (Frames) - Contract Award(s)
- OBLG128610: BNL_UDF_Adhoc Comments: 180328 ELM add per GRY / BNL_UDF_Old Activity Name 181221: Procure TPC R2 Module Prod. Parts (Strongbacks) - Contract Award(s)
- OBLG128910: BNL_UDF_Adhoc Comments: 180328 ELM add per GRY / BNL_UDF_Old Activity Name 181221: Procure TPC R2 Module Prod. Parts (Padplanes) - Contract Award(s)
- OBLG129210: BNL_UDF_Adhoc Comments: 180328 ELM add per GRY / BNL_UDF_Old Activity Name 181221: Procure TPC R2 Module Prod. Parts (Grids) - Contract Award(s)
- S128800: BNL_UDF_Adhoc Comments: 180328 ELM pred, rename, code per GRY / BNL_UDF_Old Activity Name 181221: Procure TPC R2 Module Prod. Parts (Strongbacks) - Delivery Acceptance
- S128500: BNL_UDF_Adhoc Comments: 180328 ELM rename, pred per GRY / BNL_UDF_Old Activity Name 181221: Procure TPC R2 Module Prod. Parts (Frames) - Delivery Acceptance
- S129400: BNL_UDF_Adhoc Comments: 180328 ELM pred, rename, code per GRY / BNL_UDF_Old Activity Name 181221: Procure TPC R2 Module Prod. Parts (Grids) - Delivery Acceptance
- S128900: BNL_UDF_Adhoc Comments: 180328 ELM add per GRY / BNL_UDF_Old Activity Name 181221: Procure TPC R2 Module Prod. Parts (Padplanes) - Contract Award(s)
- S129000: BNL_UDF_Adhoc Comments: 180328 ELM add per GRY / BNL_UDF_Old Activity Name 181221: Procure TPC R2 Module Prod. Parts (Padplanes) - Contract/PO - Leadtime
- S129100: BNL_UDF_Adhoc Comments: 180328 ELM pred, rename, code per GRY / BNL_UDF_Old Activity Name 181221: Procure TPC R2 Module Prod. Parts (Padplanes) - Delivery Acceptance
- S129500: BNL_UDF_Adhoc Comments: 180410 ELM pred/succ per GRY; 180329 ELM pred per GRY / BNL_UDF_Old Activity Name 181221: Build TPC R2 Modules
- S129600: BNL_UDF_Adhoc Comments: 180410 ELM pred/succ per GRY; 180327 IVS added S116800 FF and deleted wrong successor / BNL_UDF_Old Activity Name 181221: Test TPC R2 Modules
- S129700: BNL_UDF_Old Activity Name 181221: TPC R2 GEM Modules Production Ends

| ID | WBS | Activity | Duration | Start | Finish | Predecessors | Complete | Resources | Cost | BNL_UDF_Temp Text 01 | BNL_UDF_Percent Complete | BNL_UDF_OPC TEC (deprecated) | BNL_UDF_Temp Date 01 | BNL_UDF_Old Activity ID 181221 | RG Check | BNL_Activity Status | BNL_Fund Source | BNL_Estimator | BNL_Cost Basis | BNL_Location | BNL_EDIA | BNL_CAM | BNL_Institution | BNL_R&D FY18-19 | BNL_OPC TEC (deprecated) | BNL_WBS | BNL_EVT | BNL_WBS_Hierarchical | Completed | PMP Summary Part1 | PMP Summary Part2 | Additional EVT documentation required | BNL_UDF_Status Comments | BNL_DOE OPC | BNL_Account Number | BNL_PCR ID | Cost = Awarded Proc or Mgmt | BNL_Cobra WP | BNL_Master Control Account | BNL_Cobra Control Account | Indicator - Procurement | BNL_UDF_Adhoc Comments | BNL_Proc Sig Phase | BNL_Proc Sig | SPH Proc Register |
| --- | --- | --- | --- | --- | --- | --- | --- | --- | --- | --- | --- | --- | --- | --- | --- | --- | --- | --- | --- | --- | --- | --- | --- | --- | --- | --- | --- | --- | --- | --- | --- | --- | --- | --- | --- | --- | --- | --- | --- | --- | --- | --- | --- | --- | --- |
|  | 04 | **TPC R3 Modules** |  | 2018-10-01 | 2021-06-18 |  |  |  |  |  |  |  |  |  |  |  |  |  |  |  |  |  |  |  |  |  |  |  |  |  |  |  |  |  |  |  |  |  |  |  |  |  |  |  |  |
|  | 01 | **TPC R3 Module Factory Preparation** |  | 2018-10-01 | 2019-08-30 |  |  |  |  |  |  |  |  |  |  |  |  |  |  |  |  |  |  |  |  |  |  |  |  |  |  |  |  |  |  |  |  |  |  |  |  |  |  |  |  |
| S129800 |  | Prepare TPC R3a Factory Clean Facility Labor | 112d | 2018-10-01 A | 2019-03-15 A | S114600 | 100% |  |  | S129800 | 40 | S124900 | 2019-03-15 | S124900 | NOCA | Completed | T | Hemmick,Tom | L4 | WIS | Fab & Assy | Tom Hemmick | SBU | TPC R1-3 Fact.Prep | null | POM02.1.02.04.01 | C | 01 | yes | 01 | 4 | Yes |  |  |  |  |  |  |  |  |  |  |  |  |  |
| S129900 |  | Prepare TPC R3a Factory Clean Facility M&S | 112d | 2018-10-01 A | 2019-03-15 A | S114600 | 100% |  |  | S129900 | 40 | S125000 | 2019-03-15 | S125000 | NOCA | Completed | A-OPC | Hemmick,Tom | M4 | WIS | Fab & Assy | Tom Hemmick | SBU | TPC R1-3 Fact.Prep | OPC | POM02.1.02.04.01 | C | 01 | yes | 01 | 4 | Yes | 190314 ELM BNL Units per TH; rsrc assgn per GRY | OPC000500 | 16701 | 003 | Yes |  |  |  |  |  |  |  |  |
| S130000 |  | Prepare TPC R3a Factory Tooling Labor | 208d | 2018-10-01 A | 2019-07-31 A | S114600 | 100% | SCI3 WIS - Unpaid [160 h]; STUDENT WIS - Unpaid [480 h] |  | S130000 | 40 | S125100 | 2019-03-15 | S125100 | CA | Completed | T | Hemmick,Tom | L4 | WIS | Fab & Assy | Tom Hemmick | SBU | TPC R1-3 Fact.Prep | null | POM02.1.02.04.01 | C | 01 |  | 01 | 4 | Yes |  |  | NA |  |  | S130000 | 1.02 | 1.02B |  |  |  |  |  |
| S130100 |  | Prepare TPC R3a Factory Tooling M&S | 166d | 2018-10-01 A | 2019-05-31 A | S114600 | 100% |  |  | S130100 | 40 | S125200 | 2019-03-15 | S125200 | NOCA | Completed | A-OPC | Hemmick,Tom | M4 | WIS | Fab & Assy | Tom Hemmick | SBU | TPC R1-3 Fact.Prep | OPC | POM02.1.02.04.01 | C | 01 | yes | 01 | 4 | Yes | 190314 ELM BNL Units per TH; rsrc assgn per GRY | OPC000500 | 16701 | 003 | Yes |  |  |  |  |  |  |  |  |
| S130200 |  | Prepare TPC R3b Factory Clean Facility Labor | 112d | 2018-10-01 A | 2019-03-15 A | S114600 | 100% |  |  | S130200 | 40 | S125300 | 2019-03-15 | S125300 | NOCA | Completed | T | Hemmick,Tom | L4 | Temple | Fab & Assy | Tom Hemmick | SBU | TPC R1-3 Fact.Prep | null | POM02.1.02.04.01 | C | 01 | yes | 01 | 4 | Yes |  |  |  |  |  |  |  |  |  |  |  |  |  |
| S130300 |  | Prepare TPC R3b Factory Clean Facility M&S | 112d | 2018-10-01 A | 2019-03-15 A | S114600 | 100% |  |  | S130300 | 40 | S125400 | 2019-03-15 | S125400 | NOCA | Completed | A-OPC | Hemmick,Tom | M4 | Temple | Fab & Assy | Tom Hemmick | SBU | TPC R1-3 Fact.Prep | OPC | POM02.1.02.04.01 | C | 01 | yes | 01 | 4 | Yes | 190314 ELM BNL Units per TH; rsrc assgn per GRY | OPC000500 | 16701 | 003 | Yes |  |  |  |  |  |  |  |  |
| S130400 |  | Prepare TPC R3b Factory Tooling Labor | 230d | 2018-10-01 A | 2019-08-30 A | S114600 | 100% | SCI3 Temple - Unpaid [160 h]; STUDENT Temple - Unpaid [480 h] |  | S130400 | 40 | S125500 | 2019-03-15 | S125500 | CA | Completed | T | Hemmick,Tom | L4 | Temple | Fab & Assy | Tom Hemmick | SBU | TPC R1-3 Fact.Prep | null | POM02.1.02.04.01 | C | 01 |  | 01 | 4 | Yes |  |  | NA |  |  | S130400 | 1.02 | 1.02B |  |  |  |  |  |
| S130500 |  | Prepare TPC R3b Factory Tooling M&S | 166d | 2018-10-01 A | 2019-05-31 A | S114600 | 100% |  |  | S130500 | 40 | S125600 | 2019-03-15 | S125600 | NOCA | Completed | A-OPC | Hemmick,Tom | M4 | Temple | Fab & Assy | Tom Hemmick | SBU | TPC R1-3 Fact.Prep | OPC | POM02.1.02.04.01 | C | 01 | yes | 01 | 4 | Yes | 190314 ELM BNL Units per TH; rsrc assgn per GRY | OPC000500 | 16701 | 003 | Yes |  |  |  |  |  |  |  |  |
| S130102 |  | Prepare TPC R3a Factory Tooling M&S Split | 44d | 2019-07-01 A | 2019-08-30 A | S130100 | 100% | Weizmann Contracted Purchase <$2M M&S [3600 h] | 3,971.75 | S130100 | 40 | S125200 | 2019-03-15 | S125200 | CA | Completed | A-OPC | Hemmick,Tom | M4 | WIS | Fab & Assy | Tom Hemmick | SBU | TPC R1-3 Fact.Prep | OPC | POM02.1.02.04.01 | C | 01 |  | 01 | 4 | Yes | 190314 ELM BNL Units per TH; rsrc assgn per GRY | OPC000500 | 16701 | 003 | Yes | S130102 | 1.02 | 1.02A | UDF_G3 |  |  |  |  |
| S130502 |  | Prepare TPC R3b Factory Tooling M&S Split | 22d | 2019-08-01 A | 2019-08-30 A | S130500 | 100% | Temple Contracted Purchase <$2M M&S [3600 h] | 3,971.75 | S130500 | 40 | S125600 | 2019-03-15 | S125600 | CA | Completed | A-OPC | Hemmick,Tom | M4 | Temple | Fab & Assy | Tom Hemmick | SBU | TPC R1-3 Fact.Prep | OPC | POM02.1.02.04.01 | C | 01 |  | 01 | 4 | Yes | 190314 ELM BNL Units per TH; rsrc assgn per GRY | OPC000500 | 16701 | 003 | Yes | S130502 | 1.02 | 1.02A | UDF_G3 |  |  |  |  |
|  | 02 | **TPC R3 Pre-Production Module** |  | 2018-10-30 | 2019-09-30 |  |  |  |  |  |  |  |  |  |  |  |  |  |  |  |  |  |  |  |  |  |  |  |  |  |  |  |  |  |  |  |  |  |  |  |  |  |  |  |  |
| S130600 |  | Design TPC R3 Pre-Production Module (strongback, frame, grid, pad, GEMs) | 21d | 2018-10-30 A | 2018-11-30 A | S115800, S115900, S116100 | 100% |  |  | S130600 | 100 | S125700 |  | S125700 | NOCA | Completed | B_T | Hemmick,Tom | L4 | SBU | Design | Tom Hemmick | SBU | TPC R1-3 Pre-pro Mod | null | POM02.1.02.04.02 | C | 02 | yes | 1 | 1 |  |  |  | 16709 |  |  |  |  |  |  | 180426 ELM rsrc per EOB |  |  |  |
| S131100 |  | Procure TPC R3 Pre-Production Module Grids Labor | 20d | 2018-11-30 A | 2018-12-28 A | S130600 | 100% |  |  | S131100 | 100 | S126700 |  | S126700 | NOCA | Completed | B | Hemmick,Tom | L4 | BNL | Procurement | Tom Hemmick | SBU | TPC R1-3 Pre-pro Mod | null | POM02.1.02.04.02 | C | 02 | yes | 01 | 2 |  |  |  | 16709 |  |  |  |  |  |  |  |  |  |  |
| S131200 |  | Procure TPC R3 Pre-Production Module Grids M&S | 20d | 2018-11-30 A | 2018-12-28 A | S130600 | 100% |  |  | S131200 | 100 | S126800 |  | S126800 | NOCA | Completed | A-OPC | Hemmick,Tom | M4 | BNL | Fab & Assy | Tom Hemmick | SBU | TPC R1-3 Pre-pro Mod | OPC | POM02.1.02.04.02 | C | 02 | yes | 01 | 4 |  | 190314 ELM rsrc assgn per GRY | OPC000600 | 16701 | 003 | Yes |  |  |  |  |  | PP6 | MP208100 |  |
| S130700 |  | Procure TPC R3 Pre-Production Module Stongbacks Labor | 21d | 2019-03-01 A | 2019-03-29 A | S130600 | 100% |  |  | S130700 | 0 | S125800 | 2019-01-31 | S125800 | NOCA | Completed | B | Hemmick,Tom | L4 | BNL | Procurement | Tom Hemmick | SBU | TPC R1-3 Pre-pro Mod | null | POM02.1.02.04.02 | C | 02 | yes | 01 | 2 |  |  |  | 16709 |  |  |  |  |  |  |  |  |  |  |
| S130800 |  | Procure TPC R3 Pre-Production Module Stongbacks M&S | 21d | 2019-03-01 A | 2019-03-29 A | S130600 | 100% |  |  | S130800 | 0 | S125900 | 2019-01-31 | S125900 | NOCA | Completed | A-OPC | Hemmick,Tom | M4 | BNL | Fab & Assy | Tom Hemmick | SBU | TPC R1-3 Pre-pro Mod | OPC | POM02.1.02.04.02 | C | 02 | yes | 01 | 4 |  | 190314 ELM rsrc assgn per GRY | OPC000600 | 16701 | 003 | Yes |  |  |  |  |  | PP6 | MP208100 |  |
| S131300 |  | Procure TPC R3 Pre-Production Module Pad Planes Labor | 21d | 2019-03-01 A | 2019-03-29 A | S130600 | 100% |  |  | S131300 | 0 | S126900 | 2019-01-31 | S126900 | NOCA | Completed | B | Hemmick,Tom | L4 | BNL | Procurement | Tom Hemmick | SBU | TPC R1-3 Pre-pro Mod | null | POM02.1.02.04.02 | C | 02 | yes | 01 | 2 |  |  |  | 16709 |  |  |  |  |  |  |  |  |  |  |
| S131400 |  | Procure TPC R3 Pre-Production Module Pad Planes M&S | 21d | 2019-03-01 A | 2019-03-29 A | S130600 | 100% |  |  | S131400 | 0 | S127000 | 2019-01-31 | S127000 | NOCA | Completed | A-OPC | Hemmick,Tom | M4 | BNL | Fab & Assy | Tom Hemmick | SBU | TPC R1-3 Pre-pro Mod | OPC | POM02.1.02.04.02 | C | 02 | yes | 01 | 4 |  | 190314 ELM rsrc assgn per GRY | OPC000600 | 16701 | 003 | Yes |  |  |  |  |  | PP6 | MP208100 |  |
| S131900 |  | Assemble TPC R3b Pre-Production Module in TPC R3b Factory | 22d | 2019-08-01 A | 2019-08-30 A | S130200, S130300, S130400, S130500, S130700, S130800, S130900, S131100, S131200, S131300, S131400, S131500, S131600, S131000, S130502 | 100% | SCI3 Temple - Unpaid [240 h]; STUDENT Temple - Unpaid [240 h] |  | S131900 | 0 | S127500 |  | S127500 | CA | Completed | T | Hemmick,Tom | L4 | Temple | Fab & Assy | Tom Hemmick | SBU | TPC R1-3 Pre-pro Mod | null | POM02.1.02.04.02 | C | 02 |  | 01 | 4 |  |  |  | NA |  |  | S131900 | 1.02 | 1.02B |  | 180328 ELM pred per GRY |  |  |  |
| S132000 |  | Test TPC R3b Pre-Production Module | 22d | 2019-08-01 A | 2019-08-30 A | S131900 | 100% | SCI3 Temple - Unpaid [80 h]; STUDENT Temple - Unpaid [80 h] |  | S132000 | 0 | S127600 |  | S127600 | CA | Completed | T | Hemmick,Tom | L4 | Temple | Test_Components | Tom Hemmick | SBU | TPC R1-3 Pre-pro Mod | null | POM02.1.02.04.02 | C | 02 |  | 01 | 7 |  |  |  | NA |  |  | S132000 | 1.02 | 1.02B |  |  |  |  |  |
| S130900 |  | Procure TPC R3 Pre-Production Module Frames - Labor | 21d | 2019-08-01 A | 2019-08-29 A | S130600 | 100% | TECH3 PO M [24 h] | 2,659.16 | S130900 | 0 | S126000 | 2019-01-31 | S126000 | CA | Completed | B | Hemmick,Tom | L4 | BNL | Procurement | Tom Hemmick | SBU | TPC R1-3 Pre-pro Mod | null | POM02.1.02.04.02 | C | 02 |  | 01 | 2 |  |  |  | 16709 |  |  | S130900 | 1.02 | 1.02B |  | 180328 ELM Act Name, pred per GRY |  |  |  |
| S131000 |  | Procure TPC R3 Pre-Production Module frames - M&S | 21d | 2019-08-01 A | 2019-08-29 A | S130600, S130900 SS | 100% | SBU Contracted Purchase <$2M M&S [2000 h] | 2,206.53 | S131000 | 0 | S126600 | 2019-01-31 | S126600 | CA | Completed | A-OPC | Hemmick,Tom | M4 | BNL | Fab & Assy | Tom Hemmick | SBU | TPC R1-3 Pre-pro Mod | OPC | POM02.1.02.04.02 | C | 02 |  | 01 | 4 |  | 190314 ELM rsrc assgn per GRY | OPC000600 | 16701 | 003 | Yes | S131000 | 1.02 | 1.02A | UDF_G2 | 180328 ELM Act Name, pred per GRY | PP6 | MP208100 | Combined |
| S131500 |  | Procure TPC R3 Pre-Production Module GEMs Labor | 21d | 2019-08-01 A | 2019-08-29 A | S130600 | 100% | TECH3 PO M [24 h] | 2,659.16 | S131500 | 0 | S127100 | 2019-01-31 | S127100 | CA | Completed | B | Hemmick,Tom | L4 | BNL | Procurement | Tom Hemmick | SBU | TPC R1-3 Pre-pro Mod | null | POM02.1.02.04.02 | C | 02 |  | 01 | 2 |  |  |  | 16709 |  |  | S131500 | 1.02 | 1.02B |  |  |  |  |  |
| S131600 |  | Procure TPC R3 Pre-Production Module GEMs M&S | 21d | 2019-08-01 A | 2019-08-29 A | S130600 | 100% | SBU Contracted Purchase <$2M M&S [10000 h] | 11,032.65 | S131600 | 0 | S127200 | 2019-01-31 | S127200 | CA | Completed | A-OPC | Hemmick,Tom | M4 | BNL | Fab & Assy | Tom Hemmick | SBU | TPC R1-3 Pre-pro Mod | OPC | POM02.1.02.04.02 | C | 02 |  | 01 | 4 |  | 190314 ELM rsrc assgn per GRY | OPC000600 | 16701 | 003 | Yes | S131600 | 1.02 | 1.02A | UDF_G2 |  | PP6 | MP208100 | Combined |
| S131700 |  | Assemble TPC R3a Pre-Production Module in TPC R3a Factory | 20d | 2019-09-03 A | 2019-09-30 A | S130700, S130900, S131100, S131300, S131500, S130800, S131000, S131200, S131400, S131600, S129800, S129900, S130000, S130102 | 100% | SCI3 WIS - Unpaid [240 h]; STUDENT WIS - Unpaid [240 h] |  | S131700 | 0 | S127300 |  | S127300 | CA | Completed | T | Hemmick,Tom | L4 | WIS | Fab & Assy | Tom Hemmick | SBU | TPC R1-3 Pre-pro Mod | null | POM02.1.02.04.02 | C | 02 |  | 01 | 4 |  |  |  | NA |  |  | S131700 | 1.02 | 1.02B |  |  |  |  |  |
| S131800 |  | Test TPC R3a Pre-Production Module | 20d | 2019-09-03 A | 2019-09-30 A | S131700 | 100% | SCI3 WIS - Unpaid [80 h]; STUDENT WIS - Unpaid [80 h] |  | S131800 | 0 | S127400 |  | S127400 | CA | Completed | T | Hemmick,Tom | L4 | WIS | Test_Components | Tom Hemmick | SBU | TPC R1-3 Pre-pro Mod | null | POM02.1.02.04.02 | C | 02 |  | 01 | 7 |  |  |  | NA |  |  | S131800 | 1.02 | 1.02B |  |  |  |  |  |

Notes:
- S129800: BNL_UDF_Old Activity Name 181221: Prepare TPC R3a Factory Clean Facility Labor
- S129900: BNL_UDF_Old Activity Name 181221: Prepare TPC R3a Factory Clean Facility M&S
- S130000: BNL_UDF_Old Activity Name 181221: Prepare TPC R3a Factory Tooling Labor
- S130100: BNL_UDF_Old Activity Name 181221: Prepare TPC R3a Factory Tooling M&S
- S130200: BNL_UDF_Old Activity Name 181221: Prepare TPC R3b Factory Clean Facility Labor
- S130300: BNL_UDF_Old Activity Name 181221: Prepare TPC R3b Factory Clean Facility M&S
- S130400: BNL_UDF_Old Activity Name 181221: Prepare TPC R3b Factory Tooling Labor
- S130500: BNL_UDF_Old Activity Name 181221: Prepare TPC R3b Factory Tooling M&S
- S130102: BNL_UDF_Old Activity Name 181221: Prepare TPC R3a Factory Tooling M&S
- S130502: BNL_UDF_Old Activity Name 181221: Prepare TPC R3b Factory Tooling M&S
- S130600: BNL_UDF_Old Activity Name 181221: Design TPC R3 Pre-Production Module (strongback, frame, grid, pad, GEMs)
- S131100: BNL_UDF_Old Activity Name 181221: Procure TPC R3 Pre-Production Module Grids Labor
- S131200: BNL_UDF_Old Activity Name 181221: Procure TPC R3 Pre-Production Module Grids M&S
- S130700: BNL_UDF_Old Activity Name 181221: Procure TPC R3 Pre-Production Module Stongbacks Labor
- S130800: BNL_UDF_Old Activity Name 181221: Procure TPC R3 Pre-Production Module Stongbacks M&S
- S131300: BNL_UDF_Old Activity Name 181221: Procure TPC R3 Pre-Production Module Pad Planes Labor
- S131400: BNL_UDF_Old Activity Name 181221: Procure TPC R3 Pre-Production Module Pad Planes M&S
- S131900: BNL_UDF_Old Activity Name 181221: Assemble TPC R3b Pre-Production Module in TPC R3b Factory
- S132000: BNL_UDF_Old Activity Name 181221: Test TPC R3b Pre-Production Module
- S130900: BNL_UDF_Old Activity Name 181221: Procure TPC R3 Pre-Production Module Frames - Labor
- S131000: BNL_UDF_Old Activity Name 181221: Procure TPC R3 Pre-Production Module frames - M&S
- S131500: BNL_UDF_Old Activity Name 181221: Procure TPC R3 Pre-Production Module GEMs Labor
- S131600: BNL_UDF_Old Activity Name 181221: Procure TPC R3 Pre-Production Module GEMs M&S
- S131700: BNL_UDF_Old Activity Name 181221: Assemble TPC R3a Pre-Production Module in TPC R3a Factory
- S131800: BNL_UDF_Old Activity Name 181221: Test TPC R3a Pre-Production Module

| ID | WBS | Activity | Type | Duration | Start | Finish | Predecessors | Complete | Remaining | Planned start | Planned finish | Total float | Free float | Expected finish | Resources | Cost | BNL_UDF_Temp Text 01 | BNL_UDF_Adhoc Comments | BNL_UDF_Percent Complete | BNL_UDF_OPC TEC (deprecated) | BNL_UDF_Old Activity ID 181221 | BNL_Cobra WP | RG Check | BNL_Activity Status | BNL_Fund Source | BNL_Estimator | BNL_Cost Basis | BNL_Location | BNL_EDIA | BNL_Proc Sig Phase | BNL_Proc Sig | BNL_CAM | BNL_Institution | BNL_OPC TEC (deprecated) | BNL_WBS | BNL_EVT | BNL_Master Control Account | BNL_Account Number | BNL_Cobra Control Account | BNL_WBS_Hierarchical | PMP Summary Part1 | PMP Summary Part2 | BNL_Milestone Level | SPH Proc Register | BNL_UDF_Status Comments | Indicator - Procurement | Indicator - Float | BNL_Obligation | BNL_PCR ID | BNL_UDF_Remaining Tot Cost | BNL_UDF_Percent_remaining | Additional EVT documentation required |
| --- | --- | --- | --- | --- | --- | --- | --- | --- | --- | --- | --- | --- | --- | --- | --- | --- | --- | --- | --- | --- | --- | --- | --- | --- | --- | --- | --- | --- | --- | --- | --- | --- | --- | --- | --- | --- | --- | --- | --- | --- | --- | --- | --- | --- | --- | --- | --- | --- | --- | --- | --- | --- |
|  | 03 | **TPC R3 Module Production** |  |  | 2019-10-02 | 2021-06-18 |  |  |  |  |  |  |  |  |  |  |  |  |  |  |  |  |  |  |  |  |  |  |  |  |  |  |  |  |  |  |  |  |  |  |  |  |  |  |  |  |  |  |  |  |  |  |
| S132100 |  | Procure TPC R3 Module Prod. Parts (Frames, Strongbacks, Padplanes, Grids) - Provide Requirements to Procurement |  | 5d | 2019-10-02 A | 2019-10-08 A | S123800 | 100% |  |  |  |  |  |  | TECH3 PO M [128 h]; PROF4 AM [64 h] | 24,032.59 | S132100 | 180426 ELM rsrc per EOB; 180328 ELM rename per GRY | 0 | S127700 | S127700 | S132100 | CA | Completed | B | Hemmick,Tom | L3 | BNL | Procurement | PP1 | MP101200 | Tom Hemmick | SBU | null | POM02.1.02.04.03 | C | 1.02 | 16709 | 1.02B | 03 | 01 | 3 |  |  |  |  |  |  |  |  |  |  |
| S132200 |  | Procure TPC R3 Module Prod. Parts (Frames, Strongbacks, Padplanes, Grids) - Prepare & Send Solicitation |  | 30d | 2019-10-09 A | 2019-12-31 A | S132100 | 100% |  | 2019-10-09 | 2019-11-21 |  |  |  |  |  | S132200 | 180328 ELM rename per GRY | 0 | S127800 | S127800 |  | NOCA | In Progress |  | Hemmick,Tom |  | BNL | Procurement | PP2 | MP101200 | Tom Hemmick | SBU |  | POM02.1.02.04.03 |  |  |  |  | 03 | 01 | 3 |  |  |  |  |  |  |  |  |  |  |
| S132300 |  | Procure TPC R3 Module Prod. Parts (Frames, Strongbacks, Padplanes, Grids) - Vendor Responses |  | 10d | 2019-12-02 A | 2020-02-03 A | S132200 | 100% |  | 2020-01-15 | 2020-01-29 |  |  |  |  |  | S132300 | 180328 ELM rename per GRY | 0 | S127900 | S127900 |  | NOCA | Not Started |  | Hemmick,Tom |  | BNL | Procurement | PP3 | MP101200 | Tom Hemmick | SBU |  | POM02.1.02.04.03 |  |  |  |  | 03 | 01 | 3 |  |  |  |  |  |  |  |  |  |  |
| S132500 |  | Procure TPC R3 Module Prod. Parts (Frames) - Contract Award(s) | milestone | 0d | 2020-02-04 A | 2020-02-04 A | S132400, S101000, S101010 | 100% |  | 2020-03-04 | 2020-03-04 |  |  |  |  |  | S132500 | 180328 ELM rename per GRY | 0 | S128100 | S128100 |  | NOCA | Not Started | A-TEC | Hemmick,Tom |  | BNL | Procurement | PP5 | MP101210 | Tom Hemmick | SBU |  | POM02.1.02.04.03 |  |  |  |  | 03 | 01 | 3 | L5 | Contract Award |  |  |  |  |  |  |  |  |
| S132400 |  | Procure TPC R3 Module Prod. Parts (Frames, Strongbacks, Padplanes, Grids) - Vendor Selection |  | 20d | 2020-02-04 A | 2020-02-28 A | S132300 | 100% |  | 2020-02-04 | 2020-03-03 |  |  |  |  |  | S132400 | 180328 ELM rename per GRY | 0 | S128000 | S128000 |  | NOCA | Not Started |  | Hemmick,Tom |  | BNL | Procurement | PP4 | MP101200 | Tom Hemmick | SBU |  | POM02.1.02.04.03 |  |  |  |  | 03 | 01 | 3 |  |  |  |  |  |  |  |  |  |  |
| S132600 |  | Procure TPC R3 Module Prod. Parts (Frames) - Contract/PO - Leadtime |  | 40d | 2020-02-05 A | 2020-03-31 A | S132500 SS, OBLG132510 SS | 100% |  | 2020-03-04 | 2020-04-28 |  |  |  |  |  | S132600 | 180328 ELM rename per GRY | 0 | S128200 | S128200 |  | NOCA | Not Started |  | Hemmick,Tom |  | BNL | Fab & Assy | PP6 | MP101210 | Tom Hemmick | SBU |  | POM02.1.02.04.03 |  |  |  |  | 03 | 01 | 5 |  |  |  |  |  |  |  |  |  |  |
| S132800 |  | Procure TPC R3 Module Prod. Parts (Strongbacks) - Contract Award(s) | milestone | 0d | 2020-02-05 A | 2020-02-05 A | S132400, S101000, S101010 | 100% |  | 2020-03-04 | 2020-03-04 |  |  |  |  |  | S132800 | 180328 ELM add per GRY | 0 | S128100 | S128310 |  | NOCA | Not Started | A-TEC | Hemmick,Tom |  |  | Procurement | PP5 | MP101220 | Tom Hemmick | SBU |  | POM02.1.02.04.03 |  |  |  |  | 03 | 01 | 3 | L5 | Contract Award |  |  |  |  |  |  |  |  |
| S132900 |  | Procure TPC R3 Module Prod. Parts (Strongbacks) - Contract/PO - Leadtime |  | 40d | 2020-02-05 A | 2020-03-31 A | S132800 SS, OBLG132810 SS | 100% |  | 2020-03-04 | 2020-04-28 |  |  |  |  |  | S132900 | 180328 ELM add per GRY | 0 | S128200 | S128320 |  | NOCA | Not Started |  | Hemmick,Tom |  |  | Fab & Assy | PP6 | MP101220 | Tom Hemmick | SBU |  | POM02.1.02.04.03 |  |  |  |  | 03 | 01 | 5 |  |  |  |  |  |  |  |  |  |  |
| S133400 |  | Procure TPC R3 Module Prod. Parts (Grids) - Contract Award(s) | milestone | 0d | 2020-02-05 A | 2020-02-05 A | S132400, S101000, S101010 | 100% |  | 2020-03-04 | 2020-03-04 |  |  |  |  |  | S133400 | 180328 ELM add per GRY | 0 | S128100 | S128370 |  | NOCA | Not Started | A-TEC | Hemmick,Tom |  |  | Procurement | PP5 | MP101240 | Tom Hemmick | SBU |  | POM02.1.02.04.03 |  |  |  |  | 03 | 01 | 3 | L5 | Contract Award |  |  |  |  |  |  |  |  |
| S133500 |  | Procure TPC R3 Module Prod. Parts (Grids) - Contract/PO - Leadtime |  | 40d | 2020-02-05 A | 2020-03-31 A | S133400 SS, OBLG133410 SS | 100% |  | 2020-03-04 | 2020-04-28 |  |  |  |  |  | S133500 | 180328 ELM add per GRY | 0 | S128200 | S128380 |  | NOCA | Not Started |  | Hemmick,Tom |  |  | Fab & Assy | PP6 | MP101240 | Tom Hemmick | SBU |  | POM02.1.02.04.03 |  |  |  |  | 03 | 01 | 5 |  |  |  |  |  |  |  |  |  |  |
| S133000 |  | Procure TPC R3 Module Prod. Parts (Strongbacks) - Delivery Acceptance |  | 5d | 2020-03-17 A | 2020-03-31 A | S132900 | 100% |  | 2020-04-01 | 2020-04-07 |  |  |  | SBU Contracted Purchase <$2M M&S [10762 h] | 12,246.36 | S133000 | 180328 ELM add per GRY | 0 | S128300 | S128330 | S133000 | CA | Not Started | A-TEC | Hemmick,Tom | M4 |  | Fab & Assy | PP6 | MP101220 | Tom Hemmick | SBU | TEC | POM02.1.02.04.03 | C | 1.02 | 59703 | 1.02A | 03 | 01 | 5 |  | Delivery | 190314 ELM BNL Units per TH | UDF_G3 | UDF_G3 | FAB | 003 |  |  |  |
| S132700 |  | Procure TPC R3 Module Prod. Parts (Frames) - Delivery Acceptance |  | 5d | 2020-03-18 A | 2020-04-30 A | S132600 | 100% |  | 2020-04-01 | 2020-04-07 |  |  |  | SBU Contracted Purchase <$2M M&S [16819 h] | 19,138.77 | S132700 | 180328 ELM rename, pred per GRY | 0 | S128300 | S128300 | S132700 | CA | Not Started | A-TEC | Hemmick,Tom | M4 | BNL | Fab & Assy | PP6 | MP101210 | Tom Hemmick | SBU | TEC | POM02.1.02.04.03 | C | 1.02 | 59703 | 1.02A | 03 | 01 | 5 |  | Delivery | 190314 ELM BNL Units per TH | UDF_G2 | UDF_G3 | FAB | 003 |  |  |  |
| S133600 |  | Procure TPC R3 Module Prod. Parts (Grids) - Delivery Acceptance |  | 5d | 2020-03-24 A | 2020-03-31 A | S133500 | 100% |  | 2020-04-01 | 2020-04-07 |  |  |  | SBU Contracted Purchase <$2M M&S [10288 h] | 11,706.98 | S133600 | 180328 ELM add per GRY | 0 | S128300 | S128390 | S133600 | CA | Not Started | A-TEC | Hemmick,Tom | M4 |  | Fab & Assy | PP6 | MP101240 | Tom Hemmick | SBU | TEC | POM02.1.02.04.03 | C | 1.02 | 59703 | 1.02A | 03 | 01 | 5 |  | Delivery | 190314 ELM BNL Units per TH | UDF_G3 | UDF_G3 | FAB | 003 |  |  |  |
| S133100 |  | Procure TPC R3 Module Prod. Parts (Padplanes) - Contract Award(s) | milestone | 0d | 2020-04-01 A | 2020-04-01 A | S132400, S101000, S101010 | 100% |  |  |  |  |  |  |  |  | S133100 | 180328 ELM add per GRY | 0 | S128100 | S128340 |  | NOCA | Not Started | A-TEC | Hemmick,Tom |  |  | Procurement | PP5 | MP101230 | Tom Hemmick | SBU |  | POM02.1.02.04.03 |  |  |  |  | 03 | 01 | 3 | L5 | Contract Award |  |  |  |  |  |  |  |  |
| S133200 |  | Procure TPC R3 Module Prod. Parts (Padplanes) - Contract/PO - Leadtime |  | 40d | 2020-04-01 A | 2020-06-15 A | S133100 SS, OBLG133110 SS | 100% |  | 2020-04-01 | 2020-05-27 |  |  |  |  |  | S133200 | 180328 ELM add per GRY | 0 | S128200 | S128350 |  | NOCA | Not Started |  | Hemmick,Tom |  |  | Fab & Assy | PP6 | MP101230 | Tom Hemmick | SBU |  | POM02.1.02.04.03 |  |  |  |  | 03 | 01 | 5 |  |  |  |  |  |  |  |  |  |  |
| S133300 |  | Procure TPC R3 Module Prod. Parts (Padplanes) - Delivery Acceptance |  | 5d | 2020-06-16 A | 2020-07-22 A | S133200 | 100% |  | 2020-07-16 | 2020-07-22 |  |  |  | SBU Contracted Purchase <$2M M&S [71770 h] | 81,668.93 | S133300 | 180328 ELM add per GRY | 0 | S128300 | S128360 | S133300 | CA | Not Started | A-TEC | Hemmick,Tom | M4 |  | Fab & Assy | PP6 | MP101230 | Tom Hemmick | SBU | TEC | POM02.1.02.04.03 | C | 1.02 | 59703 | 1.02A | 03 | 01 | 5 |  | Delivery | 190314 ELM BNL Units per TH | UDF_G1 | UDF_G3 | FAB | 003 | 81668.933948 | 1 |  |
| OBLG132510 |  | Procure TPC R3 Module Prod. Parts (Frames) - Obligation |  | 1d | 2020-09-01 A | 2020-09-01 A | S132400, S101000, S101010 | 100% |  |  |  |  |  |  | Obligation Resource [19138.8 h] | 19,138.78 | S132500 | 180328 ELM rename per GRY | 0 | S128100 | S128100 |  |  | Not Started | A-TEC | Hemmick,Tom |  | BNL | Procurement | PP5 | MP101210 | Tom Hemmick | SBU |  | POM02.1.02.04.03 |  |  |  |  | 03 |  |  | L5 |  |  |  |  | OBLG |  |  |  |  |
| OBLG132810 |  | Procure TPC R3 Module Prod. Parts (Strongbacks) - Obligation |  | 1d | 2020-09-01 A | 2020-09-01 A | S132400, S101000, S101010 | 100% |  |  |  |  |  |  | Obligation Resource [12246.4 h] | 12,246.36 | S132800 | 180328 ELM add per GRY | 0 | S128100 | S128310 |  |  | Not Started | A-TEC | Hemmick,Tom |  |  | Procurement | PP5 | MP101220 | Tom Hemmick | SBU |  | POM02.1.02.04.03 |  |  |  |  | 03 |  |  | L5 |  |  |  |  | OBLG |  |  |  |  |
| OBLG133110 |  | Procure TPC R3 Module Prod. Parts (Padplanes) - Obligation |  | 1d | 2020-09-01 A | 2020-09-01 A | S132400, S101000, S101010 | 100% |  |  |  |  |  |  | Obligation Resource [81668.9 h] | 81,668.95 | S133100 | 180328 ELM add per GRY | 0 | S128100 | S128340 |  |  | Not Started | A-TEC | Hemmick,Tom |  |  | Procurement | PP5 | MP101230 | Tom Hemmick | SBU |  | POM02.1.02.04.03 |  |  |  |  | 03 |  |  | L5 |  |  |  |  | OBLG |  |  |  |  |
| OBLG133410 |  | Procure TPC R3 Module Prod. Parts (Grids) - Obligation |  | 1d | 2020-09-01 A | 2020-09-01 A | S132400, S101000, S101010 | 100% |  |  |  |  |  |  | Obligation Resource [11707 h] | 11,706.98 | S133400 | 180328 ELM add per GRY | 0 | S128100 | S128370 |  |  | Not Started | A-TEC | Hemmick,Tom |  |  | Procurement | PP5 | MP101240 | Tom Hemmick | SBU |  | POM02.1.02.04.03 |  |  |  |  | 03 |  |  | L5 |  |  |  |  | OBLG |  |  |  |  |
| S133700 |  | Build TPC R3a Modules |  | 126d | 2020-10-06 A | 2021-06-04 | S120100 SS+22d, S132700, S133000, S133300, S133600, S123700 | 85% | 4d | 2020-10-06 | 2021-04-09 | 61d | 0d | 2021-06-04 | SCI3 WIS - Unpaid [288 h]; TECH3 WIS - Unpaid [960 h]; STUDENT WIS - Unpaid [2400 h] |  | S133700 | 180410 ELM pred/succ per GRY; 180329 ELM pred per GRY | 0 | S129000 | S129000 | S133700 | CA | Not Started | T | Hemmick,Tom | L3 | WIS | Fab & Assy |  |  | Tom Hemmick | SBU | null | POM02.1.02.04.03 | C | 1.02 | NA | 1.02B | 03 | 01 | 5 |  |  |  |  |  |  |  |  |  | Yes |
| S133900 |  | Build TPC R3b Modules |  | 126d | 2020-10-06 A | 2021-06-04 | S133700 SS, S123700 | 85% | 4d | 2020-10-06 | 2021-04-09 | 61d | 0d | 2021-06-04 | SCI3 Temple - Unpaid [288 h]; TECH3 Temple - Unpaid [960 h]; STUDENT Temple - Unpaid [2400 h] |  | S133900 |  | 0 | S129200 | S129200 | S133900 | CA | Not Started | T | Hemmick,Tom | L3 | Temple | Fab & Assy |  |  | Tom Hemmick | SBU | null | POM02.1.02.04.03 | C | 1.02 | NA | 1.02B | 03 | 01 | 5 |  |  |  |  |  |  |  |  |  | Yes |
| S133800 |  | Test TPC R3a Modules |  | 126d | 2020-10-21 A | 2021-06-18 | S133700 SS+10d | 85% | 14d | 2020-10-21 | 2021-04-23 | 61d | 0d | 2021-06-18 | SCI3 WIS - Unpaid [288 h]; TECH3 WIS - Unpaid [960 h]; STUDENT WIS - Unpaid [2400 h] |  | S133800 |  | 0 | S129100 | S129100 | S133800 | CA | Not Started | T | Hemmick,Tom | L3 | WIS | Test_Components |  |  | Tom Hemmick | SBU | null | POM02.1.02.04.03 | C | 1.02 | NA | 1.02B | 03 | 01 | 7 |  |  |  |  |  |  |  |  |  | Yes |
| S134000 |  | Test TPC R3b Modules |  | 126d | 2020-10-21 A | 2021-06-18 | S133900 SS+10d | 85% | 14d | 2020-10-21 | 2021-04-23 | 61d | 0d | 2021-06-18 | SCI3 Temple - Unpaid [288 h]; STUDENT Temple - Unpaid [2400 h]; TECH3 Temple - Unpaid [960 h] |  | S134000 |  | 0 | S129300 | S129300 | S134000 | CA | Not Started | T | Hemmick,Tom | L3 | Temple | Test_Components |  |  | Tom Hemmick | SBU | null | POM02.1.02.04.03 | C | 1.02 | NA | 1.02B | 03 | 01 | 7 |  |  |  |  |  |  |  |  |  | Yes |
| S134100 |  | TPC R3 GEM Modules Production Ends | milestone | 0d | 2021-06-18 | 2021-06-18 | S133800, S134000 |  |  |  |  | 94d | 90d |  |  |  | S134100 |  | 0 | S129400 | S129400 |  | NOCA | Not Started |  | Hemmick,Tom |  | SBU | Fab & Assy |  |  | Tom Hemmick | SBU |  | POM02.1.02.04.03 |  |  |  |  | 03 | 01 | 5 | L2 |  |  | UDF_G3 | UDF_G3 |  |  |  |  |  |

Notes:
- S132100: BNL_UDF_Old Activity Name 181221: Procure TPC R3 Module Prod. Parts (Frames, Strongbacks, Padplanes, Grids) - Provide Requirements to Procurement
- S132200: BNL_UDF_Old Activity Name 181221: Procure TPC R3 Module Prod. Parts (Frames, Strongbacks, Padplanes, Grids) - Prepare & Send Solicitation
- S132300: BNL_UDF_Old Activity Name 181221: Procure TPC R3 Module Prod. Parts (Frames, Strongbacks, Padplanes, Grids) - Vendor Responses
- S132500: BNL_UDF_Old Activity Name 181221: Procure TPC R3 Module Prod. Parts (Frames) - Contract Award(s)
- S132400: BNL_UDF_Old Activity Name 181221: Procure TPC R3 Module Prod. Parts (Frames, Strongbacks, Padplanes, Grids) - Vendor Selection
- S132600: BNL_UDF_Old Activity Name 181221: Procure TPC R3 Module Prod. Parts (Frames) - Contract/PO - Leadtime
- S132800: BNL_UDF_Old Activity Name 181221: Procure TPC R3 Module Prod. Parts (Strongbacks) - Contract Award(s)
- S132900: BNL_UDF_Old Activity Name 181221: Procure TPC R3 Module Prod. Parts (Strongbacks) - Contract/PO - Leadtime
- S133400: BNL_UDF_Old Activity Name 181221: Procure TPC R3 Module Prod. Parts (Grids) - Contract Award(s)
- S133500: BNL_UDF_Old Activity Name 181221: Procure TPC R3 Module Prod. Parts (Grids) - Contract/PO - Leadtime
- S133000: BNL_UDF_Old Activity Name 181221: Procure TPC R3 Module Prod. Parts (Strongbacks) - Delivery Acceptance
- S132700: BNL_UDF_Old Activity Name 181221: Procure TPC R3 Module Prod. Parts (Frames) - Delivery Acceptance
- S133600: BNL_UDF_Old Activity Name 181221: Procure TPC R3 Module Prod. Parts (Grids) - Delivery Acceptance
- S133100: BNL_UDF_Old Activity Name 181221: Procure TPC R3 Module Prod. Parts (Padplanes) - Contract Award(s)
- S133200: BNL_UDF_Old Activity Name 181221: Procure TPC R3 Module Prod. Parts (Padplanes) - Contract/PO - Leadtime
- S133300: BNL_UDF_Old Activity Name 181221: Procure TPC R3 Module Prod. Parts (Padplanes) - Delivery Acceptance
- OBLG132510: BNL_UDF_Old Activity Name 181221: Procure TPC R3 Module Prod. Parts (Frames) - Contract Award(s)
- OBLG132810: BNL_UDF_Old Activity Name 181221: Procure TPC R3 Module Prod. Parts (Strongbacks) - Contract Award(s)
- OBLG133110: BNL_UDF_Old Activity Name 181221: Procure TPC R3 Module Prod. Parts (Padplanes) - Contract Award(s)
- OBLG133410: BNL_UDF_Old Activity Name 181221: Procure TPC R3 Module Prod. Parts (Grids) - Contract Award(s)
- S133700: BNL_UDF_Old Activity Name 181221: Build TPC R3a Modules
- S133900: BNL_UDF_Old Activity Name 181221: Build TPC R3b Modules
- S133800: BNL_UDF_Old Activity Name 181221: Test TPC R3a Modules
- S134000: BNL_UDF_Old Activity Name 181221: Test TPC R3b Modules
- S134100: BNL_UDF_Old Activity Name 181221: TPC R3 GEM Modules Production Ends

| ID | WBS | Activity | Type | Duration | Start | Finish | Predecessors | Complete | Remaining | Planned start | Planned finish | Total float | Free float | Expected finish | Resources | Cost | BNL_UDF_Temp Text 01 | BNL_UDF_Percent Complete | BNL_UDF_OPC TEC (deprecated) | BNL_UDF_Old Activity Name 181221 | BNL_UDF_Old Activity ID 181221 | RG Check | BNL_Activity Status | BNL_Estimator | BNL_Location | BNL_EDIA | BNL_CAM | BNL_Institution | BNL_R&D FY18-19 | BNL_WBS | BNL_WBS_Hierarchical | Completed | PMP Summary Part1 | PMP Summary Part2 | BNL_Cost Basis | BNL_OPC TEC (deprecated) | BNL_EVT | BNL_DOE OPC | BNL_UDF_Adhoc Comments | BNL_UDF_Temp Date 01 | BNL_UDF_Status Comments | BNL_PCR ID | BNL_Fund Source | BNL_Account Number | Additional EVT documentation required | BNL_Cobra WP | BNL_Master Control Account | BNL_Cobra Control Account | Temp | Indicator - Procurement | Indicator - Float | BNL_UDF_Remaining Tot Cost | BNL_UDF_Percent_remaining | BNL_Proc Sig | BNL_Milestone Level |
| --- | --- | --- | --- | --- | --- | --- | --- | --- | --- | --- | --- | --- | --- | --- | --- | --- | --- | --- | --- | --- | --- | --- | --- | --- | --- | --- | --- | --- | --- | --- | --- | --- | --- | --- | --- | --- | --- | --- | --- | --- | --- | --- | --- | --- | --- | --- | --- | --- | --- | --- | --- | --- | --- | --- | --- |
|  | 05 | **TPC FEE** |  |  | 2017-02-01 | 2022-01-19 |  |  |  |  |  |  |  |  |  |  |  |  |  |  |  |  |  |  |  |  |  |  |  |  |  |  |  |  |  |  |  |  |  |  |  |  |  |  |  |  |  |  |  |  |  |  |  |  |  |
|  | 01 | **TPC FEE Prototype v1** |  |  | 2017-02-01 | 2019-05-24 |  |  |  |  |  |  |  |  |  |  |  |  |  |  |  |  |  |  |  |  |  |  |  |  |  |  |  |  |  |  |  |  |  |  |  |  |  |  |  |  |  |  |  |  |  |  |  |  |  |
| S134200 |  | Write TPC FEE prototype v1 design specification |  | 2d | 2017-02-01 A | 2017-02-02 A | S100090 SS | 100% |  |  |  |  |  |  |  |  | S134200 | 100 | S129500 | Write TPC FEE prototype v1 design specification | S129500 | NOCA | Completed | Sakaguchi, Takao | BNL | Design | Tom Hemmick | BNL | TPC FEE Proto v1 | POM02.1.02.05.01 | 01 | yes | 1 | 1 |  |  |  |  |  |  |  |  |  |  |  |  |  |  |  |  |  |  |  |  |  |
| S134300 |  | Design TPC FEE prototype v1 |  | 169d | 2017-02-01 A | 2017-09-29 A | S100090 SS | 100% |  |  |  |  |  |  |  |  | S134300 | 100 | S129600 | Design TPC FEE prototype v1 | S129600 | NOCA | Completed | Sakaguchi, Takao | BNL | Design | Tom Hemmick | BNL | TPC FEE Proto v1 | POM02.1.02.05.01 | 01 | yes | 1 | 1 |  |  |  |  |  |  |  |  |  |  |  |  |  |  |  |  |  |  |  |  |  |
| S135000 |  | Develop TPC FEE Test Stand Labor |  | 169d | 2017-02-01 A | 2017-09-29 A | S100090 SS | 100% |  |  |  |  |  |  |  |  | S135000 | 100 | S130300 | Develop TPC FEE Test Stand Labor | S130300 | NOCA | Completed | Sakaguchi, Takao | BNL | Test_System | Tom Hemmick | BNL | TPC FEE Proto v1 | POM02.1.02.05.01 | 01 | yes | 01 | 4 |  |  |  |  |  |  |  |  |  |  |  |  |  |  |  |  |  |  |  |  |  |
| S135100 |  | Develop TPC FEE Test Stand M&S |  | 169d | 2017-02-01 A | 2017-09-29 A | S100090 SS | 100% |  |  |  |  |  |  |  |  | S135100 | 100 | S130400 | Develop TPC FEE Test Stand M&S | S130400 | NOCA | Completed | Sakaguchi, Takao | BNL | Procurement | Tom Hemmick | BNL | TPC FEE Proto v1 | POM02.1.02.05.01 | 01 | yes | 01 | 2 |  |  |  |  |  |  |  |  |  |  |  |  |  |  |  |  |  |  |  |  |  |
| S134400 |  | Procure TPC FEE prototype v1 components Labor |  | 21d | 2017-10-02 A | 2017-10-31 A | S134200, S134300 | 100% |  |  |  |  |  |  |  |  | S134400 | 100 | S129700 | Procure TPC FEE prototype v1 components Labor | S129700 | NOCA | Completed | Sakaguchi, Takao | BNL | Procurement | Tom Hemmick | BNL | TPC FEE Proto v1 | POM02.1.02.05.01 | 01 | yes | 01 | 2 |  |  |  |  |  |  |  |  |  |  |  |  |  |  |  |  |  |  |  |  |  |
| S134500 |  | Procure TPC FEE prototype v1 components M&S |  | 21d | 2017-10-02 A | 2017-10-31 A | S134200, S134300 | 100% |  |  |  |  |  |  |  |  | S134500 | 100 | S129800 | Procure TPC FEE prototype v1 components M&S | S129800 | NOCA | Completed | Sakaguchi, Takao | BNL | Fab & Assy | Tom Hemmick | BNL | TPC FEE Proto v1 | POM02.1.02.05.01 | 01 | yes | 01 | 4 |  |  |  |  |  |  |  |  |  |  |  |  |  |  |  |  |  |  |  |  |  |
| S134800 |  | Procure TPC FEE prototype v1 LV power supplies Labor |  | 30d | 2017-10-02 A | 2017-11-14 A | S134300 | 100% |  |  |  |  |  |  |  |  | S134800 | 100 | S130100 | Procure TPC FEE prototype v1 LV power supplies Labor | S130100 | NOCA | Completed | Sakaguchi, Takao | BNL | Procurement | Tom Hemmick | BNL | TPC FEE Proto v1 | POM02.1.02.05.01 | 01 | yes | 01 | 2 | M4 | null | C |  |  |  |  |  |  |  |  |  |  |  |  |  |  |  |  |  |  |
| S134900 |  | Procure TPC FEE prototype v1 LV power supplies M&S |  | 30d | 2017-10-02 A | 2017-11-14 A | S134300 | 100% |  |  |  |  |  |  |  |  | S134900 | 100 | S130200 | Procure TPC FEE prototype v1 LV power supplies M&S | S130200 | NOCA | Completed | Sakaguchi, Takao | BNL | Fab & Assy | Tom Hemmick | BNL | TPC FEE Proto v1 | POM02.1.02.05.01 | 01 | yes | 01 | 4 | M4 | OPC | C | OPC000700 |  |  |  |  |  |  |  |  |  |  |  |  |  |  |  |  |  |
| S134600 |  | Fabricate TPC FEE prototype v1 boards Labor |  | 62d | 2017-11-01 A | 2018-02-02 A | S134400 | 100% |  |  |  |  |  |  |  |  | S134600 | 100 | S129900 | Fabricate TPC FEE prototype v1 boards Labor | S129900 | NOCA | Completed | Sakaguchi, Takao | BNL | Fab & Assy | Tom Hemmick | BNL | TPC FEE Proto v1 | POM02.1.02.05.01 | 01 | yes | 01 | 4 | M4 | null | C |  |  |  |  |  |  |  |  |  |  |  |  |  |  |  |  |  |  |
| S134700 |  | Fabricate TPC FEE prototype v1 boards M&S |  | 62d | 2017-11-01 A | 2018-02-02 A | S134500 | 100% |  |  |  |  |  |  |  |  | S134700 | 100 | S130000 | Fabricate TPC FEE prototype v1 boards M&S | S130000 | NOCA | Completed | Sakaguchi, Takao | BNL | Fab & Assy | Tom Hemmick | BNL | TPC FEE Proto v1 | POM02.1.02.05.01 | 01 | yes | 01 | 4 | M4 | OPC | C | OPC000700 |  |  |  |  |  |  |  |  |  |  |  |  |  |  |  |  |  |
| S135200 |  | Assemble and test TPC FEE prototype v1 Labor |  | 149d | 2018-03-01 A | 2018-09-28 A | S134600 FS+17d, S134800, S135000 | 100% |  |  |  |  |  |  |  |  | S135200 | 100 | S130500 | Assemble and test TPC FEE prototype v1 Labor | S130500 | NOCA | Completed | Sakaguchi, Takao | BNL | Fab & Assy | Tom Hemmick | BNL | TPC FEE Proto v1 | POM02.1.02.05.01 | 01 | yes | 01 | 4 | L3 | null | C |  | 180423 ELM rsrc per GRY; 180413 ELM status per GRY | 2018-08-31 |  |  |  |  |  |  |  |  |  |  |  |  |  |  |  |
| S135300 |  | Assemble and test TPC FEE prototype v1 M&S |  | 149d | 2018-03-01 A | 2018-09-28 A | S134700 FS+17d, S134900, S135100 | 100% |  |  |  |  |  |  |  |  | S135300 | 100 | S130600 | Assemble and test TPC FEE prototype v1 M&S | S130600 | NOCA | Completed | Sakaguchi, Takao | BNL | Fab & Assy | Tom Hemmick | BNL | TPC FEE Proto v1 | POM02.1.02.05.01 | 01 | yes | 01 | 4 | M4 | OPC | C | OPC000700 | 180413 ELM status per GRY | 2018-08-31 |  |  |  |  |  |  |  |  |  |  |  |  |  |  |  |
| S135301 |  | Preliminary Design Review - TPC FEE | milestone | 0d | 2018-09-28 A | 2018-09-28 A | S135200 FF | 100% |  |  |  |  |  |  |  |  | S135200 | 100 | S130500 | Assemble and test TPC FEE prototype v1 Labor | S130500 | NOCA | Completed | Sakaguchi, Takao | BNL | Fab & Assy | Tom Hemmick | BNL | TPC FEE Proto v1 | POM02.1.02.05.01 | 01 | yes | 01 | 4 | L3 | null | C |  | 180423 ELM rsrc per GRY; 180413 ELM status per GRY | 2018-08-31 | 190522 IVS new act. | 004 |  |  |  |  |  |  |  |  |  |  |  |  |  |
| S135400 |  | Assemble and test TPC FEE prototype v1a Labor |  | 162d | 2018-10-01 A | 2019-05-24 A | S135300, S135301 | 100% |  |  |  |  |  |  |  |  | S135400 | 60 | S130500 | Assemble and test TPC FEE prototype v1a Labor | S130625 | NOCA | Completed | Sakaguchi, Takao | BNL | Fab & Assy | Tom Hemmick | BNL | TPC FEE Proto v1 | POM02.1.02.05.01 | 01 | yes | 01 | 4 | L3 | null | C |  | 180423 ELM rsrc per GRY; 180413 ELM status per GRY | 2019-03-29 | 190417 ELM BLUs per GRY | 004 | B_T | 16709 | Yes |  |  |  |  |  |  |  |  |  |  |
| S135500 |  | Assemble and test TPC FEE prototype v1a M&S |  | 162d | 2018-10-01 A | 2019-05-24 A | S135300, S135301 | 100% |  |  |  |  |  |  |  |  | S135500 | 60 | S130600 | Assemble and test TPC FEE prototype v1a M&S | S130650 | NOCA | Completed | Sakaguchi, Takao | BNL | Fab & Assy | Tom Hemmick | BNL | TPC FEE Proto v1 | POM02.1.02.05.01 | 01 | yes | 01 | 4 | M4 | OPC | F | OPC000700 | 180413 ELM status per GRY | 2019-03-29 | 190315 ELM chg % to align with EVT 50>0, remove AS, use EF | 003 | A-OPC | 16701 | Yes |  |  |  |  |  |  |  |  |  |  |
| S135600 |  | TPC FEE Prototype v1 Safety Review |  | 25d | 2019-04-01 A | 2019-05-03 A | S135400, S135500 | 100% |  |  |  |  |  |  |  |  | S135600 | 0 | S130700 | TPC FEE Prototype v1 Safety Review | S130700 | NOCA | Completed | Sakaguchi, Takao | BNL | Management Safety Reviews | Tom Hemmick | BNL | TPC FEE Proto v1 | POM02.1.02.05.01 | 01 | yes | 1 | 1 |  |  |  |  |  |  |  |  |  |  |  |  |  |  |  |  |  |  |  |  |  |
| S135700 |  | TPC FEE Prototype v1 Design Review |  | 23d | 2019-04-03 A | 2019-05-03 A | S135600 | 100% |  |  |  |  |  |  |  |  | S135700 | 0 | S130800 | TPC FEE Prototype v1 Design Review | S130800 | NOCA | Completed | Sakaguchi, Takao | BNL | Design | Tom Hemmick | BNL | TPC FEE Proto v1 | POM02.1.02.05.01 | 01 | yes | 1 | 1 |  |  |  |  |  |  | 190522 IVS new name; 190415 ELM name per GRY | 004 |  |  |  |  |  |  |  |  |  |  |  |  |  |
|  | 02 | **TPC FEE Prototype v2 (Pre-Production)** |  |  | 2019-05-06 | 2021-06-28 |  |  |  |  |  |  |  |  |  |  |  |  |  |  |  |  |  |  |  |  |  |  |  |  |  |  |  |  |  |  |  |  |  |  |  |  |  |  |  |  |  |  |  |  |  |  |  |  |  |
| S136800 |  | v2 Design TPC FEE preproduction prototype |  | 19d | 2019-05-06 A | 2019-05-31 A | S135700, S135400, S135500 | 100% |  |  |  |  |  |  |  |  | S136800 | 0 | S131600 | v2 Design TPC FEE preproduction prototype | S131600 | NOCA | Completed | Sakaguchi, Takao | BNL | Design | Tom Hemmick | BNL | TPC FEE Pre-pro proto | POM02.1.02.05.02 | 02 | yes | 1 | 1 | L4 | null | C |  | 180413 ELM dur per GRY | 2018-11-30 |  |  | B | 16709 | Yes |  |  |  |  |  |  |  |  |  |  |
| S136802 |  | v2 Design TPC FEE preproduction prototype Split |  | 41d | 2019-08-01 A | 2019-09-30 A | S136800 | 100% |  | 2019-08-01 | 2019-09-27 |  |  |  | PROF4 PO E [332 h]; TECH3 PO D [396 h] | 91,344.03 | S136800 | 0 | S131600 | v2 Design TPC FEE preproduction prototype | S131600 | CA | Completed | Sakaguchi, Takao | BNL | Design | Tom Hemmick | BNL | TPC FEE Pre-pro proto | POM02.1.02.05.02 | 02 |  | 1 | 1 | L4 | null | C |  | 180413 ELM dur per GRY | 2018-11-30 |  |  | B | 16709 | Yes | S136802 | 1.02 | 1.02B | 1 |  |  |  |  |  |  |
| S137300 |  | v2 Modify TPC FEE Test Stand Labor |  | 30d | 2019-12-02 A | 2020-09-30 A | S136802 | 100% |  | 2019-12-02 | 2020-01-14 |  |  |  | SCI3 PO [24 h]; TECH3 PO E [60 h]; TECH3 PO D [72 h]; STUDENT SBU - Unpaid [24 h]; PROF4 PO E [240 h] | 54,538.26 | S137300 | 0 | S132100 | v2 Modify TPC FEE Test Stand Labor | S132100 | CA | Not Started | Sakaguchi, Takao | BNL | Fab & Assy | Tom Hemmick | BNL | TPC FEE Pre-pro proto | POM02.1.02.05.02 | 02 |  | 01 | 5 | L4 | null | C |  |  |  |  |  | B_T | 16709 |  | S137300 | 1.02 | 1.02B |  |  |  |  |  |  |  |
| S137400 |  | v2 Modify TPC FEE Test Stand M&S |  | 30d | 2019-12-02 A | 2020-09-30 A | S136802 | 100% |  | 2019-12-02 | 2020-01-14 |  |  |  | Material (Purchase (1st $2M) [8000 h] | 9,103.41 | S137400 | 0 | S132200 | v2 Modify TPC FEE Test Stand M&S | S132200 | CA | Not Started | Sakaguchi, Takao | BNL | Fab & Assy | Tom Hemmick | BNL | TPC FEE Pre-pro proto | POM02.1.02.05.02 | 02 |  | 01 | 5 | M4 | OPC | E | OPC000800 |  |  |  |  | A-OPC | 16701 |  | S137400 | 1.02 | 1.02A |  | UDF_G1 | UDF_G1 | 910.340632 | 0.1 | TBD |  |
| S136900 |  | v2 Procure TPC FEE preproducion prototype components Labor |  | 20d | 2020-01-02 A | 2020-09-30 A | S100600, S136802 | 100% |  | 2020-01-02 | 2020-01-30 |  |  |  | PROF4 PO E [16 h] | 2,356.24 | S136900 | 0 | S131700 | v2 Procure TPC FEE preproducion prototype components Labor | S131700 | CA | Not Started | Sakaguchi, Takao | BNL | Procurement | Tom Hemmick | BNL | TPC FEE Pre-pro proto | POM02.1.02.05.02 | 02 |  | 01 | 3 | L4 | null | C |  |  |  |  |  | B | 16709 |  | S136900 | 1.02 | 1.02B |  |  |  |  |  |  |  |
| S137000 |  | v2 Procure TPC FEE preproducion prototype components M&S |  | 20d | 2020-04-01 A | 2020-10-30 A | S100600, S136802 | 100% |  | 2020-04-01 | 2020-04-28 |  |  |  | Material (Purchase (1st $2M) [5871 h] | 6,680.76 | S137000 | 0 | S131800 | v2 Procure TPC FEE preproducion prototype components M&S | S131800 | CA | Not Started | Sakaguchi, Takao | BNL | Fab & Assy | Tom Hemmick | BNL | TPC FEE Pre-pro proto | POM02.1.02.05.02 | 02 |  | 01 | 5 | M3 | OPC | E | OPC000800 |  |  | 190315 ELM BNL Units per TS | 003 | A-OPC | 16701 |  | S137000 | 1.02 | 1.02A |  | UDF_G1 | UDF_G1 | 6346.72419735 | 0.95 | TBD |  |
| S137100 |  | v2 Fabricate TPC FEE preproduction prototype boards Labor |  | 25d | 2020-04-01 A | 2020-05-29 A | S136900 SS | 100% |  | 2020-04-01 | 2020-05-05 |  |  |  | PROF4 PO E [20 h] | 2,945.3 | S137100 | 0 | S131900 | v2 Fabricate TPC FEE preproduction prototype boards Labor | S131900 | CA | Not Started | Sakaguchi, Takao | BNL | Fab & Assy | Tom Hemmick | BNL | TPC FEE Pre-pro proto | POM02.1.02.05.02 | 02 |  | 01 | 5 | L4 | null | C |  |  |  |  |  | B | 16709 |  | S137100 | 1.02 | 1.02B |  |  |  |  |  |  |  |
| S137200 |  | v2 Fabricate TPC FEE preproduction prototype boards M&S |  | 25d | 2020-04-01 A | 2020-05-29 A | S137000 SS | 100% |  | 2020-04-01 | 2020-05-05 |  |  |  | Material (Purchase (1st $2M) [1476 h] | 1,679.58 | S137200 | 0 | S132000 | v2 Fabricate TPC FEE preproduction prototype boards M&S | S132000 | CA | Not Started | Sakaguchi, Takao | BNL | Fab & Assy | Tom Hemmick | BNL | TPC FEE Pre-pro proto | POM02.1.02.05.02 | 02 |  | 01 | 5 | M4 | OPC | E | OPC000800 |  |  | 190315 ELM BNL Units per TS | 003 | A-OPC | 16701 |  | S137200 | 1.02 | 1.02A |  | UDF_G1 | UDF_G1 | 1595.5995427 | 0.95 | TBD |  |
| S137500 |  | v2 Assemble and test TPC FEE preproduction prototype |  | 30d | 2020-04-13 A | 2021-05-28 A | S137100, S137300 | 100% |  | 2020-05-06 | 2020-06-17 |  |  |  | PROF4 PO E [248 h]; SCI3 PO [240 h]; TECH3 PO E [64 h]; TECH3 PO D [64 h]; STUDENT SBU - Unpaid [96 h] | 92,434.72 | S137500 | 0 | S132300 | v2 Assemble and test TPC FEE preproduction prototype | S132300 | CA | Not Started | Sakaguchi, Takao | BNL | Fab & Assy | Tom Hemmick | BNL | TPC FEE Pre-pro proto | POM02.1.02.05.02 | 02 |  | 01 | 5 | L4 | null | C |  | 180423 ELM rsrc per GRY |  | 190417 ELM BLUs per GRY | 004 | B_T | 16709 |  | S137500 | 1.02 | 1.02B |  |  |  |  |  |  |  |
| S137600 |  | v2 Assemble and test TPC FEE preproduction prototype M&S |  | 30d | 2020-04-13 A | 2020-10-23 A | S137200, S137400 | 100% |  | 2020-05-06 | 2020-06-17 |  |  |  | Material (Purchase (1st $2M) [5630 h] | 6,406.52 | S137600 | 0 | S132400 | v2 Assemble and test TPC FEE preproduction prototype M&S | S132400 | CA | Not Started | Sakaguchi, Takao | BNL | Fab & Assy | Tom Hemmick | BNL | TPC FEE Pre-pro proto | POM02.1.02.05.02 | 02 |  | 01 | 5 | M4 | OPC | E | OPC000800 |  |  | 190315 ELM BNL Units per TS | 003 | A-OPC | 16701 |  | S137600 | 1.02 | 1.02A |  | UDF_G1 | UDF_G1 | 6086.1960881 | 0.95 | TBD |  |
| S137700 |  | Final Design Review, Production Readiness Review - TPC FEE |  | 1d | 2020-04-13 A | 2021-06-28 | S137500 FS+5d, S137600 FS+5d | 95% | 16d | 2020-06-25 | 2020-06-25 | 7d | 0d | 2021-06-28 | PROF4 PO M [4 h]; SCI3 PO [4 h] | 1,277.48 | S137700 | 0 | S132500 | TPC FEE Preproduction Readiness Review | S132500 | CA | Not Started | Sakaguchi, Takao | BNL | Design | Tom Hemmick | BNL | TPC FEE Pre-pro proto | POM02.1.02.05.02 | 02 |  | 1 | 1 |  |  | C |  | 180420 ELM pred/succ per GRY |  | 190522 IVS new name; 190415 ELM name per GRY | 004 | B | 16709 |  | S137700 | 1.02 | 1.02B |  |  |  |  |  |  | L2 |

| ID | WBS | Activity | Type | Duration | Start | Finish | Predecessors | Complete | Remaining | Planned start | Planned finish | Total float | Free float | Constraint | Expected finish | Resources | Cost | BNL_UDF_Temp Text 01 | BNL_UDF_Percent Complete | BNL_UDF_Sort Order | BNL_UDF_OPC TEC (deprecated) | BNL_UDF_Temp Date 01 | BNL_UDF_Old Activity ID 181221 | RG Check | BNL_Activity Status | BNL_Estimator | BNL_Cost Basis | BNL_Location | BNL_EDIA | BNL_Proc Sig Phase | BNL_Proc Sig | BNL_CAM | BNL_Institution | BNL_R&D FY18-19 | BNL_DOE OPC | BNL_OPC TEC (deprecated) | BNL_WBS | BNL_EVT | BNL_WBS_Hierarchical | Completed | PMP Summary Part1 | PMP Summary Part2 | Cost = Awarded Proc or Mgmt | BNL_Fund Source | BNL_Milestone Level | BNL_PCR ID | BNL_UDF_Exclude | BNL_Account Number | SPH Proc Register | BNL_Cobra WP | Indicator - Procurement | BNL_Master Control Account | BNL_Cobra Control Account | Indicator - Float | BNL_UDF_Remaining Tot Cost | BNL_UDF_Percent_remaining | BNL_Obligation | Target Milestone Date | Variance | PMP Milestones |
| --- | --- | --- | --- | --- | --- | --- | --- | --- | --- | --- | --- | --- | --- | --- | --- | --- | --- | --- | --- | --- | --- | --- | --- | --- | --- | --- | --- | --- | --- | --- | --- | --- | --- | --- | --- | --- | --- | --- | --- | --- | --- | --- | --- | --- | --- | --- | --- | --- | --- | --- | --- | --- | --- | --- | --- | --- | --- | --- | --- | --- |
|  | 03 | **SAMPA chip 80 nsec** |  |  | 2018-05-29 | 2021-07-01 |  |  |  |  |  |  |  |  |  |  |  |  |  |  |  |  |  |  |  |  |  |  |  |  |  |  |  |  |  |  |  |  |  |  |  |  |  |  |  |  |  |  |  |  |  |  |  |  |  |  |  |  |  |  |
| S137800 |  | SAMPA chip 80 nsec development - Provide Requirements to Procurement |  | 29d | 2018-05-29 A | 2018-07-09 A | S100300 | 100% |  |  |  |  |  |  |  |  |  | S137800 | 100 | 1010 | S132600 | 2018-07-30 | S132600 | NOCA | Completed | Sakaguchi, Takao | L4 | Brasil | Procurement | PP1 | MP200100 | Tom Hemmick | BNL | SAMPA Chip 80nsec | OPC000900 | null | POM02.1.02.05.03 | C | 03 | yes | 01 | 2 | Yes |  |  |  |  |  |  |  |  |  |  |  |  |  |  |  |  |  |
| OBLG138210 |  | SAMPA chip 80 nsec development - Obligation - MPW to Test Design Changes |  | 1d | 2018-07-02 A | 2018-07-02 A | S138100 | 100% |  |  |  |  |  |  |  |  |  | S138200 | 100 |  | S132600 |  | S132640 | NOCA | Completed | Sakaguchi, Takao |  | Brasil | Procurement | PP5 | MP200100 | Tom Hemmick | BNL | SAMPA Chip 80nsec | OPC000900 |  | POM02.1.02.05.03 |  | 03 | yes | 01 | 2 | Yes | A-OPC | L3 |  |  |  |  |  |  |  |  |  |  |  |  |  |  |  |
| S138200 |  | SAMPA chip 80 nsec development - Contract Award(s) - Report feasability of 80ns/20MSPS mod | milestone | 0d | 2018-07-02 A | 2018-07-02 A | S138100 | 100% |  |  |  |  |  |  |  |  |  | S138200 | 100 | 1010 | S132600 |  | S132640 | NOCA | Completed | Sakaguchi, Takao |  | Brasil | Procurement | PP5 | MP200100 | Tom Hemmick | BNL | SAMPA Chip 80nsec | OPC000900 |  | POM02.1.02.05.03 |  | 03 | yes | 01 | 2 | Yes | A-OPC | L3 |  |  |  |  |  |  |  |  |  |  |  |  |  |  |  |
| S138300 |  | SAMPA chip 80 nsec development - Contract Award(s) - Design at Layout level of new circuits | milestone | 0d | 2018-07-02 A | 2018-07-02 A | S138100 | 100% |  |  |  |  |  |  |  |  |  | S138300 | 100 | 1020 | S132600 |  | S132645 | NOCA | Completed | Sakaguchi, Takao |  | Brasil | Procurement | PP5 | MP200150 | Tom Hemmick | BNL | SAMPA Chip 80nsec | OPC000900 |  | POM02.1.02.05.03 |  | 03 | yes | 01 | 2 | Yes | A-OPC | L3 | 003,004 |  |  |  |  |  |  |  |  |  |  |  |  |  |  |
| S138310 |  | SAMPA chip 80 nsec development - Contract Award(s) - Layout finalization for MPW and submission | milestone | 0d | 2018-07-02 A | 2018-07-02 A | S138300 SS, S138100 | 100% |  |  |  |  |  |  |  |  |  | S138300 | 0 | 1030 | S132600 |  | S132645 | NOCA | Completed | Sakaguchi, Takao |  | Brasil | Procurement | PP5 | MP200151 | Tom Hemmick | BNL | SAMPA Chip 80nsec | OPC000900 |  | POM02.1.02.05.03 |  | 03 |  | 01 | 2 |  | A-OPC | L3 | 003,004 |  |  |  |  |  |  |  |  |  |  |  |  |  |  |
| S137801 |  | Preliminary Design Review - SAMPA chip 80 nsec | milestone | 0d | 2018-07-09 A | 2018-07-09 A | S137800 FF | 100% |  |  |  |  |  |  |  |  |  | S137800 | 100 | 1000 | S132600 | 2018-07-30 | S132600 | NOCA | Completed | Sakaguchi, Takao | L4 | Brasil | Procurement | PP1 | MP200100 | Tom Hemmick | BNL | SAMPA Chip 80nsec | OPC000900 | null | POM02.1.02.05.03 | C | 03 | yes | 01 | 2 | Yes |  |  | 004 |  |  |  |  |  |  |  |  |  |  |  |  |  |  |
| S137900 |  | SAMPA chip 80 nsec development - Prepare & Send Solicitation |  | 10d | 2018-07-10 A | 2018-07-23 A | S137801 | 100% |  |  |  |  |  |  |  |  |  | S137900 | 100 | 1010 | S132600 |  | S132610 | NOCA | Completed | Sakaguchi, Takao |  | Brasil | Procurement | PP2 | MP200100 | Tom Hemmick | BNL | SAMPA Chip 80nsec | OPC000900 |  | POM02.1.02.05.03 |  | 03 | yes | 01 | 2 | Yes |  |  |  |  |  |  |  |  |  |  |  |  |  |  |  |  |  |
| S138000 |  | SAMPA chip 80 nsec development - Vendor Responses |  | 8d | 2018-07-24 A | 2018-08-02 A | S137900 | 100% |  |  |  |  |  |  |  |  |  | S138000 | 100 | 1010 | S132600 |  | S132620 | NOCA | Completed | Sakaguchi, Takao |  | Brasil | Procurement | PP3 | MP200100 | Tom Hemmick | BNL | SAMPA Chip 80nsec | OPC000900 |  | POM02.1.02.05.03 |  | 03 | yes | 01 | 2 | Yes |  |  |  |  |  |  |  |  |  |  |  |  |  |  |  |  |  |
| S138100 |  | SAMPA chip 80 nsec development - Vendor Selection |  | 5d | 2018-08-03 A | 2018-08-09 A | S138000 | 100% |  |  |  |  |  |  |  |  |  | S138100 | 100 | 1010 | S132600 |  | S132630 | NOCA | Completed | Sakaguchi, Takao |  | Brasil | Procurement | PP4 | MP200100 | Tom Hemmick | BNL | SAMPA Chip 80nsec | OPC000900 |  | POM02.1.02.05.03 |  | 03 | yes | 01 | 2 | Yes |  |  |  |  |  |  |  |  |  |  |  |  |  |  |  |  |  |
| S138400 |  | SAMPA chip 80 nsec development - Leadtime - Report feasability of 80ns/20MSPS mod |  | 110d | 2018-10-01 A | 2019-03-13 A | S138200 SS, OBLG138210 SS | 100% |  |  |  |  |  |  |  |  |  | S138400 | 80 | 1010 | S132600 | 2019-04-10 | S132650 | NOCA | Completed | Sakaguchi, Takao |  | Brasil | Fab & Assy | PP6 | MP200100 | Tom Hemmick | BNL | SAMPA Chip 80nsec | OPC000900 |  | POM02.1.02.05.03 |  | 03 | yes | 01 | 4 | Yes |  |  |  | MP6LA |  |  |  |  |  |  |  |  |  |  |  |  |  |
| S139705 |  | Procure second phase of SAMPA development - Contract Award |  | 2d | 2019-02-26 A | 2019-02-27 A | S138310 | 100% |  |  |  |  |  |  |  |  |  | S139700 | 0 | 1040 | S132600 |  | S277593564 | NOCA | Completed | Sakaguchi, Takao | M4 | Brasil | Fab & Assy | PP6 | MP200011 | Tom Hemmick | BNL | SAMPA Chip 80nsec | OPC000900 | OPC | POM02.1.02.05.03 | E | 03 |  | 01 | 4 |  | A-OPC |  | 003 | MP6LA | 16701 | Contract Award |  |  |  |  |  |  |  |  |  |  |  |
| S138500 |  | SAMPA chip 80 nsec development - Delivery Acceptance - Report feasability of 80ns/20MSPS mod |  | 4d | 2019-03-14 A | 2019-03-19 A | S138400 | 100% |  |  |  |  |  |  |  |  |  | S138500 | 0 | 1010 | S132600 |  | S132656 | NOCA | Completed | Sakaguchi, Takao | M4 | Brasil | Fab & Assy | PP6 | MP200100 | Tom Hemmick | BNL | SAMPA Chip 80nsec | OPC000900 | OPC | POM02.1.02.05.03 | E | 03 |  | 01 | 4 | Yes | A-OPC |  | 003 | MP6LA | 16701 |  |  |  |  |  |  |  |  |  |  |  |  |
| S139100 |  | Procure MPW Run of SAMPA v5 components - Provide Requirements to Procurement |  | 5d | 2019-03-18 A | 2019-03-23 A | S139010 | 100% |  | 2019-03-18 | 2019-03-22 |  |  |  |  |  |  | S139100 | 0 | 1040 | S132600 | 2018-07-30 | S277593284 | NOCA | Completed | Sakaguchi, Takao | L4 | Brasil | Procurement | PP1 | MP210010 | Tom Hemmick | BNL | SAMPA Chip 80nsec | OPC000900 | null | POM02.1.02.05.03 | C | 03 |  | 01 | 2 |  | B |  | 003 |  | 16709 |  |  |  |  |  |  |  |  |  |  |  |  |
| S139200 |  | Procure MPW Run of SAMPA v5 components - Prepare & Send Solicitation |  | 2d | 2019-03-25 A | 2019-03-26 A | S139100 | 100% |  |  |  |  |  |  |  |  |  | S139200 | 0 | 1040 | S132600 |  | S277593324 | NOCA | Completed | Sakaguchi, Takao |  | Brasil | Procurement | PP2 | MP210010 | Tom Hemmick | BNL | SAMPA Chip 80nsec | OPC000900 |  | POM02.1.02.05.03 |  | 03 |  | 01 | 2 |  |  |  |  |  |  |  |  |  |  |  |  |  |  |  |  |  |  |
| S139300 |  | Procure MPW Run of SAMPA v5 components - Vendor Responses |  | 3d | 2019-03-27 A | 2019-03-29 A | S139200 | 100% |  |  |  |  |  |  |  |  |  | S139300 | 0 | 1040 | S132600 |  | S277593364 | NOCA | Completed | Sakaguchi, Takao |  | Brasil | Procurement | PP3 | MP210010 | Tom Hemmick | BNL | SAMPA Chip 80nsec | OPC000900 |  | POM02.1.02.05.03 |  | 03 |  | 01 | 2 |  |  |  |  |  |  |  |  |  |  |  |  |  |  |  |  |  |  |
| S139400 |  | Procure MPW Run of SAMPA v5 components - Vendor Selection |  | 1d | 2019-03-29 A | 2019-03-29 A | S139300 | 100% |  |  |  |  |  |  |  |  |  | S139400 | 0 | 1040 | S132600 |  | S277593404 | NOCA | Completed | Sakaguchi, Takao |  | Brasil | Procurement | PP4 | MP210010 | Tom Hemmick | BNL | SAMPA Chip 80nsec | OPC000900 |  | POM02.1.02.05.03 |  | 03 |  | 01 | 2 |  |  |  |  |  |  |  |  |  |  |  |  |  |  |  |  |  |  |
| S139500 |  | Procure MPW Run of SAMPA v5 components - Contract Award | milestone | 0d | 2019-03-29 A | 2019-03-29 A | S139400 | 100% |  |  |  |  |  |  |  |  |  | S139500 | 0 | 1040 | S132600 |  | S277593484 | NOCA | Completed | Sakaguchi, Takao |  | Brasil | Procurement | PP5 | MP210010 | Tom Hemmick | BNL | SAMPA Chip 80nsec | OPC000900 |  | POM02.1.02.05.03 |  | 03 |  | 01 | 2 |  | A-OPC | L3 |  |  |  | Contract Award |  |  |  |  |  |  |  |  |  |  |  |
| S138800 |  | SAMPA chip 80 nsec development - Leadtime - Design at Layout level of new circuits |  | 18d | 2019-04-01 A | 2019-04-24 A | S138300 SS, S138500 | 100% |  |  |  |  |  |  |  |  |  | S138800 | 0 | 1020 | S132600 |  | S132658 | NOCA | Completed | Sakaguchi, Takao |  | Brasil | Fab & Assy | PP6 | MP200150 | Tom Hemmick | BNL | SAMPA Chip 80nsec | OPC000900 |  | POM02.1.02.05.03 |  | 03 |  | 01 | 4 | Yes |  |  |  | MP6LA |  |  |  |  |  |  |  |  |  |  |  |  |  |
| S139600 |  | Procure MPW Run of SAMPA v5 components - Leadtime |  | 22d | 2019-04-01 A | 2019-04-30 A | S139500 SS, S139400 | 100% |  |  |  |  |  |  |  |  |  | S139600 | 0 | 1040 | S132600 |  | S277593524 | NOCA | Completed | Sakaguchi, Takao |  | Brasil | Fab & Assy | PP6 | MP210010 | Tom Hemmick | BNL | SAMPA Chip 80nsec | OPC000900 |  | POM02.1.02.05.03 |  | 03 |  | 01 | 4 |  |  |  |  | MP6LA |  |  |  |  |  |  |  |  |  |  |  |  |  |
| S138315 |  | SAMPA chip 80 nsec development - Leadtime - Layout finalization for MPW and submission |  | 5d | 2019-04-24 A | 2019-04-30 A | S138310 | 100% |  |  |  |  |  |  |  |  |  | S138300 | 0 | 1030 | S132600 |  | S132645 | NOCA | Completed | Sakaguchi, Takao |  | Brasil | Procurement | PP5 | MP200151 | Tom Hemmick | BNL | SAMPA Chip 80nsec | OPC000900 |  | POM02.1.02.05.03 |  | 03 |  | 01 | 2 |  | A-OPC | L3 | 003,004 |  |  |  |  |  |  |  |  |  |  |  |  |  |  |
| S139000 |  | SAMPA chip 80 nsec development - Delivery Acceptance - Design at Layout level of new circuits |  | 2d | 2019-04-25 A | 2019-04-26 A |  | 100% |  |  |  |  |  |  |  |  |  | S139000 | 0 | 1020 | S132600 |  | S132660 | NOCA | Completed | Sakaguchi, Takao | M4 | Brasil | Fab & Assy | PP6 | MP200150 | Tom Hemmick | BNL | SAMPA Chip 80nsec | OPC000900 | OPC | POM02.1.02.05.03 | E | 03 |  | 01 | 4 | Yes | A-OPC |  | 003,004 | MP6LA | 16701 |  |  |  |  |  |  |  |  |  |  |  |  |
| S139010 |  | SAMPA chip 80 nsec development - Delivery Acceptance - Layout finalization for MPW and submission |  | 2d | 2019-05-01 A | 2019-05-02 A | S139000 SS, S138315 | 100% |  |  |  |  |  |  |  |  |  | S139000 | 0 | 1030 | S132600 |  | S132660 | NOCA | Completed | Sakaguchi, Takao | M4 | Brasil | Fab & Assy | PP6 | MP200151 | Tom Hemmick | BNL | SAMPA Chip 80nsec | OPC000900 | OPC | POM02.1.02.05.03 | E | 03 |  | 01 | 4 |  | A-OPC |  | 003,004 | MP6LA | 16701 |  |  |  |  |  |  |  |  |  |  |  |  |
| S139700 |  | Procure MPW Run of SAMPA v5 components - Delivery Acceptance |  | 2d | 2019-05-01 A | 2019-05-02 A | S139600 | 100% |  |  |  |  |  |  |  |  |  | S139700 | 0 | 1040 | S132600 |  | S277593564 | NOCA | Completed | Sakaguchi, Takao | M4 | Brasil | Fab & Assy | PP6 | MP210010 | Tom Hemmick | BNL | SAMPA Chip 80nsec | OPC000900 | OPC | POM02.1.02.05.03 | E | 03 |  | 01 | 4 |  | A-OPC |  | 003 | MP6LA | 59704 | Delivery |  |  |  |  |  |  |  |  |  |  |  |
| S139710 |  | Procure second phase of SAMPA development - Delivery of Test Boards |  | 4d | 2019-05-03 A | 2019-05-08 A | S139705 | 100% |  |  |  |  |  |  |  |  |  | S139700 | 0 | 1040 | S132600 |  | S277593564 | NOCA | Completed | Sakaguchi, Takao | M4 | Brasil | Fab & Assy | PP6 | MP200011 | Tom Hemmick | BNL | SAMPA Chip 80nsec | OPC000900 | OPC | POM02.1.02.05.03 | E | 03 |  | 01 | 4 |  | A-OPC |  | 003 | MP6LA | 16701 |  |  |  |  |  |  |  |  |  |  |  |  |
| S139715 |  | Procure second phase of SAMPA development - Delivery of Results from first round of tests |  | 5d | 2019-05-21 A | 2019-05-28 A | S139710 | 100% |  |  |  |  |  |  |  |  |  | S139700 | 0 | 1040 | S132600 |  | S277593564 | NOCA | Completed | Sakaguchi, Takao | M4 | Brasil | Fab & Assy | PP6 | MP200011 | Tom Hemmick | BNL | SAMPA Chip 80nsec | OPC000900 | OPC | POM02.1.02.05.03 | E | 03 |  | 01 | 4 |  | A-OPC |  | 003 | MP6LA | 16701 |  |  |  |  |  |  |  |  |  |  |  |  |
| S139720 |  | Procure second phase of SAMPA development - Delivery of First Chip Layout |  | 10d | 2019-07-02 A | 2019-07-16 A | S139715 | 100% |  |  |  |  |  | start on or after 2019-07-01 |  | Material (Purchase (1st $2M) [35000 h] | 38,614.28 | S139700 | 0 | 1040 | S132600 |  | S277593564 | CA | Completed | Sakaguchi, Takao | M4 | Brasil | Fab & Assy | PP6 | MP200011 | Tom Hemmick | BNL | SAMPA Chip 80nsec | OPC000900 | OPC | POM02.1.02.05.03 | E | 03 |  | 01 | 4 |  | A-OPC |  | 003 | MP6LA | 16701 | Delivery | S139720 | UDF_G2 | 1.02 | 1.02A |  |  |  |  |  |  |  |
| S139725 |  | Procure second phase of SAMPA development - Delivery of Final Review of test results |  | 11d | 2019-07-17 A | 2019-07-31 A | S139720 | 100% |  |  |  |  |  |  |  | Material (Purchase (1st $2M) [70000 h] | 77,228.55 | S139700 | 0 | 1040 | S132600 |  | S277593564 | CA | Completed | Sakaguchi, Takao | M4 | Brasil | Fab & Assy | PP6 | MP200011 | Tom Hemmick | BNL | SAMPA Chip 80nsec | OPC000900 | OPC | POM02.1.02.05.03 | E | 03 |  | 01 | 4 |  | A-OPC |  | 003 | MP6LA | 16701 | Delivery | S139725 | UDF_G3 | 1.02 | 1.02A |  |  |  |  |  |  |  |
| S139730 |  | Procure second phase of SAMPA development - Delivery of Eng Design Review |  | 20d | 2019-08-01 A | 2019-08-28 A | S139725 | 100% |  |  |  |  |  |  |  | Material (Purchase (1st $2M) [47500 h] | 52,405.09 | S139700 | 0 | 1040 | S132600 |  | S277593564 | CA | Completed | Sakaguchi, Takao | M4 | Brasil | Fab & Assy | PP6 | MP200011 | Tom Hemmick | BNL | SAMPA Chip 80nsec | OPC000900 | OPC | POM02.1.02.05.03 | E | 03 |  | 01 | 4 |  | A-OPC |  | 003 | MP6LA | 16701 | Delivery | S139730 | UDF_G3 | 1.02 | 1.02A |  |  |  |  |  |  |  |
| S139900 |  | Procure Engineering Run of Full SAMPA Chip - Prepare & Send Solicitation |  | 10d | 2019-08-22 A | 2019-08-29 A | S139800 | 100% |  | 2019-10-04 | 2019-10-18 |  |  |  |  |  |  | S139900 | 0 | 1070 | S132600 |  | S277593644 | NOCA | Completed | Sakaguchi, Takao |  | Brasil | Procurement | PP2 | MP210020 | Tom Hemmick | BNL | SAMPA Chip 80nsec | OPC000900 |  | POM02.1.02.05.03 |  | 03 |  | 01 | 2 |  |  |  |  |  |  |  |  |  |  |  |  |  |  |  |  |  |  |
| S140000 |  | Procure Engineering Run of Full SAMPA Chip - Vendor Responses |  | 10d | 2019-08-22 A | 2019-08-30 A | S139900 | 100% |  | 2019-10-21 | 2019-11-01 |  |  |  |  |  |  | S140000 | 0 | 1070 | S132600 |  | S277593684 | NOCA | Completed | Sakaguchi, Takao |  | Brasil | Procurement | PP3 | MP210020 | Tom Hemmick | BNL | SAMPA Chip 80nsec | OPC000900 |  | POM02.1.02.05.03 |  | 03 |  | 01 | 3 |  |  |  |  |  |  |  |  |  |  |  |  |  |  |  |  |  |  |
| S140100 |  | Procure Engineering Run of Full SAMPA Chip - Vendor Selection |  | 5d | 2019-08-22 A | 2019-08-30 A | S140000 | 100% |  | 2019-11-04 | 2019-11-08 |  |  |  |  |  |  | S140100 | 0 | 1070 | S132600 |  | S277593724 | NOCA | Completed | Sakaguchi, Takao |  | Brasil | Procurement | PP4 | MP210020 | Tom Hemmick | BNL | SAMPA Chip 80nsec | OPC000900 |  | POM02.1.02.05.03 |  | 03 |  | 01 | 3 |  |  |  |  |  |  |  |  |  |  |  |  |  |  |  |  |  |  |
| S139800 |  | Procure Engineering Run of Full SAMPA Chip - Provide Requirements to Procurement |  | 4d | 2019-08-27 A | 2019-08-30 A | S138901, S139735 | 100% |  |  |  |  |  |  |  | SCI3 PO [40 h] | 6,683.72 | S139800 | 0 | 1070 | S132600 | 2018-07-30 | S277593604 | CA | Completed | Sakaguchi, Takao | L4 | Brasil | Procurement | PP1 | MP210020 | Tom Hemmick | BNL | SAMPA Chip 80nsec | OPC000900 | null | POM02.1.02.05.03 | C | 03 |  | 01 | 3 |  | B |  | 003 |  | 16709 |  | S139800 |  | 1.02 | 1.02B |  |  |  |  |  |  |  |
| S138901 |  | Final Design Review - SAMPA chip 80 nsec |  | 3d | 2019-08-28 A | 2019-08-30 A | S138900 FF | 100% |  |  |  |  |  |  |  | SCI3 PO [8 h]; PROF3 IO E [8 h] | 2,319.34 | S138900 | 0 | 1060 | S132700 |  | S132655 | CA | Completed | Sakaguchi, Takao |  | BNL | Design |  |  | Tom Hemmick | BNL |  |  |  | POM02.1.02.05.03 | C | 03 |  | 1 | 1 |  | B | L4 | 004 |  | 16709 |  | S138901 |  | 1.02 | 1.02B |  |  |  |  |  |  |  |
| S138900 |  | Review Design of Full-scale Production Chip (USP + BNL) |  | 2d | 2019-08-29 A | 2019-08-30 A | S139730 | 100% |  |  |  |  |  |  |  | PROF3 IO E [20 h]; SCI3 PO [20 h] | 5,798.35 | S138900 | 0 | 1050 | S132700 |  | S132655 | CA | Completed | Sakaguchi, Takao |  | BNL | Design |  |  | Tom Hemmick | BNL |  |  |  | POM02.1.02.05.03 | C | 03 |  | 1 | 1 |  | B | L4 | 003 |  | 16709 |  | S138900 |  | 1.02 | 1.02B |  |  |  |  |  |  |  |
| S139735 |  | Procure second phase of SAMPA development - Delivery of Eng Run Preparation |  | 2d | 2019-08-29 A | 2019-08-30 A | S139730 | 100% |  |  |  |  |  |  |  | Material (Purchase (1st $2M) [20000 h] | 22,065.3 | S139700 | 0 | 1040 | S132600 |  | S277593564 | CA | Completed | Sakaguchi, Takao | M4 | Brasil | Fab & Assy | PP6 | MP200011 | Tom Hemmick | BNL | SAMPA Chip 80nsec | OPC000900 | OPC | POM02.1.02.05.03 | E | 03 |  | 01 | 4 |  | A-OPC |  | 003 | MP6LA | 16701 | Delivery | S139735 | UDF_G3 | 1.02 | 1.02A |  |  |  |  |  |  |  |
| S140300 |  | Procure Engineering Run of Full SAMPA Chip - Leadtime |  | 60d | 2019-10-30 A | 2020-02-13 A | S140200 SS, OBLG140210 SS | 100% |  | 2019-10-31 | 2020-01-30 |  |  |  |  |  |  | S140300 | 0 | 1070 | S132600 |  | S277593804 | NOCA | In Progress | Sakaguchi, Takao |  | Brasil | Fab & Assy | PP6 | MP210020 | Tom Hemmick | BNL | SAMPA Chip 80nsec | OPC000900 |  | POM02.1.02.05.03 |  | 03 |  | 01 | 5 |  |  |  |  | MP6LA |  |  |  |  |  |  |  |  |  |  |  |  |  |
| S140200 |  | Procure Engineering Run of Full SAMPA Chip - Contract Award | milestone | 0d | 2019-10-31 A | 2019-10-31 A | S140100 | 100% |  |  |  |  |  | start on or after 2019-10-31 |  |  |  | S140200 | 0 | 1070 | S132600 |  | S277593764 | NOCA | Completed | Sakaguchi, Takao |  | Brasil | Procurement | PP5 | MP210020 | Tom Hemmick | BNL | SAMPA Chip 80nsec | OPC000900 |  | POM02.1.02.05.03 |  | 03 |  | 01 | 3 |  | A-TEC | L3 |  |  |  | Contract Award |  |  |  |  |  |  |  |  |  |  |  |
| S140400 |  | Procure Engineering Run of Full SAMPA Chip - Delivery Acceptance |  | 5d | 2019-12-30 A | 2020-07-06 A | S140300 SS | 100% |  | 2020-02-14 | 2020-02-21 |  |  |  |  | Material (Purchase (1st $2M) [233000 h] | 265,136.71 | S140400 | 0 | 1070 | S132600 |  | S277593844 | CA | Not Started | Sakaguchi, Takao | M4 | Brasil | Fab & Assy | PP6 | MP210020 | Tom Hemmick | BNL | SAMPA Chip 80nsec | OPC000900 | OPC | POM02.1.02.05.03 | E | 03 |  | 01 | 5 |  | A-TEC |  | 003 | MP6LA | 59704 | Delivery | S140400 | UDF_G1 | 1.02 | 1.02A | UDF_G3 | 106054.683628 | 0.4 | FAB |  |  |  |
| OBLG140210 |  | Procure Engineering Run of Full SAMPA Chip - Obligation |  | 1d | 2020-03-02 A | 2020-03-02 A | S140100 | 100% |  |  |  |  |  |  |  | Obligation Resource [265137 h] | 265,136.71 | S140200 | 0 |  | S132600 |  | S277593764 |  | Not Started | Sakaguchi, Takao |  | Brasil | Procurement | PP5 | MP210020 | Tom Hemmick | BNL | SAMPA Chip 80nsec | OPC000900 |  | POM02.1.02.05.03 |  | 03 |  |  |  |  | A-TEC | L3 |  |  |  |  |  |  |  |  |  |  |  | OBLG |  |  |  |
| S140600 |  | Test v2 Prototype TPC FEE Board with 80nsec Full SAMPA Chip March |  | 2d | 2020-03-02 A | 2020-03-03 A |  | 100% |  |  |  |  |  | finish on 2020-03-03 |  | SCI3 PO [10 h]; PROF3 PO E [10 h] | 2,986.15 | S140600 | 0 | 1090 | S132600 |  | S132680 | CA | Not Started | Sakaguchi, Takao | M4 | BNL | Procurement |  |  | Tom Hemmick | BNL | SAMPA Chip 80nsec |  | null | POM02.1.02.05.03 | C | 03 |  | 01 | 3 |  | B |  |  |  | 16709 |  | S140600 |  | 1.02 | 1.02B |  |  |  |  |  |  |  |
| S138700 |  | Review the Test Result of the Full Chip (USP + BNL) |  | 5d | 2020-04-14 A | 2020-04-20 A | S138800, S140400 | 100% |  | 2020-06-01 | 2020-06-05 |  |  |  |  |  |  | S138700 | 0 | 1080 | S132700 |  | S132659 | NOCA | Not Started | Sakaguchi, Takao |  | BNL | Design |  |  | Tom Hemmick | BNL |  |  |  | POM02.1.02.05.03 |  | 03 |  | 1 | 1 |  |  | L4 | 003,005 |  |  |  |  |  |  |  |  |  |  |  |  |  |  |
| S140800 |  | SAMPA ASIC Performance Accepted | milestone | 0d | 2020-05-29 A | 2020-05-29 A | S140700 FF, S140701 | 100% |  | 2020-06-01 | 2020-06-01 |  |  |  |  |  |  | S140800 | 0 | 1090 | S132700 |  | S132700 | NOCA | Not Started | Sakaguchi, Takao |  | BNL | Design |  |  | Tom Hemmick | BNL |  |  |  | POM02.1.02.05.03 |  | 03 |  | 1 | 1 |  |  | L2 |  |  |  |  |  | UDF_G2 |  |  | UDF_G3 |  |  |  | 2020-09-30 | 86 | PMP_1x |
| S140500 |  | Populate v2 Prototype TPC FEE Board with 80nsec Full SAMPA Chip |  | 20d | 2020-08-03 A | 2020-09-30 A | S139700, S138310 SS, S138700 | 100% |  | 2020-08-03 | 2020-08-28 |  |  |  |  | Material (Purchase (1st $2M) [3000 h] | 3,413.78 | S140500 | 0 | 1090 | S132600 |  | S132670 | CA | Not Started | Sakaguchi, Takao | M4 | BNL | Fab & Assy |  |  | Tom Hemmick | BNL | SAMPA Chip 80nsec | OPC000900 | OPC | POM02.1.02.05.03 | E | 03 |  | 01 | 5 |  | A-TEC |  | 003 |  | 59704 |  | S140500 | UDF_G1 | 1.02 | 1.02A | UDF_G3 | 3413.77737 | 1 |  |  |  |  |
| S140605 |  | Test v2 Prototype TPC FEE Board with 80nsec Full SAMPA Chip |  | 10d | 2020-08-03 A | 2021-05-28 A |  | 100% |  | 2020-08-03 | 2020-08-14 |  |  | start on or after 2020-04-01 |  | SCI3 PO [190 h]; PROF3 PO E [190 h] | 56,736.89 | S140600 | 0 | 1090 | S132600 |  | S132680 | CA | Not Started | Sakaguchi, Takao | M4 | BNL | Procurement |  |  | Tom Hemmick | BNL | SAMPA Chip 80nsec |  | null | POM02.1.02.05.03 | C | 03 |  | 01 | 3 |  | B |  |  |  | 16709 |  | S140600 |  | 1.02 | 1.02B |  |  |  |  |  |  |  |
| S140700 |  | Review Results of SAMPA 80 nsec Full Chip Performance with v2 Prototype TPC FEE Board |  | 10d | 2021-05-17 A | 2021-06-30 | S140605 | 50% | 22d | 2021-06-29 | 2021-07-13 | 4d | 0d |  | 2021-06-30 | PROF5 PO S Software [40 h]; SCI3 PO [185 h]; PROF4 PO E [40 h] | 45,868.65 | S140700 | 0 | 1090 | S132600 |  | S132690 | CA | Not Started | Sakaguchi, Takao | L4 | BNL | Procurement |  |  | Tom Hemmick | BNL | SAMPA Chip 80nsec |  | null | POM02.1.02.05.03 | C | 03 |  | 01 | 3 |  | B |  |  |  | 16709 |  | S140700 |  | 1.02 | 1.02B |  |  |  |  |  |  |  |
| S140701 |  | Production Readiness Review for TPC FEE full production |  | 1d | 2021-07-01 | 2021-07-01 | S140700 |  |  |  |  | 4d | 0d |  |  | PROF3 IO E [8 h]; PROF4 PO E [8 h]; SCI3 PO [8 h] | 3,674.05 | S140700 | 0 | 1090 | S132600 |  | S132690 | CA | Not Started | Sakaguchi, Takao | L4 | BNL | Procurement |  |  | Tom Hemmick | BNL | SAMPA Chip 80nsec |  | null | POM02.1.02.05.03 | C | 03 |  | 01 | 3 |  | B |  | 004 |  | 16709 |  | S140701 |  | 1.02 | 1.02B |  |  |  |  |  |  |  |

Notes:
- S137800: BNL_UDF_Adhoc Comments: 180413 ELM dur, pred/succ per GRY; 180220 ELM added MP & PP Nos. / BNL_UDF_Old Activity Name 181221: SAMPA chip 80 nsec development - Provide Requirements to Procurement
- OBLG138210: BNL_UDF_Adhoc Comments: 180420 ELM pred/succ per GRY; 180220 ELM added MP & PP Nos. / BNL_UDF_Old Activity Name 181221: SAMPA chip 80 nsec development - Contract Award(s) - MPW to Test Design Changes
- S138200: BNL_UDF_Adhoc Comments: 180420 ELM pred/succ per GRY; 180220 ELM added MP & PP Nos. / BNL_UDF_Old Activity Name 181221: SAMPA chip 80 nsec development - Contract Award(s) - MPW to Test Design Changes
- S138300: BNL_UDF_Status Comments: 190417 ELM name; 190318 ELM split OPC,TEC per GRY / BNL_UDF_Adhoc Comments: 180420 ELM pred/succ per GRY; 180220 ELM added MP & PP Nos. / BNL_UDF_Old Activity Name 181221: SAMPA chip 80 nsec development - Contract Award(s) - Engineering Effort to Create All Design Changes
- S138310: BNL_UDF_Status Comments: 190417 ELM name; 190318 ELM split OPC,TEC per GRY / BNL_UDF_Adhoc Comments: 180420 ELM pred/succ per GRY; 180220 ELM added MP & PP Nos. / BNL_UDF_Old Activity Name 181221: SAMPA chip 80 nsec development - Contract Award(s) - Engineering Effort to Create All Design Changes
- S137801: BNL_UDF_Status Comments: 190522 IVS new act. / BNL_UDF_Adhoc Comments: 180413 ELM dur, pred/succ per GRY; 180220 ELM added MP & PP Nos. / BNL_UDF_Old Activity Name 181221: SAMPA chip 80 nsec development - Provide Requirements to Procurement
- S137900: BNL_UDF_Adhoc Comments: 180220 ELM added MP & PP Nos. / BNL_UDF_Old Activity Name 181221: SAMPA chip 80 nsec development - Prepare & Send Solicitation
- S138000: BNL_UDF_Adhoc Comments: 180220 ELM added MP & PP Nos. / BNL_UDF_Old Activity Name 181221: SAMPA chip 80 nsec development - Vendor Responses
- S138100: BNL_UDF_Adhoc Comments: 180220 ELM added MP & PP Nos. / BNL_UDF_Old Activity Name 181221: SAMPA chip 80 nsec development - Vendor Selection
- S138400: Steps: 1) Design of 80ns analog; 2) Investigate present ADCs prototype @ 20MHz; 3) Review of schematic performan; 4) Post-layout and high high-level simulation; 5) MPW Chips - Designing and Layout; 6) Review and release for MPW; 7) MPW submission (8'' TSMC TBC!); 8) Design of test boards/ test protocol; 9) Produce Test Cards; 10) MPW Chips - Delivery; 11) MPW Chips - Mount; 12) MPW Chips - Test; 13) Full Chip - Start Design; 14) Full Chip - Start Layout; 15) Full Chip - Start Simulation; 16) Full Chip - Complete Simulation; 17) Full Chip - Submission / BNL_UDF_Adhoc Comments: 180220 ELM added MP & PP Nos. / BNL_UDF_Old Activity Name 181221: SAMPA chip 80 nsec development - Leadtime - MPW Test Run
- S139705: BNL_UDF_Status Comments: 190315 ELM BNL Units per TS / BNL_UDF_Adhoc Comments: 180220 ELM added MP & PP Nos. / BNL_UDF_Old Activity Name 181221: Procure Layout/Simulation/Submission/Reception of Full SAMPA Chip - Delivery Acceptance
- S138500: BNL_UDF_Status Comments: 190315 ELM BNL Units per TS / BNL_UDF_Adhoc Comments: 180220 ELM added MP & PP Nos. / BNL_UDF_Old Activity Name 181221: SAMPA chip 80 nsec development - Delivery Acceptance - MPW Test Run
- S139100: BNL_UDF_Status Comments: 190315 ELM add rsrc per GRY / BNL_UDF_Adhoc Comments: 180413 ELM dur, pred/succ per GRY; 180220 ELM added MP & PP Nos. / BNL_UDF_Old Activity Name 181221: Procure Layout/Simulation/Submission/Reception of Full SAMPA Chip - Provide Requirements to Procurement
- S139200: BNL_UDF_Adhoc Comments: 180220 ELM added MP & PP Nos. / BNL_UDF_Old Activity Name 181221: Procure Layout/Simulation/Submission/Reception of Full SAMPA Chip - Prepare & Send Solicitation
- S139300: BNL_UDF_Adhoc Comments: 180220 ELM added MP & PP Nos. / BNL_UDF_Old Activity Name 181221: Procure Layout/Simulation/Submission/Reception of Full SAMPA Chip - Vendor Responses
- S139400: BNL_UDF_Adhoc Comments: 180220 ELM added MP & PP Nos. / BNL_UDF_Old Activity Name 181221: Procure Layout/Simulation/Submission/Reception of Full SAMPA Chip - Vendor Selection
- S139500: BNL_UDF_Adhoc Comments: 180420 ELM pred/succ per GRY; 180220 ELM added MP & PP Nos. / BNL_UDF_Old Activity Name 181221: Procure Layout/Simulation/Submission/Reception of Full SAMPA Chip - Contract Award
- S138800: BNL_UDF_Adhoc Comments: 180220 ELM added MP & PP Nos. / BNL_UDF_Old Activity Name 181221: SAMPA chip 80 nsec development - Leadtime - Engineering Effort to Create Design Changes
- S139600: Steps: 1) Design of 80ns analog; 2) Investigate present ADCs prototype @ 20MHz; 3) Review of schematic performan; 4) Post-layout and high high-level simulation; 5) MPW Chips - Designing and Layout; 6) Review and release for MPW; 7) MPW submission (8'' TSMC TBC!); 8) Design of test boards/ test protocol; 9) Produce Test Cards; 10) MPW Chips - Delivery; 11) MPW Chips - Mount; 12) MPW Chips - Test; 13) Full Chip - Start Design; 14) Full Chip - Start Layout; 15) Full Chip - Start Simulation; 16) Full Chip - Complete Simulation; 17) Full Chip - Submission / BNL_UDF_Adhoc Comments: 180220 ELM added MP & PP Nos. / BNL_UDF_Old Activity Name 181221: Procure Layout/Simulation/Submission/Reception of Full SAMPA Chip - Leadtime
- S138315: BNL_UDF_Status Comments: 190417 ELM name; 190318 ELM split OPC,TEC per GRY / BNL_UDF_Adhoc Comments: 180420 ELM pred/succ per GRY; 180220 ELM added MP & PP Nos. / BNL_UDF_Old Activity Name 181221: SAMPA chip 80 nsec development - Contract Award(s) - Engineering Effort to Create All Design Changes
- S139000: BNL_UDF_Status Comments: 190417 ELM name; 190318 ELM split OPC,TEC per GRY; 190315 ELM BNL Units per TS / BNL_UDF_Adhoc Comments: 180220 ELM added MP & PP Nos. / BNL_UDF_Old Activity Name 181221: SAMPA chip 80 nsec development - Delivery Acceptance - Engineering Effort
- S139010: BNL_UDF_Status Comments: 190417 ELM name; 190318 ELM split OPC,TEC per GRY; 190315 ELM BNL Units per TS / BNL_UDF_Adhoc Comments: 180220 ELM added MP & PP Nos. / BNL_UDF_Old Activity Name 181221: SAMPA chip 80 nsec development - Delivery Acceptance - Engineering Effort
- S139700: BNL_UDF_Status Comments: 190315 ELM BNL Units per TS / BNL_UDF_Adhoc Comments: 180220 ELM added MP & PP Nos. / BNL_UDF_Old Activity Name 181221: Procure Layout/Simulation/Submission/Reception of Full SAMPA Chip - Delivery Acceptance
- S139710: BNL_UDF_Status Comments: 190315 ELM BNL Units per TS / BNL_UDF_Adhoc Comments: 180220 ELM added MP & PP Nos. / BNL_UDF_Old Activity Name 181221: Procure Layout/Simulation/Submission/Reception of Full SAMPA Chip - Delivery Acceptance
- S139715: BNL_UDF_Status Comments: 190315 ELM BNL Units per TS / BNL_UDF_Adhoc Comments: 180220 ELM added MP & PP Nos. / BNL_UDF_Old Activity Name 181221: Procure Layout/Simulation/Submission/Reception of Full SAMPA Chip - Delivery Acceptance
- S139720: BNL_UDF_Status Comments: 190315 ELM BNL Units per TS / BNL_UDF_Adhoc Comments: 180220 ELM added MP & PP Nos. / BNL_UDF_Old Activity Name 181221: Procure Layout/Simulation/Submission/Reception of Full SAMPA Chip - Delivery Acceptance
- S139725: BNL_UDF_Status Comments: 190315 ELM BNL Units per TS / BNL_UDF_Adhoc Comments: 180220 ELM added MP & PP Nos. / BNL_UDF_Old Activity Name 181221: Procure Layout/Simulation/Submission/Reception of Full SAMPA Chip - Delivery Acceptance
- S139730: BNL_UDF_Status Comments: 190315 ELM BNL Units per TS / BNL_UDF_Adhoc Comments: 180220 ELM added MP & PP Nos. / BNL_UDF_Old Activity Name 181221: Procure Layout/Simulation/Submission/Reception of Full SAMPA Chip - Delivery Acceptance
- S139900: BNL_UDF_Adhoc Comments: 180220 ELM added MP & PP Nos. / BNL_UDF_Old Activity Name 181221: Procure Engineering Run of Full SAMPA Chip - Prepare & Send Solicitation
- S140000: BNL_UDF_Adhoc Comments: 180220 ELM added MP & PP Nos. / BNL_UDF_Old Activity Name 181221: Procure Engineering Run of Full SAMPA Chip - Vendor Responses
- S140100: BNL_UDF_Adhoc Comments: 180220 ELM added MP & PP Nos. / BNL_UDF_Old Activity Name 181221: Procure Engineering Run of Full SAMPA Chip - Vendor Selection
- S139800: BNL_UDF_Status Comments: 190315 ELM add rsrc per GRY / BNL_UDF_Adhoc Comments: 180413 ELM dur, pred/succ per GRY; 180220 ELM added MP & PP Nos. / BNL_UDF_Old Activity Name 181221: Procure Engineering Run of Full SAMPA Chip - Provide Requirements to Procurement
- S138901: General Comments: 180502 ELM per TSakagu: This / is one more decision point whether or not we further proceed / 80nsec SAMPA / development. / BNL_UDF_Status Comments: 190522 IVS new act. / BNL_UDF_Adhoc Comments: 180502 ELM added per TS / BNL_UDF_Old Activity Name 181221: Review Design of Full-scale Production Chip
- S138900: General Comments: 180502 ELM per TSakagu: This / is one more decision point whether or not we further proceed / 80nsec SAMPA / development. / BNL_UDF_Status Comments: 190315 ELM name per GRY / BNL_UDF_Adhoc Comments: 180502 ELM added per TS / BNL_UDF_Old Activity Name 181221: Review Design of Full-scale Production Chip
- S139735: BNL_UDF_Status Comments: 190315 ELM BNL Units per TS / BNL_UDF_Adhoc Comments: 180220 ELM added MP & PP Nos. / BNL_UDF_Old Activity Name 181221: Procure Layout/Simulation/Submission/Reception of Full SAMPA Chip - Delivery Acceptance
- S140300: Steps: 1) Design of 80ns analog; 2) Investigate present ADCs prototype @ 20MHz; 3) Review of schematic performan; 4) Post-layout and high high-level simulation; 5) MPW Chips - Designing and Layout; 6) Review and release for MPW; 7) MPW submission (8'' TSMC TBC!); 8) Design of test boards/ test protocol; 9) Produce Test Cards; 10) MPW Chips - Delivery; 11) MPW Chips - Mount; 12) MPW Chips - Test; 13) Full Chip - Start Design; 14) Full Chip - Start Layout; 15) Full Chip - Start Simulation; 16) Full Chip - Complete Simulation; 17) Full Chip - Submission / BNL_UDF_Adhoc Comments: 180220 ELM added MP & PP Nos. / BNL_UDF_Old Activity Name 181221: Procure Engineering Run of Full SAMPA Chip - Leadtime
- S140200: BNL_UDF_Adhoc Comments: 180420 ELM pred/succ per GRY; 180220 ELM added MP & PP Nos. / BNL_UDF_Old Activity Name 181221: Procure Engineering Run of Full SAMPA Chip - Contract Award
- S140400: BNL_UDF_Status Comments: 190315 ELM BNL Units per TS / BNL_UDF_Adhoc Comments: 180220 ELM added MP & PP Nos. / BNL_UDF_Old Activity Name 181221: Procure Engineering Run of Full SAMPA Chip - Delivery Acceptance
- OBLG140210: BNL_UDF_Adhoc Comments: 180420 ELM pred/succ per GRY; 180220 ELM added MP & PP Nos. / BNL_UDF_Old Activity Name 181221: Procure Engineering Run of Full SAMPA Chip - Contract Award
- S140600: BNL_UDF_Adhoc Comments: 180423 ELM rsrc per GRY / BNL_UDF_Old Activity Name 181221: Test v2 Prototype TPC FEE Board with 80nsec Full SAMPA Chip
- S138700: General Comments: 180502 ELM per TSakagu: This / is the decision point whether or not we further proceed 80nsec / SAMPA / development. / BNL_UDF_Status Comments: 190607 change links, names; 190315 ELM name per GRY / BNL_UDF_Adhoc Comments: 180502 ELM added per TS / BNL_UDF_Old Activity Name 181221: Review the Test Result of the Full Chip
- S140800: BNL_UDF_Adhoc Comments: 180223 ELM added per GRY / BNL_UDF_Old Activity Name 181221: SAMPA ASIC Performance Accepted
- S140500: BNL_UDF_Status Comments: 190315 ELM BNL Units per TS / BNL_UDF_Adhoc Comments: 180223 ELM added per GRY / BNL_UDF_Old Activity Name 181221: Populate v2 Prototype TPC FEE Board with 80nsec Full SAMPA Chip
- S140605: BNL_UDF_Adhoc Comments: 180423 ELM rsrc per GRY / BNL_UDF_Old Activity Name 181221: Test v2 Prototype TPC FEE Board with 80nsec Full SAMPA Chip
- S140700: BNL_UDF_Adhoc Comments: 180423 ELM rsrc per GRY / BNL_UDF_Old Activity Name 181221: Review Results of SAMPA 80 nsec Full Chip Performance with v2 Prototype TPC FEE Board
- S140701: BNL_UDF_Status Comments: 190522 IVS new act. / BNL_UDF_Adhoc Comments: 180423 ELM rsrc per GRY / BNL_UDF_Old Activity Name 181221: Review Results of SAMPA 80 nsec Full Chip Performance with v2 Prototype TPC FEE Board

| ID | WBS | Activity | Type | Duration | Start | Finish | Predecessors | Complete | Remaining | Planned start | Planned finish | Total float | Free float | Constraint | Expected finish | Resources | Cost | BNL_UDF_Temp Text 01 | BNL_UDF_Percent Complete | BNL_UDF_OPC TEC (deprecated) | BNL_UDF_Temp Date 01 | BNL_UDF_Old Activity ID 181221 | RG Check | BNL_Activity Status | BNL_Fund Source | BNL_Estimator | BNL_Cost Basis | BNL_Location | BNL_EDIA | BNL_Proc Sig Phase | BNL_Proc Sig | BNL_CAM | BNL_Institution | BNL_R&D FY18-19 | BNL_OPC TEC (deprecated) | BNL_WBS | BNL_EVT | BNL_Account Number | BNL_PCR ID | BNL_WBS_Hierarchical | Completed | PMP Summary Part1 | PMP Summary Part2 | Additional EVT documentation required | BNL_Cobra WP | BNL_Master Control Account | BNL_Cobra Control Account | Temp | BNL_UDF_Adhoc Comments | Indicator - Procurement | Indicator - Float | BNL_Milestone Level | SPH Proc Register | BNL_UDF_Remaining Tot Cost | BNL_UDF_Percent_remaining | BNL_Obligation | BNL_UDF_Exclude | BNL_DOE OPC | Target Milestone Date | Variance | PMP Milestones |
| --- | --- | --- | --- | --- | --- | --- | --- | --- | --- | --- | --- | --- | --- | --- | --- | --- | --- | --- | --- | --- | --- | --- | --- | --- | --- | --- | --- | --- | --- | --- | --- | --- | --- | --- | --- | --- | --- | --- | --- | --- | --- | --- | --- | --- | --- | --- | --- | --- | --- | --- | --- | --- | --- | --- | --- | --- | --- | --- | --- | --- | --- |
|  | 04 | **TPC FEE Production** |  |  | 2018-10-22 | 2022-01-19 |  |  |  |  |  |  |  |  |  |  |  |  |  |  |  |  |  |  |  |  |  |  |  |  |  |  |  |  |  |  |  |  |  |  |  |  |  |  |  |  |  |  |  |  |  |  |  |  |  |  |  |  |  |  |  |
| S135800 |  | Design TPC FEE Cooling System |  | 152d | 2018-10-22 A | 2019-05-31 A | S100090 SS, S135500 FF | 100% |  |  |  |  |  |  |  |  |  | S135800 | 60 | S130900 | 2019-03-29 | S130880 | NOCA | Completed | B | Sakaguchi, Takao | L5 | BNL | Procurement | PP1 | MP202000 | Tom Hemmick | BNL | TPC FEE Pre-pro proto | null | POM02.1.02.05.04 | C | 16709 | 003 | 04 | yes | 01 | 2 | Yes |  |  |  |  |  |  |  |  |  |  |  |  |  |  |  |  |  |
| S135802 |  | Design TPC FEE Cooling System Split |  | 42d | 2019-08-01 A | 2019-11-29 A | S135800 | 100% |  | 2019-08-01 | 2019-09-30 |  |  |  |  | PROF3 PO M [160 h] | 19,651.97 | S135800 | 60 | S130900 | 2019-03-29 | S130880 | CA | Completed | B | Sakaguchi, Takao | L5 | BNL | Procurement | PP1 | MP202000 | Tom Hemmick | BNL | TPC FEE Pre-pro proto | null | POM02.1.02.05.04 | C | 16709 | 003 | 04 |  | 01 | 3 | Yes | S135802 | 1.02 | 1.02B | 1 |  |  |  |  |  |  |  |  |  |  |  |  |  |
| S140900 |  | Procure TPC FEE Production Components - Provide Requirements to Procurement |  | 5d | 2020-05-05 A | 2020-05-28 A | S137500, S137700, S137600 | 100% |  | 2020-07-22 | 2020-07-28 |  |  |  |  | PROF4 PO E [80 h]; SCI3 SBU - Unpaid [56 h]; TECH3 PO E [80 h] | 20,910.97 | S140900 | 0 | S132800 |  | S132800 | CA | Not Started | B_T | Sakaguchi, Takao | L4 | BNL | Procurement | PP1 | MP101400 | Tom Hemmick | BNL |  | null | POM02.1.02.05.04 | C | 16709 |  | 04 |  | 01 | 3 |  | S140900 | 1.02 | 1.02B |  | 180413 ELM dur, pred/succ per GRY |  |  |  |  |  |  |  |  |  |  |  |  |
| S141000 |  | Procure TPC FEE Production Components - Prepare & Send Solicitation |  | 20d | 2020-05-05 A | 2020-05-28 A | S140900 SS | 100% |  | 2020-07-22 | 2020-08-18 |  |  |  |  |  |  | S141000 | 0 | S132900 |  | S132900 | NOCA | Not Started |  | Sakaguchi, Takao |  | BNL | Procurement | PP2 | MP101400 | Tom Hemmick | BNL |  |  | POM02.1.02.05.04 |  |  |  | 04 |  | 01 | 3 |  |  |  |  |  |  |  |  |  |  |  |  |  |  |  |  |  |  |
| S141100 |  | Procure TPC FEE Production Components - Vendor Responses |  | 20d | 2020-05-05 A | 2020-05-28 A | S141000 | 100% |  | 2020-08-19 | 2020-09-16 |  |  |  |  |  |  | S141100 | 0 | S133000 |  | S133000 | NOCA | Not Started |  | Sakaguchi, Takao |  | BNL | Procurement | PP3 | MP101400 | Tom Hemmick | BNL |  |  | POM02.1.02.05.04 |  |  |  | 04 |  | 01 | 3 |  |  |  |  |  | 180413 ELM dur per GRY |  |  |  |  |  |  |  |  |  |  |  |  |
| S142600 |  | Procure TPC FEE Production Boards & Assembly - Provide Requirements to Procurement |  | 5d | 2020-05-13 A | 2020-05-26 A | S140900, S137700 | 100% |  | 2020-07-29 | 2020-08-04 |  |  |  |  | PROF4 PO E [44 h] | 6,479.66 | S142600 | 0 | S134200 |  | S134200 | CA | Not Started | B | Sakaguchi, Takao | L4 | BNL | Procurement | PP1 | MP101300 | Tom Hemmick | BNL |  | null | POM02.1.02.05.04 | C | 16709 |  | 04 |  | 01 | 3 |  | S142600 | 1.02 | 1.02B |  | 180328 ELM Act name per GRY |  |  |  |  |  |  |  |  |  |  |  |  |
| S142700 |  | Procure TPC FEE Production Boards & Assembly - Prepare & Send Solicitation |  | 30d | 2020-05-13 A | 2020-05-26 A | S142600 | 100% |  | 2020-08-05 | 2020-09-16 |  |  |  |  |  |  | S142700 | 0 | S134300 |  | S134300 | NOCA | Not Started |  | Sakaguchi, Takao |  | BNL | Procurement | PP2 | MP101300 | Tom Hemmick | BNL |  |  | POM02.1.02.05.04 |  |  |  | 04 |  | 01 | 3 |  |  |  |  |  |  |  |  |  |  |  |  |  |  |  |  |  |  |
| S142800 |  | Procure TPC FEE Production Boards & Assembly - Vendor Responses |  | 10d | 2020-05-13 A | 2020-05-26 A | S142700 | 100% |  | 2020-09-17 | 2020-09-30 |  |  |  |  |  |  | S142800 | 0 | S134400 |  | S134400 | NOCA | Not Started |  | Sakaguchi, Takao |  | BNL | Procurement | PP3 | MP101300 | Tom Hemmick | BNL |  |  | POM02.1.02.05.04 |  |  |  | 04 |  | 01 | 3 |  |  |  |  |  |  |  |  |  |  |  |  |  |  |  |  |  |  |
| S141900 |  | Procure TPC FEE LV power supplies - Provide Requirements to Procurement |  | 5d | 2020-08-25 A | 2020-08-27 A | S137700 | 100% |  | 2020-12-04 | 2020-12-10 |  |  |  |  | PROF4 PO E [32 h] | 4,853.85 | S141900 | 0 | S133500 |  | S133500 | CA | Not Started | B | Sakaguchi, Takao | L4 | BNL | Procurement | PP1 | MP101500 | Tom Hemmick | BNL |  | null | POM02.1.02.05.04 | C | 16709 |  | 04 |  | 01 | 3 |  | S141900 | 1.02 | 1.02B |  |  |  |  |  |  |  |  |  |  |  |  |  |  |
| S142000 |  | Procure TPC FEE LV Power Supplies - Prepare & Send Solicitation |  | 30d | 2020-09-22 A | 2020-09-30 A | S141900 | 100% |  | 2020-12-04 | 2021-01-19 |  |  |  |  |  |  | S142000 | 0 | S133600 |  | S133600 | NOCA | Not Started |  | Sakaguchi, Takao |  | BNL | Procurement | PP2 | MP101500 | Tom Hemmick | BNL |  |  | POM02.1.02.05.04 |  |  |  | 04 |  | 01 | 3 |  |  |  |  |  |  |  |  |  |  |  |  |  |  |  |  |  |  |
| S141200 |  | Procure TPC FEE Production Components - Vendor Selection |  | 15d | 2020-10-20 A | 2020-10-30 A | S141100 | 100% |  | 2020-12-04 | 2020-12-24 |  |  |  |  |  |  | S141200 | 0 | S133100 |  | S133100 | NOCA | Not Started |  | Sakaguchi, Takao |  | BNL | Procurement | PP4 | MP101400 | Tom Hemmick | BNL |  |  | POM02.1.02.05.04 |  |  |  | 04 |  | 01 | 3 |  |  |  |  |  | 180413 ELM dur per GRY |  |  |  |  |  |  |  |  |  |  |  |  |
| S142100 |  | Procure TPC FEE LV Power Supplies - Vendor Responses |  | 10d | 2020-10-20 A | 2020-10-30 A | S142000 | 100% |  | 2020-12-04 | 2020-12-17 |  |  |  |  |  |  | S142100 | 0 | S133700 |  | S133700 | NOCA | Not Started |  | Sakaguchi, Takao |  | BNL | Procurement | PP3 | MP101500 | Tom Hemmick | BNL |  |  | POM02.1.02.05.04 |  |  |  | 04 |  | 01 | 3 |  |  |  |  |  |  |  |  |  |  |  |  |  |  |  |  |  |  |
| S142200 |  | Procure TPC FEE LV Power Supplies - Vendor Selection |  | 20d | 2020-10-20 A | 2020-10-30 A | S142100 | 100% |  | 2020-12-18 | 2021-01-19 |  |  |  |  |  |  | S142200 | 0 | S133800 |  | S133800 | NOCA | Not Started |  | Sakaguchi, Takao |  | BNL | Procurement | PP4 | MP101500 | Tom Hemmick | BNL |  |  | POM02.1.02.05.04 |  |  |  | 04 |  | 01 | 3 |  |  |  |  |  |  |  |  |  |  |  |  |  |  |  |  |  |  |
| S141600 |  | Procure TPC FEE Production Components, Phase 2 (All except Optical and SAMPA) - Contract Award(s) | milestone | 0d | 2020-10-28 A | 2020-10-28 A | S141200, S101000, S140700, S140701 | 100% |  | 2020-12-28 | 2020-12-28 |  |  |  |  |  |  | S141600 | 0 | S133200 |  | S277593884 | NOCA | Not Started | A-TEC | Sakaguchi, Takao |  | BNL | Procurement | PP5 | MP101420 | Tom Hemmick | BNL |  |  | POM02.1.02.05.04 |  |  |  | 04 |  | 01 | 3 |  |  |  |  |  | 180420 ELM pred/succ per GRY; | UDF_G2 | UDF_G1 | L5 | Contract Award |  |  |  |  |  |  |  |  |
| S141700 |  | Procure TPC FEE Production Components, Phase 2 (All except Optical and SAMPA) - Leadtime |  | 20d | 2020-10-30 A | 2020-11-30 A | S141600 SS, OBLG141610 SS | 100% |  | 2020-12-28 | 2021-01-26 |  |  |  |  |  |  | S141700 | 0 | S133300 |  | S277593924 | NOCA | Not Started |  | Sakaguchi, Takao |  | BNL | Fab & Assy | PP6 | MP101420 | Tom Hemmick | BNL |  |  | POM02.1.02.05.04 |  |  |  | 04 |  | 01 | 5 |  |  |  |  |  |  |  |  |  |  |  |  |  |  |  |  |  |  |
| S141800 |  | Procure TPC FEE Production Components, Phase 2 (All except Optical and SAMPA) - Delivery Acceptance |  | 5d | 2020-11-02 A | 2021-07-16 | S141700 | 85% | 10d | 2021-01-27 | 2021-02-02 | 19d | 0d | start on or after 2021-01-04 | 2021-06-29 | Material (Purchase (1st $2M) [266694 h] | 309,547.54 | S141800 | 0 | S133400 |  | S277593964 | CA | Not Started | A-TEC | Sakaguchi, Takao | M3 | BNL | Fab & Assy | PP6 | MP101420 | Tom Hemmick | BNL |  | TEC | POM02.1.02.05.04 | C | 59704 | 015 | 04 |  | 01 | 5 |  | S141800 | 1.02 | 1.02A |  | 180410 ELM pred/succ per GRY | UDF_G1 | UDF_G1 |  | Delivery | 309547.541371 | 1 | FAB |  |  |  |  |  |
| S135900 |  | Procure TPC FEE Cooling System - Provide Requirements to Procurement |  | 10d | 2021-01-11 A | 2021-01-26 A | S137700, S135802 | 100% |  | 2021-02-09 | 2021-02-23 |  |  |  |  | SCI3 PO [10 h]; PROF3 PO E [10 h] | 3,075.74 | S135900 | 0 | S130900 |  | S130900 | CA | Not Started | B | Sakaguchi, Takao | L5 | BNL | Procurement | PP1 | MP202000 | Tom Hemmick | BNL | TPC FEE Pre-pro proto | null | POM02.1.02.05.04 | C | 16709 | 003 | 04 |  | 01 | 3 |  | S135900 | 1.02 | 1.02B |  |  |  |  |  |  |  |  |  |  |  |  |  |  |
| S136000 |  | Procure TPC FEE Cooling System - Prepare & Send Solicitation |  | 30d | 2021-01-11 A | 2021-01-26 A | S135900 | 100% |  | 2021-02-24 | 2021-04-06 |  |  |  |  |  |  | S136000 | 0 | S130900 |  | S130910 | NOCA | Not Started | B | Sakaguchi, Takao | L5 | BNL | Procurement | PP2 | MP202000 | Tom Hemmick | BNL | TPC FEE Pre-pro proto | null | POM02.1.02.05.04 | C | 16709 | 003 | 04 |  | 01 | 3 |  |  |  |  |  | 180402 ELM added activity for proc strg |  |  |  |  |  |  |  |  |  |  |  |  |
| S136100 |  | Procure TPC FEE Cooling System - Vendor Responses |  | 10d | 2021-01-11 A | 2021-01-26 A | S136000 | 100% |  | 2021-04-07 | 2021-04-20 |  |  |  |  |  |  | S136100 | 0 | S130900 |  | S130920 | NOCA | Not Started | B | Sakaguchi, Takao | L5 | BNL | Procurement | PP3 | MP202000 | Tom Hemmick | BNL | TPC FEE Pre-pro proto | null | POM02.1.02.05.04 | C | 16709 | 003 | 04 |  | 01 | 3 |  |  |  |  |  | 180402 ELM added activity for proc strg |  |  |  |  |  |  |  |  |  |  |  |  |
| S136200 |  | Procure TPC FEE Cooling System - Vendor Selection |  | 5d | 2021-01-11 A | 2021-01-26 A | S136100 | 100% |  | 2021-04-21 | 2021-04-27 |  |  |  |  |  |  | S136200 | 0 | S131000 |  | S131000 | NOCA | Not Started | B | Sakaguchi, Takao | L5 | BNL | Procurement | PP4 | MP202000 | Tom Hemmick | BNL | TPC FEE Pre-pro proto | null | POM02.1.02.05.04 | C | 16709 | 003 | 04 |  | 01 | 3 |  |  |  |  |  |  |  |  |  |  |  |  |  |  |  |  |  |  |
| S142300 |  | Procure TPC FEE LV Power Supplies - Contract Award(s) | milestone | 0d | 2021-01-20 A | 2021-01-20 A | S142200, S101000 | 100% |  | 2021-02-09 | 2021-02-09 |  |  |  |  |  |  | S142300 | 0 | S133900 |  | S133900 | NOCA | Not Started | A-TEC | Sakaguchi, Takao |  | BNL | Procurement | PP5 | MP101500 | Tom Hemmick | BNL |  |  | POM02.1.02.05.04 |  |  |  | 04 |  | 01 | 3 |  |  |  |  |  |  | UDF_G1 | UDF_G3 | L5 | Contract Award |  |  |  |  |  |  |  |  |
| S142400 |  | Procure TPC FEE LV Power Supplies - Contract/PO - Leadtime |  | 40d | 2021-01-21 A | 2021-03-31 A | S142300 SS, OBLG142310 SS | 100% |  | 2021-02-09 | 2021-04-06 |  |  |  |  |  |  | S142400 | 0 | S134000 |  | S134000 | NOCA | Not Started |  | Sakaguchi, Takao |  | BNL | Fab & Assy | PP6 | MP101500 | Tom Hemmick | BNL |  |  | POM02.1.02.05.04 |  |  |  | 04 |  | 01 | 5 |  |  |  |  |  |  |  |  |  |  |  |  |  |  |  |  |  |  |
| S142500 |  | Procure TPC FEE LV Power Supplies - Delivery Acceptance |  | 5d | 2021-01-25 A | 2021-06-29 | S142400 | 60% | 1d | 2021-04-07 | 2021-04-13 | 87d | 0d |  | 2021-06-29 | Material (Purchase (1st $2M) [190056 h] | 220,595.02 | S142500 | 0 | S134100 |  | S134100 | CA | Not Started | A-TEC | Sakaguchi, Takao | M3 | BNL | Fab & Assy | PP6 | MP101500 | Tom Hemmick | BNL |  | TEC | POM02.1.02.05.04 | C | 59704 | 015 | 04 |  | 01 | 5 |  | S142500 | 1.02 | 1.02A |  | 180410 ELM pred/succ per GRY | UDF_G1 | UDF_G3 |  | Delivery | 220595.017221 | 1 | FAB |  |  |  |  |  |
| S143270 |  | TPC FEE Electrical Engineering Support 1 |  | 230d | 2021-02-01 A | 2021-12-29 |  | 37% | 145d | 2021-03-01 | 2022-01-28 | 269d | 0d | start on or after 2021-02-01 | 2021-12-29 | TECH1 [1500 h] | 120,025.52 | S143200 | 0 | S134800 |  | S134800 | CA | Not Started | A-TEC | Sakaguchi, Takao | M4 | BNL | Fab & Assy | PP6 | MP101300 | Tom Hemmick | BNL |  | TEC | POM02.1.02.05.04 | C | 59704 | 020 | 04 |  | 01 | 5 |  | S143270 | 1.02 | 1.02A |  |  | UDF_G2 | UDF_G1 |  | Delivery | 175243.599177 | 1 | FAB |  |  |  |  |  |
| S143271 |  | TPC FEE Electrical Engineering Support 2 |  | 230d | 2021-02-01 A | 2021-12-29 |  | 37% | 145d | 2021-03-01 | 2022-01-28 | 269d | 0d | start on or after 2021-02-01 | 2021-12-29 | PROF3 |  | S143200 | 0 | S134800 |  | S134800 | CA | Not Started | A-TEC | Sakaguchi, Takao | M4 | BNL | Fab & Assy | PP6 | MP101300 | Tom Hemmick | BNL |  | TEC | POM02.1.02.05.04 | C | 59704 | 020 | 04 |  | 01 | 5 |  | S143271 | 1.02 | 1.02A |  |  | UDF_G2 | UDF_G1 |  | Delivery | 175243.599177 | 1 | FAB |  |  |  |  |  |
| S143250 |  | TPC Front End Electronics Protection Components |  | 105d | 2021-02-15 A | 2021-06-30 |  | 33% | 22d | 2021-03-01 | 2021-07-27 | 14d | 0d | start on or after 2020-12-01 | 2021-06-30 | Material (Purchase (1st $2M) [150000 h] | 174,102.65 | S143200 | 0 | S134800 |  | S134800 | CA | Not Started | A-TEC | Sakaguchi, Takao | M4 | BNL | Fab & Assy | PP6 | MP101300 | Tom Hemmick | BNL |  | TEC | POM02.1.02.05.04 | C | 59704 | 017 | 04 |  | 01 | 5 |  | S143250 | 1.02 | 1.02A |  |  | UDF_G2 | UDF_G1 |  | Delivery | 175243.599177 | 1 | FAB |  |  |  |  |  |
| S136300 |  | Procure TPC FEE Cooling System - Contract Award(s) | milestone | 0d | 2021-02-25 A | 2021-02-25 A | S136200, S135600, S135700 | 100% |  | 2021-03-16 | 2021-03-16 |  |  |  |  |  |  | S136300 | 0 | S131100 |  | S131100 | NOCA | Not Started | A-TEC | Sakaguchi, Takao |  | BNL | Procurement | PP5 | MP202000 | Tom Hemmick | BNL | TPC FEE Pre-pro proto |  | POM02.1.02.05.04 |  |  | 003 | 04 |  | 01 | 3 |  |  |  |  |  | 180420 ELM pred/succ per GRY; | UDF_G1 | UDF_G3 | L5 | Contract Award |  |  |  |  |  |  |  |  |
| S136400 |  | Procure TPC FEE Cooling System - Contract/PO - Leadtime |  | 60d | 2021-02-26 A | 2021-03-31 A | S136300 SS, OBLG136310 SS | 100% |  | 2021-03-16 | 2021-06-08 |  |  |  |  |  |  | S136400 | 0 | S131200 |  | S131200 | NOCA | Not Started |  | Sakaguchi, Takao |  | BNL | Fab & Assy | PP6 | MP202000 | Tom Hemmick | BNL | TPC FEE Pre-pro proto |  | POM02.1.02.05.04 |  |  | 003 | 04 |  | 01 | 5 |  |  |  |  |  |  |  |  |  |  |  |  |  |  |  |  |  |  |
| S136500 |  | Procure TPC FEE Cooling System - Delivery Acceptance |  | 5d | 2021-03-15 A | 2021-07-06 | S136400 | 18% | 5d | 2021-06-09 | 2021-06-15 | 145d | 0d |  | 2021-06-15 | Material (Purchase (1st $2M) [60155 h] | 69,820.96 | S136500 | 0 | S131300 |  | S131300 | CA | Not Started | A-TEC | Sakaguchi, Takao | M5 | BNL | Fab & Assy | PP6 | MP202000 | Tom Hemmick | BNL | TPC FEE Pre-pro proto | OPC | POM02.1.02.05.04 | C | 59704 | 015 | 04 |  | 01 | 5 |  | S136500 | 1.02 | 1.02A |  |  | UDF_G1 | UDF_G3 |  | Delivery | 69820.964668 | 1 | FAB | MP6LA | OPC000800 |  |  |  |
| S141500 |  | Procure TPC FEE Production Components, Phase 1 (Optical Transceiver Components) - Delivery Acceptance |  | 5d | 2021-03-15 A | 2021-08-06 | S141400 | 33% | 5d | 2021-05-24 | 2021-05-28 | 4d | 0d | start on or after 2021-01-04 | 2021-06-07 | Material (Purchase (1st $2M) [29663 h] | 34,429.38 | S141500 | 0 | S133400 |  | S133400 | CA | Not Started | A-TEC | Sakaguchi, Takao | M3 | BNL | Fab & Assy | PP6 | MP101400 | Tom Hemmick | BNL |  | TEC | POM02.1.02.05.04 | C | 59704 | 015 | 04 |  | 01 | 5 |  | S141500 | 1.02 | 1.02A |  | 180410 ELM pred/succ per GRY | UDF_G1 | UDF_G1 |  | Delivery | 34429.378688 | 1 | FAB |  |  |  |  |  |
| S142900 |  | Procure TPC FEE Production Boards & Assembly - Vendor Selection |  | 20d | 2021-04-12 A | 2021-04-30 A | S142800 | 100% |  | 2021-05-28 | 2021-06-25 |  |  |  |  |  |  | S142900 | 0 | S134500 |  | S134500 | NOCA | Not Started |  | Sakaguchi, Takao |  | BNL | Procurement | PP4 | MP101300 | Tom Hemmick | BNL |  |  | POM02.1.02.05.04 |  |  |  | 04 |  | 01 | 3 |  |  |  |  |  |  |  |  |  |  |  |  |  |  |  |  |  |  |
| S143000 |  | Procure TPC FEE Production Boards & Assembly - Contract Award(s) | milestone | 0d | 2021-04-30 A | 2021-04-30 A | S142900, S140800, S101000, S141500, S137700, S141800, S140500 | 100% |  | 2021-07-13 | 2021-07-13 |  |  |  |  |  |  | S143000 | 0 | S134600 |  | S134600 | NOCA | Not Started | A-TEC | Sakaguchi, Takao |  | BNL | Procurement | PP5 | MP101300 | Tom Hemmick | BNL |  |  | POM02.1.02.05.04 |  |  |  | 04 |  | 01 | 3 |  |  |  |  |  | 180420 ELM pred/succ per GRY; 180223 ELM change pred per GY | UDF_G2 | UDF_G1 | L5 | Contract Award |  |  |  |  |  |  |  |  |
| S143100 |  | Procure TPC FEE Production Boards & Assembly - Contract/PO - Leadtime |  | 55d | 2021-04-30 A | 2021-09-28 | S143000 SS, OBLG143010 SS | 10% | 36d | 2021-07-13 | 2021-09-28 | 4d | 0d |  | 2021-09-28 |  |  | S143100 | 0 | S134700 |  | S134700 | NOCA | Not Started |  | Sakaguchi, Takao |  | BNL | Fab & Assy | PP6 | MP101300 | Tom Hemmick | BNL |  |  | POM02.1.02.05.04 |  |  |  | 04 |  | 01 | 5 |  |  |  |  |  |  |  |  |  |  |  |  |  |  |  |  |  |  |
| OBLG143010 |  | Procure TPC FEE Production Boards & Assembly - Obligation |  | 1d | 2021-05-26 A | 2021-05-27 A | S142900, S140800, S101000, S141500, S137700, S141800 | 100% |  | 2021-08-09 | 2021-08-09 |  |  |  |  | Obligation Resource [175244 h] | 175,243.63 | S143000 | 0 | S134600 |  | S134600 |  | Not Started | A-TEC | Sakaguchi, Takao |  | BNL | Procurement | PP5 | MP101300 | Tom Hemmick | BNL |  |  | POM02.1.02.05.04 |  |  |  | 04 |  |  |  |  |  |  |  |  | 180420 ELM pred/succ per GRY; 180223 ELM change pred per GY |  |  | L5 |  |  |  | OBLG |  |  |  |  |  |
| OBLG141310 |  | Procure TPC FEE Production Components, Phase 1 (Optical Transceiver Components) - Obligation |  | 1d | 2021-05-27 A | 2021-05-28 A | S141200, S101000, S140700, S140701 | 100% |  | 2021-07-02 | 2021-07-02 |  |  |  |  | Obligation Resource [34429.4 h] | 34,429.38 | S141300 | 0 | S133200 |  | S133200 |  | Not Started | A-TEC | Sakaguchi, Takao |  | BNL | Procurement | PP5 | MP101400 | Tom Hemmick | BNL |  |  | POM02.1.02.05.04 |  |  |  | 04 |  |  |  |  |  |  |  |  | 180420 ELM pred/succ per GRY; |  |  | L5 |  |  |  | OBLG |  |  |  |  |  |
| OBLG141610 |  | Procure TPC FEE Production Components, Phase 2 (All except Optical and SAMPA) - Obligation |  | 1d | 2021-05-27 A | 2021-05-28 A | S141200, S101000, S140700, S140701 | 100% |  | 2021-07-02 | 2021-07-02 |  |  |  |  | Obligation Resource [309548 h] | 309,547.59 | S141600 | 0 | S133200 |  | S277593884 |  | Not Started | A-TEC | Sakaguchi, Takao |  | BNL | Procurement | PP5 | MP101420 | Tom Hemmick | BNL |  |  | POM02.1.02.05.04 |  |  |  | 04 |  |  |  |  |  |  |  |  | 180420 ELM pred/succ per GRY; |  |  | L5 |  |  |  | OBLG |  |  |  |  |  |
| OBLG136310 |  | Procure TPC FEE Cooling System - Obligation |  | 1d | 2021-06-29 | 2021-06-29 | S136200, S135600, S135700 |  |  |  |  | 145d | 0d |  |  | Obligation Resource [68451.9 h] | 68,451.93 | S136300 | 0 | S131100 |  | S131100 |  | Not Started | A-TEC | Sakaguchi, Takao |  | BNL | Procurement | PP5 | MP202000 | Tom Hemmick | BNL | TPC FEE Pre-pro proto |  | POM02.1.02.05.04 |  |  | 003 | 04 |  |  |  |  |  |  |  |  | 180420 ELM pred/succ per GRY; |  |  | L5 |  |  |  | OBLG |  |  |  |  |  |
| OBLG142310 |  | Procure TPC FEE LV Power Supplies - Obligation |  | 1d | 2021-06-29 | 2021-06-29 | S142200, S101000 |  |  |  |  | 87d | 0d |  |  | Obligation Resource [216270 h] | 216,269.63 | S142300 | 0 | S133900 |  | S133900 |  | Not Started | A-TEC | Sakaguchi, Takao |  | BNL | Procurement | PP5 | MP101500 | Tom Hemmick | BNL |  |  | POM02.1.02.05.04 |  |  |  | 04 |  |  |  |  |  |  |  |  |  |  |  | L5 |  |  |  | OBLG |  |  |  |  |  |
| S141300 |  | Procure TPC FEE Production Components, Phase 1 (Optical Transceiver Components) - Contract Award(s) | milestone | 0d | 2021-07-02 | 2021-07-02 | S141200, S101000, S140700, S140701 |  |  |  |  | 4d | 0d |  |  |  |  | S141300 | 0 | S133200 |  | S133200 | NOCA | Not Started | A-TEC | Sakaguchi, Takao |  | BNL | Procurement | PP5 | MP101400 | Tom Hemmick | BNL |  |  | POM02.1.02.05.04 |  |  |  | 04 |  | 01 | 3 |  |  |  |  |  | 180420 ELM pred/succ per GRY; | UDF_G2 | UDF_G1 | L5 | Contract Award |  |  |  |  |  |  |  |  |
| S141400 |  | Procure TPC FEE Production Components, Phase 1 (Optical Transceiver Components) - Leadtime |  | 20d | 2021-07-02 | 2021-07-30 | S141300 SS, OBLG141310 SS |  |  |  |  | 4d | 0d |  |  |  |  | S141400 | 0 | S133300 |  | S133300 | NOCA | Not Started |  | Sakaguchi, Takao |  | BNL | Fab & Assy | PP6 | MP101400 | Tom Hemmick | BNL |  |  | POM02.1.02.05.04 |  |  |  | 04 |  | 01 | 5 |  |  |  |  |  |  |  |  |  |  |  |  |  |  |  |  |  |  |
| S143200 |  | Procure TPC FEE Production Boards & Assembly - Delivery Acceptance |  | 5d | 2021-09-29 | 2021-10-05 | S143100 |  |  |  |  | 4d | 0d |  |  | Material (Purchase (1st $2M) [150983 h] | 177,346.52 | S143200 | 0 | S134800 |  | S134800 | CA | Not Started | A-TEC | Sakaguchi, Takao | M4 | BNL | Fab & Assy | PP6 | MP101300 | Tom Hemmick | BNL |  | TEC | POM02.1.02.05.04 | C | 59704 | 003,004 | 04 |  | 01 | 5 |  | S143200 | 1.02 | 1.02A |  |  | UDF_G1 | UDF_G1 |  | Delivery | 175243.599177 | 1 | FAB |  |  |  |  |  |
| S143300 |  | Perform QA Testing on TPC FEE |  | 69d | 2021-10-06 | 2022-01-19 | S143200 |  |  |  |  | 4d | 0d |  |  | PROF4 PO E [56 h]; SCI3 SBU - Unpaid [56 h]; STUDENT SBU - Unpaid [280 h]; TECH3 PO E [168 h]; SCI3 PO [323 h] | 88,064.77 | S143300 | 0 | S134900 |  | S134900 | CA | Not Started | B_T | Sakaguchi, Takao | L5 | BNL | Test_System |  |  | Tom Hemmick | BNL |  | null | POM02.1.02.05.04 | C | 16709 |  | 04 |  | 01 | 7 | Yes | S143300 | 1.02 | 1.02B |  | 180423 ELM rsrc per GRY; 180410 ELM pred/succ per GRY |  |  |  |  |  |  |  |  |  |  |  |  |
| S143400 |  | TPC FEE Production Complete | milestone | 0d | 2022-01-19 | 2022-01-19 | S143300, S136500 |  |  |  |  | 12d | 8d |  |  |  |  | S143400 | 0 | S135000 |  | S135000 | NOCA | Not Started |  | Sakaguchi, Takao |  | BNL | Fab & Assy |  |  | Tom Hemmick | BNL |  |  | POM02.1.02.05.04 |  |  |  | 04 |  | 01 | 5 |  |  |  |  |  |  | UDF_G2 | UDF_G1 | L2 |  |  |  |  |  |  | 2021-10-29 | -53 | PMP_1x |

Notes:
- S135800: BNL_UDF_Status Comments: 190315 ELM change WBS per GRY / BNL_UDF_Old Activity Name 181221: Design TPC FEE Cooling System
- S135802: BNL_UDF_Status Comments: 190315 ELM change WBS per GRY / BNL_UDF_Old Activity Name 181221: Design TPC FEE Cooling System
- S140900: BNL_UDF_Old Activity Name 181221: Procure TPC FEE Production Components - Provide Requirements to Procurement
- S141000: BNL_UDF_Old Activity Name 181221: Procure TPC FEE Production Components - Prepare & Send Solicitation
- S141100: BNL_UDF_Old Activity Name 181221: Procure TPC FEE Production Components - Vendor Responses
- S142600: BNL_UDF_Old Activity Name 181221: Procure TPC FEE Production Boards & Assembly - Provide Requirements to Procurement
- S142700: BNL_UDF_Old Activity Name 181221: Procure TPC FEE Production Boards & Assembly - Prepare & Send Solicitation
- S142800: BNL_UDF_Old Activity Name 181221: Procure TPC FEE Production Boards & Assembly - Vendor Responses
- S141900: BNL_UDF_Old Activity Name 181221: Procure TPC FEE LV power supplies - Provide Requirements to Procurement
- S142000: BNL_UDF_Old Activity Name 181221: Procure TPC FEE LV Power Supplies - Prepare & Send Solicitation
- S141200: BNL_UDF_Old Activity Name 181221: Procure TPC FEE Production Components - Vendor Selection
- S142100: BNL_UDF_Old Activity Name 181221: Procure TPC FEE LV Power Supplies - Vendor Responses
- S142200: BNL_UDF_Old Activity Name 181221: Procure TPC FEE LV Power Supplies - Vendor Selection
- S141600: BNL_UDF_Old Activity Name 181221: Procure TPC FEE Production Components - Contract Award(s) - Phase 2 - All except Optical and SAMPA
- S141700: BNL_UDF_Old Activity Name 181221: Procure TPC FEE Production Components - Contract/PO - Leadtime - Phase 2 - All except Optical and SAMPA
- S141800: BNL_UDF_Status Comments: 190322 ELM BNL Units; 190315 ELM BNL Units per TS / BNL_UDF_Old Activity Name 181221: Procure TPC FEE Production Components - Delivery Acceptance - Phase 2 - All except Optical and SAMPA
- S135900: BNL_UDF_Status Comments: 190315 ELM change WBS, pred/succ per GRY / BNL_UDF_Old Activity Name 181221: Procure TPC FEE Cooling System - Provide Requirements to Procurement
- S136000: BNL_UDF_Status Comments: 190315 ELM change WBS, remove labor per GRY / BNL_UDF_Old Activity Name 181221: Procure TPC FEE Cooling System - Prepare & Send Solicitation
- S136100: BNL_UDF_Status Comments: 190315 ELM change WBS, remove labor per GRY / BNL_UDF_Old Activity Name 181221: Procure TPC FEE Cooling System - Vendor Responses
- S136200: BNL_UDF_Status Comments: 190315 ELM change WBS, remove labor per GRY / BNL_UDF_Old Activity Name 181221: Procure TPC FEE Cooling System - Vendor Selection
- S142300: BNL_UDF_Old Activity Name 181221: Procure TPC FEE LV Power Supplies - Contract Award(s)
- S142400: BNL_UDF_Old Activity Name 181221: Procure TPC FEE LV Power Supplies - Contract/PO - Leadtime
- S142500: BNL_UDF_Status Comments: 190322 ELM BNL Units; 190315 ELM BNL Units per TS / BNL_UDF_Old Activity Name 181221: Procure TPC FEE LV Power Supplies - Delivery Acceptance
- S143270: BNL_UDF_Status Comments: 190416 ELM BNL Units per GRY; 190322 ELM BNL Units; 190315 ELM BNL Units per TS / BNL_UDF_Old Activity Name 181221: Procure TPC FEE Production Boards & Assembly - Delivery Acceptance
- S143271: BNL_UDF_Status Comments: 190416 ELM BNL Units per GRY; 190322 ELM BNL Units; 190315 ELM BNL Units per TS / BNL_UDF_Old Activity Name 181221: Procure TPC FEE Production Boards & Assembly - Delivery Acceptance
- S143250: BNL_UDF_Status Comments: 190416 ELM BNL Units per GRY; 190322 ELM BNL Units; 190315 ELM BNL Units per TS / BNL_UDF_Old Activity Name 181221: Procure TPC FEE Production Boards & Assembly - Delivery Acceptance
- S136300: BNL_UDF_Status Comments: 190315 ELM change WBS per GRY / BNL_UDF_Old Activity Name 181221: Procure TPC FEE Cooling System - Contract Award(s)
- S136400: BNL_UDF_Status Comments: 190315 ELM change WBS per GRY / BNL_UDF_Old Activity Name 181221: Procure TPC FEE Cooling System - Contract/PO - Leadtime
- S136500: BNL_UDF_Status Comments: 190315 ELM change WBS, BNLU per GRY / BNL_UDF_Old Activity Name 181221: Procure TPC FEE Cooling System - Delivery Acceptance
- S141500: BNL_UDF_Status Comments: 190322 ELM BNL Units; 190315 ELM BNL Units per TS / BNL_UDF_Old Activity Name 181221: Procure TPC FEE Production Components - Delivery Acceptance - Phase 1 - Optical Transceiver Components
- S142900: BNL_UDF_Old Activity Name 181221: Procure TPC FEE Production Boards & Assembly - Vendor Selection
- S143000: BNL_UDF_Old Activity Name 181221: Procure TPC FEE Production Boards & Assembly - Contract Award(s)
- S143100: BNL_UDF_Old Activity Name 181221: Procure TPC FEE Production Boards & Assembly - Contract/PO - Leadtime
- OBLG143010: BNL_UDF_Old Activity Name 181221: Procure TPC FEE Production Boards & Assembly - Contract Award(s)
- OBLG141310: BNL_UDF_Old Activity Name 181221: Procure TPC FEE Production Components - Contract Award(s) - Phase 1 - Optical Transceiver Components
- OBLG141610: BNL_UDF_Old Activity Name 181221: Procure TPC FEE Production Components - Contract Award(s) - Phase 2 - All except Optical and SAMPA
- OBLG136310: BNL_UDF_Status Comments: 190315 ELM change WBS, BNLU per GRY / BNL_UDF_Old Activity Name 181221: Procure TPC FEE Cooling System - Contract Award(s)
- OBLG142310: BNL_UDF_Old Activity Name 181221: Procure TPC FEE LV Power Supplies - Contract Award(s)
- S141300: BNL_UDF_Old Activity Name 181221: Procure TPC FEE Production Components - Contract Award(s) - Phase 1 - Optical Transceiver Components
- S141400: BNL_UDF_Old Activity Name 181221: Procure TPC FEE Production Components - Contract/PO - Leadtime - Phase 1 - Optical Transceiver Components
- S143200: BNL_UDF_Status Comments: 190416 ELM BNL Units per GRY; 190322 ELM BNL Units; 190315 ELM BNL Units per TS / BNL_UDF_Old Activity Name 181221: Procure TPC FEE Production Boards & Assembly - Delivery Acceptance
- S143300: BNL_UDF_Old Activity Name 181221: Perform QA Testing on TPC FEE
- S143400: BNL_UDF_Old Activity Name 181221: TPC FEE Production Complete

| ID | WBS | Activity | Type | Duration | Start | Finish | Predecessors | Complete | Planned start | Planned finish | Constraint | Resources | Cost | BNL_UDF_Temp Text 01 | BNL_UDF_Adhoc Comments | BNL_UDF_Percent Complete | BNL_UDF_OPC TEC (deprecated) | BNL_UDF_Old Activity ID 181221 | RG Check | BNL_Activity Status | BNL_Estimator | BNL_Cost Basis | BNL_Location | BNL_EDIA | BNL_CAM | BNL_Institution | BNL_R&D FY18-19 | BNL_OPC TEC (deprecated) | BNL_WBS | BNL_EVT | BNL_WBS_Hierarchical | Completed | PMP Summary Part1 | PMP Summary Part2 | BNL_Milestone Level | BNL_PCR ID | BNL_Proc Sig Phase | BNL_Proc Sig | BNL_DOE OPC | Cost = Awarded Proc or Mgmt | BNL_Fund Source | BNL_UDF_Temp Date 01 | BNL_Account Number | Additional EVT documentation required | BNL_Cobra WP | Indicator - Procurement | Indicator - Float | BNL_Master Control Account | BNL_Obligation | BNL_Cobra Control Account | Temp | Target Milestone Date | Variance | PMP Milestones |
| --- | --- | --- | --- | --- | --- | --- | --- | --- | --- | --- | --- | --- | --- | --- | --- | --- | --- | --- | --- | --- | --- | --- | --- | --- | --- | --- | --- | --- | --- | --- | --- | --- | --- | --- | --- | --- | --- | --- | --- | --- | --- | --- | --- | --- | --- | --- | --- | --- | --- | --- | --- | --- | --- | --- |
|  | 06 | **TPC DAM** |  |  | 2017-02-01 | 2022-02-02 |  |  |  |  |  |  |  |  |  |  |  |  |  |  |  |  |  |  |  |  |  |  |  |  |  |  |  |  |  |  |  |  |  |  |  |  |  |  |  |  |  |  |  |  |  |  |  |  |
|  | 01 | **TPC DAM Evaluation -- FELIX 1.5** |  |  | 2017-02-01 | 2017-12-12 |  |  |  |  |  |  |  |  |  |  |  |  |  |  |  |  |  |  |  |  |  |  |  |  |  |  |  |  |  |  |  |  |  |  |  |  |  |  |  |  |  |  |  |  |  |  |  |  |
| S143500 |  | Write Design Spec for TPC DAM prototype v1 |  | 22d | 2017-02-01 A | 2017-03-03 A | S100090 SS | 100% |  |  |  |  |  | S143500 | 180410 ELM pred/succ per GRY | 100 | S135100 | S135100 | NOCA | Completed | Huang, Jin | M4 | BNL | Design | Tom Hemmick | BNL | TPC DAM v1 | null | POM02.1.02.06.01 | C | 01 | yes | 1 | 1 |  |  |  |  |  |  |  |  |  |  |  |  |  |  |  |  |  |  |  |  |
| S143600 |  | Develop TPC DAM prototype v1 Test Stand Labor |  | 195d | 2017-03-06 A | 2017-12-12 A | S143500 | 100% |  |  |  |  |  | S143600 |  | 100 | S135200 | S135200 | NOCA | Completed | Huang, Jin | M4 | BNL | Procurement | Tom Hemmick | BNL | TPC DAM v1 | null | POM02.1.02.06.01 | C | 01 | yes | 01 | 2 |  |  |  |  |  |  |  |  |  |  |  |  |  |  |  |  |  |  |  |  |
| S143700 |  | Develop TPC DAM prototype v1 Test Stand M&S |  | 40d | 2017-03-06 A | 2017-04-28 A | S143500 | 100% |  |  |  |  |  | S143700 |  | 100 | S135300 | S135300 | NOCA | Completed | Huang, Jin | M4 | BNL | Fab & Assy | Tom Hemmick | BNL | TPC DAM v1 | OPC | POM02.1.02.06.01 | C | 01 | yes | 01 | 4 |  |  |  |  |  |  |  |  |  |  |  |  |  |  |  |  |  |  |  |  |
| S143800 |  | Measure TPC DAM prototype v1 Throughput |  | 155d | 2017-05-01 A | 2017-12-12 A | S143600 FF, S143700 | 100% |  |  |  |  |  | S143800 |  | 100 | S135400 | S135400 | NOCA | Completed | Huang, Jin | M4 | BNL | Test_System | Tom Hemmick | BNL | TPC DAM v1 | null | POM02.1.02.06.01 | C | 01 | yes | 01 | 4 |  |  |  |  |  |  |  |  |  |  |  |  |  |  |  |  |  |  |  |  |
| S143900 |  | Preliminary Design Review - TPC DAM | milestone | 0d | 2017-12-12 A | 2017-12-12 A | S143800 | 100% |  |  |  |  |  | S143900 |  | 100 | S135500 | S135500 | NOCA | Completed | Huang, Jin |  | BNL | Design | Tom Hemmick | BNL | TPC DAM v1 |  | POM02.1.02.06.01 |  | 01 | yes | 1 | 1 | L5 | 004 |  |  |  |  |  |  |  |  |  |  |  |  |  |  |  |  |  |  |
|  | 02 | **TPC DAM Evaluation -- FELIX 2.0** |  |  | 2017-12-28 | 2020-06-30 |  |  |  |  |  |  |  |  |  |  |  |  |  |  |  |  |  |  |  |  |  |  |  |  |  |  |  |  |  |  |  |  |  |  |  |  |  |  |  |  |  |  |  |  |  |  |  |  |
| S144000 |  | Procure TPC DAM Felix 2.0 Boards Evaluation - Provide Requirements to Procurement |  | 15d | 2017-12-28 A | 2018-01-19 A | S143900 FS+10d | 100% |  |  |  |  |  | S144000 |  | 100 | S135600 | S135600 | NOCA | Completed | Huang, Jin | M4 | BNL | Procurement | Tom Hemmick | BNL | TPC DAM v2 | null | POM02.1.02.06.02 | C | 02 | yes | 01 | 2 |  |  | PP1 | MP101600 | OPC001000 | Yes |  |  |  |  |  |  |  |  |  |  |  |  |  |  |
| S144100 |  | Procure TPC DAM Felix 2.0 Boards Evaluation - Prepare & Send Solicitation |  | 21d | 2018-01-20 A | 2018-02-20 A | S144000 | 100% | 2018-01-22 | 2018-02-20 |  |  |  | S144100 |  | 100 | S135700 | S135700 | NOCA | Completed | Huang, Jin |  | BNL | Procurement | Tom Hemmick | BNL | TPC DAM v2 |  | POM02.1.02.06.02 |  | 02 | yes | 01 | 2 |  |  | PP2 | MP101600 | OPC001000 | Yes |  |  |  |  |  |  |  |  |  |  |  |  |  |  |
| S144200 |  | Procure TPC DAM Felix 2.0 Boards Evaluation - Vendor Responses |  | 9d | 2018-02-21 A | 2018-03-05 A | S144100 | 100% |  |  |  |  |  | S144200 |  | 100 | S135800 | S135800 | NOCA | Completed | Huang, Jin |  | BNL | Procurement | Tom Hemmick | BNL | TPC DAM v2 |  | POM02.1.02.06.02 |  | 02 | yes | 01 | 2 |  |  | PP3 | MP101600 | OPC001000 | Yes |  |  |  |  |  |  |  |  |  |  |  |  |  |  |
| S144300 |  | Procure TPC DAM Felix 2.0 Boards Evaluation - Vendor Selection |  | 15d | 2018-03-06 A | 2018-03-26 A | S144200 | 100% |  |  |  |  |  | S144300 |  | 100 | S135900 | S135900 | NOCA | Completed | Huang, Jin |  | BNL | Procurement | Tom Hemmick | BNL | TPC DAM v2 |  | POM02.1.02.06.02 |  | 02 | yes | 01 | 2 |  |  | PP4 | MP101600 | OPC001000 | Yes |  |  |  |  |  |  |  |  |  |  |  |  |  |  |
| S144400 |  | Procure TPC DAM Felix 2.0 Boards Evaluation - Contract Award(s) | milestone | 0d | 2018-03-26 A | 2018-03-26 A | S144300 | 100% |  |  |  |  |  | S144400 |  | 100 | S136000 | S136000 | NOCA | Completed | Huang, Jin |  | BNL | Procurement | Tom Hemmick | BNL | TPC DAM v2 |  | POM02.1.02.06.02 |  | 02 | yes | 01 | 2 | L5 |  | PP5 | MP101600 | OPC001000 | Yes | A-OPC |  |  |  |  |  |  |  |  |  |  |  |  |  |
| S144500 |  | Procure TPC DAM Felix 2.0 Boards Evaluation - Contract/PO - Leadtime |  | 112d | 2018-03-27 A | 2018-08-31 A | S144400 SS | 100% |  |  |  |  |  | S144500 |  | 100 | S136100 | S136100 | NOCA | Completed | Huang, Jin |  | BNL | Fab & Assy | Tom Hemmick | BNL | TPC DAM v2 |  | POM02.1.02.06.02 |  | 02 | yes | 01 | 4 |  |  | PP6 | MP101600 | OPC001000 | Yes |  |  |  |  |  |  |  |  |  |  |  |  |  |  |
| S144600 |  | Procure TPC DAM Felix 2.0 Boards Evaluation - Delivery Acceptance |  | 2d | 2018-09-01 A | 2018-09-05 A | S144500 | 100% | 2018-09-04 | 2018-09-05 |  |  |  | S144600 | 180410 ELM pred/succ per GRY | 100 | S136200 | S136200 | NOCA | Completed | Huang, Jin | M4 | BNL | Fab & Assy | Tom Hemmick | BNL | TPC DAM v2 | OPC | POM02.1.02.06.02 | C | 02 | yes | 01 | 4 |  |  | PP6 | MP101600 | OPC001000 | Yes |  |  |  |  |  |  |  |  |  |  |  |  |  |  |
| S144700 |  | Develop TPC DAM FPGA Algorithm - FY18 |  | 17d | 2018-09-06 A | 2018-09-28 A | S144000 | 100% |  |  |  |  |  | S144700 | 180423 ELM rsrc per GRY | 100 | S136300 | S136300 | NOCA | Completed | Huang, Jin | L5 | BNL | Programming | Tom Hemmick | BNL | TPC DAM v2 | null | POM02.1.02.06.02 | C | 02 | yes | 01 | 6 |  |  |  |  |  |  |  |  |  |  |  |  |  |  |  |  |  |  |  |  |
| S144800 |  | Procure TPC DAM Felix 2.0 Boards Throughput - Prepare & Send Solicitation |  | 166d | 2018-10-01 A | 2019-06-03 A | S144700 | 100% | 2018-10-01 | 2019-05-31 |  |  |  | S144800 |  | 100 | S136800 | S136310 | NOCA | Completed | Huang, Jin |  | BNL | Procurement | Tom Hemmick | BNL | TPC DAM v2 |  | POM02.1.02.06.02 |  | 02 |  | 01 | 2 |  |  | PP2 | MP101790 | OPC001100 |  |  |  |  |  |  |  |  |  |  |  |  |  |  |  |
| S146200 |  | Develop TPC DAM FPGA Algorithm - Round 1 |  | 105d | 2019-01-02 A | 2019-05-31 A | S144000, S144700 | 100% |  |  |  |  |  | S146200 | 180423 ELM rsrc per GRY | 25 | S136300 | S136350 | NOCA | Completed | Huang, Jin | L5 | BNL | Programming | Tom Hemmick | BNL | TPC DAM v2 | null | POM02.1.02.06.02 | C | 02 | yes | 01 | 6 |  |  |  |  |  |  | B_T | 2019-08-15 | 16709 | Yes |  |  |  |  |  |  |  |  |  |  |
| S144900 |  | Procure TPC DAM Felix 2.0 Boards Throughput - Vendor Responses |  | 10d | 2019-02-01 A | 2019-02-14 A | S144800 | 100% |  |  |  |  |  | S144900 |  | 100 | S136900 | S136315 | NOCA | Completed | Huang, Jin |  | BNL | Procurement | Tom Hemmick | BNL | TPC DAM v2 |  | POM02.1.02.06.02 |  | 02 | yes | 01 | 2 |  |  | PP3 | MP101790 | OPC001100 |  |  |  |  |  |  |  |  |  |  |  |  |  |  |  |
| S145000 |  | Procure TPC DAM Felix 2.0 Boards Throughput - Vendor Selection |  | 20d | 2019-02-15 A | 2019-03-15 A | S144900 | 100% |  |  |  |  |  | S145000 |  | 80 | S137000 | S136320 | NOCA | Completed | Huang, Jin |  | BNL | Procurement | Tom Hemmick | BNL | TPC DAM v2 |  | POM02.1.02.06.02 |  | 02 | yes | 01 | 2 |  |  | PP4 | MP101790 | OPC001100 |  |  | 2019-03-15 |  |  |  |  |  |  |  |  |  |  |  |  |
| S145600 |  | Procure TPC DAM Felix 2.0 Boards Throughput - Contract/PO - Leadtime |  | 75d | 2019-03-18 A | 2019-08-01 A | S145100 SS, OBLG145110 SS | 100% | 2019-03-18 | 2019-07-01 |  |  |  | S145600 |  | 0 | S137200 | S136330 | NOCA | Completed | Huang, Jin |  | BNL | Fab & Assy | Tom Hemmick | BNL | TPC DAM v2 |  | POM02.1.02.06.02 |  | 02 |  | 01 | 4 |  |  | PP6 | MP101790 | OPC001100 |  |  |  |  |  |  |  |  |  |  |  |  |  |  |  |
| S146400 |  | Measure Throughput of FELIX 2.0 for TPC DAM |  | 44d | 2019-04-01 A | 2019-05-31 A | S146300 FF, S144600, S145750, S146201 FF, S146202 FF | 100% |  |  |  |  |  | S146400 | 180423 ELM rsrc per GRY; 180410 ELM pred/succ per GRY | 0 | S136500 | S136500 | NOCA | Completed | Huang, Jin | L4 | BNL | Test_System | Tom Hemmick | BNL | TPC DAM v2 | null | POM02.1.02.06.02 | C | 02 | yes | 01 | 7 |  |  |  |  |  |  | B |  | 16709 | Yes |  |  |  |  |  |  |  |  |  |  |
| S145100 |  | Procure TPC DAM Felix 2.0 Boards - Optical - Contract Award(s) | milestone | 0d | 2019-08-01 A | 2019-08-01 A | S145000, S146202 SS | 100% |  |  | start on or after 2019-08-01 |  |  | S145100 |  | 0 | S137100 | S136325 | NOCA | Completed | Huang, Jin |  | BNL | Procurement | Tom Hemmick | BNL | TPC DAM v2 |  | POM02.1.02.06.02 |  | 02 |  | 01 | 2 | L5 | 005 | PP5 | MP101790 | OPC001100 |  | A-OPC |  |  |  |  |  |  |  |  |  |  |  |  |  |
| S145700 |  | Procure TPC DAM Felix 2.0 Boards Throughput - Delivery Acceptance |  | 5d | 2019-08-01 A | 2020-02-28 A | S145600 | 100% | 2019-08-01 | 2019-08-07 |  | Material (Purchase (1st $2M) [73524 h] | 81,116.46 | S145700 | 180419 ELM split activity and M&S into OPC/TEC | 0 | S137300 | S136335 | CA | In Progress | Huang, Jin | M4 | BNL | Fab & Assy | Tom Hemmick | BNL | TPC DAM v2 | OPC | POM02.1.02.06.02 | C | 02 |  | 01 | 5 |  | 003 | PP6 | MP101790 | OPC001100 |  | A-OPC |  | 16701 |  | S145700 | UDF_G1 | UDF_G3 | 1.02 | FAB | 1.02A |  |  |  |  |
| S145750 |  | Procure Full Set of Data Fibers for Design Validation - M&S |  | 10d | 2019-08-01 A | 2019-08-14 A | S145100 SS | 100% |  |  | start on or after 2019-08-01 | Material (Purchase (1st $2M) [2876 h] | 3,172.99 | S145700 | 180419 ELM split activity and M&S into OPC/TEC | 0 | S137300 | S136335 | CA | Completed | Huang, Jin | M4 | BNL | Fab & Assy | Tom Hemmick | BNL | TPC DAM v2 | OPC | POM02.1.02.06.02 | F | 02 |  | 01 | 4 |  | 003,004 |  |  | OPC001100 |  | A-OPC |  | 16701 |  | S145750 | UDF_G2 |  | 1.02 |  | 1.02A |  |  |  |  |
| S146202 |  | Develop TPC DAM FPGA Algorithm - Round 1 Split |  | 22d | 2019-08-01 A | 2019-08-30 A | S146200 | 100% |  |  | start on or after 2019-08-01 | SCI3 SBU - Unpaid [42 h]; PROF4 PO E [427 h]; SCI3 PO [385 h]; TECH3 PO D [259 h]; TECH3 PO E [259 h] | 182,774.87 | S146200 | 180423 ELM rsrc per GRY | 25 | S136300 | S136350 | CA | Completed | Huang, Jin | L5 | BNL | Programming | Tom Hemmick | BNL | TPC DAM v2 | null | POM02.1.02.06.02 | C | 02 |  | 01 | 6 |  |  |  |  |  |  | B_T | 2019-08-15 | 16709 | Yes | S146202 |  |  | 1.02 |  | 1.02B |  |  |  |  |
| S146300 |  | Miscellaneous Parts for TPC DAM FPGA Algorithm Development - Round 1 |  | 22d | 2019-08-01 A | 2019-08-30 A | S146202 SS | 100% |  |  | start on or after 2019-08-01 | Material (Purchase (1st $2M) [2563 h] | 2,827.67 | S146300 |  | 0 | S136400 | S136400 | CA | Completed | Huang, Jin | M4 | BNL | Fab & Assy | Tom Hemmick | BNL | TPC DAM v2 | OPC | POM02.1.02.06.02 | F | 02 |  | 01 | 4 |  | 003 |  |  | OPC001000 |  | A-OPC |  | 16701 | Yes | S146300 | UDF_G3 |  | 1.02 |  | 1.02A |  |  |  |  |
| S146402 |  | Measure Throughput of FELIX 2.0 for TPC DAM Split |  | 8d | 2019-08-21 A | 2020-01-22 A | S146400 | 100% | 2019-08-21 | 2019-08-30 |  | PROF4 PO E [41 h]; SCI3 PO [85 h] | 20,064.9 | S146400 | 180423 ELM rsrc per GRY; 180410 ELM pred/succ per GRY | 0 | S136500 | S136500 | CA | In Progress | Huang, Jin | L4 | BNL | Test_System | Tom Hemmick | BNL | TPC DAM v2 | null | POM02.1.02.06.02 | C | 02 |  | 01 | 7 |  |  |  |  |  |  | B |  | 16709 | Yes | S146402 |  |  | 1.02 |  | 1.02B |  |  |  |  |
| OBLG145110 |  | Procure TPC DAM Felix 2.0 Boards Throughput (Optical) - Obligation |  | 1d | 2019-09-03 A | 2019-09-03 A | S145000, S146202 SS | 100% |  |  |  | Obligation Resource [81116 h] | 81,116 | S145100 |  | 0 | S137100 | S136325 |  | Completed | Huang, Jin |  | BNL | Procurement | Tom Hemmick | BNL | TPC DAM v2 |  | POM02.1.02.06.02 |  | 02 |  |  |  | L5 | 003 | PP5 | MP101790 | OPC001100 |  | A-OPC |  |  |  |  |  |  |  | OBLG |  |  |  |  |  |
| S146700 |  | Develop TPC DAM FPGA Algorithm - Round 2 |  | 20d | 2019-09-03 A | 2020-06-30 A | S146202 | 100% | 2019-09-03 | 2019-09-30 |  | PROF4 PO E [630 h]; SCI3 PO [210 h]; SCI3 SBU - Unpaid [44 h]; STUDENT SBU - Unpaid [210 h] | 125,164.22 | S146700 | 180423 ELM rsrc per GRY | 0 | S137400 | S137450 | CA | In Progress | Huang, Jin | L4 | BNL | Test_System | Tom Hemmick | BNL | TPC DAM v2 | null | POM02.1.02.06.02 | C | 02 |  | 01 | 7 |  |  |  |  |  |  | B_T |  | 16709 | Yes | S146700 |  |  | 1.02 |  | 1.02B | 1 |  |  |  |
| S146201 |  | Final Design Review - TPC DAM |  | 1d | 2020-01-02 A | 2020-01-02 A | S146202 | 100% |  |  | start on or after 2019-12-11 | PROF4 PO M [4 h]; SCI3 PO [4 h] | 1,277.48 | S146200 | 180423 ELM rsrc per GRY | 0 | S136300 | S136350 | CA | Not Started | Huang, Jin | L5 | BNL | Programming | Tom Hemmick | BNL | TPC DAM v2 | null | POM02.1.02.06.02 | C | 02 |  | 01 | 6 |  | 004,005 |  |  |  |  | B |  | 16709 | Yes | S146201 |  |  | 1.02 |  | 1.02B |  |  |  |  |
| S146500 |  | Production Readiness Review - TPC DAM |  | 2d | 2020-02-03 A | 2020-02-04 A | S146402 | 100% |  |  |  | PROF4 PO M [4 h]; SCI3 PO [4 h] | 1,277.48 | S146500 |  | 0 | S136600 | S136600 | CA | Not Started | Huang, Jin |  | BNL | Fab & Assy | Tom Hemmick | BNL | TPC DAM v2 |  | POM02.1.02.06.02 | C | 02 |  | 01 | 4 | L2 | 004 |  |  |  |  | B |  | 16709 |  | S146500 |  |  | 1.02 |  | 1.02B |  | 2020-02-28 | 16 | PMP_1x |

Notes:
- S143500: BNL_UDF_Old Activity Name 181221: Write Design Spec for TPC DAM prototype v1
- S143600: BNL_UDF_Old Activity Name 181221: Develop TPC DAM prototype v1 Test Stand Labor
- S143700: BNL_UDF_Old Activity Name 181221: Develop TPC DAM prototype v1 Test Stand M&S
- S143800: BNL_UDF_Old Activity Name 181221: Measure TPC DAM prototype v1 Throughput
- S143900: General Comments: 180420 GYoung: concerning / Conceptual Design Review - OK for "only" a CDR because this is a / Production item for LHC ATLAS / experiment / BNL_UDF_Status Comments: 190522 IVS new name / BNL_UDF_Old Activity Name 181221: TPC DAM pre CD-1 Conceptual Design Review
- S144000: BNL_UDF_Old Activity Name 181221: Procure TPC DAM Felix 2.0 Boards Evaluation - Provide Requirements to Procurement
- S144100: BNL_UDF_Old Activity Name 181221: Procure TPC DAM Felix 2.0 Boards Evaluation - Prepare & Send Solicitation
- S144200: BNL_UDF_Old Activity Name 181221: Procure TPC DAM Felix 2.0 Boards Evaluation - Vendor Responses
- S144300: BNL_UDF_Old Activity Name 181221: Procure TPC DAM Felix 2.0 Boards Evaluation - Vendor Selection
- S144400: BNL_UDF_Old Activity Name 181221: Procure TPC DAM Felix 2.0 Boards Evaluation - Contract Award(s)
- S144500: BNL_UDF_Old Activity Name 181221: Procure TPC DAM Felix 2.0 Boards Evaluation - Contract/PO - Leadtime
- S144600: BNL_UDF_Old Activity Name 181221: Procure TPC DAM Felix 2.0 Boards Evaluation - Delivery Acceptance
- S144700: Steps: Acceptance test; (New step) / BNL_UDF_Old Activity Name 181221: Develop TPC DAM FPGA Algorithm - FY18
- S144800: BNL_UDF_Old Activity Name 181221: Procure TPC DAM Felix 2.0 Boards Throughput - Prepare & Send Solicitation
- S146200: Steps: Acceptance test; 1st FEE link development; Full FEE link development; FEE clock distribution test; PCIe link development; Update PCIe Driver; Construct RC DAQ interface; FEE slow control development; Trigger function development; System integration; Control GUI / BNL_UDF_Old Activity Name 181221: Develop TPC DAM FPGA Algorithm - Round 1
- S144900: BNL_UDF_Old Activity Name 181221: Procure TPC DAM Felix 2.0 Boards Throughput - Vendor Responses
- S145000: BNL_UDF_Old Activity Name 181221: Procure TPC DAM Felix 2.0 Boards Throughput - Vendor Selection
- S145600: BNL_UDF_Old Activity Name 181221: Procure TPC DAM Felix 2.0 Boards Throughput - Contract/PO - Leadtime
- S146400: BNL_UDF_Old Activity Name 181221: Measure Throughput of FELIX 2.0 for TPC DAM
- S145100: BNL_UDF_Status Comments: 190607 IVS change name / BNL_UDF_Old Activity Name 181221: Procure TPC DAM Felix 2.0 Boards Throughput - Optical - Contract Award(s)
- S145700: BNL_UDF_Status Comments: 190314 ELM name, NLBUs per GRY / BNL_UDF_Old Activity Name 181221: Procure TPC DAM Felix 2.0 Boards Throughput - Delivery Acceptance (OPC) Optical
- S145750: BNL_UDF_Status Comments: 190416 ELM add per GRY / BNL_UDF_Old Activity Name 181221: Procure TPC DAM Felix 2.0 Boards Throughput - Delivery Acceptance (OPC) Optical
- S146202: Steps: Acceptance test; 1st FEE link development; Full FEE link development; FEE clock distribution test; PCIe link development; Update PCIe Driver; Construct RC DAQ interface; FEE slow control development; Trigger function development; System integration; Control GUI / BNL_UDF_Old Activity Name 181221: Develop TPC DAM FPGA Algorithm - Round 1
- S146300: BNL_UDF_Status Comments: 190314 ELM NLBUs per GRY / BNL_UDF_Old Activity Name 181221: Miscellaneous Parts for TPC DAM FPGA Algorithm Development - Round 1
- S146402: BNL_UDF_Old Activity Name 181221: Measure Throughput of FELIX 2.0 for TPC DAM
- OBLG145110: BNL_UDF_Status Comments: 190314 ELM name, NLBUs per GRY / BNL_UDF_Old Activity Name 181221: Procure TPC DAM Felix 2.0 Boards Throughput - Optical - Contract Award(s)
- S146700: BNL_UDF_Old Activity Name 181221: Develop TPC DAM FPGA Algorithm - Round 2
- S146201: Steps: Acceptance test; 1st FEE link development; Full FEE link development; FEE clock distribution test; PCIe link development; Update PCIe Driver; Construct RC DAQ interface; FEE slow control development; Trigger function development; System integration; Control GUI / BNL_UDF_Status Comments: 190607 IVS add resources, ask Jin about date; 190522 IVS new act. / BNL_UDF_Old Activity Name 181221: Develop TPC DAM FPGA Algorithm - Round 1
- S146500: BNL_UDF_Status Comments: 190522 IVS new name; 190415 ELM name per GRY / BNL_UDF_Old Activity Name 181221: TPC DAM Preproduction Readiness Review

| ID | WBS | Activity | Type | Duration | Start | Finish | Predecessors | Complete | Remaining | Planned start | Planned finish | Total float | Free float | Constraint | Expected finish | Resources | Cost | BNL_UDF_Status Comments | BNL_UDF_Temp Text 01 | BNL_UDF_Adhoc Comments | BNL_UDF_Percent Complete | BNL_UDF_OPC TEC (deprecated) | BNL_UDF_Old Activity ID 181221 | BNL_Cobra WP | RG Check | BNL_Activity Status | BNL_Fund Source | BNL_Estimator | BNL_Cost Basis | BNL_Location | BNL_EDIA | BNL_Proc Sig Phase | BNL_Proc Sig | BNL_CAM | BNL_Institution | BNL_R&D FY18-19 | BNL_DOE OPC | BNL_OPC TEC (deprecated) | BNL_WBS | BNL_EVT | BNL_Master Control Account | BNL_Account Number | BNL_PCR ID | BNL_Cobra Control Account | BNL_WBS_Hierarchical | PMP Summary Part1 | PMP Summary Part2 | Additional EVT documentation required | Indicator - Procurement | Indicator - Float | BNL_Milestone Level | SPH Proc Register | BNL_UDF_Remaining Tot Cost | BNL_UDF_Percent_remaining | BNL_Obligation | Target Milestone Date | Variance | PMP Milestones |
| --- | --- | --- | --- | --- | --- | --- | --- | --- | --- | --- | --- | --- | --- | --- | --- | --- | --- | --- | --- | --- | --- | --- | --- | --- | --- | --- | --- | --- | --- | --- | --- | --- | --- | --- | --- | --- | --- | --- | --- | --- | --- | --- | --- | --- | --- | --- | --- | --- | --- | --- | --- | --- | --- | --- | --- | --- | --- | --- |
|  | 03 | **TPC DAM Production** |  |  | 2020-03-02 | 2022-02-02 |  |  |  |  |  |  |  |  |  |  |  |  |  |  |  |  |  |  |  |  |  |  |  |  |  |  |  |  |  |  |  |  |  |  |  |  |  |  |  |  |  |  |  |  |  |  |  |  |  |  |  |  |
| S146600 |  | Procure TPC DAM Felix 2.0 boards - Provide Requirements to Procurement |  | 75d | 2020-03-02 A | 2020-04-30 A | S146500, S145700 | 100% |  | 2020-03-02 | 2020-06-15 |  |  |  |  | PROF4 PO E [300 h]; TECH3 PO D [240 h]; SCI3 SBU - Unpaid [30 h] | 71,568.82 | 190314 ELM add per GRY/TH | S146600 | 180413 ELM dur, pred/succ per GRY | 0 | S136700 | S136700 | S146600 | CA | Not Started | B_T | Huang, Jin | L5 | BNL | Procurement | PP1 | MP101800 | Tom Hemmick | BNL | TPC DAM v2 | OPC001100 | null | POM02.1.02.06.03 | C | 1.02 | 16709 | 003 | 1.02B | 03 | 01 | 3 | Yes |  |  |  |  |  |  |  |  |  |  |
| S146800 |  | Procure TPC DAM Felix 2.0 Boards - Prepare & Send Solicitation |  | 30d | 2020-03-02 A | 2020-08-12 A | S146600 SS | 100% |  | 2020-03-02 | 2020-04-10 |  |  |  |  |  |  |  | S146800 |  | 0 | S136800 | S136800 |  | NOCA | Not Started |  | Huang, Jin |  | BNL | Procurement | PP2 | MP101800 | Tom Hemmick | BNL | TPC DAM v2 | OPC001100 |  | POM02.1.02.06.03 |  |  |  |  |  | 03 | 01 | 3 |  |  |  |  |  |  |  |  |  |  |  |
| S147310 |  | Procure TPC DAM Felix 2.0 Optical Components - Provide Requirements to Procurement |  | 75d | 2020-03-02 A | 2021-02-23 A | S146500, S145700 | 100% |  | 2020-03-02 | 2020-06-15 |  |  |  |  | PROF4 PO E [300 h]; TECH3 PO D [240 h]; SCI3 SBU - Unpaid [30 h] | 71,568.82 | 190314 ELM add per GRY/TH | S146600 | 180413 ELM dur, pred/succ per GRY | 0 | S136700 | S136700 | S147310 | CA | Not Started | B_T | Huang, Jin | L5 | BNL | Procurement | PP1 | MP101801 | Tom Hemmick | BNL | TPC DAM v2 | OPC001100 | null | POM02.1.02.06.03 | C | 1.02 | 16709 | 003 | 1.02B | 03 | 01 | 3 | Yes |  |  |  |  |  |  |  |  |  |  |
| S147320 |  | Procure TPC DAM Felix 2.0 Optical Components - Prepare & Send Solicitation |  | 30d | 2020-03-02 A | 2021-03-31 A | S147310 SS | 100% |  | 2020-03-02 | 2020-04-10 |  |  |  |  |  |  | 190314 ELM add per GRY/TH | S146800 |  | 0 | S136800 | S136800 |  | NOCA | Not Started |  | Huang, Jin |  | BNL | Procurement | PP2 | MP101801 | Tom Hemmick | BNL | TPC DAM v2 | OPC001100 |  | POM02.1.02.06.03 |  |  |  | 003 |  | 03 | 01 | 3 |  |  |  |  |  |  |  |  |  |  |  |
| S147700 |  | Develop TPC DAM FPGA Algorithm - Round 3 |  | 170d | 2020-06-16 A | 2021-05-28 A | S146700 | 100% |  | 2020-07-01 | 2021-03-09 |  |  |  |  | PROF4 PO E [120 h]; SCI3 SBU - Unpaid [44 h]; STUDENT SBU - Unpaid [220 h]; SCI3 PO [120 h] | 39,041.38 |  | S147700 | 180423 ELM rsrc per GRY | 0 | S137400 | S137525 | S147700 | CA | Not Started | B_T | Huang, Jin | L4 | BNL | Test_System |  |  | Tom Hemmick | BNL | TPC DAM v2 |  | null | POM02.1.02.06.03 | C | 1.02 | 16709 |  | 1.02B | 03 | 01 | 7 |  |  |  |  |  |  |  |  |  |  |  |
| S147800 |  | Procure TPC EDBC Computers & Peripherals - Provide Requirements to Procurement |  | 5d | 2020-07-01 A | 2020-08-28 A | S101000 FS+180d, S146500 | 100% |  | 2020-07-01 | 2020-07-08 |  |  |  |  | PROF4 PO E [192 h]; TECH3 PO D [144 h]; SCI3 SBU - Unpaid [144 h] | 44,708.47 |  | S147800 | 180420 ELM pred/succ per GRY; | 0 | S137600 | S137600 | S147800 | CA | Not Started | B_T | Huang, Jin | L3 | BNL | Procurement | PP1 | MP101700 | Tom Hemmick | BNL |  |  | null | POM02.1.02.06.03 | C | 1.02 | 16709 |  | 1.02B | 03 | 01 | 3 |  |  |  |  |  |  |  |  |  |  |  |
| S147900 |  | Procure TPC EDBC Computers & Peripherals - Prepare & Send Solicitation |  | 30d | 2020-07-09 A | 2021-02-25 A | S147800 | 100% |  | 2020-07-09 | 2020-08-19 |  |  |  |  |  |  |  | S147900 |  | 0 | S137700 | S137700 |  | NOCA | Not Started |  | Huang, Jin |  | BNL | Procurement | PP2 | MP101700 | Tom Hemmick | BNL |  |  |  | POM02.1.02.06.03 |  |  |  |  |  | 03 | 01 | 3 |  |  |  |  |  |  |  |  |  |  |  |
| S146900 |  | Procure TPC DAM Felix 2.0 Boards - Vendor Responses |  | 10d | 2020-08-13 A | 2020-08-26 A | S146800 | 100% |  |  |  |  |  |  |  |  |  |  | S146900 |  | 0 | S136900 | S136900 |  | NOCA | Not Started |  | Huang, Jin |  | BNL | Procurement | PP3 | MP101800 | Tom Hemmick | BNL | TPC DAM v2 | OPC001100 |  | POM02.1.02.06.03 |  |  |  |  |  | 03 | 01 | 3 |  |  |  |  |  |  |  |  |  |  |  |
| S147100 |  | Procure TPC DAM Felix 2.0 Boards - Contract Award(s) | milestone | 0d | 2020-08-27 A | 2020-08-27 A | S147000, S101010 | 100% |  | 2020-09-25 | 2020-09-25 |  |  |  |  |  |  |  | S147100 |  | 0 | S137100 | S137100 |  | NOCA | Not Started | A-TEC | Huang, Jin |  | BNL | Procurement | PP5 | MP101800 | Tom Hemmick | BNL | TPC DAM v2 | OPC001100 |  | POM02.1.02.06.03 |  |  |  |  |  | 03 | 01 | 3 |  | UDF_G1 | UDF_G1 | L5 | Contract Award |  |  |  |  |  |  |
| S147000 |  | Procure TPC DAM Felix 2.0 Boards - Vendor Selection |  | 20d | 2020-08-27 A | 2020-10-30 A | S146900 | 100% |  | 2020-08-27 | 2020-09-24 |  |  |  |  |  |  |  | S147000 |  | 0 | S137000 | S137000 |  | NOCA | Not Started |  | Huang, Jin |  | BNL | Procurement | PP4 | MP101800 | Tom Hemmick | BNL | TPC DAM v2 | OPC001100 |  | POM02.1.02.06.03 |  |  |  |  |  | 03 | 01 | 3 |  |  |  |  |  |  |  |  |  |  |  |
| S147200 |  | Procure TPC DAM Felix 2.0 Boards - Contract/PO - Leadtime |  | 75d | 2020-08-28 A | 2021-04-26 A | S147100 SS, OBLG147110 SS | 100% |  | 2020-09-25 | 2021-01-15 |  |  |  |  |  |  |  | S147200 |  | 0 | S137200 | S137200 |  | NOCA | Not Started |  | Huang, Jin |  | BNL | Fab & Assy | PP6 | MP101800 | Tom Hemmick | BNL | TPC DAM v2 | OPC001100 |  | POM02.1.02.06.03 |  |  |  |  |  | 03 | 01 | 5 |  |  |  |  |  |  |  |  |  |  |  |
| S148000 |  | Procure TPC EDBC Computers & Peripherals - Vendor Responses |  | 10d | 2020-10-20 A | 2021-02-26 A | S147900 | 100% |  | 2020-12-31 | 2021-01-14 |  |  |  |  |  |  |  | S148000 |  | 0 | S137800 | S137800 |  | NOCA | Not Started |  | Huang, Jin |  | BNL | Procurement | PP3 | MP101700 | Tom Hemmick | BNL |  |  |  | POM02.1.02.06.03 |  |  |  |  |  | 03 | 01 | 3 |  |  |  |  |  |  |  |  |  |  |  |
| S148100 |  | Procure TPC EDBC Computers & Peripherals - Vendor Selection |  | 20d | 2020-10-20 A | 2021-04-30 A | S148000 | 100% |  | 2021-01-15 | 2021-02-12 |  |  |  |  |  |  |  | S148100 |  | 0 | S137900 | S137900 |  | NOCA | Not Started |  | Huang, Jin |  | BNL | Procurement | PP4 | MP101700 | Tom Hemmick | BNL |  |  |  | POM02.1.02.06.03 |  |  |  |  |  | 03 | 01 | 3 |  |  |  |  |  |  |  |  |  |  |  |
| S147330 |  | Procure TPC DAM Felix 2.0 Optical Components - Vendor Responses |  | 10d | 2020-10-21 A | 2020-10-29 A | S147320 | 100% |  | 2020-12-01 | 2020-12-14 |  |  |  |  |  |  | 190314 ELM add per GRY/TH | S146900 |  | 0 | S136900 | S136900 |  | NOCA | Not Started |  | Huang, Jin |  | BNL | Procurement | PP3 | MP101801 | Tom Hemmick | BNL | TPC DAM v2 | OPC001100 |  | POM02.1.02.06.03 |  |  |  | 003 |  | 03 | 01 | 3 |  |  |  |  |  |  |  |  |  |  |  |
| S147340 |  | Procure TPC DAM Felix 2.0 Optical Components - Vendor Selection |  | 20d | 2020-10-21 A | 2020-10-29 A | S147330 | 100% |  | 2020-12-15 | 2021-01-13 |  |  |  |  |  |  | 190314 ELM add per GRY/TH | S147000 |  | 0 | S137000 | S137000 |  | NOCA | Not Started |  | Huang, Jin |  | BNL | Procurement | PP4 | MP101801 | Tom Hemmick | BNL | TPC DAM v2 | OPC001100 |  | POM02.1.02.06.03 |  |  |  | 003 |  | 03 | 01 | 3 |  |  |  |  |  |  |  |  |  |  |  |
| S147300 |  | Procure TPC DAM Felix 2.0 Boards - Delivery Acceptance |  | 5d | 2020-12-02 A | 2021-06-30 | S147200 | 80% | 22d | 2021-05-03 | 2021-05-07 | 55d | 0d |  | 2021-06-30 | Material (Purchase (1st $2M) [130362 h] | 151,309.13 | 190314 ELM BLUs per GRY/TH | S147300 | 180419 ELM split activity and M&S into OPC/TEC | 0 | S137300 | S137310 | S147300 | CA | Not Started | A-TEC | Huang, Jin | M4 | BNL | Fab & Assy | PP6 | MP101800 | Tom Hemmick | BNL | TPC DAM v2 | OPC001100 | TEC | POM02.1.02.06.03 | C | 1.02 | 59705 | 015 | 1.02A | 03 | 01 | 5 |  | UDF_G1 | UDF_G1 |  | Delivery | 151309.12802 | 1 | FAB |  |  |  |
| S147380 |  | TPC DAM Electrical Engineering Support |  | 230d | 2021-02-01 A | 2021-12-30 |  | 36% | 146d | 2021-03-01 | 2022-01-28 | 268d | 0d | start on or after 2021-02-01 | 2021-12-30 | PROF3 [368 h] | 48,446.29 | 190314 ELM add per GRY/TH | S147300 | 180419 ELM split activity and M&S into OPC/TEC | 0 | S137300 | S137310 | S147380 | CA | Not Started | A-TEC | Huang, Jin | M4 | BNL | Fab & Assy | PP6 | MP101801 | Tom Hemmick | BNL | TPC DAM v2 | OPC001100 | TEC | POM02.1.02.06.03 | C | 1.02 | 59705 | 020 | 1.02A | 03 | 01 | 5 |  | UDF_G1 | UDF_G1 |  | Delivery | 93719.454611 | 1 | FAB |  |  |  |
| S147400 |  | Perform QA Testing on TPC DAM FELIX 2.0 boards |  | 40d | 2021-03-08 A | 2021-07-06 | S147300, S147200 | 10% | 3d | 2021-05-10 | 2021-07-06 | 55d | 0d |  | 2021-07-06 | PROF4 PO E [44 h]; TECH3 PO E [264 h]; SCI3 SBU - Unpaid [44 h]; STUDENT SBU - Unpaid [220 h]; SCI3 PO [183 h] | 70,146.34 |  | S147400 | 180423 ELM rsrc per GRY | 0 | S137400 | S137400 | S147400 | CA | Not Started | B_T | Huang, Jin | L4 | BNL | Test_System |  |  | Tom Hemmick | BNL | TPC DAM v2 |  | null | POM02.1.02.06.03 | C | 1.02 | 16709 |  | 1.02B | 03 | 01 | 7 |  |  |  |  |  |  |  |  |  |  |  |
| S147500 |  | TPC DAM Felix 2.0 Bandwidth test in 1008 |  | 40d | 2021-03-15 A | 2021-08-31 | S147400, S146700 FF | 10% | 40d | 2021-07-07 | 2021-08-31 | 105d | 0d |  | 2021-08-31 | PROF4 PO E [320 h]; SCI3 PO [67 h] | 60,415.56 |  | S147500 | 180423 ELM rsrc per GRY; 180413 ELM dur per GRY | 0 | S137500 | S137500 | S147500 | CA | Not Started | B | Huang, Jin | L5 | BNL | Test_Components |  |  | Tom Hemmick | BNL | TPC DAM v2 |  | null | POM02.1.02.06.03 | C | 1.02 | 16709 |  | 1.02B | 03 | 01 | 7 |  |  |  |  |  |  |  |  |  |  |  |
| S148200 |  | Procure TPC EDBC Computers & Peripherals - Contract Award(s) | milestone | 0d | 2021-04-30 A | 2021-04-30 A | S148100 | 100% |  | 2021-05-03 | 2021-05-03 |  |  |  |  |  |  |  | S148200 |  | 0 | S138000 | S138000 |  | NOCA | Not Started | A-TEC | Huang, Jin |  | BNL | Procurement | PP5 | MP101700 | Tom Hemmick | BNL |  |  |  | POM02.1.02.06.03 |  |  |  |  |  | 03 | 01 | 3 |  | UDF_G3 | UDF_G3 | L5 | Contract Award |  |  |  |  |  |  |
| S148300 |  | Procure TPC EDBC Computers & Peripherals - Contract/PO - Leadtime |  | 60d | 2021-05-17 A | 2021-09-13 | S148200 SS, OBLG148210 SS | 20% | 73d | 2021-06-01 | 2021-08-24 | 2d | 0d |  | 2021-09-13 |  |  |  | S148300 |  | 0 | S138100 | S138100 |  | NOCA | Not Started |  | Huang, Jin |  | BNL | Fab & Assy | PP6 | MP101700 | Tom Hemmick | BNL |  |  |  | POM02.1.02.06.03 |  |  |  |  |  | 03 | 01 | 5 |  |  |  |  |  |  |  |  |  |  |  |
| OBLG148210 |  | Procure TPC EDBC Computers & Peripherals - Obligation |  | 1d | 2021-05-27 A | 2021-05-28 A | S148100 | 100% |  | 2021-06-01 | 2021-06-01 |  |  |  |  | Obligation Resource [244769 h] | 244,768.63 | 190314 ELM add per GRY/TH | S148200 |  | 0 | S138000 | S138000 |  |  | Not Started | A-TEC | Huang, Jin |  | BNL | Procurement | PP5 | MP101700 | Tom Hemmick | BNL |  |  |  | POM02.1.02.06.03 |  |  |  | 003 |  | 03 |  |  |  |  |  | L5 |  |  |  | OBLG |  |  |  |
| OBLG147110 |  | Procure TPC DAM Felix 2.0 Boards - Obligation |  | 1d | 2021-06-01 | 2021-06-01 | S147000, S101010, S147340 |  |  |  |  | 31d | 0d |  |  | Obligation Resource [148342 h] | 148,342.28 | 190314 ELM add per GRY/TH | S147100 |  | 0 | S137100 | S137100 |  |  | Not Started | A-TEC | Huang, Jin |  | BNL | Procurement | PP5 | MP101800 | Tom Hemmick | BNL | TPC DAM v2 | OPC001100 |  | POM02.1.02.06.03 |  |  |  | 003 |  | 03 |  |  |  |  |  | L5 |  |  |  | OBLG |  |  |  |
| S147350 |  | Procure TPC DAM Felix 2.0 Optical Components - Contract Award(s) | milestone | 0d | 2021-06-01 | 2021-06-01 | S147340, S101010 |  |  |  |  | 32d | 1d |  |  |  |  | 190314 ELM add per GRY/TH | S147100 |  | 0 | S137100 | S137100 |  | NOCA | Not Started | A-TEC | Huang, Jin |  | BNL | Procurement | PP5 | MP101801 | Tom Hemmick | BNL | TPC DAM v2 | OPC001100 |  | POM02.1.02.06.03 |  |  |  | 003 |  | 03 | 01 | 3 |  | UDF_G1 | UDF_G1 | L5 | Contract Award |  |  |  |  |  |  |
| OBLG147109 |  | Procure TPC DAM Felix 2.0 Optical Components - Obligation |  | 1d | 2021-06-02 | 2021-06-02 | S147350 SS, OBLG147110 |  |  |  |  | 31d | 0d |  |  | Obligation Resource [91881.8 h] | 91,881.82 | 190314 ELM add per GRY/TH | S147100 |  | 0 | S137100 | S137100 |  |  | Not Started | A-TEC | Huang, Jin |  | BNL | Procurement | PP5 | MP101801 | Tom Hemmick | BNL | TPC DAM v2 | OPC001100 |  | POM02.1.02.06.03 |  |  |  | 003 |  | 03 |  |  |  |  |  | L5 |  |  |  | OBLG |  |  |  |
| S147360 |  | Procure TPC DAM Felix 2.0 Optical Components - Contract/PO - Leadtime |  | 75d | 2021-06-03 | 2021-09-17 | S147350 SS, OBLG147110 SS, OBLG147109 |  |  |  |  | 31d | 0d |  |  |  |  | 190314 ELM add per GRY/TH | S147200 |  | 0 | S137200 | S137200 |  | NOCA | Not Started |  | Huang, Jin |  | BNL | Fab & Assy | PP6 | MP101801 | Tom Hemmick | BNL | TPC DAM v2 | OPC001100 |  | POM02.1.02.06.03 |  |  |  | 003 |  | 03 | 01 | 5 |  |  |  |  |  |  |  |  |  |  |  |
| S147600 |  | TPC DAM Felix 2.0 Production Complete | milestone | 0d | 2021-08-31 | 2021-08-31 | S147500 FF |  |  |  |  | 105d |  |  |  |  |  |  | S147600 | 180423 ELM rsrc per GRY; 180413 ELM dur per GRY | 0 | S137500 | S343550 |  | NOCA | Not Started |  | Huang, Jin | L5 | BNL | Test_Components |  |  | Tom Hemmick | BNL | TPC DAM v2 |  | null | POM02.1.02.06.03 |  |  |  |  |  | 03 | 01 | 7 |  | UDF_G1 | UDF_G3 | L2 |  |  |  |  | 2021-08-31 | -1 | PMP_1x |
| S148400 |  | Procure TPC EDBC Computers & Peripherals - Delivery Acceptance |  | 5d | 2021-09-14 | 2021-09-20 | S148300 |  |  |  |  | 2d | 0d |  |  | Material (Purchase (1st $2M) [210883 h] | 244,768.59 | 190314 ELM BNLUs per TH | S148400 |  | 0 | S138200 | S138200 | S148400 | CA | Not Started | A-TEC | Huang, Jin | M5 | BNL | Fab & Assy | PP6 | MP101700 | Tom Hemmick | BNL |  |  | TEC | POM02.1.02.06.03 | C | 1.02 | 59705 | 003 | 1.02A | 03 | 01 | 5 |  | UDF_G1 | UDF_G1 |  | Delivery | 244768.589346 | 1 | FAB |  |  |  |
| S147370 |  | Procure TPC DAM Felix 2.0 Optical Components - Contract/PO - Delivery Acceptance |  | 5d | 2021-09-20 | 2021-09-24 | S147360 |  |  |  |  | 88d | 86d |  |  | Material (Purchase (1st $2M) [80745 h] | 93,719.45 | 190314 ELM add per GRY/TH | S147300 | 180419 ELM split activity and M&S into OPC/TEC | 0 | S137300 | S137310 | S147370 | CA | Not Started | A-TEC | Huang, Jin | M4 | BNL | Fab & Assy | PP6 | MP101801 | Tom Hemmick | BNL | TPC DAM v2 | OPC001100 | TEC | POM02.1.02.06.03 | C | 1.02 | 59705 | 015 | 1.02A | 03 | 01 | 5 |  | UDF_G1 | UDF_G3 |  | Delivery | 93719.454611 | 1 | FAB |  |  |  |
| S148500 |  | Test Full TPC DAM System |  | 90d | 2021-09-21 | 2022-02-02 | S147400, S148400, S260400 FF+30d, S147700 |  |  |  |  | 2d | 0d |  |  | PROF4 PO E [960 h]; SCI3 SBU - Unpaid [440 h]; SCI3 PO [440 h] | 229,726.04 | 190314 ELM BLUs per TH | S148500 | 180423 ELM rsrc per GRY | 0 | S138300 | S138300 | S148500 | CA | Not Started | B_T | Huang, Jin | L5 | BNL | Test_Components |  |  | Tom Hemmick | BNL |  |  | null | POM02.1.02.06.03 | K | 1.02 | 16709 | 003 | 1.02B | 03 | 01 | 7 | Yes |  |  |  |  |  |  |  |  |  |  |
| S148600 |  | TPC DAM Production Complete | milestone | 0d | 2022-02-02 | 2022-02-02 | S148500, S147370 |  |  |  |  | 2d |  |  |  |  |  |  | S148600 |  | 0 | S138400 | S138400 |  | NOCA | Not Started |  | Huang, Jin |  | BNL | Fab & Assy |  |  | Tom Hemmick | BNL |  |  |  | POM02.1.02.06.03 |  |  |  |  |  | 03 | 01 | 5 |  | UDF_G2 | UDF_G1 | L2 |  |  |  |  | 2021-11-12 | -54 | PMP_1x |

Notes:
- S146600: BNL_UDF_Old Activity Name 181221: Procure TPC DAM Felix 2.0 boards - Provide Requirements to Procurement
- S146800: BNL_UDF_Old Activity Name 181221: Procure TPC DAM Felix 2.0 Boards - Prepare & Send Solicitation
- S147310: BNL_UDF_Old Activity Name 181221: Procure TPC DAM Felix 2.0 boards - Provide Requirements to Procurement
- S147320: BNL_UDF_Old Activity Name 181221: Procure TPC DAM Felix 2.0 Boards - Prepare & Send Solicitation
- S147700: BNL_UDF_Old Activity Name 181221: (Planning Package) Develop TPC DAM FPGA Algorithm - Round 3
- S147800: Scheduler's Notes: EMenter 180329 / 260 day lag on pred in order to buy computers as late as / possible to obtain max performance / BNL_UDF_Old Activity Name 181221: Procure TPC EDBC Computers & Peripherals - Provide Requirements to Procurement
- S147900: BNL_UDF_Old Activity Name 181221: Procure TPC EDBC Computers & Peripherals - Prepare & Send Solicitation
- S146900: BNL_UDF_Old Activity Name 181221: Procure TPC DAM Felix 2.0 Boards - Vendor Responses
- S147100: BNL_UDF_Old Activity Name 181221: Procure TPC DAM Felix 2.0 Boards - Contract Award(s)
- S147000: BNL_UDF_Old Activity Name 181221: Procure TPC DAM Felix 2.0 Boards - Vendor Selection
- S147200: BNL_UDF_Old Activity Name 181221: Procure TPC DAM Felix 2.0 Boards - Contract/PO - Leadtime
- S148000: BNL_UDF_Old Activity Name 181221: Procure TPC EDBC Computers & Peripherals - Vendor Responses
- S148100: BNL_UDF_Old Activity Name 181221: Procure TPC EDBC Computers & Peripherals - Vendor Selection
- S147330: BNL_UDF_Old Activity Name 181221: Procure TPC DAM Felix 2.0 Boards - Vendor Responses
- S147340: BNL_UDF_Old Activity Name 181221: Procure TPC DAM Felix 2.0 Boards - Vendor Selection
- S147300: BNL_UDF_Old Activity Name 181221: Procure TPC DAM Felix 2.0 Boards - Delivery Acceptance (TEC)
- S147380: BNL_UDF_Old Activity Name 181221: Procure TPC DAM Felix 2.0 Boards - Delivery Acceptance (TEC)
- S147400: BNL_UDF_Old Activity Name 181221: Perform QA Testing on TPC DAM FELIX 2.0 boards
- S147500: BNL_UDF_Old Activity Name 181221: TPC DAM Felix 2.0 Bandwidth test in 1008
- S148200: BNL_UDF_Old Activity Name 181221: Procure TPC EDBC Computers & Peripherals - Contract Award(s)
- S148300: BNL_UDF_Old Activity Name 181221: Procure TPC EDBC Computers & Peripherals - Contract/PO - Leadtime
- OBLG148210: BNL_UDF_Old Activity Name 181221: Procure TPC EDBC Computers & Peripherals - Contract Award(s)
- OBLG147110: BNL_UDF_Old Activity Name 181221: Procure TPC DAM Felix 2.0 Boards - Contract Award(s)
- S147350: BNL_UDF_Old Activity Name 181221: Procure TPC DAM Felix 2.0 Boards - Contract Award(s)
- OBLG147109: BNL_UDF_Old Activity Name 181221: Procure TPC DAM Felix 2.0 Boards - Contract Award(s)
- S147360: BNL_UDF_Old Activity Name 181221: Procure TPC DAM Felix 2.0 Boards - Contract/PO - Leadtime
- S147600: BNL_UDF_Old Activity Name 181221: TPC DAM Felix 2.0 Production Complete
- S148400: BNL_UDF_Old Activity Name 181221: Procure TPC EDBC Computers & Peripherals - Delivery Acceptance
- S147370: BNL_UDF_Old Activity Name 181221: Procure TPC DAM Felix 2.0 Boards - Delivery Acceptance (TEC)
- S148500: BNL_UDF_Old Activity Name 181221: Test Full TPC DAM System
- S148600: BNL_UDF_Old Activity Name 181221: TPC DAM Production Complete

| ID | WBS | Activity | Type | Duration | Start | Finish | Predecessors | Complete | Remaining | Planned start | Planned finish | Total float | Free float | Constraint | Expected finish | Resources | Cost | BNL_UDF_Temp Text 01 | BNL_UDF_Adhoc Comments | BNL_UDF_Percent Complete | BNL_UDF_OPC TEC (deprecated) | BNL_UDF_Old Activity ID 181221 | BNL_Cobra WP | RG Check | BNL_Activity Status | BNL_Fund Source | BNL_Estimator | BNL_Cost Basis | BNL_Location | BNL_EDIA | BNL_CAM | BNL_Institution | BNL_OPC TEC (deprecated) | BNL_WBS | BNL_EVT | BNL_Master Control Account | BNL_Account Number | BNL_Cobra Control Account | BNL_WBS_Hierarchical | Temp | PMP Summary Part1 | PMP Summary Part2 | BNL_UDF_Status Comments | Indicator - Procurement | Indicator - Float | BNL_UDF_Remaining Tot Cost | BNL_UDF_Percent_remaining | BNL_Proc Sig Phase | BNL_Proc Sig | BNL_Obligation | BNL_PCR ID | SPH Proc Register | BNL_Milestone Level |
| --- | --- | --- | --- | --- | --- | --- | --- | --- | --- | --- | --- | --- | --- | --- | --- | --- | --- | --- | --- | --- | --- | --- | --- | --- | --- | --- | --- | --- | --- | --- | --- | --- | --- | --- | --- | --- | --- | --- | --- | --- | --- | --- | --- | --- | --- | --- | --- | --- | --- | --- | --- | --- | --- |
|  | 07 | **TPC Support Systems** |  |  | 2019-09-12 | 2021-12-07 |  |  |  |  |  |  |  |  |  |  |  |  |  |  |  |  |  |  |  |  |  |  |  |  |  |  |  |  |  |  |  |  |  |  |  |  |  |  |  |  |  |  |  |  |  |  |  |
|  | 01 | **TPC Laser System** |  |  | 2019-09-12 | 2021-08-05 |  |  |  |  |  |  |  |  |  |  |  |  |  |  |  |  |  |  |  |  |  |  |  |  |  |  |  |  |  |  |  |  |  |  |  |  |  |  |  |  |  |  |  |  |  |  |  |
| S148700 |  | Design TPC Laser System |  | 13d | 2019-09-12 A | 2020-03-31 A | S101000 | 100% |  | 2019-09-12 | 2019-09-30 |  |  |  |  | PROF4 PO M [320 h]; SCI3 SBU - Unpaid [320 h]; TECH3 PO M [320 h] | 81,207.66 | S148700 | 180426 ELM rsrc per EOB | 0 | S138500 | S138500 | S148700 | CA | In Progress | B_T | Pisani, Rob | L5 | BNL | Design | Tom Hemmick | BNL | null | POM02.1.02.07.01 | C | 1.02 | 16709 | 1.02B | 01 | 1 | 1 | 1 |  |  |  |  |  |  |  |  |  |  |  |
| S148701 |  | Final Design Review - TPC Laser System |  | 1d | 2020-08-24 A | 2020-08-26 A | S148700 | 100% |  | 2020-09-01 | 2020-09-01 |  |  |  |  | PROF4 PO M [4 h]; SCI3 PO [4 h] | 1,277.48 | S148700 | 180426 ELM rsrc per EOB | 0 | S138500 | S138500 | S148701 | CA | Not Started | B | Pisani, Rob | L5 | BNL | Design | Tom Hemmick | BNL | null | POM02.1.02.07.01 | C | 1.02 | 16709 | 1.02B | 01 |  | 1 | 1 | 190522 IVS new act. |  |  |  |  |  |  |  |  |  |  |
| S149600 |  | Procure TPC Lasers - Delivery Acceptance |  | 5d | 2020-10-06 A | 2021-07-16 | S149500 | 50% | 11d | 2021-07-12 | 2021-07-16 | 123d | 0d |  | 2021-07-16 | Material (Purchase (1st $2M) [145840 h] | 169,274.2 | S149600 | 180410 ELM pred/succ per GRY | 0 | S139400 | S139400 | S149600 | CA | Not Started | A-TEC | Pisani, Rob | M5 | BNL | Fab & Assy | Tom Hemmick | BNL | TEC | POM02.1.02.07.01 | C | 1.02 | 59706 | 1.02A | 01 |  | 01 | 5 | 190314 ELM BLUs per TH | UDF_G1 | UDF_G3 | 169274.19977 | 1 | PP6 | MP101900 | FAB | 003 | Delivery |  |
| S149000 |  | Procure TPC Laser(s) - Provide Requirements to Procurement |  | 5d | 2020-10-13 A | 2020-10-19 A | S148900 | 100% |  |  |  |  |  |  |  | SCI3 SBU - Unpaid [48 h]; PROF4 PO M [48 h] | 7,280.78 | S149000 | 180426 ELM rsrc per EOB; 180410 ELM pred/succ per GRY | 0 | S138800 | S138800 | S149000 | CA | Not Started | B_T | Pisani, Rob | L5 | BNL | Procurement | Tom Hemmick | BNL | null | POM02.1.02.07.01 | C | 1.02 | 16709 | 1.02B | 01 |  | 01 | 3 |  |  |  |  |  | PP1 | MP101900 |  |  |  |  |
| S149700 |  | Procure TPC Optics with mirrors - Provide Requirements to Procurement |  | 5d | 2020-10-13 A | 2020-10-19 A | S148900 | 100% |  |  |  |  |  |  |  | SCI3 SBU - Unpaid [24 h]; PROF4 PO M [24 h] | 3,640.39 | S149700 | 180426 ELM rsrc per EOB | 0 | S139500 | S139500 | S149700 | CA | Not Started | B_T | Pisani, Rob | L5 | BNL | Procurement | Tom Hemmick | BNL | null | POM02.1.02.07.01 | C | 1.02 | 16709 | 1.02B | 01 |  | 01 | 3 |  |  |  |  |  | PP1 | MP102000 |  |  |  |  |
| S149800 |  | Procure TPC Optics with Mirrors - Prepare & Send Solicitation |  | 30d | 2020-10-13 A | 2020-10-19 A | S149700 | 100% |  | 2020-10-20 | 2020-12-03 |  |  |  |  |  |  | S149800 |  | 0 | S139600 | S139600 |  | NOCA | Not Started |  | Pisani, Rob |  | BNL | Procurement | Tom Hemmick | BNL |  | POM02.1.02.07.01 |  |  |  |  | 01 |  | 01 | 3 |  |  |  |  |  | PP2 | MP102000 |  |  |  |  |
| S149900 |  | Procure TPC Optics with Mirrors - Vendor Responses |  | 10d | 2020-10-13 A | 2020-10-19 A | S149800 | 100% |  | 2020-12-04 | 2020-12-17 |  |  |  |  |  |  | S149900 |  | 0 | S139700 | S139700 |  | NOCA | Not Started |  | Pisani, Rob |  | BNL | Procurement | Tom Hemmick | BNL |  | POM02.1.02.07.01 |  |  |  |  | 01 |  | 01 | 3 |  |  |  |  |  | PP3 | MP102000 |  |  |  |  |
| S150000 |  | Procure TPC Optics with Mirrors - Vendor Selection |  | 20d | 2020-10-13 A | 2020-10-19 A | S149900 | 100% |  | 2020-12-18 | 2021-01-19 |  |  |  |  |  |  | S150000 |  | 0 | S139800 | S139800 |  | NOCA | Not Started |  | Pisani, Rob |  | BNL | Procurement | Tom Hemmick | BNL |  | POM02.1.02.07.01 |  |  |  |  | 01 |  | 01 | 3 |  |  |  |  |  | PP4 | MP102000 |  |  |  |  |
| S150100 |  | Procure TPC Optics with Mirrors - Contract Award(s) | milestone | 0d | 2020-10-13 A | 2020-10-13 A | S150000 | 100% |  | 2021-01-20 | 2021-01-20 |  |  |  |  |  |  | S150100 |  | 0 | S139900 | S139900 |  | NOCA | Not Started | A-TEC | Pisani, Rob |  | BNL | Procurement | Tom Hemmick | BNL |  | POM02.1.02.07.01 |  |  |  |  | 01 |  | 01 | 3 |  | UDF_G1 | UDF_G3 |  |  | PP5 | MP102000 |  |  | Contract Award | L5 |
| S150200 |  | Procure TPC Optics with Mirrors - Contract/PO - Leadtime |  | 60d | 2020-10-13 A | 2020-10-30 A | S150100 SS, OBLG150110 SS | 100% |  | 2021-01-20 | 2021-04-14 |  |  |  |  |  |  | S150200 |  | 0 | S140000 | S140000 |  | NOCA | Not Started |  | Pisani, Rob |  | BNL | Fab & Assy | Tom Hemmick | BNL |  | POM02.1.02.07.01 |  |  |  |  | 01 |  | 01 | 5 |  |  |  |  |  | PP6 | MP102000 |  |  |  |  |
| S150300 |  | Procure TPC Optics with Mirrors - Delivery Acceptance |  | 5d | 2020-10-13 A | 2021-07-14 | S150200 | 50% | 9d | 2021-04-15 | 2021-04-21 | 128d | 0d |  | 2021-06-15 | Material (Purchase (1st $2M) [58800 h] | 68,248.24 | S150300 | 180410 ELM pred/succ per GRY | 0 | S140100 | S140100 | S150300 | CA | Not Started | A-TEC | Pisani, Rob | M5 | BNL | Fab & Assy | Tom Hemmick | BNL | TEC | POM02.1.02.07.01 | C | 1.02 | 59706 | 1.02A | 01 |  | 01 | 5 | 190314 ELM BLUs per TH | UDF_G1 | UDF_G3 | 68248.237428 | 1 | PP6 | MP102000 | FAB | 003 | Delivery |  |
| S149100 |  | Procure TPC Lasers - Prepare & Send Solicitation |  | 30d | 2020-10-20 A | 2020-10-30 A | S149000 | 100% |  | 2020-10-20 | 2020-12-03 |  |  |  |  |  |  | S149100 |  | 0 | S138900 | S138900 |  | NOCA | Not Started |  | Pisani, Rob |  | BNL | Procurement | Tom Hemmick | BNL |  | POM02.1.02.07.01 |  |  |  |  | 01 |  | 01 | 3 |  |  |  |  |  | PP2 | MP101900 |  |  |  |  |
| S149200 |  | Procure TPC Lasers - Vendor Responses |  | 10d | 2020-10-20 A | 2020-10-30 A | S149100 | 100% |  | 2020-12-04 | 2020-12-17 |  |  |  |  |  |  | S149200 |  | 0 | S139000 | S139000 |  | NOCA | Not Started |  | Pisani, Rob |  | BNL | Procurement | Tom Hemmick | BNL |  | POM02.1.02.07.01 |  |  |  |  | 01 |  | 01 | 3 |  |  |  |  |  | PP3 | MP101900 |  |  |  |  |
| S149300 |  | Procure TPC Lasers - Vendor Selection |  | 20d | 2020-10-20 A | 2020-10-30 A | S149200 | 100% |  | 2020-12-18 | 2021-01-19 |  |  |  |  |  |  | S149300 |  | 0 | S139100 | S139100 |  | NOCA | Not Started |  | Pisani, Rob |  | BNL | Procurement | Tom Hemmick | BNL |  | POM02.1.02.07.01 |  |  |  |  | 01 |  | 01 | 3 |  |  |  |  |  | PP4 | MP101900 |  |  |  |  |
| S149400 |  | Procure TPC Lasers - Contract Award(s) | milestone | 0d | 2020-10-20 A | 2020-10-20 A | S149300 | 100% |  | 2021-01-20 | 2021-01-20 |  |  |  |  |  |  | S149400 |  | 0 | S139200 | S139200 |  | NOCA | Not Started | A-TEC | Pisani, Rob |  | BNL | Procurement | Tom Hemmick | BNL |  | POM02.1.02.07.01 |  |  |  |  | 01 |  | 01 | 3 |  | UDF_G1 | UDF_G3 |  |  | PP5 | MP101900 |  |  | Contract Award | L5 |
| S149500 |  | Procure TPC Lasers - Contract/PO - Leadtime |  | 120d | 2020-10-20 A | 2020-10-30 A | S149400 SS, OBLG149410 SS | 100% |  | 2021-01-20 | 2021-07-09 |  |  |  |  |  |  | S149500 |  | 0 | S139300 | S139300 |  | NOCA | Not Started |  | Pisani, Rob |  | BNL | Fab & Assy | Tom Hemmick | BNL |  | POM02.1.02.07.01 |  |  |  |  | 01 |  | 01 | 5 |  |  |  |  |  | PP6 | MP101900 |  |  |  |  |
| S149650 |  | TPC Diffuse Lasers |  | 147d | 2021-01-04 A | 2021-08-02 |  | 50% | 44d |  |  | 57d | 0d | start on or after 2020-12-01 | 2021-08-02 | Material (Purchase (1st $2M) [200000 h] | 232,136.86 | S149600 | 180410 ELM pred/succ per GRY | 0 | S139400 | S139400 | S149650 | CA | Not Started | A-TEC | Pisani, Rob | M5 | BNL | Fab & Assy | Tom Hemmick | BNL | TEC | POM02.1.02.07.01 | C | 1.02 | 59706 | 1.02A | 01 |  | 01 | 5 | 190314 ELM BLUs per TH | UDF_G2 | UDF_G1 | 169274.19977 | 1 | PP6 | MP101900 | FAB | 017 | Delivery |  |
| S150400 |  | Procure TPC mirror bundles with supports Labor |  | 60d | 2021-01-13 A | 2021-08-02 | S148900 | 50% | 22d | 2021-01-13 | 2021-04-08 | 123d | 0d |  | 2021-06-15 | SCI3 SBU - Unpaid [24 h]; PROF4 PO M [24 h] | 3,640.39 | S150400 | 180426 ELM rsrc per EOB | 0 | S140200 | S140200 | S150400 | CA | Not Started | B_T | Pisani, Rob | L5 | BNL | Procurement | Tom Hemmick | BNL | null | POM02.1.02.07.01 | C | 1.02 | 16709 | 1.02B | 01 |  | 01 | 3 |  |  |  |  |  |  |  |  |  |  |  |
| S150500 |  | Procure TPC mirror bundles with supports M&S |  | 60d | 2021-01-13 A | 2021-08-02 | S148900 | 50% | 22d | 2021-01-13 | 2021-04-08 | 123d | 0d |  | 2021-06-15 | Material (Purchase (1st $2M) [15000 h] | 17,410.26 | S150500 |  | 0 | S140300 | S140300 | S150500 | CA | Not Started | A-TEC | Pisani, Rob | M5 | BNL | Fab & Assy | Tom Hemmick | BNL | TEC | POM02.1.02.07.01 | C | 1.02 | 59706 | 1.02A | 01 |  | 01 | 5 |  | UDF_G1 | UDF_G3 | 17068.88685 | 1 |  | TBD |  |  |  |  |
| S148800 |  | TPC Laser System Safety Review |  | 1d | 2021-03-22 A | 2021-06-22 | S148701 | 20% | 16d | 2021-04-01 | 2021-04-01 | 123d | 0d |  | 2021-06-22 | PROF4 PO M [4 h]; SCI3 PO [4 h] | 1,315.81 | S148800 |  | 0 | S138600 | S138600 | S148800 | CA | Not Started | B | Pisani, Rob |  | BNL | Management Safety Reviews | Tom Hemmick | BNL |  | POM02.1.02.07.01 | C | 1.02 | 16709 | 1.02B | 01 |  | 1 | 1 |  | UDF_G1 | UDF_G3 |  |  |  |  |  |  |  | L5 |
| S148900 |  | Procurement Readiness Review - TPC Laser System |  | 1d | 2021-03-22 A | 2021-06-30 | S148800 FS+5d | 50% | 1d | 2021-04-09 | 2021-04-09 | 123d | 0d |  | 2021-06-22 | PROF4 PO M [4 h]; SCI3 PO [4 h] | 1,315.81 | S148900 |  | 0 | S138700 | S138700 | S148900 | CA | Not Started | B | Pisani, Rob |  | BNL | Management Tech Reviews | Tom Hemmick | BNL |  | POM02.1.02.07.01 | C | 1.02 | 16709 | 1.02B | 01 |  | 1 | 1 | 190522 IVS new name; 190415 ELM name per GRY | UDF_G1 | UDF_G3 |  |  |  |  |  | 004 |  | L4 |
| OBLG149410 |  | Procure TPC Lasers - Obligation |  | 1d | 2021-07-01 | 2021-07-01 | S149300 |  |  |  |  | 123d | 0d |  |  | Obligation Resource [167283 h] | 167,283 | S149400 |  | 0 | S139200 | S139200 |  |  | Not Started | A-TEC | Pisani, Rob |  | BNL | Procurement | Tom Hemmick | BNL |  | POM02.1.02.07.01 |  |  |  |  | 01 |  |  |  | 190314 ELM BLUs per TH |  |  |  |  | PP5 | MP101900 | OBLG | 003 |  | L5 |
| OBLG150110 |  | Procure TPC Optics with Mirrors - Obligation |  | 1d | 2021-07-01 | 2021-07-01 | S150000 |  |  |  |  | 128d | 0d |  |  | Obligation Resource [66910 h] | 66,910.04 | S150100 |  | 0 | S139900 | S139900 |  |  | Not Started | A-TEC | Pisani, Rob |  | BNL | Procurement | Tom Hemmick | BNL |  | POM02.1.02.07.01 |  |  |  |  | 01 |  |  |  | 190314 ELM BLUs per TH |  |  |  |  | PP5 | MP102000 | OBLG | 003 |  | L5 |
| S150600 |  | Install & Test TPC lasers |  | 3d | 2021-07-19 | 2021-07-21 | S149600 |  |  |  |  | 123d | 0d |  |  | TECH3 PO M [24 h] | 2,821.1 | S150600 |  | 0 | S140400 | S140400 | S150600 | CA | Not Started | B | Pisani, Rob | L5 | BNL | Fab & Assy | Tom Hemmick | BNL | null | POM02.1.02.07.01 | C | 1.02 | 16709 | 1.02B | 01 |  | 01 | 5 |  |  |  |  |  |  |  |  |  |  |  |
| S150700 |  | Install &Test TPC Laser safety interlocks Labor |  | 8d | 2021-07-22 | 2021-08-02 | S150600 |  |  |  |  | 126d | 3d |  |  | SCI3 PO [64 h]; PROF4 PO M [64 h] | 21,052.92 | S150700 | 180426 ELM rsrc per EOB | 0 | S140500 | S140500 | S150700 | CA | Not Started | B | Pisani, Rob | L5 | BNL | Fab & Assy | Tom Hemmick | BNL | null | POM02.1.02.07.01 | C | 1.02 | 16709 | 1.02B | 01 |  | 01 | 5 | 190315 ELM EVT |  |  |  |  |  |  |  | 003 |  |  |
| S150800 |  | Install &Test TPC Laser safety interlocks M&S |  | 8d | 2021-07-22 | 2021-08-02 | S150600 |  |  |  |  | 126d | 3d |  |  | Material (Purchase (1st $2M) [2000 h] | 2,321.37 | S150800 |  | 0 | S140600 | S140600 | S150800 | CA | Not Started | A-TEC | Pisani, Rob | M5 | BNL | Fab & Assy | Tom Hemmick | BNL | TEC | POM02.1.02.07.01 | E | 1.02 | 59706 | 1.02A | 01 |  | 01 | 5 |  | UDF_G1 | UDF_G3 | 2321.36862 | 1 |  | TBD |  |  |  |  |
| S150900 |  | Install &Test TPC Laser optics with mounts |  | 8d | 2021-07-22 | 2021-08-02 | S150600, S150300 |  |  |  |  | 123d | 0d |  |  | TECH3 PO M [64 h] | 7,522.93 | S150900 | 180410 ELM pred/succ per GRY | 0 | S140700 | S140700 | S150900 | CA | Not Started | B | Pisani, Rob | L5 | BNL | Fab & Assy | Tom Hemmick | BNL | null | POM02.1.02.07.01 | C | 1.02 | 16709 | 1.02B | 01 |  | 01 | 5 | 190315 ELM EVT |  |  |  |  |  |  |  | 003 |  |  |
| S151000 |  | Install &Test TPC mirror bundles and supports |  | 3d | 2021-08-03 | 2021-08-05 | S150400, S150900, S150500 |  |  |  |  | 123d | 0d |  |  | TECH3 PO M [24 h] | 2,821.1 | S151000 |  | 0 | S140800 | S140800 | S151000 | CA | Not Started | B | Pisani, Rob | L5 | BNL | Fab & Assy | Tom Hemmick | BNL | null | POM02.1.02.07.01 | C | 1.02 | 16709 | 1.02B | 01 |  | 01 | 5 | 190315 ELM EVT |  |  |  |  |  |  |  | 003 |  |  |
| S151100 |  | TPC Laser System Complete | milestone | 0d | 2021-08-05 | 2021-08-05 | S150700, S151000, S150800 |  |  |  |  | 123d | 119d |  |  |  |  | S151100 |  | 0 | S140900 | S140900 |  | NOCA | Not Started |  | Pisani, Rob |  | BNL | Fab & Assy | Tom Hemmick | BNL |  | POM02.1.02.07.01 |  |  |  |  | 01 |  | 01 | 5 |  | UDF_G1 | UDF_G3 |  |  |  |  |  |  |  | L3 |

Notes:
- S148700: BNL_UDF_Old Activity Name 181221: Design TPC Laser System
- S148701: BNL_UDF_Old Activity Name 181221: Design TPC Laser System
- S149600: BNL_UDF_Old Activity Name 181221: Procure TPC Lasers - Delivery Acceptance
- S149000: BNL_UDF_Old Activity Name 181221: Procure TPC Laser(s) - Provide Requirements to Procurement
- S149700: BNL_UDF_Old Activity Name 181221: Procure TPC Optics with mirrors - Provide Requirements to Procurement
- S149800: BNL_UDF_Old Activity Name 181221: Procure TPC Optics with Mirrors - Prepare & Send Solicitation
- S149900: BNL_UDF_Old Activity Name 181221: Procure TPC Optics with Mirrors - Vendor Responses
- S150000: BNL_UDF_Old Activity Name 181221: Procure TPC Optics with Mirrors - Vendor Selection
- S150100: BNL_UDF_Old Activity Name 181221: Procure TPC Optics with Mirrors - Contract Award(s)
- S150200: BNL_UDF_Old Activity Name 181221: Procure TPC Optics with Mirrors - Contract/PO - Leadtime
- S150300: BNL_UDF_Old Activity Name 181221: Procure TPC Optics with Mirrors - Delivery Acceptance
- S149100: BNL_UDF_Old Activity Name 181221: Procure TPC Lasers - Prepare & Send Solicitation
- S149200: BNL_UDF_Old Activity Name 181221: Procure TPC Lasers - Vendor Responses
- S149300: BNL_UDF_Old Activity Name 181221: Procure TPC Lasers - Vendor Selection
- S149400: BNL_UDF_Old Activity Name 181221: Procure TPC Lasers - Contract Award(s)
- S149500: BNL_UDF_Old Activity Name 181221: Procure TPC Lasers - Contract/PO - Leadtime
- S149650: BNL_UDF_Old Activity Name 181221: Procure TPC Lasers - Delivery Acceptance
- S150400: BNL_UDF_Old Activity Name 181221: Procure TPC mirror bundles with supports Labor
- S150500: BNL_UDF_Old Activity Name 181221: Procure TPC mirror bundles with supports M&S
- S148800: General Comments: 180420 GYoung: concerning Safety / Review - this is a check the item is compatible with BNL safety rules - / commercial catalog item / BNL_UDF_Old Activity Name 181221: TPC Laser System Safety Review
- S148900: General Comments: 180420 GYoung: concerning Design / Review - commercial catalog item / BNL_UDF_Old Activity Name 181221: TPC Laser System Design Review
- OBLG149410: BNL_UDF_Old Activity Name 181221: Procure TPC Lasers - Contract Award(s)
- OBLG150110: BNL_UDF_Old Activity Name 181221: Procure TPC Optics with Mirrors - Contract Award(s)
- S150600: BNL_UDF_Old Activity Name 181221: Install & Test TPC lasers
- S150700: BNL_UDF_Old Activity Name 181221: Install &Ttest TPC Laser safety interlocks Labor
- S150800: BNL_UDF_Old Activity Name 181221: Install &Ttest TPC Laser safety interlocks M&S
- S150900: BNL_UDF_Old Activity Name 181221: Install &Ttest TPC Laser optics with mounts
- S151000: BNL_UDF_Old Activity Name 181221: Install &Ttest TPC mirror bundles and supports
- S151100: BNL_UDF_Old Activity Name 181221: TPC Laser System Complete

| ID | WBS | Activity | Type | Duration | Start | Finish | Predecessors | Complete | Remaining | Planned start | Planned finish | Total float | Free float | Expected finish | Resources | Cost | BNL_UDF_Temp Text 01 | BNL_UDF_Percent Complete | BNL_UDF_OPC TEC (deprecated) | BNL_UDF_Old Activity ID 181221 | BNL_Cobra WP | RG Check | BNL_Activity Status | BNL_Fund Source | BNL_Estimator | BNL_Cost Basis | BNL_Location | BNL_EDIA | BNL_CAM | BNL_Institution | BNL_OPC TEC (deprecated) | BNL_WBS | BNL_EVT | BNL_Master Control Account | BNL_Account Number | BNL_Cobra Control Account | BNL_WBS_Hierarchical | Temp | PMP Summary Part1 | PMP Summary Part2 | Additional EVT documentation required | BNL_Proc Sig Phase | BNL_Proc Sig | BNL_Milestone Level | SPH Proc Register | BNL_UDF_Status Comments | Indicator - Procurement | Indicator - Float | BNL_UDF_Remaining Tot Cost | BNL_UDF_Percent_remaining | BNL_PCR ID | BNL_Obligation | BNL_UDF_Adhoc Comments |
| --- | --- | --- | --- | --- | --- | --- | --- | --- | --- | --- | --- | --- | --- | --- | --- | --- | --- | --- | --- | --- | --- | --- | --- | --- | --- | --- | --- | --- | --- | --- | --- | --- | --- | --- | --- | --- | --- | --- | --- | --- | --- | --- | --- | --- | --- | --- | --- | --- | --- | --- | --- | --- | --- |
|  | 02 | **TPC Gas System** |  |  | 2019-09-12 | 2021-12-07 |  |  |  |  |  |  |  |  |  |  |  |  |  |  |  |  |  |  |  |  |  |  |  |  |  |  |  |  |  |  |  |  |  |  |  |  |  |  |  |  |  |  |  |  |  |  |  |
| S151200 |  | Design TPC Gas Handling System |  | 13d | 2019-09-12 A | 2020-03-31 A | S101000 | 100% |  | 2019-09-12 | 2019-09-30 |  |  |  | SCI3 SBU - Unpaid [800 h]; TECH3 PO M [800 h]; PROF4 PO M [800 h] | 203,019.14 | S151200 | 0 | S141000 | S141000 | S151200 | CA | In Progress | B_T | Pisani, Rob | L4 | BNL | Design | Tom Hemmick | BNL | null | POM02.1.02.07.02 | C | 1.02 | 16709 | 1.02B | 02 | 1 | 1 | 1 | Yes |  |  |  |  |  |  |  |  |  |  |  |  |
| S151900 |  | Procure TPC Gas System Equipment - Vendor Responses |  | 10d | 2020-04-02 A | 2020-04-30 A | S151800 | 100% |  | 2020-06-02 | 2020-06-15 |  |  |  |  |  | S151900 | 0 | S141700 | S141700 |  | NOCA | Not Started |  | Pisani, Rob |  | BNL | Procurement | Tom Hemmick | BNL |  | POM02.1.02.07.02 |  |  |  |  | 02 |  | 01 | 3 |  | PP3 | MP102200 |  |  |  |  |  |  |  |  |  |  |
| S152000 |  | Procure TPC Gas System Equipment - Vendor Selection |  | 20d | 2020-04-02 A | 2020-04-30 A | S151900 | 100% |  | 2020-06-16 | 2020-07-14 |  |  |  |  |  | S152000 | 0 | S141800 | S141800 |  | NOCA | Not Started |  | Pisani, Rob |  | BNL | Procurement | Tom Hemmick | BNL |  | POM02.1.02.07.02 |  |  |  |  | 02 |  | 01 | 3 |  | PP4 | MP102200 |  |  |  |  |  |  |  |  |  |  |
| S152100 |  | Procure TPC Gas System Equipment - Contract Award(s) | milestone | 0d | 2020-04-02 A | 2020-04-02 A | S152000 | 100% |  | 2020-07-15 | 2020-07-15 |  |  |  |  |  | S152100 | 0 | S141900 | S141900 |  | NOCA | Not Started | A-TEC | Pisani, Rob |  | BNL | Procurement | Tom Hemmick | BNL |  | POM02.1.02.07.02 |  |  |  |  | 02 |  | 01 | 3 |  | PP5 | MP102200 | L5 | Contract Award |  |  |  |  |  |  |  |  |
| S152200 |  | Procure TPC Gas System Equipment - Contract/PO - Leadtime |  | 30d | 2020-04-02 A | 2021-03-29 A | S152100 SS, OBLG152110 SS | 100% |  | 2020-07-15 | 2020-08-25 |  |  |  |  |  | S152200 | 0 | S142000 | S142000 |  | NOCA | Not Started |  | Pisani, Rob |  | BNL | Fab & Assy | Tom Hemmick | BNL |  | POM02.1.02.07.02 |  |  |  |  | 02 |  | 01 | 5 |  | PP6 | MP102200 |  |  |  |  |  |  |  |  |  |  |
| S151500 |  | Procure TPC Gas System mass flow meters Labor |  | 30d | 2020-04-13 A | 2020-04-29 A | S151400 | 100% |  | 2020-04-13 | 2020-05-22 |  |  |  | PROF4 PO M [24 h] | 3,534.36 | S151500 | 0 | S141300 | S141300 | S151500 | CA | Not Started | B | Pisani, Rob | L3 | BNL | Procurement | Tom Hemmick | BNL | null | POM02.1.02.07.02 | C | 1.02 | 16709 | 1.02B | 02 |  | 01 | 3 |  |  |  |  |  |  |  |  |  |  |  |  |  |
| S151600 |  | Procure TPC Gas System mass flow meters M&S |  | 30d | 2020-04-13 A | 2020-06-30 A | S151400 | 100% |  | 2020-04-13 | 2020-05-22 |  |  |  | Material (Purchase (1st $2M) [6831 h] | 7,773.17 | S151600 | 0 | S141400 | S141400 | S151600 | CA | Not Started | A-TEC | Pisani, Rob | M4 | BNL | Fab & Assy | Tom Hemmick | BNL | TEC | POM02.1.02.07.02 | C | 1.02 | 59706 | 1.02A | 02 |  | 01 | 5 |  |  | TBD |  |  | 190314 ELM BLUs per TH | UDF_G1 | UDF_G3 | 3886.5855355 | 0.5 | 003 |  |  |
| S151700 |  | Procure TPC Gas System Analyzers (2 for redundancy) - Provide Requirements to Procurement |  | 5d | 2020-04-13 A | 2020-04-17 A | S151400 | 100% |  |  |  |  |  |  | PROF4 PO M [24 h] | 3,534.36 | S151700 | 0 | S141500 | S141500 | S151700 | CA | Not Started | B | Pisani, Rob | L4 | BNL | Procurement | Tom Hemmick | BNL | null | POM02.1.02.07.02 | C | 1.02 | 16709 | 1.02B | 02 |  | 01 | 3 |  | PP1 | MP102200 |  |  |  |  |  |  |  |  |  |  |
| S152400 |  | Procure TPC Gas System scrubbers Labor |  | 30d | 2020-04-13 A | 2020-04-29 A | S151400 | 100% |  | 2020-04-13 | 2020-05-22 |  |  |  | PROF4 PO M [24 h] | 3,534.36 | S152400 | 0 | S142200 | S142200 | S152400 | CA | Not Started | B | Pisani, Rob | L4 | BNL | Procurement | Tom Hemmick | BNL | null | POM02.1.02.07.02 | C | 1.02 | 16709 | 1.02B | 02 |  | 01 | 3 |  |  |  |  |  |  |  |  |  |  |  |  |  |
| S152500 |  | Procure TPC Gas System scrubbers M&S |  | 30d | 2020-04-13 A | 2021-03-30 A | S151400 | 100% |  | 2020-04-13 | 2020-05-22 |  |  |  | Material (Purchase (1st $2M) [7727 h] | 8,792.75 | S152500 | 0 | S142300 | S142300 | S152500 | CA | Not Started | A-TEC | Pisani, Rob | M4 | BNL | Fab & Assy | Tom Hemmick | BNL | TEC | POM02.1.02.07.02 | C | 1.02 | 59706 | 1.02A | 02 |  | 01 | 5 |  |  | TBD |  |  | 190314 ELM BLUs per TH | UDF_G1 | UDF_G1 | 8353.11495005 | 0.95 | 003 |  |  |
| S152600 |  | Procure TPC Gas System oxygen and water sensors Labor |  | 30d | 2020-04-13 A | 2020-04-29 A | S151400 | 100% |  | 2020-04-13 | 2020-05-22 |  |  |  | PROF4 PO M [24 h] | 3,534.36 | S152600 | 0 | S142400 | S142400 | S152600 | CA | Not Started | B | Pisani, Rob | L3 | BNL | Procurement | Tom Hemmick | BNL | null | POM02.1.02.07.02 | C | 1.02 | 16709 | 1.02B | 02 |  | 01 | 3 |  |  |  |  |  |  |  |  |  |  |  |  |  |
| S152700 |  | Procure TPC Gas System oxygen and water sensors M&S |  | 30d | 2020-04-13 A | 2020-10-30 A | S151400 | 100% |  | 2020-04-13 | 2020-05-22 |  |  |  | Material (Purchase (1st $2M) [11164 h] | 12,703.8 | S152700 | 0 | S142500 | S142500 | S152700 | CA | Not Started | A-TEC | Pisani, Rob | M4 | BNL | Fab & Assy | Tom Hemmick | BNL | TEC | POM02.1.02.07.02 | C | 1.02 | 59706 | 1.02A | 02 |  | 01 | 5 |  |  | TBD |  |  | 190314 ELM BLUs per TH | UDF_G1 | UDF_G3 | 12068.613344 | 0.95 | 003 |  |  |
| S151800 |  | Procure TPC Gas System Equipment - Prepare & Send Solicitation |  | 30d | 2020-04-20 A | 2020-04-30 A | S151700 | 100% |  | 2020-04-20 | 2020-06-01 |  |  |  |  |  | S151800 | 0 | S141600 | S141600 |  | NOCA | Not Started |  | Pisani, Rob |  | BNL | Procurement | Tom Hemmick | BNL |  | POM02.1.02.07.02 |  |  |  |  | 02 |  | 01 | 3 |  | PP2 | MP102200 |  |  |  |  |  |  |  |  |  |  |
| S151400 |  | Procurement Readiness Review - TPC Gas System |  | 1d | 2020-05-26 A | 2021-06-29 | S151300 FS+5d | 90% | 15d | 2020-06-10 | 2020-06-10 | 40d | 0d | 2021-06-29 | PROF4 PO M [4 h]; SCI3 PO [4 h] | 1,277.48 | S151400 | 0 | S141200 | S141200 | S151400 | CA | Not Started | B | Pisani, Rob |  | BNL | Management Tech Reviews | Tom Hemmick | BNL |  | POM02.1.02.07.02 | C | 1.02 | 16709 | 1.02B | 02 |  | 1 | 1 |  |  |  | L4 |  | 190522 IVS new name; 190415 ELM name per GRY | UDF_G1 | UDF_G3 |  |  | 004 |  |  |
| S151201 |  | Final Design Review - TPC Gas Handling System |  | 1d | 2020-08-24 A | 2020-08-26 A | S151200 FF | 100% |  | 2020-09-01 | 2020-09-01 |  |  |  | PROF4 PO M [4 h]; SCI3 PO [4 h] | 1,277.48 | S151200 | 0 | S141000 | S141000 | S151201 | CA | Not Started | B | Pisani, Rob | L4 | BNL | Design | Tom Hemmick | BNL | null | POM02.1.02.07.02 | C | 1.02 | 16709 | 1.02B | 02 |  | 1 | 1 | Yes |  |  |  |  | 190522 IVS new act. |  |  |  |  | 004 |  |  |
| OBLG152110 |  | Procure TPC Gas System Equipment - Obligation |  | 1d | 2020-09-30 A | 2020-09-30 A | S152000 | 100% |  |  |  |  |  |  | Obligation Resource [37591.4 h] | 37,591.38 | S152100 | 0 | S141900 | S141900 |  |  | Not Started | A-TEC | Pisani, Rob |  | BNL | Procurement | Tom Hemmick | BNL |  | POM02.1.02.07.02 |  |  |  |  | 02 |  |  |  |  | PP5 | MP102200 | L5 |  | 190314 ELM BLUs per TH |  |  |  |  | 003 | OBLG |  |
| OBLG153510 |  | Procure TPC Gas System Components for Installation - Obligation |  | 1d | 2021-01-11 A | 2021-01-19 A | S153400 | 100% |  | 2021-09-27 | 2021-09-27 |  |  |  | Obligation Resource [39563.1 h] | 39,563.09 | S153500 | 0 | S143800 | S143800 |  |  | Not Started | A-TEC | Pisani, Rob |  | BNL | Procurement | Tom Hemmick | BNL |  | POM02.1.02.07.02 |  |  |  |  | 02 |  |  |  |  | PP5 | MP102100 | L5 |  | 190314 ELM BLUs per TH |  |  |  |  | 003 | OBLG |  |
| S152300 |  | Procure TPC Gas System Equipment - Contract/PO - Delivery Acceptance |  | 5d | 2021-01-12 A | 2021-07-01 | S152200 | 70% | 1.33d | 2021-03-01 | 2021-03-05 | 40d | 0d | 2021-06-29 | Material (Purchase (1st $2M) [33035 h] | 38,343.21 | S152300 | 0 | S142100 | S142100 | S152300 | CA | Not Started | A-TEC | Pisani, Rob | M4 | BNL | Fab & Assy | Tom Hemmick | BNL | TEC | POM02.1.02.07.02 | C | 1.02 | 59706 | 1.02A | 02 |  | 01 | 5 |  | PP6 | MP102200 |  | Delivery | 190314 ELM BLUs per TH | UDF_G1 | UDF_G1 | 37591.378473 | 1 | 003 | FAB | 180410 ELM pred/succ per GRY |
| S153700 |  | Procure TPC Gas System Components for Installation - Delivery Acceptance |  | 5d | 2021-03-08 A | 2021-08-31 | S153600 | 70% | 5d | 2021-12-01 | 2021-12-07 | 40d | 0d | 2021-08-31 | Material (Purchase (1st $2M) [34086 h] | 40,354.35 | S153700 | 0 | S144000 | S144000 | S153700 | CA | Not Started | A-TEC | Pisani, Rob | M5 | BNL | Fab & Assy | Tom Hemmick | BNL | TEC | POM02.1.02.07.02 | C | 1.02 | 59706 | 1.02A | 02 |  | 01 | 5 |  | PP6 | MP102100 |  | Delivery | 190314 ELM BLUs per TH | UDF_G1 | UDF_G1 | 39563.085391 | 1 | 003 | FAB | 180410 ELM pred/succ per GRY |
| S153100 |  | Procure TPC Gas System Components for Installation - Provide Requirements to Procurement |  | 5d | 2021-03-11 A | 2021-03-30 A | S152800, S151300, S151400 | 100% |  | 2021-08-25 | 2021-08-31 |  |  |  | PROF4 PO M [24 h]; TECH3 PO M [40 h] | 8,342.22 | S153100 | 0 | S143400 | S143400 | S153100 | CA | Not Started | B | Pisani, Rob | L4 | BNL | Procurement | Tom Hemmick | BNL | null | POM02.1.02.07.02 | C | 1.02 | 16709 | 1.02B | 02 |  | 01 | 3 |  | PP1 | MP102100 |  |  |  |  |  |  |  |  |  |  |
| S153200 |  | Procure TPC Gas System Components for Installation - Prepare & Send Solicitation |  | 10d | 2021-03-11 A | 2021-03-30 A | S153100 | 100% |  | 2021-09-01 | 2021-09-15 |  |  |  |  |  | S153200 | 0 | S143500 | S143500 |  | NOCA | Not Started |  | Pisani, Rob |  | BNL | Procurement | Tom Hemmick | BNL |  | POM02.1.02.07.02 |  |  |  |  | 02 |  | 01 | 3 |  | PP2 | MP102100 |  |  |  |  |  |  |  |  |  |  |
| S153300 |  | Procure TPC Gas System Components for Installation - Vendor Responses |  | 10d | 2021-03-11 A | 2021-03-30 A | S153200 | 100% |  | 2021-09-16 | 2021-09-29 |  |  |  |  |  | S153300 | 0 | S143600 | S143600 |  | NOCA | Not Started |  | Pisani, Rob |  | BNL | Procurement | Tom Hemmick | BNL |  | POM02.1.02.07.02 |  |  |  |  | 02 |  | 01 | 3 |  | PP3 | MP102100 |  |  |  |  |  |  |  |  |  |  |
| S153400 |  | Procure TPC Gas System Components for Installation - Vendor Selection |  | 20d | 2021-03-11 A | 2021-03-30 A | S153300 | 100% |  | 2021-09-30 | 2021-10-28 |  |  |  |  |  | S153400 | 0 | S143700 | S143700 |  | NOCA | Not Started |  | Pisani, Rob |  | BNL | Procurement | Tom Hemmick | BNL |  | POM02.1.02.07.02 |  |  |  |  | 02 |  | 01 | 3 |  | PP4 | MP102100 |  |  |  |  |  |  |  |  |  |  |
| S153500 |  | Procure TPC Gas System Components for Installation - Contract Award(s) | milestone | 0d | 2021-03-11 A | 2021-03-11 A | S153400 | 100% |  | 2021-10-29 | 2021-10-29 |  |  |  |  |  | S153500 | 0 | S143800 | S143800 |  | NOCA | Not Started | A-TEC | Pisani, Rob |  | BNL | Procurement | Tom Hemmick | BNL |  | POM02.1.02.07.02 |  |  |  |  | 02 |  | 01 | 3 |  | PP5 | MP102100 | L5 | Contract Award |  | UDF_G1 | UDF_G3 |  |  |  |  |  |
| S153600 |  | Procure TPC Gas System Components for Installation - Contract/PO - Leadtime |  | 20d | 2021-03-11 A | 2021-03-30 A | S153500 SS, OBLG153510 SS | 100% |  | 2021-10-29 | 2021-11-30 |  |  |  |  |  | S153600 | 0 | S143900 | S143900 |  | NOCA | Not Started |  | Pisani, Rob |  | BNL | Fab & Assy | Tom Hemmick | BNL |  | POM02.1.02.07.02 |  |  |  |  | 02 |  | 01 | 5 |  | PP6 | MP102100 |  |  |  |  |  |  |  |  |  |  |
| S152900 |  | Set up TPC Gas System computer control Labor |  | 35d | 2021-03-15 A | 2021-10-14 | S152800 | 25% | 35d | 2021-08-25 | 2021-10-14 | 70d | 0d | 2021-10-14 | PROF4 PO M [24 h]; STUDENT SBU - Unpaid [480 h] | 3,668.47 | S152900 | 0 | S142700 | S142700 | S152900 | CA | Not Started | B_T | Pisani, Rob | L4 | BNL | Procurement | Tom Hemmick | BNL | null | POM02.1.02.07.02 | C | 1.02 | 16709 | 1.02B | 02 |  | 01 | 3 |  |  |  |  |  |  |  |  |  |  |  |  | 180406 ELM rmv proc strg, dur, pred/succ |
| S153800 |  | Assemble and Plumb TPC Gas System |  | 30d | 2021-03-16 A | 2021-11-30 | S153700 SS | 30% | 65d | 2021-12-01 | 2022-01-13 | 40d | 0d | 2021-11-30 | TECH3 PO M [440 h] | 53,271.76 | S153800 | 0 | S143400 | S144050 | S153800 | CA | Not Started | B | Pisani, Rob | L4 | BNL | Fab & Assy | Tom Hemmick | BNL | null | POM02.1.02.07.02 | K | 1.02 | 16709 | 1.02B | 02 |  | 01 | 3 |  | PP1 | MP102100 |  |  |  |  |  |  |  |  |  |  |
| S152800 |  | Assemble TPC Gas System controls |  | 60d | 2021-03-22 A | 2021-08-24 | S151500, S152400, S152600, S151600, S152300, S152500, S152700 | 10% | 37.67d | 2021-06-01 | 2021-08-24 | 40d | 0d | 2021-08-24 | PROF4 PO M [48 h]; STUDENT SBU - Unpaid [1920 h]; TECH3 PO M [480 h] | 63,702.77 | S152800 | 0 | S142600 | S142600 | S152800 | CA | Not Started | B_T | Pisani, Rob | L4 | BNL | Fab & Assy | Tom Hemmick | BNL | null | POM02.1.02.07.02 | C | 1.02 | 16709 | 1.02B | 02 |  | 01 | 5 |  |  |  |  |  |  |  |  |  |  |  |  | 180410 ELM pred/succ per GRY |
| S151300 |  | TPC Gas System Safety Review |  | 1d | 2021-06-01 | 2021-06-01 | S151201 |  |  |  |  | 40d | 0d |  | PROF4 PO M [4 h]; SCI3 PO [4 h] | 1,315.81 | S151300 | 0 | S141100 | S141100 | S151300 | CA | Not Started | B | Pisani, Rob |  | BNL | Management Safety Reviews | Tom Hemmick | BNL |  | POM02.1.02.07.02 | C | 1.02 | 16709 | 1.02B | 02 |  | 1 | 1 |  |  |  | L5 |  |  | UDF_G1 | UDF_G3 |  |  |  |  |  |
| S153000 |  | Procure TPC Gas System Computer Controller M&S |  | 35d | 2021-08-25 | 2021-10-14 | S152900 SS |  |  |  |  | 70d | 30d |  | Material (Purchase (1st $2M) [18401 h] | 21,467.59 | S153000 | 0 | S143300 | S143300 | S153000 | CA | Not Started | A-TEC | Pisani, Rob | M4 | BNL | Fab & Assy | Tom Hemmick | BNL | TEC | POM02.1.02.07.02 | C | 1.02 | 59706 | 1.02A | 02 |  | 01 | 5 |  |  | TBD |  |  | 190314 ELM BLUs per TH | UDF_G1 | UDF_G3 | 21357.751988 | 1 | 003 |  | 180406 ELM rmv proc strg, dur, pred/succ |
| S153900 |  | Install and Test TPC Gas System Interlocks |  | 5d | 2021-12-01 | 2021-12-07 | S152900, S153000, S153800 |  |  |  |  | 40d | 0d |  | PROF4 PO M [40 h] | 6,249.34 | S153900 | 0 | S144100 | S144100 | S153900 | CA | Not Started | B | Pisani, Rob | L4 | BNL | Fab & Assy | Tom Hemmick | BNL | null | POM02.1.02.07.02 | K | 1.02 | 16709 | 1.02B | 02 |  | 01 | 5 |  |  |  |  |  |  |  |  |  |  |  |  | 180420 ELM add per GRY |
| S154000 |  | TPC Gas System Complete | milestone | 0d | 2021-12-07 | 2021-12-07 | S153900, S153700 |  |  |  |  | 40d | 36d |  |  |  | S154000 | 0 | S144200 | S144200 |  | NOCA | Not Started |  | Pisani, Rob |  | BNL | Fab & Assy | Tom Hemmick | BNL |  | POM02.1.02.07.02 |  |  |  |  | 02 |  | 01 | 5 |  |  |  | L2 |  |  | UDF_G1 | UDF_G3 |  |  |  |  | 180410 ELM pred/succ per GRY |

Notes:
- S151200: BNL_UDF_Old Activity Name 181221: Design TPC Gas Handling System
- S151900: BNL_UDF_Old Activity Name 181221: Procure TPC Gas System Equipment - Vendor Responses
- S152000: BNL_UDF_Old Activity Name 181221: Procure TPC Gas System Equipment - Vendor Selection
- S152100: BNL_UDF_Old Activity Name 181221: Procure TPC Gas System Equipment - Contract Award(s)
- S152200: BNL_UDF_Old Activity Name 181221: Procure TPC Gas System Equipment - Contract/PO - Leadtime
- S151500: BNL_UDF_Old Activity Name 181221: Procure TPC Gas System mass flow meters Labor
- S151600: BNL_UDF_Old Activity Name 181221: Procure TPC Gas System mass flow meters M&S
- S151700: BNL_UDF_Old Activity Name 181221: Procure TPC Gas System Analyzers (2 for redundancy) - Provide Requirements to Procurement
- S152400: BNL_UDF_Old Activity Name 181221: Procure TPC Gas System scrubbers Labor
- S152500: BNL_UDF_Old Activity Name 181221: Procure TPC Gas System scrubbers M&S
- S152600: BNL_UDF_Old Activity Name 181221: Procure TPC Gas System oxygen and water sensors Labor
- S152700: BNL_UDF_Old Activity Name 181221: Procure TPC Gas System oxygen and water sensors M&S
- S151800: BNL_UDF_Old Activity Name 181221: Procure TPC Gas System Equipment - Prepare & Send Solicitation
- S151400: General Comments: 180420 GYoung: concerning Design / Review - commercial catalog item / BNL_UDF_Old Activity Name 181221: TPC Gas System Design Review
- S151201: BNL_UDF_Old Activity Name 181221: Design TPC Gas Handling System
- OBLG152110: BNL_UDF_Old Activity Name 181221: Procure TPC Gas System Equipment - Contract Award(s)
- OBLG153510: BNL_UDF_Old Activity Name 181221: Procure TPC Gas System Components for Installation - Contract Award(s)
- S152300: BNL_UDF_Old Activity Name 181221: Procure TPC Gas System Equipment - Contract/PO - Delivery Acceptance
- S153700: BNL_UDF_Old Activity Name 181221: Procure TPC Gas System Components for Installation - Delivery Acceptance
- S153100: General Comments: 180420 GYoung: concerning Design / Review - commercial catalog items and contract labor therefore design / drawings matter / BNL_UDF_Old Activity Name 181221: Procure TPC Gas System Components for Installation - Provide Requirements to Procurement
- S153200: BNL_UDF_Old Activity Name 181221: Procure TPC Gas System Components for Installation - Prepare & Send Solicitation
- S153300: BNL_UDF_Old Activity Name 181221: Procure TPC Gas System Components for Installation - Vendor Responses
- S153400: BNL_UDF_Old Activity Name 181221: Procure TPC Gas System Components for Installation - Vendor Selection
- S153500: BNL_UDF_Old Activity Name 181221: Procure TPC Gas System Components for Installation - Contract Award(s)
- S153600: BNL_UDF_Old Activity Name 181221: Procure TPC Gas System Components for Installation - Contract/PO - Leadtime
- S152900: BNL_UDF_Old Activity Name 181221: Set up TPC Gas System computer control Labor
- S153800: BNL_UDF_Old Activity Name 181221: Assemble and Plumb TPC Gas System
- S152800: BNL_UDF_Old Activity Name 181221: Assemble TPC Gas System controls
- S151300: General Comments: 180420 GYoung: concerning Safety / Review - this is a check the item is compatible with BNL safety rules - / commercial catalog item; also need consistent naming of Proc.String / activities / BNL_UDF_Old Activity Name 181221: TPC Gas System Safety Review
- S153000: BNL_UDF_Old Activity Name 181221: Procure TPC Gas System Controller M&S
- S153900: BNL_UDF_Old Activity Name 181221: Install and Test TPC Gas System Interlocks
- S154000: BNL_UDF_Old Activity Name 181221: TPC Gas System Complete

| ID | WBS | Activity | Type | Duration | Start | Finish | Predecessors | Complete | Planned start | Planned finish | Total float | Free float | Resources | Cost | BNL_UDF_Temp Text 01 | BNL_UDF_Percent Complete | BNL_UDF_OPC TEC (deprecated) | BNL_UDF_Old Activity ID 181221 | BNL_Cobra WP | RG Check | BNL_Activity Status | BNL_Fund Source | BNL_Estimator | BNL_Cost Basis | BNL_Location | BNL_EDIA | BNL_CAM | BNL_Institution | BNL_OPC TEC (deprecated) | BNL_WBS | BNL_EVT | BNL_Master Control Account | BNL_Account Number | BNL_Cobra Control Account | BNL_WBS_Hierarchical | Temp | PMP Summary Part1 | PMP Summary Part2 | Additional EVT documentation required | BNL_UDF_Status Comments | BNL_PCR ID | Indicator - Procurement | Indicator - Float | BNL_Milestone Level | BNL_Proc Sig Phase | BNL_Proc Sig | BNL_UDF_Adhoc Comments | BNL_UDF_Remaining Tot Cost | BNL_UDF_Percent_remaining | BNL_Obligation | SPH Proc Register |
| --- | --- | --- | --- | --- | --- | --- | --- | --- | --- | --- | --- | --- | --- | --- | --- | --- | --- | --- | --- | --- | --- | --- | --- | --- | --- | --- | --- | --- | --- | --- | --- | --- | --- | --- | --- | --- | --- | --- | --- | --- | --- | --- | --- | --- | --- | --- | --- | --- | --- | --- | --- |
|  | 03 | **TPC Cooling System** |  |  | 2019-09-12 | 2021-09-24 |  |  |  |  |  |  |  |  |  |  |  |  |  |  |  |  |  |  |  |  |  |  |  |  |  |  |  |  |  |  |  |  |  |  |  |  |  |  |  |  |  |  |  |  |  |
| S154100 |  | Design TPC Cooling System |  | 13d | 2019-09-12 A | 2020-10-14 A | S101000 | 100% | 2019-09-12 | 2019-09-30 |  |  | PROF4 PO M [640 h]; SCI3 SBU - Unpaid [640 h]; TECH3 PO M [212 h] | 114,993.69 | S154100 | 0 | S144300 | S144300 | S154100 | CA | In Progress | B_T | Pisani, Rob | L5 | BNL | Design | Tom Hemmick | BNL | null | POM02.1.02.07.03 | C | 1.02 | 16709 | 1.02B | 03 | 1 | 1 | 1 | Yes |  |  |  |  |  |  |  |  |  |  |  |  |
| S154101 |  | Final Design Review - TPC Cooling System |  | 1d | 2020-08-28 A | 2020-08-31 A | S154100 FF | 100% | 2020-09-30 | 2020-09-30 |  |  | PROF4 PO M [4 h]; SCI3 PO [4 h] | 1,277.48 | S154100 | 0 | S144300 | S144300 | S154101 | CA | Not Started | B | Pisani, Rob | L5 | BNL | Design | Tom Hemmick | BNL | null | POM02.1.02.07.03 | C | 1.02 | 16709 | 1.02B | 03 |  | 1 | 1 | Yes | 190522 IVS new act. | 004 |  |  |  |  |  |  |  |  |  |  |
| S154200 |  | TPC Cooling System Safety Review |  | 1d | 2020-10-15 A | 2020-10-15 A | S154101 | 100% |  |  |  |  | PROF4 PO M [4 h]; SCI3 PO [4 h] | 1,315.81 | S154200 | 0 | S144400 | S144400 | S154200 | CA | Not Started | B | Pisani, Rob |  | BNL | Management Safety Reviews | Tom Hemmick | BNL |  | POM02.1.02.07.03 | C | 1.02 | 16709 | 1.02B | 03 |  | 1 | 1 |  |  |  | UDF_G1 | UDF_G3 | L5 |  |  |  |  |  |  |  |
| S154300 |  | Procurement Readiness Review - TPC Cooling System |  | 1d | 2020-10-23 A | 2020-10-23 A | S154200 FS+5d | 100% |  |  |  |  | PROF4 PO M [4 h]; SCI3 PO [4 h] | 1,315.81 | S154300 | 0 | S144500 | S144500 | S154300 | CA | Not Started | B | Pisani, Rob |  | BNL | Design | Tom Hemmick | BNL |  | POM02.1.02.07.03 | C | 1.02 | 16709 | 1.02B | 03 |  | 1 | 1 |  | 190522 IVS new name; 190415 ELM name per GRY | 004 | UDF_G1 | UDF_G3 | L5 |  |  |  |  |  |  |  |
| S154400 |  | Procure TPC Cooling System equipment (pumps, heat exchanger, PH control, manifolds, tanks…) - Provide Requirements to Pr |  | 5d | 2020-11-17 A | 2021-04-02 A | S154300 | 100% | 2020-12-01 | 2020-12-07 |  |  | TECH3 PO M [48 h]; PROF4 PO M [48 h] | 12,922.98 | S154400 | 0 | S144600 | S144600 | S154400 | CA | Not Started | B | Pisani, Rob | L4 | BNL | Procurement | Tom Hemmick | BNL | null | POM02.1.02.07.03 | C | 1.02 | 16709 | 1.02B | 03 |  | 01 | 3 |  |  |  |  |  |  | PP1 | MP102500 |  |  |  |  |  |
| S154500 |  | Procure TPC Cooling System Equipment - Prepare & Send Solicitation |  | 30d | 2021-02-03 A | 2021-04-02 A | S154400 | 100% | 2021-02-03 | 2021-03-17 |  |  |  |  | S154500 | 0 | S144700 | S144700 |  | NOCA | Not Started |  | Pisani, Rob |  | BNL | Procurement | Tom Hemmick | BNL |  | POM02.1.02.07.03 |  |  |  |  | 03 |  | 01 | 3 |  |  |  |  |  |  | PP2 | MP102500 |  |  |  |  |  |
| S155000 |  | Procure TPC Cooling System Equipment - Delivery Acceptance |  | 5d | 2021-02-15 A | 2021-05-31 A | S154900 | 100% | 2021-07-26 | 2021-07-30 |  |  | Material (Purchase (1st $2M) [44339 h] | 51,463.58 | S155000 | 0 | S145200 | S145200 | S155000 | CA | Not Started | A-TEC | Pisani, Rob | M4 | BNL | Fab & Assy | Tom Hemmick | BNL | TEC | POM02.1.02.07.03 | C | 1.02 | 59706 | 1.02A | 03 |  | 01 | 5 |  |  |  | UDF_G1 | UDF_G1 |  | PP6 | MP102500 | 180410 ELM pred/succ per GRY | 51463.581621 | 1 | FAB | Delivery |
| S154700 |  | Procure TPC Cooling System Equipment - Vendor Selection |  | 20d | 2021-03-08 A | 2021-04-02 A | S154600 | 100% | 2021-04-01 | 2021-04-28 |  |  |  |  | S154700 | 0 | S144900 | S144900 |  | NOCA | Not Started |  | Pisani, Rob |  | BNL | Procurement | Tom Hemmick | BNL |  | POM02.1.02.07.03 |  |  |  |  | 03 |  | 01 | 3 |  |  |  |  |  |  | PP4 | MP102500 |  |  |  |  |  |
| S154600 |  | Procure TPC Cooling System Equipment - Vendor Responses |  | 10d | 2021-03-18 A | 2021-04-02 A | S154500 | 100% | 2021-03-18 | 2021-03-31 |  |  |  |  | S154600 | 0 | S144800 | S144800 |  | NOCA | Not Started |  | Pisani, Rob |  | BNL | Procurement | Tom Hemmick | BNL |  | POM02.1.02.07.03 |  |  |  |  | 03 |  | 01 | 3 |  |  |  |  |  |  | PP3 | MP102500 |  |  |  |  |  |
| S154800 |  | Procure TPC Cooling System Equipment - Contract Award(s) | milestone | 0d | 2021-04-02 A | 2021-04-02 A | S154700 | 100% | 2021-05-04 | 2021-05-04 |  |  |  |  | S154800 | 0 | S145000 | S145000 |  | NOCA | Not Started | A-TEC | Pisani, Rob |  | BNL | Procurement | Tom Hemmick | BNL |  | POM02.1.02.07.03 |  |  |  |  | 03 |  | 01 | 3 |  |  |  | UDF_G1 | UDF_G3 | L5 | PP5 | MP102500 |  |  |  |  | Contract Award |
| S154900 |  | Procure TPC Cooling System Equipment - Contract/PO - Leadtime |  | 60d | 2021-04-29 A | 2021-05-31 A | S154800 SS, OBLG154810 SS | 100% | 2021-04-29 | 2021-07-23 |  |  |  |  | S154900 | 0 | S145100 | S145100 |  | NOCA | Not Started |  | Pisani, Rob |  | BNL | Fab & Assy | Tom Hemmick | BNL |  | POM02.1.02.07.03 |  |  |  |  | 03 |  | 01 | 5 |  |  |  |  |  |  | PP6 | MP102500 |  |  |  |  |  |
| OBLG154810 |  | Procure TPC Cooling System Equipment - Obligation |  | 1d | 2021-06-01 | 2021-06-01 | S154700 |  |  |  | 88d | 0d | Obligation Resource [51464 h] | 51,464 | S154800 | 0 | S145000 | S145000 |  |  | Not Started | A-TEC | Pisani, Rob |  | BNL | Procurement | Tom Hemmick | BNL |  | POM02.1.02.07.03 |  |  |  |  | 03 |  |  |  |  |  |  |  |  | L5 | PP5 | MP102500 |  |  |  | OBLG |  |
| S155100 |  | Install TPC Cooling System pumps |  | 3d | 2021-06-01 | 2021-06-03 | S155000 |  |  |  | 88d | 0d | TECH3 PO M [24 h] | 2,821.1 | S155100 | 0 | S145300 | S145300 | S155100 | CA | Not Started | B | Pisani, Rob | L4 | BNL | Fab & Assy | Tom Hemmick | BNL | null | POM02.1.02.07.03 | C | 1.02 | 16709 | 1.02B | 03 |  | 01 | 5 |  |  |  |  |  |  |  |  | 180410 ELM pred/succ per GRY |  |  |  |  |
| S155200 |  | Install TPC Cooling System heat exchanger |  | 3d | 2021-06-04 | 2021-06-08 | S155100 |  |  |  | 88d | 0d | TECH3 PO M [24 h] | 2,821.1 | S155200 | 0 | S145400 | S145400 | S155200 | CA | Not Started | B | Pisani, Rob | L4 | BNL | Fab & Assy | Tom Hemmick | BNL | null | POM02.1.02.07.03 | C | 1.02 | 16709 | 1.02B | 03 |  | 01 | 5 |  |  |  |  |  |  |  |  |  |  |  |  |  |
| S155300 |  | Install TPC Cooling System PH control |  | 3d | 2021-06-09 | 2021-06-11 | S155200 |  |  |  | 88d | 0d | TECH3 PO M [24 h] | 2,821.1 | S155300 | 0 | S145500 | S145500 | S155300 | CA | Not Started | B | Pisani, Rob | L4 | BNL | Fab & Assy | Tom Hemmick | BNL | null | POM02.1.02.07.03 | C | 1.02 | 16709 | 1.02B | 03 |  | 01 | 5 |  |  |  |  |  |  |  |  |  |  |  |  |  |
| S155400 |  | Install TPC Cooling System end cap manifolds |  | 10d | 2021-06-14 | 2021-06-25 | S155300 |  |  |  | 88d | 0d | TECH3 PO M [80 h] | 9,403.66 | S155400 | 0 | S145600 | S145600 | S155400 | CA | Not Started | B | Pisani, Rob | L4 | BNL | Fab & Assy | Tom Hemmick | BNL | null | POM02.1.02.07.03 | C | 1.02 | 16709 | 1.02B | 03 |  | 01 | 5 |  |  |  |  |  |  |  |  |  |  |  |  |  |
| S155500 |  | Install TPC Cooling System tanks |  | 3d | 2021-06-28 | 2021-06-30 | S155400 |  |  |  | 88d | 0d | TECH3 PO M [24 h] | 2,821.1 | S155500 | 0 | S145700 | S145700 | S155500 | CA | Not Started | B | Pisani, Rob | L4 | BNL | Fab & Assy | Tom Hemmick | BNL | null | POM02.1.02.07.03 | C | 1.02 | 16709 | 1.02B | 03 |  | 01 | 5 |  |  |  |  |  |  |  |  |  |  |  |  |  |
| S155600 |  | Install TPC Cooling System plumbing Labor |  | 30d | 2021-07-01 | 2021-08-12 | S155500 |  |  |  | 88d | 0d | TECH3 PO M [240 h] | 28,210.99 | S155600 | 0 | S145800 | S145800 | S155600 | CA | Not Started | B | Pisani, Rob | L4 | BNL | Installation | Tom Hemmick | BNL | null | POM02.1.02.07.03 | C | 1.02 | 16709 | 1.02B | 03 |  | 01 | 3 |  |  |  |  |  |  |  |  | 180406 ELM name, pred/succ, rmv proc strg |  |  |  |  |
| S155700 |  | Procure TPC Plumbing - Contract/PO M&S |  | 20d | 2021-08-13 | 2021-09-10 | S155600 |  |  |  | 88d | 0d | Material (Purchase (1st $2M) [11667 h] | 13,541.7 | S155700 | 0 | S146400 | S146400 | S155700 | CA | Not Started | A-TEC | Pisani, Rob | M4 | BNL | Fab & Assy | Tom Hemmick | BNL | TEC | POM02.1.02.07.03 | C | 1.02 | 59706 | 1.02A | 03 |  | 01 | 5 |  |  |  | UDF_G1 | UDF_G3 |  |  | TBD | 180406 ELM name, pred/succ, rmv proc strg | 13541.703845 | 1 |  |  |
| S155800 |  | Set up TPC Cooling System computer controls Labor |  | 5d | 2021-09-13 | 2021-09-17 | S155700 |  |  |  | 88d | 0d | TECH3 PO M [40 h] | 4,701.83 | S155800 | 0 | S146500 | S146500 | S155800 | CA | Not Started | B | Pisani, Rob | L5 | BNL | Fab & Assy | Tom Hemmick | BNL | null | POM02.1.02.07.03 | C | 1.02 | 16709 | 1.02B | 03 |  | 01 | 5 |  |  |  |  |  |  |  |  |  |  |  |  |  |
| S155900 |  | Set up TPC Cooling System computer controls M&S |  | 5d | 2021-09-13 | 2021-09-17 | S155700 |  |  |  | 88d | 0d | Material (Purchase (1st $2M) [10493 h] | 12,179.06 | S155900 | 0 | S146600 | S146600 | S155900 | CA | Not Started | A-TEC | Pisani, Rob | M5 | BNL | Fab & Assy | Tom Hemmick | BNL | TEC | POM02.1.02.07.03 | C | 1.02 | 59706 | 1.02A | 03 |  | 01 | 5 |  |  |  | UDF_G1 | UDF_G3 |  |  | TBD |  | 12179.060465 | 1 |  |  |
| S156000 |  | Set up and Test TPC Cooling System & Interlocks |  | 5d | 2021-09-20 | 2021-09-24 | S155800, S155900 |  |  |  | 88d | 0d | TECH3 PO M [40 h] | 4,701.83 | S156000 | 0 | S146700 | S146700 | S156000 | CA | Not Started | B | Pisani, Rob | L5 | BNL | Fab & Assy | Tom Hemmick | BNL | null | POM02.1.02.07.03 | C | 1.02 | 16709 | 1.02B | 03 |  | 01 | 5 |  | 190315 ELM EVT | 003 |  |  |  |  |  |  |  |  |  |  |
| S156100 |  | TPC Cooling System Complete | milestone | 0d | 2021-09-24 | 2021-09-24 | S156000 |  |  |  | 88d | 84d |  |  | S156100 | 0 | S146800 | S146800 |  | NOCA | Not Started |  | Pisani, Rob |  | BNL | Fab & Assy | Tom Hemmick | BNL |  | POM02.1.02.07.03 |  |  |  |  | 03 |  | 01 | 5 |  |  |  | UDF_G1 | UDF_G3 | L2 |  |  |  |  |  |  |  |

Notes:
- S154100: BNL_UDF_Old Activity Name 181221: Design TPC Cooling System
- S154101: BNL_UDF_Old Activity Name 181221: Design TPC Cooling System
- S154200: General Comments: 180420 GYoung: concerning Safety / Review - this is a check the item is compatible with BNL safety / rules / BNL_UDF_Old Activity Name 181221: TPC Cooling System Safety Review
- S154300: General Comments: 180420 GYoung: concerning Design / Review - commercial catalog items / BNL_UDF_Old Activity Name 181221: TPC Cooling System Design Review
- S154400: BNL_UDF_Old Activity Name 181221: Procure TPC Cooling System equipment (pumps, heat exchanger, PH control, manifolds, tanks…) - Provide Requirements to Pr
- S154500: BNL_UDF_Old Activity Name 181221: Procure TPC Cooling System Equipment - Prepare & Send Solicitation
- S155000: BNL_UDF_Old Activity Name 181221: Procure TPC Cooling System Equipment - Delivery Acceptance
- S154700: BNL_UDF_Old Activity Name 181221: Procure TPC Cooling System Equipment - Vendor Selection
- S154600: BNL_UDF_Old Activity Name 181221: Procure TPC Cooling System Equipment - Vendor Responses
- S154800: BNL_UDF_Old Activity Name 181221: Procure TPC Cooling System Equipment - Contract Award(s)
- S154900: BNL_UDF_Old Activity Name 181221: Procure TPC Cooling System Equipment - Contract/PO - Leadtime
- OBLG154810: BNL_UDF_Old Activity Name 181221: Procure TPC Cooling System Equipment - Contract Award(s)
- S155100: BNL_UDF_Old Activity Name 181221: Install TPC Cooling System pumps
- S155200: BNL_UDF_Old Activity Name 181221: Install TPC Cooling System heat exchanger
- S155300: BNL_UDF_Old Activity Name 181221: Install TPC Cooling System PH control
- S155400: BNL_UDF_Old Activity Name 181221: Install TPC Cooling System end cap manifolds
- S155500: BNL_UDF_Old Activity Name 181221: Install TPC Cooling System tanks
- S155600: BNL_UDF_Old Activity Name 181221: Install TPC Cooling System plumbing Labor
- S155700: BNL_UDF_Old Activity Name 181221: Procure TPC Plumbing - Contract/PO M&S
- S155800: BNL_UDF_Old Activity Name 181221: Set up TPC Cooling System computer controls Labor
- S155900: BNL_UDF_Old Activity Name 181221: Set up TPC Cooling System computer controls M&S
- S156000: BNL_UDF_Old Activity Name 181221: Set up and Test TPC Cooling System & Interlocks
- S156100: BNL_UDF_Old Activity Name 181221: TPC Cooling System Complete

| ID | WBS | Activity | Type | Duration | Start | Finish | Predecessors | Complete | Planned start | Planned finish | Resources | Cost | BNL_UDF_Status Comments | BNL_UDF_Temp Text 01 | BNL_UDF_Percent Complete | BNL_UDF_Old Activity ID 181221 | BNL_Cobra WP | RG Check | BNL_Activity Status | BNL_Fund Source | BNL_Estimator | BNL_Cost Basis | BNL_Location | BNL_EDIA | BNL_CAM | BNL_OPC TEC (deprecated) | BNL_WBS | BNL_Actuals | BNL_FY | BNL_EVT | BNL_Master Control Account | BNL_Account Number | BNL_PCR ID | BNL_Cobra Control Account | BNL_WBS_Hierarchical | Completed | PMP Summary Part1 | PMP Summary Part2 | Indicator - Procurement | BNL_UDF_OPC TEC (deprecated) | BNL_Institution | BNL_R&D FY18-19 | BNL_UDF_Adhoc Comments |
| --- | --- | --- | --- | --- | --- | --- | --- | --- | --- | --- | --- | --- | --- | --- | --- | --- | --- | --- | --- | --- | --- | --- | --- | --- | --- | --- | --- | --- | --- | --- | --- | --- | --- | --- | --- | --- | --- | --- | --- | --- | --- | --- | --- |
|  | 03 | **EMCal** |  |  | 2017-02-01 | 2022-02-04 |  |  |  |  |  |  |  |  |  |  |  |  |  |  |  |  |  |  |  |  |  |  |  |  |  |  |  |  |  |  |  |  |  |  |  |  |  |
| S156200 |  | Actuals - Labor - sPHENIX EMCal FY17 |  | 169d | 2017-02-01 A | 2017-09-29 A | S100090 SS | 100% |  |  | Actual Labor [979.83 h] | 163,722.63 | 190315 DurType to align with EVT | S156200 | 100 | S338740 | S156200 | CA | Completed | B | Woody, Craig | L1 | BNL | Design | Craig Woody | null | POM02.1.03 | Yes | 2017 | A | 1.03 | 16710 | 003 | 1.03B | 03 | yes | 1 | 1 |  |  |  |  |  |
| S156400 |  | Actuals - Nonlabor - sPHENIX EMCal FY17 |  | 169d | 2017-02-01 A | 2017-09-29 A | S100090 SS | 100% |  |  | Actual Nonlabor [40976.6 h] | 45,714 | 190315 DurType to align with EVT | S156400 | 100 | S339142 | S156400 | CA | Completed | A-OPC | Woody, Craig | M1 | BNL | Design | Craig Woody | OPC | POM02.1.03 | Yes | 2017 | A | 1.03 | 16702 | 003 | 1.03A | 03 | yes | 1 | 1 | UDF_G3 |  |  |  |  |
| S156300 |  | Actuals - Labor - sPHENIX EMCal FY18 |  | 249d | 2017-10-02 A | 2018-09-28 A | S156200 | 100% |  |  | Actual Labor [2869.45 h] | 479,464.7 | 190315 DurType to align with EVT | S156300 | 100 | S339140 | S156300 | CA | Completed | B | Woody, Craig | L1 | BNL | Design | Craig Woody | null | POM02.1.03 | Yes | 2018 | A | 1.03 | 16710 | 003 | 1.03B | 03 | yes | 1 | 1 |  |  |  |  |  |
| S156500 |  | Actuals - Nonlabor - sPHENIX EMCal FY18 |  | 249d | 2017-10-02 A | 2018-09-28 A | S156400 | 100% |  |  | Actual Nonlabor [415271 h] | 463,282.35 | 190315 DurType to align with EVT | S156500 | 100 | S339145 | S156500 | CA | Completed | A-OPC | Woody, Craig | M1 | BNL | Design | Craig Woody | OPC | POM02.1.03 | Yes | 2018 | A | 1.03 | 16702 | 003 | 1.03A | 03 | yes | 1 | 1 | UDF_G3 |  |  |  |  |
| S1001879 |  | Actuals - Nonlabor - sPHENIX EMCal FY19M8 |  | 166d | 2018-10-01 A | 2019-05-31 A |  | 100% |  |  | Actual Nonlabor [73248 h] | 80,811.96 | 190315 DurType to align with EVT | S156500 | 100 | S339145 | S1001879 | CA | Completed | A-TEC | Woody, Craig | M1 | BNL | Design | Craig Woody | TEC | POM02.1.03 | Yes | 2019 | A | 1.03 | 59708 | 003 | 1.03A | 03 | yes | 1 | 1 | UDF_G3 |  |  |  |  |
| S156310 |  | Actuals - Labor - sPHENIX EMCal FY19M8 |  | 166d | 2018-10-01 A | 2019-05-31 A | S156300 | 100% |  |  | Actual Labor [2337.04 h] | 390,502.77 | 190315 DurType to align with EVT | S156300 | 100 | S339140 | S156310 | CA | Completed | B | Woody, Craig | L1 | BNL | Design | Craig Woody | null | POM02.1.03 | Yes | 2019 | A | 1.03 | 16710 | 003 | 1.03B | 03 | yes | 1 | 1 |  |  |  |  |  |
| S156510 |  | Actuals - Nonlabor - sPHENIX EMCal FY19M8 |  | 166d | 2018-10-01 A | 2019-05-31 A | S156500 | 100% |  |  | Actual Nonlabor [634129 h] | 699,611.97 | 190315 DurType to align with EVT | S156500 | 100 | S339145 | S156510 | CA | Completed | A-OPC | Woody, Craig | M1 | BNL | Design | Craig Woody | OPC | POM02.1.03 | Yes | 2019 | A | 1.03 | 16702 | 003 | 1.03A | 03 | yes | 1 | 1 | UDF_G3 |  |  |  |  |
|  | 01 | **EMCAL Block Fabrication** |  |  | 2017-03-31 | 2022-01-07 |  |  |  |  |  |  |  |  |  |  |  |  |  |  |  |  |  |  |  |  |  |  |  |  |  |  |  |  |  |  |  |  |  |  |  |  |  |
|  | 01 | **EMCAL Prototype V2.1 Block Production** |  |  | 2017-04-13 | 2017-10-16 |  |  |  |  |  |  |  |  |  |  |  |  |  |  |  |  |  |  |  |  |  |  |  |  |  |  |  |  |  |  |  |  |  |  |  |  |  |
| S156600 |  | Order screens for v2.1 prototype |  | 25d | 2017-04-13 A | 2017-05-17 A | S180900 FS+10d | 100% |  |  |  |  |  | S156600 | 100 | S146900 |  | NOCA | Completed |  | Woody, Craig |  | UIUC | Procurement | Craig Woody |  | POM02.1.03.01.01 |  |  |  |  |  |  |  | 01 | yes | 02 | 2 |  | S146900 | BNL | EMCal v2.1 |  |
| S156700 |  | Order screens for v2.1 prototype |  | 25d | 2017-04-13 A | 2017-05-17 A | S180900 FS+10d | 100% |  |  |  |  |  | S156700 | 100 | S147000 |  | NOCA | Completed |  | Woody, Craig |  | UIUC | Procurement | Craig Woody |  | POM02.1.03.01.01 |  |  |  |  |  |  |  | 01 | yes | 02 | 2 |  | S147000 | BNL | EMCal v2.1 |  |
| S156800 |  | Fabricate molds for v2.1 prototype |  | 20d | 2017-05-18 A | 2017-06-15 A | S180800 FS+40d | 100% |  |  |  |  |  | S156800 | 100 | S147100 |  | NOCA | Completed |  | Woody, Craig |  | UIUC | Fab & Assy | Craig Woody |  | POM02.1.03.01.01 |  |  |  |  |  |  |  | 01 | yes | 02 | 4 |  | S147100 | BNL | EMCal v2.1 |  |
| S156900 |  | Fabricate blocks for v2.1 prototype |  | 79d | 2017-06-16 A | 2017-10-06 A | S156600, S156800, S156700 | 100% |  |  |  |  |  | S156900 | 100 | S147200 |  | NOCA | Completed |  | Woody, Craig |  | UIUC | Fab & Assy | Craig Woody |  | POM02.1.03.01.01 |  |  |  |  |  |  |  | 01 | yes | 02 | 4 |  | S147200 | BNL | EMCal v2.1 |  |
| S157000 |  | Ship v2.1 blocks 1-16 to BNL |  | 5d | 2017-10-10 A | 2017-10-16 A | S156900 | 100% |  |  |  |  |  | S157000 | 100 | S147300 |  | NOCA | Completed |  | Woody, Craig |  | UIUC | Fab & Assy | Craig Woody |  | POM02.1.03.01.01 |  |  |  |  |  |  |  | 01 | yes | 02 | 4 |  | S147300 | BNL | EMCal v2.1 |  |
|  | 02 | **EMCAL Preproduction Prototype Block Production** |  |  | 2017-03-31 | 2020-10-19 |  |  |  |  |  |  |  |  |  |  |  |  |  |  |  |  |  |  |  |  |  |  |  |  |  |  |  |  |  |  |  |  |  |  |  |  |  |
|  | 01 | **Order Material for preproduction prototype Sector 0** |  |  | 2017-03-31 | 2018-05-20 |  |  |  |  |  |  |  |  |  |  |  |  |  |  |  |  |  |  |  |  |  |  |  |  |  |  |  |  |  |  |  |  |  |  |  |  |  |
| S158100 |  | Set up factory for preproduction prototype Sector 0 |  | 90d | 2017-03-31 A | 2017-08-07 A | S100090 SS+41d | 100% |  |  |  |  |  | S158100 | 100 | S148400 |  | NOCA | Completed |  | Sickles, Anne |  | UIUC | Fab & Assy | Craig Woody |  | POM02.1.03.01.02.01 |  |  |  |  |  |  |  | 01 | yes | 02 | 4 |  | S148400 | UIUC | EMCal Prepro Sector |  |
| S157300 |  | Order fibers preproduction prototype Sector 0 |  | 90d | 2017-04-06 A | 2017-08-11 A | S100090 SS+45d | 100% |  |  |  |  |  | S157300 | 100 | S147600 |  | NOCA | Completed |  | Sickles, Anne |  | UIUC | Procurement | Craig Woody |  | POM02.1.03.01.02.01 |  |  |  |  |  |  |  | 01 | yes | 02 | 2 |  | S147600 | UIUC | EMCal Prepro Sector |  |
| S157400 |  | Order fibers preproduction prototype Sector 0 |  | 90d | 2017-04-06 A | 2017-08-11 A | S100090 SS+45d | 100% |  |  |  |  |  | S157400 | 100 | S147700 |  | NOCA | Completed |  | Sickles, Anne |  | UIUC | Procurement | Craig Woody |  | POM02.1.03.01.02.01 |  |  |  |  |  |  |  | 01 | yes | 02 | 2 |  | S147700 | UIUC | EMCal Prepro Sector |  |
| S157500 |  | Order screens for preproduction prototype Sector 0 |  | 135d | 2017-04-20 A | 2017-10-31 A | S182400 FS+10d | 100% |  |  |  |  |  | S157500 | 100 | S147800 |  | NOCA | Completed |  | Sickles, Anne |  | UIUC | Procurement | Craig Woody |  | POM02.1.03.01.02.01 |  |  |  |  |  |  |  | 01 | yes | 02 | 2 |  | S147800 | UIUC | EMCal Prepro Sector |  |
| S157600 |  | Order screens for preproduction prototype Sector 0 |  | 135d | 2017-04-20 A | 2017-10-31 A | S182400 FS+10d | 100% |  |  |  |  |  | S157600 | 100 | S147900 |  | NOCA | Completed |  | Sickles, Anne |  | UIUC | Procurement | Craig Woody |  | POM02.1.03.01.02.01 |  |  |  |  |  |  |  | 01 | yes | 02 | 2 |  | S147900 | UIUC | EMCal Prepro Sector |  |
| S157100 |  | Order W powder preproduction prototype Sector 0 Labor |  | 40d | 2017-06-09 A | 2017-08-04 A | S100090 SS+90d | 100% |  |  |  |  |  | S157100 | 100 | S147400 |  | NOCA | Completed |  | Sickles, Anne |  | UIUC | Procurement | Craig Woody |  | POM02.1.03.01.02.01 |  |  |  |  |  |  |  | 01 | yes | 02 | 2 |  | S147400 | UIUC | EMCal Prepro Sector |  |
| S157200 |  | Order W powder preproduction prototype Sector 0 M&S |  | 40d | 2017-06-09 A | 2017-08-04 A | S100090 SS+90d | 100% |  |  |  |  |  | S157200 | 100 | S147500 |  | NOCA | Completed |  | Sickles, Anne |  | UIUC | Procurement | Craig Woody |  | POM02.1.03.01.02.01 |  |  |  |  |  |  |  | 01 | yes | 02 | 2 |  | S147500 | UIUC | EMCal Prepro Sector |  |
| S157700 |  | Order epoxy for preproduction prototype Sector 0 |  | 20d | 2017-07-24 A | 2017-08-18 A | S100090 SS+120d | 100% |  |  |  |  |  | S157700 | 100 | S148000 |  | NOCA | Completed |  | Sickles, Anne |  | UIUC | Procurement | Craig Woody |  | POM02.1.03.01.02.01 |  |  |  |  |  |  |  | 01 | yes | 02 | 2 |  | S148000 | UIUC | EMCal Prepro Sector |  |
| S157800 |  | Order epoxy for preproduction prototype Sector 0 |  | 20d | 2017-07-24 A | 2017-08-18 A | S100090 SS+120d | 100% |  |  |  |  |  | S157800 | 100 | S148100 |  | NOCA | Completed |  | Sickles, Anne |  | UIUC | Procurement | Craig Woody |  | POM02.1.03.01.02.01 |  |  |  |  |  |  |  | 01 | yes | 02 | 2 |  | S148100 | UIUC | EMCal Prepro Sector |  |
| S157900 |  | Order parts and fabricate molds for preproduction prototype Sector 0 M&S |  | 20d | 2017-07-24 A | 2017-08-18 A | S182300 FS+80d | 100% |  |  |  |  |  | S157900 | 100 | S148200 |  | NOCA | Completed |  | Sickles, Anne |  | UIUC | Fab & Assy | Craig Woody |  | POM02.1.03.01.02.01 |  |  |  |  |  |  |  | 01 | yes | 02 | 4 |  | S148200 | UIUC | EMCal Prepro Sector |  |
| S158000 |  | Order parts and fabricate molds for preproduction prototype Sector 0 Labor |  | 20d | 2017-07-24 A | 2017-08-18 A | S182300 FS+80d | 100% |  |  |  |  |  | S158000 | 100 | S148300 |  | NOCA | Completed |  | Sickles, Anne |  | UIUC | Procurement | Craig Woody |  | POM02.1.03.01.02.01 |  |  |  |  |  |  |  | 01 | yes | 02 | 2 |  | S148300 | UIUC | EMCal Prepro Sector |  |
| S158200 |  | Prepare fiber assemblies for preproduction prototype Sector 0 |  | 44d | 2018-03-20 A | 2018-05-20 A | S157500, S157600, S160800 | 100% | 2018-03-20 | 2018-05-18 |  |  |  | S158200 | 100 | S148500 |  | NOCA | Completed |  | Sickles, Anne | L4 | UIUC | Fab & Assy | Craig Woody | null | POM02.1.03.01.02.01 |  |  | C |  |  |  |  | 01 | yes | 02 | 4 |  | S148500 | UIUC | EMCal Prepro Sector | 180413 ELM status per GRY |
| S158201 |  | Preliminary Design Review - EMCal Blocks | milestone | 0d | 2018-03-20 A | 2018-03-20 A | S158200 FF | 100% |  |  |  |  | 190522 IVS new act. | S158200 | 100 | S148500 |  | NOCA | Completed |  | Sickles, Anne | L4 | UIUC | Fab & Assy | Craig Woody | null | POM02.1.03.01.02.01 |  |  | C |  |  | 004 |  | 01 | yes | 02 | 4 |  | S148500 | UIUC | EMCal Prepro Sector | 180413 ELM status per GRY |

Notes:
- S156200: BNL_UDF_Old Activity Name 181221: Actuals - Labor - sPHENIX EMCal FY17
- S156400: BNL_UDF_Old Activity Name 181221: Actuals - Nonlabor - sPHENIX EMCal FY17
- S156300: BNL_UDF_Old Activity Name 181221: Actuals - Labor - sPHENIX EMCal FY18
- S156500: BNL_UDF_Old Activity Name 181221: Actuals - Nonlabor - sPHENIX EMCal FY18
- S1001879: BNL_UDF_Old Activity Name 181221: Actuals - Nonlabor - sPHENIX EMCal FY18
- S156310: BNL_UDF_Old Activity Name 181221: Actuals - Labor - sPHENIX EMCal FY18
- S156510: BNL_UDF_Old Activity Name 181221: Actuals - Nonlabor - sPHENIX EMCal FY18
- S156600: BNL_UDF_Old Activity Name 181221: Order screens for v2.1 prototype
- S156700: BNL_UDF_Old Activity Name 181221: Order screens for v2.1 prototype
- S156800: BNL_UDF_Old Activity Name 181221: Fabricate molds for v2.1 prototype
- S156900: BNL_UDF_Old Activity Name 181221: Fabricate blocks for v2.1 prototype
- S157000: BNL_UDF_Old Activity Name 181221: Ship v2.1 blocks 1-16 to BNL
- S158100: BNL_UDF_Old Activity Name 181221: Set up factory for preproduction prototype Sector 0
- S157300: BNL_UDF_Old Activity Name 181221: Order fibers preproduction prototype Sector 0
- S157400: BNL_UDF_Old Activity Name 181221: Order fibers preproduction prototype Sector 0
- S157500: BNL_UDF_Old Activity Name 181221: Order screens for preproduction prototype Sector 0
- S157600: BNL_UDF_Old Activity Name 181221: Order screens for preproduction prototype Sector 0
- S157100: BNL_UDF_Old Activity Name 181221: Order W powder preproduction prototype Sector 0 Labor
- S157200: BNL_UDF_Old Activity Name 181221: Order W powder preproduction prototype Sector 0 M&S
- S157700: BNL_UDF_Old Activity Name 181221: Order epoxy for preproduction prototype Sector 0
- S157800: BNL_UDF_Old Activity Name 181221: Order epoxy for preproduction prototype Sector 0
- S157900: BNL_UDF_Old Activity Name 181221: Order parts and fabricate molds for preproduction prototype Sector 0 M&S
- S158000: BNL_UDF_Old Activity Name 181221: Order parts and fabricate molds for preproduction prototype Sector 0 Labor
- S158200: BNL_UDF_Old Activity Name 181221: Prepare fiber assemblies for preproduction prototype Sector 0
- S158201: BNL_UDF_Old Activity Name 181221: Prepare fiber assemblies for preproduction prototype Sector 0

| ID | WBS | Activity | Duration | Start | Finish | Predecessors | Complete | BNL_UDF_Temp Text 01 | BNL_UDF_Percent Complete | BNL_UDF_OPC TEC (deprecated) | BNL_UDF_Temp Date 01 | BNL_UDF_Old Activity ID 181221 | RG Check | BNL_Activity Status | BNL_Estimator | BNL_Cost Basis | BNL_Location | BNL_EDIA | BNL_CAM | BNL_Institution | BNL_R&D FY18-19 | BNL_OPC TEC (deprecated) | BNL_WBS | BNL_EVT | BNL_WBS_Hierarchical | Completed | PMP Summary Part1 | PMP Summary Part2 | BNL_Split Activity | BNL_Fund Source | BNL_Proc Sig Phase | BNL_Proc Sig | BNL_Account Number | BNL_PCR ID | Cost = Awarded Proc or Mgmt | BNL_UDF_Adhoc Comments | BNL_DOE OPC |
| --- | --- | --- | --- | --- | --- | --- | --- | --- | --- | --- | --- | --- | --- | --- | --- | --- | --- | --- | --- | --- | --- | --- | --- | --- | --- | --- | --- | --- | --- | --- | --- | --- | --- | --- | --- | --- | --- |
|  | 02 | **Fabricate blocks for preproduction prototype Sector 0** |  | 2018-06-21 | 2019-05-03 |  |  |  |  |  |  |  |  |  |  |  |  |  |  |  |  |  |  |  |  |  |  |  |  |  |  |  |  |  |  |  |  |
| S158300 |  | Fabricate & test batch No. 1 of 8 batches of 12 blocks for preproduction prototype Sector 0 | 64d | 2018-06-21 A | 2018-09-20 A | S157100, S157300, S157500, S157700, S157900, S158100, S157200, S157400, S157600, S157800, S158000, S158200 SS+5d | 100% | S158300 | 100 | S148600 | 2018-07-15 | S148600 | NOCA | Completed | Sickles, Anne | L4 | UIUC | Fab & Assy | Craig Woody | UIUC | EMCal Prepro Sector | null | POM02.1.03.01.02.02 | C | 02 | yes | 02 | 4 |  |  |  |  |  |  |  |  |  |
| S158400 |  | Fabricate & test batch No. 2 of 8 batches of 12 blocks for preproduction prototype Sector 0 FY18 | 27d | 2018-08-22 A | 2018-09-28 A | S158300 | 100% | S158400 | 100 | S148700 |  | S148700 | NOCA | Completed | Sickles, Anne | L4 | UIUC | Fab & Assy | Craig Woody | UIUC | EMCal Prepro Sector | null | POM02.1.03.01.02.02 |  | 02 | yes | 02 | 4 | FY18 |  |  |  |  |  |  |  |  |
| S158500 |  | Fabricate & test batch No. 2 of 8 batches of 12 blocks for preproduction prototype Sector 0 FY19 | 33d | 2018-10-01 A | 2018-11-16 A | S158400, S179300 SS | 100% | S158500 | 100 | S148700 |  | S148725 | NOCA | Completed | Sickles, Anne | L4 | UIUC | Fab & Assy | Craig Woody | UIUC | EMCal Prepro Sector | null | POM02.1.03.01.02.02 | C | 02 | yes | 02 | 4 | FY19 | A-OPC | PP6 | MP203200 | 16702 | 003 | Yes |  |  |
| S158600 |  | Fabricate & test batch No. 3 of 8 batches of 12 blocks for preproduction prototype Sector 0 | 24d | 2018-10-15 A | 2018-11-16 A | S158500 SS, S179300 SS | 100% | S158600 | 100 | S148800 |  | S148800 | NOCA | Completed | Sickles, Anne | L4 | UIUC | Fab & Assy | Craig Woody | UIUC | EMCal Prepro Sector | null | POM02.1.03.01.02.02 | C | 02 | yes | 02 | 4 |  | A-OPC | PP6 | MP203200 | 16702 | 003 | Yes |  |  |
| S158700 |  | Fabricate & test batch No. 4 of 8 batches of 12 blocks for preproduction prototype Sector 0 | 80d | 2018-11-08 A | 2019-03-08 A | S158600 SS, S179300 SS | 100% | S158700 | 50 | S148900 | 2019-03-08 | S148900 | NOCA | Completed | Sickles, Anne | L4 | UIUC | Fab & Assy | Craig Woody | UIUC | EMCal Prepro Sector | null | POM02.1.03.01.02.02 | C | 02 | yes | 02 | 4 |  | A-OPC | PP6 | MP203200 | 16702 | 003 | Yes |  |  |
| S158800 |  | Fabricate & test batch No. 5 of 8 batches of 12 blocks for preproduction prototype Sector 0 | 57d | 2018-11-16 A | 2019-02-11 A | S158700 SS, S179300 SS | 100% | S158800 | 50 | S149000 | 2019-03-19 | S149000 | NOCA | Completed | Sickles, Anne | L4 | UIUC | Fab & Assy | Craig Woody | UIUC | EMCal Prepro Sector | null | POM02.1.03.01.02.02 | C | 02 | yes | 02 | 4 |  | A-OPC | PP6 | MP203200 | 16702 | 003 | Yes |  |  |
| S158900 |  | Fabricate & test batch No. 6 of 8 batches of 12 blocks for preproduction prototype Sector 0 | 16d | 2019-03-20 A | 2019-04-10 A | S158800, S179300 SS | 100% | S158900 | 0 | S149100 |  | S149100 | NOCA | Completed | Sickles, Anne | L4 | UIUC | Fab & Assy | Craig Woody | UIUC | EMCal Prepro Sector | null | POM02.1.03.01.02.02 | C | 02 | yes | 02 | 4 |  | A-OPC | PP6 | MP203200 | 16702 | 003 | Yes |  |  |
| S159000 |  | Fabricate & test batch No. 7 of 8 batches of 12 blocks for preproduction prototype Sector 0 | 28d | 2019-03-27 A | 2019-05-03 A | S158900, S179300 SS | 100% | S159000 | 0 | S149200 |  | S149200 | NOCA | Completed | Sickles, Anne | L4 | UIUC | Fab & Assy | Craig Woody | UIUC | EMCal Prepro Sector | null | POM02.1.03.01.02.02 | C | 02 | yes | 02 | 4 |  | A-OPC | PP6 | MP203200 | 16702 | 003 | Yes |  |  |
| S159100 |  | Fabricate & test batch No. 8 of 8 batches of 12 blocks for preproduction prototype Sector 0 | 23d | 2019-04-03 A | 2019-05-03 A | S159000, S158200, S179300 SS, S158201 | 100% | S159100 | 0 | S149300 |  | S149300 | NOCA | Completed | Sickles, Anne | L4 | UIUC | Fab & Assy | Craig Woody | UIUC | EMCal Prepro Sector | null | POM02.1.03.01.02.02 | C | 02 | yes | 02 | 4 |  | A-OPC | PP6 | MP203200 | 16702 | 003 | Yes |  |  |
|  | 03 | **Pack and ship preproduction blocks to BNL Sector 0** |  | 2018-10-02 | 2019-05-03 |  |  |  |  |  |  |  |  |  |  |  |  |  |  |  |  |  |  |  |  |  |  |  |  |  |  |  |  |  |  |  |  |
| S159200 |  | Ship batch No. 1 of 8 batches of 12 preproduction prototype blocks for Sector 0 to BNL - Purchased Services | 5d | 2018-10-02 A | 2018-10-09 A | S158300, S179300 SS | 100% | S159200 | 100 | S149400 |  | S149400 | NOCA | Completed | Sickles, Anne | L4 | UIUC | Fab & Assy | Craig Woody | UIUC | EMCal Prepro Sector | null | POM02.1.03.01.02.03 | C | 03 | yes | 02 | 4 |  | A-OPC | PP6 | MP203200 | 16702 | 003 | Yes |  |  |
| S159300 |  | Ship batch No. 1 of 8 batches of 12 preproduction prototype blocks for Sector 0 to BNL - M&S | 5d | 2018-10-02 A | 2018-10-09 A | S158300, S179300 SS | 100% | S159300 | 100 | S149500 |  | S149500 | NOCA | Completed | Sickles, Anne | M4 | UIUC | Fab & Assy | Craig Woody | UIUC | EMCal Prepro Sector | OPC | POM02.1.03.01.02.03 | C | 03 | yes | 02 | 4 |  | A-OPC | PP6 | MP203200 | 16702 | 003 | Yes | 180410 ELM pred/succ per GRY | OPC001300 |
| S159400 |  | Ship batch No. 2 of 8 batches of 12 preproduction prototype blocks for Sector 0 to BNL - Purchased Services | 5d | 2018-10-15 A | 2018-10-19 A | S158500 SS, S179300 SS | 100% | S159400 | 100 | S149600 |  | S149600 | NOCA | Completed | Sickles, Anne | L4 | UIUC | Fab & Assy | Craig Woody | UIUC | EMCal Prepro Sector | null | POM02.1.03.01.02.03 | C | 03 | yes | 02 | 4 |  | A-OPC | PP6 | MP203200 | 16702 | 003 | Yes | 180410 ELM pred/succ per GRY |  |
| S159500 |  | Ship batch No. 2 of 8 batches of 12 preproduction prototype blocks for Sector 0 to BNL - M&S | 5d | 2018-10-15 A | 2018-10-19 A | S158500 SS, S179300 SS | 100% | S159500 | 100 | S149700 |  | S149700 | NOCA | Completed | Sickles, Anne | M4 | UIUC | Fab & Assy | Craig Woody | UIUC | EMCal Prepro Sector | OPC | POM02.1.03.01.02.03 | C | 03 | yes | 02 | 4 |  | A-OPC | PP6 | MP203200 | 16702 | 003 | Yes | 180410 ELM pred/succ per GRY | OPC001300 |
| S159600 |  | Ship batch No. 3 of 8 batches of 12 preproduction prototype blocks for Sector 0 to BNL - Purchased Services | 5d | 2018-10-22 A | 2018-10-26 A | S158600 SS, S179300 SS | 100% | S159600 | 100 | S149800 |  | S149800 | NOCA | Completed | Sickles, Anne | L4 | UIUC | Fab & Assy | Craig Woody | UIUC | EMCal Prepro Sector | null | POM02.1.03.01.02.03 | C | 03 | yes | 02 | 4 |  | A-OPC | PP6 | MP203200 | 16702 | 003 | Yes | 180410 ELM pred/succ per GRY |  |
| S159700 |  | Ship batch No. 3 of 8 batches of 12 preproduction prototype blocks for Sector 0 to BNL - M&S | 5d | 2018-10-22 A | 2018-10-26 A | S158600 SS, S179300 SS | 100% | S159700 | 100 | S149900 |  | S149900 | NOCA | Completed | Sickles, Anne | M4 | UIUC | Fab & Assy | Craig Woody | UIUC | EMCal Prepro Sector | OPC | POM02.1.03.01.02.03 | C | 03 | yes | 02 | 4 |  | A-OPC | PP6 | MP203200 | 16702 | 003 | Yes | 180410 ELM pred/succ per GRY | OPC001300 |
| S159800 |  | Ship batch No. 4 of 8 batches of 12 preproduction prototype blocks for Sector 0 to BNL - Purchased Services | 15d | 2019-03-11 A | 2019-03-29 A | S158700, S179300 SS | 100% | S159800 | 0 | S150000 |  | S150000 | NOCA | Completed | Sickles, Anne | L4 | UIUC | Fab & Assy | Craig Woody | UIUC | EMCal Prepro Sector | null | POM02.1.03.01.02.03 | C | 03 | yes | 02 | 4 |  | A-OPC | PP6 | MP203200 | 16702 | 003 | Yes | 180410 ELM pred/succ per GRY |  |
| S159900 |  | Ship batch No. 4 of 8 batches of 12 preproduction prototype blocks for Sector 0 to BNL - M&S | 15d | 2019-03-11 A | 2019-03-29 A | S158700, S179300 SS | 100% | S159900 | 0 | S150100 |  | S150100 | NOCA | Completed | Sickles, Anne | M4 | UIUC | Fab & Assy | Craig Woody | UIUC | EMCal Prepro Sector | OPC | POM02.1.03.01.02.03 | F | 03 | yes | 02 | 4 |  | A-OPC | PP6 | MP203200 | 16702 | 003 | Yes | 180410 ELM pred/succ per GRY | OPC001300 |
| S160000 |  | Ship batch No. 5 of 8 batches of 12 preproduction prototype blocks for Sector 0 to BNL - Purchased Services | 16d | 2019-03-20 A | 2019-04-10 A | S158800, S179300 SS | 100% | S160000 | 0 | S150200 |  | S150200 | NOCA | Completed | Sickles, Anne | L4 | UIUC | Fab & Assy | Craig Woody | UIUC | EMCal Prepro Sector | null | POM02.1.03.01.02.03 | C | 03 | yes | 02 | 4 |  | A-OPC | PP6 | MP203200 | 16702 | 003 | Yes | 180410 ELM pred/succ per GRY |  |
| S160100 |  | Ship batch No. 5 of 8 batches of 12 preproduction prototype blocks for Sector 0 to BNL - M&S | 16d | 2019-03-20 A | 2019-04-10 A | S158800, S179300 SS | 100% | S160100 | 0 | S150300 |  | S150300 | NOCA | Completed | Sickles, Anne | M4 | UIUC | Fab & Assy | Craig Woody | UIUC | EMCal Prepro Sector | OPC | POM02.1.03.01.02.03 | F | 03 | yes | 02 | 4 |  | A-OPC | PP6 | MP203200 | 16702 | 003 | Yes | 180410 ELM pred/succ per GRY | OPC001300 |
| S160200 |  | Ship batch No. 6 of 8 batches of 12 preproduction prototype blocks for Sector 0 to BNL - Purchased Services | 11d | 2019-03-27 A | 2019-04-10 A | S158900, S179300 SS | 100% | S160200 | 0 | S150400 |  | S150400 | NOCA | Completed | Sickles, Anne | L4 | UIUC | Fab & Assy | Craig Woody | UIUC | EMCal Prepro Sector | null | POM02.1.03.01.02.03 | C | 03 | yes | 02 | 4 |  | A-OPC | PP6 | MP203200 | 16702 | 003 | Yes | 180410 ELM pred/succ per GRY |  |
| S160300 |  | Ship batch No. 6 of 8 batches of 12 preproduction prototype blocks for Sector 0 to BNL - M&S | 11d | 2019-03-27 A | 2019-04-10 A | S158900, S179300 SS | 100% | S160300 | 0 | S150500 |  | S150500 | NOCA | Completed | Sickles, Anne | M4 | UIUC | Fab & Assy | Craig Woody | UIUC | EMCal Prepro Sector | OPC | POM02.1.03.01.02.03 | F | 03 | yes | 02 | 4 |  | A-OPC | PP6 | MP203200 | 16702 | 003 | Yes | 180410 ELM pred/succ per GRY | OPC001300 |
| S160400 |  | Ship batch No. 7 of 8 batches of 12 preproduction prototype blocks for Sector 0 to BNL - Purchased Services | 23d | 2019-04-03 A | 2019-05-03 A | S159000, S179300 SS | 100% | S160400 | 0 | S150600 |  | S150600 | NOCA | Completed | Sickles, Anne | L4 | UIUC | Fab & Assy | Craig Woody | UIUC | EMCal Prepro Sector | null | POM02.1.03.01.02.03 | C | 03 | yes | 02 | 4 |  | A-OPC | PP6 | MP203200 | 16702 | 003 | Yes | 180410 ELM pred/succ per GRY |  |
| S160500 |  | Ship batch No. 7 of 8 batches of 12 preproduction prototype blocks for Sector 0 to BNL - M&S | 23d | 2019-04-03 A | 2019-05-03 A | S159000, S179300 SS | 100% | S160500 | 0 | S150700 |  | S150700 | NOCA | Completed | Sickles, Anne | M4 | UIUC | Fab & Assy | Craig Woody | UIUC | EMCal Prepro Sector | OPC | POM02.1.03.01.02.03 | F | 03 | yes | 02 | 4 |  | A-OPC | PP6 | MP203200 | 16702 | 003 | Yes | 180410 ELM pred/succ per GRY | OPC001300 |
| S160600 |  | Ship batch No. 8 of 8 batches of 12 preproduction prototype blocks for Sector 0 to BNL - Purchased Services | 15d | 2019-04-15 A | 2019-05-03 A | S159100, S179300 SS | 100% | S160600 | 0 | S150800 |  | S150800 | NOCA | Completed | Sickles, Anne | L4 | UIUC | Fab & Assy | Craig Woody | UIUC | EMCal Prepro Sector | null | POM02.1.03.01.02.03 | C | 03 | yes | 02 | 4 |  | A-OPC | PP6 | MP203200 | 16702 | 003 | Yes | 180410 ELM pred/succ per GRY |  |
| S160700 |  | Ship batch No. 8 of 8 batches of 12 preproduction prototype blocks for Sector 0 to BNL - M&S | 15d | 2019-04-15 A | 2019-05-03 A | S159100, S179300 SS | 100% | S160700 | 0 | S150900 |  | S150900 | NOCA | Completed | Sickles, Anne | M4 | UIUC | Fab & Assy | Craig Woody | UIUC | EMCal Prepro Sector | OPC | POM02.1.03.01.02.03 | F | 03 | yes | 02 | 4 |  | A-OPC | PP6 | MP203200 | 16702 | 003 | Yes |  | OPC001300 |

Notes:
- S158300: BNL_UDF_Old Activity Name 181221: Fabricate & test batch No. 1 of 8 batches of 12 blocks for preproduction prototype Sector 0
- S158400: BNL_UDF_Old Activity Name 181221: Fabricate & test batch No. 2 of 8 batches of 12 blocks for preproduction prototype Sector 0 FY18
- S158500: BNL_UDF_Old Activity Name 181221: Fabricate & test batch No. 2 of 8 batches of 12 blocks for preproduction prototype Sector 0 FY19
- S158600: BNL_UDF_Old Activity Name 181221: Fabricate & test batch No. 3 of 8 batches of 12 blocks for preproduction prototype Sector 0
- S158700: BNL_UDF_Old Activity Name 181221: Fabricate & test batch No. 4 of 8 batches of 12 blocks for preproduction prototype Sector 0
- S158800: BNL_UDF_Old Activity Name 181221: Fabricate & test batch No. 5 of 8 batches of 12 blocks for preproduction prototype Sector 0
- S158900: BNL_UDF_Old Activity Name 181221: Fabricate & test batch No. 6 of 8 batches of 12 blocks for preproduction prototype Sector 0
- S159000: BNL_UDF_Old Activity Name 181221: Fabricate & test batch No. 7 of 8 batches of 12 blocks for preproduction prototype Sector 0
- S159100: BNL_UDF_Old Activity Name 181221: Fabricate & test batch No. 8 of 8 batches of 12 blocks for preproduction prototype Sector 0
- S159200: BNL_UDF_Old Activity Name 181221: Ship batch No. 1 of 8 batches of 12 preproduction prototype blocks for Sector 0 to BNL - Labor
- S159300: BNL_UDF_Old Activity Name 181221: Ship batch No. 1 of 8 batches of 12 preproduction prototype blocks for Sector 0 to BNL - M&S
- S159400: BNL_UDF_Old Activity Name 181221: Ship batch No. 2 of 8 batches of 12 preproduction prototype blocks for Sector 0 to BNL - Labor
- S159500: BNL_UDF_Old Activity Name 181221: Ship batch No. 2 of 8 batches of 12 preproduction prototype blocks for Sector 0 to BNL - M&S
- S159600: BNL_UDF_Old Activity Name 181221: Ship batch No. 3 of 8 batches of 12 preproduction prototype blocks for Sector 0 to BNL - Labor
- S159700: BNL_UDF_Old Activity Name 181221: Ship batch No. 3 of 8 batches of 12 preproduction prototype blocks for Sector 0 to BNL - M&S
- S159800: BNL_UDF_Old Activity Name 181221: Ship batch No. 4 of 8 batches of 12 preproduction prototype blocks for Sector 0 to BNL - Labor
- S159900: BNL_UDF_Old Activity Name 181221: Ship batch No. 4 of 8 batches of 12 preproduction prototype blocks for Sector 0 to BNL - M&S
- S160000: BNL_UDF_Old Activity Name 181221: Ship batch No. 5 of 8 batches of 12 preproduction prototype blocks for Sector 0 to BNL - Labor
- S160100: BNL_UDF_Old Activity Name 181221: Ship batch No. 5 of 8 batches of 12 preproduction prototype blocks for Sector 0 to BNL - M&S
- S160200: BNL_UDF_Old Activity Name 181221: Ship batch No. 6 of 8 batches of 12 preproduction prototype blocks for Sector 0 to BNL - Labor
- S160300: BNL_UDF_Old Activity Name 181221: Ship batch No. 6 of 8 batches of 12 preproduction prototype blocks for Sector 0 to BNL - M&S
- S160400: BNL_UDF_Old Activity Name 181221: Ship batch No. 7 of 8 batches of 12 preproduction prototype blocks for Sector 0 to BNL - Labor
- S160500: BNL_UDF_Old Activity Name 181221: Ship batch No. 7 of 8 batches of 12 preproduction prototype blocks for Sector 0 to BNL - M&S
- S160600: BNL_UDF_Old Activity Name 181221: Ship batch No. 8 of 8 batches of 12 preproduction prototype blocks for Sector 0 to BNL - Labor
- S160700: BNL_UDF_Old Activity Name 181221: Ship batch No. 8 of 8 batches of 12 preproduction prototype blocks for Sector 0 to BNL - M&S

| ID | WBS | Activity | Type | Duration | Start | Finish | Predecessors | Complete | Planned start | Planned finish | Resources | Cost | BNL_UDF_Temp Text 01 | BNL_UDF_Percent Complete | BNL_UDF_OPC TEC (deprecated) | BNL_UDF_Old Activity ID 181221 | RG Check | BNL_Activity Status | BNL_Estimator | BNL_Location | BNL_EDIA | BNL_CAM | BNL_Institution | BNL_R&D FY18-19 | BNL_WBS | BNL_LLPs and Precursors | BNL_WBS_Hierarchical | Completed | PMP Summary Part1 | PMP Summary Part2 | BNL_UDF_Status Comments | BNL_Proc Sig Phase | BNL_Proc Sig | BNL_DOE OPC | BNL_PCR ID | Cost = Awarded Proc or Mgmt | BNL_Cost Basis | BNL_OPC TEC (deprecated) | BNL_EVT | BNL_Fund Source | BNL_Milestone Level | BNL_Obligation | BNL_UDF_Temp Date 01 | BNL_Split Activity | BNL_Account Number | SPH Proc Register | Additional EVT documentation required | BNL_Cobra WP | BNL_Master Control Account | BNL_Cobra Control Account | Indicator - Procurement | Indicator - Float |
| --- | --- | --- | --- | --- | --- | --- | --- | --- | --- | --- | --- | --- | --- | --- | --- | --- | --- | --- | --- | --- | --- | --- | --- | --- | --- | --- | --- | --- | --- | --- | --- | --- | --- | --- | --- | --- | --- | --- | --- | --- | --- | --- | --- | --- | --- | --- | --- | --- | --- | --- | --- | --- |
|  | 04 | **Order Material for EMCal Block Preproduction** |  |  | 2017-12-18 | 2020-03-30 |  |  |  |  |  |  |  |  |  |  |  |  |  |  |  |  |  |  |  |  |  |  |  |  |  |  |  |  |  |  |  |  |  |  |  |  |  |  |  |  |  |  |  |  |  |  |
| S160800 |  | Establish contract for EMCAL Prepro Sectors 1-12 blocks with UIUC |  | 119d | 2017-12-18 A | 2018-06-07 A | S100340 FS+21d | 100% |  |  |  |  | S160800 | 100 | S151000 | S151000 | NOCA | Completed | Sickles, Anne | UIUC | Procurement | Craig Woody | UIUC | EMCal Prepro Sectors 1-12 | POM02.1.03.01.02.04 | Pre-1 | 04 | yes | 02 | 2 |  |  |  |  |  |  |  |  |  |  |  |  |  |  |  |  |  |  |  |  |  |  |
| S163200 |  | Order screens for EMCal Prepro Sectors 1-12 & 13-64 Blocks - Provide Requirements to Procurement |  | 39d | 2018-04-12 A | 2018-06-06 A | S160800 | 100% |  |  |  |  | S163200 | 100 | S153100 | S153100 | NOCA | Completed | Sickles, Anne | UIUC | Procurement | Craig Woody | UIUC | EMCal Prepro Sectors 1-12 | POM02.1.03.01.02.04 |  | 04 | yes | 02 | 2 | 190316 ELM add proc strg nos | PP1 | MP202600 | OPC001300 | 003 | Yes |  |  |  |  |  |  |  |  |  |  |  |  |  |  |  |  |
| S164100 |  | Order epoxy for EMCal Prepro Sectors 1-12 Blocks - Provide Requirements to Procurement |  | 5d | 2018-04-12 A | 2018-04-18 A | S160800 | 100% |  |  |  |  | S164100 | 100 | S153300 | S153300 | NOCA | Completed | Sickles, Anne | UIUC | Procurement | Craig Woody | UIUC | EMCal Prepro Sectors 1-12 | POM02.1.03.01.02.04 |  | 04 | yes | 02 | 2 | 190316 ELM add proc strg nos | PP1 | MP202500 | OPC001300 | 003 | Yes | M3 |  |  |  |  |  |  |  |  |  |  |  |  |  |  |  |
| S165000 |  | Set up factory for EMCal Prepro Sectors 1-12 Blocks - Provide Requirements to Procurement |  | 49d | 2018-04-12 A | 2018-06-20 A | S160800, S179300 SS, OBLG179310 SS | 100% |  |  |  |  | S165000 | 100 | S153700 | S153700 | NOCA | Completed | Sickles, Anne | UIUC | Procurement | Craig Woody | UIUC | EMCal Prepro Sectors 1-12 | POM02.1.03.01.02.04 |  | 04 | yes | 02 | 2 | 190316 ELM add proc strng nos | PP1 | MP202400 |  | 003 | Yes | L4 | null | C |  |  |  |  |  |  |  |  |  |  |  |  |  |
| S163300 |  | Order screens for EMCal Prepro Sectors 1-12 & 13-64 Blocks - Prepare & Send Solicitation |  | 39d | 2018-04-19 A | 2018-06-13 A | S163200 | 100% |  |  |  |  | S163300 | 100 | S153100 | S341920 | NOCA | Completed | Sickles, Anne | UIUC | Procurement | Craig Woody | UIUC | EMCal Prepro Sectors 1-12 | POM02.1.03.01.02.04 |  | 04 | yes | 02 | 2 | 190316 ELM add proc strg nos | PP2 | MP202600 | OPC001300 | 003 | Yes |  |  |  |  |  |  |  |  |  |  |  |  |  |  |  |  |
| S164200 |  | Order epoxy for EMCal Prepro Sectors 1-12 Blocks - Prepare & Send Solicitation |  | 5d | 2018-04-19 A | 2018-04-25 A | S164100 | 100% |  |  |  |  | S164200 | 100 | S153300 | S342360 | NOCA | Completed | Sickles, Anne | UIUC | Procurement | Craig Woody | UIUC | EMCal Prepro Sectors 1-12 | POM02.1.03.01.02.04 |  | 04 | yes | 02 | 2 | 190316 ELM add proc strg nos | PP2 | MP202500 | OPC001300 | 003 | Yes | M3 |  |  |  |  |  |  |  |  |  |  |  |  |  |  |  |
| S163400 |  | Order screens for EMCal Prepro Sectors 1-12 & 13-64 Blocks - Vendor Responses |  | 39d | 2018-04-26 A | 2018-06-20 A | S163300 | 100% |  |  |  |  | S163400 | 100 | S153100 | S341960 | NOCA | Completed | Sickles, Anne | UIUC | Procurement | Craig Woody | UIUC | EMCal Prepro Sectors 1-12 | POM02.1.03.01.02.04 |  | 04 | yes | 02 | 2 | 190316 ELM add proc strg nos | PP3 | MP202600 | OPC001300 | 003 | Yes |  |  |  |  |  |  |  |  |  |  |  |  |  |  |  |  |
| S164300 |  | Order epoxy for EMCal Prepro Sectors 1-12 Blocks - Vendor Responses |  | 5d | 2018-04-26 A | 2018-05-02 A | S164200 | 100% |  |  |  |  | S164300 | 100 | S153300 | S342400 | NOCA | Completed | Sickles, Anne | UIUC | Procurement | Craig Woody | UIUC | EMCal Prepro Sectors 1-12 | POM02.1.03.01.02.04 |  | 04 | yes | 02 | 2 | 190316 ELM add proc strg nos | PP3 | MP202500 | OPC001300 | 003 | Yes | M3 |  |  |  |  |  |  |  |  |  |  |  |  |  |  |  |
| S161800 |  | Procurement Readiness Review - EMCal - Scintillating FIbers (LLP) |  | 0d | 2018-04-30 A | 2018-04-30 A | S100340 FS+41d | 100% |  |  |  |  | S161800 | 100 | S152100 | S152100 | NOCA | Completed | Sickles, Anne | UIUC | Design | Craig Woody | UIUC | EMCal Prepro Sectors 1-12 | POM02.1.03.01.02.04 | Pre-1 | 04 | yes | 1 | 1 | 190415 ELM name per GRY |  |  |  | 004 |  |  |  |  |  |  |  |  |  |  |  |  |  |  |  |  |  |
| S161900 |  | Procure EMCAL fibers for Prepro Sectors 1-12 Blocks - Provide Requirements to Procurement |  | 0d | 2018-05-01 A | 2018-05-01 A | S161800 | 100% |  |  |  |  | S161900 | 100 | S152200 | S152200 | NOCA | Completed | Sickles, Anne | UIUC | Procurement | Craig Woody | UIUC | EMCal Prepro Sectors 1-12 | POM02.1.03.01.02.04 |  | 04 | yes | 02 | 2 |  | PP1 | MP109800 |  |  | Yes |  |  |  |  |  |  |  |  |  |  |  |  |  |  |  |  |
| S164400 |  | Order epoxy for EMCal Prepro Sectors 1-12 Blocks - Vendor Selection |  | 5d | 2018-05-03 A | 2018-05-09 A | S164300 | 100% |  |  |  |  | S164400 | 100 | S153300 | S342440 | NOCA | Completed | Sickles, Anne | UIUC | Procurement | Craig Woody | UIUC | EMCal Prepro Sectors 1-12 | POM02.1.03.01.02.04 |  | 04 | yes | 02 | 2 | 190316 ELM add proc strg nos | PP4 | MP202500 | OPC001300 | 003 | Yes | M3 |  |  |  |  |  |  |  |  |  |  |  |  |  |  |  |
| S162000 |  | Procure EMCAL fibers for Prepro Sectors 1-12 Blocks - Prepare & Send Solicitation |  | 0d | 2018-05-08 A | 2018-05-08 A | S161900 | 100% |  |  |  |  | S162000 | 100 | S152300 | S152300 | NOCA | Completed | Sickles, Anne | UIUC | Procurement | Craig Woody | UIUC | EMCal Prepro Sectors 1-12 | POM02.1.03.01.02.04 |  | 04 | yes | 02 | 2 |  | PP2 | MP109800 |  |  | Yes |  |  |  |  |  |  |  |  |  |  |  |  |  |  |  |  |
| S162100 |  | Procure EMCAL fibers for Prepro Sectors 1-12 Blocks - Vendor Responses |  | 0d | 2018-05-08 A | 2018-05-08 A | S162000 | 100% |  |  |  |  | S162100 | 100 | S152400 | S152400 | NOCA | Completed | Sickles, Anne | UIUC | Procurement | Craig Woody | UIUC | EMCal Prepro Sectors 1-12 | POM02.1.03.01.02.04 |  | 04 | yes | 02 | 2 |  | PP3 | MP109800 |  |  | Yes |  |  |  |  |  |  |  |  |  |  |  |  |  |  |  |  |
| S162200 |  | Procure EMCAL fibers for Prepro Sectors 1-12 Blocks - Vendor Selection |  | 0d | 2018-05-21 A | 2018-05-21 A | S162100 | 100% |  |  |  |  | S162200 | 100 | S152500 | S152500 | NOCA | Completed | Sickles, Anne | UIUC | Procurement | Craig Woody | UIUC | EMCal Prepro Sectors 1-12 | POM02.1.03.01.02.04 |  | 04 | yes | 02 | 2 |  | PP4 | MP109800 |  |  | Yes |  |  |  |  |  |  |  |  |  |  |  |  |  |  |  |  |
| OBLG162410 |  | Procure EMCAL fibers for Prepro Sectors 1-12 Blocks - Obligation 2nd batch FY18 |  | 1d | 2018-05-23 A | 2018-05-23 A | S162200 | 100% |  |  |  |  | S162400 | 100 | S152600 | S277592444 |  | Completed | Sickles, Anne | UIUC | Procurement | Craig Woody | UIUC | EMCal Prepro Sectors 1-12 | POM02.1.03.01.02.04 |  | 04 | yes |  |  |  | PP5 | MP109810 |  | 003 | Yes |  |  |  | A-OPC | L5 | OBLG |  |  |  |  |  |  |  |  |  |  |
| OBLG162510 |  | Procure EMCAL fibers for Prepro Sectors 1-12 Blocks - Obligation 3rd batch FY19 |  | 1d | 2018-05-23 A | 2018-05-23 A | S162200 | 100% |  |  | Obligation Resource |  | S162500 | 100 | S152600 | S277592484 | NOCA | Completed | Sickles, Anne | UIUC | Procurement | Craig Woody | UIUC | EMCal Prepro Sectors 1-12 | POM02.1.03.01.02.04 |  | 04 | yes | 02 | 2 |  | PP5 | MP109820 |  | 003 | Yes |  |  |  | A-OPC | L5 |  |  |  |  |  |  |  |  |  |  |  |
| OBLG162610 |  | Procure EMCAL fibers for Prepro Sectors 1-12 Blocks - Obligation 4th batch |  | 1d | 2018-05-23 A | 2018-05-23 A | S162200 | 100% |  |  | Obligation Resource |  | S162600 | 100 | S152600 | S277592524 | NOCA | Completed | Sickles, Anne | UIUC | Procurement | Craig Woody | UIUC | EMCal Prepro Sectors 1-12 | POM02.1.03.01.02.04 |  | 04 | yes | 02 | 2 |  | PP5 | MP109830 |  | 003 | Yes |  |  |  | A-OPC | L5 |  |  |  |  |  |  |  |  |  |  |  |
| S162300 |  | Procure EMCAL fibers for Prepro Sectors 1-12 Blocks - Contract Award 1st batch | milestone | 0d | 2018-05-23 A | 2018-05-23 A | S162200 | 100% |  |  |  |  | S162300 | 100 | S152600 | S152600 | NOCA | Completed | Sickles, Anne | UIUC | Procurement | Craig Woody | UIUC | EMCal Prepro Sectors 1-12 | POM02.1.03.01.02.04 |  | 04 | yes | 02 | 2 |  | PP5 | MP109800 |  |  | Yes |  |  |  | A-OPC | L5 |  |  |  |  |  |  |  |  |  |  |  |
| S162400 |  | Procure EMCAL fibers for Prepro Sectors 1-12 Blocks - Contract Award 2nd batch FY18 | milestone | 0d | 2018-05-23 A | 2018-05-23 A | S162200 | 100% |  |  |  |  | S162400 | 100 | S152600 | S277592444 | NOCA | Completed | Sickles, Anne | UIUC | Procurement | Craig Woody | UIUC | EMCal Prepro Sectors 1-12 | POM02.1.03.01.02.04 |  | 04 | yes | 02 | 2 |  | PP5 | MP109810 |  |  | Yes |  |  |  | A-OPC | L5 |  |  |  |  |  |  |  |  |  |  |  |
| S162500 |  | Procure EMCAL fibers for Prepro Sectors 1-12 Blocks - Contract Award 3rd batch FY19 | milestone | 0d | 2018-05-23 A | 2018-05-23 A | S162200 | 100% |  |  |  |  | S162500 | 100 | S152600 | S277592484 | NOCA | Completed | Sickles, Anne | UIUC | Procurement | Craig Woody | UIUC | EMCal Prepro Sectors 1-12 | POM02.1.03.01.02.04 |  | 04 | yes | 02 | 2 |  | PP5 | MP109820 |  |  | Yes |  |  |  | A-OPC | L5 |  |  |  |  |  |  |  |  |  |  |  |
| S162600 |  | Procure EMCAL fibers for Prepro Sectors 1-12 Blocks - Contract Award 4th batch | milestone | 0d | 2018-05-23 A | 2018-05-23 A | S162200 | 100% |  |  |  |  | S162600 | 100 | S152600 | S277592524 | NOCA | Completed | Sickles, Anne | UIUC | Procurement | Craig Woody | UIUC | EMCal Prepro Sectors 1-12 | POM02.1.03.01.02.04 |  | 04 | yes | 02 | 2 |  | PP5 | MP109830 |  |  | Yes |  |  |  | A-OPC | L5 |  |  |  |  |  |  |  |  |  |  |  |
| S165100 |  | Set up factory for EMCal Prepro Sectors 1-12 Blocks - Prepare & Send Solicitation |  | 5d | 2018-06-25 A | 2018-06-29 A | S165000 | 100% |  |  |  |  | S165100 | 100 | S153700 | S153710 | NOCA | Completed | Sickles, Anne | UIUC | Procurement | Craig Woody | UIUC | EMCal Prepro Sectors 1-12 | POM02.1.03.01.02.04 |  | 04 | yes | 02 | 2 | 190316 ELM add proc strng nos | PP2 | MP202400 |  | 003 | Yes |  |  |  |  |  |  |  |  |  |  |  |  |  |  |  |  |
| S165200 |  | Set up factory for EMCal Prepro Sectors 1-12 Blocks - Vendor Responses |  | 4d | 2018-07-02 A | 2018-07-06 A | S165100 | 100% |  |  |  |  | S165200 | 100 | S153700 | S153720 | NOCA | Completed | Sickles, Anne | UIUC | Procurement | Craig Woody | UIUC | EMCal Prepro Sectors 1-12 | POM02.1.03.01.02.04 |  | 04 | yes | 02 | 2 | 190316 ELM add proc strng nos | PP3 | MP202400 |  | 003 | Yes |  |  |  |  |  |  |  |  |  |  |  |  |  |  |  |  |
| S162700 |  | Procure EMCAL fibers for Prepro Sectors 1-12 Blocks - Lead Time |  | 30d | 2018-07-03 A | 2018-08-14 A | S162300 SS, S162400 SS, S162500 SS, S162600 SS, OBLG162510 SS, OBLG162610 SS, OBLG162410 SS | 100% |  |  |  |  | S162700 | 100 | S152700 | S152700 | NOCA | Completed | Sickles, Anne | UIUC | Fab & Assy | Craig Woody | UIUC | EMCal Prepro Sectors 1-12 | POM02.1.03.01.02.04 |  | 04 | yes | 02 | 4 |  | PP6 | MP109800 |  |  | Yes |  |  |  |  |  |  |  |  |  |  |  |  |  |  |  |  |
| S165300 |  | Set up factory for EMCal Prepro Sectors 1-12 Blocks - Vendor Selection |  | 5d | 2018-07-16 A | 2018-07-20 A | S165200 | 100% |  |  |  |  | S165300 | 100 | S153700 | S153730 | NOCA | Completed | Sickles, Anne | UIUC | Procurement | Craig Woody | UIUC | EMCal Prepro Sectors 1-12 | POM02.1.03.01.02.04 |  | 04 | yes | 02 | 2 | 190316 ELM add proc strng nos | PP4 | MP202400 |  | 003 | Yes |  |  |  |  |  |  |  |  |  |  |  |  |  |  |  |  |
| OBLG165410 |  | Set up factory for EMCal Prepro Sectors 1-12 Blocks - Obligation |  | 1d | 2018-07-23 A | 2018-07-23 A | S165300, S160900, S161800 | 100% |  |  | Obligation Resource |  | S165400 | 100 | S153700 | S153740 | NOCA | Completed | Sickles, Anne | UIUC | Procurement | Craig Woody | UIUC | EMCal Prepro Sectors 1-12 | POM02.1.03.01.02.04 |  | 04 | yes | 02 | 2 |  | PP5 | MP202400 |  | 003 | Yes |  |  |  | A-OPC | L5 |  | 2018-08-15 |  |  |  |  |  |  |  |  |  |
| S165400 |  | Set up factory for EMCal Prepro Sectors 1-12 Blocks - Contract Award(s) | milestone | 0d | 2018-07-23 A | 2018-07-23 A | S165300, S160900, S161800 | 100% |  |  |  |  | S165400 | 100 | S153700 | S153740 | NOCA | Completed | Sickles, Anne | UIUC | Procurement | Craig Woody | UIUC | EMCal Prepro Sectors 1-12 | POM02.1.03.01.02.04 |  | 04 | yes | 02 | 2 | 190316 ELM add proc strng nos | PP5 | MP202400 |  | 003 | Yes |  |  |  | A-OPC | L5 |  | 2018-08-15 |  |  |  |  |  |  |  |  |  |
| S165500 |  | Set up factory for EMCal Prepro Sectors 1-12 Blocks - Contract/PO - Leadtime FY18 |  | 49d | 2018-07-23 A | 2018-09-28 A | S165400 SS, OBLG165410 SS | 100% |  |  |  |  | S165500 | 100 | S153700 | S153750 | NOCA | Completed | Sickles, Anne | UIUC | Fab & Assy | Craig Woody | UIUC | EMCal Prepro Sectors 1-12 | POM02.1.03.01.02.04 |  | 04 | yes | 02 | 4 | 190316 ELM add proc strng nos | PP6 | MP202400 |  | 003 | Yes |  |  |  |  |  |  |  |  |  |  |  |  |  |  |  |  |
| S162800 |  | Procure EMCAL fibers for Prepro Sectors 1-12 Blocks - Delivery acceptance 1st batch 1-6 of 20 |  | 10d | 2018-08-15 A | 2018-08-28 A | S162700 | 100% |  |  |  |  | S162800 | 100 | S152800 | S152800 | NOCA | Completed | Sickles, Anne | UIUC | Fab & Assy | Craig Woody | UIUC | EMCal Prepro Sectors 1-12 | POM02.1.03.01.02.04 |  | 04 | yes | 02 | 4 |  | PP6 | MP109800 | OPC001300 |  | Yes | M3 | OPC |  |  |  |  |  |  |  |  |  |  |  |  |  |  |
| OBLG163610 |  | Order screens for EMCal Prepro Sectors 1-12 Blocks - Obligation |  | 1d | 2018-08-28 A | 2018-08-28 A | S163500, S160900, S161800 | 100% |  |  | Obligation Resource |  | S163600 | 100 | S153100 | S342040 | NOCA | Completed | Sickles, Anne | UIUC | Procurement | Craig Woody | UIUC | EMCal Prepro Sectors 1-12 | POM02.1.03.01.02.04 |  | 04 | yes | 02 | 2 |  | PP5 | MP202600 | OPC001300 | 003 | Yes |  |  |  | A-OPC | L5 |  | 2018-07-15 |  |  |  |  |  |  |  |  |  |
| S160900 |  | Final Design Review - EMCal Blocks, Procurement Readiness Review - EMCAL - Tungsten Powder (LLP) | milestone | 0d | 2018-08-28 A | 2018-08-28 A | S160800 | 100% |  |  |  |  | S160900 | 100 | S151100 | S151100 | NOCA | Completed | Sickles, Anne | UIUC | Design | Craig Woody | UIUC | EMCal Prepro Sectors 1-12 | POM02.1.03.01.02.04 | Pre-1 | 04 | yes | 1 | 1 | 190522 IVS new name; 190415 ELM name per GRY |  |  |  | 004 |  |  |  |  |  | L5 |  |  |  |  |  |  |  |  |  |  |  |
| S163600 |  | Order screens for EMCal Prepro Sectors 1-12 & 13-64 Blocks - Contract Award | milestone | 0d | 2018-08-28 A | 2018-08-28 A | S163500, S160900, S161800 | 100% |  |  |  |  | S163600 | 100 | S153100 | S342040 | NOCA | Completed | Sickles, Anne | UIUC | Procurement | Craig Woody | UIUC | EMCal Prepro Sectors 1-12 | POM02.1.03.01.02.04 |  | 04 | yes | 02 | 2 | 190316 ELM add proc strg nos | PP5 | MP202600 | OPC001300 | 003 | Yes |  |  |  | A-OPC | L5 |  | 2018-07-15 |  |  |  |  |  |  |  |  |  |
| S162900 |  | Procure EMCAL fibers for Prepro Sectors 1-12 Blocks - Delivery acceptance 2nd batch 7-12 of 20 FY18 |  | 22d | 2018-08-29 A | 2018-09-28 A | S162800 | 100% |  |  |  |  | S162900 | 100 | S152900 | S152900 | NOCA | Completed | Sickles, Anne | UIUC | Fab & Assy | Craig Woody | UIUC | EMCal Prepro Sectors 1-12 | POM02.1.03.01.02.04 |  | 04 | yes | 02 | 4 |  | PP6 | MP109810 | OPC001300 |  | Yes | M3 | OPC |  |  |  | FAB |  | FY18 |  |  |  |  |  |  |  |  |
| S163800 |  | Order screens for EMCal Prepro Sectors 1-12 & 13-64 Blocks - Lead Time FY18 |  | 22d | 2018-08-29 A | 2018-09-28 A | S163600 SS, OBLG163610 SS | 100% |  |  |  |  | S163800 | 100 | S153100 | S342120 | NOCA | Completed | Sickles, Anne | UIUC | Procurement | Craig Woody | UIUC | EMCal Prepro Sectors 1-12 | POM02.1.03.01.02.04 |  | 04 | yes | 02 | 2 | 190316 ELM add proc strg nos | PP6 | MP202600 | OPC001300 | 003 | Yes |  |  |  |  |  |  |  |  |  |  |  |  |  |  |  |  |
| S161000 |  | Procure EMCAL W powder for Prepro Sectors 1-12 Blocks - Provide Requirements to Procurement |  | 0d | 2018-08-31 A | 2018-08-31 A | S160900 | 100% |  |  |  |  | S161000 | 100 | S151200 | S151200 | NOCA | Completed | Sickles, Anne | UIUC | Procurement | Craig Woody | UIUC | EMCal Prepro Sectors 1-12 | POM02.1.03.01.02.04 |  | 04 | yes | 02 | 2 | 190316 ELM add proc strg nos | PP1 | MP109600 |  | 003 | Yes |  |  |  |  |  |  |  |  |  |  |  |  |  |  |  |  |
| S161100 |  | Procure EMCAL W powder for Prepro Sectors 1-12 Blocks - Prepare & Send Solicitation |  | 0d | 2018-09-04 A | 2018-09-04 A | S161000 | 100% |  |  |  |  | S161100 | 100 | S151300 | S151300 | NOCA | Completed | Sickles, Anne | UIUC | Procurement | Craig Woody | UIUC | EMCal Prepro Sectors 1-12 | POM02.1.03.01.02.04 |  | 04 | yes | 02 | 2 | 190316 ELM add proc strg nos | PP2 | MP109600 |  | 003 | Yes |  |  |  |  |  |  |  |  |  |  |  |  |  |  |  |  |
| S161200 |  | Procure EMCAL W powder for Prepro Sectors 1-12 Blocks - Vendor Responses |  | 0d | 2018-09-05 A | 2018-09-05 A | S161100 | 100% |  |  |  |  | S161200 | 100 | S151400 | S151400 | NOCA | Completed | Sickles, Anne | UIUC | Procurement | Craig Woody | UIUC | EMCal Prepro Sectors 1-12 | POM02.1.03.01.02.04 |  | 04 | yes | 02 | 2 | 190316 ELM add proc strg nos | PP3 | MP109600 |  | 003 | Yes |  |  |  |  |  |  |  |  |  |  |  |  |  |  |  |  |
| S161300 |  | Procure EMCAL W powder for Prepro Sectors 1-12 Blocks - Vendor Selection |  | 0d | 2018-09-05 A | 2018-09-05 A | S161200 | 100% |  |  |  |  | S161300 | 100 | S151500 | S151500 | NOCA | Completed | Sickles, Anne | UIUC | Procurement | Craig Woody | UIUC | EMCal Prepro Sectors 1-12 | POM02.1.03.01.02.04 |  | 04 | yes | 02 | 2 | 190316 ELM add proc strg nos | PP3 | MP109600 |  | 003 | Yes |  |  |  |  |  |  |  |  |  |  |  |  |  |  |  |  |
| OBLG164510 |  | Order epoxy for EMCal Prepro Sectors 1-12 Blocks - Obligation |  | 1d | 2018-10-01 A | 2018-10-01 A | S164400, S160900, S161800 | 100% |  |  | Obligation Resource |  | S164500 | 100 | S153300 | S342480 | NOCA | Completed | Sickles, Anne | UIUC | Procurement | Craig Woody | UIUC | EMCal Prepro Sectors 1-12 | POM02.1.03.01.02.04 |  | 04 | yes | 02 | 2 |  | PP5 | MP202500 | OPC001300 | 003 | Yes | M3 |  |  | A-OPC | L5 |  | 2018-08-15 |  |  |  |  |  |  |  |  |  |
| S163000 |  | Procure EMCAL fibers for Prepro Sectors 1-12 Blocks - Delivery acceptance 3rd batch 13-17 of 20 FY19 |  | 9d | 2018-10-01 A | 2018-10-12 A | S162900 | 100% |  |  |  |  | S163000 | 100 | S152900 | S152925 | NOCA | Completed | Sickles, Anne | UIUC | Fab & Assy | Craig Woody | UIUC | EMCal Prepro Sectors 1-12 | POM02.1.03.01.02.04 |  | 04 | yes | 02 | 4 |  | PP6 | MP109820 | OPC001300 |  | Yes | M3 | OPC | C | A-OPC |  |  |  | FY19 | 16702 |  |  |  |  |  |  |  |
| S163500 |  | Order screens for EMCal Prepro Sectors 1-12 & 13-64 Blocks - Vendor Selection |  | 5d | 2018-10-01 A | 2018-10-05 A | S163400 | 100% |  |  |  |  | S163500 | 100 | S153100 | S342000 | NOCA | Completed | Sickles, Anne | UIUC | Procurement | Craig Woody | UIUC | EMCal Prepro Sectors 1-12 | POM02.1.03.01.02.04 |  | 04 | yes | 02 | 2 | 190316 ELM add proc strg nos | PP4 | MP202600 | OPC001300 | 003 | Yes |  |  |  |  |  |  |  |  |  |  |  |  |  |  |  |  |
| S163900 |  | Order screens for EMCal Prepro Sectors 1-12 & 13-64 Blocks - Lead Time FY19 |  | 10d | 2018-10-01 A | 2018-10-15 A | S163800 | 100% |  |  |  |  | S163900 | 100 | S153100 | S342130 | NOCA | Completed | Sickles, Anne | UIUC | Procurement | Craig Woody | UIUC | EMCal Prepro Sectors 1-12 | POM02.1.03.01.02.04 |  | 04 | yes | 02 | 2 | 190316 ELM add proc strg nos | PP6 | MP202600 | OPC001300 | 003 | Yes |  |  |  |  |  |  |  |  |  |  |  |  |  |  |  |  |
| S164500 |  | Order epoxy for EMCal Prepro Sectors 1-12 Blocks - Contract Award | milestone | 0d | 2018-10-01 A | 2018-10-01 A | S164400, S160900, S161800 | 100% |  |  |  |  | S164500 | 100 | S153300 | S342480 | NOCA | Completed | Sickles, Anne | UIUC | Procurement | Craig Woody | UIUC | EMCal Prepro Sectors 1-12 | POM02.1.03.01.02.04 |  | 04 | yes | 02 | 2 | 190316 ELM add proc strg nos | PP5 | MP202500 | OPC001300 | 003 | Yes | M3 |  |  | A-OPC | L5 |  | 2018-08-15 |  |  |  |  |  |  |  |  |  |
| S164600 |  | Order epoxy for EMCal Prepro Sectors 1-12 Blocks - Lead Time |  | 20d | 2018-10-01 A | 2018-10-29 A | S164500 SS, OBLG164510 SS | 100% |  |  |  |  | S164600 | 100 | S153300 | S342520 | NOCA | Completed | Sickles, Anne | UIUC | Procurement | Craig Woody | UIUC | EMCal Prepro Sectors 1-12 | POM02.1.03.01.02.04 |  | 04 | yes | 02 | 2 | 190316 ELM add proc strg nos | PP6 | MP202500 | OPC001300 | 003 | Yes | M3 |  |  |  |  |  | 2018-08-31 |  |  |  |  |  |  |  |  |  |
| S164800 |  | Order parts and fabricate molds for EMCal Prepro Sectors 1-12 Blocks M&S |  | 20d | 2018-10-01 A | 2018-10-29 A | S160800, S179300 SS | 100% |  |  |  |  | S164800 | 100 | S153500 | S153500 | NOCA | Completed | Sickles, Anne | UIUC | Fab & Assy | Craig Woody | UIUC | EMCal Prepro Sectors 1-12 | POM02.1.03.01.02.04 |  | 04 | yes | 02 | 4 |  | PP6 | MP203200 | OPC001300 | 003 | Yes | M3 | OPC | C | A-OPC |  |  |  |  | 16702 |  |  |  |  |  |  |  |
| S164900 |  | Order parts and fabricate molds for EMCal Prepro Sectors 1-12 Blocks Purchased Services |  | 20d | 2018-10-01 A | 2018-10-29 A | S160800 | 100% |  |  |  |  | S164900 | 100 | S153600 | S153600 | NOCA | Completed | Sickles, Anne | UIUC | Procurement | Craig Woody | UIUC | EMCal Prepro Sectors 1-12 | POM02.1.03.01.02.04 |  | 04 | yes | 02 | 2 |  |  |  |  |  |  |  |  |  |  |  |  |  |  |  |  |  |  |  |  |  |  |
| S165600 |  | Set up factory for EMCal Prepro Sectors 1-12 Blocks - Contract/PO - Leadtime FY19 |  | 112d | 2018-10-01 A | 2019-03-15 A | S165500 | 100% |  |  |  |  | S165600 | 100 | S153700 | S153755 | NOCA | Completed | Sickles, Anne | UIUC | Fab & Assy | Craig Woody | UIUC | EMCal Prepro Sectors 1-12 | POM02.1.03.01.02.04 |  | 04 | yes | 02 | 4 | 190316 ELM add proc strng nos | PP6 | MP202400 |  | 003 | Yes |  |  |  |  |  |  |  |  |  |  |  |  |  |  |  |  |
| OBLG161410 |  | Procure EMCAL W powder for Prepro Sectors 1-12 Blocks - Obligation |  | 1d | 2018-10-09 A | 2018-10-09 A | S161300, S160800 | 100% |  |  | Obligation Resource |  | S161400 | 100 | S151600 | S151600 | NOCA | Completed | Sickles, Anne | UIUC | Procurement | Craig Woody | UIUC | EMCal Prepro Sectors 1-12 | POM02.1.03.01.02.04 |  | 04 | yes | 02 | 2 |  | PP5 | MP109600 |  | 003 | Yes |  |  |  | A-OPC | L5 |  |  |  |  |  |  |  |  |  |  |  |
| S161400 |  | Procure EMCAL W powder for Prepro Sectors 1-12 Blocks - Contract Award | milestone | 0d | 2018-10-09 A | 2018-10-09 A | S161300, S160800 | 100% |  |  |  |  | S161400 | 100 | S151600 | S151600 | NOCA | Completed | Sickles, Anne | UIUC | Procurement | Craig Woody | UIUC | EMCal Prepro Sectors 1-12 | POM02.1.03.01.02.04 |  | 04 | yes | 02 | 2 | 190316 ELM add proc strg nos | PP4 | MP109600 |  | 003 | Yes |  |  |  | A-OPC | L5 |  |  |  |  | Contract Award |  |  |  |  |  |  |
| S161500 |  | Procure EMCAL W powder for Prepro Sectors 1-12 Blocks - Lead Time |  | 9d | 2018-10-09 A | 2018-10-19 A | S161400 SS, OBLG161410 SS | 100% |  |  |  |  | S161500 | 100 | S151700 | S151700 | NOCA | Completed | Sickles, Anne | UIUC | Fab & Assy | Craig Woody | UIUC | EMCal Prepro Sectors 1-12 | POM02.1.03.01.02.04 |  | 04 | yes | 02 | 4 | 190316 ELM add proc strg nos | PP5 | MP109600 |  | 003 | Yes |  |  |  |  |  |  |  |  |  |  |  |  |  |  |  |  |
| S163100 |  | Procure EMCAL fibers for Prepro Sectors 1-12 Blocks - Delivery acceptance 4th batch 18-20 of 20 |  | 27d | 2018-10-15 A | 2018-11-21 A | S163000 | 100% |  |  |  |  | S163100 | 100 | S153000 | S153000 | NOCA | Completed | Sickles, Anne | UIUC | Fab & Assy | Craig Woody | UIUC | EMCal Prepro Sectors 1-12 | POM02.1.03.01.02.04 |  | 04 | yes | 02 | 4 | 190319 ELM code | PP6 | MP109830 | OPC001300 | 003 | Yes | M3 | OPC | C | A-OPC |  |  |  |  | 16702 |  |  |  |  |  |  |  |
| S164000 |  | Order screens for EMCal Prepro Sectors 1-12 & 13-64 Blocks - Delivery acceptance |  | 119d | 2018-10-16 A | 2019-04-09 A | S163900 | 100% |  |  |  |  | S164000 | 79 | S153200 | S153200 | NOCA | Completed | Sickles, Anne | UIUC | Fab & Assy | Craig Woody | UIUC | EMCal Prepro Sectors 1-12 | POM02.1.03.01.02.04 |  | 04 | yes | 02 | 4 | 190316 ELM add proc strg nos | PP6 | MP202600 |  | 003 | Yes | M4 | OPC | C | A-OPC |  |  | 2019-03-29 |  | 16702 |  | Yes |  |  |  |  |  |
| S161600 |  | Procure EMCAL W powder for Prepro Sectors 1-12 Blocks - Delivery acceptance Phase 1 of 2 Phases (Sectors 1-3) |  | 2d | 2018-10-22 A | 2018-10-23 A | S161500 SS | 100% |  |  |  |  | S161600 | 100 | S151800 | S151800 | NOCA | Completed | Sickles, Anne | UIUC | Fab & Assy | Craig Woody | UIUC | EMCal Prepro Sectors 1-12 | POM02.1.03.01.02.04 |  | 04 | yes | 02 | 4 | 190316 ELM add proc strg nos | PP6 | MP109600 |  | 003 | Yes |  |  | C | A-OPC |  |  |  |  | 16702 |  |  |  |  |  |  |  |
| S164700 |  | Order epoxy for EMCal Prepro Sectors 1-12 Blocks - Delivery acceptance |  | 146d | 2018-10-30 A | 2019-05-31 A | S164600 | 100% |  |  |  |  | S164700 | 10 | S153400 | S153400 | NOCA | Completed | Sickles, Anne | UIUC | Fab & Assy | Craig Woody | UIUC | EMCal Prepro Sectors 1-12 | POM02.1.03.01.02.04 |  | 04 | yes | 02 | 4 | 190316 ELM add proc strg nos | PP6 | MP202500 |  | 003 | Yes | M3 | OPC | C | A-OPC |  |  | 2019-03-08 |  | 16702 |  | Yes |  |  |  |  |  |
| S165800 |  | Prepare fiber assemblies for EMCal Prepro Sectors 1-12 Blocks |  | 146d | 2018-10-30 A | 2019-05-31 A | S162800 SS, S163100 FF, S160800, S163900, S179300 SS | 100% |  |  |  |  | S165800 | 27 | S153800 | S153800 | NOCA | Completed | Sickles, Anne | UIUC | Fab & Assy | Craig Woody | UIUC | EMCal Prepro Sectors 1-12 | POM02.1.03.01.02.04 |  | 04 | yes | 02 | 4 | 190319 ELM rsrc per GRY/CR | PP6 | MP203200 |  | 003 | Yes | L4 | null | C | A-OPC |  |  | 2019-08-16 |  | 16702 |  | Yes |  |  |  |  |  |
| S165700 |  | Set up factory for EMCal Prepro Sectors 1-12 Blocks - Delivery Acceptance |  | 40d | 2019-01-02 A | 2019-02-28 A | S165500, S165600 | 100% |  |  |  |  | S165700 | 100 | S153700 | S339020 | NOCA | Completed | Sickles, Anne | UIUC | Fab & Assy | Craig Woody | UIUC | EMCal Prepro Sectors 1-12 | POM02.1.03.01.02.04 |  | 04 | yes | 02 | 4 |  | PP6 | MP202400 | OPC001300 | 003 | Yes | M3 | OPC | F | A-OPC |  |  |  |  | 16702 |  |  |  |  |  |  |  |
| S165802 |  | Prepare fiber assemblies for EMCal Prepro Sectors 1-12 Blocks Split |  | 20d | 2019-06-03 A | 2019-06-28 A | S165800 | 100% |  |  | TECH3 UIUC - Purchased Services; STUDENT UIUC - Purchased Services [662 h]; TECH3 Senior UIUC - Purchased Services | 11,004.36 | S165800 | 27 | S153800 | S153800 | CA | Completed | Sickles, Anne | UIUC | Fab & Assy | Craig Woody | UIUC | EMCal Prepro Sectors 1-12 | POM02.1.03.01.02.04 |  | 04 |  | 02 | 4 | 190319 ELM rsrc per GRY/CR | PP6 | MP203200 |  | 003 | Yes | L4 | null | C | A-OPC |  |  | 2019-08-16 |  | 16702 |  | Yes | S165802 | 1.03 | 1.03A |  |  |
| S164702 |  | Order epoxy for EMCal Prepro Sectors 1-12 Blocks - Delivery acceptance Split |  | 64d | 2019-07-01 A | 2020-03-30 A | S164700 | 100% | 2019-07-01 | 2019-09-30 | UIUC Contracted Purchase <$2M M&S [33239 h] | 36,671.43 | S164700 | 10 | S153400 | S153400 | CA | In Progress | Sickles, Anne | UIUC | Fab & Assy | Craig Woody | UIUC | EMCal Prepro Sectors 1-12 | POM02.1.03.01.02.04 |  | 04 |  | 02 | 4 | 190316 ELM add proc strg nos | PP6 | MP202500 |  | 003 | Yes | M3 | OPC | C | A-OPC |  |  | 2019-03-08 |  | 16702 |  | Yes | S164702 | 1.03 | 1.03A | UDF_G1 | UDF_G3 |
| S161700 |  | Procure EMCAL W powder for Prepro Sectors 1-12 Blocks - Delivery acceptance Phase 2 of 2 Phases (Sectors 4-12) |  | 20d | 2019-09-03 A | 2019-09-30 A | S161600 | 100% |  |  | UIUC Contracted Purchase <$2M M&S [219420 h] | 242,078.42 | S161700 | 0 | S152000 | S152000 | CA | Completed | Sickles, Anne | UIUC | Fab & Assy | Craig Woody | UIUC | EMCal Prepro Sectors 1-12 | POM02.1.03.01.02.04 |  | 04 |  | 02 | 4 | 190316 ELM add proc strg nos | PP6 | MP109600 | OPC001300 | 003 | Yes | M3 | OPC | C | A-OPC |  |  |  |  | 16702 | Delivery |  | S161700 | 1.03 | 1.03A | UDF_G2 |  |

Notes:
- S160800: BNL_UDF_Adhoc Comments: 180413 status per GRY; 180410 ELM pred/succ rmv const per GRY / BNL_UDF_Old Activity Name 181221: Establish contract for EMCAL Prepro Sectors 1-12 blocks with UIUC
- S163200: BNL_UDF_Adhoc Comments: 180406 ELM add proc strg; 180402 ELM swapped labor / M&S resources for ID sequence / BNL_UDF_Old Activity Name 181221: Order screens for EMCal Prepro Sectors 1-12 & 13-64 Blocks - Provide Requirements to Procurement
- S164100: BNL_UDF_Adhoc Comments: 180420 ELM fix MP tag per GRY; 180406 ELM add proc strg; 180402 ELM swapped labor / M&S resources for ID sequence / BNL_UDF_Old Activity Name 181221: Order epoxy for EMCal Prepro Sectors 1-12 Blocks - Provide Requirements to Procurement
- S165000: BNL_UDF_Old Activity Name 181221: Set up factory for EMCal Prepro Sectors 1-12 Blocks - Provide Requirements to Procurement
- S163300: BNL_UDF_Adhoc Comments: 180406 ELM add proc strg / BNL_UDF_Old Activity Name 181221: Order screens for EMCal Prepro Sectors 1-12 & 13-64 Blocks - Prepare & Send Solicitation
- S164200: BNL_UDF_Adhoc Comments: 180420 ELM fix MP tag per GRY; 180406 ELM add proc strg; 180402 ELM swapped labor / M&S resources for ID sequence / BNL_UDF_Old Activity Name 181221: Order epoxy for EMCal Prepro Sectors 1-12 Blocks - Prepare & Send Solicitation
- S163400: BNL_UDF_Adhoc Comments: 180406 ELM add proc strg / BNL_UDF_Old Activity Name 181221: Order screens for EMCal Prepro Sectors 1-12 & 13-64 Blocks - Vendor Responses
- S164300: BNL_UDF_Adhoc Comments: 180420 ELM fix MP tag per GRY; 180406 ELM add proc strg; 180402 ELM swapped labor / M&S resources for ID sequence / BNL_UDF_Old Activity Name 181221: Order epoxy for EMCal Prepro Sectors 1-12 Blocks - Vendor Responses
- S161800: General Comments: 180420 GYoung: concerning Internal / Design Review - appropriate level for a preproduction / order / BNL_UDF_Adhoc Comments: 180413 status per GRY; 180410 ELM pred/succ per GRY / BNL_UDF_Old Activity Name 181221: EMCal Internal Design Review for Prepro Sectors 1-12 Fibers
- S161900: BNL_UDF_Old Activity Name 181221: Procure EMCAL fibers for Prepro Sectors 1-12 Blocks - Provide Requirements to Procurement
- S164400: BNL_UDF_Adhoc Comments: 180420 ELM fix MP tag per GRY; 180406 ELM add proc strg; 180402 ELM swapped labor / M&S resources for ID sequence / BNL_UDF_Old Activity Name 181221: Order epoxy for EMCal Prepro Sectors 1-12 Blocks - Vendor Selection
- S162000: BNL_UDF_Old Activity Name 181221: Procure EMCAL fibers for Prepro Sectors 1-12 Blocks - Prepare & Send Solicitation
- S162100: BNL_UDF_Old Activity Name 181221: Procure EMCAL fibers for Prepro Sectors 1-12 Blocks - Vendor Responses
- S162200: BNL_UDF_Old Activity Name 181221: Procure EMCAL fibers for Prepro Sectors 1-12 Blocks - Vendor Selection
- OBLG162410: BNL_UDF_Old Activity Name 181221: Procure EMCAL fibers for Prepro Sectors 1-12 Blocks - Contract Award 2nd batch FY18
- OBLG162510: BNL_UDF_Old Activity Name 181221: Procure EMCAL fibers for Prepro Sectors 1-12 Blocks - Contract Award 2nd batch FY19
- OBLG162610: BNL_UDF_Old Activity Name 181221: Procure EMCAL fibers for Prepro Sectors 1-12 Blocks - Contract Award 3rd batch
- S162300: BNL_UDF_Old Activity Name 181221: Procure EMCAL fibers for Prepro Sectors 1-12 Blocks - Contract Award 1st batch
- S162400: BNL_UDF_Old Activity Name 181221: Procure EMCAL fibers for Prepro Sectors 1-12 Blocks - Contract Award 2nd batch FY18
- S162500: BNL_UDF_Old Activity Name 181221: Procure EMCAL fibers for Prepro Sectors 1-12 Blocks - Contract Award 2nd batch FY19
- S162600: BNL_UDF_Old Activity Name 181221: Procure EMCAL fibers for Prepro Sectors 1-12 Blocks - Contract Award 3rd batch
- S165100: BNL_UDF_Adhoc Comments: 180402 ELM added activity for proc strg / BNL_UDF_Old Activity Name 181221: Set up factory for EMCal Prepro Sectors 1-12 Blocks - Prepare & Send Solicitation
- S165200: BNL_UDF_Adhoc Comments: 180402 ELM added activity for proc strg / BNL_UDF_Old Activity Name 181221: Set up factory for EMCal Prepro Sectors 1-12 Blocks - Vendor Responses
- S162700: BNL_UDF_Old Activity Name 181221: Procure EMCAL fibers for Prepro Sectors 1-12 Blocks - Lead Time
- S165300: BNL_UDF_Adhoc Comments: 180402 ELM added activity for proc strg / BNL_UDF_Old Activity Name 181221: Set up factory for EMCal Prepro Sectors 1-12 Blocks - Vendor Selection
- OBLG165410: BNL_UDF_Adhoc Comments: 180420 ELM pred/succ per GRY; 180402 ELM added activity for proc strg / BNL_UDF_Old Activity Name 181221: Set up factory for EMCal Prepro Sectors 1-12 Blocks - Contract Award(s)
- S165400: BNL_UDF_Adhoc Comments: 180420 ELM pred/succ per GRY; 180402 ELM added activity for proc strg / BNL_UDF_Old Activity Name 181221: Set up factory for EMCal Prepro Sectors 1-12 Blocks - Contract Award(s)
- S165500: BNL_UDF_Adhoc Comments: 180402 ELM added activity for proc strg / BNL_UDF_Old Activity Name 181221: Set up factory for EMCal Prepro Sectors 1-12 Blocks - Contract/PO - Leadtime FY18
- S162800: BNL_UDF_Adhoc Comments: 180410 ELM dur per GRY / BNL_UDF_Old Activity Name 181221: Procure EMCAL fibers for Prepro Sectors 1-12 Blocks - Delivery acceptance 1st batch 1-6 of 20
- OBLG163610: BNL_UDF_Adhoc Comments: 180420 ELM pred/succ per GRY; 180406 ELM add proc strg / BNL_UDF_Old Activity Name 181221: Order screens for EMCal Prepro Sectors 1-12 Blocks - Contract Award
- S160900: General Comments: 180420 GYoung: concerning Internal / Design Review - appropriate level for a preproduction / order / BNL_UDF_Adhoc Comments: 180413 status per GRY; 180410 ELM pred/succ per GRY / BNL_UDF_Old Activity Name 181221: EMCal Internal Design Review for Prepro Sectors 1-12 W Powder
- S163600: BNL_UDF_Adhoc Comments: 180420 ELM pred/succ per GRY; 180406 ELM add proc strg / BNL_UDF_Old Activity Name 181221: Order screens for EMCal Prepro Sectors 1-12 Blocks - Contract Award
- S162900: BNL_UDF_Adhoc Comments: 180410 ELM dur per GRY / BNL_UDF_Old Activity Name 181221: Procure EMCAL fibers for Prepro Sectors 1-12 Blocks - Delivery acceptance 2nd batch 7-12 of 20 FY18
- S163800: BNL_UDF_Adhoc Comments: 180406 ELM add proc strg / BNL_UDF_Old Activity Name 181221: Order screens for EMCal Prepro Sectors 1-12 & 13-64 Blocks - Lead Time FY18
- S161000: BNL_UDF_Adhoc Comments: 180413 ELM status per GRY; 180410 ELM rmv const per GRY / BNL_UDF_Old Activity Name 181221: Procure EMCAL W powder for Prepro Sectors 1-12 Blocks - Provide Requirements to Procurement
- S161100: BNL_UDF_Old Activity Name 181221: Procure EMCAL W powder for Prepro Sectors 1-12 Blocks - Prepare & Send Solicitation
- S161200: BNL_UDF_Old Activity Name 181221: Procure EMCAL W powder for Prepro Sectors 1-12 Blocks - Vendor Responses
- S161300: BNL_UDF_Old Activity Name 181221: Procure EMCAL W powder for Prepro Sectors 1-12 Blocks - Vendor Selection
- OBLG164510: BNL_UDF_Adhoc Comments: 180420 ELM pred/succ, fix MP tag per GRY; 180406 ELM add proc strg / BNL_UDF_Old Activity Name 181221: Order epoxy for EMCal Prepro Sectors 1-12 Blocks - Contract Award
- S163000: BNL_UDF_Adhoc Comments: 180410 ELM dur per GRY / BNL_UDF_Old Activity Name 181221: Procure EMCAL fibers for Prepro Sectors 1-12 Blocks - Delivery acceptance 3rd batch 13-17 of 20 FY19
- S163500: BNL_UDF_Adhoc Comments: 180406 ELM add proc strg / BNL_UDF_Old Activity Name 181221: Order screens for EMCal Prepro Sectors 1-12 & 13-64 Blocks - Vendor Selection
- S163900: BNL_UDF_Adhoc Comments: 180406 ELM add proc strg / BNL_UDF_Old Activity Name 181221: Order screens for EMCal Prepro Sectors 1-12 & 13-64 Blocks - Lead Time FY19
- S164500: BNL_UDF_Adhoc Comments: 180420 ELM pred/succ, fix MP tag per GRY; 180406 ELM add proc strg / BNL_UDF_Old Activity Name 181221: Order epoxy for EMCal Prepro Sectors 1-12 Blocks - Contract Award
- S164600: BNL_UDF_Adhoc Comments: 180420 ELM fix MP tag per GRY; 180406 ELM add proc strg; 180402 ELM swapped labor / M&S resources for ID sequence / BNL_UDF_Old Activity Name 181221: Order epoxy for EMCal Prepro Sectors 1-12 Blocks - Lead Time
- S164800: BNL_UDF_Old Activity Name 181221: Order parts and fabricate molds for EMCal Prepro Sectors 1-12 Blocks M&S
- S164900: BNL_UDF_Old Activity Name 181221: Order parts and fabricate molds for EMCal Prepro Sectors 1-12 Blocks Labor
- S165600: BNL_UDF_Adhoc Comments: 180402 ELM added activity for proc strg / BNL_UDF_Old Activity Name 181221: Set up factory for EMCal Prepro Sectors 1-12 Blocks - Contract/PO - Leadtime FY19
- OBLG161410: BNL_UDF_Old Activity Name 181221: Procure EMCAL W powder for Prepro Sectors 1-12 Blocks - Contract Award
- S161400: BNL_UDF_Old Activity Name 181221: Procure EMCAL W powder for Prepro Sectors 1-12 Blocks - Contract Award
- S161500: BNL_UDF_Old Activity Name 181221: Procure EMCAL W powder for Prepro Sectors 1-12 Blocks - Lead Time
- S163100: BNL_UDF_Adhoc Comments: 180410 ELM dur per GRY / BNL_UDF_Old Activity Name 181221: Procure EMCAL fibers for Prepro Sectors 1-12 Blocks - Delivery acceptance 4th batch 18-20 of 20
- S164000: BNL_UDF_Adhoc Comments: 180406 ELM add proc strg; 180406 RFG filled in BNL_Cost Basis; 180402 ELM swapped labor / M&S resources for ID sequence / BNL_UDF_Old Activity Name 181221: Order screens for EMCal Prepro Sectors 1-12 & 13-64 Blocks - Delivery acceptance
- S161600: BNL_UDF_Old Activity Name 181221: Procure EMCAL W powder for Prepro Sectors 1-12 Blocks - Delivery acceptance Phase 1 of 2 Phases (Sectors 1-3)
- S164700: BNL_UDF_Adhoc Comments: 180420 ELM fix MP tag per GRY; 180406 ELM add proc strg; 180406 RFG filled in BNL_Cost Basis; 180402 ELM swapped labor / M&S resources for ID sequence / BNL_UDF_Old Activity Name 181221: Order epoxy for EMCal Prepro Sectors 1-12 Blocks - Delivery acceptance
- S165800: BNL_UDF_Old Activity Name 181221: Prepare fiber assemblies for EMCal Prepro Sectors 1-12 Blocks
- S165700: BNL_UDF_Old Activity Name 181221: Set up factory for EMCal Prepro Sectors 1-12 Blocks - Delivery Acceptance
- S165802: BNL_UDF_Old Activity Name 181221: Prepare fiber assemblies for EMCal Prepro Sectors 1-12 Blocks
- S164702: BNL_UDF_Adhoc Comments: 180420 ELM fix MP tag per GRY; 180406 ELM add proc strg; 180406 RFG filled in BNL_Cost Basis; 180402 ELM swapped labor / M&S resources for ID sequence / BNL_UDF_Old Activity Name 181221: Order epoxy for EMCal Prepro Sectors 1-12 Blocks - Delivery acceptance
- S161700: BNL_UDF_Old Activity Name 181221: Procure EMCAL W powder for Prepro Sectors 1-12 Blocks - Delivery acceptance Phase 2 of 2 Phases (Sectors 4-12)

| ID | WBS | Activity | Duration | Start | Finish | Predecessors | Complete | Planned start | Planned finish | Resources | Cost | BNL_UDF_Temp Text 01 | BNL_UDF_Percent Complete | BNL_UDF_OPC TEC (deprecated) | BNL_UDF_Old Activity Name 181221 | BNL_UDF_Old Activity ID 181221 | RG Check | BNL_Activity Status | BNL_Fund Source | BNL_Estimator | BNL_Cost Basis | BNL_Location | BNL_EDIA | BNL_Proc Sig Phase | BNL_Proc Sig | BNL_CAM | BNL_Institution | BNL_R&D FY18-19 | BNL_OPC TEC (deprecated) | BNL_WBS | BNL_EVT | BNL_Account Number | BNL_PCR ID | BNL_WBS_Hierarchical | Completed | PMP Summary Part1 | PMP Summary Part2 | Additional EVT documentation required | Cost = Awarded Proc or Mgmt | BNL_Cobra WP | BNL_Master Control Account | BNL_Cobra Control Account | Indicator - Procurement | BNL_DOE OPC | BNL_UDF_Adhoc Comments | Indicator - Float | BNL_UDF_Remaining Tot Cost | BNL_UDF_Percent_remaining |
| --- | --- | --- | --- | --- | --- | --- | --- | --- | --- | --- | --- | --- | --- | --- | --- | --- | --- | --- | --- | --- | --- | --- | --- | --- | --- | --- | --- | --- | --- | --- | --- | --- | --- | --- | --- | --- | --- | --- | --- | --- | --- | --- | --- | --- | --- | --- | --- | --- |
|  | 05 | **Fabricate EMCal Prepro blocks Sectors 1-12** |  | 2019-04-01 | 2020-10-09 |  |  |  |  |  |  |  |  |  |  |  |  |  |  |  |  |  |  |  |  |  |  |  |  |  |  |  |  |  |  |  |  |  |  |  |  |  |  |  |  |  |  |  |
| S165900 |  | Fabricate EMCAL Prepro blocks sector 1 | 44d | 2019-04-01 A | 2019-05-31 A | S164900, S164800, S164000 SS+5d, S165600 SS, S161500 SS+15d, S165700 FF, S159100, S179300 SS, S165802 | 100% |  |  |  |  | S165900 | 0 | S153900 | Fabricate EMCAL Prepro blocks sector 1 | S153900 | NOCA | Completed | A-OPC | Sickles, Anne | L4 | UIUC | Fab & Assy | PP6 | MP203200 | Craig Woody | UIUC | EMCal Prepro Sectors 1-12 | null | POM02.1.03.01.02.05 | C | 16702 | 003,005 | 05 | yes | 02 | 4 | Yes | Yes |  |  |  |  |  |  |  |  |  |
| S165902 |  | Fabricate EMCAL Prepro blocks sector 1 Split | 64d | 2019-07-01 A | 2019-09-30 A | S165900 | 100% |  |  | TECH3 UIUC - Purchased Services [107 h]; STUDENT UIUC - Purchased Services [6 h]; TECH3 Senior UIUC - Purchased Services [13 h] | 6,820.39 | S165900 | 0 | S153900 | Fabricate EMCAL Prepro blocks sector 1 | S153900 | CA | Completed | A-OPC | Sickles, Anne | L4 | UIUC | Fab & Assy | PP6 | MP203200 | Craig Woody | UIUC | EMCal Prepro Sectors 1-12 | null | POM02.1.03.01.02.05 | C | 16702 | 003,005 | 05 |  | 02 | 4 | Yes | Yes | S165902 | 1.03 | 1.03A |  |  |  |  |  |  |
| S166000 |  | Fabricate EMCAL Prepro blocks sector 2 | 25d | 2019-10-01 A | 2019-12-31 A | S165902 | 100% | 2019-10-01 | 2019-11-05 | TECH3 UIUC - Purchased Services [142.8 h]; STUDENT UIUC - Purchased Services [8.4 h]; TECH3 Senior UIUC - Purchased Services [16.8 h] | 9,425.14 | S166000 | 0 | S154000 | Fabricate EMCAL Prepro blocks sector 2 | S154000 | CA | In Progress | A-OPC | Sickles, Anne | L4 | UIUC | Fab & Assy | PP6 | MP203200 | Craig Woody | UIUC | EMCal Prepro Sectors 1-12 | null | POM02.1.03.01.02.05 | C | 16702 | 003,004 | 05 |  | 02 | 4 | Yes | Yes | S166000 | 1.03 | 1.03A |  |  |  |  |  |  |
| S166100 |  | Fabricate EMCAL Prepro blocks sector 3 | 25d | 2019-12-19 A | 2020-01-31 A | S166000 | 100% | 2020-01-14 | 2020-02-19 | TECH3 UIUC - Purchased Services [142.8 h]; STUDENT UIUC - Purchased Services [8.4 h]; TECH3 Senior UIUC - Purchased Services [16.8 h] | 9,425.14 | S166100 | 0 | S154100 | Fabricate EMCAL Prepro blocks sector 3 | S154100 | CA | Not Started | A-OPC | Sickles, Anne | L4 | UIUC | Fab & Assy | PP6 | MP203200 | Craig Woody | UIUC | EMCal Prepro Sectors 1-12 | null | POM02.1.03.01.02.05 | C | 16702 | 003,004 | 05 |  | 02 | 4 | Yes | Yes | S166100 | 1.03 | 1.03A |  |  |  |  |  |  |
| S166200 |  | Fabricate EMCAL Prepro blocks sector 4 | 15d | 2020-02-03 A | 2020-03-04 A | S166100, S161700 SS+5d | 100% | 2020-02-03 | 2020-02-24 | TECH3 UIUC - Purchased Services [142.8 h]; STUDENT UIUC - Purchased Services [8.4 h]; TECH3 Senior UIUC - Purchased Services [16.8 h] | 9,425.14 | S166200 | 0 | S154200 | Fabricate EMCAL Prepro blocks sector 4 | S154200 | CA | Not Started | A-OPC | Sickles, Anne | L4 | UIUC | Fab & Assy | PP6 | MP203200 | Craig Woody | UIUC | EMCal Prepro Sectors 1-12 | null | POM02.1.03.01.02.05 | C | 16702 | 003,004 | 05 |  | 02 | 4 | Yes | Yes | S166200 | 1.03 | 1.03A |  |  |  |  |  |  |
| S166300 |  | Fabricate EMCAL Prepro blocks sector 5 | 15d | 2020-03-05 A | 2020-05-29 A | S166200 | 100% | 2020-03-05 | 2020-03-25 | TECH3 UIUC - Purchased Services [142.8 h]; STUDENT UIUC - Purchased Services [8.4 h]; TECH3 Senior UIUC - Purchased Services [16.8 h] | 9,425.14 | S166300 | 0 | S154300 | Fabricate EMCAL Prepro blocks sector 5 | S154300 | CA | Not Started | A-OPC | Sickles, Anne | L4 | UIUC | Fab & Assy | PP6 | MP203200 | Craig Woody | UIUC | EMCal Prepro Sectors 1-12 | null | POM02.1.03.01.02.05 | C | 16702 | 003,004 | 05 |  | 02 | 4 |  | Yes | S166300 | 1.03 | 1.03A |  |  |  |  |  |  |
| S166400 |  | Fabricate EMCAL Prepro blocks sector 6 | 15d | 2020-05-06 A | 2020-06-17 A | S166300 | 100% | 2020-06-01 | 2020-06-19 | TECH3 UIUC - Purchased Services [142.8 h]; STUDENT UIUC - Purchased Services [8.4 h]; TECH3 Senior UIUC - Purchased Services [16.8 h] | 9,425.14 | S166400 | 0 | S154400 | Fabricate EMCAL Prepro blocks sector 6 | S154400 | CA | Not Started | A-OPC | Sickles, Anne | L4 | UIUC | Fab & Assy | PP6 | MP203200 | Craig Woody | UIUC | EMCal Prepro Sectors 1-12 | null | POM02.1.03.01.02.05 | C | 16702 | 003,004 | 05 |  | 02 | 4 |  | Yes | S166400 | 1.03 | 1.03A |  |  |  |  |  |  |
| S166500 |  | Fabricate EMCAL Prepro blocks sector 7 | 10d | 2020-07-01 A | 2020-07-15 A | S166400 | 100% |  |  | TECH3 UIUC - Purchased Services [142.8 h]; STUDENT UIUC - Purchased Services [8.4 h]; TECH3 Senior UIUC - Purchased Services [16.8 h] | 9,425.14 | S166500 | 0 | S154500 | Fabricate EMCAL Prepro blocks sector 7 | S154500 | CA | Not Started | A-OPC | Sickles, Anne | L4 | UIUC | Fab & Assy | PP6 | MP203200 | Craig Woody | UIUC | EMCal Prepro Sectors 1-12 | null | POM02.1.03.01.02.05 | C | 16702 | 003,004 | 05 |  | 02 | 4 |  | Yes | S166500 | 1.03 | 1.03A |  |  |  |  |  |  |
| S166600 |  | Fabricate EMCAL Prepro blocks sector 8 | 10d | 2020-07-16 A | 2020-07-29 A | S166500 | 100% |  |  | TECH3 UIUC - Purchased Services [142.8 h]; STUDENT UIUC - Purchased Services [8.4 h]; TECH3 Senior UIUC - Purchased Services [16.8 h] | 9,425.14 | S166600 | 0 | S154600 | Fabricate EMCAL Prepro blocks sector 8 | S154600 | CA | Not Started | A-OPC | Sickles, Anne | L4 | UIUC | Fab & Assy | PP6 | MP203200 | Craig Woody | UIUC | EMCal Prepro Sectors 1-12 | null | POM02.1.03.01.02.05 | C | 16702 | 003,004 | 05 |  | 02 | 4 |  | Yes | S166600 | 1.03 | 1.03A |  |  |  |  |  |  |
| S166700 |  | Fabricate EMCAL Prepro blocks sector 9 | 10d | 2020-07-30 A | 2020-08-14 A | S166600 | 100% | 2020-07-30 | 2020-08-12 | TECH3 UIUC - Purchased Services [142.8 h]; STUDENT UIUC - Purchased Services [8.4 h]; TECH3 Senior UIUC - Purchased Services [16.8 h] | 9,425.14 | S166700 | 0 | S154700 | Fabricate EMCAL Prepro blocks sector 9 | S154700 | CA | Not Started | A-OPC | Sickles, Anne | L4 | UIUC | Fab & Assy | PP6 | MP203200 | Craig Woody | UIUC | EMCal Prepro Sectors 1-12 | null | POM02.1.03.01.02.05 | C | 16702 | 003,004 | 05 |  | 02 | 4 |  | Yes | S166700 | 1.03 | 1.03A |  |  |  |  |  |  |
| S166800 |  | Fabricate EMCAL Prepro blocks sector 10 | 10d | 2020-08-17 A | 2020-09-11 A | S166700 | 100% | 2020-08-17 | 2020-08-28 | TECH3 UIUC - Purchased Services [142.8 h]; STUDENT UIUC - Purchased Services [8.4 h]; TECH3 Senior UIUC - Purchased Services [16.8 h] | 9,425.14 | S166800 | 0 | S154800 | Fabricate EMCAL Prepro blocks sector 10 | S154800 | CA | Not Started | A-OPC | Sickles, Anne | L4 | UIUC | Fab & Assy | PP6 | MP203200 | Craig Woody | UIUC | EMCal Prepro Sectors 1-12 | null | POM02.1.03.01.02.05 | C | 16702 | 003,004 | 05 |  | 02 | 4 |  | Yes | S166800 | 1.03 | 1.03A |  |  |  |  |  |  |
| S166900 |  | Fabricate EMCAL Prepro blocks sector 11 | 10d | 2020-09-14 A | 2020-09-25 A | S166800 | 100% |  |  | TECH3 UIUC - Purchased Services [142.8 h]; STUDENT UIUC - Purchased Services [8.4 h]; TECH3 Senior UIUC - Purchased Services [16.8 h] | 9,425.14 | S166900 | 0 | S154900 | Fabricate EMCAL Prepro blocks sector 11 | S154900 | CA | Not Started | A-OPC | Sickles, Anne | L4 | UIUC | Fab & Assy | PP6 | MP203200 | Craig Woody | UIUC | EMCal Prepro Sectors 1-12 | null | POM02.1.03.01.02.05 | C | 16702 | 003,004 | 05 |  | 02 | 4 |  | Yes | S166900 | 1.03 | 1.03A |  |  |  |  |  |  |
| S167000 |  | Fabricate EMCAL Prepro blocks sector 12 | 10d | 2020-09-28 A | 2020-10-09 A | S166900 | 100% |  |  | TECH3 UIUC - Purchased Services [142.8 h]; STUDENT UIUC - Purchased Services [8.4 h]; TECH3 Senior UIUC - Purchased Services [16.8 h] | 9,623.07 | S167000 | 0 | S155000 | Fabricate EMCAL Prepro blocks sector 12 | S155000 | CA | Not Started | A-OPC | Sickles, Anne | L4 | UIUC | Fab & Assy | PP6 | MP203200 | Craig Woody | UIUC | EMCal Prepro Sectors 1-12 | null | POM02.1.03.01.02.05 | C | 16702 | 003,004 | 05 |  | 02 | 4 |  | Yes | S167000 | 1.03 | 1.03A |  |  |  |  |  |  |
|  | 06 | **Pack and ship EMCal Blocks for Prepro Sectors 1-12 to BNL** |  | 2019-07-01 | 2020-10-19 |  |  |  |  |  |  |  |  |  |  |  |  |  |  |  |  |  |  |  |  |  |  |  |  |  |  |  |  |  |  |  |  |  |  |  |  |  |  |  |  |  |  |  |
| S167100 |  | Pack and ship EMCAL blocks for Prepro sector 1 to BNL Purchased Services | 5d | 2019-07-01 A | 2019-11-29 A | S179300 SS | 100% | 2019-07-01 | 2019-07-08 | STUDENT UIUC - Purchased Services [12 h]; TECH3 UIUC - Purchased Services [4 h]; TECH3 Senior UIUC - Purchased Services [4 h] | 831.42 | S167100 | 0 | S155100 | Pack and ship EMCAL blocks for Prepro sector 1 to BNL Labor | S155100 | CA | Completed | A-OPC | Sickles, Anne | L4 | UIUC | Fab & Assy | PP6 | MP203200 | Craig Woody | UIUC | EMCal Prepro Sectors 1-12 | null | POM02.1.03.01.02.06 | C | 16702 | 003 | 06 |  | 02 | 4 |  | Yes | S167100 | 1.03 | 1.03A |  |  |  |  |  |  |
| S167200 |  | Pack and ship EMCAL blocks for Prepro sector 1 to BNL M&S | 5d | 2019-07-01 A | 2019-11-29 A | S179300 SS | 100% | 2019-07-01 | 2019-07-08 | UIUC Contracted Purchase <$2M M&S [1080 h] | 1,191.53 | S167200 | 0 | S155200 | Pack and ship EMCAL blocks for Prepro sector 1 to BNL M&S | S155200 | CA | Completed | A-OPC | Sickles, Anne | M4 | UIUC | Fab & Assy | PP6 | MP203200 | Craig Woody | UIUC | EMCal Prepro Sectors 1-12 | OPC | POM02.1.03.01.02.06 | F | 16702 | 003 | 06 |  | 02 | 4 |  | Yes | S167200 | 1.03 | 1.03A | UDF_G2 | OPC001300 |  |  |  |  |
| S167300 |  | Pack and ship EMCAL blocks for Prepro sector 2 to BNL Purchased Services | 5d | 2019-12-11 A | 2020-01-28 A | S166000, S179300 SS | 100% | 2020-01-02 | 2020-01-08 | STUDENT UIUC - Purchased Services [12 h]; TECH3 UIUC - Purchased Services [4 h]; TECH3 Senior UIUC - Purchased Services [4 h] | 865.95 | S167300 | 0 | S155300 | Pack and ship EMCAL blocks for Prepro sector 2 to BNL Labor | S155300 | CA | Not Started | A-OPC | Sickles, Anne | L4 | UIUC | Fab & Assy | PP6 | MP203200 | Craig Woody | UIUC | EMCal Prepro Sectors 1-12 | null | POM02.1.03.01.02.06 | C | 16702 | 003 | 06 |  | 02 | 4 |  | Yes | S167300 | 1.03 | 1.03A |  |  | 180410 ELM pred/succ per GRY |  |  |  |
| S167400 |  | Pack and ship EMCAL blocks for Prepro sector 2 to BNL M&S | 5d | 2019-12-11 A | 2020-01-28 A | S166000, S179300 SS | 100% | 2020-01-02 | 2020-01-08 | UIUC Contracted Purchase <$2M M&S [1080 h] | 1,228.96 | S167400 | 0 | S155400 | Pack and ship EMCAL blocks for Prepro sector 2 to BNL M&S | S155400 | CA | Not Started | A-OPC | Sickles, Anne | M4 | UIUC | Fab & Assy | PP6 | MP203200 | Craig Woody | UIUC | EMCal Prepro Sectors 1-12 | OPC | POM02.1.03.01.02.06 | F | 16702 | 003 | 06 |  | 02 | 4 |  | Yes | S167400 | 1.03 | 1.03A | UDF_G2 | OPC001300 | 180410 ELM pred/succ per GRY | UDF_G3 |  |  |
| S167500 |  | Pack and ship EMCAL blocks for Prepro sector 3 to BNL Purchased Services | 5d | 2020-02-03 A | 2020-02-07 A | S166100, S179300 SS | 100% |  |  | STUDENT UIUC - Purchased Services [12 h]; TECH3 UIUC - Purchased Services [4 h]; TECH3 Senior UIUC - Purchased Services [4 h] | 865.95 | S167500 | 0 | S155500 | Pack and ship EMCAL blocks for Prepro sector 3 to BNL Labor | S155500 | CA | Not Started | A-OPC | Sickles, Anne | L4 | UIUC | Fab & Assy | PP6 | MP203200 | Craig Woody | UIUC | EMCal Prepro Sectors 1-12 | null | POM02.1.03.01.02.06 | C | 16702 | 003 | 06 |  | 02 | 4 |  | Yes | S167500 | 1.03 | 1.03A |  |  | 180410 ELM pred/succ per GRY |  |  |  |
| S167600 |  | Pack and ship EMCAL blocks for Prepro sector 3 to BNL M&S | 5d | 2020-02-03 A | 2020-02-07 A | S166100, S179300 SS | 100% |  |  | UIUC Contracted Purchase <$2M M&S [1080 h] | 1,228.96 | S167600 | 0 | S155600 | Pack and ship EMCAL blocks for Prepro sector 3 to BNL M&S | S155600 | CA | Not Started | A-OPC | Sickles, Anne | M4 | UIUC | Fab & Assy | PP6 | MP203200 | Craig Woody | UIUC | EMCal Prepro Sectors 1-12 | OPC | POM02.1.03.01.02.06 | F | 16702 | 003 | 06 |  | 02 | 4 |  | Yes | S167600 | 1.03 | 1.03A | UDF_G2 | OPC001300 | 180410 ELM pred/succ per GRY | UDF_G3 |  |  |
| S167700 |  | Pack and ship EMCAL blocks for Prepro sector 4 to BNL Purchased Services | 5d | 2020-05-01 A | 2020-05-07 A | S166200, S179300 SS | 100% |  |  | STUDENT UIUC - Purchased Services [12 h]; TECH3 UIUC - Purchased Services [4 h]; TECH3 Senior UIUC - Purchased Services [4 h] | 865.95 | S167700 | 0 | S155700 | Pack and ship EMCAL blocks for Prepro sector 4 to BNL Labor | S155700 | CA | Not Started | A-OPC | Sickles, Anne | L4 | UIUC | Fab & Assy | PP6 | MP203200 | Craig Woody | UIUC | EMCal Prepro Sectors 1-12 | null | POM02.1.03.01.02.06 | C | 16702 | 003 | 06 |  | 02 | 4 |  | Yes | S167700 | 1.03 | 1.03A |  |  | 180410 ELM pred/succ per GRY |  |  |  |
| S167800 |  | Pack and ship EMCAL blocks for Prepro sector 4 to BNL M&S | 5d | 2020-05-01 A | 2020-05-07 A | S166200, S179300 SS | 100% |  |  | UIUC Contracted Purchase <$2M M&S [1080 h] | 1,228.96 | S167800 | 0 | S155800 | Pack and ship EMCAL blocks for Prepro sector 4 to BNL M&S | S155800 | CA | Not Started | A-OPC | Sickles, Anne | M4 | UIUC | Fab & Assy | PP6 | MP203200 | Craig Woody | UIUC | EMCal Prepro Sectors 1-12 | OPC | POM02.1.03.01.02.06 | F | 16702 | 003 | 06 |  | 02 | 4 |  | Yes | S167800 | 1.03 | 1.03A | UDF_G1 | OPC001300 | 180410 ELM pred/succ per GRY | UDF_G3 | 1228.959853 | 1 |
| S167900 |  | Pack and ship EMCAL blocks for Prepro sector 5 to BNL Purchased Services | 5d | 2020-06-01 A | 2020-06-05 A | S166300, S179300 SS | 100% |  |  | STUDENT UIUC - Purchased Services [12 h]; TECH3 UIUC - Purchased Services [4 h]; TECH3 Senior UIUC - Purchased Services [4 h] | 865.95 | S167900 | 0 | S155900 | Pack and ship EMCAL blocks for Prepro sector 5 to BNL Labor | S155900 | CA | Not Started | A-OPC | Sickles, Anne | L4 | UIUC | Fab & Assy | PP6 | MP203200 | Craig Woody | UIUC | EMCal Prepro Sectors 1-12 | null | POM02.1.03.01.02.06 | C | 16702 | 003 | 06 |  | 02 | 4 |  | Yes | S167900 | 1.03 | 1.03A |  |  | 180410 ELM pred/succ per GRY |  |  |  |
| S168000 |  | Pack and ship EMCAL blocks for Prepro sector 5 to BNL M&S | 5d | 2020-06-01 A | 2020-06-05 A | S166300, S179300 SS | 100% |  |  | UIUC Contracted Purchase <$2M M&S [1080 h] | 1,228.96 | S168000 | 0 | S156000 | Pack and ship EMCAL blocks for Prepro sector 5 to BNL M&S | S156000 | CA | Not Started | A-OPC | Sickles, Anne | M4 | UIUC | Fab & Assy | PP6 | MP203200 | Craig Woody | UIUC | EMCal Prepro Sectors 1-12 | OPC | POM02.1.03.01.02.06 | F | 16702 | 003 | 06 |  | 02 | 4 |  | Yes | S168000 | 1.03 | 1.03A | UDF_G1 | OPC001300 | 180410 ELM pred/succ per GRY | UDF_G3 | 1228.959853 | 1 |
| S168100 |  | Pack and ship EMCAL blocks for Prepro sector 6 to BNL Purchased Services | 5d | 2020-07-01 A | 2020-07-08 A | S166400, S179300 SS | 100% |  |  | STUDENT UIUC - Purchased Services [12 h]; TECH3 UIUC - Purchased Services [4 h]; TECH3 Senior UIUC - Purchased Services [4 h] | 865.95 | S168100 | 0 | S156100 | Pack and ship EMCAL blocks for Prepro sector 6 to BNL Labor | S156100 | CA | Not Started | A-OPC | Sickles, Anne | L4 | UIUC | Fab & Assy | PP6 | MP203200 | Craig Woody | UIUC | EMCal Prepro Sectors 1-12 | null | POM02.1.03.01.02.06 | C | 16702 | 003 | 06 |  | 02 | 4 |  | Yes | S168100 | 1.03 | 1.03A |  |  | 180410 ELM pred/succ per GRY |  |  |  |
| S168200 |  | Pack and ship EMCAL blocks for Prepro sector 6 to BNL M&S | 5d | 2020-07-01 A | 2020-07-08 A | S166400, S179300 SS | 100% |  |  | UIUC Contracted Purchase <$2M M&S [1080 h] | 1,228.96 | S168200 | 0 | S156200 | Pack and ship EMCAL blocks for Prepro sector 6 to BNL M&S | S156200 | CA | Not Started | A-OPC | Sickles, Anne | M4 | UIUC | Fab & Assy | PP6 | MP203200 | Craig Woody | UIUC | EMCal Prepro Sectors 1-12 | OPC | POM02.1.03.01.02.06 | F | 16702 | 003 | 06 |  | 02 | 4 |  | Yes | S168200 | 1.03 | 1.03A | UDF_G1 | OPC001300 | 180410 ELM pred/succ per GRY | UDF_G3 | 1228.959853 | 1 |
| S168300 |  | Pack and ship EMCAL blocks for Prepro sector 7 to BNL Purchased Services | 5d | 2020-07-16 A | 2020-07-22 A | S166500, S179300 SS | 100% |  |  | STUDENT UIUC - Purchased Services [12 h]; TECH3 UIUC - Purchased Services [4 h]; TECH3 Senior UIUC - Purchased Services [4 h] | 865.95 | S168300 | 0 | S156300 | Pack and ship EMCAL blocks for Prepro sector 7 to BNL Labor | S156300 | CA | Not Started | A-OPC | Sickles, Anne | L4 | UIUC | Fab & Assy | PP6 | MP203200 | Craig Woody | UIUC | EMCal Prepro Sectors 1-12 | null | POM02.1.03.01.02.06 | C | 16702 | 003 | 06 |  | 02 | 4 |  | Yes | S168300 | 1.03 | 1.03A |  |  | 180410 ELM pred/succ per GRY |  |  |  |
| S168400 |  | Pack and ship EMCAL blocks for Prepro sector 7 to BNL M&S | 5d | 2020-07-16 A | 2020-07-22 A | S166500, S179300 SS | 100% |  |  | UIUC Contracted Purchase <$2M M&S [1080 h] | 1,228.96 | S168400 | 0 | S156400 | Pack and ship EMCAL blocks for Prepro sector 7 to BNL M&S | S156400 | CA | Not Started | A-OPC | Sickles, Anne | M4 | UIUC | Fab & Assy | PP6 | MP203200 | Craig Woody | UIUC | EMCal Prepro Sectors 1-12 | OPC | POM02.1.03.01.02.06 | F | 16702 | 003 | 06 |  | 02 | 4 |  | Yes | S168400 | 1.03 | 1.03A | UDF_G1 | OPC001300 | 180410 ELM pred/succ per GRY | UDF_G3 | 1228.959853 | 1 |
| S168500 |  | Pack and ship EMCAL blocks for Prepro sector 8 to BNL Purchased Services | 5d | 2020-08-03 A | 2020-08-07 A | S166600, S179300 SS | 100% |  |  | STUDENT UIUC - Purchased Services [12 h]; TECH3 UIUC - Purchased Services [4 h]; TECH3 Senior UIUC - Purchased Services [4 h] | 865.95 | S168500 | 0 | S156500 | Pack and ship EMCAL blocks for Prepro sector 8 to BNL Labor | S156500 | CA | Not Started | A-OPC | Sickles, Anne | L4 | UIUC | Fab & Assy | PP6 | MP203200 | Craig Woody | UIUC | EMCal Prepro Sectors 1-12 | null | POM02.1.03.01.02.06 | C | 16702 | 003 | 06 |  | 02 | 4 |  | Yes | S168500 | 1.03 | 1.03A |  |  | 180410 ELM pred/succ per GRY |  |  |  |
| S168600 |  | Pack and ship EMCAL blocks for Prepro sector 8 to BNL M&S | 5d | 2020-08-03 A | 2020-08-07 A | S166600, S179300 SS | 100% |  |  | UIUC Contracted Purchase <$2M M&S [1080 h] | 1,228.96 | S168600 | 0 | S156600 | Pack and ship EMCAL blocks for Prepro sector 8 to BNL M&S | S156600 | CA | Not Started | A-OPC | Sickles, Anne | M4 | UIUC | Fab & Assy | PP6 | MP203200 | Craig Woody | UIUC | EMCal Prepro Sectors 1-12 | OPC | POM02.1.03.01.02.06 | F | 16702 | 003 | 06 |  | 02 | 4 |  | Yes | S168600 | 1.03 | 1.03A | UDF_G1 | OPC001300 | 180410 ELM pred/succ per GRY | UDF_G3 | 1228.959853 | 1 |
| S168700 |  | Pack and ship EMCAL blocks for Prepro sector 9 to BNL Purchased Services | 5d | 2020-09-01 A | 2020-09-08 A | S166700, S179300 SS | 100% |  |  | TECH3 UIUC - Purchased Services [4 h]; STUDENT UIUC - Purchased Services [12 h]; TECH3 Senior UIUC - Purchased Services [4 h] | 865.95 | S168700 | 0 | S156700 | Pack and ship EMCAL blocks for Prepro sector 9 to BNL Labor | S156700 | CA | Not Started | A-OPC | Sickles, Anne | L4 | UIUC | Fab & Assy | PP6 | MP203200 | Craig Woody | UIUC | EMCal Prepro Sectors 1-12 | null | POM02.1.03.01.02.06 | C | 16702 | 003 | 06 |  | 02 | 4 |  | Yes | S168700 | 1.03 | 1.03A |  |  | 180410 ELM pred/succ per GRY |  |  |  |
| S168800 |  | Pack and ship EMCAL blocks for Prepro sector 9 to BNL M&S | 5d | 2020-09-01 A | 2020-09-08 A | S166700, S179300 SS | 100% |  |  | UIUC Contracted Purchase <$2M M&S [1080 h] | 1,228.96 | S168800 | 0 | S156800 | Pack and ship EMCAL blocks for Prepro sector 9 to BNL M&S | S156800 | CA | Not Started | A-OPC | Sickles, Anne | M4 | UIUC | Fab & Assy | PP6 | MP203200 | Craig Woody | UIUC | EMCal Prepro Sectors 1-12 | OPC | POM02.1.03.01.02.06 | F | 16702 | 003 | 06 |  | 02 | 4 |  | Yes | S168800 | 1.03 | 1.03A | UDF_G1 | OPC001300 | 180410 ELM pred/succ per GRY | UDF_G3 | 1228.959853 | 1 |
| S168900 |  | Pack and ship EMCAL blocks for Prepro sector 10 to BNL Purchased Services | 5d | 2020-09-14 A | 2020-09-18 A | S166800, S179300 SS | 100% |  |  | TECH3 UIUC - Purchased Services [4 h]; STUDENT UIUC - Purchased Services [12 h]; TECH3 Senior UIUC - Purchased Services [4 h] | 865.95 | S168900 | 0 | S156900 | Pack and ship EMCAL blocks for Prepro sector 10 to BNL Labor | S156900 | CA | Not Started | A-OPC | Sickles, Anne | L4 | UIUC | Fab & Assy | PP6 | MP203200 | Craig Woody | UIUC | EMCal Prepro Sectors 1-12 | null | POM02.1.03.01.02.06 | C | 16702 | 003 | 06 |  | 02 | 4 |  | Yes | S168900 | 1.03 | 1.03A |  |  | 180410 ELM pred/succ per GRY |  |  |  |
| S169000 |  | Pack and ship EMCAL blocks for Prepro sector 10 to BNL M&S | 5d | 2020-09-14 A | 2020-09-18 A | S166800, S179300 SS | 100% |  |  | UIUC Contracted Purchase <$2M M&S [1080 h] | 1,228.96 | S169000 | 0 | S157000 | Pack and ship EMCAL blocks for Prepro sector 10 to BNL M&S | S157000 | CA | Not Started | A-OPC | Sickles, Anne | M4 | UIUC | Fab & Assy | PP6 | MP203200 | Craig Woody | UIUC | EMCal Prepro Sectors 1-12 | OPC | POM02.1.03.01.02.06 | F | 16702 | 003 | 06 |  | 02 | 4 |  | Yes | S169000 | 1.03 | 1.03A | UDF_G1 | OPC001300 | 180410 ELM pred/succ per GRY | UDF_G3 | 1228.959853 | 1 |
| S169100 |  | Pack and ship EMCAL blocks for Prepro sector 11 to BNL Purchased Services | 5d | 2020-10-01 A | 2020-10-07 A | S166900, S179300 SS | 100% |  |  | TECH3 UIUC - Purchased Services [4 h]; STUDENT UIUC - Purchased Services [12 h]; TECH3 Senior UIUC - Purchased Services [4 h] | 891.93 | S169100 | 0 | S157100 | Pack and ship EMCAL blocks for Prepro sector 11 to BNL Labor | S157100 | CA | Not Started | A-OPC | Sickles, Anne | L4 | UIUC | Fab & Assy | PP6 | MP203200 | Craig Woody | UIUC | EMCal Prepro Sectors 1-12 | null | POM02.1.03.01.02.06 | C | 16702 | 003 | 06 |  | 02 | 4 |  | Yes | S169100 | 1.03 | 1.03A |  |  | 180410 ELM pred/succ per GRY |  |  |  |
| S169200 |  | Pack and ship EMCAL blocks for Prepro sector 11 to BNL M&S | 5d | 2020-10-01 A | 2020-10-07 A | S166900, S179300 SS | 100% |  |  | UIUC Contracted Purchase <$2M M&S [1080 h] | 1,253.54 | S169200 | 0 | S157200 | Pack and ship EMCAL blocks for Prepro sector 11 to BNL M&S | S157200 | CA | Not Started | A-OPC | Sickles, Anne | M4 | UIUC | Fab & Assy | PP6 | MP203200 | Craig Woody | UIUC | EMCal Prepro Sectors 1-12 | OPC | POM02.1.03.01.02.06 | F | 16702 | 003 | 06 |  | 02 | 4 |  | Yes | S169200 | 1.03 | 1.03A | UDF_G1 | OPC001300 | 180410 ELM pred/succ per GRY | UDF_G3 | 1228.959853 | 1 |
| S169300 |  | Pack and ship EMCAL blocks for Prepro sector 12 to BNL Purchased Services | 5d | 2020-10-13 A | 2020-10-19 A | S167000, S179300 SS | 100% |  |  | TECH3 UIUC - Purchased Services [4 h]; STUDENT UIUC - Purchased Services [12 h]; TECH3 Senior UIUC - Purchased Services [4 h] | 891.93 | S169300 | 0 | S157300 | Pack and ship EMCAL blocks for Prepro sector 12 to BNL Labor | S157300 | CA | Not Started | A-OPC | Sickles, Anne | L4 | UIUC | Fab & Assy | PP6 | MP203200 | Craig Woody | UIUC | EMCal Prepro Sectors 1-12 | null | POM02.1.03.01.02.06 | C | 16702 | 003 | 06 |  | 02 | 4 |  | Yes | S169300 | 1.03 | 1.03A |  |  | 180410 ELM pred/succ per GRY |  |  |  |
| S169400 |  | Pack and ship EMCAL blocks for Prepro sector 12 to BNL M&S | 5d | 2020-10-13 A | 2020-10-19 A | S167000, S179300 SS | 100% |  |  | UIUC Contracted Purchase <$2M M&S [1080 h] | 1,253.54 | S169400 | 0 | S157400 | Pack and ship EMCAL blocks for Prepro sector 12 to BNL M&S | S157400 | CA | Not Started | A-OPC | Sickles, Anne | M4 | UIUC | Fab & Assy | PP6 | MP203200 | Craig Woody | UIUC | EMCal Prepro Sectors 1-12 | OPC | POM02.1.03.01.02.06 | F | 16702 | 003 | 06 |  | 02 | 4 |  | Yes | S169400 | 1.03 | 1.03A | UDF_G1 | OPC001300 | 180410 ELM pred/succ per GRY | UDF_G1 | 1228.959853 | 1 |

Notes:
- S165900: BNL_UDF_Status Comments: 190605 IVS link epoxy SS; 190322 ELM dur per GRY/AS; 190322 ELM BL Units
- S165902: BNL_UDF_Status Comments: 190605 IVS link epoxy SS; 190322 ELM dur per GRY/AS; 190322 ELM BL Units
- S166000: BNL_UDF_Status Comments: 190522 IVS REL remove pred 179300; 190322 ELM dur per GRY/AS; 190322 ELM BL Units
- S166100: BNL_UDF_Status Comments: 190522 IVS REL remove pred 179300; 190322 ELM dur per GRY/AS; 190322 ELM BL Units
- S166200: BNL_UDF_Status Comments: 190522 IVS REL remove pred 179300; 190322 ELM dur per GRY/AS; 190322 ELM BL Units
- S166300: BNL_UDF_Status Comments: 190522 IVS REL remove pred 179300; 190322 ELM dur per GRY/AS; 190322 ELM BL Units
- S166400: BNL_UDF_Status Comments: 190522 IVS REL remove pred 179300; 190322 ELM dur per GRY/AS; 190322 ELM BL Units
- S166500: BNL_UDF_Status Comments: 190522 IVS REL remove pred 179300; 190322 ELM BL Units
- S166600: BNL_UDF_Status Comments: 190522 IVS REL remove pred 179300; 190322 ELM BL Units
- S166700: BNL_UDF_Status Comments: 190522 IVS REL remove pred 179300; 190322 ELM BL Units
- S166800: BNL_UDF_Status Comments: 190522 IVS REL remove pred 179300; 190322 ELM BL Units
- S166900: BNL_UDF_Status Comments: 190522 IVS REL remove pred 179300; 190322 ELM BL Units
- S167000: BNL_UDF_Status Comments: 190522 IVS REL remove pred 179300; 190322 ELM BL Units

| ID | WBS | Activity | Type | Duration | Start | Finish | Predecessors | Complete | Remaining | Planned start | Planned finish | Total float | Free float | Constraint | Expected finish | Resources | Cost | BNL_UDF_Temp Text 01 | BNL_UDF_Percent Complete | BNL_UDF_OPC TEC (deprecated) | BNL_UDF_Old Activity ID 181221 | RG Check | BNL_Activity Status | BNL_Fund Source | BNL_Estimator | BNL_Cost Basis | BNL_Location | BNL_EDIA | BNL_Proc Sig Phase | BNL_Proc Sig | BNL_CAM | BNL_Institution | BNL_OPC TEC (deprecated) | BNL_WBS | BNL_LLPs and Precursors | BNL_EVT | BNL_Account Number | BNL_PCR ID | BNL_WBS_Hierarchical | Completed | PMP Summary Part1 | PMP Summary Part2 | Cost = Awarded Proc or Mgmt | BNL_Milestone Level | BNL_Obligation | SPH Proc Register | BNL_UDF_Temp Date 01 | BNL_Cobra WP | Indicator - Procurement | BNL_Master Control Account | BNL_Cobra Control Account | Additional EVT documentation required | Indicator - Float | BNL_R&D FY18-19 | BNL_UDF_Remaining Tot Cost | BNL_UDF_Percent_remaining | Target Milestone Date | Variance | PMP Milestones |
| --- | --- | --- | --- | --- | --- | --- | --- | --- | --- | --- | --- | --- | --- | --- | --- | --- | --- | --- | --- | --- | --- | --- | --- | --- | --- | --- | --- | --- | --- | --- | --- | --- | --- | --- | --- | --- | --- | --- | --- | --- | --- | --- | --- | --- | --- | --- | --- | --- | --- | --- | --- | --- | --- | --- | --- | --- | --- | --- | --- |
|  | 03 | **EMCAL Final Block Production** |  |  | 2018-10-01 | 2022-01-07 |  |  |  |  |  |  |  |  |  |  |  |  |  |  |  |  |  |  |  |  |  |  |  |  |  |  |  |  |  |  |  |  |  |  |  |  |  |  |  |  |  |  |  |  |  |  |  |  |  |  |  |  |  |
|  | 01 | **Order Material for EMCAL Final Block Production** |  |  | 2018-10-01 | 2021-11-30 |  |  |  |  |  |  |  |  |  |  |  |  |  |  |  |  |  |  |  |  |  |  |  |  |  |  |  |  |  |  |  |  |  |  |  |  |  |  |  |  |  |  |  |  |  |  |  |  |  |  |  |  |  |
| S169600 |  | Procure EMCAL W Powder for Final Blocks - Provide Requirements to Procurement |  | 5d | 2018-10-01 A | 2018-10-05 A | S100500, S160900 SS, S179300 | 100% |  |  |  |  |  |  |  |  |  | S169600 | 100 | S157600 | S157600 | NOCA | Completed | A-OPC | Sickles, Anne | L4 | UIUC | Procurement | PP6 | MP203200 | Craig Woody | UIUC | null | POM02.1.03.01.03.01 | W Powd | C | 16702 | 003 | 01 | yes | 02 | 3 | Yes |  |  |  |  |  |  |  |  |  |  |  |  |  |  |  |  |
| S170400 |  | Procure EMCAL Fibers for final Blocks - Provide Requirements to Procurement |  | 5d | 2018-10-01 A | 2018-10-05 A | S100500, S161800 | 100% |  |  |  |  |  |  |  |  |  | S170400 | 100 | S158300 | S158300 | NOCA | Completed |  | Sickles, Anne |  | UIUC | Procurement | PP1 | MP103000 | Craig Woody | UIUC |  | POM02.1.03.01.03.01 | Fibers |  |  |  | 01 | yes | 02 | 3 | Yes |  |  |  |  |  |  |  |  |  |  |  |  |  |  |  |  |
| S169700 |  | Procure EMCAL W Powder for Final Blocks - Prepare & Send Solicitation |  | 4d | 2018-10-08 A | 2018-10-12 A | S169600 | 100% |  | 2018-10-09 | 2018-10-12 |  |  |  |  |  |  | S169700 | 100 | S157700 | S157700 | NOCA | Completed |  | Sickles, Anne |  | UIUC | Procurement |  |  | Craig Woody | UIUC |  | POM02.1.03.01.03.01 | W Powd |  |  |  | 01 | yes | 02 | 3 |  |  |  |  |  |  |  |  |  |  |  |  |  |  |  |  |  |
| S170500 |  | Procure EMCAL Fibers for Final Blocks- Prepare & Send Solicitation |  | 4d | 2018-10-08 A | 2018-10-12 A | S170400 | 100% |  | 2018-10-09 | 2018-10-12 |  |  |  |  |  |  | S170500 | 100 | S158400 | S158400 | NOCA | Completed |  | Sickles, Anne |  | UIUC | Procurement | PP2 | MP103000 | Craig Woody | UIUC |  | POM02.1.03.01.03.01 | Fibers |  |  |  | 01 | yes | 02 | 3 | Yes |  |  |  |  |  |  |  |  |  |  |  |  |  |  |  |  |
| S169800 |  | Procure EMCAL W Powder for Final Blocks - Vendor Responses |  | 10d | 2018-10-15 A | 2018-10-26 A | S169700 | 100% |  |  |  |  |  |  |  |  |  | S169800 | 100 | S157800 | S157800 | NOCA | Completed |  | Sickles, Anne |  | UIUC | Procurement |  |  | Craig Woody | UIUC |  | POM02.1.03.01.03.01 | W Powd |  |  |  | 01 | yes | 02 | 3 |  |  |  |  |  |  |  |  |  |  |  |  |  |  |  |  |  |
| S170600 |  | Procure EMCAL Fibers for Final Blocks- Vendor Responses |  | 5d | 2018-10-15 A | 2018-10-19 A | S170500 | 100% |  |  |  |  |  |  |  |  |  | S170600 | 100 | S158500 | S158500 | NOCA | Completed |  | Sickles, Anne |  | UIUC | Procurement | PP3 | MP103000 | Craig Woody | UIUC |  | POM02.1.03.01.03.01 | Fibers |  |  |  | 01 | yes | 02 | 3 | Yes |  |  |  |  |  |  |  |  |  |  |  |  |  |  |  |  |
| S170700 |  | Procure EMCAL Fibers for Final Blocks- Vendor Selection |  | 5d | 2018-10-22 A | 2018-10-26 A | S170600 | 100% |  |  |  |  |  |  |  |  |  | S170700 | 100 | S158600 | S158600 | NOCA | Completed |  | Sickles, Anne |  | UIUC | Procurement | PP4 | MP103000 | Craig Woody | UIUC |  | POM02.1.03.01.03.01 | Fibers |  |  |  | 01 | yes | 02 | 3 | Yes |  |  |  |  |  |  |  |  |  |  |  |  |  |  |  |  |
| OBLG170810 |  | Procure EMCAL Fibers for Final Blocks- Obligation |  | 21d | 2018-12-20 A | 2019-01-22 A | S100600, S160900, S161800, S170700 | 100% |  |  |  |  |  |  |  | Obligation Resource |  | S170800 | 100 | S158700 | S158700 |  | Completed | A-TEC | Sickles, Anne |  | UIUC | Procurement | PP5 | MP103000 | Craig Woody | UIUC |  | POM02.1.03.01.03.01 | Fibers |  |  | 001,003 | 01 | yes | 02 | 3 | Yes | L5 | OBLG |  |  |  |  |  |  |  |  |  |  |  |  |  |  |
| S170800 |  | Procure EMCAL Fibers for Final Blocks- Contract Award(s) | milestone | 0d | 2018-12-21 A | 2018-12-21 A | S170700, S161800, S160900, S100600 | 100% |  |  |  |  |  |  |  |  |  | S170800 | 0 | S158700 | S158700 | NOCA | Completed | A-TEC | Sickles, Anne |  | UIUC | Procurement | PP5 | MP103000 | Craig Woody | UIUC |  | POM02.1.03.01.03.01 | Fibers |  |  | 001,003 | 01 | yes | 02 | 3 | Yes | L5 |  | Contract Award |  |  |  |  |  |  |  |  |  |  |  |  |  |
| S170900 |  | Procure EMCAL Fibers for Final Blocks- Contract/PO - Leadtime |  | 72d | 2019-01-02 A | 2019-04-15 A | S170800 SS, OBLG170810 SS | 100% |  |  |  |  |  |  |  |  |  | S170900 | 50 | S158800 | S158800 | NOCA | Completed | A-TEC | Sickles, Anne |  | UIUC | Procurement | PP6 | MP103000 | Craig Woody | UIUC |  | POM02.1.03.01.03.01 | Fibers |  |  | 001 | 01 | yes | 02 | 3 | Yes |  |  |  | 2019-04-15 |  |  |  |  |  |  |  |  |  |  |  |  |
| S171000 |  | Procure EMCAL Fibers for Final Blocks - Delivery Acceptance 1 |  | 9d | 2019-04-05 A | 2019-04-17 A | S170900 | 100% |  |  |  |  |  |  |  |  |  | S171000 | 0 | S158900 | S158900 | NOCA | Completed | A-TEC | Sickles, Anne | M1 | UIUC | Procurement | PP6 | MP103000 | Craig Woody | UIUC | TEC | POM02.1.03.01.03.01 | Fibers | F | 59708 | 001 | 01 | yes | 02 | 3 | Yes |  |  |  |  |  |  |  |  |  |  |  |  |  |  |  |  |
| S171002 |  | Procure EMCAL Fibers for Final Blocks - Delivery Acceptance 2 |  | 3d | 2019-05-01 A | 2019-05-03 A | S171000 | 100% |  |  |  |  |  |  |  |  |  | S171000 | 0 | S158900 | S158900 | NOCA | Completed | A-TEC | Sickles, Anne | M1 | UIUC | Procurement | PP6 | MP103000 | Craig Woody | UIUC | TEC | POM02.1.03.01.03.01 | Fibers | F | 59708 | 001 | 01 | yes | 02 | 3 | Yes |  |  |  |  |  |  |  |  |  |  |  |  |  |  |  |  |
| S169900 |  | Procure EMCAL W Powder for Final Blocks - Vendor Selection |  | 3d | 2019-05-29 A | 2019-05-31 A | S169800 | 100% |  |  |  |  |  |  |  |  |  | S169900 | 0 | S157900 | S157900 | NOCA | Completed |  | Sickles, Anne |  | UIUC | Procurement |  |  | Craig Woody | UIUC |  | POM02.1.03.01.03.01 | W Powd |  |  | 003 | 01 | yes | 02 | 3 |  |  |  |  |  |  |  |  |  |  |  |  |  |  |  |  |  |
| S170000 |  | Procure EMCAL W Powder for Final Blocks - Contract Award(s) | milestone | 0d | 2019-05-31 A | 2019-05-31 A | S169900, S160800, S160900, S161800 | 100% |  |  |  |  |  |  |  |  |  | S170000 | 0 | S158000 | S158000 | NOCA | Completed | A-TEC | Sickles, Anne |  | UIUC | Procurement |  |  | Craig Woody | UIUC |  | POM02.1.03.01.03.01 | W Powd |  |  |  | 01 | yes | 02 | 3 |  | L5 |  | Contract Award |  |  |  |  |  |  |  |  |  |  |  |  |  |
| S171003 |  | Procure EMCAL Fibers for Final Blocks - Delivery Acceptance 3 |  | 12d | 2019-06-03 A | 2019-06-18 A | S171002 | 100% |  |  |  |  |  |  |  | Material (Purchase (1st $2M) [36624 h] | 40,405.98 | S171000 | 0 | S158900 | S158900 | CA | Completed | A-TEC | Sickles, Anne | M1 | UIUC | Procurement | PP6 | MP103000 | Craig Woody | UIUC | TEC | POM02.1.03.01.03.01 | Fibers | F | 59708 | 001 | 01 |  | 02 | 3 | Yes |  |  | Delivery |  | S171003 | UDF_G3 | 1.03 | 1.03A |  |  |  |  |  |  |  |  |
| S172600 |  | Set up factory for final blocks Purchased Services |  | 98d | 2019-06-05 A | 2019-11-25 A | S101000 FS+5d, S179600 | 100% |  | 2019-07-31 | 2019-12-20 |  |  |  |  | TECH3 UIUC - Purchased Services [29 h]; TECH3 Senior UIUC - Purchased Services [50 h] | 7,016.6 | S172600 | 0 | S159700 | S159700 | CA | Completed | A-TEC | Sickles, Anne | L4 | UIUC | Fab & Assy | PP6 | MP203210 | Craig Woody | UIUC | null | POM02.1.03.01.03.01 |  | C | 59708 | 003 | 01 |  | 02 | 5 |  |  | FAB |  |  | S172600 |  | 1.03 | 1.03A | Yes |  |  |  |  |  |  |  |
| S172700 |  | Set up factory for final blocks M&S |  | 98d | 2019-06-05 A | 2019-11-25 A | S101000 FS+5d, S179600 | 100% |  | 2019-07-31 | 2019-12-20 |  |  |  |  | UIUC Contracted Purchase <$2M M&S [2530 h] | 2,840.48 | S172700 | 0 | S159800 | S159800 | CA | Completed | A-TEC | Sickles, Anne | M3 | UIUC | Fab & Assy | PP6 | MP203210 | Craig Woody | UIUC | TEC | POM02.1.03.01.03.01 |  | C | 59708 |  | 01 |  | 02 | 5 |  |  | FAB |  |  | S172700 | UDF_G3 | 1.03 | 1.03A | Yes |  |  |  |  |  |  |  |
| S171004 |  | Procure EMCAL Fibers for Final Blocks - Delivery Acceptance 4 |  | 8d | 2019-06-19 A | 2019-06-28 A | S171003 | 100% |  |  |  |  |  |  |  | Material (Purchase (1st $2M) [36624 h] | 40,405.98 | S171000 | 0 | S158900 | S158900 | CA | Completed | A-TEC | Sickles, Anne | M1 | UIUC | Procurement | PP6 | MP103000 | Craig Woody | UIUC | TEC | POM02.1.03.01.03.01 | Fibers | F | 59708 | 001 | 01 |  | 02 | 3 | Yes |  |  | Delivery |  | S171004 | UDF_G3 | 1.03 | 1.03A |  |  |  |  |  |  |  |  |
| S172800 |  | Prepare fiber assemblies for final blocks |  | 487d | 2019-06-21 A | 2021-08-02 | S163200 SS, S169500 SS, S171000 SS+5d, S179600 | 89% | 44d | 2019-08-21 | 2021-08-02 | 15d | 0d |  | 2021-08-02 | TECH3 UIUC - Purchased Services; STUDENT UIUC - Purchased Services [9360 h]; TECH3 Senior UIUC - Purchased Services | 163,756.61 | S172800 | 0 | S159900 | S159900 | CA | In Progress | A-TEC | Sickles, Anne | L4 | UIUC | Fab & Assy | PP6 | MP203210 | Craig Woody | UIUC | null | POM02.1.03.01.03.01 |  | C | 59708 | 003 | 01 |  | 02 | 5 |  |  | FAB |  |  | S172800 |  | 1.03 | 1.03A | Yes |  |  |  |  |  |  |  |
| S170100 |  | Procure EMCAL W Powder for Final Blocks - Contract/PO - Leadtime |  | 70d | 2019-07-01 A | 2019-11-29 A | S170000 SS | 100% |  | 2019-07-01 | 2019-10-08 |  |  |  |  |  |  | S170100 | 0 | S158100 | S158100 | NOCA | Completed | A-TEC | Sickles, Anne |  | UIUC | Fab & Assy |  |  | Craig Woody | UIUC |  | POM02.1.03.01.03.01 | W Powd |  |  |  | 01 |  | 02 | 5 |  |  |  |  |  |  |  |  |  |  |  |  |  |  |  |  |  |
| S171005 |  | Procure EMCAL Fibers for Final Blocks - Delivery Acceptance 5 |  | 14d | 2019-08-01 A | 2019-08-20 A | S171004 | 100% |  |  |  |  |  |  |  | Material (Purchase (1st $2M) [36624 h] | 40,405.98 | S171000 | 0 | S158900 | S158900 | CA | Completed | A-TEC | Sickles, Anne | M1 | UIUC | Procurement | PP6 | MP103000 | Craig Woody | UIUC | TEC | POM02.1.03.01.03.01 | Fibers | F | 59708 | 001 | 01 |  | 02 | 3 | Yes |  |  | Delivery |  | S171005 | UDF_G3 | 1.03 | 1.03A |  |  |  |  |  |  |  |  |
| S171006 |  | Procure EMCAL Fibers for Final Blocks - Delivery Acceptance 6 |  | 20d | 2019-09-03 A | 2019-09-30 A | S171005 | 100% |  |  |  |  |  |  |  | Material (Purchase (1st $2M) [36624 h] | 40,405.98 | S171000 | 0 | S158900 | S158900 | CA | Completed | A-TEC | Sickles, Anne | M1 | UIUC | Procurement | PP6 | MP103000 | Craig Woody | UIUC | TEC | POM02.1.03.01.03.01 | Fibers | F | 59708 | 001 | 01 |  | 02 | 3 | Yes |  |  | Delivery |  | S171006 | UDF_G3 | 1.03 | 1.03A |  |  |  |  |  |  |  |  |
| S169500 |  | Establish EMCAL final blocks contract with UIUC |  | 20d | 2019-09-12 A | 2019-11-29 A | S101000, S179600 | 100% |  | 2019-09-12 | 2019-10-09 |  |  |  |  | TECH3 Senior UIUC - Purchased Services [10 h] | 1,099.15 | S169500 | 0 | S157500 | S157500 | CA | Completed | A-TEC | Sickles, Anne | L4 | UIUC | Procurement | PP6 | MP203210 | Craig Woody | UIUC | null | POM02.1.03.01.03.01 |  | C | 59708 | 003 | 01 |  | 02 | 3 |  |  | FAB |  |  | S169500 |  | 1.03 | 1.03A |  |  |  |  |  |  |  |  |
| S171007 |  | Procure EMCAL Fibers for Final Blocks - Delivery Acceptance 7 |  | 21d | 2019-10-01 A | 2019-10-30 A | S171006 | 100% |  |  |  |  |  |  |  | Material (Purchase (1st $2M) [36624 h] | 40,858.23 | S171000 | 0 | S158900 | S158900 | CA | Completed | A-TEC | Sickles, Anne | M1 | UIUC | Procurement | PP6 | MP103000 | Craig Woody | UIUC | TEC | POM02.1.03.01.03.01 | Fibers | F | 59708 | 001 | 01 |  | 02 | 3 | Yes |  |  | Delivery |  | S171007 | UDF_G3 | 1.03 | 1.03A |  |  |  |  |  |  |  |  |
| S170200 |  | Procure EMCAL W Powder for Final Blocks - Sectors 13-38 - Delivery Acceptance |  | 5d | 2019-11-01 A | 2019-11-29 A | S170100 FS+5d, S179600 | 100% |  | 2019-12-09 | 2019-12-13 |  |  |  |  | UIUC Contracted Purchase <$2M M&S [475410 h] | 540,981.3 | S170200 | 0 | S158200 | S158200 | CA | Completed | A-TEC | Sickles, Anne | M3 | UIUC | Fab & Assy | PP6 | MP203210 | Craig Woody | UIUC | TEC | POM02.1.03.01.03.01 | W Powd | C | 59708 | 003 | 01 |  | 02 | 5 |  |  | FAB | Delivery |  | S170200 | UDF_G3 | 1.03 | 1.03A |  |  |  |  |  |  |  |  |
| S171008 |  | Procure EMCAL Fibers for Final Blocks - Delivery Acceptance 8 |  | 22d | 2019-11-08 A | 2019-11-25 A | S171007 | 100% |  | 2019-12-02 | 2020-01-02 |  |  |  |  | Material (Purchase (1st $2M) [36624 h] | 40,858.23 | S171000 | 0 | S158900 | S158900 | CA | Completed | A-TEC | Sickles, Anne | M1 | UIUC | Procurement | PP6 | MP103000 | Craig Woody | UIUC | TEC | POM02.1.03.01.03.01 | Fibers | F | 59708 | 001 | 01 |  | 02 | 3 | Yes |  |  | Delivery |  | S171008 | UDF_G3 | 1.03 | 1.03A |  |  |  |  |  |  |  |  |
| S171009 |  | Procure EMCAL Fibers for Final Blocks - Delivery Acceptance 9 |  | 18d | 2019-12-03 A | 2019-12-18 A | S171008 | 100% |  | 2020-01-02 | 2020-01-28 |  |  |  |  | Material (Purchase (1st $2M) [36624 h] | 40,858.23 | S171000 | 0 | S158900 | S158900 | CA | Not Started | A-TEC | Sickles, Anne | M1 | UIUC | Procurement | PP6 | MP103000 | Craig Woody | UIUC | TEC | POM02.1.03.01.03.01 | Fibers | F | 59708 | 001 | 01 |  | 02 | 3 | Yes |  |  | Delivery |  | S171009 | UDF_G3 | 1.03 | 1.03A |  |  |  |  |  |  |  |  |
| S171010 |  | Procure EMCAL Fibers for Final Blocks - Delivery Acceptance 10 |  | 21d | 2020-01-02 A | 2020-01-31 A | S171009 | 100% |  |  |  |  |  |  |  | Material (Purchase (1st $2M) [36624 h] | 40,858.23 | S171000 | 0 | S158900 | S158900 | CA | Not Started | A-TEC | Sickles, Anne | M1 | UIUC | Procurement | PP6 | MP103000 | Craig Woody | UIUC | TEC | POM02.1.03.01.03.01 | Fibers | F | 59708 | 001 | 01 |  | 02 | 3 | Yes |  |  | Delivery |  | S171010 | UDF_G3 | 1.03 | 1.03A |  | UDF_G1 |  |  |  |  |  |  |
| S171011 |  | Procure EMCAL Fibers for Final Blocks - Delivery Acceptance 11 |  | 21d | 2020-02-03 A | 2020-02-28 A | S171010 | 100% |  | 2020-02-03 | 2020-03-03 |  |  |  |  | Material (Purchase (1st $2M) [36624 h] | 40,858.23 | S171000 | 0 | S158900 | S158900 | CA | Not Started | A-TEC | Sickles, Anne | M1 | UIUC | Procurement | PP6 | MP103000 | Craig Woody | UIUC | TEC | POM02.1.03.01.03.01 | Fibers | F | 59708 | 001 | 01 |  | 02 | 3 | Yes |  |  | Delivery |  | S171011 | UDF_G3 | 1.03 | 1.03A |  | UDF_G1 |  |  |  |  |  |  |
| S171012 |  | Procure EMCAL Fibers for Final Blocks - Delivery Acceptance 12 |  | 19d | 2020-03-02 A | 2020-03-26 A | S171011 | 100% |  |  |  |  |  |  |  | Material (Purchase (1st $2M) [36624 h] | 40,858.23 | S171000 | 0 | S158900 | S158900 | CA | Not Started | A-TEC | Sickles, Anne | M1 | UIUC | Procurement | PP6 | MP103000 | Craig Woody | UIUC | TEC | POM02.1.03.01.03.01 | Fibers | F | 59708 | 001 | 01 |  | 02 | 3 | Yes |  |  | Delivery |  | S171012 | UDF_G3 | 1.03 | 1.03A |  | UDF_G1 |  |  |  |  |  |  |
| S171400 |  | Procure EMCAL Epoxy for Final Blocks- Vendor Responses |  | 1d | 2020-03-17 A | 2020-03-25 A | S171300 | 100% |  | 2020-05-22 | 2020-05-22 |  |  |  |  |  |  | S171400 | 0 | S159200 | S159200 | NOCA | Not Started |  | Sickles, Anne |  | UIUC | Procurement | PP3 | MP102600 | Craig Woody | UIUC |  | POM02.1.03.01.03.01 |  |  |  | 003 | 01 |  | 02 | 3 |  |  |  |  |  |  |  |  |  |  |  |  |  |  |  |  |  |
| S171300 |  | Procure EMCAL Epoxy for Final Blocks- Prepare & Send Solicitation |  | 1d | 2020-03-18 A | 2020-03-24 A | S171200 | 100% |  | 2020-05-21 | 2020-05-21 |  |  |  |  |  |  | S171300 | 0 | S159100 | S159100 | NOCA | Not Started |  | Sickles, Anne |  | UIUC | Procurement | PP2 | MP102600 | Craig Woody | UIUC |  | POM02.1.03.01.03.01 |  |  |  | 003 | 01 |  | 02 | 3 |  |  |  |  |  |  |  |  |  |  |  |  |  |  |  |  |  |
| S171500 |  | Procure EMCAL Epoxy for Final Blocks- Vendor Selection |  | 1d | 2020-03-18 A | 2020-03-31 A | S171400 | 100% |  | 2020-05-26 | 2020-05-26 |  |  |  |  |  |  | S171500 | 0 | S159300 | S159300 | NOCA | Not Started |  | Sickles, Anne |  | UIUC | Procurement | PP4 | MP102600 | Craig Woody | UIUC |  | POM02.1.03.01.03.01 |  |  |  | 003 | 01 |  | 02 | 3 |  |  |  |  |  |  |  |  |  |  |  |  |  |  |  |  |  |
| S171200 |  | Procure EMCAL Epoxy for Final Blocks - Provide Requirements to Procurement |  | 1d | 2020-03-19 A | 2020-03-24 A |  | 100% |  | 2020-05-20 | 2020-05-20 |  |  |  |  | TECH3 UIUC - Purchased Services [8 h]; TECH3 Senior UIUC - Purchased Services [8 h] | 1,316.39 | S171200 | 0 | S159000 | S159000 | CA | Not Started | A-TEC | Sickles, Anne | L4 | UIUC | Procurement | PP1 | MP102600 | Craig Woody | UIUC | null | POM02.1.03.01.03.01 |  | C | 59708 | 003 | 01 |  | 02 | 3 |  |  |  |  |  | S171200 |  | 1.03 | 1.03A |  |  |  |  |  |  |  |  |
| S171900 |  | Order parts and fabricate molds for EMCal Sectors 13-64 Blocks - Provide Requirements to Procurement |  | 1d | 2020-03-19 A | 2020-03-24 A | S171200 SS | 100% |  | 2020-05-20 | 2020-05-20 |  |  |  |  |  |  | S171900 | 0 | S153500 | S159605 | NOCA | Not Started |  | Sickles, Anne |  | UIUC | Procurement | PP1 | MP202300 | Craig Woody | UIUC |  | POM02.1.03.01.03.01 |  |  |  | 003 | 01 |  | 02 | 3 |  |  |  |  |  |  |  |  |  |  |  | EMCal Prepro Sectors 1-12 |  |  |  |  |  |
| S172000 |  | Order parts and fabricate molds for EMCal Sectors 13-64 Blocks - Prepare & Send Solicitation |  | 1d | 2020-03-19 A | 2020-03-24 A | S171900 | 100% |  | 2020-05-21 | 2020-05-21 |  |  |  |  |  |  | S172000 | 0 | S153500 | S159610 | NOCA | Not Started |  | Sickles, Anne |  | UIUC | Procurement | PP2 | MP202300 | Craig Woody | UIUC |  | POM02.1.03.01.03.01 |  |  |  | 003 | 01 |  | 02 | 3 |  |  |  |  |  |  |  |  |  |  |  | EMCal Prepro Sectors 1-12 |  |  |  |  |  |
| S172100 |  | Order parts and fabricate molds for EMCal Sectors 13-64 Blocks - Vendor Responses |  | 1d | 2020-03-19 A | 2020-03-24 A | S172000 | 100% |  | 2020-05-22 | 2020-05-22 |  |  |  |  |  |  | S172100 | 0 | S153500 | S159615 | NOCA | Not Started |  | Sickles, Anne |  | UIUC | Procurement | PP3 | MP202300 | Craig Woody | UIUC |  | POM02.1.03.01.03.01 |  |  |  | 003 | 01 |  | 02 | 3 |  |  |  |  |  |  |  |  |  |  |  | EMCal Prepro Sectors 1-12 |  |  |  |  |  |
| S172200 |  | Order parts and fabricate molds for EMCal Sectors 13-64 Blocks - Vendor Selection |  | 1d | 2020-03-19 A | 2020-03-24 A | S172100 | 100% |  | 2020-05-26 | 2020-05-26 |  |  |  |  |  |  | S172200 | 0 | S153500 | S159620 | NOCA | Not Started |  | Sickles, Anne |  | UIUC | Procurement | PP4 | MP202300 | Craig Woody | UIUC |  | POM02.1.03.01.03.01 |  |  |  | 003 | 01 |  | 02 | 3 |  |  |  |  |  |  |  |  |  |  |  | EMCal Prepro Sectors 1-12 |  |  |  |  |  |
| S171600 |  | Procure EMCAL Epoxy for Final Blocks- Contract Award(s) | milestone | 0d | 2020-03-31 A | 2020-03-31 A | S171500, S101000 | 100% |  | 2020-05-27 | 2020-05-27 |  |  |  |  |  |  | S171600 | 0 | S159400 | S159400 | NOCA | Not Started | A-TEC | Sickles, Anne |  | UIUC | Procurement | PP5 | MP102600 | Craig Woody | UIUC |  | POM02.1.03.01.03.01 |  |  |  | 003 | 01 |  | 02 | 3 |  | L5 |  | Contract Award |  |  |  |  |  |  |  |  |  |  |  |  |  |
| S172300 |  | Order parts and fabricate molds for EMCal Sectors 13-64 Blocks - Contract Award(s) | milestone | 0d | 2020-03-31 A | 2020-03-31 A | S172200 | 100% |  | 2020-05-27 | 2020-05-27 |  |  |  |  |  |  | S172300 | 0 | S153500 | S159625 | NOCA | Not Started | A-TEC | Sickles, Anne |  | UIUC | Procurement | PP5 | MP202300 | Craig Woody | UIUC |  | POM02.1.03.01.03.01 |  |  |  | 003 | 01 |  | 02 | 3 |  | L5 |  | Contract Award |  |  |  |  |  |  |  | EMCal Prepro Sectors 1-12 |  |  |  |  |  |
| S171700 |  | Procure EMCAL Epoxy for Final Blocks- Contract/PO - Leadtime |  | 1d | 2020-05-01 A | 2020-07-29 A | S171600 SS, OBLG171610 SS | 100% |  | 2020-07-23 | 2020-07-23 |  |  |  |  |  |  | S171700 | 0 | S159500 | S159500 | NOCA | Not Started |  | Sickles, Anne |  | UIUC | Fab & Assy | PP6 | MP102600 | Craig Woody | UIUC |  | POM02.1.03.01.03.01 |  |  |  | 003 | 01 |  | 02 | 5 |  |  |  |  |  |  |  |  |  |  |  |  |  |  |  |  |  |
| S172400 |  | Order parts and fabricate molds for EMCal Sectors 13-64 Blocks - Contract/PO - Leadtime |  | 1d | 2020-05-01 A | 2020-07-31 A | S172300 SS, OBLG172310 SS | 100% |  | 2020-07-23 | 2020-07-23 |  |  |  |  |  |  | S172400 | 0 | S153500 | S159630 | NOCA | Not Started |  | Sickles, Anne |  | UIUC | Fab & Assy | PP6 | MP202300 | Craig Woody | UIUC |  | POM02.1.03.01.03.01 |  |  |  | 003 | 01 |  | 02 | 5 |  |  |  |  |  |  |  |  |  |  |  | EMCal Prepro Sectors 1-12 |  |  |  |  |  |
| S171013 |  | Procure EMCAL Fibers for Final Blocks - Delivery Acceptance 13 |  | 23d | 2020-05-01 A | 2020-05-12 A | S171012 | 100% |  | 2020-05-01 | 2020-06-03 |  |  |  |  | Material (Purchase (1st $2M) [36624 h] | 40,858.23 | S171000 | 0 | S158900 | S158900 | CA | Not Started | A-TEC | Sickles, Anne | M1 | UIUC | Procurement | PP6 | MP103000 | Craig Woody | UIUC | TEC | POM02.1.03.01.03.01 | Fibers | F | 59708 | 001 | 01 |  | 02 | 3 | Yes |  |  | Delivery |  | S171013 | UDF_G2 | 1.03 | 1.03A |  | UDF_G1 |  | 40858.229556 | 1 |  |  |  |
| S172850 |  | Supervise EMCal Final Block Production |  | 370d | 2020-05-01 A | 2021-11-30 |  | 63% | 125d | 2020-05-01 | 2021-10-21 | 289d | 0d | start on or after 2020-04-01 | 2021-11-30 | Material (Purchase (1st $2M) [52800 h] | 60,986.25 | S172800 | 0 | S159900 | S159900 | CA | In Progress | A-TEC | Sickles, Anne | L4 | UIUC | Fab & Assy | PP6 | MP203210 | Craig Woody | UIUC | null | POM02.1.03.01.03.01 |  | C | 59708 | 011 | 01 |  | 02 | 5 |  |  | FAB |  |  | S172850 | UDF_G2 | 1.03 | 1.03A | Yes | UDF_G3 |  | 60986.252291 | 1 |  |  |  |
| S171014 |  | Procure EMCAL Fibers for Final Blocks - Delivery Acceptance 14 |  | 22d | 2020-05-13 A | 2020-05-27 A | S171013 | 100% |  | 2020-06-04 | 2020-07-06 |  |  |  |  | Material (Purchase (1st $2M) [36624 h] | 40,858.23 | S171000 | 0 | S158900 | S158900 | CA | Not Started | A-TEC | Sickles, Anne | M1 | UIUC | Procurement | PP6 | MP103000 | Craig Woody | UIUC | TEC | POM02.1.03.01.03.01 | Fibers | F | 59708 | 001 | 01 |  | 02 | 3 | Yes |  |  | Delivery |  | S171014 | UDF_G2 | 1.03 | 1.03A |  | UDF_G1 |  | 40858.229556 | 1 |  |  |  |
| S171015 |  | Procure EMCAL Fibers for Final Blocks - Delivery Acceptance 15 |  | 20d | 2020-06-01 A | 2020-06-26 A | S171014 | 100% |  |  |  |  |  |  |  | Material (Purchase (1st $2M) [36624 h] | 40,858.23 | S171000 | 0 | S158900 | S158900 | CA | Not Started | A-TEC | Sickles, Anne | M1 | UIUC | Procurement | PP6 | MP103000 | Craig Woody | UIUC | TEC | POM02.1.03.01.03.01 | Fibers | F | 59708 | 001 | 01 |  | 02 | 3 | Yes |  |  | Delivery |  | S171015 | UDF_G3 | 1.03 | 1.03A |  | UDF_G1 |  | 40858.229556 | 1 |  |  |  |
| OBLG171610 |  | Procure EMCAL Epoxy for Final Blocks- Obligation |  | 1d | 2020-06-02 A | 2020-06-03 A | S171500, S101000 | 100% |  | 2020-08-24 | 2020-08-24 |  |  |  |  | Obligation Resource [103156 h] | 103,156.39 | S171600 | 0 | S159400 | S159400 |  | Not Started | A-TEC | Sickles, Anne |  | UIUC | Procurement | PP5 | MP102600 | Craig Woody | UIUC |  | POM02.1.03.01.03.01 |  |  |  | 003 | 01 |  |  |  |  | L5 | OBLG |  |  |  |  |  |  |  |  |  |  |  |  |  |  |
| S170210 |  | Procure EMCAL W Powder for Final Blocks - Sectors 39-64 - Delivery Acceptance |  | 18d | 2020-06-15 A | 2020-06-26 A | S170200, S101010 FS+66d, S179600, OBLG179611 SS, OBLG179610 | 100% |  | 2020-06-15 | 2020-07-09 |  |  | start on or after 2020-06-15 |  | UIUC Contracted Purchase <$2M M&S [475410 h] | 540,981.3 | S170200 | 0 | S158200 | S158200 | CA | Not Started | A-TEC | Sickles, Anne | M3 | UIUC | Fab & Assy | PP6 | MP203220 | Craig Woody | UIUC | TEC | POM02.1.03.01.03.01 | W Powd | C | 59708 | 011 | 01 |  | 02 | 5 |  |  | FAB | Delivery |  | S170210 | UDF_G2 | 1.03 | 1.03A |  | UDF_G3 |  | 540981.299824 | 1 |  |  |  |
| S170300 |  | EMCal W Powder Acquisition Complete | milestone | 0d | 2020-06-15 A | 2020-06-15 A | S170210 SF | 100% |  |  |  |  |  |  |  |  |  | S170300 | 0 | S158200 | S158260 | NOCA | Not Started |  | Sickles, Anne | M3 | UIUC | Fab & Assy |  |  | Craig Woody | UIUC |  | POM02.1.03.01.03.01 |  |  |  |  | 01 |  | 02 | 5 |  | L2 |  |  |  |  | UDF_G3 |  |  |  | UDF_G3 |  |  |  | 2020-06-30 | 11 | PMP_1x |
| S171016 |  | Procure EMCAL Fibers for Final Blocks - Delivery Acceptance 16 |  | 21d | 2020-07-01 A | 2020-07-30 A | S171015 | 100% |  |  |  |  |  |  |  | Material (Purchase (1st $2M) [36624 h] | 40,858.23 | S171000 | 0 | S158900 | S158900 | CA | Not Started | A-TEC | Sickles, Anne | M1 | UIUC | Procurement | PP6 | MP103000 | Craig Woody | UIUC | TEC | POM02.1.03.01.03.01 | Fibers | F | 59708 | 001 | 01 |  | 02 | 3 | Yes |  |  | Delivery |  | S171016 | UDF_G3 | 1.03 | 1.03A |  | UDF_G3 |  | 40858.229556 | 1 |  |  |  |
| S171017 |  | Procure EMCAL Fibers for Final Blocks - Delivery Acceptance 17 |  | 22d | 2020-08-03 A | 2020-08-31 A | S171016 | 100% |  | 2020-08-03 | 2020-09-01 |  |  |  |  | Material (Purchase (1st $2M) [36624 h] | 40,858.23 | S171000 | 0 | S158900 | S158900 | CA | Not Started | A-TEC | Sickles, Anne | M1 | UIUC | Procurement | PP6 | MP103000 | Craig Woody | UIUC | TEC | POM02.1.03.01.03.01 | Fibers | F | 59708 | 001 | 01 |  | 02 | 3 | Yes |  |  | Delivery |  | S171017 | UDF_G2 | 1.03 | 1.03A |  | UDF_G3 |  | 40858.229556 | 1 |  |  |  |
| S171800 |  | Procure EMCAL Epoxy for Final Blocks - Delivery Acceptance |  | 240d | 2020-08-03 A | 2021-07-19 | S171700 | 55% | 34d |  |  | 15d | 0d |  | 2021-07-19 | UIUC Contracted Purchase <$2M M&S [90653 h] | 104,858.47 | S171800 | 0 | S159600 | S159600 | CA | Not Started | A-TEC | Sickles, Anne | M3 | UIUC | Fab & Assy | PP6 | MP102600 | Craig Woody | UIUC | TEC | POM02.1.03.01.03.01 |  | F | 59708 | 003 | 01 |  | 02 | 5 |  |  | FAB | Delivery |  | S171800 | UDF_G2 | 1.03 | 1.03A |  | UDF_G1 |  | 104674.848932 | 1 |  |  |  |
| S172500 |  | Order parts and fabricate molds for EMCal Sectors 13-64 Blocks - Delivery Acceptance |  | 240d | 2020-08-03 A | 2021-07-19 | S172400 SS | 75% | 34d |  |  | 15d | 0d |  | 2021-07-19 | UIUC Contracted Purchase <$2M M&S [26230 h] | 30,340.28 | S172500 | 0 | S153500 | S159650 | CA | Not Started | A-TEC | Sickles, Anne | M4 | UIUC | Fab & Assy | PP6 | MP202300 | Craig Woody | UIUC | TEC | POM02.1.03.01.03.01 |  | C | 59708 |  | 01 |  | 02 | 5 |  |  | FAB | Delivery |  | S172500 | UDF_G2 | 1.03 | 1.03A |  | UDF_G1 | EMCal Prepro Sectors 1-12 | 30284.765249 | 1 |  |  |  |
| S172900 |  | Production Readiness Review, Safety Review - EMCal Blocks |  | 5d | 2020-08-03 A | 2020-08-07 A | S169500 FS+11d, S179600, S166200 | 100% |  |  |  |  |  |  |  | TECH3 UIUC - Purchased Services [10 h]; TECH3 Senior UIUC - Purchased Services [10 h] | 1,645.49 | S172900 | 0 | S160000 | S160000 | CA | Not Started | A-TEC | Sickles, Anne | L4 | UIUC | Fab & Assy | PP6 | MP203210 | Craig Woody | UIUC | null | POM02.1.03.01.03.01 |  | C | 59708 | 003,004 | 01 |  | 02 | 5 |  |  | FAB |  |  | S172900 |  | 1.03 | 1.03A |  |  |  |  |  |  |  |  |
| OBLG172310 |  | Order parts and fabricate molds for EMCal Sectors 13-64 Blocks - Obligation |  | 1d | 2020-09-01 A | 2020-09-01 A | S172200 | 100% |  |  |  |  |  |  |  | Obligation Resource [29847.8 h] | 29,847.79 | S172300 | 0 | S153500 | S159625 |  | Not Started | A-TEC | Sickles, Anne |  | UIUC | Procurement | PP5 | MP202300 | Craig Woody | UIUC |  | POM02.1.03.01.03.01 |  |  |  | 003 | 01 |  |  |  |  | L5 | OBLG |  |  |  |  |  |  |  |  | EMCal Prepro Sectors 1-12 |  |  |  |  |  |
| S171018 |  | Procure EMCAL Fibers for Final Blocks - Delivery Acceptance 18 |  | 21d | 2020-09-01 A | 2020-09-30 A | S171017 | 100% |  |  |  |  |  |  |  | Material (Purchase (1st $2M) [36624 h] | 40,858.23 | S171000 | 0 | S158900 | S158900 | CA | Not Started | A-TEC | Sickles, Anne | M1 | UIUC | Procurement | PP6 | MP103000 | Craig Woody | UIUC | TEC | POM02.1.03.01.03.01 | Fibers | F | 59708 | 001 | 01 |  | 02 | 3 | Yes |  |  | Delivery |  | S171018 | UDF_G3 | 1.03 | 1.03A |  | UDF_G3 |  | 40858.229556 | 1 |  |  |  |
| S171019 |  | Procure EMCAL Fibers for Final Blocks - Delivery Acceptance 19 |  | 21d | 2020-10-01 A | 2020-10-30 A | S171018 | 100% |  |  |  |  |  |  |  | Material (Purchase (1st $2M) [36624 h] | 40,858.23 | S171000 | 0 | S158900 | S158900 | CA | Not Started | A-TEC | Sickles, Anne | M1 | UIUC | Procurement | PP6 | MP103000 | Craig Woody | UIUC | TEC | POM02.1.03.01.03.01 | Fibers | F | 59708 | 001 | 01 |  | 02 | 3 | Yes |  |  | Delivery |  | S171019 | UDF_G3 | 1.03 | 1.03A |  | UDF_G3 |  | 40858.229556 | 1 |  |  |  |
| S171020 |  | Procure EMCAL Fibers for Final Blocks - Delivery Acceptance 20 |  | 20d | 2020-11-02 A | 2020-11-27 A | S171019 | 100% |  | 2020-11-02 | 2020-12-02 |  |  |  |  | Material (Purchase (1st $2M) [36624 h] | 40,858.23 | S171000 | 0 | S158900 | S158900 | CA | Not Started | A-TEC | Sickles, Anne | M1 | UIUC | Procurement | PP6 | MP103000 | Craig Woody | UIUC | TEC | POM02.1.03.01.03.01 | Fibers | F | 59708 | 001 | 01 |  | 02 | 3 | Yes |  |  | Delivery |  | S171020 | UDF_G3 | 1.03 | 1.03A |  | UDF_G3 |  | 40858.229556 | 1 |  |  |  |
| S172870 |  | EMCal Block Production QA |  | 147d | 2020-12-01 A | 2021-09-27 |  | 60% | 83d | 2021-01-04 | 2021-08-02 | 4d | 0d |  | 2021-09-27 | Material (Purchase (1st $2M) [460000 h] | 533,914.78 | S172600 | 0 | S159700 | S159700 | CA | Completed | A-TEC | Sickles, Anne | L4 | UIUC | Fab & Assy | PP6 | MP203210 | Craig Woody | UIUC | null | POM02.1.03.01.03.01 |  | C | 59708 | 017 | 01 |  | 02 | 5 |  |  | FAB |  |  | S172870 | UDF_G2 | 1.03 | 1.03A | Yes | UDF_G1 |  |  |  |  |  |  |
| S171021 |  | Procure EMCAL Fibers for Final Blocks - Delivery Acceptance 21 |  | 20d | 2021-01-04 A | 2021-01-18 A | S171020 | 100% |  | 2021-01-04 | 2021-02-01 |  |  |  |  | Material (Purchase (1st $2M) [36624 h] | 40,858.23 | S171000 | 0 | S158900 | S158900 | CA | Not Started | A-TEC | Sickles, Anne | M1 | UIUC | Procurement | PP6 | MP103000 | Craig Woody | UIUC | TEC | POM02.1.03.01.03.01 | Fibers | F | 59708 | 001 | 01 |  | 02 | 3 | Yes |  |  | Delivery |  | S171021 | UDF_G2 | 1.03 | 1.03A |  | UDF_G3 |  | 40858.229556 | 1 |  |  |  |
| S171022 |  | Procure EMCAL Fibers for Final Blocks - Delivery Acceptance 22 |  | 21d | 2021-01-19 A | 2021-01-28 A | S171021 | 100% |  | 2021-02-02 | 2021-03-03 |  |  |  |  | Material (Purchase (1st $2M) [36624 h] | 40,858.23 | S171000 | 0 | S158900 | S158900 | CA | Not Started | A-TEC | Sickles, Anne | M1 | UIUC | Procurement | PP6 | MP103000 | Craig Woody | UIUC | TEC | POM02.1.03.01.03.01 | Fibers | F | 59708 | 001 | 01 |  | 02 | 3 | Yes |  |  | Delivery |  | S171022 | UDF_G2 | 1.03 | 1.03A |  | UDF_G3 |  | 40858.229556 | 1 |  |  |  |
| S171023 |  | Procure EMCAL Fibers for Final Blocks - Delivery Acceptance 23 |  | 20d | 2021-02-01 A | 2021-02-25 A | S171022 | 100% |  | 2021-02-01 | 2021-03-01 |  |  |  |  | Material (Purchase (1st $2M) [34272 h] | 38,234.31 | S171000 | 0 | S158900 | S158900 | CA | Not Started | A-TEC | Sickles, Anne | M1 | UIUC | Procurement | PP6 | MP103000 | Craig Woody | UIUC | TEC | POM02.1.03.01.03.01 | Fibers | F | 59708 | 001 | 01 |  | 02 | 3 | Yes |  |  | Delivery |  | S171023 | UDF_G3 | 1.03 | 1.03A |  | UDF_G3 |  | 38234.306557 | 1 |  |  |  |
| S171100 |  | EMCal Scintillating Fiber Acquisition Complete | milestone | 0d | 2021-02-25 A | 2021-02-25 A | S171023 | 100% |  | 2021-03-01 | 2021-03-01 |  |  |  |  |  |  | S171100 | 0 | S158900 | S158960 | NOCA | Not Started |  | Sickles, Anne | M3 | UIUC | Fab & Assy |  |  | Craig Woody | UIUC |  | POM02.1.03.01.03.01 |  |  |  | 001 | 01 |  | 02 | 5 |  | L2 |  |  |  |  | UDF_G2 |  |  |  | UDF_G1 |  |  |  | 2021-05-31 | 67 | PMP_1x |

Notes:
- S169600: BNL_UDF_Status Comments: 190317 ELM logic / BNL_UDF_Adhoc Comments: 180329 ELM pred per GRY / BNL_UDF_Old Activity Name 181221: Procure EMCAL W Powder for Final Blocks - Provide Requirements to Procurement
- S170400: BNL_UDF_Adhoc Comments: 180329 ELM pred per GRY / BNL_UDF_Old Activity Name 181221: Procure EMCAL Fibers for final Blocks - Provide Requirements to Procurement
- S169700: BNL_UDF_Old Activity Name 181221: Procure EMCAL W Powder for Final Blocks - Prepare & Send Solicitation
- S170500: BNL_UDF_Old Activity Name 181221: Procure EMCAL Fibers for Final Blocks- Prepare & Send Solicitation
- S169800: BNL_UDF_Adhoc Comments: 180329 ELM dur per GRY / BNL_UDF_Old Activity Name 181221: Procure EMCAL W Powder for Final Blocks - Vendor Responses
- S170600: BNL_UDF_Adhoc Comments: 180329 ELM dur per GRY / BNL_UDF_Old Activity Name 181221: Procure EMCAL Fibers for Final Blocks- Vendor Responses
- S170700: BNL_UDF_Old Activity Name 181221: Procure EMCAL Fibers for Final Blocks- Vendor Selection
- OBLG170810: BNL_UDF_Status Comments: 190317 ELM actual dates / BNL_UDF_Old Activity Name 181221: Procure EMCAL Fibers for Final Blocks- Contract Award(s)
- S170800: BNL_UDF_Status Comments: 190317 ELM actual dates / BNL_UDF_Old Activity Name 181221: Procure EMCAL Fibers for Final Blocks- Contract Award(s)
- S170900: BNL_UDF_Old Activity Name 181221: Procure EMCAL Fibers for Final Blocks- Contract/PO - Leadtime
- S171000: BNL_UDF_Old Activity Name 181221: Procure EMCAL Fibers for Final Blocks - Delivery Acceptance
- S171002: BNL_UDF_Old Activity Name 181221: Procure EMCAL Fibers for Final Blocks - Delivery Acceptance
- S169900: BNL_UDF_Status Comments: 190214 ELM dur per GRY / BNL_UDF_Old Activity Name 181221: Procure EMCAL W Powder for Final Blocks - Vendor Selection
- S170000: BNL_UDF_Adhoc Comments: 180420 ELM pred/succ per GRY / BNL_UDF_Old Activity Name 181221: Procure EMCAL W Powder for Final Blocks - Contract Award(s)
- S171003: BNL_UDF_Old Activity Name 181221: Procure EMCAL Fibers for Final Blocks - Delivery Acceptance
- S172600: BNL_UDF_Adhoc Comments: 180410 ELM pred/succ per GRY / BNL_UDF_Old Activity Name 181221: Set up factory for final blocks Labor
- S172700: BNL_UDF_Old Activity Name 181221: Set up factory for final blocks M&S
- S171004: BNL_UDF_Old Activity Name 181221: Procure EMCAL Fibers for Final Blocks - Delivery Acceptance
- S172800: BNL_UDF_Status Comments: 190319 ELM rsrc per GRY/CR / BNL_UDF_Adhoc Comments: 180411 ELM pred/succ,dur per GRY / BNL_UDF_Old Activity Name 181221: Prepare fiber assemblies for final blocks
- S170100: BNL_UDF_Old Activity Name 181221: Procure EMCAL W Powder for Final Blocks - Contract/PO - Leadtime
- S171005: BNL_UDF_Old Activity Name 181221: Procure EMCAL Fibers for Final Blocks - Delivery Acceptance
- S171006: BNL_UDF_Old Activity Name 181221: Procure EMCAL Fibers for Final Blocks - Delivery Acceptance
- S169500: BNL_UDF_Old Activity Name 181221: Establish EMCAL final blocks contract with UIUC
- S171007: BNL_UDF_Old Activity Name 181221: Procure EMCAL Fibers for Final Blocks - Delivery Acceptance
- S170200: BNL_UDF_Status Comments: 190315 ELM Name, BNL Units per EOB, logic per GRY; 190214 ELM name, logic, dur, rsrc per GRY / BNL_UDF_Adhoc Comments: 180410 ELM pred/succ per GRY / BNL_UDF_Old Activity Name 181221: Procure EMCAL W Powder for Final Blocks - Delivery Acceptance
- S171008: BNL_UDF_Old Activity Name 181221: Procure EMCAL Fibers for Final Blocks - Delivery Acceptance
- S171009: BNL_UDF_Old Activity Name 181221: Procure EMCAL Fibers for Final Blocks - Delivery Acceptance
- S171010: BNL_UDF_Old Activity Name 181221: Procure EMCAL Fibers for Final Blocks - Delivery Acceptance
- S171011: BNL_UDF_Old Activity Name 181221: Procure EMCAL Fibers for Final Blocks - Delivery Acceptance
- S171012: BNL_UDF_Old Activity Name 181221: Procure EMCAL Fibers for Final Blocks - Delivery Acceptance
- S171400: BNL_UDF_Status Comments: 190316 ELM add proc strg nos / BNL_UDF_Adhoc Comments: 180330 ELM dur per GRY / BNL_UDF_Old Activity Name 181221: Procure EMCAL Epoxy for Final Blocks- Vendor Responses
- S171300: BNL_UDF_Status Comments: 190316 ELM add proc strg nos / BNL_UDF_Adhoc Comments: 180330 ELM dur per GRY / BNL_UDF_Old Activity Name 181221: Procure EMCAL Epoxy for Final Blocks- Prepare & Send Solicitation
- S171500: BNL_UDF_Status Comments: 190316 ELM add proc strg nos / BNL_UDF_Adhoc Comments: 180330 ELM dur per GRY / BNL_UDF_Old Activity Name 181221: Procure EMCAL Epoxy for Final Blocks- Vendor Selection
- S171200: Scheduler's Notes: 180330 ELM per GRY / This is a fixed catalog number; no / solicitations / BNL_UDF_Status Comments: 190316 ELM add proc strg nos / BNL_UDF_Adhoc Comments: 180330 ELM dur, pred per GRY / BNL_UDF_Old Activity Name 181221: Procure EMCAL Epoxy for Final Blocks - Provide Requirements to Procurement
- S171900: BNL_UDF_Status Comments: 190316 ELM add proc strg nos / BNL_UDF_Adhoc Comments: 180402 ELM added activity for proc strg / BNL_UDF_Old Activity Name 181221: Order parts and fabricate molds for EMCal Sectors 13-64 Blocks - Provide Requirements to Procurement
- S172000: BNL_UDF_Status Comments: 190316 ELM add proc strg nos / BNL_UDF_Adhoc Comments: 180402 ELM added activity for proc strg / BNL_UDF_Old Activity Name 181221: Order parts and fabricate molds for EMCal Sectors 13-64 Blocks - Prepare & Send Solicitation
- S172100: BNL_UDF_Status Comments: 190316 ELM add proc strg nos / BNL_UDF_Adhoc Comments: 180402 ELM added activity for proc strg / BNL_UDF_Old Activity Name 181221: Order parts and fabricate molds for EMCal Sectors 13-64 Blocks - Vendor Responses
- S172200: BNL_UDF_Status Comments: 190316 ELM add proc strg nos / BNL_UDF_Adhoc Comments: 180402 ELM added activity for proc strg / BNL_UDF_Old Activity Name 181221: Order parts and fabricate molds for EMCal Sectors 13-64 Blocks - Vendor Selection
- S171600: BNL_UDF_Status Comments: 190316 ELM add proc strg nos / BNL_UDF_Old Activity Name 181221: Procure EMCAL Epoxy for Final Blocks- Contract Award(s)
- S172300: BNL_UDF_Status Comments: 190316 ELM add proc strg nos / BNL_UDF_Adhoc Comments: 180402 ELM added activity for proc strg / BNL_UDF_Old Activity Name 181221: Order parts and fabricate molds for EMCal Sectors 13-64 Blocks - Contract Award(s)
- S171700: BNL_UDF_Status Comments: 190316 ELM add proc strg nos / BNL_UDF_Old Activity Name 181221: Procure EMCAL Epoxy for Final Blocks- Contract/PO - Leadtime
- S172400: BNL_UDF_Status Comments: 190316 ELM add proc strg nos / BNL_UDF_Adhoc Comments: 180402 ELM added activity for proc strg / BNL_UDF_Old Activity Name 181221: Order parts and fabricate molds for EMCal Sectors 13-64 Blocks - Contract/PO - Leadtime
- S171013: BNL_UDF_Old Activity Name 181221: Procure EMCAL Fibers for Final Blocks - Delivery Acceptance
- S172850: BNL_UDF_Status Comments: 190319 ELM rsrc per GRY/CR / BNL_UDF_Adhoc Comments: 180411 ELM pred/succ,dur per GRY / BNL_UDF_Old Activity Name 181221: Prepare fiber assemblies for final blocks
- S171014: BNL_UDF_Old Activity Name 181221: Procure EMCAL Fibers for Final Blocks - Delivery Acceptance
- S171015: BNL_UDF_Old Activity Name 181221: Procure EMCAL Fibers for Final Blocks - Delivery Acceptance
- OBLG171610: BNL_UDF_Old Activity Name 181221: Procure EMCAL Epoxy for Final Blocks- Contract Award(s)
- S170210: BNL_UDF_Status Comments: 190315 ELM Name, BNL Units per EOB; 190214 ELM new per GRY / BNL_UDF_Adhoc Comments: 180410 ELM pred/succ per GRY / BNL_UDF_Old Activity Name 181221: Procure EMCAL W Powder for Final Blocks - Delivery Acceptance
- S170300: BNL_UDF_Adhoc Comments: 180410 ELM pred/succ per GRY / BNL_UDF_Old Activity Name 181221: EMCal W Powder Acquisition Complete
- S171016: BNL_UDF_Old Activity Name 181221: Procure EMCAL Fibers for Final Blocks - Delivery Acceptance
- S171017: BNL_UDF_Old Activity Name 181221: Procure EMCAL Fibers for Final Blocks - Delivery Acceptance
- S171800: BNL_UDF_Status Comments: 190316 ELM add proc strg nos / BNL_UDF_Adhoc Comments: 180330 ELM dur per GRY / BNL_UDF_Old Activity Name 181221: Procure EMCAL Epoxy for Final Blocks - Delivery Acceptance
- S172500: BNL_UDF_Adhoc Comments: 180411 ELM pred/succ per GRY; 180406 RFG filled in BNL_Cost Basis; / BNL_UDF_Old Activity Name 181221: Order parts and fabricate molds for EMCal Sectors 13-64 Blocks - Delivery Acceptance
- S172900: BNL_UDF_Status Comments: 190522 IVS new name; 190415 ELM name per GRY / BNL_UDF_Old Activity Name 181221: Readiness and Safety Review for final block production
- OBLG172310: BNL_UDF_Adhoc Comments: 180402 ELM added activity for proc strg / BNL_UDF_Old Activity Name 181221: Order parts and fabricate molds for EMCal Sectors 13-64 Blocks - Contract Award(s)
- S171018: BNL_UDF_Old Activity Name 181221: Procure EMCAL Fibers for Final Blocks - Delivery Acceptance
- S171019: BNL_UDF_Old Activity Name 181221: Procure EMCAL Fibers for Final Blocks - Delivery Acceptance
- S171020: BNL_UDF_Old Activity Name 181221: Procure EMCAL Fibers for Final Blocks - Delivery Acceptance
- S172870: BNL_UDF_Adhoc Comments: 180410 ELM pred/succ per GRY / BNL_UDF_Old Activity Name 181221: Set up factory for final blocks Labor
- S171021: BNL_UDF_Old Activity Name 181221: Procure EMCAL Fibers for Final Blocks - Delivery Acceptance
- S171022: BNL_UDF_Old Activity Name 181221: Procure EMCAL Fibers for Final Blocks - Delivery Acceptance
- S171023: BNL_UDF_Old Activity Name 181221: Procure EMCAL Fibers for Final Blocks - Delivery Acceptance
- S171100: BNL_UDF_Old Activity Name 181221: EMCal Scintillating Fiber Acquisition Complete

| ID | WBS | Activity | Type | Duration | Start | Finish | Predecessors | Complete | Remaining | Planned start | Planned finish | Total float | Free float | Expected finish | Resources | Cost | BNL_UDF_Temp Text 01 | BNL_UDF_Percent Complete | BNL_UDF_OPC TEC (deprecated) | BNL_UDF_Old Activity Name 181221 | BNL_UDF_Old Activity ID 181221 | BNL_Cobra WP | RG Check | BNL_Activity Status | BNL_Fund Source | BNL_Estimator | BNL_Cost Basis | BNL_Location | BNL_EDIA | BNL_Proc Sig Phase | BNL_Proc Sig | BNL_CAM | BNL_Institution | BNL_OPC TEC (deprecated) | BNL_WBS | BNL_EVT | BNL_Master Control Account | BNL_Account Number | BNL_Obligation | BNL_PCR ID | BNL_Cobra Control Account | BNL_WBS_Hierarchical | PMP Summary Part1 | PMP Summary Part2 | BNL_UDF_Status Comments | Indicator - Procurement | Indicator - Float | BNL_Milestone Level |
| --- | --- | --- | --- | --- | --- | --- | --- | --- | --- | --- | --- | --- | --- | --- | --- | --- | --- | --- | --- | --- | --- | --- | --- | --- | --- | --- | --- | --- | --- | --- | --- | --- | --- | --- | --- | --- | --- | --- | --- | --- | --- | --- | --- | --- | --- | --- | --- | --- |
|  | 02 | **Fabricate final blocks** |  |  | 2020-10-13 | 2022-01-06 |  |  |  |  |  |  |  |  |  |  |  |  |  |  |  |  |  |  |  |  |  |  |  |  |  |  |  |  |  |  |  |  |  |  |  |  |  |  |  |  |  |  |
| S173000 |  | Fabricate final blocks sector 13 |  | 6d | 2020-10-13 A | 2020-10-20 A | S172900, S170200 SS+30d, S164800, S172800 SS+20d, S172700, S172600, S164000 SS, OBLG179610, S179600 SS, S179600, S171800 SS, S172500 SS, S167000 | 100% |  |  |  |  |  |  | TECH3 UIUC - Purchased Services [50 h]; STUDENT UIUC - Purchased Services [75 h]; TECH3 Senior UIUC - Purchased Services [10 h] | 5,162.69 | S173000 | 0 | S160200 | Fabricate final blocks sector 13 | S160200 | S173000 | CA | Not Started | A-TEC | Sickles, Anne | L4 | UIUC | Fab & Assy | PP6 | MP203210 | Craig Woody | UIUC | null | POM02.1.03.01.03.02 | C | 1.03 | 59708 | FAB | 003 | 1.03A | 02 | 02 | 5 |  |  |  |  |
| S173300 |  | Fabricate final blocks sector 16 |  | 6d | 2020-10-21 A | 2020-11-16 A | S173200 | 100% |  | 2020-11-06 | 2020-11-16 |  |  |  | TECH3 UIUC - Purchased Services [50 h]; STUDENT UIUC - Purchased Services [75 h]; TECH3 Senior UIUC - Purchased Services [10 h] | 5,162.69 | S173300 | 0 | S160500 | Fabricate final blocks sector 16 | S160500 | S173300 | CA | Not Started | A-TEC | Sickles, Anne | L4 | UIUC | Fab & Assy | PP6 | MP203210 | Craig Woody | UIUC | null | POM02.1.03.01.03.02 | C | 1.03 | 59708 | FAB | 003,004 | 1.03A | 02 | 02 | 5 | 190522 IVS REL remove pred. 179600 |  |  |  |
| S173100 |  | Fabricate final blocks sector 14 |  | 6d | 2020-10-21 A | 2020-10-28 A | S173000 | 100% |  |  |  |  |  |  | TECH3 UIUC - Purchased Services [50 h]; STUDENT UIUC - Purchased Services [75 h]; TECH3 Senior UIUC - Purchased Services [10 h] | 5,162.69 | S173100 | 0 | S160300 | Fabricate final blocks sector 14 | S160300 | S173100 | CA | Not Started | A-TEC | Sickles, Anne | L4 | UIUC | Fab & Assy | PP6 | MP203210 | Craig Woody | UIUC | null | POM02.1.03.01.03.02 | C | 1.03 | 59708 | FAB | 003,004 | 1.03A | 02 | 02 | 5 | 190522 IVS REL remove pred. 179600 |  |  |  |
| S173200 |  | Fabricate final blocks sector 15 |  | 6d | 2020-10-22 A | 2020-10-30 A | S173100 | 100% |  | 2020-10-29 | 2020-11-05 |  |  |  | TECH3 UIUC - Purchased Services [50 h]; STUDENT UIUC - Purchased Services [75 h]; TECH3 Senior UIUC - Purchased Services [10 h] | 5,162.69 | S173200 | 0 | S160400 | Fabricate final blocks sector 15 | S160400 | S173200 | CA | Not Started | A-TEC | Sickles, Anne | L4 | UIUC | Fab & Assy | PP6 | MP203210 | Craig Woody | UIUC | null | POM02.1.03.01.03.02 | C | 1.03 | 59708 | FAB | 003,004 | 1.03A | 02 | 02 | 5 | 190522 IVS REL remove pred. 179600 |  |  |  |
| S173400 |  | Fabricate final blocks sector 17 |  | 6d | 2020-11-17 A | 2020-11-24 A | S173300 | 100% |  |  |  |  |  |  | TECH3 UIUC - Purchased Services [50 h]; STUDENT UIUC - Purchased Services [75 h]; TECH3 Senior UIUC - Purchased Services [10 h] | 5,162.69 | S173400 | 0 | S160600 | Fabricate final blocks sector 17 | S160600 | S173400 | CA | Not Started | A-TEC | Sickles, Anne | L4 | UIUC | Fab & Assy | PP6 | MP203210 | Craig Woody | UIUC | null | POM02.1.03.01.03.02 | C | 1.03 | 59708 | FAB | 003,004 | 1.03A | 02 | 02 | 5 | 190522 IVS REL remove pred. 179600 |  |  |  |
| S173500 |  | Fabricate final blocks sector 18 |  | 6d | 2020-11-25 A | 2020-12-08 A | S173400 | 100% |  | 2020-11-25 | 2020-12-04 |  |  |  | TECH3 UIUC - Purchased Services [50 h]; STUDENT UIUC - Purchased Services [75 h]; TECH3 Senior UIUC - Purchased Services [10 h] | 5,162.69 | S173500 | 0 | S160700 | Fabricate final blocks sector 18 | S160700 | S173500 | CA | Not Started | A-TEC | Sickles, Anne | L4 | UIUC | Fab & Assy | PP6 | MP203210 | Craig Woody | UIUC | null | POM02.1.03.01.03.02 | C | 1.03 | 59708 | FAB | 003,004 | 1.03A | 02 | 02 | 5 | 190522 IVS REL remove pred. 179600 |  |  |  |
| S173600 |  | Fabricate final blocks sector 19 |  | 6d | 2020-12-09 A | 2020-12-16 A | S173500 | 100% |  |  |  |  |  |  | TECH3 UIUC - Purchased Services [50 h]; STUDENT UIUC - Purchased Services [75 h]; TECH3 Senior UIUC - Purchased Services [10 h] | 5,162.69 | S173600 | 0 | S160800 | Fabricate final blocks sector 19 | S160800 | S173600 | CA | Not Started | A-TEC | Sickles, Anne | L4 | UIUC | Fab & Assy | PP6 | MP203210 | Craig Woody | UIUC | null | POM02.1.03.01.03.02 | C | 1.03 | 59708 | FAB | 003,004 | 1.03A | 02 | 02 | 5 | 190522 IVS REL remove pred. 179600 |  |  |  |
| S173700 |  | Fabricate final blocks sector 20 |  | 6d | 2020-12-17 A | 2021-01-11 A | S173600 | 100% |  | 2020-12-17 | 2020-12-24 |  |  |  | TECH3 UIUC - Purchased Services [50 h]; STUDENT UIUC - Purchased Services [75 h]; TECH3 Senior UIUC - Purchased Services [10 h] | 5,162.69 | S173700 | 0 | S160900 | Fabricate final blocks sector 20 | S160900 | S173700 | CA | Not Started | A-TEC | Sickles, Anne | L4 | UIUC | Fab & Assy | PP6 | MP203210 | Craig Woody | UIUC | null | POM02.1.03.01.03.02 | C | 1.03 | 59708 | FAB | 003,004 | 1.03A | 02 | 02 | 5 | 190522 IVS REL remove pred. 179600 |  |  |  |
| S173800 |  | Fabricate final blocks sector 21 |  | 6d | 2021-01-12 A | 2021-01-20 A | S173700 | 100% |  |  |  |  |  |  | TECH3 UIUC - Purchased Services [50 h]; STUDENT UIUC - Purchased Services [75 h]; TECH3 Senior UIUC - Purchased Services [10 h] | 5,162.69 | S173800 | 0 | S161000 | Fabricate final blocks sector 21 | S161000 | S173800 | CA | Not Started | A-TEC | Sickles, Anne | L4 | UIUC | Fab & Assy | PP6 | MP203210 | Craig Woody | UIUC | null | POM02.1.03.01.03.02 | C | 1.03 | 59708 | FAB | 003,004 | 1.03A | 02 | 02 | 5 | 190522 IVS REL remove pred. 179600 |  |  |  |
| S173900 |  | Fabricate final blocks sector 22 |  | 6d | 2021-01-21 A | 2021-02-08 A | S173800 | 100% |  | 2021-01-21 | 2021-01-28 |  |  |  | TECH3 UIUC - Purchased Services [50 h]; STUDENT UIUC - Purchased Services [75 h]; TECH3 Senior UIUC - Purchased Services [10 h] | 5,162.69 | S173900 | 0 | S161100 | Fabricate final blocks sector 22 | S161100 | S173900 | CA | Not Started | A-TEC | Sickles, Anne | L4 | UIUC | Fab & Assy | PP6 | MP203210 | Craig Woody | UIUC | null | POM02.1.03.01.03.02 | C | 1.03 | 59708 | FAB | 003,004 | 1.03A | 02 | 02 | 5 | 190522 IVS REL remove pred. 179600 |  |  |  |
| S174000 |  | Fabricate final blocks sector 23 |  | 6d | 2021-02-09 A | 2021-02-17 A | S173900 | 100% |  |  |  |  |  |  | TECH3 UIUC - Purchased Services [50 h]; STUDENT UIUC - Purchased Services [75 h]; TECH3 Senior UIUC - Purchased Services [10 h] | 5,162.69 | S174000 | 0 | S161200 | Fabricate final blocks sector 23 | S161200 | S174000 | CA | Not Started | A-TEC | Sickles, Anne | L4 | UIUC | Fab & Assy | PP6 | MP203210 | Craig Woody | UIUC | null | POM02.1.03.01.03.02 | C | 1.03 | 59708 | FAB | 003,004 | 1.03A | 02 | 02 | 5 | 190522 IVS REL remove pred. 179600 |  |  |  |
| S174100 |  | Fabricate final blocks sector 24 |  | 6d | 2021-02-18 A | 2021-02-22 A | S174000 | 100% |  | 2021-02-18 | 2021-02-25 |  |  |  | TECH3 UIUC - Purchased Services [50 h]; STUDENT UIUC - Purchased Services [75 h]; TECH3 Senior UIUC - Purchased Services [10 h] | 5,162.69 | S174100 | 0 | S161300 | Fabricate final blocks sector 24 | S161300 | S174100 | CA | Not Started | A-TEC | Sickles, Anne | L4 | UIUC | Fab & Assy | PP6 | MP203210 | Craig Woody | UIUC | null | POM02.1.03.01.03.02 | C | 1.03 | 59708 | FAB | 003,004 | 1.03A | 02 | 02 | 5 | 190522 IVS REL remove pred. 179600 |  |  |  |
| S174200 |  | Fabricate final blocks sector 25 |  | 6d | 2021-02-23 A | 2021-02-26 A | S174100 | 100% |  | 2021-02-26 | 2021-03-05 |  |  |  | TECH3 UIUC - Purchased Services [50 h]; STUDENT UIUC - Purchased Services [75 h]; TECH3 Senior UIUC - Purchased Services [10 h] | 5,162.69 | S174200 | 0 | S161400 | Fabricate final blocks sector 25 | S161400 | S174200 | CA | Not Started | A-TEC | Sickles, Anne | L4 | UIUC | Fab & Assy | PP6 | MP203210 | Craig Woody | UIUC | null | POM02.1.03.01.03.02 | C | 1.03 | 59708 | FAB | 003,004 | 1.03A | 02 | 02 | 5 | 190522 IVS REL remove pred. 179600 |  |  |  |
| S174300 |  | Fabricate final blocks sector 26 |  | 6d | 2021-02-26 A | 2021-03-26 A | S174200 | 100% |  | 2021-03-08 | 2021-03-15 |  |  |  | TECH3 UIUC - Purchased Services [50 h]; STUDENT UIUC - Purchased Services [75 h]; TECH3 Senior UIUC - Purchased Services [10 h] | 5,162.69 | S174300 | 0 | S161500 | Fabricate final blocks sector 26 | S161500 | S174300 | CA | Not Started | A-TEC | Sickles, Anne | L4 | UIUC | Fab & Assy | PP6 | MP203210 | Craig Woody | UIUC | null | POM02.1.03.01.03.02 | C | 1.03 | 59708 | FAB | 003,004 | 1.03A | 02 | 02 | 5 | 190522 IVS REL remove pred. 179600 |  |  |  |
| S174400 |  | Fabricate final blocks sector 27 |  | 10d | 2021-03-16 A | 2021-03-29 A | S174300 | 100% |  |  |  |  |  |  | TECH3 UIUC - Purchased Services [50 h]; STUDENT UIUC - Purchased Services [75 h]; TECH3 Senior UIUC - Purchased Services [10 h] | 5,162.69 | S174400 | 0 | S161600 | Fabricate final blocks sector 27 | S161600 | S174400 | CA | Not Started | A-TEC | Sickles, Anne | L4 | UIUC | Fab & Assy | PP6 | MP203210 | Craig Woody | UIUC | null | POM02.1.03.01.03.02 | C | 1.03 | 59708 | FAB | 003,004 | 1.03A | 02 | 02 | 5 | 190522 IVS REL remove pred. 179600 |  |  |  |
| S174500 |  | Fabricate final blocks sector 28 |  | 10d | 2021-03-18 A | 2021-03-31 A | S174400 | 100% |  |  |  |  |  |  | TECH3 UIUC - Purchased Services [50 h]; STUDENT UIUC - Purchased Services [75 h]; TECH3 Senior UIUC - Purchased Services [10 h] | 5,162.69 | S174500 | 0 | S161700 | Fabricate final blocks sector 28 | S161700 | S174500 | CA | Not Started | A-TEC | Sickles, Anne | L4 | UIUC | Fab & Assy | PP6 | MP203210 | Craig Woody | UIUC | null | POM02.1.03.01.03.02 | C | 1.03 | 59708 | FAB | 003,004 | 1.03A | 02 | 02 | 5 | 190522 IVS REL remove pred. 179600 |  |  |  |
| S174600 |  | Fabricate final blocks sector 29 |  | 6d | 2021-03-26 A | 2021-04-02 A | S174500 | 100% |  | 2021-04-26 | 2021-05-03 |  |  |  | TECH3 UIUC - Purchased Services [50 h]; STUDENT UIUC - Purchased Services [75 h]; TECH3 Senior UIUC - Purchased Services [10 h] | 5,162.69 | S174600 | 0 | S161800 | Fabricate final blocks sector 29 | S161800 | S174600 | CA | Not Started | A-TEC | Sickles, Anne | L4 | UIUC | Fab & Assy | PP6 | MP203210 | Craig Woody | UIUC | null | POM02.1.03.01.03.02 | C | 1.03 | 59708 | FAB | 003,004 | 1.03A | 02 | 02 | 5 | 190522 IVS REL remove pred. 179600 |  |  |  |
| S174700 |  | Fabricate final blocks sector 30 |  | 6d | 2021-04-05 A | 2021-04-12 A | S174600 | 100% |  |  |  |  |  |  | TECH3 UIUC - Purchased Services [50 h]; STUDENT UIUC - Purchased Services [75 h]; TECH3 Senior UIUC - Purchased Services [10 h] | 5,162.69 | S174700 | 0 | S161900 | Fabricate final blocks sector 30 | S161900 | S174700 | CA | Not Started | A-TEC | Sickles, Anne | L4 | UIUC | Fab & Assy | PP6 | MP203210 | Craig Woody | UIUC | null | POM02.1.03.01.03.02 | C | 1.03 | 59708 | FAB | 003,004 | 1.03A | 02 | 02 | 5 | 190522 IVS REL remove pred. 179600 |  |  |  |
| S174800 |  | Fabricate final blocks sector 31 |  | 6d | 2021-04-13 A | 2021-04-20 A | S174700 | 100% |  |  |  |  |  |  | TECH3 UIUC - Purchased Services [50 h]; STUDENT UIUC - Purchased Services [75 h]; TECH3 Senior UIUC - Purchased Services [10 h] | 5,162.69 | S174800 | 0 | S162000 | Fabricate final blocks sector 31 | S162000 | S174800 | CA | Not Started | A-TEC | Sickles, Anne | L4 | UIUC | Fab & Assy | PP6 | MP203210 | Craig Woody | UIUC | null | POM02.1.03.01.03.02 | C | 1.03 | 59708 | FAB | 003,004 | 1.03A | 02 | 02 | 5 | 190522 IVS REL remove pred. 179600 |  |  |  |
| S174900 |  | Fabricate final blocks sector 32 |  | 6d | 2021-04-21 A | 2021-04-28 A | S174800 | 100% |  |  |  |  |  |  | TECH3 UIUC - Purchased Services [50 h]; STUDENT UIUC - Purchased Services [75 h]; TECH3 Senior UIUC - Purchased Services [10 h] | 5,162.69 | S174900 | 0 | S162100 | Fabricate final blocks sector 32 | S162100 | S174900 | CA | Not Started | A-TEC | Sickles, Anne | L4 | UIUC | Fab & Assy | PP6 | MP203210 | Craig Woody | UIUC | null | POM02.1.03.01.03.02 | C | 1.03 | 59708 | FAB | 003,004 | 1.03A | 02 | 02 | 5 | 190522 IVS REL remove pred. 179600 |  |  |  |
| S175100 |  | Fabricate final blocks sector 34 |  | 6d | 2021-04-29 A | 2021-04-30 A | S175000 | 100% |  | 2021-05-07 | 2021-05-14 |  |  |  | TECH3 UIUC - Purchased Services [50 h]; STUDENT UIUC - Purchased Services [75 h]; TECH3 Senior UIUC - Purchased Services [10 h] | 5,162.69 | S175100 | 0 | S162300 | Fabricate final blocks sector 34 | S162300 | S175100 | CA | Not Started | A-TEC | Sickles, Anne | L4 | UIUC | Fab & Assy | PP6 | MP203220 | Craig Woody | UIUC | null | POM02.1.03.01.03.02 | C | 1.03 | 59708 | FAB | 003,004 | 1.03A | 02 | 02 | 5 | 190522 IVS REL - Remove pred. OBLG179610, 179600 |  |  |  |
| S175000 |  | Fabricate final blocks sector 33 |  | 6d | 2021-04-29 A | 2021-04-30 A | S174900, S179600 SS, OBLG179610 | 100% |  | 2021-04-29 | 2021-05-06 |  |  |  | TECH3 UIUC - Purchased Services [50 h]; STUDENT UIUC - Purchased Services [75 h]; TECH3 Senior UIUC - Purchased Services [10 h] | 5,162.69 | S175000 | 0 | S162200 | Fabricate final blocks sector 33 | S162200 | S175000 | CA | Not Started | A-TEC | Sickles, Anne | L4 | UIUC | Fab & Assy | PP6 | MP203220 | Craig Woody | UIUC | null | POM02.1.03.01.03.02 | C | 1.03 | 59708 | FAB | 003,004 | 1.03A | 02 | 02 | 5 | 190522 IVS REL remove pred. 179600 |  |  |  |
| S175200 |  | Fabricate final blocks sector 35 |  | 6d | 2021-04-30 A | 2021-05-07 A | S175100 | 100% |  | 2021-05-17 | 2021-05-24 |  |  |  | TECH3 UIUC - Purchased Services [50 h]; STUDENT UIUC - Purchased Services [75 h]; TECH3 Senior UIUC - Purchased Services [10 h] | 5,162.69 | S175200 | 0 | S162400 | Fabricate final blocks sector 35 | S162400 | S175200 | CA | Not Started | A-TEC | Sickles, Anne | L4 | UIUC | Fab & Assy | PP6 | MP203220 | Craig Woody | UIUC | null | POM02.1.03.01.03.02 | C | 1.03 | 59708 | FAB | 003,004 | 1.03A | 02 | 02 | 5 | 190522 IVS REL - Remove pred. OBLG179610, 179600 |  |  |  |
| S175300 |  | Fabricate final blocks sector 36 |  | 6d | 2021-05-10 A | 2021-05-17 A | S175200 | 100% |  |  |  |  |  |  | TECH3 UIUC - Purchased Services [50 h]; STUDENT UIUC - Purchased Services [75 h]; TECH3 Senior UIUC - Purchased Services [10 h] | 5,162.69 | S175300 | 0 | S162500 | Fabricate final blocks sector 36 | S162500 | S175300 | CA | Not Started | A-TEC | Sickles, Anne | L4 | UIUC | Fab & Assy | PP6 | MP203220 | Craig Woody | UIUC | null | POM02.1.03.01.03.02 | C | 1.03 | 59708 | FAB | 003,004 | 1.03A | 02 | 02 | 5 | 190522 IVS REL - Remove pred. OBLG179610, 179600 |  |  |  |
| S175400 |  | Fabricate final blocks sector 37 |  | 6d | 2021-05-18 A | 2021-05-25 A | S175300 | 100% |  |  |  |  |  |  | TECH3 UIUC - Purchased Services [50 h]; STUDENT UIUC - Purchased Services [75 h]; TECH3 Senior UIUC - Purchased Services [10 h] | 5,162.69 | S175400 | 0 | S162600 | Fabricate final blocks sector 37 | S162600 | S175400 | CA | Not Started | A-TEC | Sickles, Anne | L4 | UIUC | Fab & Assy | PP6 | MP203220 | Craig Woody | UIUC | null | POM02.1.03.01.03.02 | C | 1.03 | 59708 | FAB | 003,004 | 1.03A | 02 | 02 | 5 | 190522 IVS REL - Remove pred. OBLG179610, 179600 |  |  |  |
| S175500 |  | Fabricate final blocks sector 38 |  | 6d | 2021-05-26 A | 2021-06-03 | S175400 | 94% | 3d |  |  | 15d | 0d | 2021-06-03 | TECH3 UIUC - Purchased Services [50 h]; STUDENT UIUC - Purchased Services [75 h]; TECH3 Senior UIUC - Purchased Services [10 h] | 5,162.69 | S175500 | 0 | S162700 | Fabricate final blocks sector 38 | S162700 | S175500 | CA | Not Started | A-TEC | Sickles, Anne | L4 | UIUC | Fab & Assy | PP6 | MP203220 | Craig Woody | UIUC | null | POM02.1.03.01.03.02 | C | 1.03 | 59708 | FAB | 003,004 | 1.03A | 02 | 02 | 5 | 190522 IVS REL - Remove pred. OBLG179610, 179600 |  |  |  |
| S175600 |  | Fabricate final blocks sector 39 |  | 6d | 2021-06-04 | 2021-06-11 | S175500, S170300 FF |  |  |  |  | 15d | 0d |  | TECH3 UIUC - Purchased Services [50 h]; STUDENT UIUC - Purchased Services [75 h]; TECH3 Senior UIUC - Purchased Services [10 h] | 5,162.69 | S175600 | 0 | S162800 | Fabricate final blocks sector 39 | S162800 | S175600 | CA | Not Started | A-TEC | Sickles, Anne | L4 | UIUC | Fab & Assy | PP6 | MP203220 | Craig Woody | UIUC | null | POM02.1.03.01.03.02 | C | 1.03 | 59708 | FAB | 003,004 | 1.03A | 02 | 02 | 5 | 190522 IVS REL - Remove pred. OBLG179610, 179600 |  |  |  |
| S175700 |  | Fabricate final blocks sector 40 |  | 6d | 2021-06-14 | 2021-06-21 | S175600 |  |  |  |  | 15d | 0d |  | TECH3 UIUC - Purchased Services [50 h]; STUDENT UIUC - Purchased Services [75 h]; TECH3 Senior UIUC - Purchased Services [10 h] | 5,162.69 | S175700 | 0 | S162900 | Fabricate final blocks sector 40 | S162900 | S175700 | CA | Not Started | A-TEC | Sickles, Anne | L4 | UIUC | Fab & Assy | PP6 | MP203220 | Craig Woody | UIUC | null | POM02.1.03.01.03.02 | C | 1.03 | 59708 | FAB | 003,004 | 1.03A | 02 | 02 | 5 | 190522 IVS REL - Remove pred. OBLG179610, 179600 |  |  |  |
| S175800 |  | Fabricate final blocks sector 41 |  | 6d | 2021-06-22 | 2021-06-29 | S175700 |  |  |  |  | 15d | 0d |  | TECH3 UIUC - Purchased Services [50 h]; STUDENT UIUC - Purchased Services [75 h]; TECH3 Senior UIUC - Purchased Services [10 h] | 5,162.69 | S175800 | 0 | S163000 | Fabricate final blocks sector 41 | S163000 | S175800 | CA | Not Started | A-TEC | Sickles, Anne | L4 | UIUC | Fab & Assy | PP6 | MP203220 | Craig Woody | UIUC | null | POM02.1.03.01.03.02 | F | 1.03 | 59708 | FAB | 003,004 | 1.03A | 02 | 02 | 5 | 190522 IVS REL - Remove pred. OBLG179610, 179600 |  |  |  |
| S175900 |  | Fabricate final blocks sector 42 |  | 6d | 2021-06-30 | 2021-07-08 | S175800 |  |  |  |  | 15d | 0d |  | TECH3 UIUC - Purchased Services [50 h]; STUDENT UIUC - Purchased Services [75 h]; TECH3 Senior UIUC - Purchased Services [10 h] | 5,162.69 | S175900 | 0 | S163100 | Fabricate final blocks sector 42 | S163100 | S175900 | CA | Not Started | A-TEC | Sickles, Anne | L4 | UIUC | Fab & Assy | PP6 | MP203220 | Craig Woody | UIUC | null | POM02.1.03.01.03.02 | F | 1.03 | 59708 | FAB | 003,004 | 1.03A | 02 | 02 | 5 | 190522 IVS REL - Remove pred. OBLG179610, 179600 |  |  |  |
| S176000 |  | Fabricate final blocks sector 43 |  | 6d | 2021-07-09 | 2021-07-16 | S175900 |  |  |  |  | 15d | 0d |  | TECH3 UIUC - Purchased Services [50 h]; STUDENT UIUC - Purchased Services [75 h]; TECH3 Senior UIUC - Purchased Services [10 h] | 5,162.69 | S176000 | 0 | S163200 | Fabricate final blocks sector 43 | S163200 | S176000 | CA | Not Started | A-TEC | Sickles, Anne | L4 | UIUC | Fab & Assy | PP6 | MP203220 | Craig Woody | UIUC | null | POM02.1.03.01.03.02 | F | 1.03 | 59708 | FAB | 003,004 | 1.03A | 02 | 02 | 5 | 190522 IVS REL - Remove pred. OBLG179610, 179600 |  |  |  |
| S176100 |  | Fabricate final blocks sector 44 |  | 6d | 2021-07-19 | 2021-07-26 | S176000 |  |  |  |  | 15d | 0d |  | TECH3 UIUC - Purchased Services [50 h]; STUDENT UIUC - Purchased Services [75 h]; TECH3 Senior UIUC - Purchased Services [10 h] | 5,162.69 | S176100 | 0 | S163300 | Fabricate final blocks sector 44 | S163300 | S176100 | CA | Not Started | A-TEC | Sickles, Anne | L4 | UIUC | Fab & Assy | PP6 | MP203220 | Craig Woody | UIUC | null | POM02.1.03.01.03.02 | F | 1.03 | 59708 | FAB | 003,004 | 1.03A | 02 | 02 | 5 | 190522 IVS REL - Remove pred. OBLG179610, 179600 |  |  |  |
| S176200 |  | Fabricate final blocks sector 45 |  | 6d | 2021-07-27 | 2021-08-03 | S176100 |  |  |  |  | 15d | 0d |  | TECH3 UIUC - Purchased Services [50 h]; STUDENT UIUC - Purchased Services [75 h]; TECH3 Senior UIUC - Purchased Services [10 h] | 5,162.69 | S176200 | 0 | S163400 | Fabricate final blocks sector 45 | S163400 | S176200 | CA | Not Started | A-TEC | Sickles, Anne | L4 | UIUC | Fab & Assy | PP6 | MP203220 | Craig Woody | UIUC | null | POM02.1.03.01.03.02 | F | 1.03 | 59708 | FAB | 003,004 | 1.03A | 02 | 02 | 5 | 190522 IVS REL - Remove pred. OBLG179610, 179600 |  |  |  |
| S176300 |  | Fabricate final blocks sector 46 |  | 6d | 2021-08-04 | 2021-08-11 | S176200 |  |  |  |  | 15d | 0d |  | TECH3 UIUC - Purchased Services [50 h]; STUDENT UIUC - Purchased Services [75 h]; TECH3 Senior UIUC - Purchased Services [10 h] | 5,162.69 | S176300 | 0 | S163500 | Fabricate final blocks sector 46 | S163500 | S176300 | CA | Not Started | A-TEC | Sickles, Anne | L4 | UIUC | Fab & Assy | PP6 | MP203220 | Craig Woody | UIUC | null | POM02.1.03.01.03.02 | F | 1.03 | 59708 | FAB | 003,004 | 1.03A | 02 | 02 | 5 | 190522 IVS REL - Remove pred. OBLG179610, 179600 |  |  |  |
| S176400 |  | Fabricate final blocks sector 47 |  | 6d | 2021-08-12 | 2021-08-19 | S176300, S171100 |  |  |  |  | 15d | 0d |  | TECH3 UIUC - Purchased Services [50 h]; STUDENT UIUC - Purchased Services [75 h]; TECH3 Senior UIUC - Purchased Services [10 h] | 5,162.69 | S176400 | 0 | S163600 | Fabricate final blocks sector 47 | S163600 | S176400 | CA | Not Started | A-TEC | Sickles, Anne | L4 | UIUC | Fab & Assy | PP6 | MP203220 | Craig Woody | UIUC | null | POM02.1.03.01.03.02 | F | 1.03 | 59708 | FAB | 003,004 | 1.03A | 02 | 02 | 5 | 190522 IVS REL - Remove pred. OBLG179610, 179600 |  |  |  |
| S176500 |  | Fabricate final blocks sector 48 |  | 6d | 2021-08-20 | 2021-08-27 | S176400 |  |  |  |  | 15d | 0d |  | TECH3 UIUC - Purchased Services [50 h]; STUDENT UIUC - Purchased Services [75 h]; TECH3 Senior UIUC - Purchased Services [10 h] | 5,162.69 | S176500 | 0 | S163700 | Fabricate final blocks sector 48 | S163700 | S176500 | CA | Not Started | A-TEC | Sickles, Anne | L4 | UIUC | Fab & Assy | PP6 | MP203220 | Craig Woody | UIUC | null | POM02.1.03.01.03.02 | F | 1.03 | 59708 | FAB | 003,004 | 1.03A | 02 | 02 | 5 | 190522 IVS REL - Remove pred. OBLG179610, 179600 |  |  |  |
| S176600 |  | Fabricate final blocks sector 49 |  | 6d | 2021-08-30 | 2021-09-07 | S176500 |  |  |  |  | 15d | 0d |  | TECH3 UIUC - Purchased Services [50 h]; STUDENT UIUC - Purchased Services [75 h]; TECH3 Senior UIUC - Purchased Services [10 h] | 5,162.69 | S176600 | 0 | S163800 | Fabricate final blocks sector 49 | S163800 | S176600 | CA | Not Started | A-TEC | Sickles, Anne | L4 | UIUC | Fab & Assy | PP6 | MP203220 | Craig Woody | UIUC | null | POM02.1.03.01.03.02 | F | 1.03 | 59708 | FAB | 003,004 | 1.03A | 02 | 02 | 5 | 190522 IVS REL - Remove pred. OBLG179610, 179600 |  |  |  |
| S176700 |  | Fabricate final blocks sector 50 |  | 6d | 2021-09-08 | 2021-09-15 | S176600 |  |  |  |  | 15d | 0d |  | TECH3 UIUC - Purchased Services [50 h]; STUDENT UIUC - Purchased Services [75 h]; TECH3 Senior UIUC - Purchased Services [10 h] | 5,162.69 | S176700 | 0 | S163900 | Fabricate final blocks sector 50 | S163900 | S176700 | CA | Not Started | A-TEC | Sickles, Anne | L4 | UIUC | Fab & Assy | PP6 | MP203220 | Craig Woody | UIUC | null | POM02.1.03.01.03.02 | F | 1.03 | 59708 | FAB | 003,004 | 1.03A | 02 | 02 | 5 | 190522 IVS REL - Remove pred. OBLG179610, 179600 |  |  |  |
| S176800 |  | Fabricate final blocks sector 51 |  | 6d | 2021-09-16 | 2021-09-23 | S176700 |  |  |  |  | 15d | 0d |  | TECH3 UIUC - Purchased Services [50 h]; STUDENT UIUC - Purchased Services [75 h]; TECH3 Senior UIUC - Purchased Services [10 h] | 5,162.69 | S176800 | 0 | S164000 | Fabricate final blocks sector 51 | S164000 | S176800 | CA | Not Started | A-TEC | Sickles, Anne | L4 | UIUC | Fab & Assy | PP6 | MP203220 | Craig Woody | UIUC | null | POM02.1.03.01.03.02 | F | 1.03 | 59708 | FAB | 003,004 | 1.03A | 02 | 02 | 5 | 190522 IVS REL - Remove pred. OBLG179610, 179600 |  |  |  |
| S176900 |  | Fabricate final blocks sector 52 |  | 6d | 2021-09-24 | 2021-10-01 | S176800 |  |  |  |  | 15d | 0d |  | TECH3 UIUC - Purchased Services [50 h]; STUDENT UIUC - Purchased Services [75 h]; TECH3 Senior UIUC - Purchased Services [10 h] | 5,188.51 | S176900 | 0 | S164100 | Fabricate final blocks sector 52 | S164100 | S176900 | CA | Not Started | A-TEC | Sickles, Anne | L4 | UIUC | Fab & Assy | PP6 | MP203220 | Craig Woody | UIUC | null | POM02.1.03.01.03.02 | F | 1.03 | 59708 | FAB | 003,004 | 1.03A | 02 | 02 | 5 | 190522 IVS REL - Remove pred. OBLG179610, 179600 |  |  |  |
| S177000 |  | Fabricate final blocks sector 53 |  | 6d | 2021-10-04 | 2021-10-12 | S176900 |  |  |  |  | 15d | 0d |  | TECH3 UIUC - Purchased Services [50 h]; STUDENT UIUC - Purchased Services [75 h]; TECH3 Senior UIUC - Purchased Services [10 h] | 5,317.57 | S177000 | 0 | S164200 | Fabricate final blocks sector 53 | S164200 | S177000 | CA | Not Started | A-TEC | Sickles, Anne | L4 | UIUC | Fab & Assy | PP6 | MP203220 | Craig Woody | UIUC | null | POM02.1.03.01.03.02 | F | 1.03 | 59708 | FAB | 003,004 | 1.03A | 02 | 02 | 5 | 190522 IVS REL - Remove pred. OBLG179610, 179600 |  |  |  |
| S177100 |  | Fabricate final blocks sector 54 |  | 6d | 2021-10-13 | 2021-10-20 | S177000 |  |  |  |  | 15d | 0d |  | TECH3 UIUC - Purchased Services [50 h]; STUDENT UIUC - Purchased Services [75 h]; TECH3 Senior UIUC - Purchased Services [10 h] | 5,317.57 | S177100 | 0 | S164300 | Fabricate final blocks sector 54 | S164300 | S177100 | CA | Not Started | A-TEC | Sickles, Anne | L4 | UIUC | Fab & Assy | PP6 | MP203220 | Craig Woody | UIUC | null | POM02.1.03.01.03.02 | F | 1.03 | 59708 | FAB | 003,004 | 1.03A | 02 | 02 | 5 | 190522 IVS REL - Remove pred. OBLG179610, 179600 |  |  |  |
| S177200 |  | Fabricate final blocks sector 55 |  | 6d | 2021-10-21 | 2021-10-28 | S177100 |  |  |  |  | 15d | 0d |  | TECH3 UIUC - Purchased Services [50 h]; STUDENT UIUC - Purchased Services [75 h]; TECH3 Senior UIUC - Purchased Services [10 h] | 5,317.57 | S177200 | 0 | S164400 | Fabricate final blocks sector 55 | S164400 | S177200 | CA | Not Started | A-TEC | Sickles, Anne | L4 | UIUC | Fab & Assy | PP6 | MP203220 | Craig Woody | UIUC | null | POM02.1.03.01.03.02 | F | 1.03 | 59708 | FAB | 003,004 | 1.03A | 02 | 02 | 5 | 190522 IVS REL - Remove pred. OBLG179610, 179600 |  |  |  |
| S177300 |  | Fabricate final blocks sector 56 |  | 5d | 2021-10-29 | 2021-11-04 | S177200 |  |  |  |  | 15d | 0d |  | TECH3 UIUC - Purchased Services [50 h]; STUDENT UIUC - Purchased Services [75 h]; TECH3 Senior UIUC - Purchased Services [10 h] | 5,317.57 | S177300 | 0 | S164500 | Fabricate final blocks sector 56 | S164500 | S177300 | CA | Not Started | A-TEC | Sickles, Anne | L4 | UIUC | Fab & Assy | PP6 | MP203220 | Craig Woody | UIUC | null | POM02.1.03.01.03.02 | F | 1.03 | 59708 | FAB | 003,004 | 1.03A | 02 | 02 | 5 | 190522 IVS REL - Remove pred. OBLG179610, 179600 |  |  |  |
| S177400 |  | Fabricate final blocks sector 57 |  | 5d | 2021-11-05 | 2021-11-12 | S177300 |  |  |  |  | 15d | 0d |  | TECH3 UIUC - Purchased Services [50 h]; STUDENT UIUC - Purchased Services [75 h]; TECH3 Senior UIUC - Purchased Services [10 h] | 5,317.57 | S177400 | 0 | S164600 | Fabricate final blocks sector 57 | S164600 | S177400 | CA | Not Started | A-TEC | Sickles, Anne | L4 | UIUC | Fab & Assy | PP6 | MP203220 | Craig Woody | UIUC | null | POM02.1.03.01.03.02 | F | 1.03 | 59708 | FAB | 003,004 | 1.03A | 02 | 02 | 5 | 190522 IVS REL - Remove pred. OBLG179610, 179600 |  |  |  |
| S177500 |  | Fabricate final blocks sector 58 |  | 5d | 2021-11-15 | 2021-11-19 | S177400 |  |  |  |  | 15d | 0d |  | TECH3 UIUC - Purchased Services [50 h]; STUDENT UIUC - Purchased Services [75 h]; TECH3 Senior UIUC - Purchased Services [10 h] | 5,317.57 | S177500 | 0 | S164700 | Fabricate final blocks sector 58 | S164700 | S177500 | CA | Not Started | A-TEC | Sickles, Anne | L4 | UIUC | Fab & Assy | PP6 | MP203220 | Craig Woody | UIUC | null | POM02.1.03.01.03.02 | F | 1.03 | 59708 | FAB | 003,004 | 1.03A | 02 | 02 | 5 | 190522 IVS REL - Remove pred. OBLG179610, 179600 |  |  |  |
| S177600 |  | Fabricate final blocks sector 59 |  | 5d | 2021-11-22 | 2021-11-30 | S177500 |  |  |  |  | 15d | 0d |  | TECH3 UIUC - Purchased Services [50 h]; STUDENT UIUC - Purchased Services [75 h]; TECH3 Senior UIUC - Purchased Services [10 h] | 5,317.57 | S177600 | 0 | S164800 | Fabricate final blocks sector 59 | S164800 | S177600 | CA | Not Started | A-TEC | Sickles, Anne | L4 | UIUC | Fab & Assy | PP6 | MP203220 | Craig Woody | UIUC | null | POM02.1.03.01.03.02 | F | 1.03 | 59708 | FAB | 003,004 | 1.03A | 02 | 02 | 5 | 190522 IVS REL - Remove pred. OBLG179610, 179600 |  |  |  |
| S177700 |  | Fabricate final blocks sector 60 |  | 5d | 2021-12-01 | 2021-12-07 | S177600 |  |  |  |  | 15d | 0d |  | TECH3 UIUC - Purchased Services [50 h]; STUDENT UIUC - Purchased Services [75 h]; TECH3 Senior UIUC - Purchased Services [10 h] | 5,317.57 | S177700 | 0 | S164900 | Fabricate final blocks sector 60 | S164900 | S177700 | CA | Not Started | A-TEC | Sickles, Anne | L4 | UIUC | Fab & Assy | PP6 | MP203220 | Craig Woody | UIUC | null | POM02.1.03.01.03.02 | F | 1.03 | 59708 | FAB | 003,004 | 1.03A | 02 | 02 | 5 | 190522 IVS REL - Remove pred. OBLG179610, 179600 |  |  |  |
| S177800 |  | Fabricate final blocks sector 61 |  | 5d | 2021-12-08 | 2021-12-14 | S177700 |  |  |  |  | 15d | 0d |  | TECH3 UIUC - Purchased Services [50 h]; STUDENT UIUC - Purchased Services [75 h]; TECH3 Senior UIUC - Purchased Services [10 h] | 5,317.57 | S177800 | 0 | S165000 | Fabricate final blocks sector 61 | S165000 | S177800 | CA | Not Started | A-TEC | Sickles, Anne | L4 | UIUC | Fab & Assy | PP6 | MP203220 | Craig Woody | UIUC | null | POM02.1.03.01.03.02 | F | 1.03 | 59708 | FAB | 003,004 | 1.03A | 02 | 02 | 5 | 190522 IVS REL - Remove pred. OBLG179610, 179600 |  |  |  |
| S177900 |  | Fabricate final blocks sector 62 |  | 5d | 2021-12-15 | 2021-12-21 | S177800 |  |  |  |  | 15d | 0d |  | TECH3 UIUC - Purchased Services [50 h]; STUDENT UIUC - Purchased Services [75 h]; TECH3 Senior UIUC - Purchased Services [10 h] | 5,317.57 | S177900 | 0 | S165100 | Fabricate final blocks sector 62 | S165100 | S177900 | CA | Not Started | A-TEC | Sickles, Anne | L4 | UIUC | Fab & Assy | PP6 | MP203220 | Craig Woody | UIUC | null | POM02.1.03.01.03.02 | F | 1.03 | 59708 | FAB | 003,004 | 1.03A | 02 | 02 | 5 | 190522 IVS REL - Remove pred. OBLG179610, 179600 |  |  |  |
| S178000 |  | Fabricate final blocks sector 63 |  | 5d | 2021-12-22 | 2021-12-29 | S177900 |  |  |  |  | 15d | 0d |  | TECH3 UIUC - Purchased Services [50 h]; STUDENT UIUC - Purchased Services [75 h]; TECH3 Senior UIUC - Purchased Services [10 h] | 5,317.57 | S178000 | 0 | S165200 | Fabricate final blocks sector 63 | S165200 | S178000 | CA | Not Started | A-TEC | Sickles, Anne | L4 | UIUC | Fab & Assy | PP6 | MP203220 | Craig Woody | UIUC | null | POM02.1.03.01.03.02 | F | 1.03 | 59708 | FAB | 003,004 | 1.03A | 02 | 02 | 5 | 190522 IVS REL - Remove pred. OBLG179610, 179600 |  |  |  |
| S178100 |  | Fabricate final blocks sector 64 |  | 5d | 2021-12-30 | 2022-01-06 | S178000 |  |  |  |  | 15d | 0d |  | TECH3 UIUC - Purchased Services [50 h]; STUDENT UIUC - Purchased Services [75 h]; TECH3 Senior UIUC - Purchased Services [10 h] | 5,317.57 | S178100 | 0 | S165300 | Fabricate final blocks sector 64 | S165300 | S178100 | CA | Not Started | A-TEC | Sickles, Anne | L4 | UIUC | Fab & Assy | PP6 | MP203220 | Craig Woody | UIUC | null | POM02.1.03.01.03.02 | F | 1.03 | 59708 | FAB | 003,004 | 1.03A | 02 | 02 | 5 | 190522 IVS REL - Remove pred. OBLG179610, 179600 |  |  |  |
| S178200 |  | EMCal Block fabrication is complete | milestone | 0d | 2022-01-06 | 2022-01-06 | S178100 FF |  |  |  |  | 16d | 1d |  |  |  | S178200 | 0 | S165400 | EMCal Block fabrication is complete | S165400 |  | NOCA | Not Started |  | Sickles, Anne |  | UIUC | Fab & Assy |  |  | Craig Woody | UIUC | null | POM02.1.03.01.03.02 |  |  |  |  |  |  | 02 | 02 | 5 |  | UDF_G2 | UDF_G1 | L3 |

| ID | WBS | Activity | Type | Duration | Start | Finish | Predecessors | Complete | Remaining | Planned start | Planned finish | Total float | Free float | Expected finish | Resources | Cost | BNL_UDF_Temp Text 01 | BNL_UDF_Percent Complete | BNL_UDF_Sort Order | BNL_UDF_OPC TEC (deprecated) | BNL_UDF_Old Activity ID 181221 | BNL_Cobra WP | RG Check | BNL_Activity Status | BNL_Fund Source | BNL_Estimator | BNL_Cost Basis | BNL_Location | BNL_EDIA | BNL_Proc Sig Phase | BNL_Proc Sig | BNL_CAM | BNL_Institution | BNL_OPC TEC (deprecated) | BNL_WBS | BNL_EVT | BNL_Master Control Account | BNL_Account Number | BNL_Obligation | BNL_PCR ID | BNL_Cobra Control Account | BNL_WBS_Hierarchical | PMP Summary Part1 | PMP Summary Part2 | Indicator - Procurement | Indicator - Float | BNL_UDF_Remaining Tot Cost | BNL_UDF_Percent_remaining | BNL_Milestone Level | BNL_UDF_Exclude | BNL_UDF_Adhoc Comments | Completed | Cost = Awarded Proc or Mgmt | BNL_UDF_Status Comments | BNL_LLPs and Precursors |
| --- | --- | --- | --- | --- | --- | --- | --- | --- | --- | --- | --- | --- | --- | --- | --- | --- | --- | --- | --- | --- | --- | --- | --- | --- | --- | --- | --- | --- | --- | --- | --- | --- | --- | --- | --- | --- | --- | --- | --- | --- | --- | --- | --- | --- | --- | --- | --- | --- | --- | --- | --- | --- | --- | --- | --- |
|  | 03 | **Pack and ship final blocks to BNL** |  |  | 2020-10-22 | 2022-01-07 |  |  |  |  |  |  |  |  |  |  |  |  |  |  |  |  |  |  |  |  |  |  |  |  |  |  |  |  |  |  |  |  |  |  |  |  |  |  |  |  |  |  |  |  |  |  |  |  |  |
| S178300 |  | Pack and ship final blocks for sectors 13-16 to BNL - Purchased Services |  | 5d | 2020-10-22 A | 2020-11-23 A | S173300, S179600 SS | 100% |  | 2020-11-17 | 2020-11-23 |  |  |  | STUDENT UIUC - Purchased Services [8 h]; TECH3 UIUC - Purchased Services [5 h]; TECH3 Senior UIUC - Purchased Services [7 h] | 1,222.54 | S178300 | 0 | 1000 | S165500 | S165500 | S178300 | CA | Not Started | A-TEC | Sickles, Anne | L4 | UIUC | Fab & Assy | PP6 | MP203210 | Craig Woody | UIUC | null | POM02.1.03.01.03.03 | C | 1.03 | 59708 | FAB | 003 | 1.03A | 03 | 02 | 5 |  |  |  |  |  |  |  |  |  |  |  |
| S178310 |  | Pack and ship final blocks for sectors 13-16 to BNL - M&S |  | 5d | 2020-10-22 A | 2020-11-23 A | S173300, S179600 SS | 100% |  | 2020-11-17 | 2020-11-23 |  |  |  | UIUC Contracted Purchase <$2M M&S [3240 h] | 3,760.62 | S178300 | 0 | 1000 | S165500 | S165500 | S178310 | CA | Not Started | A-TEC | Sickles, Anne | L4 | UIUC | Fab & Assy | PP6 | MP203210 | Craig Woody | UIUC | null | POM02.1.03.01.03.03 | F | 1.03 | 59708 | FAB | 003 | 1.03A | 03 | 02 | 5 | UDF_G1 | UDF_G1 | 3686.87956 | 1 |  |  |  |  |  |  |  |
| S178400 |  | Pack and ship final blocks for sectors 17-24 to BNL - Purchased Services |  | 5d | 2020-11-16 A | 2021-03-30 A | S174100 FF, S179600 SS, S173400 SS | 100% |  | 2021-01-29 | 2021-02-04 |  |  |  | STUDENT UIUC - Purchased Services [16 h]; TECH3 UIUC - Purchased Services [10 h]; TECH3 Senior UIUC - Purchased Services [15 h] | 2,561.3 | S178400 | 0 | 1000 | S165600 | S165600 | S178400 | CA | Not Started | A-TEC | Sickles, Anne | L4 | UIUC | Fab & Assy | PP6 | MP203210 | Craig Woody | UIUC | null | POM02.1.03.01.03.03 | C | 1.03 | 59708 | FAB | 003 | 1.03A | 03 | 02 | 5 |  |  |  |  |  |  |  |  |  |  |  |
| S178410 |  | Pack and ship final blocks for sectors 17-24 to BNL - M&S |  | 5d | 2020-11-16 A | 2021-03-30 A | S174100 FF, S179600 SS, S173400 | 100% |  | 2021-01-29 | 2021-02-04 |  |  |  | UIUC Contracted Purchase <$2M M&S [6480 h] | 7,521.23 | S178400 | 0 | 1000 | S165600 | S165600 | S178410 | CA | Not Started | A-TEC | Sickles, Anne | L4 | UIUC | Fab & Assy | PP6 | MP203210 | Craig Woody | UIUC | null | POM02.1.03.01.03.03 | F | 1.03 | 59708 | FAB | 003 | 1.03A | 03 | 02 | 5 | UDF_G1 | UDF_G3 | 7521.234329 | 1 |  |  |  |  |  |  |  |
| S178500 |  | Pack and ship final blocks for sectors 25-32 to BNL - Purchased Services |  | 5d | 2021-03-22 A | 2021-05-07 A | S174900, S179600 SS, OBLG179610, S178400 | 100% |  | 2021-05-28 | 2021-06-04 |  |  |  | STUDENT UIUC - Purchased Services [16 h]; TECH3 UIUC - Purchased Services [10 h]; TECH3 Senior UIUC - Purchased Services [15 h] | 2,561.3 | S178500 | 0 | 1000 | S165700 | S165700 | S178500 | CA | Not Started | A-TEC | Sickles, Anne | L4 | UIUC | Fab & Assy | PP6 | MP203220 | Craig Woody | UIUC | null | POM02.1.03.01.03.03 | C | 1.03 | 59708 | FAB | 003 | 1.03A | 03 | 02 | 5 |  |  |  |  |  |  |  |  |  |  |  |
| S178510 |  | Pack and ship final blocks for sectors 25-32 to BNL - M&S |  | 5d | 2021-03-22 A | 2021-05-07 A | S174900, S179600 SS, OBLG179610 | 100% |  | 2021-05-28 | 2021-06-04 |  |  |  | UIUC Contracted Purchase <$2M M&S [6480 h] | 7,521.23 | S178500 | 0 | 1000 | S165700 | S165700 | S178510 | CA | Not Started | A-TEC | Sickles, Anne | L4 | UIUC | Fab & Assy | PP6 | MP203220 | Craig Woody | UIUC | null | POM02.1.03.01.03.03 | F | 1.03 | 59708 | FAB | 003 | 1.03A | 03 | 02 | 5 | UDF_G1 | UDF_G3 | 7521.234329 | 1 |  |  |  |  |  |  |  |
| S178600 |  | Pack and ship final blocks for sectors 33-40 to BNL - Purchased Services |  | 5d | 2021-05-17 A | 2021-06-28 | S175700, S179600 SS, OBLG179610, S178500 | 38% | 5d | 2021-06-22 | 2021-06-28 | 136d | 0d | 2021-06-28 | STUDENT UIUC - Purchased Services [16 h]; TECH3 UIUC - Purchased Services [10 h]; TECH3 Senior UIUC - Purchased Services [15 h] | 2,561.3 | S178600 | 0 | 1000 | S165800 | S165800 | S178600 | CA | Not Started | A-TEC | Sickles, Anne | L4 | UIUC | Fab & Assy | PP6 | MP203220 | Craig Woody | UIUC | null | POM02.1.03.01.03.03 | F | 1.03 | 59708 | FAB | 003 | 1.03A | 03 | 02 | 5 |  |  |  |  |  |  |  |  |  |  |  |
| S178610 |  | Pack and ship final blocks for sectors 33-40 to BNL - M&S |  | 5d | 2021-05-17 A | 2021-06-28 | S175700, S179600 SS, OBLG179610 | 38% | 5d | 2021-06-22 | 2021-06-28 | 146d | 0d | 2021-06-28 | UIUC Contracted Purchase <$2M M&S [6480 h] | 7,521.23 | S178600 | 0 | 1000 | S165800 | S165800 | S178610 | CA | Not Started | A-TEC | Sickles, Anne | L4 | UIUC | Fab & Assy | PP6 | MP203220 | Craig Woody | UIUC | null | POM02.1.03.01.03.03 | F | 1.03 | 59708 | FAB | 003 | 1.03A | 03 | 02 | 5 | UDF_G1 | UDF_G3 | 7521.234329 | 1 |  |  |  |  |  |  |  |
| S178700 |  | Pack and ship final blocks for sectors 40-48 to BNL - Purchased Services |  | 5d | 2021-08-30 | 2021-09-03 | S176500, S179600 SS, OBLG179610, S178600 |  |  |  |  | 93d | 42d |  | STUDENT UIUC - Purchased Services [16 h]; TECH3 UIUC - Purchased Services [10 h]; TECH3 Senior UIUC - Purchased Services [15 h] | 2,561.3 | S178700 | 0 | 1000 | S165900 | S165900 | S178700 | CA | Not Started | A-TEC | Sickles, Anne | L4 | UIUC | Fab & Assy | PP6 | MP203220 | Craig Woody | UIUC | null | POM02.1.03.01.03.03 | F | 1.03 | 59708 | FAB | 003 | 1.03A | 03 | 02 | 5 |  |  |  |  |  |  |  |  |  |  |  |
| S178710 |  | Pack and ship final blocks for sectors 40-48 to BNL - M&S |  | 5d | 2021-08-30 | 2021-09-03 | S176500, S179600 SS, OBLG179610 |  |  |  |  | 98d | 83d |  | UIUC Contracted Purchase <$2M M&S [6480 h] | 7,521.23 | S178700 | 0 | 1000 | S165900 | S165900 | S178710 | CA | Not Started | A-TEC | Sickles, Anne | L4 | UIUC | Fab & Assy | PP6 | MP203220 | Craig Woody | UIUC | null | POM02.1.03.01.03.03 | F | 1.03 | 59708 | FAB | 003 | 1.03A | 03 | 02 | 5 | UDF_G1 | UDF_G3 | 7521.234329 | 1 |  |  |  |  |  |  |  |
| S178800 |  | Pack and ship final blocks for sectors 49-56 to BNL - Purchased Services |  | 5d | 2021-11-05 | 2021-11-12 | S177300, S179600 SS, OBLG179610, S178700 |  |  |  |  | 51d | 36d |  | STUDENT UIUC - Purchased Services [16 h]; TECH3 UIUC - Purchased Services [10 h]; TECH3 Senior UIUC - Purchased Services [15 h] | 2,638.14 | S178800 | 0 | 1000 | S166000 | S166000 | S178800 | CA | Not Started | A-TEC | Sickles, Anne | L4 | UIUC | Fab & Assy | PP6 | MP203220 | Craig Woody | UIUC | null | POM02.1.03.01.03.03 | F | 1.03 | 59708 | FAB | 003 | 1.03A | 03 | 02 | 5 |  |  |  |  |  |  |  |  |  |  |  |
| S178910 |  | Pack and ship final blocks for sectors 49-56 to BNL - M&S |  | 5d | 2021-11-05 | 2021-11-12 | S177300, S179600 SS, OBLG179610 |  |  |  |  | 51d | 36d |  | UIUC Contracted Purchase <$2M M&S [6480 h] | 7,671.66 | S178800 | 0 | 1000 | S166000 | S166000 | S178910 | CA | Not Started | A-TEC | Sickles, Anne | L4 | UIUC | Fab & Assy | PP6 | MP203220 | Craig Woody | UIUC | null | POM02.1.03.01.03.03 | F | 1.03 | 59708 | FAB | 003 | 1.03A | 03 | 02 | 5 | UDF_G1 | UDF_G1 | 7521.234329 | 1 |  |  |  |  |  |  |  |
| S176010 |  | Pack and ship final blocks for sectors 57-64 to BNL - M&S |  | 1d | 2022-01-07 | 2022-01-07 | S178100, S179600 SS, OBLG179610 |  |  |  |  | 15d | 0d |  | UIUC Contracted Purchase <$2M M&S [6480 h] | 7,671.66 | S178900 | 0 | 3000 | S166100 | S166100 | S176010 | CA | Not Started | A-TEC | Sickles, Anne | L4 | UIUC | Fab & Assy | PP6 | MP203220 | Craig Woody | UIUC | null | POM02.1.03.01.03.03 | F | 1.03 | 59708 | FAB | 003 | 1.03A | 03 | 02 | 5 | UDF_G1 | UDF_G1 | 7551.319258 | 1 |  |  |  |  |  |  |  |
| S178900 |  | Pack and ship final blocks for sectors 57-64 to BNL - Purchased Services |  | 1d | 2022-01-07 | 2022-01-07 | S178100, S179600 SS, OBLG179610 |  |  |  |  | 15d | 0d |  | STUDENT UIUC - Purchased Services [16 h]; TECH3 UIUC - Purchased Services [10 h]; TECH3 Senior UIUC - Purchased Services [15 h] | 2,638.14 | S178900 | 0 | 2000 | S166100 | S166100 | S178900 | CA | Not Started | A-TEC | Sickles, Anne | L4 | UIUC | Fab & Assy | PP6 | MP203220 | Craig Woody | UIUC | null | POM02.1.03.01.03.03 | F | 1.03 | 59708 | FAB | 003 | 1.03A | 03 | 02 | 5 |  |  |  |  |  |  |  |  |  |  |  |
| S179000 |  | EMCal final blocks arrive at BNL | milestone | 0d | 2022-01-07 | 2022-01-07 | S178900 FF, S178200 FF, S176010 FF, S178910, S178400, S178410, S178500, S178510, S178600, S178610, S178700, S178710, S178800 |  |  |  |  | 15d |  |  |  |  | S179000 | 0 |  | S166200 | S166200 |  | NOCA | Not Started |  | Sickles, Anne |  | UIUC | Fab & Assy |  |  | Craig Woody | UIUC |  | POM02.1.03.01.03.03 |  |  |  |  |  |  | 03 | 02 | 5 | UDF_G2 | UDF_G1 |  |  | L2 |  |  |  |  |  |  |
|  | 04 | **EMCAL Block Fabrication Procurement** |  |  | 2017-06-09 | 2019-11-25 |  |  |  |  |  |  |  |  |  |  |  |  |  |  |  |  |  |  |  |  |  |  |  |  |  |  |  |  |  |  |  |  |  |  |  |  |  |  |  |  |  |  |  |  |  |  |  |  |  |
| S179100 |  | Procure Contracted Labor Univ. Illinois Urbana-Champaign (UIUC) - Provide Requirements to Procurement |  | 5d | 2017-06-09 A | 2017-06-15 A | S100090 SS+90d | 100% |  |  |  |  |  |  |  |  | S179100 | 100 |  |  | S342530 |  | NOCA | Completed |  | Sickles, Anne |  | BNL | Design | PP1 | MP203200 | Craig Woody | BNL | null | POM02.1.03.01.04 |  |  |  |  |  |  | 04 | 02 | 2 |  |  |  |  |  | MP6LAEXCLUDE | 180419 ELM added procurement string | yes | Yes |  |  |
| S179200 |  | Procure Contracted Labor Univ. Illinois Urbana-Champaign (UIUC) - Vendor Selection |  | 30d | 2017-06-16 A | 2017-07-28 A | S179100 | 100% |  |  |  |  |  |  |  |  | S179200 | 100 |  |  | S342540 |  | NOCA | Completed |  | Sickles, Anne |  | BNL | Design | PP4 | MP203200 | Craig Woody | BNL | null | POM02.1.03.01.04 |  |  |  |  |  |  | 04 | 02 | 2 |  |  |  |  |  | MP6LAEXCLUDE | 180419 ELM added procurement string | yes | Yes |  |  |
| OBLG179310 |  | Procure Contracted Labor Univ. Illinois Urbana-Champaign (UIUC) - Obligation |  | 1d | 2017-07-31 A | 2017-07-31 A | S179200 | 100% |  |  |  |  |  |  | Obligation Resource |  | S179300 | 100 |  |  | S342550 |  | NOCA | Completed | A-OPC | Sickles, Anne |  | BNL | Design | PP5 | MP203200 | Craig Woody | BNL |  | POM02.1.03.01.04 |  |  |  |  | 003 |  | 04 | 02 | 3 |  |  |  |  | L5 | MP6LAEXCLUDE | 180419 ELM added procurement string | yes | Yes |  |  |
| S179300 |  | Procure Contracted Labor Univ. Illinois Urbana-Champaign (UIUC) - Contract Award | milestone | 0d | 2017-07-31 A | 2017-07-31 A | S179200 | 100% |  |  |  |  |  |  |  |  | S179300 | 100 |  |  | S342550 |  | NOCA | Completed | A-OPC | Sickles, Anne |  | BNL | Design | PP5 | MP203200 | Craig Woody | BNL |  | POM02.1.03.01.04 |  |  |  |  | 003 |  | 04 | 02 | 2 |  |  |  |  | L5 | MP6LAEXCLUDE | 180419 ELM added procurement string | yes | Yes |  |  |
| OBLG179610 |  | Procure Contracted Labor and M&S Univ. Illinois Urbana-Champaign (UIUC) - Obligation FY19 |  | 1d | 2019-09-11 A | 2019-09-11 A | S179200, S101000 FF | 100% |  |  |  |  |  |  | Obligation Resource [833633 h] | 833,633 | S179600 | 0 |  |  | S342570 |  |  | Completed | A-TEC | Sickles, Anne |  | BNL | Design | PP5 | MP203210 | Craig Woody |  |  | POM02.1.03.01.04 |  |  |  | OBLG | 003,004 |  | 04 |  |  |  |  |  |  | L5 |  | 180419 ELM added procurement string |  |  | 190328 ELM name, split |  |
| OBLG179611 |  | Procure Contracted Labor and M&S Univ. Illinois Urbana-Champaign (UIUC) - Obligation FY20 |  | 1d | 2019-10-01 A | 2019-10-01 A | S101010, S179601 SS | 100% |  |  |  |  |  |  | Obligation Resource [756600 h] | 756,600 | S179600 | 0 |  |  | S342570 |  |  | Completed | A-TEC | Sickles, Anne |  | BNL | Design | PP5 | MP203220 | Craig Woody |  |  | POM02.1.03.01.04 |  |  |  | OBLG | 003 |  | 04 |  |  |  |  |  |  | L5 |  | 180419 ELM added procurement string |  |  | 190328 ELM add |  |
| S179600 |  | Procure Contracted Labor and M&S Univ. Illinois Urbana-Champaign (UIUC) - Contract Award FY19 | milestone | 0d | 2019-11-25 A | 2019-11-25 A | S179200, S101000 | 100% |  | 2019-12-02 | 2019-12-02 |  |  |  |  |  | S179600 | 0 |  |  | S342570 |  | NOCA | Completed | A-TEC | Sickles, Anne |  | BNL | Design | PP5 | MP203210 | Craig Woody |  |  | POM02.1.03.01.04 |  |  |  |  | 003,004 |  | 04 | 02 | 3 |  |  |  |  | L5 |  | 180419 ELM added procurement string |  |  | 190328 ELM name, split | LLPs |
| S179601 |  | Procure Contracted Labor and M&S Univ. Illinois Urbana-Champaign (UIUC) - Contract Award FY20 | milestone | 0d | 2019-11-25 A | 2019-11-25 A | S179600 SS, S101010 | 100% |  | 2019-12-02 | 2019-12-02 |  |  |  |  |  | S179600 | 0 |  |  | S342570 |  | NOCA | Completed | A-TEC | Sickles, Anne |  | BNL | Design | PP5 | MP203220 | Craig Woody |  |  | POM02.1.03.01.04 |  |  |  |  | 003 |  | 04 | 02 | 3 |  |  |  |  | L5 |  | 180419 ELM added procurement string |  |  | 190328 ELM add | LLPs |

Notes:
- S178300: BNL_UDF_Old Activity Name 181221: Pack and ship final blocks for sectors 13-16 to BNL
- S178310: BNL_UDF_Old Activity Name 181221: Pack and ship final blocks for sectors 13-16 to BNL
- S178400: BNL_UDF_Old Activity Name 181221: Pack and ship final blocks for sectors 17-24 to BNL
- S178410: BNL_UDF_Old Activity Name 181221: Pack and ship final blocks for sectors 17-24 to BNL
- S178500: BNL_UDF_Old Activity Name 181221: Pack and ship final blocks for sectors 25-32 to BNL
- S178510: BNL_UDF_Old Activity Name 181221: Pack and ship final blocks for sectors 25-32 to BNL
- S178600: BNL_UDF_Old Activity Name 181221: Pack and ship final blocks for sectors 33-40 to BNL
- S178610: BNL_UDF_Old Activity Name 181221: Pack and ship final blocks for sectors 33-40 to BNL
- S178700: BNL_UDF_Old Activity Name 181221: Pack and ship final blocks for sectors 40-48 to BNL
- S178710: BNL_UDF_Old Activity Name 181221: Pack and ship final blocks for sectors 40-48 to BNL
- S178800: BNL_UDF_Old Activity Name 181221: Pack and ship final blocks for sectors 49-56 to BNL
- S178910: BNL_UDF_Old Activity Name 181221: Pack and ship final blocks for sectors 49-56 to BNL
- S176010: BNL_UDF_Old Activity Name 181221: Pack and ship final blocks for sectors 56-64 to BNL
- S178900: BNL_UDF_Old Activity Name 181221: Pack and ship final blocks for sectors 56-64 to BNL
- S179000: BNL_UDF_Old Activity Name 181221: EMCal final blocks arrive at BNL
- S179100: BNL_UDF_Old Activity Name 181221: Procure Contracted Labor Univ. Illinois Urbana-Champaign (UIUC) - Provide Requirements to Procurement
- S179200: BNL_UDF_Old Activity Name 181221: Procure Contracted Labor Univ. Illinois Urbana-Champaign (UIUC) - Vendor Selection
- OBLG179310: BNL_UDF_Old Activity Name 181221: Procure Contracted Labor Univ. Illinois Urbana-Champaign (UIUC) - Contract Award No. 1 - OPC
- S179300: BNL_UDF_Old Activity Name 181221: Procure Contracted Labor Univ. Illinois Urbana-Champaign (UIUC) - Contract Award No. 1 - OPC
- OBLG179610: BNL_UDF_Old Activity Name 181221: Procure Contracted Labor Univ. Illinois Urbana-Champaign (UIUC) - Contract Award No. 2 - TEC
- OBLG179611: BNL_UDF_Old Activity Name 181221: Procure Contracted Labor Univ. Illinois Urbana-Champaign (UIUC) - Contract Award No. 2 - TEC
- S179600: BNL_UDF_Old Activity Name 181221: Procure Contracted Labor Univ. Illinois Urbana-Champaign (UIUC) - Contract Award No. 2 - TEC
- S179601: BNL_UDF_Old Activity Name 181221: Procure Contracted Labor Univ. Illinois Urbana-Champaign (UIUC) - Contract Award No. 2 - TEC

| ID | WBS | Activity | Type | Duration | Start | Finish | Predecessors | Complete | Planned start | Planned finish | Resources | Cost | BNL_UDF_Temp Text 01 | BNL_UDF_Percent Complete | BNL_UDF_OPC TEC (deprecated) | BNL_UDF_Old Activity ID 181221 | RG Check | BNL_Activity Status | BNL_Estimator | BNL_Cost Basis | BNL_Location | BNL_EDIA | BNL_CAM | BNL_Institution | BNL_OPC TEC (deprecated) | BNL_WBS | BNL_EVT | BNL_WBS_Hierarchical | Completed | PMP Summary Part1 | PMP Summary Part2 | BNL_DOE OPC | BNL_UDF_Status Comments | BNL_PCR ID | BNL_UDF_Temp Date 01 | BNL_Fund Source | BNL_Account Number | BNL_Cobra WP | BNL_Master Control Account | BNL_Cobra Control Account | Temp | Indicator - Procurement | BNL_R&D FY18-19 |
| --- | --- | --- | --- | --- | --- | --- | --- | --- | --- | --- | --- | --- | --- | --- | --- | --- | --- | --- | --- | --- | --- | --- | --- | --- | --- | --- | --- | --- | --- | --- | --- | --- | --- | --- | --- | --- | --- | --- | --- | --- | --- | --- | --- |
|  | 02 | **EMCAL Module Fabrication and Sector Assembly** |  |  | 2017-03-09 | 2022-02-04 |  |  |  |  |  |  |  |  |  |  |  |  |  |  |  |  |  |  |  |  |  |  |  |  |  |  |  |  |  |  |  |  |  |  |  |  |  |
|  | 01 | **Set up Module Fabrication, Sector Assembly and Test area** |  |  | 2018-05-01 | 2019-11-25 |  |  |  |  |  |  |  |  |  |  |  |  |  |  |  |  |  |  |  |  |  |  |  |  |  |  |  |  |  |  |  |  |  |  |  |  |  |
| S180500 |  | Set up EMCAL test area Labor |  | 22d | 2018-05-01 A | 2018-05-31 A | S158100 SS | 100% |  |  |  |  | S180500 | 100 | S166400 | S166400 | NOCA | Completed | Stoll, Sean | L3 | BNL | Fab & Assy | Craig Woody | BNL | null | POM02.1.03.02.01 | C | 01 | yes | 02 | 7 |  |  |  |  |  |  |  |  |  |  |  |  |
| S180600 |  | Set up EMCAL test area M&S |  | 22d | 2018-05-01 A | 2018-05-31 A | S158100 SS | 100% |  |  |  |  | S180600 | 100 | S166700 | S166700 | NOCA | Completed | Stoll, Sean | M4 | BNL | Fab & Assy | Craig Woody | BNL | OPC | POM02.1.03.02.01 | C | 01 | yes | 02 | 7 | OPC001200 |  |  |  |  |  |  |  |  |  |  |  |
| S180700 |  | Safety Review of Assembly and Test Areas |  | 0d | 2018-06-01 A | 2018-06-01 A | S180500, S180600 | 100% |  |  |  |  | S180700 | 100 | S166500 | S166500 | NOCA | Completed | Stoll, Sean | L2 | BNL | Fab & Assy | Craig Woody | BNL | null | POM02.1.03.02.01 | C | 01 | yes | 02 | 7 |  | 190522 IVS new name; 190415 ELM name per GRY | 004 |  |  |  |  |  |  |  |  |  |
| S180200 |  | Set up EMCAL Final module production and sector assembly areas Labor |  | 146d | 2018-10-30 A | 2019-05-31 A | S158300 | 100% |  |  |  |  | S180200 | 30 | S166300 | S166300 | NOCA | Completed | Stoll, Sean | L3 | BNL | Fab & Assy | Craig Woody | BNL | null | POM02.1.03.02.01 | C | 01 | yes | 02 | 7 |  |  |  | 2019-05-01 | B | 16710 |  |  |  |  |  |  |
| S180300 |  | Set up EMCAL Prepro module production and sector assembly areas M&S |  | 40d | 2018-10-31 A | 2018-12-31 A | S158300 | 100% |  |  |  |  | S180300 | 100 | S166600 | S166600 | NOCA | Completed | Stoll, Sean | M4 | BNL | Fab & Assy | Craig Woody | BNL | OPC | POM02.1.03.02.01 | C | 01 | yes | 02 | 7 | OPC001200 |  |  |  | A-OPC | 16702 |  |  |  |  |  |  |
| S180400 |  | Set up EMCAL Final module production and sector assembly areas M&S |  | 105d | 2019-01-02 A | 2019-05-31 A | S180300 | 100% |  |  |  |  | S180400 | 10 | S166600 | S166650 | NOCA | Completed | Stoll, Sean | M4 | BNL | Fab & Assy | Craig Woody | BNL | OPC | POM02.1.03.02.01 | C | 01 | yes | 02 | 7 | OPC001200 |  |  | 2019-05-01 | A-OPC | 16702 |  |  |  |  |  |  |
| S180202 |  | Set up EMCAL Final module production and sector assembly areas Labor Split_75% |  | 84d | 2019-06-03 A | 2019-11-25 A | S180200 | 100% | 2019-06-03 | 2019-09-30 | SCI3 PO [14 h]; TECH3 PO M [17 h] | 4,222.87 | S180200 | 30 | S166300 | S166300 | CA | Completed | Stoll, Sean | L3 | BNL | Fab & Assy | Craig Woody | BNL | null | POM02.1.03.02.01 | C | 01 |  | 02 | 7 |  |  |  | 2019-05-01 | B | 16710 | S180202 | 1.03 | 1.03B | 1 |  |  |
| S180402 |  | Set up EMCAL Final module production and sector assembly areas M&S Split |  | 64d | 2019-06-03 A | 2019-08-30 A | S180400 | 100% |  |  | Material (Purchase (1st $2M) [10150 h] | 11,198.14 | S180400 | 10 | S166600 | S166650 | CA | Completed | Stoll, Sean | M4 | BNL | Fab & Assy | Craig Woody | BNL | OPC | POM02.1.03.02.01 | C | 01 |  | 02 | 7 | OPC001200 |  |  | 2019-05-01 | A-OPC | 16702 | S180402 | 1.03 | 1.03A |  | UDF_G2 |  |
|  | 02 | **EMCAL Module Fabrication** |  |  | 2017-03-09 | 2022-02-03 |  |  |  |  |  |  |  |  |  |  |  |  |  |  |  |  |  |  |  |  |  |  |  |  |  |  |  |  |  |  |  |  |  |  |  |  |  |
|  | 01 | **EMCAL Prototype V2.1 Module Fabrication** |  |  | 2017-03-09 | 2017-12-18 |  |  |  |  |  |  |  |  |  |  |  |  |  |  |  |  |  |  |  |  |  |  |  |  |  |  |  |  |  |  |  |  |  |  |  |  |  |
| S180800 |  | Design 2D projective blocks for v2.1 prototype |  | 10d | 2017-03-09 A | 2017-03-22 A | S100090 SS+25d | 100% |  |  |  |  | S180800 | 100 | S166800 | S166800 | NOCA | Completed | Stoll, Sean |  | BNL | Design | Craig Woody | BNL |  | POM02.1.03.02.02.01 |  | 01 | yes | 1 | 1 |  |  |  |  |  |  |  |  |  |  |  | EMCal v2.1 |
| S180900 |  | Design screens for v2.1 prototype blocks |  | 5d | 2017-03-23 A | 2017-03-29 A | S180800 | 100% |  |  |  |  | S180900 | 100 | S166900 | S166900 | NOCA | Completed | Stoll, Sean |  | BNL | Design | Craig Woody | BNL |  | POM02.1.03.02.02.01 |  | 01 | yes | 1 | 1 |  |  |  |  |  |  |  |  |  |  |  | EMCal v2.1 |
| S181000 |  | Design light guides for v2.1 prototype blocks |  | 30d | 2017-03-30 A | 2017-05-10 A | S180900 | 100% |  |  |  |  | S181000 | 100 | S167000 | S167000 | NOCA | Completed | Stoll, Sean |  | BNL | Design | Craig Woody | BNL |  | POM02.1.03.02.02.01 |  | 01 | yes | 1 | 1 |  |  |  |  |  |  |  |  |  |  |  | EMCal v2.1 |
| S181100 |  | Procure light guides for v2.1 prototype modules Labor |  | 140d | 2017-05-11 A | 2017-12-01 A | S181000 | 100% |  |  |  |  | S181100 | 100 | S167100 | S167100 | NOCA | Completed | Stoll, Sean |  | BNL | Procurement | Craig Woody | BNL |  | POM02.1.03.02.02.01 |  | 01 | yes | 02 | 2 |  |  |  |  |  |  |  |  |  |  |  | EMCal v2.1 |
| S181800 |  | Procure light guides for v2.1 prototype modules M&S |  | 140d | 2017-05-11 A | 2017-12-01 A | S181000 | 100% |  |  |  |  | S181800 | 100 | S167800 | S167800 | NOCA | Completed | Stoll, Sean |  | BNL | Fab & Assy | Craig Woody | BNL |  | POM02.1.03.02.02.01 |  | 01 | yes | 02 | 4 |  |  |  |  |  |  |  |  |  |  |  | EMCal v2.1 |
| S181200 |  | Procure mechanical parts for V2.1 prototype modules Labor |  | 36d | 2017-08-21 A | 2017-10-11 A | S180800 | 100% |  |  |  |  | S181200 | 100 | S167200 | S167200 | NOCA | Completed | Stoll, Sean |  | BNL | Procurement | Craig Woody | BNL |  | POM02.1.03.02.02.01 |  | 01 | yes | 02 | 2 |  |  |  |  |  |  |  |  |  |  |  | EMCal v2.1 |
| S181900 |  | Procure mechanical parts for V2.1 prototype modules M&S |  | 36d | 2017-08-21 A | 2017-10-11 A | S180800 | 100% |  |  |  |  | S181900 | 100 | S167900 | S167900 | NOCA | Completed | Stoll, Sean |  | BNL | Fab & Assy | Craig Woody | BNL |  | POM02.1.03.02.02.01 |  | 01 | yes | 02 | 4 |  |  |  |  |  |  |  |  |  |  |  | EMCal v2.1 |
| S181300 |  | Receive, unpack, log and inspect blocks for v2.1 Prototype |  | 0d | 2017-10-17 A | 2017-10-17 A | S157000 | 100% |  |  |  |  | S181300 | 100 | S167300 | S167300 | NOCA | Completed | Stoll, Sean |  | BNL | Fab & Assy | Craig Woody | BNL |  | POM02.1.03.02.02.01 |  | 01 | yes | 02 | 4 |  |  |  |  |  |  |  |  |  |  |  | EMCal v2.1 |
| S181400 |  | Install reflectors and mounting supports on v2.1 prototype blocks |  | 0d | 2017-10-18 A | 2017-10-18 A | S181300, S181200 | 100% |  |  |  |  | S181400 | 100 | S167400 | S167400 | NOCA | Completed | Stoll, Sean |  | BNL | Fab & Assy | Craig Woody | BNL |  | POM02.1.03.02.02.01 |  | 01 | yes | 02 | 4 |  |  |  |  |  |  |  |  |  |  |  | EMCal v2.1 |
| S182000 |  | Install reflectors and mounting supports on v2.1 prototype blocks |  | 0d | 2017-10-18 A | 2017-10-18 A | S181300, S181900 | 100% |  |  |  |  | S182000 | 100 | S168000 | S168000 | NOCA | Completed | Stoll, Sean |  | BNL | Procurement | Craig Woody | BNL |  | POM02.1.03.02.02.01 |  | 01 | yes | 02 | 2 |  |  |  |  |  |  |  |  |  |  |  | EMCal v2.1 |
| S181500 |  | Prepare light guides for V2.1 prototype |  | 5d | 2017-12-04 A | 2017-12-08 A | S181100, S181800 | 100% |  |  |  |  | S181500 | 100 | S167500 | S167500 | NOCA | Completed | Stoll, Sean |  | BNL | Fab & Assy | Craig Woody | BNL |  | POM02.1.03.02.02.01 |  | 01 | yes | 02 | 4 |  |  |  |  |  |  |  |  |  |  |  | EMCal v2.1 |
| S181600 |  | Install light guides on v2.1 prototype blocks |  | 5d | 2017-12-11 A | 2017-12-15 A | S181300, S181500 | 100% |  |  |  |  | S181600 | 100 | S167600 | S167600 | NOCA | Completed | Stoll, Sean |  | BNL | Procurement | Craig Woody | BNL |  | POM02.1.03.02.02.01 |  | 01 | yes | 02 | 2 |  |  |  |  |  |  |  |  |  |  |  | EMCal v2.1 |
| S182100 |  | Procure EMCAL Prototype V2.1 Blocks & Modules - Delivery Acceptance |  | 5d | 2017-12-11 A | 2017-12-15 A | S181300, S181500 | 100% |  |  |  |  | S182100 | 100 | S168100 | S168100 | NOCA | Completed | Stoll, Sean |  | BNL | Fab & Assy | Craig Woody | BNL |  | POM02.1.03.02.02.01 |  | 01 | yes | 02 | 4 |  |  |  |  |  |  |  |  |  |  |  | EMCal v2.1 |
| S181700 |  | Install SiPMs & daughterboards on v2.1 prototype blocks |  | 0d | 2017-12-18 A | 2017-12-18 A | S181400, S181600 | 100% |  |  |  |  | S181700 | 100 | S167700 | S167700 | NOCA | Completed | Stoll, Sean |  | BNL | Fab & Assy | Craig Woody | BNL |  | POM02.1.03.02.02.01 |  | 01 | yes | 02 | 4 |  |  |  |  |  |  |  |  |  |  |  | EMCal v2.1 |
| S182200 |  | Install SiPMs & daughterboards on v2.1 prototype blocks |  | 0d | 2017-12-18 A | 2017-12-18 A | S182000, S182100 | 100% |  |  |  |  | S182200 | 100 | S168200 | S168200 | NOCA | Completed | Stoll, Sean |  | BNL | Procurement | Craig Woody | BNL |  | POM02.1.03.02.02.01 |  | 01 | yes | 02 | 2 |  |  |  |  |  |  |  |  |  |  |  | EMCal v2.1 |
| S182201 |  | Preliminary Design Review - EMCal Modules for Sectors 1-12 | milestone | 0d | 2017-12-18 A | 2017-12-18 A | S182200 FF | 100% |  |  |  |  | S182200 | 100 | S168200 | S168200 | NOCA | Completed | Stoll, Sean |  | BNL | Procurement | Craig Woody | BNL |  | POM02.1.03.02.02.01 |  | 01 | yes | 02 | 2 |  | 190522 IVS new act. | 004 |  |  |  |  |  |  |  |  | EMCal v2.1 |

Notes:
- S180500: BNL_UDF_Adhoc Comments: 180410 ELM pred/succ per GRY; 180330 ELM pred per GRY; 180410 ELM dur per GRY; 180227 ELM deduct 4 tech hr per GRY / BNL_UDF_Old Activity Name 181221: Set up EMCAL test area Labor
- S180600: BNL_UDF_Adhoc Comments: 180410 ELM pred/succ,dur per GRY; 180330 ELM pred per GRY; 180410 ELM dur per GRY; 180410 ELM pred/succ per GRY / BNL_UDF_Old Activity Name 181221: Set up EMCAL test area M&S
- S180700: General Comments: 180420 GYoung: concerning Safety / Review - Setting up space at BNL thus need safety / review / BNL_UDF_Adhoc Comments: 180330 ELM pred per GRY / BNL_UDF_Old Activity Name 181221: Safety Review of Assembly and Test Areas
- S180200: BNL_UDF_Adhoc Comments: 180410 ELM pred/succ,dur per GRY; 180227 ELM add 4 tech hr per GRY / BNL_UDF_Old Activity Name 181221: Set up EMCAL Final module production and sector assembly areas Labor
- S180300: BNL_UDF_Adhoc Comments: 180330 ELM pred per GRY / BNL_UDF_Old Activity Name 181221: Set up EMCAL Prepro module production and sector assembly areas M&S
- S180400: BNL_UDF_Adhoc Comments: 180330 ELM pred per GRY / BNL_UDF_Old Activity Name 181221: Set up EMCAL Final module production and sector assembly areas M&S
- S180202: BNL_UDF_Adhoc Comments: 180410 ELM pred/succ,dur per GRY; 180227 ELM add 4 tech hr per GRY / BNL_UDF_Old Activity Name 181221: Set up EMCAL Final module production and sector assembly areas Labor
- S180402: BNL_UDF_Adhoc Comments: 180330 ELM pred per GRY / BNL_UDF_Old Activity Name 181221: Set up EMCAL Final module production and sector assembly areas M&S
- S180800: BNL_UDF_Old Activity Name 181221: Design 2D projective blocks for v2.1 prototype
- S180900: BNL_UDF_Old Activity Name 181221: Design screens for v2.1 prototype blocks
- S181000: BNL_UDF_Old Activity Name 181221: Design light guides for v2.1 prototype blocks
- S181100: BNL_UDF_Old Activity Name 181221: Procure light guides for v2.1 prototype modules Labor
- S181800: BNL_UDF_Old Activity Name 181221: Procure light guides for v2.1 prototype modules M&S
- S181200: BNL_UDF_Old Activity Name 181221: Procure mechanical parts for V2.1 prototype modules Labor
- S181900: BNL_UDF_Old Activity Name 181221: Procure mechanical parts for V2.1 prototype modules M&S
- S181300: BNL_UDF_Old Activity Name 181221: Receive, unpack, log and inspect blocks for v2.1 Prototype
- S181400: BNL_UDF_Old Activity Name 181221: Install reflectors and and mounting supports on v2.1 prototype blocks
- S182000: BNL_UDF_Old Activity Name 181221: Install reflectors and and mounting supports on v2.1 prototype blocks
- S181500: BNL_UDF_Old Activity Name 181221: Prepare light guides for V2.1 prototype
- S181600: BNL_UDF_Old Activity Name 181221: Install light guides on v2.1 prototype blocks
- S182100: BNL_UDF_Old Activity Name 181221: Procure EMCAL Prototype V2.1 Blocks & Modules - Delivery Acceptance
- S181700: BNL_UDF_Old Activity Name 181221: Install SiPMs & daughterboards on v2.1 prototype blocks
- S182200: BNL_UDF_Old Activity Name 181221: Install SiPMs & daughterboards on v2.1 prototype blocks
- S182201: BNL_UDF_Old Activity Name 181221: Install SiPMs & daughterboards on v2.1 prototype blocks

| ID | WBS | Activity | Type | Duration | Start | Finish | Predecessors | Complete | Planned start | Planned finish | Resources | Cost | BNL_UDF_Temp Text 01 | BNL_UDF_Percent Complete | BNL_UDF_OPC TEC (deprecated) | BNL_UDF_Old Activity ID 181221 | RG Check | BNL_Activity Status | BNL_Estimator | BNL_Location | BNL_EDIA | BNL_CAM | BNL_Institution | BNL_R&D FY18-19 | BNL_WBS | BNL_WBS_Hierarchical | Completed | PMP Summary Part1 | PMP Summary Part2 | BNL_UDF_Temp Date 01 | BNL_Cost Basis | BNL_OPC TEC (deprecated) | BNL_EVT | BNL_DOE OPC | BNL_Split Activity | BNL_Fund Source | BNL_Account Number | BNL_PCR ID | Cost = Awarded Proc or Mgmt | BNL_Proc Sig Phase | BNL_Proc Sig | BNL_Milestone Level | SPH Proc Register | BNL_UDF_Exclude | BNL_Cobra WP | BNL_Master Control Account | BNL_Cobra Control Account | BNL_Obligation | Indicator - Procurement | Indicator - Float | BNL_UDF_Remaining Tot Cost | BNL_UDF_Percent_remaining | Additional EVT documentation required |
| --- | --- | --- | --- | --- | --- | --- | --- | --- | --- | --- | --- | --- | --- | --- | --- | --- | --- | --- | --- | --- | --- | --- | --- | --- | --- | --- | --- | --- | --- | --- | --- | --- | --- | --- | --- | --- | --- | --- | --- | --- | --- | --- | --- | --- | --- | --- | --- | --- | --- | --- | --- | --- | --- |
|  | 02 | **EMCAL Preprod Sector 0, 1-12 Module Fabrication** |  |  | 2017-03-23 | 2021-01-11 |  |  |  |  |  |  |  |  |  |  |  |  |  |  |  |  |  |  |  |  |  |  |  |  |  |  |  |  |  |  |  |  |  |  |  |  |  |  |  |  |  |  |  |  |  |  |  |
| S182300 |  | Design 2D projective blocks for preproduction prototype |  | 5d | 2017-03-23 A | 2017-03-29 A | S180800 | 100% |  |  |  |  | S182300 | 100 | S168300 | S168300 | NOCA | Completed | Stoll, Sean | BNL | Design | Craig Woody | BNL | EMCal Prepro Sector | POM02.1.03.02.02.02 | 02 | yes | 1 | 1 |  |  |  |  |  |  |  |  |  |  |  |  |  |  |  |  |  |  |  |  |  |  |  |  |
| S182400 |  | Design screens for preproduction prototype blocks |  | 5d | 2017-03-30 A | 2017-04-05 A | S180900 | 100% |  |  |  |  | S182400 | 100 | S168400 | S168400 | NOCA | Completed | Stoll, Sean | BNL | Design | Craig Woody | BNL | EMCal Prepro Sector | POM02.1.03.02.02.02 | 02 | yes | 1 | 1 |  |  |  |  |  |  |  |  |  |  |  |  |  |  |  |  |  |  |  |  |  |  |  |  |
| S182500 |  | Design light guides for preproduction prototype |  | 57d | 2017-05-11 A | 2017-08-01 A | S181000 | 100% |  |  |  |  | S182500 | 100 | S168500 | S168500 | NOCA | Completed | Stoll, Sean | BNL | Design | Craig Woody | BNL | EMCal Prepro Sector | POM02.1.03.02.02.02 | 02 | yes | 1 | 1 |  |  |  |  |  |  |  |  |  |  |  |  |  |  |  |  |  |  |  |  |  |  |  |  |
| S182600 |  | Procure light guides for preproduction prototype sector 0 Labor |  | 90d | 2018-05-23 A | 2018-09-28 A | S182500, S190100 | 100% |  |  |  |  | S182600 | 100 | S168600 | S168600 | NOCA | Completed | Stoll, Sean | BNL | Procurement | Craig Woody | BNL | EMCal Prepro Sector | POM02.1.03.02.02.02 | 02 | yes | 02 | 2 | 2018-07-31 | L2 | null | C |  |  |  |  |  |  |  |  |  |  |  |  |  |  |  |  |  |  |  |  |
| S182700 |  | Procure light guides for preproduction prototype sector 0 M&S |  | 90d | 2018-05-23 A | 2018-09-28 A | S182500, S190100 | 100% |  |  |  |  | S182700 | 100 | S168700 | S168700 | NOCA | Completed | Stoll, Sean | BNL | Fab & Assy | Craig Woody | BNL | EMCal Prepro Sector | POM02.1.03.02.02.02 | 02 | yes | 02 | 4 | 2018-07-31 | M3 | OPC |  | OPC001400 |  |  |  |  |  |  |  |  |  |  |  |  |  |  |  |  |  |  |  |
| S182800 |  | Procure mechanical parts for modules for preproduction prototype sector 0 M&S FY18 |  | 90d | 2018-05-23 A | 2018-09-28 A | S100300, S190100 | 100% |  |  |  |  | S182800 | 100 | S168800 | S168800 | NOCA | Completed | Stoll, Sean | BNL | Fab & Assy | Craig Woody | BNL | EMCal Prepro Sector | POM02.1.03.02.02.02 | 02 | yes | 02 | 4 | 2018-11-01 | M3 | OPC |  | OPC001400 | FY18 |  |  |  |  |  |  |  |  |  |  |  |  |  |  |  |  |  |  |
| S183000 |  | Procure mechanical parts for modules for preproduction prototype sector 0 Labor FY18 |  | 90d | 2018-05-23 A | 2018-09-28 A | S182300, S190100 | 100% |  |  |  |  | S183000 | 100 | S168900 | S168900 | NOCA | Completed | Stoll, Sean | BNL | Procurement | Craig Woody | BNL | EMCal Prepro Sector | POM02.1.03.02.02.02 | 02 | yes | 02 | 2 | 2018-11-01 | L2 | null |  |  | FY18 |  |  |  |  |  |  |  |  |  |  |  |  |  |  |  |  |  |  |
| S182900 |  | Procure mechanical parts for modules for preproduction prototype sector 0 M&S FY19 |  | 22d | 2018-10-01 A | 2018-10-31 A | S182800 | 100% |  |  |  |  | S182900 | 100 | S168800 | S168820 | NOCA | Completed | Stoll, Sean | BNL | Fab & Assy | Craig Woody | BNL | EMCal Prepro Sector | POM02.1.03.02.02.02 | 02 | yes | 02 | 4 | 2018-11-01 | M3 | OPC | C | OPC001400 | FY19 | A-OPC | 16702 |  |  |  |  |  |  |  |  |  |  |  |  |  |  |  |  |
| S183100 |  | Procure mechanical parts for modules for preproduction prototype sector 0 Labor FY19 |  | 22d | 2018-10-01 A | 2018-10-31 A | S183000 | 100% |  |  |  |  | S183100 | 100 | S168900 | S168920 | NOCA | Completed | Stoll, Sean | BNL | Procurement | Craig Woody | BNL | EMCal Prepro Sector | POM02.1.03.02.02.02 | 02 | yes | 02 | 2 | 2018-11-01 | L2 | null | C |  | FY19 | B | 16710 |  |  |  |  |  |  |  |  |  |  |  |  |  |  |  |  |
| S183200 |  | Receive, unpack, log & inspect preproduction prototype blocks sector 0 M&S |  | 138d | 2018-10-25 A | 2019-05-15 A | S159300, S159500, S160700 FF, S159200, S159400, S159600 SS, S159700 SS, S159800 FF, S159900 FF, S160000 FF, S160100 FF, S160200 FF, S160300 FF, S160400 FF, S160500 FF, S160600 FF, S180402 | 100% |  |  |  |  | S183200 | 30 | S169200 | S169201 | NOCA | Completed | Stoll, Sean | BNL | Fab & Assy | Craig Woody | BNL | EMCal Prepro Sector | POM02.1.03.02.02.02 | 02 | yes | 02 | 4 | 2019-05-01 |  |  | F |  |  | A-OPC | 16702 | 003 |  |  |  |  |  |  |  |  |  |  |  |  |  |  |  |
| S183300 |  | Receive, unpack, log & inspect preproduction prototype blocks sector 0 Labor |  | 138d | 2018-10-25 A | 2019-05-15 A | S159200, S159300, S159500, S160700 FF, S159400, S159600 SS, S159700 SS, S159800 FF, S159900 FF, S160000 FF, S160100 FF, S160200 FF, S160300 FF, S160400 FF, S160500 FF, S160600 FF | 100% |  |  |  |  | S183300 | 30 | S169300 | S169301 | NOCA | Completed | Stoll, Sean | BNL | Fab & Assy | Craig Woody | BNL | EMCal Prepro Sector | POM02.1.03.02.02.02 | 02 | yes | 02 | 4 | 2019-05-01 | L3 | null | C |  | FY18 | B | 16710 |  |  |  |  |  |  |  |  |  |  |  |  |  |  |  |  |
| S183400 |  | Install reflectors on preproduction prototype blocks sector 0 M&S |  | 137d | 2018-10-26 A | 2019-05-15 A | S182900 SS, S183100 SS, S183300 FF, S183200 FF, S183500 SS | 100% |  |  |  |  | S183400 | 30 | S169400 | S169400 | NOCA | Completed | Stoll, Sean | BNL | Fab & Assy | Craig Woody | BNL | EMCal Prepro Sector | POM02.1.03.02.02.02 | 02 | yes | 02 | 4 | 2019-05-01 | M3 | OPC | C | OPC001400 |  | A-OPC | 16702 |  | Yes |  |  |  |  |  |  |  |  |  |  |  |  |  |  |
| S183500 |  | Install reflectors on preproduction prototype blocks sector 0 Labor |  | 137d | 2018-10-26 A | 2019-05-15 A | S182900 SS, S183100 SS, S183300 FF, S183200 FF | 100% |  |  |  |  | S183500 | 30 | S169500 | S169500 | NOCA | Completed | Stoll, Sean | BNL | Fab & Assy | Craig Woody | BNL | EMCal Prepro Sector | POM02.1.03.02.02.02 | 02 | yes | 02 | 4 | 2019-05-01 | L3 | null | C |  |  | B | 16710 |  |  |  |  |  |  |  |  |  |  |  |  |  |  |  |  |
| S183600 |  | Install light guides on preproduction prototype blocks sector 0 M&S |  | 137d | 2018-10-26 A | 2019-05-15 A | S182700, S183400 SS, S182600, S183300 FF, S183200 FF | 100% |  |  |  |  | S183600 | 30 | S169600 | S169600 | NOCA | Completed | Stoll, Sean | BNL | Fab & Assy | Craig Woody | BNL | EMCal Prepro Sector | POM02.1.03.02.02.02 | 02 | yes | 02 | 4 | 2019-05-01 | M3 | OPC | C | OPC001400 |  | A-OPC | 16702 |  | Yes |  |  |  |  |  |  |  |  |  |  |  |  |  |  |
| S183700 |  | Install light guides on preproduction prototype blocks sector 0 Labor |  | 137d | 2018-10-26 A | 2019-05-15 A | S182600, S183500 SS, S183300 FF, S183200 FF | 100% |  |  |  |  | S183700 | 30 | S169700 | S169700 | NOCA | Completed | Stoll, Sean | BNL | Fab & Assy | Craig Woody | BNL | EMCal Prepro Sector | POM02.1.03.02.02.02 | 02 | yes | 02 | 4 | 2019-05-01 | L3 | null | C |  |  | B | 16710 |  |  |  |  |  |  |  |  |  |  |  |  |  |  |  |  |
| S184300 |  | Procure light guides for modules in Sectors (Prepro) 1-12 - Prepare & Send Solicitation |  | 38d | 2019-01-02 A | 2019-02-26 A | S184200 | 100% |  |  |  |  | S184300 | 100 | S170200 | S170200 | NOCA | Completed | Stoll, Sean | BNL | Procurement | Craig Woody | BNL | EMCal Prepro Sectors 1-12 | POM02.1.03.02.02.02 | 02 | yes | 02 | 2 |  |  |  |  |  |  |  |  |  |  | PP2 | MP200700 |  |  |  |  |  |  |  |  |  |  |  |  |
| S183900 |  | Install SiPMs & daughterboards on preproduction prototype blocks sector 0 |  | 73d | 2019-02-01 A | 2019-05-15 A | S218300, S183700 SS, S183600, S218800 | 100% |  |  |  |  | S183900 | 30 | S169900 | S169900 | NOCA | Completed | Stoll, Sean | BNL | Fab & Assy | Craig Woody | BNL | EMCal Prepro Sector | POM02.1.03.02.02.02 | 02 | yes | 02 | 4 | 2019-04-30 | L3 | null | C |  |  | B | 16710 |  |  |  |  |  |  |  |  |  |  |  |  |  |  |  |  |
| S184200 |  | Procure light guides for modules in Sectors (Prepro) 1-12 - Provide Requirements to Procurement |  | 4d | 2019-02-20 A | 2019-02-25 A | S183600 SS+60d, S183700 SS+60d | 100% |  |  |  |  | S184200 | 100 | S170100 | S170100 | NOCA | Completed | Stoll, Sean | BNL | Procurement | Craig Woody | BNL | EMCal Prepro Sectors 1-12 | POM02.1.03.02.02.02 | 02 | yes | 02 | 2 |  |  |  |  |  |  |  |  |  |  | PP1 | MP200700 |  |  |  |  |  |  |  |  |  |  |  |  |
| S184400 |  | Procure light guides for modules in Sectors (Prepro) 1-12 - Vendor Responses |  | 2d | 2019-02-26 A | 2019-02-27 A | S184300 | 100% |  |  |  |  | S184400 | 100 | S170300 | S170300 | NOCA | Completed | Stoll, Sean | BNL | Procurement | Craig Woody | BNL | EMCal Prepro Sectors 1-12 | POM02.1.03.02.02.02 | 02 | yes | 02 | 2 |  |  |  |  |  |  |  |  |  |  | PP3 | MP200700 |  |  |  |  |  |  |  |  |  |  |  |  |
| S184500 |  | Procure light guides for modules in Sectors (Prepro) 1-12 - Vendor Selection |  | 2d | 2019-02-27 A | 2019-02-28 A | S184400 | 100% |  |  |  |  | S184500 | 100 | S170400 | S170400 | NOCA | Completed | Stoll, Sean | BNL | Procurement | Craig Woody | BNL | EMCal Prepro Sectors 1-12 | POM02.1.03.02.02.02 | 02 | yes | 02 | 2 |  |  |  |  |  |  |  |  |  |  | PP4 | MP200700 |  |  |  |  |  |  |  |  |  |  |  |  |
| S184600 |  | Procure light guides for modules in Sectors (Prepro) 1-12 - Contract Award | milestone | 0d | 2019-03-01 A | 2019-03-01 A | S184500, S161800, S160900 | 100% |  |  |  |  | S184600 | 0 | S170500 | S170500 | NOCA | Completed | Stoll, Sean | BNL | Procurement | Craig Woody | BNL | EMCal Prepro Sectors 1-12 | POM02.1.03.02.02.02 | 02 | yes | 02 | 2 |  |  |  |  |  |  | A-OPC |  |  |  | PP5 | MP200700 | L5 | Contract Award |  |  |  |  |  |  |  |  |  |  |
| S184700 |  | Procure light guides for modules in Sectors (Prepro) 1-12 - Contract/PO Leadtime |  | 125d | 2019-03-01 A | 2019-06-28 A | S184600 SS, OBLG184610 SS | 100% | 2019-03-01 | 2019-08-26 |  |  | S184700 | 0 | S170600 | S170600 | NOCA | Completed | Stoll, Sean | BNL | Fab & Assy | Craig Woody | BNL | EMCal Prepro Sectors 1-12 | POM02.1.03.02.02.02 | 02 |  | 02 | 4 |  |  |  |  |  |  | A-OPC |  |  |  | PP6 | MP200700 |  |  | MP6LA |  |  |  |  |  |  |  |  |  |
| S183800 |  | EmCal Test Fit Blocks Sector 0 and Preproduction Readiness Review |  | 16d | 2019-05-02 A | 2019-05-23 A | S183500, S191000, S191100, S191110 | 100% |  |  |  |  | S183800 | 0 | S169800 | S169800 | NOCA | Completed | Stoll, Sean | BNL | Test_System | Craig Woody | BNL | EMCal Prepro Sector | POM02.1.03.02.02.02 | 02 | yes | 02 | 7 |  |  |  |  |  |  |  |  | 004 |  |  |  |  |  |  |  |  |  |  |  |  |  |  |  |
| S184000 |  | Glue preproduction prototype blocks together into modules sector 0 |  | 10d | 2019-05-02 A | 2019-05-15 A | S183900 SS+5d | 100% |  |  |  |  | S184000 | 0 | S170000 | S170000 | NOCA | Completed | Stoll, Sean | BNL | Fab & Assy | Craig Woody | BNL | EMCal Prepro Sector | POM02.1.03.02.02.02 | 02 | yes | 02 | 4 |  | L4 |  | C |  |  | B | 16710 |  |  |  |  |  |  |  |  |  |  |  |  |  |  |  |  |
| S184100 |  | Sector 0 Module Production Complete | milestone | 0d | 2019-05-15 A | 2019-05-15 A | S184000 FF | 100% |  |  |  |  | S184100 | 0 | S170000 | S170050 | NOCA | Completed | Stoll, Sean | BNL | Fab & Assy | Craig Woody | BNL | EMCal Prepro Sector | POM02.1.03.02.02.02 | 02 | yes | 02 | 4 |  | L4 | null | C |  |  | B |  |  |  |  |  | L4 |  |  |  |  |  |  |  |  |  |  |  |
| S183801 |  | Final Design Review, Production Readiness Review - EMCal Modules for Sectors 1-12 |  | 1d | 2019-08-01 A | 2019-08-01 A | S183800 FF | 100% |  |  | SCI3 Other - Unpaid [8 h]; PROF3 PO M [8 h]; SCI 4 PO [8 h] | 2,581.88 | S183800 | 0 | S169800 | S169800 | CA | Completed | Stoll, Sean | BNL | Test_System | Craig Woody | BNL | EMCal Prepro Sector | POM02.1.03.02.02.02 | 02 |  | 02 | 7 |  |  |  | C |  |  | B | 16710 | 004 |  |  |  |  |  |  | S183801 | 1.03 | 1.03B |  |  |  |  |  |  |
| S184900 |  | Procure mechanical parts for modules in Sectors (Prepro) 1-12 - Provide Requirements to Procurement |  | 5d | 2019-08-01 A | 2019-08-07 A | S183801 | 100% |  |  | PROF3 PO M [40 h] | 4,912.99 | S184900 | 0 | S170800 | S170800 | CA | Completed | Stoll, Sean | BNL | Procurement | Craig Woody | BNL | EMCal Prepro Sectors 1-12 | POM02.1.03.02.02.02 | 02 |  | 02 | 2 |  | L3 | null | C | OPC001400 |  | B | 16710 |  |  | PP1 | MP201100 |  |  |  | S184900 | 1.03 | 1.03B |  |  |  |  |  |  |
| S185300 |  | Procure mechanical parts for modules in Sectors (Prepro) 1-12 - Contract Award(s) | milestone | 0d | 2019-08-01 A | 2019-08-01 A | S185200, S160900, S161800 | 100% |  |  |  |  | S185300 | 0 | S170800 | S170840 | NOCA | Completed | Stoll, Sean | BNL | Procurement | Craig Woody | BNL | EMCal Prepro Sectors 1-12 | POM02.1.03.02.02.02 | 02 |  | 02 | 2 |  |  |  |  | OPC001400 |  | A-OPC |  |  |  | PP5 | MP201100 | L5 | Contract Award | MP6LA |  |  |  |  |  |  |  |  |  |
| S185400 |  | Procure mechanical parts for modules in Sectors (Prepro) 1-12 - Contract/PO - Leadtime |  | 40d | 2019-08-01 A | 2019-10-31 A | S185300 SS, OBLG185310 SS | 100% | 2019-08-01 | 2019-09-26 |  |  | S185400 | 0 | S170800 | S170850 | NOCA | Completed | Stoll, Sean | BNL | Fab & Assy | Craig Woody | BNL | EMCal Prepro Sectors 1-12 | POM02.1.03.02.02.02 | 02 |  | 02 | 4 |  |  |  |  | OPC001400 |  |  |  |  |  | PP6 | MP201100 |  |  | MP6LA |  |  |  |  |  |  |  |  |  |
| S185000 |  | Procure mechanical parts for modules in Sectors (Prepro) 1-12 - Prepare & Send Solicitation |  | 15d | 2019-08-08 A | 2019-08-28 A | S184900 | 100% |  |  |  |  | S185000 | 0 | S170800 | S170810 | NOCA | Completed | Stoll, Sean | BNL | Procurement | Craig Woody | BNL | EMCal Prepro Sectors 1-12 | POM02.1.03.02.02.02 | 02 |  | 02 | 2 |  |  |  |  | OPC001400 |  |  |  |  |  | PP2 | MP201100 |  |  |  |  |  |  |  |  |  |  |  |  |
| S185200 |  | Procure mechanical parts for modules in Sectors (Prepro) 1-12 - Vendor Selection |  | 20d | 2019-08-21 A | 2019-08-30 A | S185100 | 100% | 2019-09-13 | 2019-10-10 |  |  | S185200 | 0 | S170800 | S170830 | NOCA | Completed | Stoll, Sean | BNL | Procurement | Craig Woody | BNL | EMCal Prepro Sectors 1-12 | POM02.1.03.02.02.02 | 02 |  | 02 | 2 |  |  |  |  | OPC001400 |  |  |  |  |  | PP4 | MP201100 |  |  | MP6LA |  |  |  |  |  |  |  |  |  |
| S185100 |  | Procure mechanical parts for modules in Sectors (Prepro) 1-12 - Vendor Responses |  | 10d | 2019-08-29 A | 2019-08-30 A | S185000 | 100% | 2019-08-29 | 2019-09-12 |  |  | S185100 | 0 | S170800 | S170820 | NOCA | Completed | Stoll, Sean | BNL | Procurement | Craig Woody | BNL | EMCal Prepro Sectors 1-12 | POM02.1.03.02.02.02 | 02 |  | 02 | 2 |  |  |  |  | OPC001400 |  |  |  |  |  | PP3 | MP201100 |  |  | MP6LA |  |  |  |  |  |  |  |  |  |
| OBLG184610 |  | Procure light guides for modules in Sectors (Prepro) 1-12 - Obligation |  | 1d | 2019-09-03 A | 2019-09-03 A | S184500, S161800, S160900 | 100% |  |  | Obligation Resource [88914.4 h] | 88,914.4 | S184600 | 0 | S170500 | S170500 |  | Completed | Stoll, Sean | BNL | Procurement | Craig Woody | BNL | EMCal Prepro Sectors 1-12 | POM02.1.03.02.02.02 | 02 |  |  |  |  |  |  |  |  |  | A-OPC |  |  |  | PP5 | MP200700 | L5 |  |  |  |  |  | OBLG |  |  |  |  |  |
| OBLG185310 |  | Procure mechanical parts for modules in Sectors (Prepro) 1-12 - Obligation |  | 1d | 2019-09-03 A | 2019-09-03 A | S185200, S160900, S161800 | 100% |  |  | Obligation Resource [14961.5 h] | 14,961.45 | S185300 | 0 | S170800 | S170840 |  | Completed | Stoll, Sean | BNL | Procurement | Craig Woody | BNL | EMCal Prepro Sectors 1-12 | POM02.1.03.02.02.02 | 02 |  |  |  |  |  |  |  | OPC001400 |  | A-OPC |  |  |  | PP5 | MP201100 | L5 |  | MP6LA |  |  |  | OBLG |  |  |  |  |  |
| S184800 |  | Procure light guides for modules in Sectors (Prepro) 1-12 - Delivery Acceptance |  | 35d | 2019-09-03 A | 2020-12-14 A | S184700 | 100% | 2019-09-03 | 2019-10-22 | Material (Purchase (1st $2M) [79700 h] | 89,114.14 | S184800 | 0 | S170700 | S170700 | CA | In Progress | Stoll, Sean | BNL | Fab & Assy | Craig Woody | BNL | EMCal Prepro Sectors 1-12 | POM02.1.03.02.02.02 | 02 |  | 02 | 4 |  | M3 | OPC | C | OPC001400 |  | A-OPC | 16702 | 005 |  | PP6 | MP200700 |  | Delivery | MP6LA | S184800 | 1.03 | 1.03A | FAB | UDF_G1 | UDF_G1 | 64162.17815976 | 0.72 |  |
| S185800 |  | Install reflectors on blocks for modules for Prepro Sectors 1-12 M&S |  | 120d | 2019-10-09 A | 2020-10-30 A | S185600 SS+5d, S185500, S185700 SS+5d | 100% | 2019-12-09 | 2020-05-29 | Material (Purchase (1st $2M) [350 h] | 398.27 | S185800 | 0 | S171400 | S171400 | CA | In Progress | Stoll, Sean | BNL | Fab & Assy | Craig Woody | BNL | EMCal Prepro Sectors 1-12 | POM02.1.03.02.02.02 | 02 |  | 02 | 4 |  | M3 | OPC | C | OPC001400 |  | A-OPC | 16702 |  |  |  |  |  |  |  | S185800 | 1.03 | 1.03A |  | UDF_G1 | UDF_G1 | 306.67100002 | 0.77 | Yes |
| S185500 |  | Procure mechanical parts for modules in Sectors (Prepro) 1-12 - Delivery Acceptance |  | 1d | 2019-10-16 A | 2019-10-31 A | S185400 | 100% | 2019-12-02 | 2019-12-02 | Material (Purchase (1st $2M) [13148 h] | 14,961.45 | S185500 | 0 | S170900 | S170900 | CA | Completed | Stoll, Sean | BNL | Fab & Assy | Craig Woody | BNL | EMCal Prepro Sectors 1-12 | POM02.1.03.02.02.02 | 02 |  | 02 | 4 |  | M5 | OPC | C |  |  | A-OPC | 16702 |  |  | PP6 | MP201100 |  | Delivery | MP6LA | S185500 | 1.03 | 1.03A | FAB | UDF_G3 |  |  |  |  |
| S185600 |  | Receive, unpack, log & inspect blocks for Prepro Sectors 1-12 M&S |  | 120d | 2019-10-16 A | 2020-10-30 A | S167300 FF, S167500 FF, S167700 FF, S167900 FF, S168100 FF, S168300 FF, S168500 FF, S168700 FF, S168900 FF, S169100 FF, S169300 FF, S167400 FF, S167600 FF, S167800 FF, S168000 FF, S168200 FF, S168400 FF, S168600 FF, S168800 FF, S169000 FF, S169200 FF, S169400 FF | 100% | 2019-12-02 | 2020-05-21 |  |  | S185600 | 0 | S171200 | S171200 | NOCA | In Progress | Stoll, Sean | BNL | Fab & Assy | Craig Woody | BNL | EMCal Prepro Sectors 1-12 | POM02.1.03.02.02.02 | 02 |  | 02 | 4 |  |  |  |  |  |  |  |  |  |  |  |  |  |  |  |  |  |  |  |  |  |  |  |  |
| S185700 |  | Receive, unpack, log & inspect blocks for Prepro Sectors 1-12 Labor |  | 120d | 2019-10-21 A | 2020-10-30 A | S169300 FF, S167400 FF, S167600 FF, S167800 FF, S168000 FF, S168200 FF, S168400 FF, S168600 FF, S168800 FF, S169000 FF, S169200 FF, S169400 FF, S167300 FF, S167500 FF, S167700 FF, S167900 FF, S168100 FF, S168300 FF, S168500 FF, S168700 FF, S168900 FF, S169100 FF | 100% | 2019-12-02 | 2020-05-21 | PROF4 PO E [218 h]; TECH3 PO M [314 h] | 67,938.12 | S185700 | 0 | S171300 | S171300 | CA | In Progress | Stoll, Sean | BNL | Procurement | Craig Woody | BNL | EMCal Prepro Sectors 1-12 | POM02.1.03.02.02.02 | 02 |  | 02 | 2 |  | L4 | null | C |  |  | B | 16710 | 004 |  |  |  |  |  |  | S185700 | 1.03 | 1.03B |  |  |  |  |  | Yes |
| S185900 |  | Install reflectors on blocks for modules for Prepro Sectors 1-12 Labor |  | 120d | 2019-10-21 A | 2020-10-30 A | S185600 SS+5d, S185500, S185700 SS+5d | 100% | 2019-12-09 | 2020-05-29 | PROF4 PO E [218 h]; TECH3 PO M [339 h] | 70,791.18 | S185900 | 0 | S171500 | S171500 | CA | In Progress | Stoll, Sean | BNL | Fab & Assy | Craig Woody | BNL | EMCal Prepro Sectors 1-12 | POM02.1.03.02.02.02 | 02 |  | 02 | 4 |  | L4 | null | C |  |  | B | 16710 | 004 |  |  |  |  |  |  | S185900 | 1.03 | 1.03B |  |  |  |  |  | Yes |
| S186000 |  | Install light guides on preproduction prototype blocks Labor |  | 120d | 2020-01-09 A | 2021-01-11 A | S185900 SS+1d, S185800 SS+1d, S184800 SS+10d | 100% | 2020-03-09 | 2020-08-25 | PROF4 PO E [218 h]; TECH3 PO M [339 h] | 70,791.18 | S186000 | 0 | S171600 | S171600 | CA | Not Started | Stoll, Sean | BNL | Fab & Assy | Craig Woody | BNL | EMCal Prepro Sectors 1-12 | POM02.1.03.02.02.02 | 02 |  | 02 | 4 |  | L4 | null | C |  |  | B | 16710 | 004 |  |  |  |  |  |  | S186000 | 1.03 | 1.03B |  |  |  |  |  | Yes |
| S186200 |  | Glue blocks together into modules for modules in Sectors (Prepro) 1-12 Labor |  | 120d | 2020-02-25 A | 2021-01-11 A | S186100 SS | 100% | 2020-02-25 | 2020-08-12 | PROF4 PO E [218 h]; TECH3 PO M [339 h] | 70,791.18 | S186200 | 0 | S171800 | S171800 | CA | Not Started | Stoll, Sean | BNL | Fab & Assy | Craig Woody | BNL | EMCal Prepro Sectors 1-12 | POM02.1.03.02.02.02 | 02 |  | 02 | 4 |  | L4 | null | C | OPC001400 |  | B | 16710 | 004 |  |  |  |  |  |  | S186200 | 1.03 | 1.03B |  |  |  |  |  | Yes |
| S186100 |  | Install SiPM daughterboards on blocks for modules in Sectors (Prepro) 1-12 Labor |  | 120d | 2020-02-25 A | 2021-01-11 A | S186000 SS+5d, S221500 SS+3d, S221300 SS+5d, S221400 SS+5d, S212201 FS+3d | 100% | 2020-02-25 | 2020-08-12 | PROF4 PO E [218 h]; TECH3 PO M [339 h] | 70,791.18 | S186100 | 0 | S171700 | S171700 | CA | Not Started | Stoll, Sean | BNL | Fab & Assy | Craig Woody | BNL | EMCal Prepro Sectors 1-12 | POM02.1.03.02.02.02 | 02 |  | 02 | 4 |  | L4 | null | C |  |  | B | 16710 | 004 |  |  |  |  |  |  | S186100 | 1.03 | 1.03B |  |  |  |  |  | Yes |

Notes:
- S182300: BNL_UDF_Old Activity Name 181221: Design 2D projective blocks for preproduction prototype
- S182400: BNL_UDF_Old Activity Name 181221: Design screens for preproduction prototype blocks
- S182500: BNL_UDF_Old Activity Name 181221: Design light guides for preproduction prototype
- S182600: BNL_UDF_Old Activity Name 181221: Procure light guides for preproduction prototype sector 0 Labor
- S182700: BNL_UDF_Old Activity Name 181221: Procure light guides for preproduction prototype sector 0 M&S
- S182800: BNL_UDF_Old Activity Name 181221: Procure mechanical parts for modules for preproduction prototype sector 0 M&S FY18
- S183000: BNL_UDF_Old Activity Name 181221: Procure mechanical parts for modules for preproduction prototype sector 0 Labor FY18
- S182900: BNL_UDF_Old Activity Name 181221: Procure mechanical parts for modules for preproduction prototype sector 0 M&S FY19
- S183100: BNL_UDF_Old Activity Name 181221: Procure mechanical parts for modules for preproduction prototype sector 0 Labor FY19
- S183200: BNL_UDF_Status Comments: 190605 IVS status; 190315 ELM chg % to align with EVT 30>0, remove AS, use EF / BNL_UDF_Old Activity Name 181221: Receive, unpack, log & inspect preproduction prototype blocks sector 0 M&S
- S183300: BNL_UDF_Status Comments: 190605 IVS status / BNL_UDF_Old Activity Name 181221: Receive, unpack, log & inspect preproduction prototype blocks sector 0 Labor
- S183400: BNL_UDF_Status Comments: 190605 IVS status / BNL_UDF_Old Activity Name 181221: Install reflectors on preproduction prototype blocks sector 0 M&S
- S183500: BNL_UDF_Status Comments: 190605 IVS status / BNL_UDF_Old Activity Name 181221: Install reflectors on preproduction prototype blocks sector 0 Labor
- S183600: BNL_UDF_Status Comments: 190605 IVS status / BNL_UDF_Old Activity Name 181221: Install light guides on preproduction prototype blocks sector 0 M&S
- S183700: BNL_UDF_Status Comments: 190605 IVS status / BNL_UDF_Old Activity Name 181221: Install light guides on preproduction prototype blocks sector 0 Labor
- S184300: BNL_UDF_Adhoc Comments: 180402 ELM assigned proc values; 180227 removed resource assgnmts per GRY / BNL_UDF_Old Activity Name 181221: Procure light guides for modules in Sectors (Prepro) 1-12 & 13-64 - Prepare & Send Solicitation
- S183900: BNL_UDF_Status Comments: 190605 IVS status / BNL_UDF_Old Activity Name 181221: Install SiPMs & daughterboards on preproduction prototype blocks sector 0
- S184200: BNL_UDF_Adhoc Comments: 180402 ELM assigned proc values; 180227 removed resource assgnmts per GRY / BNL_UDF_Old Activity Name 181221: Procure light guides for modules in Sectors (Prepro) 1-12 & 13-64 - Provide Requirements to Procurement
- S184400: BNL_UDF_Adhoc Comments: 180402 ELM assigned proc values; 180227 removed resource assgnmts per GRY / BNL_UDF_Old Activity Name 181221: Procure light guides for modules in Sectors (Prepro) 1-12 & 13-64 - Vendor Responses
- S184500: BNL_UDF_Adhoc Comments: 180402 ELM assigned proc values; 180227 removed resource assgnmts per GRY / BNL_UDF_Old Activity Name 181221: Procure light guides for modules in Sectors (Prepro) 1-12 & 13-64 - Vendor Selection
- S184600: BNL_UDF_Status Comments: 190605 IVS status / BNL_UDF_Adhoc Comments: 180420 ELM pred/succ per GRY; 180402 ELM assigned proc values / BNL_UDF_Old Activity Name 181221: Procure light guides for modules in Sectors (Prepro) 1-12 & 13-64 - Contract Award - OPC Funds
- S184700: BNL_UDF_Status Comments: 190605 IVS status / BNL_UDF_Adhoc Comments: 180402 ELM assigned proc values; 180227 removed resource assgnmts per GRY / BNL_UDF_Old Activity Name 181221: Procure light guides for modules in Sectors (Prepro) 1-12 & 13-64 - Contract/PO Leadtime - OPC Funds
- S183800: BNL_UDF_Status Comments: 190415 ELM name per GRY / BNL_UDF_Old Activity Name 181221: EmCal Test Fit Blocks Sector 0
- S184000: BNL_UDF_Status Comments: 190605 IVS status / BNL_UDF_Old Activity Name 181221: Glue preproduction prototype blocks together into modules sector 0
- S184100: BNL_UDF_Status Comments: 190605 IVS status / BNL_UDF_Old Activity Name 181221: Sector 0 Module Production Complete
- S183801: BNL_UDF_Status Comments: 190522 IVS new name; 190415 ELM name per GRY / BNL_UDF_Old Activity Name 181221: EmCal Test Fit Blocks Sector 0
- S184900: BNL_UDF_Adhoc Comments: 180406 RFG filled in BNL_Cost Basis; 180402 ELM swapped labor and M&S for seq; 180227 removed resource labor units per GRY / BNL_UDF_Old Activity Name 181221: Procure mechanical parts for modules in Sectors (Prepro) 1-12 - Provide Requirements to Procurement
- S185300: BNL_UDF_Adhoc Comments: 180420 ELM pred/succ per GRY; 180402 ELM added activity for proc strg / BNL_UDF_Old Activity Name 181221: Procure mechanical parts for modules in Sectors (Prepro) 1-12 - Contract Award(s)
- S185400: BNL_UDF_Adhoc Comments: 180402 ELM added activity for proc strg / BNL_UDF_Old Activity Name 181221: Procure mechanical parts for modules in Sectors (Prepro) 1-12 - Contract/PO - Leadtime
- S185000: BNL_UDF_Adhoc Comments: 180402 ELM added activity for proc strg / BNL_UDF_Old Activity Name 181221: Procure mechanical parts for modules in Sectors (Prepro) 1-12 - Prepare & Send Solicitation
- S185200: BNL_UDF_Adhoc Comments: 180402 ELM added activity for proc strg / BNL_UDF_Old Activity Name 181221: Procure mechanical parts for modules in Sectors (Prepro) 1-12 - Vendor Selection
- S185100: BNL_UDF_Adhoc Comments: 180402 ELM added activity for proc strg / BNL_UDF_Old Activity Name 181221: Procure mechanical parts for modules in Sectors (Prepro) 1-12 - Vendor Responses
- OBLG184610: BNL_UDF_Adhoc Comments: 180420 ELM pred/succ per GRY; 180402 ELM assigned proc values / BNL_UDF_Old Activity Name 181221: Procure light guides for modules in Sectors (Prepro) 1-12 & 13-64 - Contract Award - OPC Funds
- OBLG185310: BNL_UDF_Adhoc Comments: 180420 ELM pred/succ per GRY; 180402 ELM added activity for proc strg / BNL_UDF_Old Activity Name 181221: Procure mechanical parts for modules in Sectors (Prepro) 1-12 - Contract Award(s)
- S184800: BNL_UDF_Status Comments: 190605 IVS link SS with installing / BNL_UDF_Adhoc Comments: 180402 ELM assigned proc values; 180227 removed resource assgnmts per GRY / BNL_UDF_Old Activity Name 181221: Procure light guides for modules in Sectors (Prepro) 1-12 (16) - Delivery Acceptance - OPC Funds
- S185800: BNL_UDF_Old Activity Name 181221: Install reflectors on blocks for modules for Prepro Sectors 1-12 M&S
- S185500: BNL_UDF_Adhoc Comments: 180406 RFG filled in BNL_Cost Basis; 180402 ELM swapped labor and M&S for seq; 180227 increased resource labor units per GRY / BNL_UDF_Old Activity Name 181221: Procure mechanical parts for modules in Sectors (Prepro) 1-12 - Delivery Acceptance
- S185600: BNL_UDF_Old Activity Name 181221: Receive, unpack, log & inspect blocks for Prepro Sectors 1-12 M&S
- S185700: BNL_UDF_Status Comments: 190418 ELM BLU per GRY / BNL_UDF_Adhoc Comments: 180405 ELM rsrc per GRY / BNL_UDF_Old Activity Name 181221: Receive, unpack, log & inspect blocks for Prepro Sectors 1-12 Labor
- S185900: BNL_UDF_Status Comments: 190418 ELM BLU per GRY / BNL_UDF_Adhoc Comments: 180405 ELM rsrc per GRY / BNL_UDF_Old Activity Name 181221: Install reflectors on blocks for modules for Prepro Sectors 1-12 Labor
- S186000: BNL_UDF_Status Comments: 190418 ELM BLU per GRY / BNL_UDF_Adhoc Comments: 180405 ELM rsrc per GRY / BNL_UDF_Old Activity Name 181221: Install light guides on preproduction prototype blocks Labor
- S186200: BNL_UDF_Status Comments: 190418 ELM BLU per GRY / BNL_UDF_Adhoc Comments: 180405 ELM rsrc per GRY / BNL_UDF_Old Activity Name 181221: Glue blocks together into modules for modules in Sectors (Prepro) 1-12 Labor
- S186100: BNL_UDF_Status Comments: 190418 ELM BLU per GRY / BNL_UDF_Adhoc Comments: 180410 ELM pred/succ per GRY; 180405 ELM rsrc per GRY / BNL_UDF_Old Activity Name 181221: Install SiPM daughterboards on blocks for modules in Sectors (Prepro) 1-12 Labor

| ID | WBS | Activity | Type | Duration | Start | Finish | Predecessors | Complete | Remaining | Planned start | Planned finish | Total float | Free float | Constraint | Expected finish | Resources | Cost | BNL_UDF_Temp Text 01 | BNL_UDF_Percent Complete | BNL_UDF_OPC TEC (deprecated) | BNL_UDF_Old Activity ID 181221 | BNL_Cobra WP | RG Check | BNL_Activity Status | BNL_Fund Source | BNL_Estimator | BNL_Cost Basis | BNL_Location | BNL_EDIA | BNL_CAM | BNL_Institution | BNL_OPC TEC (deprecated) | BNL_WBS | BNL_EVT | BNL_Master Control Account | BNL_Account Number | BNL_PCR ID | BNL_Cobra Control Account | BNL_WBS_Hierarchical | PMP Summary Part1 | PMP Summary Part2 | BNL_Proc Sig Phase | BNL_Proc Sig | BNL_Milestone Level | BNL_R&D FY18-19 | SPH Proc Register | BNL_UDF_Exclude | BNL_Obligation | Indicator - Procurement | Indicator - Float | BNL_UDF_Remaining Tot Cost | BNL_UDF_Percent_remaining | Additional EVT documentation required | BNL_DOE OPC | Completed | BNL_UDF_Temp Date 01 | BNL_LLPs and Precursors | BNL_Split Activity |
| --- | --- | --- | --- | --- | --- | --- | --- | --- | --- | --- | --- | --- | --- | --- | --- | --- | --- | --- | --- | --- | --- | --- | --- | --- | --- | --- | --- | --- | --- | --- | --- | --- | --- | --- | --- | --- | --- | --- | --- | --- | --- | --- | --- | --- | --- | --- | --- | --- | --- | --- | --- | --- | --- | --- | --- | --- | --- | --- |
|  | 03 | **EMCAL Final Module Fabrication** |  |  | 2020-03-24 | 2022-02-03 |  |  |  |  |  |  |  |  |  |  |  |  |  |  |  |  |  |  |  |  |  |  |  |  |  |  |  |  |  |  |  |  |  |  |  |  |  |  |  |  |  |  |  |  |  |  |  |  |  |  |  |  |
| S186300 |  | Revise module production procedure based on module production for Prepro Sectors 1-12 |  | 10d | 2020-03-24 A | 2020-06-30 A | S194200 SS | 100% |  | 2020-05-14 | 2020-05-28 |  |  |  |  | PROF4 PO M [144 h] | 21,206.16 | S186300 | 0 | S171900 | S171900 | S186300 | CA | Not Started | B | Stoll, Sean | L3 | BNL | Fab & Assy | Craig Woody | BNL | null | POM02.1.03.02.02.03 | A | 1.03 | 16710 | 003 | 1.03B | 03 | 02 | 5 |  |  |  |  |  |  |  |  |  |  |  |  |  |  |  |  |  |
| S186500 |  | Procure EMCAL Mechanical Parts for Final Modules Sectors 13-64 - Provide Requirements to Procurement |  | 5d | 2020-04-14 A | 2020-05-29 A | S186300, S186400 | 100% |  | 2020-05-14 | 2020-05-21 |  |  |  |  | TECH3 PO D [56 h] | 6,390.84 | S186500 | 0 | S172100 | S172100 | S186500 | CA | Not Started | B | Stoll, Sean | L2 | BNL | Procurement | Craig Woody | BNL | null | POM02.1.03.02.02.03 | C | 1.03 | 16710 |  | 1.03B | 03 | 02 | 3 | PP1 | MP103600 |  |  |  |  |  |  |  |  |  |  |  |  |  |  |  |
| S186600 |  | Procure EMCAL Mechanical Parts for Final Modules Sectors 13-64 - Prepare & Send Solicitation |  | 30d | 2020-04-14 A | 2020-05-29 A | S186500 | 100% |  | 2020-05-21 | 2020-07-06 |  |  |  |  |  |  | S186600 | 0 | S172200 | S172200 |  | NOCA | Not Started |  | Stoll, Sean |  | BNL | Procurement | Craig Woody | BNL |  | POM02.1.03.02.02.03 |  |  |  |  |  | 03 | 02 | 3 | PP2 | MP103600 |  |  |  |  |  |  |  |  |  |  |  |  |  |  |  |
| S187200 |  | Procure light guides for modules in Sectors 13-64 - Contract Award | milestone | 0d | 2020-04-20 A | 2020-04-20 A | S186300, S186400, S185200 | 100% |  | 2020-05-14 | 2020-05-14 |  |  |  |  |  |  | S187200 | 0 | S170500 | S172710 |  | NOCA | Not Started | A-TEC | Stoll, Sean |  | BNL | Procurement | Craig Woody | BNL |  | POM02.1.03.02.02.03 |  |  |  |  |  | 03 | 02 | 3 | PP5 | MP200701 | L5 | EMCal Prepro Sectors 1-12 | Contract Award |  |  |  |  |  |  |  |  |  |  |  |  |
| S186700 |  | Procure EMCAL Mechanical Parts for Final Modules Sectors 13-64 - Vendor Responses |  | 10d | 2020-05-20 A | 2020-05-29 A | S186600 | 100% |  | 2020-07-07 | 2020-07-20 |  |  |  |  |  |  | S186700 | 0 | S172300 | S172300 |  | NOCA | Not Started |  | Stoll, Sean |  | BNL | Procurement | Craig Woody | BNL |  | POM02.1.03.02.02.03 |  |  |  |  |  | 03 | 02 | 3 | PP3 | MP103600 |  |  |  |  |  |  |  |  |  |  |  |  |  |  |  |
| S187300 |  | Procure light guides for modules in Sectors 13-64 - Contract/PO Leadtime |  | 100d | 2020-06-01 A | 2020-12-30 A | S187200 SS, OBLG187210 SS | 100% |  | 2020-07-09 | 2020-12-02 |  |  |  |  |  |  | S187300 | 0 | S170600 | S172720 |  | NOCA | Not Started | A-TEC | Stoll, Sean |  | BNL | Fab & Assy | Craig Woody | BNL |  | POM02.1.03.02.02.03 |  |  |  |  |  | 03 | 02 | 5 | PP6 | MP200701 |  | EMCal Prepro Sectors 1-12 |  | MP6LA |  |  |  |  |  |  |  |  |  |  |  |
| S186800 |  | Procure EMCAL Mechanical Parts for Final Modules Sectors 13-64 - Vendor Selection |  | 20d | 2020-06-10 A | 2020-06-17 A | S186700 | 100% |  | 2020-08-10 | 2020-09-04 |  |  |  |  |  |  | S186800 | 0 | S172400 | S172400 |  | NOCA | Not Started |  | Stoll, Sean |  | BNL | Procurement | Craig Woody | BNL |  | POM02.1.03.02.02.03 |  |  |  |  |  | 03 | 02 | 3 | PP4 | MP103600 |  |  |  |  |  |  |  |  |  |  |  |  |  |  |  |
| OBLG186910 |  | Procure EMCAL Mechanical Parts for Final Modules Sectors 13-64 - Obligation |  | 1d | 2020-06-23 A | 2020-06-30 A | S186800, S101000 | 100% |  | 2020-08-10 | 2020-08-10 |  |  |  |  | Obligation Resource [59945.9 h] | 59,945.93 | S186900 | 0 | S172500 | S172500 |  |  | Not Started | A-TEC | Stoll, Sean |  | BNL | Procurement | Craig Woody | BNL |  | POM02.1.03.02.02.03 |  |  |  |  |  | 03 |  |  | PP5 | MP103600 | L5 |  |  |  | OBLG |  |  |  |  |  |  |  |  |  |  |
| S187000 |  | Procure EMCAL Mechanical Parts for Final Modules Sectors 13-64 - Contract/PO - Leadtime |  | 20d | 2020-06-24 A | 2020-11-30 A | S186900 SS, OBLG186910 SS | 100% |  | 2020-08-10 | 2020-09-04 |  |  |  |  |  |  | S187000 | 0 | S172600 | S172600 |  | NOCA | Not Started |  | Stoll, Sean |  | BNL | Fab & Assy | Craig Woody | BNL |  | POM02.1.03.02.02.03 |  |  |  |  |  | 03 | 02 | 5 | PP6 | MP103600 |  |  |  |  |  |  |  |  |  |  |  |  |  |  |  |
| S186900 |  | Procure EMCAL Mechanical Parts for Final Modules Sectors 13-64 - Contract Award(s) | milestone | 0d | 2020-06-30 A | 2020-06-30 A | S186800, S101000 | 100% |  | 2020-09-08 | 2020-09-08 |  |  |  |  |  |  | S186900 | 0 | S172500 | S172500 |  | NOCA | Not Started | A-TEC | Stoll, Sean |  | BNL | Procurement | Craig Woody | BNL |  | POM02.1.03.02.02.03 |  |  |  |  |  | 03 | 02 | 3 | PP5 | MP103600 | L5 |  | Contract Award |  |  | UDF_G2 | UDF_G1 |  |  |  |  |  |  |  |  |
| S186400 |  | Production Readiness Review - EMCal Modules for Sectors 13-64 |  | 5d | 2020-07-27 A | 2020-07-29 A | S194200 SS+10d | 100% |  | 2020-09-02 | 2020-09-09 |  |  |  |  | PROF4 PO E [80 h]; SCI3 PO PM [120 h]; SCI 4 PO [160 h] | 65,379.07 | S186400 | 0 | S172000 | S172000 | S186400 | CA | Not Started | B | Stoll, Sean | L2 | BNL | Fab & Assy | Craig Woody | BNL | null | POM02.1.03.02.02.03 | A | 1.03 | 16710 | 003,004 | 1.03B | 03 | 02 | 5 |  |  |  |  |  |  |  |  |  |  |  |  |  |  |  |  |  |
| OBLG187210 |  | Procure light guides for modules in Sectors 13-64 - Obligation |  | 1d | 2020-10-15 A | 2020-11-02 A | S186300, S186400, S185200 | 100% |  | 2020-11-02 | 2020-11-02 |  |  |  |  | Obligation Resource [244932 h] | 244,931.7 | S187200 | 0 | S170500 | S172710 |  |  | Not Started | A-TEC | Stoll, Sean |  | BNL | Procurement | Craig Woody | BNL |  | POM02.1.03.02.02.03 |  |  |  |  |  | 03 |  |  | PP5 | MP200701 | L5 | EMCal Prepro Sectors 1-12 |  |  | OBLG |  |  |  |  |  |  |  |  |  |  |
| S187100 |  | Procure EMCAL Mechanical Parts for Final Modules Sectors 13-64 - Delivery Acceptance |  | 5d | 2020-10-15 A | 2020-11-30 A | S187000 | 100% |  | 2020-12-15 | 2020-12-21 |  |  | start on or after 2020-12-15 |  | Material (Purchase (1st $2M) [52680 h] | 61,144.85 | S187100 | 0 | S172700 | S172700 | S187100 | CA | Not Started | A-TEC | Stoll, Sean | M4 | BNL | Fab & Assy | Craig Woody | BNL | TEC | POM02.1.03.02.02.03 | C | 1.03 | 59709 | 015 | 1.03A | 03 | 02 | 5 | PP6 | MP103600 |  |  | Delivery |  | FAB | UDF_G1 | UDF_G3 | 59945.930617 | 1 |  |  |  |  |  |  |
| S187500 |  | Receive, unpack, log & inspect final blocks |  | 266d | 2020-11-23 A | 2022-01-31 | S178900 FF, S179000 FF, S176010 FF | 42% | 166d | 2020-12-09 | 2022-01-03 | 0d |  |  | 2022-01-31 | PROF4 PO E [462 h]; TECH3 PO M [922 h] | 179,682.47 | S187500 | 0 | S173700 | S173700 | S187500 | CA | Not Started | B | Stoll, Sean | L4 | BNL | Fab & Assy | Craig Woody | BNL | null | POM02.1.03.02.02.03 | C | 1.03 | 16710 | 004 | 1.03B | 03 | 02 | 5 |  |  |  |  |  |  |  |  |  |  |  | Yes |  |  |  |  |  |
| S187800 |  | Install reflectors on final blocks Labor |  | 266d | 2020-11-23 A | 2022-01-31 | S187600 SS+1d, S186900 SS+10d, S187500 FF | 31% | 166d | 2020-12-11 | 2022-01-05 | 0d |  |  | 2022-01-31 | PROF4 PO E [462 h]; TECH3 PO M [922 h] | 179,722.73 | S187800 | 0 | S173900 | S173900 | S187800 | CA | Not Started | B | Stoll, Sean | L4 | BNL | Fab & Assy | Craig Woody | BNL | null | POM02.1.03.02.02.03 | C | 1.03 | 16710 | 004 | 1.03B | 03 | 02 | 5 |  |  |  |  |  |  |  |  |  |  |  | Yes |  |  |  |  |  |
| S187900 |  | Install reflectors on final blocks M&S |  | 266d | 2020-11-23 A | 2022-01-31 | S187700 SS+1d, S186900 SS+10d, S187500 FF | 31% | 166d | 2020-12-11 | 2022-01-05 | 0d |  |  | 2022-01-31 |  |  | S187900 | 0 | S173800 | S173800 |  | NOCA | Not Started |  | Stoll, Sean |  | BNL | Fab & Assy | Craig Woody | BNL |  | POM02.1.03.02.02.03 |  |  |  |  |  | 03 | 02 | 5 |  |  |  |  |  |  |  |  |  |  |  |  |  |  |  |  |  |
| S187400 |  | Procure light guides for modules in Sectors 13-64 - Delivery Acceptance |  | 41d | 2020-12-22 A | 2021-06-02 | S187300 | 69% | 2d | 2021-01-12 | 2021-03-11 | 164d | 0d |  | 2021-06-02 | Material (Purchase (1st $2M) [215244 h] | 240,129.12 | S187400 | 0 | S170700 | S172730 | S187400 | CA | Not Started | A-TEC | Stoll, Sean | M3 | BNL | Fab & Assy | Craig Woody | BNL | OPC | POM02.1.03.02.02.03 | C | 1.03 | 59709 | 014 | 1.03A | 03 | 02 | 5 | PP6 | MP200701 |  | EMCal Prepro Sectors 1-12 | Delivery | MP6LA | FAB | UDF_G1 | UDF_G3 | 249830.333622 | 1 |  | OPC001400 |  |  |  |  |
| S187600 |  | Install light guides on final blocks Labor |  | 250d | 2021-01-21 A | 2022-01-31 | S187500 SS+1d, S187300 SS+60d | 28% | 166d | 2021-01-21 | 2022-01-20 | 0d |  |  | 2022-01-31 | PROF4 PO E [462 h]; TECH3 PO M [922 h] | 180,018.02 | S187600 | 0 | S174100 | S174100 | S187600 | CA | Not Started | B | Stoll, Sean | L4 | BNL | Fab & Assy | Craig Woody | BNL | null | POM02.1.03.02.02.03 | C | 1.03 | 16710 | 004 | 1.03B | 03 | 02 | 5 |  |  |  |  |  |  |  |  |  |  |  | Yes |  |  |  |  |  |
| S187700 |  | Install light guides on final blocks M&S |  | 250d | 2021-01-21 A | 2022-01-31 | S187500 SS+1d, S187400 FF, S187100 FF | 28% | 166d | 2021-01-21 | 2022-01-20 | 0d |  |  | 2022-01-31 | Material (Purchase (1st $2M) [1650 h] | 1,926.31 | S187700 | 0 | S174000 | S174000 | S187700 | CA | Not Started | A-TEC | Stoll, Sean | M3 | BNL | Fab & Assy | Craig Woody | BNL | TEC | POM02.1.03.02.02.03 | C | 1.03 | 59709 |  | 1.03A | 03 | 02 | 5 |  |  |  |  |  |  |  | UDF_G1 | UDF_G1 | 1913.471279 | 1 | Yes |  |  |  |  |  |
| S188000 |  | Install SiPMs daughterboards on final blocks Labor |  | 250d | 2021-01-22 A | 2022-02-03 | S227510, S228200 FF, S228300 FF, S228400 FF, S228100 FF+1d, S228600 FF, S187700 SS+1d, S187600 SS+1d, S228450 FF, S228500 FF, S228110 FF+1d, S228190 | 27% | 169d | 2021-01-22 | 2022-01-21 | 0d |  |  | 2022-02-03 | PROF4 PO E [462 h]; TECH3 PO M [922 h] | 180,039.44 | S188000 | 0 | S174300 | S174300 | S188000 | CA | Not Started | B | Stoll, Sean | L4 | BNL | Fab & Assy | Craig Woody | BNL | null | POM02.1.03.02.02.03 | C | 1.03 | 16710 | 004 | 1.03B | 03 | 02 | 5 |  |  |  |  |  |  |  |  |  |  |  | Yes |  |  |  |  |  |
| S188100 |  | Install SiPMs daughterboards on final blocks M&S |  | 250d | 2021-01-22 A | 2022-02-03 | S228100 FF+1d, S187600 SS+1d, S187700 SS+1d, S228110 FF+1d, S228190 | 27% | 169d | 2021-01-22 | 2022-01-21 | 0d |  |  | 2022-02-03 | Material (Purchase (1st $2M) [300 h] | 350.27 | S188100 | 0 | S174200 | S174200 | S188100 | CA | Not Started | A-TEC | Stoll, Sean | M3 | BNL | Fab & Assy | Craig Woody | BNL | TEC | POM02.1.03.02.02.03 | C | 1.03 | 59709 |  | 1.03A | 03 | 02 | 5 |  |  |  |  |  |  |  | UDF_G1 | UDF_G1 | 348.006029 | 1 | Yes |  |  |  |  |  |
| S188200 |  | Glue final blocks together into modules |  | 250d | 2021-01-22 A | 2022-02-03 | S188000 SS, S188100 SS, S187900 SS, S187800 SS | 27% | 169d | 2021-01-22 | 2022-01-21 | 0d |  |  | 2022-02-03 | PROF4 PO E [462 h]; TECH3 PO M [922 h] | 180,039.44 | S188200 | 0 | S174400 | S174400 | S188200 | CA | Not Started | B | Stoll, Sean | L4 | BNL | Fab & Assy | Craig Woody | BNL | null | POM02.1.03.02.02.03 | C | 1.03 | 16710 | 004 | 1.03B | 03 | 02 | 3 |  |  |  |  |  |  |  |  |  |  |  | Yes |  |  |  |  |  |
|  | 03 | **EMCAL Sector Assembly** |  |  | 2017-04-27 | 2022-02-04 |  |  |  |  |  |  |  |  |  |  |  |  |  |  |  |  |  |  |  |  |  |  |  |  |  |  |  |  |  |  |  |  |  |  |  |  |  |  |  |  |  |  |  |  |  |  |  |  |  |  |  |  |
|  | 01 | **EMCAL Prototype v2.1 Sector Assembly** |  |  | 2017-04-27 | 2018-09-28 |  |  |  |  |  |  |  |  |  |  |  |  |  |  |  |  |  |  |  |  |  |  |  |  |  |  |  |  |  |  |  |  |  |  |  |  |  |  |  |  |  |  |  |  |  |  |  |  |  |  |  |  |
| S188300 |  | Design cooling system for V2.1 prototype |  | 30d | 2017-04-27 A | 2017-06-08 A | S100090 SS+60d | 100% |  |  |  |  |  |  |  |  |  | S188300 | 100 | S174500 | S174500 |  | NOCA | Completed |  | Stoll, Sean |  | BNL | Design | Craig Woody | BNL |  | POM02.1.03.02.03.01 |  |  |  |  |  | 01 | 1 | 1 |  |  |  | EMCal v2.1 |  |  |  |  |  |  |  |  |  | yes |  |  |  |
| S188400 |  | Procure parts for cooling system for V2.1 prototype Labor |  | 110d | 2017-06-09 A | 2017-11-15 A | S188300 | 100% |  |  |  |  |  |  |  |  |  | S188400 | 100 | S174600 | S174600 |  | NOCA | Completed |  | Stoll, Sean |  | BNL | Procurement | Craig Woody | BNL |  | POM02.1.03.02.03.01 |  |  |  |  |  | 01 | 02 | 2 |  |  |  | EMCal v2.1 |  |  |  |  |  |  |  |  |  | yes |  |  |  |
| S188800 |  | Procure parts for cooling system for V2.1 prototype M&S |  | 110d | 2017-06-09 A | 2017-11-15 A | S188300 | 100% |  |  |  |  |  |  |  |  |  | S188800 | 100 | S175600 | S174950 |  | NOCA | Completed |  | Stoll, Sean |  | BNL | Fab & Assy | Craig Woody | BNL |  | POM02.1.03.02.03.01 |  |  |  |  |  | 01 | 02 | 4 |  |  |  | EMCal v2.1 |  |  |  |  |  |  |  |  |  | yes |  |  |  |
| S188500 |  | Prepare mounting supports for V2.1 prototype |  | 3d | 2017-10-12 A | 2017-10-16 A | S181200, S181900 | 100% |  |  |  |  |  |  |  |  |  | S188500 | 100 | S174700 | S174700 |  | NOCA | Completed |  | Stoll, Sean |  | BNL | Fab & Assy | Craig Woody | BNL |  | POM02.1.03.02.03.01 |  |  |  |  |  | 01 | 02 | 4 |  |  |  | EMCal v2.1 |  |  |  |  |  |  |  |  |  | yes |  |  |  |
| S188600 |  | Install blocks in v2.1 prototype |  | 2d | 2017-12-19 A | 2017-12-20 A | S181700, S188500, S182201 | 100% |  |  |  |  |  |  |  |  |  | S188600 | 100 | S174800 | S174800 |  | NOCA | Completed |  | Stoll, Sean |  | BNL | Fab & Assy | Craig Woody | BNL |  | POM02.1.03.02.03.01 |  |  |  |  |  | 01 | 02 | 4 |  |  |  | EMCal v2.1 |  |  |  |  |  |  |  |  |  | yes |  |  |  |
| S188700 |  | Install readout electronics on v2.1 prototype |  | 0d | 2017-12-21 A | 2017-12-21 A | S188600 | 100% |  |  |  |  |  |  |  |  |  | S188700 | 100 | S174900 | S174900 |  | NOCA | Completed |  | Stoll, Sean |  | BNL | Fab & Assy | Craig Woody | BNL |  | POM02.1.03.02.03.01 |  |  |  |  |  | 01 | 02 | 4 |  |  |  | EMCal v2.1 |  |  |  |  |  |  |  |  |  | yes |  |  |  |
| S188900 |  | Install cooling system on v2.1 prototype |  | 5d | 2017-12-22 A | 2017-12-29 A | S188300, S188400, S188700, S188800 | 100% |  |  |  |  |  |  |  |  |  | S188900 | 100 | S175000 | S175000 |  | NOCA | Completed |  | Stoll, Sean |  | BNL | Fab & Assy | Craig Woody | BNL |  | POM02.1.03.02.03.01 |  |  |  |  |  | 01 | 02 | 4 |  |  |  | EMCal v2.1 |  |  |  |  |  |  |  |  |  | yes |  |  |  |
| S189000 |  | Test v2.1 prototype with LEDs & cosmic rays |  | 31d | 2018-01-02 A | 2018-02-14 A | S188900 | 100% |  |  |  |  |  |  |  |  |  | S189000 | 100 | S175100 | S175100 |  | NOCA | Completed |  | Stoll, Sean | L1 | BNL | Test_Components | Craig Woody | BNL | null | POM02.1.03.02.03.01 | C |  |  |  |  | 01 | 02 | 7 |  |  |  | EMCal v2.1 |  |  |  |  |  |  |  |  |  | yes | 2018-03-14 | Pre-1 |  |
| S189100 |  | Pack & ship v2.1 prototype to Fermilab Labor |  | 0d | 2018-02-14 A | 2018-02-14 A | S189000 | 100% |  |  |  |  |  |  |  |  |  | S189100 | 100 | S175200 | S175200 |  | NOCA | Completed |  | Stoll, Sean | L1 | BNL | Fab & Assy | Craig Woody | BNL | null | POM02.1.03.02.03.01 | C |  |  |  |  | 01 | 02 | 4 |  |  |  | EMCal v2.1 |  |  |  |  |  |  |  |  |  | yes |  | Pre-1 |  |
| S189200 |  | Pack & ship v2.1 prototype to Fermilab M&S |  | 0d | 2018-02-14 A | 2018-02-14 A | S189000, S189100 SS | 100% |  |  |  |  |  |  |  |  |  | S189200 | 100 | S175700 | S175250 |  | NOCA | Completed |  | Stoll, Sean | M1 | BNL | Fab & Assy | Craig Woody | BNL | OPC | POM02.1.03.02.03.01 | C |  |  |  |  | 01 | 02 | 4 |  |  |  | EMCal v2.1 |  |  |  |  |  |  |  |  |  | yes |  | Pre-1 |  |
| S189300 |  | Test v2.1 prototype in test beam at Fermilab Labor |  | 64d | 2018-02-21 A | 2018-05-21 A | S189100 | 100% |  |  |  |  |  |  |  |  |  | S189300 | 100 | S175300 | S175300 |  | NOCA | Completed |  | Stoll, Sean | L2 | BNL | Test_System | Craig Woody | BNL | null | POM02.1.03.02.03.01 | C |  |  |  |  | 01 | 02 | 7 |  |  |  | EMCal v2.1 |  |  |  |  |  |  |  |  |  | yes |  | Pre-1 |  |
| S189400 |  | Test v2.1 prototype in test beam at Fermilab M&S |  | 64d | 2018-02-21 A | 2018-05-21 A | S189200, S189300 SS | 100% |  |  |  |  |  |  |  |  |  | S189400 | 100 | S175800 | S175350 |  | NOCA | Completed |  | Stoll, Sean | M1 | BNL | Fab & Assy | Craig Woody | BNL | OPC | POM02.1.03.02.03.01 | C |  |  |  |  | 01 | 02 | 4 |  |  |  | EMCal v2.1 |  |  |  |  |  |  |  |  |  | yes |  | Pre-1 |  |
| S189500 |  | Analyze test beam results from v2.1 prototype FY18 |  | 91d | 2018-05-22 A | 2018-09-28 A | S189300 SS+10d, S189400 SS+10d | 100% |  |  |  |  |  |  |  |  |  | S189500 | 100 | S175400 | S175400 |  | NOCA | Completed |  | Stoll, Sean | L3 | BNL | Test_System | Craig Woody | BNL | null | POM02.1.03.02.03.01 |  |  |  |  |  | 01 | 02 | 7 |  |  |  | EMCal v2.1 |  |  |  |  |  |  |  |  |  | yes |  |  | FY18 |
| S189600 |  | Completion of v2.1 prototype | milestone | 0d | 2018-09-28 A | 2018-09-28 A | S189500 FF | 100% |  |  |  |  |  |  |  |  |  | S189600 | 100 | S175500 | S175500 |  | NOCA | Completed |  | Stoll, Sean |  | BNL | Fab & Assy | Craig Woody | BNL |  | POM02.1.03.02.03.01 |  |  |  |  |  | 01 | 02 | 4 |  |  | L4 | EMCal v2.1 |  |  |  |  |  |  |  |  |  | yes |  |  |  |

Notes:
- S186300: BNL_UDF_Status Comments: 190315 DurType to align with EVT / BNL_UDF_Old Activity Name 181221: Revise module production procedure based on module production for Prepro Sectors 1-12
- S186500: BNL_UDF_Adhoc Comments: 180330 ELM pred per GRY / BNL_UDF_Old Activity Name 181221: Procure EMCAL Mechanical Parts for Final Modules Sectors 13-64 - Provide Requirements to Procurement
- S186600: BNL_UDF_Old Activity Name 181221: Procure EMCAL Mechanical Parts for Final Modules Sectors 13-64 - Prepare & Send Solicitation
- S187200: BNL_UDF_Adhoc Comments: 180420 ELM pred/succ per GRY; 180402 ELM assigned proc values / BNL_UDF_Old Activity Name 181221: Procure light guides for modules in Sectors 13-64 - Contract Award - TEC Funds
- S186700: BNL_UDF_Old Activity Name 181221: Procure EMCAL Mechanical Parts for Final Modules Sectors 13-64 - Vendor Responses
- S187300: BNL_UDF_Adhoc Comments: 180402 ELM assigned proc values; 180227 removed resource assgnmts per GRY / BNL_UDF_Old Activity Name 181221: Procure light guides for modules in Sectors 13-64 - Contract/PO Leadtime - TEC Funds
- S186800: BNL_UDF_Old Activity Name 181221: Procure EMCAL Mechanical Parts for Final Modules Sectors 13-64 - Vendor Selection
- OBLG186910: BNL_UDF_Adhoc Comments: 180330 ELM pred per GRY / BNL_UDF_Old Activity Name 181221: Procure EMCAL Mechanical Parts for Final Modules Sectors 13-64 - Contract Award(s)
- S187000: BNL_UDF_Old Activity Name 181221: Procure EMCAL Mechanical Parts for Final Modules Sectors 13-64 - Contract/PO - Leadtime
- S186900: BNL_UDF_Adhoc Comments: 180330 ELM pred per GRY / BNL_UDF_Old Activity Name 181221: Procure EMCAL Mechanical Parts for Final Modules Sectors 13-64 - Contract Award(s)
- S186400: General Comments: 180420 GYoung: concerning Production Readiness / Review - for Modules, also links back thru epoxy / above / BNL_UDF_Status Comments: 190522 IVS new name; 190415 ELM name per GRY; 19315 DurType to align with EVT / BNL_UDF_Adhoc Comments: 180330 ELM pred per GRY / BNL_UDF_Old Activity Name 181221: Readiness Review for final module production
- OBLG187210: BNL_UDF_Adhoc Comments: 180420 ELM pred/succ per GRY; 180402 ELM assigned proc values / BNL_UDF_Old Activity Name 181221: Procure light guides for modules in Sectors 13-64 - Contract Award - TEC Funds
- S187100: BNL_UDF_Adhoc Comments: 180410 ELM pred/succ per GRY; 180330 ELM pred per GRY / BNL_UDF_Old Activity Name 181221: Procure EMCAL Mechanical Parts for Final Modules Sectors 13-64 - Delivery Acceptance
- S187500: BNL_UDF_Status Comments: 190418 ELM BLU per GRY / BNL_UDF_Adhoc Comments: 180405 ELM rsrc per GRY / BNL_UDF_Old Activity Name 181221: Receive, unpack, log & inspect final blocks
- S187800: BNL_UDF_Status Comments: 190614 ELM rel, dur per GRY; 190418 ELM BLU per GRY / BNL_UDF_Adhoc Comments: 180416 ELM pred/succ per GRY; 180405 ELM rsrc per GRY / BNL_UDF_Old Activity Name 181221: Install reflectors on final blocks Labor
- S187900: BNL_UDF_Status Comments: 190614 ELM rel, dur per GRY / BNL_UDF_Adhoc Comments: 180416 ELM pred/succ per GRY / BNL_UDF_Old Activity Name 181221: Install reflectors on final blocks M&S
- S187400: BNL_UDF_Adhoc Comments: 180402 ELM assigned proc values; 180227 removed resource assgnmts per GRY / BNL_UDF_Old Activity Name 181221: Procure light guides for modules in Sectors 13-64 - Delivery Acceptance - TEC Funds
- S187600: BNL_UDF_Status Comments: 190614 ELM rel, dur per GRY; 190418 ELM BLU per GRY / BNL_UDF_Adhoc Comments: 180416 ELM pred/succ per GRY; 180405 ELM rsrc per GRY / BNL_UDF_Old Activity Name 181221: Install light guides on final blocks Labor
- S187700: BNL_UDF_Status Comments: 190614 ELM rel, dur per GRY / BNL_UDF_Adhoc Comments: 180416 ELM pred/succ per GRY / BNL_UDF_Old Activity Name 181221: Install light guides on final blocks M&S
- S188000: BNL_UDF_Status Comments: 190614 ELM rel, dur per GRY; 190418 ELM BLU per GRY / BNL_UDF_Adhoc Comments: 180416 ELM pred/succ per GRY; 180405 ELM rsrc per GRY / BNL_UDF_Old Activity Name 181221: Install SiPMs daughterboards on final blocks Labor
- S188100: BNL_UDF_Status Comments: 190614 ELM rel, dur per GRY / BNL_UDF_Adhoc Comments: 180416 ELM pred/succ per GRY / BNL_UDF_Old Activity Name 181221: Install SiPMs daughterboards on final blocks M&S
- S188200: BNL_UDF_Status Comments: 190614 ELM dur per GRY; 190418 ELM BLU per GRY / BNL_UDF_Adhoc Comments: 180416 ELM pred/succ per GRY; 180405 ELM rsrc per GRY / BNL_UDF_Old Activity Name 181221: Glue final blocks together into modules
- S188300: BNL_UDF_Old Activity Name 181221: Design cooling system for V2.1 prototype
- S188400: BNL_UDF_Old Activity Name 181221: Procure parts for cooling system for V2.1 prototype Labor
- S188800: BNL_UDF_Old Activity Name 181221: Procure parts for cooling system for V2.1 prototype M&S
- S188500: BNL_UDF_Old Activity Name 181221: Prepare mounting supports for V2.1 prototype
- S188600: BNL_UDF_Old Activity Name 181221: Install blocks in v2.1 prototype
- S188700: BNL_UDF_Old Activity Name 181221: Install readout electronics on v2.1 prototype
- S188900: BNL_UDF_Old Activity Name 181221: Install cooling system on v2.1 prototype
- S189000: BNL_UDF_Old Activity Name 181221: Test v2.1 prototype with LEDs & cosmic rays
- S189100: BNL_UDF_Adhoc Comments: 180413 ELM status, pred/succ per GRY / BNL_UDF_Old Activity Name 181221: Pack & ship v2.1 prototype to Fermilab Labor
- S189200: BNL_UDF_Adhoc Comments: 180413 ELM status per GRY / BNL_UDF_Old Activity Name 181221: Pack & ship v2.1 prototype to Fermilab M&S
- S189300: BNL_UDF_Adhoc Comments: 180413 ELM status, pred/succ per GRY / BNL_UDF_Old Activity Name 181221: Test v2.1 prototype in test beam at Fermilab Labor
- S189400: BNL_UDF_Adhoc Comments: 180413 ELM status per GRY / BNL_UDF_Old Activity Name 181221: Test v2.1 prototype in test beam at Fermilab M&S
- S189500: BNL_UDF_Adhoc Comments: 180413 ELM status, dur, pred/succ per GRY / BNL_UDF_Old Activity Name 181221: Analyze test beam results from v2.1 prototype FY18
- S189600: BNL_UDF_Old Activity Name 181221: Completion of v2.1 prototype

| ID | WBS | Activity | Type | Duration | Start | Finish | Predecessors | Complete | Planned start | Planned finish | Constraint | Resources | Cost | BNL_UDF_Temp Text 01 | BNL_UDF_Percent Complete | BNL_UDF_OPC TEC (deprecated) | BNL_UDF_Temp Date 01 | BNL_UDF_Old Activity ID 181221 | RG Check | BNL_Activity Status | BNL_Estimator | BNL_Cost Basis | BNL_Location | BNL_EDIA | BNL_CAM | BNL_Institution | BNL_R&D FY18-19 | BNL_OPC TEC (deprecated) | BNL_WBS | BNL_EVT | BNL_WBS_Hierarchical | Completed | PMP Summary Part1 | PMP Summary Part2 | BNL_PCR ID | BNL_Milestone Level | BNL_DOE OPC | BNL_Split Activity | BNL_Fund Source | BNL_Account Number | Cost = Awarded Proc or Mgmt | BNL_Cobra WP | BNL_Master Control Account | BNL_Cobra Control Account | Indicator - Procurement | Temp | BNL_Proc Sig Phase | BNL_Proc Sig | BNL_Obligation | SPH Proc Register | Indicator - Float | BNL_UDF_Remaining Tot Cost | BNL_UDF_Percent_remaining | Target Milestone Date | Variance | PMP Milestones | Additional EVT documentation required |
| --- | --- | --- | --- | --- | --- | --- | --- | --- | --- | --- | --- | --- | --- | --- | --- | --- | --- | --- | --- | --- | --- | --- | --- | --- | --- | --- | --- | --- | --- | --- | --- | --- | --- | --- | --- | --- | --- | --- | --- | --- | --- | --- | --- | --- | --- | --- | --- | --- | --- | --- | --- | --- | --- | --- | --- | --- | --- |
|  | 02 | **EMCAL Preproduction Sector Assembly and Testing** |  |  | 2018-01-02 | 2021-04-05 |  |  |  |  |  |  |  |  |  |  |  |  |  |  |  |  |  |  |  |  |  |  |  |  |  |  |  |  |  |  |  |  |  |  |  |  |  |  |  |  |  |  |  |  |  |  |  |  |  |  |  |
| S189700 |  | Design mechanical enclosure for preproduction prototype Sector 0 |  | 132d | 2018-01-02 A | 2018-07-10 A | S188900 | 100% |  |  |  |  |  | S189700 | 100 | S175900 | 2018-03-28 | S175900 | NOCA | Completed | Stoll, Sean | L1 | BNL | Fab & Assy | Craig Woody | BNL | EMCal Prepro Sector | null | POM02.1.03.02.03.02 | C | 02 | yes | 02 | 4 |  |  |  |  |  |  |  |  |  |  |  |  |  |  |  |  |  |  |  |  |  |  |  |
| S189800 |  | Design mechanical support structure for preproduction prototype Sector 0 |  | 132d | 2018-01-02 A | 2018-07-10 A | S188900 | 100% |  |  |  |  |  | S189800 | 100 | S176000 | 2018-03-28 | S176000 | NOCA | Completed | Stoll, Sean | L1 | BNL | Design | Craig Woody | BNL | EMCal Prepro Sector | null | POM02.1.03.02.03.02 | C | 02 | yes | 1 | 1 |  |  |  |  |  |  |  |  |  |  |  |  |  |  |  |  |  |  |  |  |  |  |  |
| S189900 |  | Design cooling system for preproduction prototype Sector 0 |  | 132d | 2018-01-02 A | 2018-07-10 A | S188900 | 100% |  |  |  |  |  | S189900 | 100 | S176100 | 2018-03-28 | S176100 | NOCA | Completed | Stoll, Sean | L3 | BNL | Design | Craig Woody | BNL | EMCal Prepro Sector | null | POM02.1.03.02.03.02 | C | 02 | yes | 1 | 1 |  |  |  |  |  |  |  |  |  |  |  |  |  |  |  |  |  |  |  |  |  |  |  |
| S190000 |  | Preliminary Design Review - EMCal Sectors 1-12 |  | 0d | 2018-07-17 A | 2018-07-17 A | S189700 FF, S189900 FF, S189800 FF, S189600 FF | 100% |  |  |  |  |  | S190000 | 100 | S176200 |  | S176200 | NOCA | Completed | Stoll, Sean |  | BNL | Design | Craig Woody |  | EMCal Prepro Sector |  | POM02.1.03.02.03.02 |  | 02 | yes | 1 | 1 | 004 |  |  |  |  |  |  |  |  |  |  |  |  |  |  |  |  |  |  |  |  |  |  |
| S190100 |  | Preliminary Design Review - EMCal Sectors 1-12 | milestone | 0d | 2018-07-17 A | 2018-07-17 A | S190000 FF | 100% |  |  |  |  |  | S190100 | 100 | S176200 |  | S176250 | NOCA | Completed | Stoll, Sean |  | BNL | Design | Craig Woody |  | EMCal Prepro Sector |  | POM02.1.03.02.03.02 |  | 02 | yes | 1 | 1 | 004 | L2 |  |  |  |  |  |  |  |  |  |  |  |  |  |  |  |  |  |  |  |  |  |
| S190200 |  | Procure mechanical parts for preproduction prototype Sector 0 M&S FY18 |  | 52d | 2018-07-18 A | 2018-09-28 A | S100300, S190100 | 100% |  |  |  |  |  | S190200 | 100 | S176300 |  | S176300 | NOCA | Completed | Stoll, Sean | M3 | BNL | Fab & Assy | Craig Woody | BNL | EMCal Prepro Sector | OPC | POM02.1.03.02.03.02 |  | 02 | yes | 02 | 4 |  |  | OPC001500 | FY18 |  |  |  |  |  |  |  |  |  |  |  |  |  |  |  |  |  |  |  |
| S190400 |  | Procure mechanical parts for preproduction prototype Sector 0 Labor FY18 |  | 52d | 2018-07-18 A | 2018-09-28 A | S100300, S190100 | 100% |  |  |  |  |  | S190400 | 100 | S176400 |  | S176400 | NOCA | Completed | Stoll, Sean | L2 | BNL | Procurement | Craig Woody | BNL | EMCal Prepro Sector | null | POM02.1.03.02.03.02 |  | 02 | yes | 02 | 2 |  |  |  | FY18 |  |  |  |  |  |  |  |  |  |  |  |  |  |  |  |  |  |  |  |
| S190600 |  | Procure parts for cooling system for preproduction prototype Sector 0 Labor FY18 |  | 52d | 2018-07-18 A | 2018-09-28 A | S100300, S190100 | 100% |  |  |  |  |  | S190600 | 100 | S176500 |  | S176500 | NOCA | Completed | Stoll, Sean | L2 | BNL | Procurement | Craig Woody | BNL | EMCal Prepro Sector | null | POM02.1.03.02.03.02 |  | 02 | yes | 02 | 2 |  |  |  | FY18 |  |  |  |  |  |  |  |  |  |  |  |  |  |  |  |  |  |  |  |
| S190800 |  | Procure parts for cooling system for preproduction prototype Sector 0 M&S FY18 |  | 52d | 2018-07-18 A | 2018-09-28 A | S100300, S190100 | 100% |  |  |  |  |  | S190800 | 100 | S176600 |  | S176600 | NOCA | Completed | Stoll, Sean | M3 | BNL | Fab & Assy | Craig Woody | BNL | EMCal Prepro Sector | OPC | POM02.1.03.02.03.02 |  | 02 | yes | 02 | 4 |  |  | OPC001500 | FY18 |  |  |  |  |  |  |  |  |  |  |  |  |  |  |  |  |  |  |  |
| S190300 |  | Procure mechanical parts for preproduction prototype Sector 0 M&S FY19 |  | 144d | 2018-11-01 A | 2019-05-31 A | S190200 | 100% |  |  |  |  |  | S190300 | 5 | S176300 | 2019-03-29 | S176320 | NOCA | Completed | Stoll, Sean | M3 | BNL | Fab & Assy | Craig Woody | BNL | EMCal Prepro Sector | OPC | POM02.1.03.02.03.02 | C | 02 | yes | 02 | 4 |  |  | OPC001500 | FY19 | A-OPC | 16702 | Yes |  |  |  |  |  |  |  |  |  |  |  |  |  |  |  |  |
| S190500 |  | Procure mechanical parts for preproduction prototype Sector 0 Labor FY19 |  | 144d | 2018-11-01 A | 2019-05-31 A | S190400 | 100% |  |  |  |  |  | S190500 | 50 | S176400 | 2019-03-29 | S176420 | NOCA | Completed | Stoll, Sean | L2 | BNL | Procurement | Craig Woody | BNL | EMCal Prepro Sector | null | POM02.1.03.02.03.02 | C | 02 | yes | 02 | 2 |  |  |  | FY19 | B | 16710 |  |  |  |  |  |  |  |  |  |  |  |  |  |  |  |  |  |
| S190700 |  | Procure parts for cooling system for preproduction prototype Sector 0 Labor FY19 |  | 144d | 2018-11-01 A | 2019-05-31 A | S190600 | 100% |  |  |  |  |  | S190700 | 50 | S176500 | 2019-03-29 | S176520 | NOCA | Completed | Stoll, Sean | L2 | BNL | Procurement | Craig Woody | BNL | EMCal Prepro Sector | null | POM02.1.03.02.03.02 | C | 02 | yes | 02 | 2 |  |  |  | FY19 | B | 16710 |  |  |  |  |  |  |  |  |  |  |  |  |  |  |  |  |  |
| S190900 |  | Procure parts for cooling system for preproduction prototype Sector 0 M&S FY19 |  | 144d | 2018-11-01 A | 2019-05-31 A | S190800 | 100% |  |  |  |  |  | S190900 | 5 | S176600 | 2019-03-29 | S176620 | NOCA | Completed | Stoll, Sean | M3 | BNL | Fab & Assy | Craig Woody | BNL | EMCal Prepro Sector | OPC | POM02.1.03.02.03.02 | C | 02 | yes | 02 | 4 |  |  | OPC001500 | FY19 | A-OPC | 16702 | Yes |  |  |  |  |  |  |  |  |  |  |  |  |  |  |  |  |
| S191000 |  | Build mechanical enclosure for preproduction prototype Sector 0 |  | 43d | 2019-04-01 A | 2019-05-30 A | S190302, S190502 | 100% |  |  |  |  |  | S191000 | 0 | S176700 |  | S176700 | NOCA | Completed | Stoll, Sean | L3 | BNL | Fab & Assy | Craig Woody | BNL | EMCal Prepro Sector | null | POM02.1.03.02.03.02 | C | 02 | yes | 02 | 4 |  |  |  |  | B | 16710 |  |  |  |  |  |  |  |  |  |  |  |  |  |  |  |  |  |
| S191300 |  | Install modules in preproduction prototype Sector 0 |  | 38d | 2019-04-09 A | 2019-05-31 A | S191000, S191100, S191200, S184100 FS+5d, S191110 | 100% |  |  |  |  |  | S191300 | 0 | S177000 |  | S177000 | NOCA | Completed | Stoll, Sean | L4 | BNL | Fab & Assy | Craig Woody | BNL | EMCal Prepro Sector | null | POM02.1.03.02.03.02 | C | 02 | yes | 02 | 4 |  |  |  |  | B | 16710 |  |  |  |  |  |  |  |  |  |  |  |  |  |  |  |  |  |
| S190902 |  | Procure parts for cooling system for preproduction prototype Sector 0 M&S FY19 (second part) |  | 17d | 2019-05-01 A | 2019-05-23 A | S190900 | 100% |  |  |  |  |  | S190900 | 5 | S176600 | 2019-03-29 | S176620 | NOCA | Completed | Stoll, Sean | M3 | BNL | Fab & Assy | Craig Woody | BNL | EMCal Prepro Sector | OPC | POM02.1.03.02.03.02 | C | 02 |  | 02 | 4 |  |  | OPC001500 | FY19 | A-OPC | 16702 | Yes |  |  |  |  |  |  |  |  |  |  |  |  |  |  |  |  |
| S191200 |  | Build cooling system for preproduction prototype Sector 0 |  | 18d | 2019-05-01 A | 2019-05-24 A | S190702, S190902 | 100% |  |  |  |  |  | S191200 | 0 | S176900 |  | S176900 | NOCA | Completed | Stoll, Sean | L4 | BNL | Fab & Assy | Craig Woody | BNL | EMCal Prepro Sector | null | POM02.1.03.02.03.02 | C | 02 |  | 02 | 4 |  |  |  |  | B | 16710 |  |  |  |  |  |  |  |  |  |  |  |  |  |  |  |  |  |
| S190302 |  | Procure mechanical parts for preproduction prototype Sector 0 M&S FY19 Split |  | 21d | 2019-06-03 A | 2019-06-28 A | S190300 | 100% | 2019-06-03 | 2019-07-01 |  | Material (Purchase (1st $2M) |  | S190300 | 5 | S176300 | 2019-03-29 | S176320 | NOCA | Completed | Stoll, Sean | M3 | BNL | Fab & Assy | Craig Woody | BNL | EMCal Prepro Sector | OPC | POM02.1.03.02.03.02 | C | 02 |  | 02 | 4 |  |  | OPC001500 | FY19 | A-OPC | 16702 | Yes |  |  |  |  |  |  |  |  |  |  |  |  |  |  |  |  |
| S190502 |  | Procure mechanical parts for preproduction prototype Sector 0 Labor FY19 Split |  | 21d | 2019-06-03 A | 2019-06-28 A | S190500 | 100% | 2019-06-03 | 2019-07-01 |  | TECH3 PO D |  | S190500 | 50 | S176400 | 2019-03-29 | S176420 | NOCA | Completed | Stoll, Sean | L2 | BNL | Procurement | Craig Woody | BNL | EMCal Prepro Sector | null | POM02.1.03.02.03.02 | C | 02 |  | 02 | 2 |  |  |  | FY19 | B | 16710 |  |  |  |  |  |  |  |  |  |  |  |  |  |  |  |  |  |
| S190702 |  | Procure parts for cooling system for preproduction prototype Sector 0 Labor FY19 Split |  | 20d | 2019-06-03 A | 2019-06-28 A | S190700 | 100% |  |  |  | PROF4 PO M [9 h] | 1,286.78 | S190700 | 50 | S176500 | 2019-03-29 | S176520 | CA | Completed | Stoll, Sean | L2 | BNL | Procurement | Craig Woody | BNL | EMCal Prepro Sector | null | POM02.1.03.02.03.02 | C | 02 |  | 02 | 2 |  |  |  | FY19 | B | 16710 |  | S190702 | 1.03 | 1.03B |  |  |  |  |  |  |  |  |  |  |  |  |  |
| S191400 |  | Install readout electronics on preproduction prototype Sector 0 |  | 41d | 2019-06-03 A | 2019-07-30 A | S218200, S219100, S218800 | 100% |  |  |  | TECH3 PO E [64 h]; TECH3 PO M [32 h]; PROF4 PO E [32 h] | 15,211.85 | S191400 | 0 | S177100 |  | S177100 | CA | Completed | Stoll, Sean | L4 | BNL | Fab & Assy | Craig Woody | BNL | EMCal Prepro Sector | null | POM02.1.03.02.03.02 | C | 02 |  | 02 | 4 |  |  |  |  | B | 16710 |  | S191400 | 1.03 | 1.03B |  |  |  |  |  |  |  |  |  |  |  |  |  |
| S191100 |  | Build mechanical stand/support for preproduction prototype Sector 0 - Labor |  | 20d | 2019-07-01 A | 2019-07-29 A | S190302, S190502 | 100% |  |  |  | TECH3 PO M [48 h] | 5,318.31 | S191100 | 0 | S176800 |  | S176800 | CA | Completed | Stoll, Sean | L3 | BNL | Fab & Assy | Craig Woody | BNL | EMCal Prepro Sector | null | POM02.1.03.02.03.02 | C | 02 |  | 02 | 4 |  |  |  |  | B | 16710 |  | S191100 | 1.03 | 1.03B |  |  |  |  |  |  |  |  |  |  |  |  |  |
| S191110 |  | Build mechanical stand/support for preproduction prototype Sector 0 - M&S |  | 20d | 2019-07-01 A | 2019-07-29 A | S190302, S190502 | 100% |  |  |  | Material (Purchase (1st $2M) [500 h] | 551.63 | S191100 | 0 | S176800 |  | S176800 | CA | Completed | Stoll, Sean | L3 | BNL | Fab & Assy | Craig Woody | BNL | EMCal Prepro Sector | null | POM02.1.03.02.03.02 | C | 02 |  | 02 | 4 |  |  |  |  | A-OPC | 16702 |  | S191110 | 1.03 | 1.03A | UDF_G3 |  |  |  |  |  |  |  |  |  |  |  |  |
| S191500 |  | Install cables and cooling system on preproduction prototype Sector 0 |  | 44d | 2019-07-01 A | 2019-08-30 A | S219300, S219500, S190702 | 100% |  |  |  | PROF4 PO E [32 h]; PROF4 PO M [32 h]; TECH3 PO M [32 h] | 12,695.99 | S191500 | 0 | S177200 |  | S177200 | CA | Completed | Stoll, Sean | L4 | BNL | Fab & Assy | Craig Woody | BNL | EMCal Prepro Sector | null | POM02.1.03.02.03.02 | C | 02 |  | 02 | 4 |  |  |  |  | B | 16710 |  | S191500 | 1.03 | 1.03B |  |  |  |  |  |  |  |  |  |  |  |  |  |
| S191700 |  | Test preproduction prototype Sector 0 with LEDs & cosmic rays_10% |  | 44d | 2019-07-30 A | 2019-11-25 A | S191500 | 100% | 2019-07-30 | 2019-09-30 |  | PROF4 PO E [32 h]; SCI 4 PO [16 h]; STUDENT Other - Unpaid [160 h] | 7,773.79 | S191700 | 0 | S177400 |  | S177400 | CA | Completed | Stoll, Sean | L3 | BNL | Test_Components | Craig Woody | BNL | EMCal Prepro Sector | null | POM02.1.03.02.03.02 | C | 02 |  | 02 | 7 |  |  |  |  | B_T | 16710 |  | S191700 | 1.03 | 1.03B |  | 1 |  |  |  |  |  |  |  |  |  |  |  |
| S191600 |  | Revise module and sector design based on performance of Sector 0 |  | 20d | 2019-07-31 A | 2019-08-27 A | S191500 SS, S191400 | 100% |  |  |  | PROF4 PO E [160 h]; SCI 4 PO [160 h]; SCI3 PO PM [120 h] | 74,912.89 | S191600 | 0 | S177300 |  | S177300 | CA | Completed | Stoll, Sean | L3 | BNL | Design | Craig Woody | BNL | EMCal Prepro Sector | null | POM02.1.03.02.03.02 | A | 02 |  | 1 | 1 | 003 |  |  |  | B | 16710 |  | S191600 | 1.03 | 1.03B |  |  |  |  |  |  |  |  |  |  |  |  |  |
| S192100 |  | Final Design Review, Production Readiness Review - EMCal Sectors 1-12 |  | 1d | 2019-08-01 A | 2019-08-01 A | S191600, S220900 SS | 100% |  |  |  | SCI3 PO [8 h] | 1,336.74 | S192100 | 0 | S177800 |  | S177800 | CA | Completed | Stoll, Sean | M4 | BNL | Fab & Assy | Craig Woody |  | EMCal Prepro Sectors 1-12 | null | POM02.1.03.02.03.02 | A | 02 |  | 02 | 4 | 003,004 |  |  |  | B | 16710 |  | S192100 | 1.03 | 1.03B |  |  |  |  |  |  |  |  |  |  |  |  |  |
| S192200 |  | Procure mechanical parts for Prepro Sectors 1-12 - Provide Requirements to Procurement |  | 5d | 2019-08-02 A | 2019-08-08 A | S192100 | 100% |  |  |  | TECH3 PO D [24 h] | 2,659.16 | S192200 | 0 | S177900 |  | S177900 | CA | Completed | Stoll, Sean | L3 | BNL | Procurement | Craig Woody | BNL | EMCal Prepro Sectors 1-12 | null | POM02.1.03.02.03.02 | C | 02 |  | 02 | 2 |  |  |  |  | B | 16710 |  | S192200 | 1.03 | 1.03B |  |  | PP1 | MP200200 |  |  |  |  |  |  |  |  |  |
| S192900 |  | Procure parts for cooling system for Prepro Sectors 1-12 - Provide Requirements to Procurement |  | 5d | 2019-08-02 A | 2019-08-08 A | S192100 | 100% |  |  |  | PROF4 PO M [24 h] | 3,431.42 | S192900 | 0 | S178100 |  | S178100 | CA | Completed | Stoll, Sean | L3 | BNL | Procurement | Craig Woody | BNL | EMCal Prepro Sectors 1-12 | null | POM02.1.03.02.03.02 | C | 02 |  | 02 | 2 |  |  |  |  | B | 16710 |  | S192900 | 1.03 | 1.03B |  |  | PP1 | MP201800 |  |  |  |  |  |  |  |  |  |
| S192300 |  | Procure mechanical parts for Prepro Sectors 1-12 - Prepare & Send Solicitation |  | 15d | 2019-08-09 A | 2019-08-29 A | S192200 | 100% |  |  |  |  |  | S192300 | 0 | S177900 |  | S177910 | NOCA | Completed | Stoll, Sean |  | BNL | Procurement | Craig Woody | BNL | EMCal Prepro Sectors 1-12 |  | POM02.1.03.02.03.02 |  | 02 |  | 02 | 2 |  |  |  |  |  |  |  |  |  |  |  |  | PP2 | MP200200 |  |  |  |  |  |  |  |  |  |
| S193000 |  | Procure parts for cooling system for Prepro Sectors 1-12 - Prepare & Send Solicitation |  | 15d | 2019-08-09 A | 2019-08-29 A | S192900 | 100% |  |  |  |  |  | S193000 | 0 | S178100 |  | S178110 | NOCA | Completed | Stoll, Sean |  | BNL | Procurement | Craig Woody | BNL | EMCal Prepro Sectors 1-12 |  | POM02.1.03.02.03.02 |  | 02 |  | 02 | 2 |  |  |  |  |  |  |  |  |  |  |  |  | PP2 | MP201800 |  |  |  |  |  |  |  |  |  |
| S192500 |  | Procure mechanical parts for Prepro Sectors 1-12 - Vendor Selection |  | 5d | 2019-08-15 A | 2019-08-27 A | S192400 | 100% | 2019-09-23 | 2019-09-27 |  |  |  | S192500 | 0 | S177900 |  | S177930 | NOCA | Completed | Stoll, Sean |  | BNL | Procurement | Craig Woody | BNL | EMCal Prepro Sectors 1-12 |  | POM02.1.03.02.03.02 |  | 02 |  | 02 | 2 |  |  |  |  |  |  |  |  |  |  |  |  | PP4 | MP200200 |  |  |  |  |  |  |  |  |  |
| S192400 |  | Procure mechanical parts for Prepro Sectors 1-12 - Vendor Responses |  | 15d | 2019-08-21 A | 2019-08-30 A | S192300 | 100% | 2019-08-30 | 2019-09-20 |  |  |  | S192400 | 0 | S177900 |  | S177920 | NOCA | Completed | Stoll, Sean |  | BNL | Procurement | Craig Woody | BNL | EMCal Prepro Sectors 1-12 |  | POM02.1.03.02.03.02 |  | 02 |  | 02 | 2 |  |  |  |  |  |  |  |  |  |  |  |  | PP3 | MP200200 |  |  |  |  |  |  |  |  |  |
| S193200 |  | Procure parts for cooling system for Prepro Sectors 1-12 - Vendor Selection |  | 5d | 2019-08-22 A | 2019-08-30 A | S193100 | 100% | 2019-09-23 | 2019-09-27 |  |  |  | S193200 | 0 | S178100 |  | S178130 | NOCA | Completed | Stoll, Sean |  | BNL | Procurement | Craig Woody | BNL | EMCal Prepro Sectors 1-12 |  | POM02.1.03.02.03.02 |  | 02 |  | 02 | 2 |  |  |  |  |  |  |  |  |  |  |  |  | PP4 | MP201800 |  |  |  |  |  |  |  |  |  |
| S193100 |  | Procure parts for cooling system for Prepro Sectors 1-12 - Vendor Responses |  | 15d | 2019-08-23 A | 2019-08-30 A | S193000 | 100% | 2019-08-30 | 2019-09-20 |  |  |  | S193100 | 0 | S178100 |  | S178120 | NOCA | Completed | Stoll, Sean |  | BNL | Procurement | Craig Woody | BNL | EMCal Prepro Sectors 1-12 |  | POM02.1.03.02.03.02 |  | 02 |  | 02 | 2 |  |  |  |  |  |  |  |  |  |  |  |  | PP3 | MP201800 |  |  |  |  |  |  |  |  |  |
| OBLG192610 |  | Procure mechanical parts for Prepro Sectors 1-12, Phase 1 - Obligation |  | 1d | 2019-09-03 A | 2019-09-03 A | S100300, S192500 | 100% |  |  |  | Obligation Resource [41873.4 h] | 41,873.39 | S192600 | 0 | S177900 |  | S177940 |  | Completed | Stoll, Sean |  | BNL | Procurement | Craig Woody | BNL | EMCal Prepro Sectors 1-12 |  | POM02.1.03.02.03.02 |  | 02 |  |  |  | 003,004 | L5 |  |  | A-OPC |  |  |  |  |  |  |  | PP5 | MP200200 | OBLG |  |  |  |  |  |  |  |  |
| OBLG193310 |  | Procure parts for cooling system for Prepro Sectors 1-12 - Obligation |  | 1d | 2019-09-03 A | 2019-09-03 A | S100300, S193200 | 100% |  |  |  | Obligation Resource [22508.2 h] | 22,508.17 | S193300 | 0 | S178100 |  | S178140 |  | Completed | Stoll, Sean |  | BNL | Procurement | Craig Woody | BNL | EMCal Prepro Sectors 1-12 |  | POM02.1.03.02.03.02 |  | 02 |  |  |  |  | L5 |  |  | A-OPC |  |  |  |  |  |  |  | PP5 | MP201800 | OBLG |  |  |  |  |  |  |  |  |
| S192700 |  | Procure mechanical parts for Prepro Sectors 1-12 - Contract/PO - Leadtime |  | 40d | 2019-09-03 A | 2019-10-22 A | S192600 SS, OBLG192610 SS | 100% | 2019-09-03 | 2019-10-29 |  |  |  | S192700 | 0 | S177900 |  | S177950 | NOCA | Completed | Stoll, Sean |  | BNL | Fab & Assy | Craig Woody | BNL | EMCal Prepro Sectors 1-12 |  | POM02.1.03.02.03.02 |  | 02 |  | 02 | 4 |  |  |  |  |  |  |  |  |  |  |  |  | PP6 | MP200200 |  |  |  |  |  |  |  |  |  |
| S193400 |  | Procure parts for cooling system for Prepro Sectors 1-12 - Contract/PO - Leadtime |  | 40d | 2019-09-03 A | 2019-10-15 A | S193300 SS, OBLG193310 SS | 100% | 2019-09-03 | 2019-10-29 |  |  |  | S193400 | 0 | S178100 |  | S178150 | NOCA | Completed | Stoll, Sean |  | BNL | Fab & Assy | Craig Woody | BNL | EMCal Prepro Sectors 1-12 |  | POM02.1.03.02.03.02 |  | 02 |  | 02 | 4 |  |  |  |  |  |  |  |  |  |  |  |  | PP6 | MP201800 |  |  |  |  |  |  |  |  |  |
| S192600 |  | Procure mechanical parts for Prepro Sectors 1-12, Phase 1 - Contract Award(s) | milestone | 0d | 2019-09-30 A | 2019-09-30 A | S100300, S192500 | 100% |  |  |  |  |  | S192600 | 0 | S177900 |  | S177940 | NOCA | Completed | Stoll, Sean |  | BNL | Procurement | Craig Woody | BNL | EMCal Prepro Sectors 1-12 |  | POM02.1.03.02.03.02 |  | 02 |  | 02 | 2 | 003,004 | L5 |  |  | A-OPC |  |  |  |  |  |  |  | PP5 | MP200200 |  | Contract Award |  |  |  |  |  |  |  |
| S192620 |  | Procure mechanical parts for Prepro Sectors 1-12, Phase 2 - Contract Award(s) | milestone | 0d | 2019-09-30 A | 2019-09-30 A | S101000, S192500 | 100% |  |  |  |  |  | S192600 | 0 | S177900 |  | S177940 | NOCA | Completed | Stoll, Sean |  | BNL | Procurement | Craig Woody | BNL | EMCal Prepro Sectors 1-12 |  | POM02.1.03.02.03.02 |  | 02 |  | 02 | 2 | 003,004 | L5 |  |  | A-TEC |  |  |  |  |  |  |  | PP5 | MP200201 |  | Contract Award |  |  |  |  |  |  |  |
| S193300 |  | Procure parts for cooling system for Prepro Sectors 1-12 - Contract Award(s) | milestone | 0d | 2019-09-30 A | 2019-09-30 A | S100300, S193200 | 100% |  |  |  |  |  | S193300 | 0 | S178100 |  | S178140 | NOCA | Completed | Stoll, Sean |  | BNL | Procurement | Craig Woody | BNL | EMCal Prepro Sectors 1-12 |  | POM02.1.03.02.03.02 |  | 02 |  | 02 | 2 |  | L5 |  |  | A-OPC |  |  |  |  |  |  |  | PP5 | MP201800 |  | Contract Award |  |  |  |  |  |  |  |
| OBLG192611 |  | Procure mechanical parts for Prepro Sectors 1-12, Phase 2 - Obligation |  | 1d | 2019-10-01 A | 2019-10-01 A | S101000, S192620 SS | 100% |  |  |  | Obligation Resource [41873.4 h] | 41,873.39 | S192600 | 0 | S177900 |  | S177940 |  | Completed | Stoll, Sean |  | BNL | Procurement | Craig Woody | BNL | EMCal Prepro Sectors 1-12 |  | POM02.1.03.02.03.02 |  | 02 |  |  |  | 003,004 | L5 |  |  | A-TEC |  |  |  |  |  |  |  | PP5 | MP200201 | OBLG |  |  |  |  |  |  |  |  |
| S192810 |  | Procure mechanical parts for Prepro Sectors 1-12, Phase 2 - Delivery Acceptance |  | 2.5d | 2019-10-10 A | 2020-05-29 A | S192620, OBLG192611, S192800 SS | 100% | 2019-12-02 | 2019-12-04 |  | Material (Purchase (1st $2M) [36798 h] | 41,873.39 | S192800 | 0 | S178000 |  | S178000 | CA | In Progress | Stoll, Sean | M4 | BNL | Fab & Assy | Craig Woody | BNL | EMCal Prepro Sectors 1-12 | OPC | POM02.1.03.02.03.02 | C | 02 |  | 02 | 4 | 003,004 |  | OPC001500 |  | A-TEC | 59709 |  | S192810 | 1.03 | 1.03A | UDF_G1 |  | PP6 | MP200201 | FAB | Delivery | UDF_G1 | 10468.348305 | 0.25 |  |  |  |  |
| S193500 |  | Procure parts for cooling system for Prepro Sectors 1-12 - Delivery Acceptance |  | 5d | 2019-10-16 A | 2020-12-14 A | S193400 | 100% | 2019-12-02 | 2019-12-06 |  | Material (Purchase (1st $2M) [19780 h] | 22,508.17 | S193500 | 0 | S178200 |  | S178200 | CA | In Progress | Stoll, Sean | M4 | BNL | Fab & Assy | Craig Woody | BNL | EMCal Prepro Sectors 1-12 | OPC | POM02.1.03.02.03.02 | C | 02 |  | 02 | 4 |  |  | OPC001500 |  | A-OPC | 16702 |  | S193500 | 1.03 | 1.03A | UDF_G1 |  | PP6 | MP201800 | FAB | Delivery | UDF_G1 | 11254.086063 | 0.5 |  |  |  |  |
| S192800 |  | Procure mechanical parts for Prepro Sectors 1-12, Phase 1 - Delivery Acceptance |  | 2.5d | 2019-10-23 A | 2020-05-29 A | S192700 | 100% | 2019-12-02 | 2019-12-04 |  | Material (Purchase (1st $2M) [36798 h] | 41,873.39 | S192800 | 0 | S178000 |  | S178000 | CA | In Progress | Stoll, Sean | M4 | BNL | Fab & Assy | Craig Woody | BNL | EMCal Prepro Sectors 1-12 | OPC | POM02.1.03.02.03.02 | C | 02 |  | 02 | 4 | 003,004 |  | OPC001500 |  | A-OPC | 16702 |  | S192800 | 1.03 | 1.03A | UDF_G1 |  | PP6 | MP200200 | FAB | Delivery | UDF_G1 | 10468.348305 | 0.25 |  |  |  |  |
| S191800 |  | Analyze test results from preproduction prototype Sector 0 |  | 20d | 2019-11-07 A | 2019-11-25 A | S191700 FF | 100% | 2019-12-03 | 2019-12-31 |  | SCI3 PO [64 h]; STUDENT Other - Unpaid [320 h]; SCI 4 PO [32 h] | 17,603.8 | S191800 | 0 | S177500 |  | S177500 | CA | Completed | Stoll, Sean | L3 | BNL | Test_System | Craig Woody | BNL | EMCal Prepro Sector | null | POM02.1.03.02.03.02 | A | 02 |  | 02 | 7 | 003 |  |  |  | B_T | 16710 |  | S191800 | 1.03 | 1.03B |  |  |  |  |  |  |  |  |  |  |  |  |  |
| S191900 |  | Performance review of preproduction prototype Sector 0 |  | 5d | 2019-11-07 A | 2019-11-25 A | S191800 | 100% | 2020-01-02 | 2020-01-08 |  | PROF4 PO E [160 h]; SCI3 PO PM [120 h]; SCI 4 PO [160 h] | 77,160.27 | S191900 | 0 | S177600 |  | S177600 | CA | Completed | Stoll, Sean | L2 | BNL | Fab & Assy | Craig Woody | BNL | EMCal Prepro Sector | null | POM02.1.03.02.03.02 | A | 02 |  | 02 | 4 | 003,004 |  |  |  | B | 16710 |  | S191900 | 1.03 | 1.03B |  |  |  |  |  |  |  |  |  |  |  |  |  |
| S193600 |  | Build mechanical enclosure for Prepro Sectors 1-12 |  | 30d | 2019-11-13 A | 2021-01-11 A | S192800 SS+5d, S192000, S192810 SS | 100% | 2020-01-09 | 2020-02-21 |  | TECH3 PO M [336 h] | 38,345.04 | S193600 | 0 | S178300 |  | S178300 | CA | In Progress | Stoll, Sean | L4 | BNL | Fab & Assy | Craig Woody | BNL | EMCal Prepro Sectors 1-12 | null | POM02.1.03.02.03.02 | C | 02 |  | 02 | 4 | 003 |  |  |  | B | 16710 |  | S193600 | 1.03 | 1.03B |  |  |  |  |  |  |  |  |  |  |  |  |  |
| S193710 |  | Build mechanical stand/support for Prepro Sectors 1-12 - M&S |  | 30d | 2019-11-13 A | 2020-09-30 A | S192800 SS+5d, S192810 SS | 100% | 2019-12-02 | 2020-01-14 |  | Material (Purchase (1st $2M) [500 h] | 568.96 | S193700 | 0 | S178400 |  | S178400 | CA | In Progress | Stoll, Sean | L4 | BNL | Fab & Assy | Craig Woody | BNL | EMCal Prepro Sectors 1-12 | null | POM02.1.03.02.03.02 | C | 02 |  | 02 | 4 |  |  |  |  | A-OPC | 16702 |  | S193710 | 1.03 | 1.03A | UDF_G1 |  |  |  |  |  | UDF_G1 | 426.72217125 | 0.75 |  |  |  |  |
| S193700 |  | Build mechanical stand/support for Prepro Sectors 1-12 - Labor |  | 30d | 2019-11-14 A | 2020-09-30 A | S192800 SS+5d, S192810 SS | 100% | 2019-12-02 | 2020-01-14 |  | TECH3 PO M [336 h] | 38,345.04 | S193700 | 0 | S178400 |  | S178400 | CA | In Progress | Stoll, Sean | L4 | BNL | Fab & Assy | Craig Woody | BNL | EMCal Prepro Sectors 1-12 | null | POM02.1.03.02.03.02 | C | 02 |  | 02 | 4 | 003 |  |  |  | B | 16710 |  | S193700 | 1.03 | 1.03B |  |  |  |  |  |  |  |  |  |  |  |  |  |
| S192000 |  | EMCal Preproduction Sector 0 Assembled | milestone | 0d | 2019-11-25 A | 2019-11-25 A | S191900 FF | 100% | 2020-01-08 | 2020-01-08 |  |  |  | S192000 | 0 | S177700 |  | S177700 | NOCA | Completed | Stoll, Sean |  | BNL | Fab & Assy | Craig Woody | BNL | EMCal Prepro Sector |  | POM02.1.03.02.03.02 |  | 02 |  | 02 | 4 |  | L2 |  |  |  |  |  |  |  |  |  |  |  |  |  |  |  |  |  | 2019-12-31 | 23 | PMP_1x |  |
| S193800 |  | Build cooling system for Prepro Sectors 1-12 |  | 30d | 2020-02-03 A | 2021-01-11 A | S193500 SS+5d | 100% | 2020-02-03 | 2020-03-16 |  | TECH3 PO M [216 h] | 24,650.38 | S193800 | 0 | S178500 |  | S178500 | CA | Not Started | Stoll, Sean | L4 | BNL | Fab & Assy | Craig Woody | BNL | EMCal Prepro Sectors 1-12 | null | POM02.1.03.02.03.02 | C | 02 |  | 02 | 4 | 003 |  |  |  | B | 16710 |  | S193800 | 1.03 | 1.03B |  |  |  |  |  |  |  |  |  |  |  |  |  |
| S193900 |  | Install modules in Prepro Sectors 1-12 |  | 100d | 2020-03-11 A | 2021-01-26 A | S193600, S193700, S193800 SS+5d, S186200 SS+5d, S193710 | 100% | 2020-04-01 | 2020-08-20 | start on or after 2020-04-01 | PROF4 PO E [218 h]; TECH3 PO M [557 h] | 95,669.8 | S193900 | 0 | S178600 |  | S178600 | CA | Not Started | Stoll, Sean | L4 | BNL | Fab & Assy | Craig Woody | BNL | EMCal Prepro Sectors 1-12 | null | POM02.1.03.02.03.02 | C | 02 |  | 02 | 4 | 004 |  |  |  | B | 16710 |  | S193900 | 1.03 | 1.03B |  |  |  |  |  |  |  |  |  |  |  |  | Yes |
| S194000 |  | Install readout electronics on Prepro Sectors 1-12 |  | 120d | 2020-03-24 A | 2021-01-26 A | S193900 SS+5d, S223100 SS, S222300 | 100% | 2020-05-01 | 2020-10-21 |  | PROF4 PO E [218 h]; TECH3 PO E [371 h]; TECH3 PO M [186 h] | 96,004.65 | S194000 | 0 | S178700 |  | S178700 | CA | Not Started | Stoll, Sean | L4 | BNL | Fab & Assy | Craig Woody | BNL | EMCal Prepro Sectors 1-12 | null | POM02.1.03.02.03.02 | C | 02 |  | 02 | 4 | 004 |  |  |  | B | 16710 |  | S194000 | 1.03 | 1.03B |  |  |  |  |  |  |  |  |  |  |  |  | Yes |
| S194200 |  | Test and Review Preproduction Sectors 1-12 with LEDs & cosmic rays |  | 120d | 2020-03-24 A | 2021-03-31 A | S194100 SS+5d | 100% | 2020-05-01 | 2020-10-21 |  | PROF4 PO E [218 h]; STUDENT Other - Unpaid [1698 h]; SCI 4 PO [170 h] | 67,342.92 | S194200 | 0 | S178900 |  | S178900 | CA | Not Started | Stoll, Sean | L3 | BNL | Test_Components | Craig Woody | BNL | EMCal Prepro Sectors 1-12 | null | POM02.1.03.02.03.02 | A | 02 |  | 02 | 7 | 003,004 |  |  |  | B_T | 16710 |  | S194200 | 1.03 | 1.03B |  |  |  |  |  |  |  |  |  |  |  |  | Yes |
| S194300 |  | Analyze and Review Test Results from Prepro Sectors 1-12 |  | 86d | 2020-03-24 A | 2021-04-05 A | S194200 SS+5d | 100% | 2020-05-01 | 2020-09-01 |  | SCI3 PO [64 h]; STUDENT Other - Unpaid [1088 h]; SCI 4 PO [186 h]; PROF4 PO E [77 h]; PROF4 PO M [77 h]; TECH3 PO E [77 h]; TECH3 PO M [154 h] | 98,354.57 | S194300 | 0 | S179000 |  | S179000 | CA | Not Started | Stoll, Sean | L2 | BNL | Test_System | Craig Woody | BNL | EMCal Prepro Sectors 1-12 | null | POM02.1.03.02.03.02 | A | 02 |  | 02 | 7 | 003,004 |  |  |  | B_T | 16710 |  | S194300 | 1.03 | 1.03B |  |  |  |  |  |  |  |  |  |  |  |  | Yes |
| S194100 |  | Install cables and cooling system on Prepro Sectors 1-12 |  | 120d | 2020-03-25 A | 2021-02-01 A | S194000 SS | 100% | 2020-05-01 | 2020-10-21 |  | PROF4 PO E [218 h]; PROF4 PO M [608 h]; TECH3 PO M [493 h] | 178,525.77 | S194100 | 0 | S178800 |  | S178800 | CA | Not Started | Stoll, Sean | L4 | BNL | Fab & Assy | Craig Woody | BNL | EMCal Prepro Sectors 1-12 | null | POM02.1.03.02.03.02 | C | 02 |  | 02 | 4 | 004 |  |  |  | B | 16710 |  | S194100 | 1.03 | 1.03B |  |  |  |  |  |  |  |  |  |  |  |  | Yes |
| S194400 |  | Completion of EMCal Prepro Sectors 1-12 | milestone | 0d | 2021-04-05 A | 2021-04-05 A | S194300 FF | 100% |  |  |  |  |  | S194400 | 0 | S179100 |  | S179100 | NOCA | Not Started | Stoll, Sean |  | BNL | Fab & Assy | Craig Woody | BNL | EMCal Prepro Sectors 1-12 |  | POM02.1.03.02.03.02 |  | 02 |  | 02 | 4 |  | L3 | OPC001500 |  |  |  |  |  |  |  | UDF_G3 |  |  |  |  |  | UDF_G3 |  |  |  |  |  |  |

Notes:
- S189700: BNL_UDF_Adhoc Comments: 180219 ELM resource removed PROF4 AD per EOB / BNL_UDF_Old Activity Name 181221: Design mechanical enclosure for preproduction prototype Sector 0
- S189800: BNL_UDF_Adhoc Comments: 180219 ELM resource removed PROF4 AD per EOB / BNL_UDF_Old Activity Name 181221: Design mechanical support structure for preproduction prototype Sector 0
- S189900: BNL_UDF_Old Activity Name 181221: Design cooling system for preproduction prototype Sector 0
- S190000: BNL_UDF_Status Comments: 190522 IVS new name; 190415 ELM name per GRY / BNL_UDF_Old Activity Name 181221: Design Review for EMCal preproduction prototype Sector 0
- S190100: BNL_UDF_Status Comments: 190522 IVS new name / BNL_UDF_Old Activity Name 181221: Design Review for EMCal preproduction prototype Sector 0 Complete
- S190200: BNL_UDF_Old Activity Name 181221: Procure mechanical parts for preproduction prototype Sector 0 M&S FY18
- S190400: BNL_UDF_Old Activity Name 181221: Procure mechanical parts for preproduction prototype Sector 0 Labor FY18
- S190600: BNL_UDF_Old Activity Name 181221: Procure parts for cooling system for preproduction prototype Sector 0 Labor FY18
- S190800: BNL_UDF_Old Activity Name 181221: Procure parts for cooling system for preproduction prototype Sector 0 M&S FY18
- S190300: BNL_UDF_Old Activity Name 181221: Procure mechanical parts for preproduction prototype Sector 0 M&S FY19
- S190500: BNL_UDF_Old Activity Name 181221: Procure mechanical parts for preproduction prototype Sector 0 Labor FY19
- S190700: BNL_UDF_Old Activity Name 181221: Procure parts for cooling system for preproduction prototype Sector 0 Labor FY19
- S190900: BNL_UDF_Old Activity Name 181221: Procure parts for cooling system for preproduction prototype Sector 0 M&S FY19
- S191000: BNL_UDF_Old Activity Name 181221: Build mechanical enclosure for preproduction prototype Sector 0
- S191300: BNL_UDF_Old Activity Name 181221: Install modules in preproduction prototype Sector 0
- S190902: BNL_UDF_Old Activity Name 181221: Procure parts for cooling system for preproduction prototype Sector 0 M&S FY19
- S191200: BNL_UDF_Old Activity Name 181221: Build cooling system for preproduction prototype Sector 0
- S190302: BNL_UDF_Old Activity Name 181221: Procure mechanical parts for preproduction prototype Sector 0 M&S FY19
- S190502: BNL_UDF_Old Activity Name 181221: Procure mechanical parts for preproduction prototype Sector 0 Labor FY19
- S190702: BNL_UDF_Old Activity Name 181221: Procure parts for cooling system for preproduction prototype Sector 0 Labor FY19
- S191400: BNL_UDF_Old Activity Name 181221: Install readout electronics on preproduction prototype Sector 0
- S191100: BNL_UDF_Old Activity Name 181221: Build mechanical support for preproduction prototype Sector 0
- S191110: BNL_UDF_Old Activity Name 181221: Build mechanical support for preproduction prototype Sector 0
- S191500: BNL_UDF_Old Activity Name 181221: Install cables and cooling system on preproduction prototype Sector 0
- S191700: BNL_UDF_Old Activity Name 181221: Test preproduction prototype Sector 0 with LEDs & cosmic rays
- S191600: BNL_UDF_Status Comments: 190315 DurType to align with EVT / BNL_UDF_Old Activity Name 181221: Revise module and sector design based on performance of Sector 0
- S192100: BNL_UDF_Status Comments: 190522 IVS new name; 190315 DurType to align with EVT / BNL_UDF_Adhoc Comments: 180420 ELM name per GRY; 180227 ELM added rsrc assgnmt per GRY / BNL_UDF_Old Activity Name 181221: Production Readiness Review for Prepro Sectors 1-12
- S192200: BNL_UDF_Adhoc Comments: 180403 ELM dur, succ / BNL_UDF_Old Activity Name 181221: Procure mechanical parts for Prepro Sectors 1-12 - Provide Requirements to Procurement
- S192900: BNL_UDF_Old Activity Name 181221: Procure parts for cooling system for Prepro Sectors 1-12 - Provide Requirements to Procurement
- S192300: BNL_UDF_Adhoc Comments: 180402 ELM added activity for proc strg / BNL_UDF_Old Activity Name 181221: Procure mechanical parts for Prepro Sectors 1-12 - Prepare & Send Solicitation
- S193000: BNL_UDF_Adhoc Comments: 180402 ELM added activity for proc strg / BNL_UDF_Old Activity Name 181221: Procure parts for cooling system for Prepro Sectors 1-12 - Prepare & Send Solicitation
- S192500: BNL_UDF_Adhoc Comments: 180402 ELM added activity for proc strg / BNL_UDF_Old Activity Name 181221: Procure mechanical parts for Prepro Sectors 1-12 - Vendor Selection
- S192400: BNL_UDF_Adhoc Comments: 180402 ELM added activity for proc strg / BNL_UDF_Old Activity Name 181221: Procure mechanical parts for Prepro Sectors 1-12 - Vendor Responses
- S193200: BNL_UDF_Adhoc Comments: 180402 ELM added activity for proc strg / BNL_UDF_Old Activity Name 181221: Procure parts for cooling system for Prepro Sectors 1-12 - Vendor Selection
- S193100: BNL_UDF_Adhoc Comments: 180402 ELM added activity for proc strg / BNL_UDF_Old Activity Name 181221: Procure parts for cooling system for Prepro Sectors 1-12 - Vendor Responses
- OBLG192610: BNL_UDF_Status Comments: 190417 ELM name; 190318 ELM split OPC,TEC per GRY / BNL_UDF_Adhoc Comments: 180402 ELM added activity for proc strg / BNL_UDF_Old Activity Name 181221: Procure mechanical parts for Prepro Sectors 1-12 - Contract Award(s)
- OBLG193310: BNL_UDF_Adhoc Comments: 180402 ELM added activity for proc strg / BNL_UDF_Old Activity Name 181221: Procure parts for cooling system for Prepro Sectors 1-12 - Contract Award(s)
- S192700: BNL_UDF_Adhoc Comments: 180402 ELM added activity for proc strg / BNL_UDF_Old Activity Name 181221: Procure mechanical parts for Prepro Sectors 1-12 - Contract/PO - Leadtime
- S193400: BNL_UDF_Adhoc Comments: 180402 ELM added activity for proc strg / BNL_UDF_Old Activity Name 181221: Procure parts for cooling system for Prepro Sectors 1-12 - Contract/PO - Leadtime
- S192600: BNL_UDF_Status Comments: 190417 ELM name; 190318 ELM split OPC,TEC per GRY / BNL_UDF_Adhoc Comments: 180402 ELM added activity for proc strg / BNL_UDF_Old Activity Name 181221: Procure mechanical parts for Prepro Sectors 1-12 - Contract Award(s)
- S192620: BNL_UDF_Status Comments: 190417 ELM name; 190318 ELM split OPC,TEC per GRY / BNL_UDF_Adhoc Comments: 180402 ELM added activity for proc strg / BNL_UDF_Old Activity Name 181221: Procure mechanical parts for Prepro Sectors 1-12 - Contract Award(s)
- S193300: BNL_UDF_Adhoc Comments: 180402 ELM added activity for proc strg / BNL_UDF_Old Activity Name 181221: Procure parts for cooling system for Prepro Sectors 1-12 - Contract Award(s)
- OBLG192611: BNL_UDF_Status Comments: 190417 ELM name; 190318 ELM split OPC,TEC per GRY / BNL_UDF_Adhoc Comments: 180402 ELM added activity for proc strg / BNL_UDF_Old Activity Name 181221: Procure mechanical parts for Prepro Sectors 1-12 - Contract Award(s)
- S192810: BNL_UDF_Status Comments: 190417 ELM name; 190318 ELM split OPC,TEC per GRY / BNL_UDF_Adhoc Comments: 180410 ELM pred/succ per GRY; 180403 ELM dur, pred / BNL_UDF_Old Activity Name 181221: Procure mechanical parts for Prepro Sectors 1-12 - Delivery Acceptance
- S193500: BNL_UDF_Adhoc Comments: 180410 ELM pred/succ per GRY / BNL_UDF_Old Activity Name 181221: Procure parts for cooling system for Prepro Sectors 1-12 - Delivery Acceptance
- S192800: BNL_UDF_Status Comments: 190417 ELM name; 190318 ELM split OPC,TEC per GRY / BNL_UDF_Adhoc Comments: 180410 ELM pred/succ per GRY; 180403 ELM dur, pred / BNL_UDF_Old Activity Name 181221: Procure mechanical parts for Prepro Sectors 1-12 - Delivery Acceptance
- S191800: BNL_UDF_Status Comments: 190315 DurType to align with EVT / BNL_UDF_Old Activity Name 181221: Analyze test results from preproduction prototype Sector 0
- S191900: BNL_UDF_Status Comments: 190522 IVS new name; 190415 ELM name per GRY; 19315 DurType to align with EVT / BNL_UDF_Old Activity Name 181221: Performance review of preproduction prototype Sector 0
- S193600: Scheduler's Notes: 180413 ELM per GRY: / assume 2 people do this / BNL_UDF_Status Comments: 190315 ELM EVT / BNL_UDF_Adhoc Comments: 180405 ELM rsrc per GRY / BNL_UDF_Old Activity Name 181221: Build mechanical enclosure for Prepro Sectors 1-12
- S193710: Scheduler's Notes: 180413 ELM per GRY: / assume 2 people do this / BNL_UDF_Adhoc Comments: 180405 ELM rsrc per GRY / BNL_UDF_Old Activity Name 181221: Build mechanical support for Prepro Sectors 1-12
- S193700: Scheduler's Notes: 180413 ELM per GRY: / assume 2 people do this / BNL_UDF_Status Comments: 190315 ELM EVT / BNL_UDF_Adhoc Comments: 180405 ELM rsrc per GRY / BNL_UDF_Old Activity Name 181221: Build mechanical support for Prepro Sectors 1-12
- S192000: BNL_UDF_Adhoc Comments: 180417 ELM pred/succ per GRY / BNL_UDF_Old Activity Name 181221: EMCal Preproduction Sector 0 Assembled
- S193800: BNL_UDF_Status Comments: 190315 ELM EVT / BNL_UDF_Adhoc Comments: 180405 ELM rsrc per GRY / BNL_UDF_Old Activity Name 181221: Build cooling system for Prepro Sectors 1-12
- S193900: Scheduler's Notes: 180413 ELM per GRY: / assume 2 people do this / BNL_UDF_Status Comments: 190418 ELM BLU per GRY / BNL_UDF_Adhoc Comments: 180405 ELM rsrc per GRY / BNL_UDF_Old Activity Name 181221: Install modules in Prepro Sectors 1-12
- S194000: BNL_UDF_Status Comments: 190418 ELM BLU per GRY / BNL_UDF_Adhoc Comments: 180410 ELM pred/succ per GRY; 180405 ELM rsrc per GRY / BNL_UDF_Old Activity Name 181221: Install readout electronics on Prepro Sectors 1-12
- S194200: BNL_UDF_Status Comments: 190415 ELM name per GRY; 19315 DurType to align with EVT / BNL_UDF_Adhoc Comments: 180405 ELM rsrc per GRY / BNL_UDF_Old Activity Name 181221: Test preproduction sectors 1-12 with LEDs & cosmic rays
- S194300: BNL_UDF_Status Comments: 190415 ELM name per GRY; 19315 DurType to align with EVT / BNL_UDF_Adhoc Comments: 180405 ELM rsrc per GRY / BNL_UDF_Old Activity Name 181221: Analyze test results from Prepro Sectors 1-12
- S194100: Scheduler's Notes: 180413 ELM per GRY: / assume 2 people do this / BNL_UDF_Status Comments: 190418 ELM BLU per GRY / BNL_UDF_Adhoc Comments: 180405 ELM rsrc per GRY / BNL_UDF_Old Activity Name 181221: Install cables and cooling system on Prepro Sectors 1-12
- S194400: BNL_UDF_Old Activity Name 181221: Completion of EMCal Prepro Sectors 1-12

| ID | WBS | Activity | Type | Duration | Start | Finish | Predecessors | Complete | Remaining | Planned start | Planned finish | Total float | Free float | Constraint | Expected finish | Resources | Cost | BNL_UDF_Temp Text 01 | BNL_UDF_Percent Complete | BNL_UDF_OPC TEC (deprecated) | BNL_UDF_Old Activity ID 181221 | BNL_Cobra WP | RG Check | BNL_Activity Status | BNL_Fund Source | BNL_Estimator | BNL_Cost Basis | BNL_Location | BNL_EDIA | BNL_Proc Sig Phase | BNL_Proc Sig | BNL_CAM | BNL_Institution | BNL_OPC TEC (deprecated) | BNL_WBS | BNL_EVT | BNL_Master Control Account | BNL_Account Number | BNL_PCR ID | BNL_Cobra Control Account | BNL_WBS_Hierarchical | PMP Summary Part1 | PMP Summary Part2 | Indicator - Procurement | Indicator - Float | BNL_Milestone Level | SPH Proc Register | BNL_Obligation | Target Milestone Date | Variance | PMP Milestones | BNL_UDF_Remaining Tot Cost | BNL_UDF_Percent_remaining | Additional EVT documentation required |
| --- | --- | --- | --- | --- | --- | --- | --- | --- | --- | --- | --- | --- | --- | --- | --- | --- | --- | --- | --- | --- | --- | --- | --- | --- | --- | --- | --- | --- | --- | --- | --- | --- | --- | --- | --- | --- | --- | --- | --- | --- | --- | --- | --- | --- | --- | --- | --- | --- | --- | --- | --- | --- | --- | --- |
|  | 03 | **EMCAL Final Production Sector Assembly** |  |  | 2020-04-15 | 2022-02-04 |  |  |  |  |  |  |  |  |  |  |  |  |  |  |  |  |  |  |  |  |  |  |  |  |  |  |  |  |  |  |  |  |  |  |  |  |  |  |  |  |  |  |  |  |  |  |  |  |
| S194800 |  | Procure EMCAL Mechanical Parts for Final Sectors - Provide Requirements to Procurement |  | 5d | 2020-04-15 A | 2020-04-30 A | S194500, S194700 | 100% |  | 2020-05-11 | 2020-05-15 |  |  |  |  | TECH3 PO D [56 h] | 6,390.84 | S194800 | 0 | S179400 | S179400 | S194800 | CA | Not Started | B | Stoll, Sean | L3 | BNL | Procurement | PP1 | MP103700 | Craig Woody | BNL | null | POM02.1.03.02.03.03 | C | 1.03 | 16710 | 003 | 1.03B | 03 | 02 | 3 |  |  |  |  |  |  |  |  |  |  |  |
| S194900 |  | Procure EMCAL Mechanical Parts for Final Sectors - Prepare & Send Solicitation |  | 10d | 2020-04-23 A | 2020-04-30 A | S194800 | 100% |  | 2020-05-18 | 2020-06-01 |  |  |  |  |  |  | S194900 | 0 | S179500 | S179500 |  | NOCA | Not Started |  | Stoll, Sean |  | BNL | Procurement | PP2 | MP103700 | Craig Woody | BNL |  | POM02.1.03.02.03.03 |  |  |  |  |  | 03 | 02 | 3 |  |  |  |  |  |  |  |  |  |  |  |
| S195000 |  | Procure EMCAL Mechanical Parts for Final Sectors - Vendor Responses |  | 10d | 2020-06-01 A | 2020-06-30 A | S194900 | 100% |  | 2020-07-23 | 2020-08-05 |  |  |  |  |  |  | S195000 | 0 | S179600 | S179600 |  | NOCA | Not Started |  | Stoll, Sean |  | BNL | Procurement | PP3 | MP103700 | Craig Woody | BNL |  | POM02.1.03.02.03.03 |  |  |  |  |  | 03 | 02 | 3 |  |  |  |  |  |  |  |  |  |  |  |
| S195100 |  | Procure EMCAL Mechanical Parts for Final Sectors - Vendor Selection |  | 20d | 2020-06-01 A | 2020-06-30 A | S195000 | 100% |  | 2020-08-06 | 2020-09-02 |  |  |  |  |  |  | S195100 | 0 | S179700 | S179700 |  | NOCA | Not Started |  | Stoll, Sean |  | BNL | Procurement | PP4 | MP103700 | Craig Woody | BNL |  | POM02.1.03.02.03.03 |  |  |  |  |  | 03 | 02 | 3 |  |  |  |  |  |  |  |  |  |  |  |
| S195500 |  | Procure EMCAL Cooling System for Final Sectors - Provide Requirements to Procurement |  | 5d | 2020-06-09 A | 2020-06-15 A | S194500, S194700 | 100% |  | 2020-08-24 | 2020-08-28 |  |  |  |  | PROF4 PO M [56 h] | 8,246.84 | S195500 | 0 | S180100 | S180100 | S195500 | CA | Not Started | B | Stoll, Sean | L3 | BNL | Procurement | PP1 | MP103800 | Craig Woody | BNL | null | POM02.1.03.02.03.03 | C | 1.03 | 16710 | 003 | 1.03B | 03 | 02 | 3 |  |  |  |  |  |  |  |  |  |  |  |
| S195600 |  | Procure EMCAL Cooling System for Final Sectors - Prepare & Send Solicitation |  | 10d | 2020-06-09 A | 2020-06-15 A | S195500 | 100% |  | 2020-08-31 | 2020-09-14 |  |  |  |  |  |  | S195600 | 0 | S180200 | S180200 |  | NOCA | Not Started |  | Stoll, Sean |  | BNL | Procurement | PP2 | MP103800 | Craig Woody | BNL |  | POM02.1.03.02.03.03 |  |  |  |  |  | 03 | 02 | 3 |  |  |  |  |  |  |  |  |  |  |  |
| S195700 |  | Procure EMCAL Cooling System for Final Sectors - Vendor Responses |  | 10d | 2020-06-25 A | 2020-07-30 A | S195600 | 100% |  | 2020-09-15 | 2020-09-28 |  |  |  |  |  |  | S195700 | 0 | S180300 | S180300 |  | NOCA | Not Started |  | Stoll, Sean |  | BNL | Procurement | PP3 | MP103800 | Craig Woody | BNL |  | POM02.1.03.02.03.03 |  |  |  |  |  | 03 | 02 | 3 |  |  |  |  |  |  |  |  |  |  |  |
| S195200 |  | Procure EMCAL Mechanical Parts for Final Sectors - Contract Award(s) | milestone | 0d | 2020-06-30 A | 2020-06-30 A | S195100, S101000, S101010 | 100% |  | 2020-08-24 | 2020-08-24 |  |  |  |  |  |  | S195200 | 0 | S179800 | S179800 |  | NOCA | Not Started | A-TEC | Stoll, Sean |  | BNL | Procurement | PP5 | MP103700 | Craig Woody | BNL |  | POM02.1.03.02.03.03 |  |  |  |  |  | 03 | 02 | 3 | UDF_G2 | UDF_G1 | L5 | Contract Award |  |  |  |  |  |  |  |
| S195300 |  | Procure EMCAL Mechanical Parts for Final Sectors - Contract/PO - Leadtime |  | 70d | 2020-06-30 A | 2020-11-30 A | S195200 SS, OBLG195210 SS | 100% |  | 2020-08-24 | 2020-12-04 |  |  |  |  |  |  | S195300 | 0 | S179900 | S179900 |  | NOCA | Not Started |  | Stoll, Sean |  | BNL | Fab & Assy | PP6 | MP103700 | Craig Woody | BNL |  | POM02.1.03.02.03.03 |  |  |  |  |  | 03 | 02 | 5 |  |  |  |  |  |  |  |  |  |  |  |
| S195800 |  | Procure EMCAL Cooling System for Final Sectors - Vendor Selection |  | 20d | 2020-07-29 A | 2020-07-30 A | S195700 | 100% |  | 2020-09-29 | 2020-10-27 |  |  |  |  |  |  | S195800 | 0 | S180400 | S180400 |  | NOCA | Not Started |  | Stoll, Sean |  | BNL | Procurement | PP4 | MP103800 | Craig Woody | BNL |  | POM02.1.03.02.03.03 |  |  |  |  |  | 03 | 02 | 3 |  |  |  |  |  |  |  |  |  |  |  |
| OBLG195910 |  | Procure EMCAL Cooling System for Final Sectors - Obligation |  | 1d | 2020-07-30 A | 2020-07-30 A | S195800, S101000 | 100% |  | 2020-09-24 | 2020-09-24 |  |  |  |  | Obligation Resource [82284.4 h] | 82,284.41 | S195900 | 0 | S180500 | S180500 |  |  | Not Started | A-TEC | Stoll, Sean |  | BNL | Procurement | PP5 | MP103800 | Craig Woody | BNL |  | POM02.1.03.02.03.03 |  |  |  |  |  | 03 |  |  |  |  | L5 |  | OBLG |  |  |  |  |  |  |
| S194500 |  | Revise sector assembly procedure based on preproduction Sector 1-12 fabrication |  | 20d | 2020-07-30 A | 2020-07-30 A | S194200 SS+5d | 100% |  | 2020-05-15 | 2020-06-12 |  |  |  |  | PROF4 PO M [144 h] | 21,206.16 | S194500 | 0 | S179200 | S179200 | S194500 | CA | Not Started | B | Stoll, Sean | L3 | BNL | Fab & Assy |  |  | Craig Woody | BNL | null | POM02.1.03.02.03.03 | A | 1.03 | 16710 | 003 | 1.03B | 03 | 02 | 5 |  |  |  |  |  |  |  |  |  |  |  |
| S194600 |  | Production Readiness Review - EMCal Sectors 13-63 |  | 5d | 2020-07-30 A | 2020-07-30 A | S194500 | 100% |  | 2020-09-17 | 2020-09-23 |  |  |  |  | PROF4 PO E [40 h]; SCI3 PO PM [40 h]; SCI 4 PO [80 h] | 29,247.42 | S194600 | 0 | S179300 | S179300 | S194600 | CA | Not Started | B | Stoll, Sean | L2 | BNL | Fab & Assy |  |  | Craig Woody | BNL | null | POM02.1.03.02.03.03 | A | 1.03 | 16710 | 003,004 | 1.03B | 03 | 02 | 5 |  |  |  |  |  |  |  |  |  |  |  |
| S194700 |  | EMCal Production Readiness Review Blocks/Modules/Sectors Complete | milestone | 0d | 2020-07-30 A | 2020-07-30 A | S194600 FF | 100% |  | 2020-09-23 | 2020-09-23 |  |  |  |  |  |  | S194700 | 0 | S179300 | S179350 |  | NOCA | Not Started |  | Stoll, Sean | L2 | BNL | Fab & Assy |  |  | Craig Woody | BNL | null | POM02.1.03.02.03.03 |  |  |  |  |  | 03 | 02 | 5 | UDF_G2 | UDF_G1 | L2 |  |  | 2020-07-31 | 1 | PMP_1x |  |  |  |
| S195900 |  | Procure EMCAL Cooling System for Final Sectors - Contract Award(s) | milestone | 0d | 2020-07-31 A | 2020-07-31 A | S195800, S101000 | 100% |  | 2020-10-28 | 2020-10-28 |  |  |  |  |  |  | S195900 | 0 | S180500 | S180500 |  | NOCA | Not Started | A-TEC | Stoll, Sean |  | BNL | Procurement | PP5 | MP103800 | Craig Woody | BNL |  | POM02.1.03.02.03.03 |  |  |  |  |  | 03 | 02 | 3 | UDF_G2 | UDF_G1 | L5 | Contract Award |  |  |  |  |  |  |  |
| S195400 |  | Procure EMCAL Mechanical Parts for Final Sectors - Delivery Acceptance |  | 5d | 2020-09-14 A | 2021-06-14 | S195300 | 90% | 10d | 2021-01-04 | 2021-01-08 | 0d |  | start on or after 2021-01-04 | 2021-06-14 | Material (Purchase (1st $2M) [251357 h] | 291,746.13 | S195400 | 0 | S180000 | S180000 | S195400 | CA | Not Started | A-TEC | Stoll, Sean | M4 | BNL | Fab & Assy | PP6 | MP103700 | Craig Woody | BNL | TEC | POM02.1.03.02.03.03 | C | 1.03 | 59709 | 015 | 1.03A | 03 | 02 | 5 | UDF_G1 | UDF_G1 |  | Delivery | FAB |  |  |  | 291746.126109 | 1 |  |
| OBLG195210 |  | Procure EMCAL Mechanical Parts for Final Sectors - Obligation |  | 1d | 2020-10-15 A | 2020-11-02 A | S195100, S101000, S101010 | 100% |  | 2020-11-02 | 2020-11-02 |  |  |  |  | Obligation Resource [291746 h] | 291,746.17 | S195200 | 0 | S179800 | S179800 |  |  | Not Started | A-TEC | Stoll, Sean |  | BNL | Procurement | PP5 | MP103700 | Craig Woody | BNL |  | POM02.1.03.02.03.03 |  |  |  |  |  | 03 |  |  |  |  | L5 |  | OBLG |  |  |  |  |  |  |
| S196000 |  | Procure EMCAL Cooling System for Final Sectors - Contract/PO - Leadtime |  | 70d | 2020-12-22 A | 2021-02-26 A | S195900 SS, OBLG195910 SS | 100% |  | 2021-01-12 | 2021-04-21 |  |  |  |  |  |  | S196000 | 0 | S180600 | S180600 |  | NOCA | Not Started |  | Stoll, Sean |  | BNL | Fab & Assy | PP6 | MP103800 | Craig Woody | BNL |  | POM02.1.03.02.03.03 |  |  |  |  |  | 03 | 02 | 5 |  |  |  |  |  |  |  |  |  |  |  |
| S196910 |  | Technical support labor for EMCal assembly |  | 257d | 2021-01-04 A | 2022-01-12 |  | 42% | 154d | 2021-02-01 | 2022-02-09 | 260d | 0d | start on or after 2021-01-04 | 2022-01-12 | TECH1 [3520 h] | 281,618.43 | S196100 | 0 | S180700 | S180700 | S196910 | CA | Not Started | A-TEC | Stoll, Sean | M4 | BNL | Fab & Assy | PP6 | MP103800 | Craig Woody | BNL | TEC | POM02.1.03.02.03.03 | C | 1.03 | 59709 | 020 | 1.03A | 03 | 02 | 5 | UDF_G1 | UDF_G1 |  | Delivery | FAB |  |  |  | 82284.392789 | 1 |  |
| S196200 |  | Build mechanical enclosures for final sectors |  | 60d | 2021-01-12 A | 2021-06-14 | S195300 SS+40d, S195400 FF | 25% | 10d | 2021-01-12 | 2021-04-07 | 0d |  |  | 2021-06-14 | TECH3 PO M [720 h] | 84,632.98 | S196200 | 0 | S180800 | S180800 | S196200 | CA | Not Started | B | Stoll, Sean | L4 | BNL | Fab & Assy |  |  | Craig Woody | BNL | null | POM02.1.03.02.03.03 | C | 1.03 | 16710 |  | 1.03B | 03 | 02 | 5 |  |  |  |  |  |  |  |  |  |  |  |
| S196300 |  | Build mechanical fixtures for final sectors |  | 60d | 2021-01-12 A | 2021-06-14 | S195300 SS+40d | 45% | 10d | 2021-01-12 | 2021-04-07 | 0d |  |  | 2021-06-14 | TECH3 PO M [720 h] | 84,632.98 | S196300 | 0 | S180900 | S180900 | S196300 | CA | Not Started | B | Stoll, Sean | L4 | BNL | Fab & Assy |  |  | Craig Woody | BNL | null | POM02.1.03.02.03.03 | C | 1.03 | 16710 |  | 1.03B | 03 | 02 | 5 |  |  |  |  |  |  |  |  |  |  |  |
| S196400 |  | Build cooling system for final sectors |  | 60d | 2021-01-12 A | 2021-06-14 | S196000 SS+40d, S196100 FF | 25% | 10d | 2021-03-02 | 2021-05-24 | 0d |  |  | 2021-06-14 | PROF4 PO M [180 h] | 27,302.93 | S196400 | 0 | S181000 | S181000 | S196400 | CA | Not Started | B | Stoll, Sean | L4 | BNL | Fab & Assy |  |  | Craig Woody | BNL | null | POM02.1.03.02.03.03 | C | 1.03 | 16710 |  | 1.03B | 03 | 02 | 5 |  |  |  |  |  |  |  |  |  |  |  |
| S196100 |  | Procure EMCAL Cooling System for Final Sectors - Delivery Acceptance |  | 5d | 2021-01-18 A | 2021-06-14 | S196000 | 35% | 10d | 2021-04-22 | 2021-04-28 | 0d |  | start on or after 2021-02-08 | 2021-06-14 | Material (Purchase (1st $2M) [70893 h] | 82,284.39 | S196100 | 0 | S180700 | S180700 | S196100 | CA | Not Started | A-TEC | Stoll, Sean | M4 | BNL | Fab & Assy | PP6 | MP103800 | Craig Woody | BNL | TEC | POM02.1.03.02.03.03 | C | 1.03 | 59709 | 015 | 1.03A | 03 | 02 | 5 | UDF_G1 | UDF_G1 |  | Delivery | FAB |  |  |  | 82284.392789 | 1 |  |
| S196500 |  | Install modules in final sectors |  | 248d | 2021-01-26 A | 2022-02-03 | S188200 SS, S196200 SS, S196300 SS, S188200 FF | 25% | 169d | 2021-01-26 | 2022-01-21 | 0d |  |  | 2022-02-03 | PROF4 PO E [462 h]; TECH3 PO M [1383 h] | 234,725.91 | S196500 | 0 | S181100 | S181100 | S196500 | CA | Not Started | B | Stoll, Sean | L4 | BNL | Fab & Assy |  |  | Craig Woody | BNL | null | POM02.1.03.02.03.03 | C | 1.03 | 16710 | 004 | 1.03B | 03 | 02 | 5 |  |  |  |  |  |  |  |  |  |  | Yes |
| S196700 |  | Install readout electronics on final sectors |  | 209d | 2021-02-22 A | 2022-02-04 | S229400 SS+1d, S196600 FF+1d, S230200 SS+1d, S229405 SS+1d, S230205 SS+1d, S196500 FF | 25% | 170d | 2021-03-24 | 2022-01-24 | 0d |  |  | 2022-02-04 | TECH3 PO M [1383 h]; PROF4 PO E [462 h] | 235,147.91 | S196700 | 0 | S181200 | S181200 | S196700 | CA | Not Started | B | Stoll, Sean | L4 | BNL | Fab & Assy |  |  | Craig Woody | BNL | null | POM02.1.03.02.03.03 | C | 1.03 | 16710 | 004 | 1.03B | 03 | 02 | 5 |  |  |  |  |  |  |  |  |  |  | Yes |
| S196800 |  | Install cables & cooling system on final sectors |  | 208d | 2021-02-22 A | 2022-02-04 | S196400 SS, S196700 SS+1d | 25% | 170d | 2021-03-25 | 2022-01-24 | 0d |  |  | 2022-02-04 | PROF4 PO E [462 h]; PROF4 PO M [1728 h]; TECH3 PO M [1383 h] | 500,103.4 | S196800 | 0 | S181300 | S181300 | S196800 | CA | Not Started | B | Stoll, Sean | L4 | BNL | Fab & Assy |  |  | Craig Woody | BNL | null | POM02.1.03.02.03.03 | C | 1.03 | 16710 | 004 | 1.03B | 03 | 02 | 5 |  |  |  |  |  |  |  |  |  |  | Yes |
| S196900 |  | Test final sectors with LEDs & cosmic rays |  | 208d | 2021-02-23 A | 2022-02-04 | S196800 SS+1d | 8% | 170d | 2021-03-23 | 2022-01-20 | 0d |  |  | 2022-02-04 | PROF4 PO E [462 h]; TECH3 PO E [462 h]; STUDENT Other - Unpaid [4608 h] | 125,693.3 | S196900 | 0 | S181400 | S181400 | S196900 | CA | Not Started | B_T | Stoll, Sean | L3 | BNL | Test_Components |  |  | Craig Woody | BNL | null | POM02.1.03.02.03.03 | C | 1.03 | 16710 | 004 | 1.03B | 03 | 02 | 7 |  |  |  |  |  |  |  |  |  |  | Yes |
| S197000 |  | Repair or rework any sectors as required |  | 208d | 2021-03-16 A | 2022-02-04 | S196900 SS+1d, S196900 FF | 29% | 147d | 2021-04-12 | 2022-02-09 | 0d |  |  | 2022-02-01 | PROF4 PO M [231 h]; TECH3 PO M [462 h]; STUDENT Other - Unpaid [2304 h]; SCI 4 PO [462 h]; PROF4 PO E [231 h]; TECH3 PO E [231 h] | 252,650.88 | S197000 | 0 | S181500 | S181500 | S197000 | CA | Not Started | B_T | Stoll, Sean | L4 | BNL | Fab & Assy |  |  | Craig Woody | BNL | null | POM02.1.03.02.03.03 | A | 1.03 | 16710 | 003 | 1.03B | 03 | 02 | 5 |  |  |  |  |  |  |  |  |  |  | Yes |
| S196600 |  | EMCal Modules Complete | milestone | 0d | 2022-02-03 | 2022-02-03 | S196500 FF |  |  |  |  | 0d |  |  |  |  |  | S196600 | 0 | S181100 | S181150 |  | NOCA | Not Started |  | Stoll, Sean | L4 | BNL | Fab & Assy |  |  | Craig Woody | BNL | null | POM02.1.03.02.03.03 |  |  |  |  |  | 03 | 02 | 5 | UDF_G3 | UDF_G1 | L2 |  |  |  |  |  |  |  |  |
| S197100 |  | EMCal Sectors Complete | milestone | 0d | 2022-02-04 | 2022-02-04 | S197000 FF, S194400 FF |  |  |  |  | 0d |  |  |  |  |  | S197100 | 0 | S181500 | S181550 |  | NOCA | Not Started |  | Stoll, Sean | L4 | BNL | Fab & Assy |  |  | Craig Woody | BNL | null | POM02.1.03.02.03.03 |  |  |  |  |  | 03 | 02 | 5 | UDF_G3 | UDF_G1 | L2 |  |  |  |  |  |  |  |  |
| S197300 |  | EMCal Ready to Install | milestone | 0d | 2022-02-04 | 2022-02-04 | S197100, S196900 |  |  |  |  | 0d |  |  |  |  |  | S197300 | 0 | S181700 | S181700 |  | NOCA | Not Started |  | Stoll, Sean |  | BNL | Fab & Assy |  |  | Craig Woody | BNL |  | POM02.1.03.02.03.03 |  |  |  |  |  | 03 | 02 | 5 | UDF_G3 | UDF_G1 | L2 |  |  | 2022-02-04 | -1 | PMP_1x |  |  |  |

Notes:
- S194800: BNL_UDF_Status Comments: 190315 ELM EVT / BNL_UDF_Adhoc Comments: 180330 ELM pred per GRY / BNL_UDF_Old Activity Name 181221: Procure EMCAL Mechanical Parts for Final Sectors - Provide Requirements to Procurement
- S194900: BNL_UDF_Adhoc Comments: 180330 ELM dur per GRY / BNL_UDF_Old Activity Name 181221: Procure EMCAL Mechanical Parts for Final Sectors - Prepare & Send Solicitation
- S195000: BNL_UDF_Old Activity Name 181221: Procure EMCAL Mechanical Parts for Final Sectors - Vendor Responses
- S195100: BNL_UDF_Old Activity Name 181221: Procure EMCAL Mechanical Parts for Final Sectors - Vendor Selection
- S195500: BNL_UDF_Status Comments: 190315 ELM EVT / BNL_UDF_Adhoc Comments: 180330 ELM pred per GRY / BNL_UDF_Old Activity Name 181221: Procure EMCAL Cooling System for Final Sectors - Provide Requirements to Procurement
- S195600: BNL_UDF_Adhoc Comments: 180330 ELM dur per GRY / BNL_UDF_Old Activity Name 181221: Procure EMCAL Cooling System for Final Sectors - Prepare & Send Solicitation
- S195700: BNL_UDF_Old Activity Name 181221: Procure EMCAL Cooling System for Final Sectors - Vendor Responses
- S195200: BNL_UDF_Adhoc Comments: RG set constraint to push obligation across fiscal boundary, must verify with L2 / BNL_UDF_Old Activity Name 181221: Procure EMCAL Mechanical Parts for Final Sectors - Contract Award(s)
- S195300: BNL_UDF_Old Activity Name 181221: Procure EMCAL Mechanical Parts for Final Sectors - Contract/PO - Leadtime
- S195800: BNL_UDF_Old Activity Name 181221: Procure EMCAL Cooling System for Final Sectors - Vendor Selection
- OBLG195910: BNL_UDF_Old Activity Name 181221: Procure EMCAL Cooling System for Final Sectors - Contract Award(s)
- S194500: BNL_UDF_Status Comments: 190315 DurType to align with EVT / BNL_UDF_Adhoc Comments: 180411 ELM pred/succ per GRY / BNL_UDF_Old Activity Name 181221: Revise sector assembly procedure based on preproduction Sector 1-12 fabrication
- S194600: General Comments: 180420 GYoung: concerning Production Readiness / Review - for Sectors, also links back thru epoxy / above / BNL_UDF_Status Comments: 190522 IVS new name; 190415 ELM name per GRY; 19315 DurType to align with EVT / BNL_UDF_Old Activity Name 181221: Readiness Review for final sector 13-64 fabrication
- S194700: General Comments: 180420 GYoung: concerning Production Readiness / Review - for Sectors, also links back thru epoxy / above / BNL_UDF_Old Activity Name 181221: EMCal Production Readiness Review Blocks/Modules/Sectors Complete
- S195900: BNL_UDF_Old Activity Name 181221: Procure EMCAL Cooling System for Final Sectors - Contract Award(s)
- S195400: BNL_UDF_Adhoc Comments: 180410 ELM pred/succ per GRY / BNL_UDF_Old Activity Name 181221: Procure EMCAL Mechanical Parts for Final Sectors - Delivery Acceptance
- OBLG195210: BNL_UDF_Adhoc Comments: RG set constraint to push obligation across fiscal boundary, must verify with L2 / BNL_UDF_Old Activity Name 181221: Procure EMCAL Mechanical Parts for Final Sectors - Contract Award(s)
- S196000: BNL_UDF_Old Activity Name 181221: Procure EMCAL Cooling System for Final Sectors - Contract/PO - Leadtime
- S196910: BNL_UDF_Status Comments: 190415 ELM BNLU per GRY / BNL_UDF_Adhoc Comments: 180410 ELM pred/succ per GRY / BNL_UDF_Old Activity Name 181221: Procure EMCAL Cooling System for Final Sectors - Delivery Acceptance
- S196200: Scheduler's Notes: 180413 ELM per GRY: / assume 2 people do this / BNL_UDF_Adhoc Comments: 180410 ELM pred/succ per GRY; 180410 ELM pred/succ per GRY; 180405 ELM rsrc per GRY / BNL_UDF_Old Activity Name 181221: Build mechanical enclosures for final sectors
- S196300: Scheduler's Notes: 180413 ELM per GRY: / assume 2 people do this / BNL_UDF_Adhoc Comments: 180410 ELM pred/succ per GRY; 180410 ELM pred/succ per GRY; 180405 ELM rsrc per GRY / BNL_UDF_Old Activity Name 181221: Build mechanical fixtures for final sectors
- S196400: BNL_UDF_Adhoc Comments: 180410 ELM pred/succ per GRY; 180410 ELM pred/succ per GRY; 180405 ELM rsrc per GRY / BNL_UDF_Old Activity Name 181221: Build cooling system for final sectors
- S196100: BNL_UDF_Status Comments: 190415 ELM BNLU per GRY / BNL_UDF_Adhoc Comments: 180410 ELM pred/succ per GRY / BNL_UDF_Old Activity Name 181221: Procure EMCAL Cooling System for Final Sectors - Delivery Acceptance
- S196500: Scheduler's Notes: 180413 ELM per GRY: / assume 2 people do this / BNL_UDF_Status Comments: 190614 ELM rel, dur per GRY; 190418 ELM BLU per GRY / BNL_UDF_Adhoc Comments: 180416 ELM pred/succ per GRY; 180410 ELM pred/succ per GRY; 180405 ELM rsrc per GRY / BNL_UDF_Old Activity Name 181221: Install modules in final sectors
- S196700: Scheduler's Notes: 180413 ELM per GRY: / assume 2 people do this / BNL_UDF_Status Comments: 190614 ELM rel, dur per GRY; 190418 ELM BLU per GRY / BNL_UDF_Adhoc Comments: 180416 ELM pred/succ per GRY; 180405 ELM rsrc per GRY / BNL_UDF_Old Activity Name 181221: Install readout electronics on final sectors
- S196800: Scheduler's Notes: 180413 ELM per GRY: / assume 2 people do this / BNL_UDF_Status Comments: 190614 ELM dur per GRY; 190418 ELM BLU per GRY / BNL_UDF_Adhoc Comments: 180416 ELM pred/succ per GRY; 180405 ELM rsrc per GRY / BNL_UDF_Old Activity Name 181221: Install cables & cooling system on final sectors
- S196900: BNL_UDF_Status Comments: 190614 ELM dur per GRY; 190418 ELM BLU per GRY / BNL_UDF_Adhoc Comments: 180416 ELM pred/succ per GRY; 180410 ELM pred/succ per GRY; 180405 ELM rsrc per GRY / BNL_UDF_Old Activity Name 181221: Test final sectors with LEDs & cosmic rays
- S197000: BNL_UDF_Status Comments: 190614 ELM dur per GRY; 190613 IVS move to 2.X; 190315 DurType to align with EVT / BNL_UDF_Adhoc Comments: 180412 pred/succ, dur per GRY; 180405 ELM rsrc per GRY / BNL_UDF_Old Activity Name 181221: Repair or rework any sectors as required
- S196600: Scheduler's Notes: 180413 ELM per GRY: / assume 2 people do this / BNL_UDF_Adhoc Comments: 180416 ELM pred/succ per GRY; 180410 ELM pred/succ per GRY; 180405 ELM rsrc per GRY / BNL_UDF_Old Activity Name 181221: EMCal Modules Complete
- S197100: BNL_UDF_Adhoc Comments: 180412 pred/succ, dur per GRY; 180405 ELM rsrc per GRY / BNL_UDF_Old Activity Name 181221: EMCal Sectors Complete
- S197300: BNL_UDF_Old Activity Name 181221: EMCal Ready to Install

| ID | WBS | Activity | Type | Duration | Start | Finish | Predecessors | Complete | Planned start | Planned finish | Total float | Free float | Constraint | Resources | Cost | BNL_UDF_Status Comments | BNL_UDF_Temp Text 01 | BNL_UDF_Percent Complete | BNL_UDF_Old Activity ID 181221 | BNL_Cobra WP | RG Check | BNL_Activity Status | BNL_Fund Source | BNL_Estimator | BNL_Cost Basis | BNL_Location | BNL_EDIA | BNL_CAM | BNL_Institution | BNL_OPC TEC (deprecated) | BNL_WBS | BNL_Actuals | BNL_FY | BNL_EVT | BNL_Master Control Account | BNL_Account Number | BNL_PCR ID | BNL_Cobra Control Account | BNL_WBS_Hierarchical | Completed | Indicator - Procurement | BNL_UDF_OPC TEC (deprecated) | BNL_UDF_Temp Text 02 | BNL_Split Activity | BNL_UDF_Adhoc Comments | BNL_Proc Sig Phase | BNL_Proc Sig | Indicator - Float | BNL_Milestone Level | BNL_UDF_Exclude | SPH Proc Register | BNL_Obligation | BNL_UDF_Remaining Tot Cost | BNL_UDF_Percent_remaining | Variance | BNL_UDF_PCR_Labor_Delta | BNL_UDF_PCR_Direct$_Delta | BNL_UDF_PCR_TotCost_Delta | Target Milestone Date | PMP Milestones |
| --- | --- | --- | --- | --- | --- | --- | --- | --- | --- | --- | --- | --- | --- | --- | --- | --- | --- | --- | --- | --- | --- | --- | --- | --- | --- | --- | --- | --- | --- | --- | --- | --- | --- | --- | --- | --- | --- | --- | --- | --- | --- | --- | --- | --- | --- | --- | --- | --- | --- | --- | --- | --- | --- | --- | --- | --- | --- | --- | --- | --- |
|  | 04 | **HCal** |  |  | 2017-02-01 | 2021-11-19 |  |  |  |  |  |  |  |  |  |  |  |  |  |  |  |  |  |  |  |  |  |  |  |  |  |  |  |  |  |  |  |  |  |  |  |  |  |  |  |  |  |  |  |  |  |  |  |  |  |  |  |  |  |  |
| S197400 |  | Actuals - Labor - sPHENIX HCal FY17 |  | 169d | 2017-02-01 A | 2017-09-29 A | S100090 SS | 100% |  |  |  |  |  | Actual Labor [1556.52 h] | 260,083.43 | 190315 DurType to align with EVT | S197400 | 100 | S338700 | S197400 | CA | Completed | B | Lajoie, John | L1 | ISU | Design | John Lajoie | ISU | null | POM02.1.04 | Yes | 2017 | A | 1.04 | 16711 | 003 | 1.04B | 04 | yes |  |  |  |  |  |  |  |  |  |  |  |  |  |  |  |  |  |  |  |  |
| S197600 |  | Actuals - Nonlabor - sPHENIX HCal FY17 |  | 169d | 2017-02-01 A | 2017-09-29 A | S100090 SS | 100% |  |  |  |  |  | Actual Nonlabor [2707.93 h] | 3,021 | 190315 DurType to align with EVT | S197600 | 100 | S339182 | S197600 | CA | Completed | A-OPC | Lajoie, John | M1 | ISU | Design | John Lajoie | ISU | OPC | POM02.1.04 | Yes | 2017 | A | 1.04 | 16703 | 003 | 1.04A | 04 | yes | UDF_G3 |  |  |  |  |  |  |  |  |  |  |  |  |  |  |  |  |  |  |  |
| S197500 |  | Actuals - Labor - sPHENIX HCal FY18 |  | 249d | 2017-10-02 A | 2018-09-28 A | S197400 | 100% |  |  |  |  |  | Actual Labor [3466.94 h] | 579,301.03 | 190315 DurType to align with EVT | S197500 | 100 | S339180 | S197500 | CA | Completed | B | Lajoie, John | L1 | ISU | Design | John Lajoie | ISU | null | POM02.1.04 | Yes | 2018 | A | 1.04 | 16711 | 003 | 1.04B | 04 | yes |  |  |  |  |  |  |  |  |  |  |  |  |  |  |  |  |  |  |  |  |
| S197700 |  | Actuals - Nonlabor - sPHENIX HCal FY18 |  | 249d | 2017-10-02 A | 2018-09-28 A | S197600 | 100% |  |  |  |  |  | Actual Nonlabor [127709 h] | 142,473.39 | 190315 DurType to align with EVT | S197700 | 100 | S339185 | S197700 | CA | Completed | A-OPC | Lajoie, John | M1 | ISU | Design | John Lajoie | ISU | OPC | POM02.1.04 | Yes | 2018 | A | 1.04 | 16703 | 003 | 1.04A | 04 | yes | UDF_G3 |  |  |  |  |  |  |  |  |  |  |  |  |  |  |  |  |  |  |  |
| S1001919 |  | Actuals - Nonlabor - sPHENIX HCal FY19M8 |  | 166d | 2018-10-01 A | 2019-05-31 A |  | 100% |  |  |  |  |  | Actual Nonlabor [16811.6 h] | 18,547.64 | 190315 DurType to align with EVT | S197700 | 100 | S339185 | S1001919 | CA | Completed | A-TEC | Lajoie, John | M1 | ISU | Design | John Lajoie | ISU | TEC | POM02.1.04 | Yes | 2019 | A | 1.04 | 59712 | 003 | 1.04A | 04 | yes | UDF_G3 |  |  |  |  |  |  |  |  |  |  |  |  |  |  |  |  |  |  |  |
| S197510 |  | Actuals - Labor - sPHENIX HCal FY19M8 |  | 166d | 2018-10-01 A | 2019-05-31 A | S197500 | 100% |  |  |  |  |  | Actual Labor [1570.66 h] | 262,446.12 | 190315 DurType to align with EVT | S197500 | 100 | S339180 | S197510 | CA | Completed | B | Lajoie, John | L1 | ISU | Design | John Lajoie | ISU | null | POM02.1.04 | Yes | 2019 | A | 1.04 | 16711 | 003 | 1.04B | 04 | yes |  |  |  |  |  |  |  |  |  |  |  |  |  |  |  |  |  |  |  |  |
| S197710 |  | Actuals - Nonlabor - sPHENIX HCal FY19M8 |  | 166d | 2018-10-01 A | 2019-05-31 A | S197700 | 100% |  |  |  |  |  | Actual Nonlabor [415146 h] | 458,015.62 | 190315 DurType to align with EVT | S197700 | 100 | S339185 | S197710 | CA | Completed | A-OPC | Lajoie, John | M1 | ISU | Design | John Lajoie | ISU | OPC | POM02.1.04 | Yes | 2019 | A | 1.04 | 16703 | 003 | 1.04A | 04 | yes | UDF_G3 |  |  |  |  |  |  |  |  |  |  |  |  |  |  |  |  |  |  |  |
|  | 01 | **Inner HCAL Support Structure & Support Rings** |  |  | 2018-07-02 | 2021-11-19 |  |  |  |  |  |  |  |  |  |  |  |  |  |  |  |  |  |  |  |  |  |  |  |  |  |  |  |  |  |  |  |  |  |  |  |  |  |  |  |  |  |  |  |  |  |  |  |  |  |  |  |  |  |  |
| S197800 |  | Design Inner HCAL Support Structure |  | 40d | 2018-07-02 A | 2018-08-27 A | S100500 | 100% |  |  |  |  |  |  |  |  | S197800 | 100 | S181800 |  | NOCA | Completed |  | Pontieri, Chris | L5 | ISU | Design | John Lajoie | ISU | null | POM02.1.04.01 |  |  | C |  |  |  |  | 01 | yes |  | S181800 | 0 |  |  |  |  |  |  |  |  |  |  |  |  |  |  |  |  |  |
| S198300 |  | Design Inner HCAL Support Rings FY18 |  | 63d | 2018-07-02 A | 2018-09-28 A | S100500 | 100% |  |  |  |  |  |  |  |  | S198300 | 100 | S182800 |  | NOCA | Completed |  | Pontieri, Chris | L5 | ISU | Design | John Lajoie | ISU | null | POM02.1.04.01 |  |  |  |  |  |  |  | 01 | yes |  | S182800 | 0 | FY18 |  |  |  |  |  |  |  |  |  |  |  |  |  |  |  |  |
| S197801 |  | Preliminary Design Review - Inner HCAL Support Structure | milestone | 0d | 2018-08-27 A | 2018-08-27 A | S197800 FF | 100% |  |  |  |  |  |  |  | 190508 ELM add per GRY | S197800 | 100 | S181800 |  | NOCA | Completed |  | Pontieri, Chris | L5 | ISU | Design | John Lajoie | ISU | null | POM02.1.04.01 |  |  | C |  |  | 004 |  | 01 | yes |  | S181800 | 0 |  |  |  |  |  |  |  |  |  |  |  |  |  |  |  |  |  |
| S198400 |  | Design Inner HCAL Support Rings FY20 |  | 22d | 2019-05-01 A | 2019-05-31 A | S198300, S101010 | 100% |  |  |  |  |  |  |  | 190605 IVS remove FY20 funding pred. | S198400 | 0 | S182850 |  | NOCA | Completed | B | Pontieri, Chris | L5 | ISU | Design | John Lajoie | ISU | null | POM02.1.04.01 |  |  | C |  | 16711 | 005 |  | 01 | yes |  | S182800 | 0 | FY19 |  |  |  |  |  |  |  |  |  |  |  |  |  |  |  |  |
| S198402 |  | Design Inner HCAL Support Rings FY20 Split |  | 23d | 2019-10-01 A | 2020-03-18 A | S198400 | 100% | 2019-10-01 | 2019-11-01 |  |  |  | PROF4 PO M [21 h]; TECH3 PO D [51 h] | 8,912.79 | 190605 IVS remove FY20 funding pred. | S198400 | 0 | S182850 | S198402 | CA | In Progress | B | Pontieri, Chris | L5 | ISU | Design | John Lajoie | ISU | null | POM02.1.04.01 |  |  | C | 1.04 | 16711 | 005 | 1.04B | 01 |  |  | S182800 | 0 | FY19 |  |  |  |  |  |  |  |  |  |  |  |  |  |  |  |  |
| S198401 |  | Preliminary Design Review - Inner HCAL Support Rings | milestone | 0d | 2020-03-18 A | 2020-03-18 A | S198402 | 100% |  |  |  |  |  |  |  | 190508 ELM add per GRY | S198400 | 0 | S182850 |  | NOCA | Not Started |  | Pontieri, Chris | L5 | ISU | Design | John Lajoie | ISU | null | POM02.1.04.01 |  |  | C |  | 16711 | 004 |  | 01 |  |  | S182800 | 0 | FY19 |  |  |  |  |  |  |  |  |  |  |  |  |  |  |  |  |
| S197900 |  | Final Design Review. Procurement Readiness Review - Inner HCAL Support Structure |  | 3d | 2020-03-24 A | 2020-03-24 A | S197801 FS+240d | 100% | 2020-03-02 | 2020-03-04 |  |  | start on or after 2020-02-12 | PROF4 PO M [16 h]; SCI3 PO [16 h]; TECH3 PO D [16 h] | 6,935.89 | 190508 ELM dur; name per GRY; 190415 ELM name per GRY | S197900 | 0 | S181900 | S197900 | CA | Not Started | B | Pontieri, Chris | L5 | ISU | Test_Components | John Lajoie | ISU | null | POM02.1.04.01 |  |  | C | 1.04 | 16711 | 004 | 1.04B | 01 |  |  | S181900 | 0 |  |  |  |  |  |  |  |  |  |  |  |  |  |  |  |  |  |
| S198500 |  | Final Design Review. Procurement Readiness Review - Inner HCAL Support Rings |  | 2d | 2020-03-24 A | 2020-05-29 A | S198401 | 100% | 2020-03-19 | 2020-03-20 |  |  |  | PROF4 PO M [16 h]; SCI3 PO [16 h]; TECH3 PO D [16 h] | 6,935.89 | 190508 ELM name per GRY; 190415 ELM name per GRY | S198500 | 0 | S182900 | S198500 | CA | Not Started | B | Pontieri, Chris | L5 | ISU | Test_Components | John Lajoie | ISU | null | POM02.1.04.01 |  |  | C | 1.04 | 16711 | 004 | 1.04B | 01 |  |  | S182900 | 0 |  |  |  |  |  |  |  |  |  |  |  |  |  |  |  |  |  |
| S198000 |  | Address Issues from Internal Review Support Structure |  | 10d | 2020-03-25 A | 2020-05-29 A | S197900 | 100% | 2020-03-05 | 2020-03-18 |  |  |  | PROF4 PO M [8 h]; SCI3 PO [8 h]; TECH3 PO D [20 h] | 4,837.41 |  | S198000 | 0 | S182000 | S198000 | CA | Not Started | B | Pontieri, Chris | L5 | ISU | Fab & Assy | John Lajoie | ISU | null | POM02.1.04.01 |  |  | C | 1.04 | 16711 |  | 1.04B | 01 |  |  | S182000 | 0 |  |  |  |  |  |  |  |  |  |  |  |  |  |  |  |  |  |
| S198200 |  | Manufacture Inner HCAL Support Structure - Provide Requirements to Procurement |  | 5d | 2020-05-13 A | 2020-05-26 A | S198100 | 100% | 2020-06-01 | 2020-06-05 |  |  |  | SCI3 PO [14 h]; PROF4 PO M [20 h]; TECH3 PO D [40 h] | 9,919.67 |  | S198200 | 0 | S182740 | S198200 | CA | Not Started | B | Pontieri, Chris | L4 | ISU | Fab & Assy | John Lajoie | ISU | null | POM02.1.04.01 |  |  | C | 1.04 | 16711 |  | 1.04B | 01 |  |  |  | 0 |  | 180220 ELM add MP & PP Nos. | PP1 | MP202700 |  |  |  |  |  |  |  |  |  |  |  |  |  |
| S198600 |  | Address Issues from Internal Review of Inner HCAL Support Rings |  | 10d | 2020-05-20 A | 2020-05-28 A | S198500 | 100% | 2020-06-01 | 2020-06-12 |  |  |  | PROF4 PO M [8 h]; SCI3 PO [8 h]; TECH3 PO D [20 h] | 4,837.41 |  | S198600 | 0 | S183000 | S198600 | CA | Not Started | B | Pontieri, Chris | L4 | ISU | Test_Components | John Lajoie | ISU | null | POM02.1.04.01 |  |  | C | 1.04 | 16711 |  | 1.04B | 01 |  |  | S183000 | 0 |  |  |  |  |  |  |  |  |  |  |  |  |  |  |  |  |  |
| S198100 |  | Inner HCAL Support Structure Design Complete | milestone | 0d | 2020-05-29 A | 2020-05-29 A | S198000, S101000 | 100% |  |  |  |  |  |  |  |  | S198100 | 0 | S182100 |  | NOCA | Not Started |  | Pontieri, Chris |  | ISU | Design | John Lajoie | ISU |  | POM02.1.04.01 |  |  |  |  |  |  |  | 01 |  | UDF_G1 | S182100 | 0 |  |  |  |  | UDF_G3 | L5 |  |  |  |  |  |  |  |  |  |  |  |
| S198700 |  | Inner HCAL Support Rings Design Complete | milestone | 0d | 2020-06-30 A | 2020-06-30 A | S198600 | 100% | 2020-07-01 | 2020-07-01 |  |  |  |  |  |  | S198700 | 0 | S183100 |  | NOCA | Not Started |  | Pontieri, Chris |  | ISU | Design | John Lajoie | ISU |  | POM02.1.04.01 |  |  |  |  |  |  |  | 01 |  | UDF_G1 | S183100 | 0 |  |  |  |  | UDF_G3 | L5 |  |  |  |  |  |  |  |  |  |  |  |
| S198800 |  | Manufacture Inner HCAL Support Structure - Prepare & Send Solicitation |  | 20d | 2020-07-01 A | 2020-12-18 A | S198200 | 100% | 2020-07-01 | 2020-07-29 |  |  |  | PROF4 PO M [28 h]; SCI3 PO [7 h]; TECH3 PO D [40 h]; TECH3 PO M [8 h] | 10,806.02 |  | S198800 | 0 | S337300 | S198800 | CA | Not Started | B | Pontieri, Chris | L4 | ISU | Procurement | John Lajoie | ISU | null | POM02.1.04.01 |  |  | C | 1.04 | 16711 |  | 1.04B | 01 |  |  |  | 0 |  | 180220 ELM add MP & PP Nos. | PP2 | MP202700 |  |  |  |  |  |  |  |  |  |  |  |  |  |
| S199400 |  | Manufacture Inner HCAL Support Rings - Provide Requirements to Procurement |  | 5d | 2020-07-01 A | 2020-11-30 A | S198700 | 100% | 2020-07-01 | 2020-07-08 |  |  |  | SCI3 PO [28 h]; PROF4 PO M [88 h]; TECH3 PO D [88 h]; TECH3 PO M [80 h] | 36,950.8 |  | S199400 | 0 | S337540 | S199400 | CA | Not Started | B | Pontieri, Chris | L4 | ISU | Procurement | John Lajoie | ISU | null | POM02.1.04.01 |  |  | C | 1.04 | 16711 |  | 1.04B | 01 |  |  |  | 0 |  | 180410 ELM pred/succ per GRY | PP1 | MP201600 |  |  |  |  |  |  |  |  |  |  |  |  |  |
| S199500 |  | Manufacture Inner HCAL Support Rings - Prepare & Send Solicitation |  | 20d | 2020-09-23 A | 2020-11-30 A | S199400 | 100% | 2020-09-02 | 2020-09-30 |  |  |  |  |  |  | S199500 | 0 | S337580 |  | NOCA | Not Started |  | Pontieri, Chris |  | ISU | Procurement | John Lajoie | ISU |  | POM02.1.04.01 |  |  |  |  |  |  |  | 01 |  |  |  | 0 |  | 180410 ELM pred/succ per GRY; 180227 name change per GRY | PP2 | MP201600 |  |  | MP6LA |  |  |  |  |  |  |  |  |  |  |
| S199600 |  | Manufacture Inner HCAL Support Rings - Vendor Responses |  | 20d | 2020-12-01 A | 2020-12-29 A | S199500 | 100% |  |  |  |  |  |  |  |  | S199600 | 0 | S337620 |  | NOCA | Not Started |  | Pontieri, Chris |  | ISU | Procurement | John Lajoie | ISU |  | POM02.1.04.01 |  |  |  |  |  |  |  | 01 |  |  |  | 0 |  | 180410 ELM pred/succ per GRY; 180227 name change per GRY | PP3 | MP201600 |  |  | MP6LA |  |  |  |  |  |  |  |  |  |  |
| S198900 |  | Manufacture Inner HCAL Support Structure - Vendor Responses |  | 25d | 2020-12-21 A | 2020-12-23 A | S198800 | 100% | 2020-12-31 | 2021-02-05 |  |  |  |  |  |  | S198900 | 0 | S337340 |  | NOCA | Not Started |  | Pontieri, Chris |  | ISU | Procurement | John Lajoie | ISU |  | POM02.1.04.01 |  |  |  |  |  |  |  | 01 |  |  |  | 0 |  | 180220 ELM add MP & PP Nos. | PP3 | MP202700 |  |  |  |  |  |  |  |  |  |  |  |  |  |
| S199000 |  | Manufacture Inner HCAL Support Structure - Vendor Selection |  | 10d | 2020-12-24 A | 2020-12-28 A | S198900 | 100% | 2021-02-08 | 2021-02-22 |  |  |  | TECH3 PO M [40 h]; TECH3 PO D [40 h]; SCI3 PO [7 h]; PROF4 PO M [40 h] | 16,711.86 |  | S199000 | 0 | S337380 | S199000 | CA | Not Started | B | Pontieri, Chris | L4 | ISU | Procurement | John Lajoie | ISU | null | POM02.1.04.01 |  |  | C | 1.04 | 16711 |  | 1.04B | 01 |  |  |  | 0 |  | 180220 ELM add MP & PP Nos. | PP4 | MP202700 |  |  |  |  |  |  |  |  |  |  |  |  |  |
| S199700 |  | Manufacture Inner HCAL Support Rings - Vendor Selection |  | 10d | 2020-12-28 A | 2020-12-30 A | S199600 | 100% | 2020-12-30 | 2021-01-13 |  |  |  |  |  |  | S199700 | 0 | S337660 |  | NOCA | Not Started |  | Pontieri, Chris |  | ISU | Procurement | John Lajoie | ISU |  | POM02.1.04.01 |  |  |  |  |  |  |  | 01 |  |  |  | 0 |  | 180227 name change per GRY | PP4 | MP201600 |  |  | MP6LA |  |  |  |  |  |  |  |  |  |  |
| S199800 |  | Manufacture Inner HCAL Support Rings - Contract Award(s) | milestone | 0d | 2020-12-30 A | 2020-12-30 A | S199700 | 100% | 2021-01-14 | 2021-01-14 |  |  |  |  |  |  | S199800 | 0 | S337700 |  | NOCA | Not Started | A-TEC | Pontieri, Chris |  | ISU | Procurement | John Lajoie | ISU |  | POM02.1.04.01 |  |  |  |  |  |  |  | 01 |  | UDF_G1 |  | 0 |  |  | PP5 | MP201600 | UDF_G3 | L5 | MP6LA | Contract Award |  |  |  |  |  |  |  |  |  |
| S199100 |  | Manufacture Inner HCAL Support Structure - Contract Award(s) | milestone | 0d | 2020-12-31 A | 2020-12-31 A | S199000, S101015 | 100% | 2021-02-23 | 2021-02-23 |  |  |  |  |  |  | S199100 | 0 | S337420 |  | NOCA | Not Started | A-TEC | Pontieri, Chris |  | ISU | Procurement | John Lajoie | ISU |  | POM02.1.04.01 |  |  |  |  |  |  |  | 01 |  | UDF_G3 |  | 0 |  | 180220 ELM add MP & PP Nos. | PP5 | MP202700 | UDF_G3 | L5 |  | Contract Award |  |  |  |  |  |  |  |  |  |
| S199900 |  | Manufacture Inner HCAL Support Rings - Contract lead time |  | 32d | 2021-01-04 A | 2021-04-22 A | S199800 SS, OBLG199810 SS | 100% | 2021-01-04 | 2021-02-18 |  |  |  |  |  |  | S199900 | 0 | S337740 |  | NOCA | Not Started |  | Pontieri, Chris |  | ISU | Fab & Assy | John Lajoie | ISU |  | POM02.1.04.01 |  |  |  |  |  | 009 |  | 01 |  |  |  | 0 |  | 180410 ELM pred/succ per GRY | PP6 | MP201600 |  |  | MP6LA |  |  |  |  |  |  |  |  |  |  |
| OBLG199810 |  | Manufacture Inner HCAL Support Rings - Obligation |  | 1d | 2021-02-15 A | 2021-02-15 A | S199700 | 100% | 2021-03-01 | 2021-03-01 |  |  |  | Obligation Resource [56896.3 h] | 56,896.29 |  | S199800 | 0 | S337700 |  |  | Not Started | A-TEC | Pontieri, Chris |  | ISU | Procurement | John Lajoie | ISU |  | POM02.1.04.01 |  |  |  |  |  |  |  | 01 |  |  |  | 0 |  |  | PP5 | MP201600 |  | L5 | MP6LA |  | OBLG |  |  |  |  |  |  |  |  |
| S199200 |  | Manufacture Inner HCAL Support Structure - Contract lead time |  | 85d | 2021-02-15 A | 2021-05-28 A | S199100 SS, OBLG199110 SS | 100% | 2021-03-01 | 2021-06-28 |  |  |  |  |  |  | S199200 | 0 | S337460 |  | NOCA | Not Started |  | Pontieri, Chris |  | ISU | Fab & Assy | John Lajoie | ISU |  | POM02.1.04.01 |  |  |  |  |  |  |  | 01 |  |  |  | 0 |  | 180220 ELM add MP & PP Nos. | PP6 | MP202700 |  |  |  |  |  |  |  |  |  |  |  |  |  |
| S200000 |  | Manufacture Inner HCAL Support Rings - Delivery Acceptance |  | 0d | 2021-05-17 A | 2021-05-20 A | S199900 | 100% | 2021-06-01 | 2021-06-01 |  |  | start on or after 2021-05-28 | Material (Purchase (1st $2M) [127182 h] | 141,885.96 |  | S200000 | 0 | S337780 | S200000 | CA | Not Started | A-TEC | Pontieri, Chris | M5 | ISU | Fab & Assy | John Lajoie | ISU | TEC | POM02.1.04.01 |  |  | E | 1.04 | 59710 | 021 | 1.04A | 01 |  | UDF_G3 |  | 0 |  | 180411 ELM pred/succ per GRY | PP6 | MP201600 | UDF_G3 |  | MP6LA | Delivery | FAB | 58034.2155 | 1 |  |  |  |  |  |  |
| OBLG199110 |  | Manufacture Inner HCAL Support Structure - Obligation |  | 1d | 2021-06-01 | 2021-06-01 | S199000, S101015 |  |  |  | 413d | 0d |  | Obligation Resource [1077202 h] | 1,077,202.27 |  | S199100 | 0 | S337420 |  |  | Not Started | A-TEC | Pontieri, Chris |  | ISU | Procurement | John Lajoie | ISU |  | POM02.1.04.01 |  |  |  |  |  |  |  | 01 |  |  |  | 0 |  | 180220 ELM add MP & PP Nos. | PP5 | MP202700 |  | L5 |  |  | OBLG |  |  |  |  |  |  |  |  |
| S199300 |  | Manufacture Inner HCAL Support Structure - Delivery Acceptance 1 |  | 0d | 2021-08-09 | 2021-08-09 | S199200 |  |  |  | 366d |  | start on or after 2021-08-09 | Material (Purchase (1st $2M) [237500 h] | 264,958.21 |  | S199300 | 0 | S337500 | S199300 | CA | Not Started | A-TEC | Pontieri, Chris | M5 | ISU | Fab & Assy | John Lajoie | ISU | TEC | POM02.1.04.01 |  |  | K | 1.04 | 59710 | 022 | 1.04A | 01 |  | UDF_G2 |  | 0 |  | 180411 ELM pred/succ per GRY; 180220 ELM add MP & PP Nos. | PP6 | MP202700 | UDF_G3 |  |  | Delivery | FAB | 1077202.091003 | 1 |  |  |  |  |  |  |
| S199310 |  | Manufacture Inner HCAL Support Structure - Delivery Acceptance 2 |  | 5d | 2021-08-16 | 2021-08-20 |  |  |  |  | 356d |  | start on or after 2021-08-16 | Material (Purchase (1st $2M) [237500 h] | 264,958.21 |  | S199300 | 0 | S337500 | S199310 | CA | Not Started | A-TEC | Pontieri, Chris | M5 | ISU | Fab & Assy | John Lajoie | ISU | TEC | POM02.1.04.01 |  |  | K | 1.04 | 59710 | 022 | 1.04A | 01 |  | UDF_G3 |  | 0 |  | 180411 ELM pred/succ per GRY; 180220 ELM add MP & PP Nos. | PP6 | MP202700 | UDF_G3 |  |  |  | FAB |  |  | 0 | 0 | 237500 | 264958.211 |  |  |
| S199320 |  | Manufacture Inner HCAL Support Structure - Delivery Acceptance 3 |  | 5d | 2021-09-24 | 2021-09-30 |  |  |  |  | 328d |  | start on or after 2021-09-24 | Material (Purchase (1st $2M) [237500 h] | 264,958.21 |  | S199300 | 0 | S337500 | S199320 | CA | Not Started | A-TEC | Pontieri, Chris | M5 | ISU | Fab & Assy | John Lajoie | ISU | TEC | POM02.1.04.01 |  |  | K | 1.04 | 59710 | 022 | 1.04A | 01 |  | UDF_G3 |  | 0 |  | 180411 ELM pred/succ per GRY; 180220 ELM add MP & PP Nos. | PP6 | MP202700 | UDF_G3 |  |  |  | FAB |  |  | 0 | 0 | 237500 | 264958.211 |  |  |
| S199330 |  | Manufacture Inner HCAL Support Structure - Delivery Acceptance 4 |  | 5d | 2021-11-15 | 2021-11-19 |  |  |  |  | 6d | 0d | start on or after 2021-11-15 | Material (Purchase (1st $2M) [237500 h] | 264,958.21 |  | S199300 | 0 | S337500 | S199330 | CA | Not Started | A-TEC | Pontieri, Chris | M5 | ISU | Fab & Assy | John Lajoie | ISU | TEC | POM02.1.04.01 |  |  | K | 1.04 | 59710 | 022 | 1.04A | 01 |  | UDF_G3 |  | 0 |  | 180411 ELM pred/succ per GRY; 180220 ELM add MP & PP Nos. | PP6 | MP202700 | UDF_G1 |  |  |  | FAB |  |  | 0 | 0 | 237500 | 264958.211 |  |  |
| S200100 |  | Inner HCAL Support Structure Ready for Installation | milestone | 0d | 2021-11-19 | 2021-11-19 | S200000 FF, S199330 |  |  |  | 6d | 0d |  |  |  |  | S200100 | 0 | S337785 |  | NOCA | Not Started |  | Pontieri, Chris |  | BNL | Fab & Assy | John Lajoie | ISU |  | POM02.1.04.01 |  |  |  |  |  |  |  | 01 |  | UDF_G2 |  | 0 |  |  |  |  | UDF_G3 | L2 | MP6LA |  |  |  |  | -72 |  |  |  | 2021-08-09 | PMP_1x |

Notes:
- S197400: BNL_UDF_Old Activity Name 181221: Actuals - Labor - sPHENIX HCal FY17
- S197600: BNL_UDF_Old Activity Name 181221: Actuals - Nonlabor - sPHENIX HCal FY17
- S197500: BNL_UDF_Old Activity Name 181221: Actuals - Labor - sPHENIX HCal FY18
- S197700: BNL_UDF_Old Activity Name 181221: Actuals - Nonlabor - sPHENIX HCal FY18
- S1001919: BNL_UDF_Old Activity Name 181221: Actuals - Nonlabor - sPHENIX HCal FY18
- S197510: BNL_UDF_Old Activity Name 181221: Actuals - Labor - sPHENIX HCal FY18
- S197710: BNL_UDF_Old Activity Name 181221: Actuals - Nonlabor - sPHENIX HCal FY18
- S197800: BNL_UDF_Old Activity Name 181221: Design Inner HCAL Support Structure
- S198300: BNL_UDF_Old Activity Name 181221: Design Inner HCAL Support Rings FY18
- S197801: BNL_UDF_Old Activity Name 181221: Design Inner HCAL Support Structure
- S198400: BNL_UDF_Old Activity Name 181221: Design Inner HCAL Support Rings FY20
- S198402: BNL_UDF_Old Activity Name 181221: Design Inner HCAL Support Rings FY20
- S198401: BNL_UDF_Old Activity Name 181221: Design Inner HCAL Support Rings FY20
- S197900: BNL_UDF_Old Activity Name 181221: Internal Review of Inner HCAL Support Structure
- S198500: BNL_UDF_Old Activity Name 181221: Internal Review of Inner HCAL Support Rings
- S198000: BNL_UDF_Old Activity Name 181221: Address Issues from Internal Review Support Structure
- S198200: BNL_UDF_Old Activity Name 181221: Manufacture Inner HCAL Support Structure - Provide Requirements to Procurement
- S198600: BNL_UDF_Old Activity Name 181221: Address Issues from Internal Review of Inner HCAL Support Rings
- S198100: BNL_UDF_Old Activity Name 181221: Inner HCAL Support Structure Design Complete
- S198700: BNL_UDF_Old Activity Name 181221: Inner HCAL Support Rings Design Complete
- S198800: BNL_UDF_Old Activity Name 181221: Manufacture Inner HCAL Support Structure - Prepare & Send Solicitation
- S199400: BNL_UDF_Old Activity Name 181221: Manufacture Inner HCAL Support Rings - Provide Requirements to Procurement
- S199500: BNL_UDF_Old Activity Name 181221: Manufacture Inner HCAL Support Rings - Prepare & Send Solicitation
- S199600: BNL_UDF_Old Activity Name 181221: Manufacture Inner HCAL Support Rings - Vendor Responses
- S198900: BNL_UDF_Old Activity Name 181221: Manufacture Inner HCAL Support Structure - Vendor Responses
- S199000: BNL_UDF_Old Activity Name 181221: Manufacture Inner HCAL Support Structure - Vendor Selection
- S199700: BNL_UDF_Old Activity Name 181221: Manufacture Inner HCAL Support Rings - Vendor Selection
- S199800: BNL_UDF_Old Activity Name 181221: Manufacture Inner HCAL Support Rings - Contract Award(s)
- S199100: BNL_UDF_Old Activity Name 181221: Manufacture Inner HCAL Support Structure - Contract Award(s)
- S199900: BNL_UDF_Old Activity Name 181221: Manufacture Inner HCAL Support Rings - Contract lead time
- OBLG199810: BNL_UDF_Old Activity Name 181221: Manufacture Inner HCAL Support Rings - Contract Award(s)
- S199200: BNL_UDF_Old Activity Name 181221: Manufacture Inner HCAL Support Structure - Contract lead time
- S200000: BNL_UDF_Old Activity Name 181221: Manufacture Inner HCAL Support Rings - Delivery Acceptance
- OBLG199110: BNL_UDF_Old Activity Name 181221: Manufacture Inner HCAL Support Structure - Contract Award(s)
- S199300: BNL_UDF_Old Activity Name 181221: Manufacture Inner HCAL Support Structure - Delivery Acceptance
- S199310: BNL_UDF_Old Activity Name 181221: Manufacture Inner HCAL Support Structure - Delivery Acceptance
- S199320: BNL_UDF_Old Activity Name 181221: Manufacture Inner HCAL Support Structure - Delivery Acceptance
- S199330: BNL_UDF_Old Activity Name 181221: Manufacture Inner HCAL Support Structure - Delivery Acceptance
- S200100: BNL_UDF_Old Activity Name 181221: Inner HCAL Ready for Installation

| ID | WBS | Activity | Type | Duration | Start | Finish | Predecessors | Complete | Planned start | Planned finish | Constraint | Resources | Cost | BNL_UDF_Temp Text 01 | BNL_UDF_Percent Complete | BNL_UDF_OPC TEC (deprecated) | BNL_UDF_Temp Text 02 | BNL_UDF_Old Activity ID 181221 | RG Check | BNL_Activity Status | BNL_Estimator | BNL_Cost Basis | BNL_Location | BNL_EDIA | BNL_CAM | BNL_Institution | BNL_OPC TEC (deprecated) | BNL_WBS | BNL_EVT | BNL_WBS_Hierarchical | Completed | BNL_PCR ID | BNL_Milestone Level | BNL_UDF_Adhoc Comments | BNL_UDF_Temp Date 01 | BNL_Fund Source | BNL_Account Number | Cost = Awarded Proc or Mgmt | BNL_Proc Sig Phase | BNL_Proc Sig | BNL_Cobra WP | BNL_Master Control Account | BNL_Cobra Control Account | Indicator - Procurement | Indicator - Float | BNL_Obligation | SPH Proc Register | BNL_UDF_Remaining Tot Cost | BNL_UDF_Percent_remaining |
| --- | --- | --- | --- | --- | --- | --- | --- | --- | --- | --- | --- | --- | --- | --- | --- | --- | --- | --- | --- | --- | --- | --- | --- | --- | --- | --- | --- | --- | --- | --- | --- | --- | --- | --- | --- | --- | --- | --- | --- | --- | --- | --- | --- | --- | --- | --- | --- | --- | --- |
|  | 02 | **Outer HCAL Sector Mechanical Structure** |  |  | 2018-05-10 | 2021-03-26 |  |  |  |  |  |  |  |  |  |  |  |  |  |  |  |  |  |  |  |  |  |  |  |  |  |  |  |  |  |  |  |  |  |  |  |  |  |  |  |  |  |  |  |
| S203900 |  | Design Revision of Outer HCAL Splice Plates (Dog bones) |  | 42d | 2018-05-10 A | 2018-07-10 A | S318600 | 100% |  |  |  |  |  | S203900 | 100 | S187400 | 0 | S187400 | NOCA | Completed | Pontieri, Chris | L3 | BNL | Design | John Lajoie | ISU | null | POM02.1.04.02 | C | 02 | yes |  |  |  |  |  |  |  |  |  |  |  |  |  |  |  |  |  |  |
| S203901 |  | Preliminary Design Review - Outer HCAL Splice Plates (Dog bones) | milestone | 0d | 2018-07-10 A | 2018-07-10 A | S203900 FF | 100% |  |  |  |  |  | S203900 | 100 | S187400 | 0 | S187400 | NOCA | Completed | Pontieri, Chris | L3 | BNL | Design | John Lajoie | ISU | null | POM02.1.04.02 | C | 02 | yes | 004 |  |  |  |  |  |  |  |  |  |  |  |  |  |  |  |  |  |
| S204000 |  | Internal Review of Outer HCAL Splice Plates (Dog bones) |  | 2d | 2018-07-11 A | 2018-07-12 A | S203901 | 100% |  |  |  |  |  | S204000 | 100 | S187500 | 0 | S187500 | NOCA | Completed | Pontieri, Chris | L3 | BNL | Fab & Assy | John Lajoie | ISU | null | POM02.1.04.02 | C | 02 | yes | 004 |  |  |  |  |  |  |  |  |  |  |  |  |  |  |  |  |  |
| S204100 |  | Address Issues from Internal Review of Outer HCAL Splice Plates |  | 10d | 2018-07-13 A | 2018-07-26 A | S204000 | 100% |  |  |  |  |  | S204100 | 100 | S187600 | 0 | S187600 | NOCA | Completed | Pontieri, Chris | L3 | BNL | Test_Components | John Lajoie | ISU | null | POM02.1.04.02 | C | 02 | yes | 004 |  |  |  |  |  |  |  |  |  |  |  |  |  |  |  |  |  |
| S204200 |  | Outer HCAL Splice Plate Design Complete | milestone | 0d | 2018-07-26 A | 2018-07-26 A | S204100 | 100% |  |  |  |  |  | S204200 | 100 | S187700 | 0 | S187700 | NOCA | Completed | Pontieri, Chris |  | BNL | Design | John Lajoie | ISU |  | POM02.1.04.02 |  | 02 | yes |  | L5 |  |  |  |  |  |  |  |  |  |  |  |  |  |  |  |  |
| S204300 |  | Procure Preproduction Outer HCAL Splice Plates - Delivery Acceptance |  | 148d | 2018-10-16 A | 2019-05-20 A | S204200 | 100% |  |  |  |  |  | S204300 | 5 | S188400 | x | S187750 | NOCA | Completed | Pontieri, Chris | M5 | BNL | Fab & Assy | John Lajoie | ISU | OPC | POM02.1.04.02 | E | 02 | yes | 003 |  | 180410 ELM pred/succ per GRY | 2018-12-19 | A-OPC | 16703 | Yes |  |  |  |  |  |  |  |  |  |  |  |
| S204400 |  | Procure Preproduction Outer HCAL Splice Plates -Use in test assembly |  | 33d | 2019-04-16 A | 2019-05-31 A | S204300 | 100% |  |  |  |  |  | S204400 | 0 | S188400 | x | S187775 | NOCA | Completed | Pontieri, Chris | M5 | BNL | Fab & Assy | John Lajoie | ISU | null | POM02.1.04.02 | C | 02 | yes |  |  | 180410 ELM pred/succ per GRY |  | B | 16711 |  | PP6 | MP104900 |  |  |  |  |  |  |  |  |  |
| S205200 |  | Design Revision of Outer HCAL Lifting Fixture and Supports |  | 39d | 2019-07-24 A | 2019-09-17 A | S101000 | 100% |  |  |  | PROF4 PO M [16 h]; SCI3 PO [16 h]; TECH3 PO M [40 h] | 9,393.03 | S205200 | 0 | S188500 | 0 | S188500 | CA | Completed | Pontieri, Chris | L3 | BNL | Design | John Lajoie | ISU | null | POM02.1.04.02 | C | 02 |  |  |  |  | 2019-08-21 | B | 16711 |  |  |  | S205200 | 1.04 | 1.04B |  |  |  |  |  |  |
| S204401 |  | Final Design Review - Outer HCAL Splice Plates (Dog bones) |  | 2d | 2019-09-17 A | 2019-09-18 A | S204400 FF | 100% |  |  | start on or after 2019-08-30 | PROF3 PO M [8 h]; PROF4 PO M [4 h]; SCI 4 PO [4 h] | 2,354.14 | S204400 | 0 | S188400 | x | S187775 | CA | Completed | Pontieri, Chris | M5 | BNL | Management Tech Reviews | John Lajoie | ISU | null | POM02.1.04.02 | F | 02 |  | 004,005 |  | 180410 ELM pred/succ per GRY |  | B | 16711 |  | PP6 | MP104900 | S204401 | 1.04 | 1.04B |  |  |  |  |  |  |
| S205201 |  | Preliminary Design Review - Outer HCAL Lifting Fixture and Supports |  | 1d | 2019-10-01 A | 2019-10-01 A | S205200 FF | 100% |  |  |  | SCI3 PO [4 h]; PROF4 PO M [4 h]; TECH3 PO M [4 h] | 1,733.97 | S205200 | 0 | S188500 | 0 | S188500 | CA | Completed | Pontieri, Chris | L3 | BNL | Management Tech Reviews | John Lajoie | ISU | null | POM02.1.04.02 | F | 02 |  | 004 |  |  | 2019-08-21 | B | 16711 |  |  |  | S205201 | 1.04 | 1.04B |  |  |  |  |  |  |
| S205300 |  | Final Design Review, Procurement Readiness Review - Outer HCAL Lifting Fixture and Supports |  | 1d | 2019-10-02 A | 2019-10-02 A | S205201 | 100% |  |  |  | PROF4 PO M [8 h]; SCI3 PO [8 h]; TECH3 PO M [8 h] | 3,467.94 | S205300 | 0 | S188600 | 0 | S188600 | CA | Completed | Pontieri, Chris | L3 | BNL | Fab & Assy | John Lajoie | ISU | null | POM02.1.04.02 | C | 02 |  | 004 |  |  |  | B | 16711 |  |  |  | S205300 | 1.04 | 1.04B |  |  |  |  |  |  |
| S205400 |  | Address Issues from Internal Review of Outer HCAL Lifting Fixture and Supports |  | 10d | 2019-10-03 A | 2019-10-17 A | S205300 | 100% |  |  |  | PROF4 PO M [8 h]; SCI3 PO [8 h]; TECH3 PO M [20 h] | 4,837.41 | S205400 | 0 | S188700 | 0 | S188700 | CA | Completed | Pontieri, Chris | L3 | BNL | Test_Components | John Lajoie | ISU | null | POM02.1.04.02 | C | 02 |  |  |  |  |  | B | 16711 |  |  |  | S205400 | 1.04 | 1.04B |  |  |  |  |  |  |
| S205500 |  | Outer HCAL Lifting Fixture and Supports Design Complete | milestone | 0d | 2019-10-17 A | 2019-10-17 A | S205400 | 100% |  |  |  |  |  | S205500 | 0 | S188800 | 0 | S188800 | NOCA | Completed | Pontieri, Chris |  | BNL | Design | John Lajoie | ISU |  | POM02.1.04.02 |  | 02 |  |  | L3 |  |  |  |  |  |  |  |  |  |  |  |  |  |  |  |  |
| S205600 |  | Procure Outer HCAL Lifting Fixtures & Supports - Provide Requirements to Procurement |  | 5d | 2019-11-01 A | 2019-11-25 A | S205500 | 100% | 2019-12-02 | 2019-12-06 |  | PROF4 PO M [72 h]; SCI3 PO [36 h]; TECH3 PO D [72 h] | 25,015.68 | S205600 | 0 | S188900 | x | S188900 | CA | Completed | Pontieri, Chris | L3 | BNL | Procurement | John Lajoie | ISU | null | POM02.1.04.02 | C | 02 |  |  |  | 180330 ELM pred |  | B | 16711 |  | PP1 | MP104800 | S205600 | 1.04 | 1.04B |  |  |  |  |  |  |
| S205700 |  | Procure Outer HCAL Lifting Fixtures & Supports - Prepare & Send Solicitation |  | 30d | 2019-11-13 A | 2019-11-15 A | S205600 | 100% | 2019-12-09 | 2020-01-22 |  |  |  | S205700 | 0 | S189000 | 0 | S189000 | NOCA | Completed | Pontieri, Chris |  | BNL | Procurement | John Lajoie | ISU |  | POM02.1.04.02 |  | 02 |  |  |  |  |  |  |  |  | PP2 | MP104800 |  |  |  |  |  |  |  |  |  |
| S206200 |  | Procure Outer HCAL Lifting Fixtures & Supports - Delivery Acceptance |  | 5d | 2019-11-14 A | 2020-01-23 A | S206100 | 100% | 2020-07-14 | 2020-07-20 |  | Material (Purchase (1st $2M) [40000 h] | 45,517.03 | S206200 | 0 | S189500 | x | S189500 | CA | In Progress | Pontieri, Chris | M4 | BNL | Procurement | John Lajoie | ISU | TEC | POM02.1.04.02 | F | 02 |  |  |  | 180410 ELM pred/succ per GRY; 180330 ELM pred |  | A-TEC | 59711 |  | PP6 | MP104800 | S206200 | 1.04 | 1.04A | UDF_G3 | UDF_G3 | FAB | Delivery |  |  |
| S205800 |  | Procure Outer HCAL Lifting Fixtures & Supports - Vendor Responses |  | 10d | 2019-11-15 A | 2019-11-21 A | S205700 | 100% | 2020-01-23 | 2020-02-05 |  |  |  | S205800 | 0 | S189100 | 0 | S189100 | NOCA | Completed | Pontieri, Chris |  | BNL | Procurement | John Lajoie | ISU |  | POM02.1.04.02 |  | 02 |  |  |  |  |  |  |  |  | PP3 | MP104800 |  |  |  |  |  |  |  |  |  |
| S205900 |  | Procure Outer HCAL Lifting Fixtures & Supports - Vendor Selection |  | 20d | 2019-11-19 A | 2019-11-25 A | S205800 | 100% | 2020-02-06 | 2020-03-05 |  |  |  | S205900 | 0 | S189200 | 0 | S189200 | NOCA | Completed | Pontieri, Chris |  | BNL | Procurement | John Lajoie | ISU |  | POM02.1.04.02 |  | 02 |  |  |  |  |  |  |  |  | PP4 | MP104800 |  |  |  |  |  |  |  |  |  |
| S206100 |  | Procure Outer HCAL Lifting Fixtures & Supports - Contract/PO - Leadtime |  | 90d | 2019-11-20 A | 2019-11-27 A | S206000 SS, OBLG206010 SS | 100% | 2020-03-06 | 2020-07-13 |  |  |  | S206100 | 0 | S189400 | 0 | S189400 | NOCA | Completed | Pontieri, Chris |  | BNL | Fab & Assy | John Lajoie | ISU |  | POM02.1.04.02 |  | 02 |  |  |  |  |  |  |  |  | PP6 | MP104800 |  |  |  |  |  |  |  |  |  |
| S206000 |  | Procure Outer HCAL Lifting Fixtures & Supports - Contract Award(s) | milestone | 0d | 2019-11-27 A | 2019-11-27 A | S205900, S100600 | 100% | 2020-03-06 | 2020-03-06 |  |  |  | S206000 | 0 | S189300 | 0 | S189300 | NOCA | Completed | Pontieri, Chris |  | BNL | Procurement | John Lajoie | ISU |  | POM02.1.04.02 |  | 02 |  |  | L5 |  |  | A-TEC |  |  | PP5 | MP104800 |  |  |  |  |  |  | Contract Award |  |  |
| S204450 |  | Procurement Readiness Review - Outer HCAL Splice Plates (Dog bones) |  | 1d | 2020-02-03 A | 2020-02-03 A | S204200, S204401 | 100% |  |  | start on or after 2020-01-15 | PROF4 PO M [4 h]; PROF3 PO M [8 h]; SCI 4 PO [4 h] | 2,424.77 | S204500 | 0 | S187800 | x | S187800 | CA | Not Started | Pontieri, Chris | L4 | BNL | Management Tech Reviews | John Lajoie | ISU | null | POM02.1.04.02 | F | 02 |  | 004 |  |  |  | B | 16711 |  | PP1 | MP104900 | S204450 | 1.04 | 1.04B |  |  |  |  |  |  |
| S204500 |  | Procure Outer HCAL Splice Plates - Provide Requirements to Procurement |  | 5d | 2020-02-04 A | 2020-02-10 A | S204450 | 100% |  |  |  | PROF4 PO M [36 h]; TECH3 PO D [36 h] | 9,409.94 | S204500 | 0 | S187800 | x | S187800 | CA | Not Started | Pontieri, Chris | L4 | BNL | Procurement | John Lajoie | ISU | null | POM02.1.04.02 | C | 02 |  |  |  |  |  | B | 16711 |  | PP1 | MP104900 | S204500 | 1.04 | 1.04B |  |  |  |  |  |  |
| S204600 |  | Procure Outer HCAL Splice Plates - Prepare & Send Solicitation |  | 9d | 2020-02-11 A | 2020-02-24 A | S204500 | 100% |  |  | start on or after 2019-09-11 |  |  | S204600 | 0 | S187900 | 0 | S187900 | NOCA | Not Started | Pontieri, Chris |  | BNL | Procurement | John Lajoie | ISU |  | POM02.1.04.02 |  | 02 |  |  |  |  |  |  |  |  | PP2 | MP104900 |  |  |  |  |  |  |  |  |  |
| S204700 |  | Procure Outer HCAL Splice Plates - Vendor Responses |  | 10d | 2020-03-02 A | 2020-03-13 A | S204600 | 100% |  |  |  |  |  | S204700 | 0 | S188000 | 0 | S188000 | NOCA | Not Started | Pontieri, Chris |  | BNL | Procurement | John Lajoie | ISU |  | POM02.1.04.02 |  | 02 |  |  |  |  |  |  |  |  | PP3 | MP104900 |  |  |  |  |  |  |  |  |  |
| S204800 |  | Procure Outer HCAL Splice Plates - Vendor Selection |  | 20d | 2020-04-01 A | 2020-04-28 A | S204700 | 100% |  |  |  |  |  | S204800 | 0 | S188100 | 0 | S188100 | NOCA | Not Started | Pontieri, Chris |  | BNL | Procurement | John Lajoie | ISU |  | POM02.1.04.02 |  | 02 |  |  |  |  |  |  |  |  | PP4 | MP104900 |  |  |  |  |  |  |  |  |  |
| S204900 |  | Procure Outer HCAL Splice Plates - Contract Award(s) | milestone | 0d | 2020-06-09 A | 2020-06-09 A | S204800, S101000, S101010 | 100% | 2020-07-01 | 2020-07-01 |  |  |  | S204900 | 0 | S188200 | 0 | S188200 | NOCA | Not Started | Pontieri, Chris |  | BNL | Procurement | John Lajoie | ISU |  | POM02.1.04.02 |  | 02 |  |  | L5 |  |  | A-TEC |  |  | PP5 | MP104900 |  |  |  | UDF_G1 | UDF_G3 |  | Contract Award |  |  |
| S205000 |  | Procure Outer HCAL Splice Plates - Contract/PO - Leadtime |  | 90d | 2020-07-01 A | 2021-02-01 A | S204900 SS, OBLG204910 SS | 100% | 2020-07-01 | 2020-11-06 |  |  |  | S205000 | 0 | S188300 | 0 | S188300 | NOCA | Not Started | Pontieri, Chris |  | BNL | Procurement | John Lajoie | ISU |  | POM02.1.04.02 |  | 02 |  |  |  |  |  |  |  |  | PP6 | MP104900 |  |  |  |  |  |  |  |  |  |
| OBLG204910 |  | Procure Outer HCAL Splice Plates - Obligation |  | 1d | 2020-09-01 A | 2020-09-01 A | S204800, S101000, S101010 | 100% |  |  |  | Obligation Resource [303326 h] | 303,325.5 | S204900 | 0 | S188200 | 0 | S188200 |  | Not Started | Pontieri, Chris |  | BNL | Procurement | John Lajoie | ISU |  | POM02.1.04.02 |  | 02 |  |  | L5 |  |  | A-TEC |  |  | PP5 | MP104900 |  |  |  |  |  | OBLG |  |  |  |
| OBLG206010 |  | Procure Outer HCAL Lifting Fixtures & Supports - Obligation |  | 1d | 2020-09-01 A | 2020-09-01 A | S205900, S100600 | 100% |  |  |  | Obligation Resource [45517 h] | 45,517.03 | S206000 | 0 | S189300 | 0 | S189300 |  | Not Started | Pontieri, Chris |  | BNL | Procurement | John Lajoie | ISU |  | POM02.1.04.02 |  | 02 |  |  | L5 |  |  | A-TEC |  |  | PP5 | MP104800 |  |  |  |  |  | OBLG |  |  |  |
| S205100 |  | Procure Outer HCAL Splice Plates - Delivery Acceptance |  | 5d | 2021-02-22 A | 2021-03-26 A | S205000, S101010 | 100% | 2021-03-01 | 2021-03-05 |  | Material (Purchase (1st $2M) [266560 h] | 309,392.01 | S205100 | 0 | S188400 | x | S188400 | CA | Not Started | Pontieri, Chris | M5 | BNL | Fab & Assy | John Lajoie | ISU | TEC | POM02.1.04.02 | F | 02 |  |  |  | 180410 ELM pred/succ per GRY |  | A-TEC | 59711 |  | PP6 | MP104900 | S205100 | 1.04 | 1.04A | UDF_G1 | UDF_G3 | FAB | Delivery | 303325.498582 | 1 |

Notes:
- S203900: BNL_UDF_Old Activity Name 181221: Design Revision of Outer HCAL Splice Plates (Dog bones)
- S203901: BNL_UDF_Status Comments: 190508 ELM add per GRY / BNL_UDF_Old Activity Name 181221: Design Revision of Outer HCAL Splice Plates (Dog bones)
- S204000: BNL_UDF_Status Comments: 190523 ELM name; 190415 ELM name per GRY / BNL_UDF_Old Activity Name 181221: Internal Review of Outer HCAL Splice Plates (Dog bones)
- S204100: BNL_UDF_Status Comments: 190523 ELM name; 190415 ELM name per GRY / BNL_UDF_Old Activity Name 181221: Address Issues from Internal Review of Outer HCAL Splice Plates
- S204200: BNL_UDF_Old Activity Name 181221: Outer HCAL Splice Plate Design Complete
- S204300: BNL_UDF_Status Comments: 190315 ELM chg % to align with EVT 5>50 / BNL_UDF_Old Activity Name 181221: Procure Preproduction Outer HCAL Splice Plates - Delivery Acceptance
- S204400: BNL_UDF_Old Activity Name 181221: Procure Preproduction Outer HCAL Splice Plates -Use in test assembly
- S205200: BNL_UDF_Old Activity Name 181221: Design Revision of Outer HCAL Lifting Fixture and Supports
- S204401: BNL_UDF_Status Comments: 190606 IVS change start and add resources; 190508 ELM add per GRY / BNL_UDF_Old Activity Name 181221: Procure Preproduction Outer HCAL Splice Plates -Use in test assembly
- S205201: BNL_UDF_Status Comments: 190508 ELM add per GRY / BNL_UDF_Old Activity Name 181221: Design Revision of Outer HCAL Lifting Fixture and Supports
- S205300: BNL_UDF_Status Comments: 190508 ELM name per GRY; 190415 ELM name per GRY / BNL_UDF_Old Activity Name 181221: Internal Review of Outer HCAL Lifting Fixture and Supports
- S205400: BNL_UDF_Old Activity Name 181221: Address Issues from Internal Review of Outer HCAL Lifting Fixture and Supports
- S205500: BNL_UDF_Old Activity Name 181221: Outer HCAL Lifting Fixture and Supports Design Complete
- S205600: BNL_UDF_Old Activity Name 181221: Procure Outer HCAL Lifting Fixtures & Supports - Provide Requirements to Procurement
- S205700: BNL_UDF_Old Activity Name 181221: Procure Outer HCAL Lifting Fixtures & Supports - Prepare & Send Solicitation
- S206200: BNL_UDF_Old Activity Name 181221: Procure Outer HCAL Lifting Fixtures & Supports - Delivery Acceptance
- S205800: BNL_UDF_Old Activity Name 181221: Procure Outer HCAL Lifting Fixtures & Supports - Vendor Responses
- S205900: BNL_UDF_Old Activity Name 181221: Procure Outer HCAL Lifting Fixtures & Supports - Vendor Selection
- S206100: BNL_UDF_Old Activity Name 181221: Procure Outer HCAL Lifting Fixtures & Supports - Contract/PO - Leadtime
- S206000: BNL_UDF_Old Activity Name 181221: Procure Outer HCAL Lifting Fixtures & Supports - Contract Award(s)
- S204450: BNL_UDF_Status Comments: 190508 ELM name per GRY; 190415 ELM add per GRY / BNL_UDF_Old Activity Name 181221: Procure Outer HCAL Splice Plates - Provide Requirements to Procurement
- S204500: BNL_UDF_Old Activity Name 181221: Procure Outer HCAL Splice Plates - Provide Requirements to Procurement
- S204600: BNL_UDF_Old Activity Name 181221: Procure Outer HCAL Splice Plates - Prepare & Send Solicitation
- S204700: BNL_UDF_Old Activity Name 181221: Procure Outer HCAL Splice Plates - Vendor Responses
- S204800: BNL_UDF_Old Activity Name 181221: Procure Outer HCAL Splice Plates - Vendor Selection
- S204900: BNL_UDF_Old Activity Name 181221: Procure Outer HCAL Splice Plates - Contract Award(s)
- S205000: BNL_UDF_Old Activity Name 181221: Procure Outer HCAL Splice Plates - Contract/PO - Leadtime
- OBLG204910: BNL_UDF_Old Activity Name 181221: Procure Outer HCAL Splice Plates - Contract Award(s)
- OBLG206010: BNL_UDF_Old Activity Name 181221: Procure Outer HCAL Lifting Fixtures & Supports - Contract Award(s)
- S205100: BNL_UDF_Old Activity Name 181221: Procure Outer HCAL Splice Plates - Delivery Acceptance

| ID | WBS | Activity | Type | Duration | Start | Finish | Predecessors | Complete | Planned start | Planned finish | Constraint | Resources | Cost | BNL_UDF_Temp Text 01 | BNL_UDF_Percent Complete | BNL_UDF_OPC TEC (deprecated) | BNL_UDF_Temp Text 02 | BNL_UDF_Old Activity ID 181221 | RG Check | BNL_Activity Status | BNL_Estimator | BNL_Location | BNL_EDIA | BNL_CAM | BNL_Institution | BNL_WBS | BNL_LLPs and Precursors | BNL_WBS_Hierarchical | Completed | BNL_UDF_Status Comments | BNL_PCR ID | BNL_Milestone Level | BNL_Cost Basis | BNL_Proc Sig Phase | BNL_Proc Sig | BNL_OPC TEC (deprecated) | BNL_EVT | BNL_UDF_Exclude | BNL_Fund Source | BNL_Account Number | Additional EVT documentation required | SPH Proc Register | BNL_Obligation | BNL_Cobra WP | Indicator - Procurement | BNL_Master Control Account | BNL_Cobra Control Account | Indicator - Float | BNL_UDF_Remaining Tot Cost | BNL_UDF_Percent_remaining |
| --- | --- | --- | --- | --- | --- | --- | --- | --- | --- | --- | --- | --- | --- | --- | --- | --- | --- | --- | --- | --- | --- | --- | --- | --- | --- | --- | --- | --- | --- | --- | --- | --- | --- | --- | --- | --- | --- | --- | --- | --- | --- | --- | --- | --- | --- | --- | --- | --- | --- | --- |
|  | 03 | **Outer HCAL Procure Scintillating Tiles** |  |  | 2017-02-01 | 2021-01-04 |  |  |  |  |  |  |  |  |  |  |  |  |  |  |  |  |  |  |  |  |  |  |  |  |  |  |  |  |  |  |  |  |  |  |  |  |  |  |  |  |  |  |  |  |
| S206300 |  | Design Outer HCAL Scintillating Tiles |  | 40d | 2017-02-01 A | 2017-03-29 A | S100090 SS | 100% |  |  |  |  |  | S206300 | 100 | S189600 | 0 | S189600 | NOCA | Completed | Connors, Megan | BNL | Design | John Lajoie | ISU | POM02.1.04.03 | Pre-2 | 03 | yes |  |  |  |  |  |  |  |  |  |  |  |  |  |  |  |  |  |  |  |  |  |
| S206700 |  | Design Outer HCAL Light Collection |  | 20d | 2017-03-23 A | 2017-04-19 A | S206300 SS+35d | 100% |  |  |  |  |  | S206700 | 100 | S190000 | 0 | S190000 | NOCA | Completed | Connors, Megan | BNL | Design | John Lajoie | ISU | POM02.1.04.03 | Pre-2 | 03 | yes |  |  |  |  |  |  |  |  |  |  |  |  |  |  |  |  |  |  |  |  |  |
| S206400 |  | Internal Review of OHCAL Scint. Tiles; First part of Procurement Readiness Review - OHCAL Scint. Tiles (LLP) |  | 2d | 2017-03-30 A | 2017-03-31 A | S206300 | 100% |  |  |  |  |  | S206400 | 100 | S189700 | 0 | S189700 | NOCA | Completed | Connors, Megan | BNL | Test_Components | John Lajoie | ISU | POM02.1.04.03 | Pre-2 | 03 | yes | 190522 IVS name change | 004 |  |  |  |  |  |  |  |  |  |  |  |  |  |  |  |  |  |  |  |
| S206500 |  | Address Issues from Internal Review of Outer HCAL Scintillating Tile |  | 10d | 2017-04-03 A | 2017-04-14 A | S206400 | 100% |  |  |  |  |  | S206500 | 100 | S189800 | 0 | S189800 | NOCA | Completed | Connors, Megan | BNL | Fab & Assy | John Lajoie | ISU | POM02.1.04.03 | Pre-2 | 03 | yes |  |  |  |  |  |  |  |  |  |  |  |  |  |  |  |  |  |  |  |  |  |
| S206600 |  | Outer HCAL Scintillating Tile Design Complete | milestone | 0d | 2017-04-14 A | 2017-04-14 A | S206500 | 100% |  |  |  |  |  | S206600 | 100 | S189900 | 0 | S189900 | NOCA | Completed | Connors, Megan | BNL | Design | John Lajoie | ISU | POM02.1.04.03 | Pre-2 | 03 | yes |  |  | L5 |  |  |  |  |  |  |  |  |  |  |  |  |  |  |  |  |  |  |
| S206800 |  | Internal Review of OHCAL Light collections; Second part of Procurement Readiness Review - OHCAL Scint. Tiles (LLP) |  | 0d | 2017-04-20 A | 2017-04-20 A | S206700 | 100% |  |  |  |  |  | S206800 | 100 | S190100 | 0 | S190100 | NOCA | Completed | Connors, Megan | BNL | Test_Components | John Lajoie | ISU | POM02.1.04.03 | Pre-2 | 03 | yes | 190522 IVS name change | 004 |  |  |  |  |  |  |  |  |  |  |  |  |  |  |  |  |  |  |  |
| S206900 |  | Address Issues from Internal Review of Outer HCAL Light Collection |  | 10d | 2017-04-21 A | 2017-05-04 A | S206800 | 100% |  |  |  |  |  | S206900 | 100 | S190200 | 0 | S190200 | NOCA | Completed | Connors, Megan | BNL | Fab & Assy | John Lajoie | ISU | POM02.1.04.03 | Pre-2 | 03 | yes |  |  |  |  |  |  |  |  |  |  |  |  |  |  |  |  |  |  |  |  |  |
| S207100 |  | Design Outer HCAL LED/Fiber Calibration System |  | 20d | 2017-04-28 A | 2017-05-25 A | S206900 SS+5d | 100% |  |  |  |  |  | S207100 | 100 | S190400 | 0 | S190400 | NOCA | Completed | Connors, Megan | BNL | Design | John Lajoie | ISU | POM02.1.04.03 | Pre-2 | 03 | yes |  |  |  |  |  |  |  |  |  |  |  |  |  |  |  |  |  |  |  |  |  |
| S207000 |  | Outer HCAL Light Collection Complete | milestone | 0d | 2017-05-04 A | 2017-05-04 A | S206900 FF | 100% |  |  |  |  |  | S207000 | 100 | S190300 | 0 | S190300 | NOCA | Completed | Connors, Megan | BNL | Fab & Assy | John Lajoie | ISU | POM02.1.04.03 | Pre-2 | 03 | yes |  |  | L5 |  |  |  |  |  |  |  |  |  |  |  |  |  |  |  |  |  |  |
| S207200 |  | Internal Review of OHCAL LED/Fiber calibration; Third part of Procurement Readiness Review - OHCAL Scint. Tiles (LLP) |  | 2d | 2017-05-26 A | 2017-05-30 A | S207100 | 100% |  |  |  |  |  | S207200 | 100 | S190500 | 0 | S190500 | NOCA | Completed | Connors, Megan | BNL | Test_Components | John Lajoie | ISU | POM02.1.04.03 | Pre-2 | 03 | yes | 190522 IVS name change | 004 |  |  |  |  |  |  |  |  |  |  |  |  |  |  |  |  |  |  |  |
| S207300 |  | Address Issues from Internal Review of Outer HCAL LED/Fiber Calibration System |  | 10d | 2017-05-31 A | 2017-06-13 A | S207200 | 100% |  |  |  |  |  | S207300 | 100 | S190600 | 0 | S190600 | NOCA | Completed | Connors, Megan | BNL | Fab & Assy | John Lajoie | ISU | POM02.1.04.03 | Pre-2 | 03 | yes |  |  |  |  |  |  |  |  |  |  |  |  |  |  |  |  |  |  |  |  |  |
| S207400 |  | Outer HCAL LED/Fiber Calibration Conceptual Design Complete | milestone | 0d | 2017-06-13 A | 2017-06-13 A | S207300 | 100% |  |  |  |  |  | S207400 | 100 | S190700 | 0 | S190700 | NOCA | Completed | Connors, Megan | BNL | Design | John Lajoie | ISU | POM02.1.04.03 | Pre-2 | 03 | yes |  |  | L5 |  |  |  |  |  |  |  |  |  |  |  |  |  |  |  |  |  |  |
| S207700 |  | Procure Outer HCAL Scintillating Tiles (Prod) - Provide Requirements to Procurement |  | 0d | 2018-07-02 A | 2018-07-02 A | S100500, S206600 | 100% |  |  |  |  |  | S207700 | 100 | S191500 | 0 | S191500 | NOCA | Completed | Connors, Megan | Russia | Procurement | John Lajoie | ISU | POM02.1.04.03 | Tiles | 03 | yes |  |  |  | L4 | PP1 | MP105000 | null | C |  |  |  |  |  |  |  |  |  |  |  |  |  |
| S207800 |  | Procure Outer HCAL Scintillating Tiles (Prod) - Prepare & Send Solicitation |  | 14d | 2018-07-10 A | 2018-07-27 A | S207700 | 100% |  |  |  |  |  | S207800 | 100 | S191600 | 0 | S191600 | NOCA | Completed | Connors, Megan | Russia | Procurement | John Lajoie | ISU | POM02.1.04.03 | Tiles | 03 | yes |  |  |  | L4 | PP2 | MP105000 | null | C |  |  |  |  |  |  |  |  |  |  |  |  |  |
| S207900 |  | Procure Outer HCAL Scintillating Tiles (Prod) - Vendor Responses |  | 10d | 2018-07-30 A | 2018-08-10 A | S207800 | 100% |  |  |  |  |  | S207900 | 100 | S191700 | 0 | S191700 | NOCA | Completed | Connors, Megan | Russia | Procurement | John Lajoie | ISU | POM02.1.04.03 | Tiles | 03 | yes |  |  |  |  | PP3 | MP105000 |  |  |  |  |  |  |  |  |  |  |  |  |  |  |  |
| S208000 |  | Procure Outer HCAL Scintillating Tiles (Prod) - Vendor Selection |  | 4d | 2018-08-13 A | 2018-08-16 A | S207900 | 100% |  |  |  |  |  | S208000 | 100 | S191800 | 0 | S191800 | NOCA | Completed | Connors, Megan | Russia | Procurement | John Lajoie | ISU | POM02.1.04.03 | Tiles | 03 | yes |  |  |  | L4 | PP4 | MP105000 | null | C | MP6LA |  |  |  |  |  |  |  |  |  |  |  |  |
| S207500 |  | Procure Outer HCAL LED/Calibration Fibers Labor |  | 60d | 2019-03-01 A | 2019-05-23 A | S100600 | 100% |  |  |  |  |  | S207500 | 0 | S190800 | 0 | S190800 | NOCA | Completed | Connors, Megan | BNL | Procurement | John Lajoie | ISU | POM02.1.04.03 |  | 03 | yes |  |  |  | L4 |  |  | null | C |  | B | 16711 | Yes |  |  |  |  |  |  |  |  |  |
| S207600 |  | Procure Outer HCAL LED/Calibration Fibers M&S |  | 60d | 2019-03-01 A | 2019-05-23 A | S207500 SS | 100% |  |  |  |  |  | S207600 | 0 | S191400 | 0 | S191400 | NOCA | Completed | Connors, Megan | BNL | Procurement | John Lajoie | ISU | POM02.1.04.03 |  | 03 | yes | 190213 ELM BUs per GRY | 003 |  | M5 |  |  | TEC | C |  | A-TEC | 59712 | Yes |  |  |  |  |  |  |  |  |  |
| S208100 |  | Procure Outer HCAL Scintillating Tiles (Prod) - Contract Award(s) | milestone | 0d | 2019-04-15 A | 2019-04-15 A | S208000, S100600, S206500, S206900, S207300, S202200 | 100% |  |  |  |  |  | S208100 | 0 | S191900 | 0 | S191900 | NOCA | Completed | Connors, Megan | Russia | Procurement | John Lajoie | ISU | POM02.1.04.03 | Tiles | 03 | yes |  |  | L5 |  | PP5 | MP105000 |  |  | MP6LA | A-TEC |  |  | Contract Award |  |  |  |  |  |  |  |  |
| S208200 |  | Procure Outer HCAL Scintillating Tiles (Prod) - Contract/PO - Leadtime |  | 130d | 2019-06-03 A | 2019-09-26 A | S208100 SS, OBLG208110 SS | 100% | 2019-07-01 | 2020-01-08 |  |  |  | S208200 | 0 | S192000 | 0 | S192000 | NOCA | Completed | Connors, Megan | Russia | Procurement | John Lajoie | ISU | POM02.1.04.03 | Tiles | 03 |  |  |  |  |  | PP6 | MP105000 |  |  | MP6LA | A-TEC |  |  |  |  |  |  |  |  |  |  |  |
| OBLG208110 |  | Procure Outer HCAL Scintillating Tiles (Prod) - Obligation |  | 1d | 2019-06-28 A | 2019-06-28 A | S208000, S100600, S206500, S206900, S207300, S202200 | 100% | 2019-07-01 | 2019-07-01 |  | Obligation Resource [1756599 h] | 1,756,598.99 | S208100 | 0 | S191900 | 0 | S191900 |  | Completed | Connors, Megan | Russia | Procurement | John Lajoie | ISU | POM02.1.04.03 | Tiles | 03 |  | 190418 ELM BNLU per GRY; 190417 ELM BNLU per GRY | 004 | L5 |  | PP5 | MP105000 |  |  | MP6LA | A-TEC |  |  |  | OBLG |  |  |  |  |  |  |  |
| S208220 |  | Procure Outer HCAL Scintillating Tiles (Prod) - Delivery Acceptance 0 |  | 5d | 2019-09-18 A | 2019-09-24 A | S208200 | 100% |  |  | start on or after 2019-09-30 | Material (Purchase (1st $2M) [185242 h] | 204,371.02 | S208300 | 0 | S192100 | 0 | S192100 | CA | Completed | Connors, Megan | Russia | Fab & Assy | John Lajoie | ISU | POM02.1.04.03 | Tiles | 03 |  | 190418 ELM BNLU per GRY; 190417 ELM BNLU per GRY | 007 |  | M4 | PP6 | MP105000 | TEC | F | MP6LA | A-TEC | 59712 |  | Delivery | FAB | S208220 | UDF_G3 | 1.04 | 1.04A |  |  |  |
| S208300 |  | Procure Outer HCAL Scintillating Tiles (Prod) - Delivery Acceptance 1 |  | 28d | 2019-09-25 A | 2019-11-04 A | S208220 | 100% | 2019-11-05 | 2019-12-17 |  | Material (Purchase (1st $2M) [143106 h] | 159,650.99 | S208300 | 0 | S192100 | 0 | S192100 | CA | Completed | Connors, Megan | Russia | Fab & Assy | John Lajoie | ISU | POM02.1.04.03 | Tiles | 03 |  | 190418 ELM BNLU per GRY; 190417 ELM BNLU per GRY | 004 |  | M4 | PP6 | MP105000 | TEC | C | MP6LA | A-TEC | 59712 |  | Delivery | FAB | S208300 | UDF_G2 | 1.04 | 1.04A |  |  |  |
| S208302 |  | Procure Outer HCAL Scintillating Tiles (Prod) - Delivery Acceptance 2 |  | 10d | 2019-11-12 A | 2019-11-25 A |  | 100% | 2019-12-02 | 2019-12-13 |  | Material (Purchase (1st $2M) [113203 h] | 126,290.8 | S208300 | 0 | S192100 | 0 | S192100 | CA | Completed | Connors, Megan | Russia | Fab & Assy | John Lajoie | ISU | POM02.1.04.03 | Tiles | 03 |  | 190418 ELM BNLU per GRY; 190417 ELM BNLU per GRY | 007 |  | M4 | PP6 | MP105000 | TEC | F | MP6LA | A-TEC | 59712 |  | Delivery | FAB | S208302 | UDF_G2 | 1.04 | 1.04A |  |  |  |
| S208303 |  | Procure Outer HCAL Scintillating Tiles (Prod) - Delivery Acceptance 3 |  | 5d | 2020-01-20 A | 2020-01-30 A | S208302 | 100% | 2020-01-02 | 2020-01-08 | start on or after 2019-12-20 | Material (Purchase (1st $2M) [113203 h] | 126,290.8 | S208300 | 0 | S192100 | 0 | S192100 | CA | Not Started | Connors, Megan | Russia | Fab & Assy | John Lajoie | ISU | POM02.1.04.03 | Tiles | 03 |  | 190418 ELM BNLU per GRY; 190417 ELM BNLU per GRY | 007 |  | M4 | PP6 | MP105000 | TEC | F | MP6LA | A-TEC | 59712 |  | Delivery | FAB | S208303 | UDF_G2 | 1.04 | 1.04A | UDF_G3 |  |  |
| S208304 |  | Procure Outer HCAL Scintillating Tiles (Prod) - Delivery Acceptance 4 |  | 5d | 2020-01-20 A | 2020-01-30 A | S208303 | 100% | 2020-03-18 | 2020-03-24 | start on or after 2020-03-18 | Material (Purchase (1st $2M) [113203 h] | 126,290.8 | S208300 | 0 | S192100 | 0 | S192100 | CA | Not Started | Connors, Megan | Russia | Fab & Assy | John Lajoie | ISU | POM02.1.04.03 | Tiles | 03 |  | 190418 ELM BNLU per GRY; 190417 ELM BNLU per GRY | 007 |  | M4 | PP6 | MP105000 | TEC | F | MP6LA | A-TEC | 59712 |  | Delivery | FAB | S208304 | UDF_G3 | 1.04 | 1.04A | UDF_G3 |  |  |
| S208306 |  | Procure Outer HCAL Scintillating Tiles (Prod) - Delivery Acceptance 5&6 |  | 5d | 2020-06-15 A | 2020-06-22 A |  | 100% | 2020-07-01 | 2020-07-08 | start on or after 2020-05-18 | Material (Purchase (1st $2M) [226406 h] | 252,581.59 | S208300 | 0 | S192100 | 0 | S192100 | CA | Not Started | Connors, Megan | Russia | Fab & Assy | John Lajoie | ISU | POM02.1.04.03 | Tiles | 03 |  | 190418 ELM BNLU per GRY; 190417 ELM BNLU per GRY | 007 |  | M4 | PP6 | MP105000 | TEC | F | MP6LA | A-TEC | 59712 |  | Delivery | FAB | S208306 | UDF_G2 | 1.04 | 1.04A | UDF_G3 | 252581.594609 | 1 |
| S208400 |  | Outer HCAL Scintillating Tile Acceptance Testing |  | 131d | 2020-06-15 A | 2020-12-22 A | S208300 FF, S208312 FF+10d | 100% | 2020-07-01 | 2021-01-11 |  | STUDENT GSU OnC - Purchased Services [650 h] | 11,640.88 | S208400 | 0 | S192200 | 0 | S192200 | CA | Not Started | Connors, Megan | GSU | Test_System | John Lajoie | ISU | POM02.1.04.03 |  | 03 |  |  |  |  | L4 | PP6 | MP203102 | null | C |  | A-TEC | 59712 | Yes |  | FAB | S208400 |  | 1.04 | 1.04A |  |  |  |
| S208308 |  | Procure Outer HCAL Scintillating Tiles (Prod) - Delivery Acceptance 7&8 |  | 5d | 2020-06-23 A | 2020-06-30 A |  | 100% | 2020-07-20 | 2020-07-24 | start on or after 2020-07-20 | Material (Purchase (1st $2M) [226406 h] | 252,581.59 | S208300 | 0 | S192100 | 0 | S192100 | CA | Not Started | Connors, Megan | Russia | Fab & Assy | John Lajoie | ISU | POM02.1.04.03 | Tiles | 03 |  | 190418 ELM BNLU per GRY; 190417 ELM BNLU per GRY | 007 |  | M4 | PP6 | MP105000 | TEC | F | MP6LA | A-TEC | 59712 |  | Delivery | FAB | S208308 | UDF_G3 | 1.04 | 1.04A | UDF_G3 | 252581.594609 | 1 |
| S208310 |  | Procure Outer HCAL Scintillating Tiles (Prod) - Delivery Acceptance 9&10 |  | 5d | 2020-06-23 A | 2020-08-31 A |  | 100% | 2020-09-14 | 2020-09-18 | start on or after 2020-09-14 | Material (Purchase (1st $2M) [211458 h] | 235,905.4 | S208300 | 0 | S192100 | 0 | S192100 | CA | Not Started | Connors, Megan | Russia | Fab & Assy | John Lajoie | ISU | POM02.1.04.03 | Tiles | 03 |  | 190418 ELM BNLU per GRY; 190417 ELM BNLU per GRY | 007 |  | M4 | PP6 | MP105000 | TEC | F | MP6LA | A-TEC | 59712 |  | Delivery | FAB | S208310 | UDF_G3 | 1.04 | 1.04A | UDF_G3 | 235905.403712 | 1 |
| S208410 |  | Outer HCAL Scintillating Tile Acceptance Testing - Contributed Labor |  | 131d | 2020-07-01 A | 2020-12-22 A | S208300 FF, S208312 FF+10d | 100% | 2020-07-01 | 2021-01-11 |  | PROF3 PO E [80 h]; PROF4 PO M [40 h]; SCI3 PO [83 h]; TECH3 PO D [40 h]; STUDENT GSU OnC - Purchased Services [650 h] | 47,036.79 | S208400 | 0 | S192200 | 0 | S192200 | CA | Not Started | Connors, Megan | GSU | Test_System | John Lajoie | ISU | POM02.1.04.03 |  | 03 |  |  |  |  | L4 |  |  | null | C |  | B_T | 16711 | Yes |  |  | S208410 |  | 1.04 | 1.04B |  |  |  |
| S208312 |  | Procure Outer HCAL Scintillating Tiles (Prod) - Delivery Acceptance 11&12 |  | 5d | 2020-08-17 A | 2020-11-30 A |  | 100% | 2020-11-16 | 2020-11-20 | start on or after 2020-11-16 | Material (Purchase (1st $2M) [211458 h] | 235,905.4 | S208300 | 0 | S192100 | 0 | S192100 | CA | Not Started | Connors, Megan | Russia | Fab & Assy | John Lajoie | ISU | POM02.1.04.03 | Tiles | 03 |  | 190418 ELM BNLU per GRY; 190417 ELM BNLU per GRY | 007 |  | M4 | PP6 | MP105000 | TEC | C | MP6LA | A-TEC | 59712 |  | Delivery | FAB | S208312 | UDF_G2 | 1.04 | 1.04A | UDF_G3 | 235905.403712 | 1 |
| S208500 |  | Completion of Outer HCAL Scintillating Tile Testing | milestone | 0d | 2021-01-04 A | 2021-01-04 A | S208400, S208410 | 100% |  |  |  |  |  | S208500 | 0 | S192300 | x | S192300 | NOCA | Not Started | Connors, Megan | GSU | Test_Components | John Lajoie | ISU | POM02.1.04.03 |  | 03 |  |  |  | L5 |  |  |  |  |  |  |  |  |  |  |  |  | UDF_G3 |  |  | UDF_G3 |  |  |

Notes:
- S206300: BNL_UDF_Old Activity Name 181221: Design Outer HCAL Scintillating Tiles
- S206700: BNL_UDF_Adhoc Comments: 180330 ELM pred per GRY / BNL_UDF_Old Activity Name 181221: Design Outer HCAL Light Collection
- S206400: BNL_UDF_Old Activity Name 181221: Internal Review of Outer HCAL Scintillating Tiles
- S206500: BNL_UDF_Old Activity Name 181221: Address Issues from Internal Review of Outer HCAL Scintillating Tile
- S206600: BNL_UDF_Old Activity Name 181221: Outer HCAL Scintillating Tile Design Complete
- S206800: BNL_UDF_Old Activity Name 181221: Internal Review of Outer HCAL Light Collection
- S206900: BNL_UDF_Old Activity Name 181221: Address Issues from Internal Review of Outer HCAL Light Collection
- S207100: BNL_UDF_Adhoc Comments: 180330 ELM pred per GRY / BNL_UDF_Old Activity Name 181221: Design Outer HCAL LED/Fiber Calibration System
- S207000: BNL_UDF_Old Activity Name 181221: Outer HCAL Light Collection Complete
- S207200: BNL_UDF_Old Activity Name 181221: Internal Review of Outer HCAL LED/Fiber Calibration System
- S207300: BNL_UDF_Old Activity Name 181221: Address Issues from Internal Review of Outer HCAL LED/Fiber Calibration System
- S207400: BNL_UDF_Adhoc Comments: 180424 name per EOB / BNL_UDF_Old Activity Name 181221: Outer HCAL LED/Fiber Calibration Conceptual Design Complete
- S207700: BNL_UDF_Old Activity Name 181221: Procure Outer HCAL Scintillating Tiles (Prod) - Provide Requirements to Procurement
- S207800: BNL_UDF_Old Activity Name 181221: Procure Outer HCAL Scintillating Tiles (Prod) - Prepare & Send Solicitation
- S207900: BNL_UDF_Adhoc Comments: 180329 ELM dur per GRY / BNL_UDF_Old Activity Name 181221: Procure Outer HCAL Scintillating Tiles (Prod) - Vendor Responses
- S208000: BNL_UDF_Old Activity Name 181221: Procure Outer HCAL Scintillating Tiles (Prod) - Vendor Selection
- S207500: BNL_UDF_Adhoc Comments: 180406 ELM remv proc strg, dur, pred/succ / BNL_UDF_Old Activity Name 181221: Procure Outer HCAL LED/Calibration Fibers Labor
- S207600: BNL_UDF_Adhoc Comments: 180406 ELM remv proc strg, dur, pred/succ / BNL_UDF_Old Activity Name 181221: Procure Outer HCAL LED/Calibration Fibers M&S
- S208100: BNL_UDF_Adhoc Comments: 180420 ELM pred/succ per GRY / BNL_UDF_Old Activity Name 181221: Procure Outer HCAL Scintillating Tiles (Prod) - Contract Award(s)
- S208200: Scheduler's Notes: EMenter 180329 / Successor is SS with lag because the tiles feed the tile / acceptance testing and then feeds the outer HCAL production sector assembly in / WBS 1.04.02.04 / BNL_UDF_Old Activity Name 181221: Procure Outer HCAL Scintillating Tiles (Prod) - Contract/PO - Leadtime
- OBLG208110: BNL_UDF_Adhoc Comments: 180420 ELM pred/succ per GRY / BNL_UDF_Old Activity Name 181221: Procure Outer HCAL Scintillating Tiles (Prod) - Contract Award(s)
- S208220: BNL_UDF_Adhoc Comments: 180227 ELM chg budgeted units per Lajoie/Young / BNL_UDF_Old Activity Name 181221: Procure Outer HCAL Scintillating Tiles (Prod) - Delivery Acceptance
- S208300: BNL_UDF_Adhoc Comments: 180227 ELM chg budgeted units per Lajoie/Young / BNL_UDF_Old Activity Name 181221: Procure Outer HCAL Scintillating Tiles (Prod) - Delivery Acceptance
- S208302: BNL_UDF_Adhoc Comments: 180227 ELM chg budgeted units per Lajoie/Young / BNL_UDF_Old Activity Name 181221: Procure Outer HCAL Scintillating Tiles (Prod) - Delivery Acceptance
- S208303: BNL_UDF_Adhoc Comments: 180227 ELM chg budgeted units per Lajoie/Young / BNL_UDF_Old Activity Name 181221: Procure Outer HCAL Scintillating Tiles (Prod) - Delivery Acceptance
- S208304: BNL_UDF_Adhoc Comments: 180227 ELM chg budgeted units per Lajoie/Young / BNL_UDF_Old Activity Name 181221: Procure Outer HCAL Scintillating Tiles (Prod) - Delivery Acceptance
- S208306: BNL_UDF_Adhoc Comments: 180227 ELM chg budgeted units per Lajoie/Young / BNL_UDF_Old Activity Name 181221: Procure Outer HCAL Scintillating Tiles (Prod) - Delivery Acceptance
- S208400: BNL_UDF_Adhoc Comments: 180220 ELM recoded GSA resource from A - MIE to TP - contracted Labor (kept hours) / BNL_UDF_Old Activity Name 181221: Outer HCAL Scintillating Tile Acceptance Testing
- S208308: BNL_UDF_Adhoc Comments: 180227 ELM chg budgeted units per Lajoie/Young / BNL_UDF_Old Activity Name 181221: Procure Outer HCAL Scintillating Tiles (Prod) - Delivery Acceptance
- S208310: BNL_UDF_Adhoc Comments: 180227 ELM chg budgeted units per Lajoie/Young / BNL_UDF_Old Activity Name 181221: Procure Outer HCAL Scintillating Tiles (Prod) - Delivery Acceptance
- S208410: BNL_UDF_Adhoc Comments: 180220 ELM recoded GSA resource from A - MIE to TP - contracted Labor (kept hours) / BNL_UDF_Old Activity Name 181221: Outer HCAL Scintillating Tile Acceptance Testing
- S208312: BNL_UDF_Adhoc Comments: 180227 ELM chg budgeted units per Lajoie/Young / BNL_UDF_Old Activity Name 181221: Procure Outer HCAL Scintillating Tiles (Prod) - Delivery Acceptance
- S208500: BNL_UDF_Old Activity Name 181221: Completion of Outer HCAL Scintillating Tile Testing

| ID | WBS | Activity | Type | Duration | Start | Finish | Predecessors | Complete | Planned start | Planned finish | Constraint | Resources | Cost | BNL_UDF_Temp Text 01 | BNL_UDF_Percent Complete | BNL_UDF_OPC TEC (deprecated) | BNL_UDF_Temp Text 02 | BNL_UDF_Old Activity ID 181221 | RG Check | BNL_Activity Status | BNL_Estimator | BNL_Location | BNL_EDIA | BNL_CAM | BNL_Institution | BNL_WBS | BNL_PCR ID | BNL_WBS_Hierarchical | Completed | BNL_UDF_Temp Date 01 | BNL_Cost Basis | BNL_R&D FY18-19 | BNL_OPC TEC (deprecated) | BNL_EVT | BNL_Milestone Level | BNL_Proc Sig Phase | BNL_Proc Sig | Cost = Awarded Proc or Mgmt | BNL_Fund Source | BNL_UDF_Exclude | BNL_Split Activity | BNL_Account Number | BNL_DOE OPC | BNL_Obligation | BNL_Cobra WP | BNL_Master Control Account | BNL_Cobra Control Account | Temp | Indicator - Procurement | Indicator - Float | BNL_UDF_Remaining Tot Cost | BNL_UDF_Percent_remaining |
| --- | --- | --- | --- | --- | --- | --- | --- | --- | --- | --- | --- | --- | --- | --- | --- | --- | --- | --- | --- | --- | --- | --- | --- | --- | --- | --- | --- | --- | --- | --- | --- | --- | --- | --- | --- | --- | --- | --- | --- | --- | --- | --- | --- | --- | --- | --- | --- | --- | --- | --- | --- | --- |
|  | 04 | **Outer HCAL Sector Assembly and Testing** |  |  | 2017-02-01 | 2021-04-30 |  |  |  |  |  |  |  |  |  |  |  |  |  |  |  |  |  |  |  |  |  |  |  |  |  |  |  |  |  |  |  |  |  |  |  |  |  |  |  |  |  |  |  |  |  |  |
|  | 01 | **Outer HCAL Sector Assembly and Testing - Preproduction** |  |  | 2017-02-01 | 2021-01-22 |  |  |  |  |  |  |  |  |  |  |  |  |  |  |  |  |  |  |  |  |  |  |  |  |  |  |  |  |  |  |  |  |  |  |  |  |  |  |  |  |  |  |  |  |  |  |
| S200200 |  | Outer HCAL Prototype v2.0 Test Beam Operation |  | 17d | 2017-02-01 A | 2017-02-24 A | S100090 SS | 100% |  |  |  |  |  | S200200 | 100 | S183800 | 0 | S183800 | NOCA | Completed | Bathe, Stefan | ISU | Test_System | John Lajoie | ISU | POM02.1.04.04.01 | 003 | 01 | yes |  |  |  |  |  |  |  |  |  |  |  |  |  |  |  |  |  |  |  |  |  |  |  |
| S200400 |  | Procurement for Outer HCAL Prototype v2.1 Mechanical Structure |  | 60d | 2017-02-01 A | 2017-04-26 A | S100090 SS | 100% |  |  |  |  |  | S200400 | 100 | S184000 | 0 | S184000 | NOCA | Completed | Bathe, Stefan | ISU | Procurement | John Lajoie | ISU | POM02.1.04.04.01 | 003 | 01 | yes |  |  |  |  |  |  |  |  |  |  |  |  |  |  |  |  |  |  |  |  |  |  |  |
| S203700 |  | Build Tile Test Box/Fixture Labor |  | 418d | 2017-02-01 A | 2018-09-28 A | S100090 SS | 100% |  |  |  |  |  | S203700 | 100 | S186800 | 0 | S186800 | NOCA | Completed | Bathe, Stefan | GSU | Fab & Assy | John Lajoie | ISU | POM02.1.04.04.01 | 003 | 01 | yes | 2018-08-31 | L4 | HCal v2.1 | null | C |  |  |  |  |  |  |  |  |  |  |  |  |  |  |  |  |  |  |
| S203800 |  | Build Tile Test Box/Fixture M&S |  | 418d | 2017-02-01 A | 2018-09-28 A | S100090 SS | 100% |  |  |  |  |  | S203800 | 100 | S186900 | 0 | S186900 | NOCA | Completed | Bathe, Stefan | GSU | Fab & Assy | John Lajoie | ISU | POM02.1.04.04.01 | 003 | 01 | yes | 2018-08-31 | M5 | HCal v2.1 | OPC | C |  |  |  |  |  |  |  |  |  |  |  |  |  |  |  |  |  |  |
| S200300 |  | Complete Outer HCAL Prototype v2.0 | milestone | 0d | 2017-02-24 A | 2017-02-24 A | S200200 | 100% |  |  |  |  |  | S200300 | 100 | S183900 | 0 | S183900 | NOCA | Completed | Bathe, Stefan | ISU | Fab & Assy | John Lajoie | ISU | POM02.1.04.04.01 | 003 | 01 | yes |  |  |  |  |  | L5 |  |  |  |  |  |  |  |  |  |  |  |  |  |  |  |  |  |
| S200500 |  | Award Procurement for Outer HCAL Prototype v2.1 Mechanical Structure | milestone | 0d | 2017-04-26 A | 2017-04-26 A | S200300, S200400 | 100% |  |  |  |  |  | S200500 | 100 | S184100 | 0 | S184100 | NOCA | Completed | Bathe, Stefan | ISU | Procurement | John Lajoie | ISU | POM02.1.04.04.01 | 003 | 01 | yes |  |  |  |  |  | L5 |  |  |  |  |  |  |  |  |  |  |  |  |  |  |  |  |  |
| S200600 |  | Outer HCAL Prototype v2.1 Mechanical Structure Production |  | 80d | 2017-04-27 A | 2017-08-18 A | S200500 | 100% |  |  |  |  |  | S200600 | 100 | S184200 | 0 | S184200 | NOCA | Completed | Bathe, Stefan | ISU | Fab & Assy | John Lajoie | ISU | POM02.1.04.04.01 | 003 | 01 | yes |  |  |  |  |  |  |  |  |  |  |  |  |  |  |  |  |  |  |  |  |  |  |  |
| S200900 |  | Procure Scintillating Tiles for HCAL Prototype v2.1 |  | 25d | 2017-06-20 A | 2017-07-25 A | S100090 SS+97d | 100% |  |  |  |  |  | S200900 | 100 | S184500 | 0 | S184500 | NOCA | Completed | Bathe, Stefan | ISU | Procurement | John Lajoie | ISU | POM02.1.04.04.01 | 003 | 01 | yes |  |  | HCal v2.1 |  |  |  |  |  |  |  |  |  |  |  |  |  |  |  |  |  |  |  |  |
| S201000 |  | Award Procurement for Scintillating Tiles for HCAL Test Beam Prototype v2.1 | milestone | 0d | 2017-07-26 A | 2017-07-26 A | S200900 FS+1d | 100% |  |  |  |  |  | S201000 | 100 | S184600 | 0 | S184600 | NOCA | Completed | Bathe, Stefan | ISU | Procurement | John Lajoie | ISU | POM02.1.04.04.01 | 003 | 01 | yes |  |  | HCal v2.1 |  |  | L5 |  |  |  |  |  |  |  |  |  |  |  |  |  |  |  |  |  |
| S201100 |  | Fabricate HCAL Prototype v2.1 Tiles & Ship to BNL |  | 88d | 2017-07-27 A | 2017-12-04 A | S201000 | 100% |  |  |  |  |  | S201100 | 100 | S184700 | 0 | S184700 | NOCA | Completed | Bathe, Stefan | ISU | Fab & Assy | John Lajoie | ISU | POM02.1.04.04.01 | 003 | 01 | yes |  |  | HCal v2.1 |  |  |  |  |  |  |  |  |  |  |  |  |  |  |  |  |  |  |  |  |
| S200700 |  | Incorporate Feedback from Prototype v2.1 into Outer HCAL Design |  | 10d | 2017-08-21 A | 2017-09-01 A | S200600 | 100% |  |  |  |  |  | S200700 | 100 | S184300 | 0 | S184300 | NOCA | Completed | Bathe, Stefan | ISU | Design | John Lajoie | ISU | POM02.1.04.04.01 | 003 | 01 | yes |  |  |  |  |  |  |  |  |  |  |  |  |  |  |  |  |  |  |  |  |  |  |  |
| S200800 |  | Complete Outer HCAL Prototype v2.1 | milestone | 0d | 2017-09-01 A | 2017-09-01 A | S200700 | 100% |  |  |  |  |  | S200800 | 100 | S184400 | 0 | S184400 | NOCA | Completed | Bathe, Stefan | ISU | Fab & Assy | John Lajoie | ISU | POM02.1.04.04.01 | 003 | 01 | yes |  |  |  |  |  | L5 |  |  |  |  |  |  |  |  |  |  |  |  |  |  |  |  |  |
| S200801 |  | Preliminary Design Review - Outer HCAL Sector Assembly 1-6 | milestone | 0d | 2017-09-01 A | 2017-09-01 A | S200800 FF | 100% |  |  |  |  |  | S200800 | 100 | S184400 | 0 | S184400 | NOCA | Completed | Bathe, Stefan | ISU | Fab & Assy | John Lajoie | ISU | POM02.1.04.04.01 | 004 | 01 | yes |  |  |  |  |  | L5 |  |  |  |  |  |  |  |  |  |  |  |  |  |  |  |  |  |
| S201200 |  | Inspect HCAL Prototype v2.1 Scintillating Tiles and Final Design Review and Procurement Readiness Review |  | 10d | 2017-12-05 A | 2017-12-18 A | S201100 | 100% |  |  |  |  |  | S201200 | 100 | S184800 | 0 | S184800 | NOCA | Completed | Bathe, Stefan | ISU | Test_Components | John Lajoie | ISU | POM02.1.04.04.01 | 003,004 | 01 | yes |  |  | HCal v2.1 |  |  |  |  |  |  |  |  |  |  |  |  |  |  |  |  |  |  |  |  |
| S201201 |  | Final Design Review - Outer HCAL Sector Assembly 1-6 | milestone | 0d | 2017-12-18 A | 2017-12-18 A | S201200 FF | 100% |  |  |  |  |  | S201200 | 100 | S184800 | 0 | S184800 | NOCA | Completed | Bathe, Stefan | ISU | Test_Components | John Lajoie | ISU | POM02.1.04.04.01 | 003,004 | 01 | yes |  |  | HCal v2.1 |  |  |  |  |  |  |  |  |  |  |  |  |  |  |  |  |  |  |  |  |
| S201300 |  | Procure Outer HCAL Scint. Tiles for Preproduction - Provide Requirements to Procurement |  | 36d | 2018-05-10 A | 2018-06-29 A | S206600, S207000, S207400, S203700, S203800, S201201 | 100% |  |  |  |  |  | S201300 | 100 | S184900 | 0 | S184900 | NOCA | Completed | Bathe, Stefan | Russia | Procurement | John Lajoie | ISU | POM02.1.04.04.01 | 003 | 01 | yes | 2018-07-02 | L4 |  | null | C |  | PP1 | MP200000 | Yes |  |  |  |  |  |  |  |  |  |  |  |  |  |  |
| S201400 |  | Procure Outer HCAL Scint. Tiles for Preproduction - Prepare & Send Solicitation |  | 19d | 2018-07-02 A | 2018-07-27 A | S201300 | 100% |  |  |  |  |  | S201400 | 100 | S185000 | 0 | S185000 | NOCA | Completed | Bathe, Stefan | Russia | Procurement | John Lajoie | ISU | POM02.1.04.04.01 | 003 | 01 | yes |  | L4 |  | null | C |  | PP2 | MP200000 | Yes |  |  |  |  |  |  |  |  |  |  |  |  |  |  |
| S201500 |  | Procure Outer HCAL Scint. Tiles for Preproduction - Vendor Responses |  | 10d | 2018-07-30 A | 2018-08-10 A | S201400 | 100% |  |  |  |  |  | S201500 | 100 | S185100 | 0 | S185100 | NOCA | Completed | Bathe, Stefan | Russia | Procurement | John Lajoie | ISU | POM02.1.04.04.01 | 003 | 01 | yes |  |  |  |  |  |  | PP3 | MP200000 | Yes |  |  |  |  |  |  |  |  |  |  |  |  |  |  |
| S201600 |  | Procure Outer HCAL Scint. Tiles for Preproduction - Vendor Selection |  | 4d | 2018-08-13 A | 2018-08-16 A | S201500 | 100% |  |  |  |  |  | S201600 | 100 | S185200 | 0 | S185200 | NOCA | Completed | Bathe, Stefan | Russia | Procurement | John Lajoie | ISU | POM02.1.04.04.01 | 003 | 01 | yes |  |  |  |  |  |  | PP4 | MP200000 | Yes |  |  |  |  |  |  |  |  |  |  |  |  |  |  |
| OBLG201710 |  | Procure Outer HCAL Scint. Tiles for Preproduction - Obligation Batch 1 |  | 1d | 2018-08-17 A | 2018-08-17 A | S201600, S207300, S206900, S206500 | 100% |  |  |  | Obligation Resource |  | S201700 | 100 | S185300 | 0 | S185300 | NOCA | Completed | Bathe, Stefan | Russia | Procurement | John Lajoie | ISU | POM02.1.04.04.01 |  | 01 | yes |  |  |  |  |  | L5 | PP5 | MP200000 | Yes | A-OPC |  |  |  |  |  |  |  |  |  |  |  |  |  |
| OBLG201810 |  | Procure Outer HCAL Scint. Tiles for Preproduction - Obligation Batch 2 |  | 1d | 2018-08-17 A | 2018-08-17 A | S201600, S207300, S206900, S206500 | 100% |  |  |  | Obligation Resource |  | S201800 | 100 | S185300 | 0 | S185325 | NOCA | Completed | Bathe, Stefan | Russia | Procurement | John Lajoie | ISU | POM02.1.04.04.01 |  | 01 | yes |  |  |  |  |  | L5 | PP5 | MP200010 | Yes | A-OPC |  |  |  |  |  |  |  |  |  |  |  |  |  |
| OBLG201910 |  | Procure Outer HCAL Scint. Tiles for Preproduction - Obligation Batch 3 |  | 1d | 2018-08-17 A | 2018-08-17 A | S201600, S207300, S206900, S206500 | 100% |  |  |  | Obligation Resource |  | S201900 | 100 | S185300 | 0 | S185350 | NOCA | Completed | Bathe, Stefan | Russia | Procurement | John Lajoie | ISU | POM02.1.04.04.01 |  | 01 | yes |  |  |  |  |  | L5 | PP5 | MP200020 | Yes | A-OPC |  |  |  |  |  |  |  |  |  |  |  |  |  |
| S201700 |  | Procure Outer HCAL Scint. Tiles for Preproduction - Contract Award(s) Batch 1 | milestone | 0d | 2018-08-17 A | 2018-08-17 A | S201600, S207300, S206900, S206500 | 100% |  |  |  |  |  | S201700 | 100 | S185300 | 0 | S185300 | NOCA | Completed | Bathe, Stefan | Russia | Procurement | John Lajoie | ISU | POM02.1.04.04.01 | 003 | 01 | yes |  |  |  |  |  | L5 | PP5 | MP200000 | Yes | A-OPC |  |  |  |  |  |  |  |  |  |  |  |  |  |
| S201800 |  | Procure Outer HCAL Scint. Tiles for Preproduction - Contract Award(s) Batch 2 | milestone | 0d | 2018-08-17 A | 2018-08-17 A | S201600, S207300, S206900, S206500 | 100% |  |  |  |  |  | S201800 | 100 | S185300 | 0 | S185325 | NOCA | Completed | Bathe, Stefan | Russia | Procurement | John Lajoie | ISU | POM02.1.04.04.01 | 003 | 01 | yes |  |  |  |  |  | L5 | PP5 | MP200010 | Yes | A-OPC |  |  |  |  |  |  |  |  |  |  |  |  |  |
| S201900 |  | Procure Outer HCAL Scint. Tiles for Preproduction - Contract Award(s) Batch 3 | milestone | 0d | 2018-08-17 A | 2018-08-17 A | S201600, S207300, S206900, S206500 | 100% |  |  |  |  |  | S201900 | 100 | S185300 | 0 | S185350 | NOCA | Completed | Bathe, Stefan | Russia | Procurement | John Lajoie | ISU | POM02.1.04.04.01 | 003 | 01 | yes |  |  |  |  |  | L5 | PP5 | MP200020 | Yes | A-OPC |  |  |  |  |  |  |  |  |  |  |  |  |  |
| S202000 |  | Procure Outer HCAL Scint. Tiles for Preproduction - Contract lead time FY18 |  | 30d | 2018-08-17 A | 2018-09-28 A | S201700 SS, S201800 SS, S201900 SS, OBLG201710 SS, OBLG201810 SS, OBLG201910 SS | 100% |  |  |  |  |  | S202000 | 100 | S185400 | 0 | S185400 | NOCA | Completed | Bathe, Stefan | Russia | Procurement | John Lajoie | ISU | POM02.1.04.04.01 | 003 | 01 | yes |  |  |  |  |  |  | PP6 | MP200000 | Yes |  | MP6LA | FY18 |  |  |  |  |  |  |  |  |  |  |  |
| S202100 |  | Procure Outer HCAL Scint. Tiles for Preproduction - Contract lead time FY19 |  | 106d | 2018-10-01 A | 2019-03-07 A | S202000 | 100% |  |  |  |  |  | S202100 | 25 | S185400 | 0 | S185450 | NOCA | Completed | Bathe, Stefan | Russia | Procurement | John Lajoie | ISU | POM02.1.04.04.01 | 003 | 01 | yes |  |  |  |  |  |  | PP6 | MP200000 | Yes |  | MP6LA | FY19 |  |  |  |  |  |  |  |  |  |  |  |
| S208600 |  | Procure Contracted Labor Georgia State Univ. (GSU) - Provide Requirements to Procurement |  | 5d | 2018-10-01 A | 2018-10-05 A | S100400 | 100% |  |  |  |  |  | S208600 | 100 |  | 0 | S339480 | NOCA | Completed | Bathe, Stefan | GSU | Procurement | John Lajoie | BNL | POM02.1.04.04.01 | 003 | 01 | yes |  |  |  |  |  |  | PP1 | MP203101 |  |  |  |  |  |  |  |  |  |  |  |  |  |  |  |
| S202700 |  | Procure Table for Outer HCAL sector assembly and testing area (Preproduction) - Labor |  | 111d | 2018-10-16 A | 2019-03-28 A | S203700, S206900, S207300 | 100% |  |  |  |  |  | S202700 | 50 | S186000 | 0 | S186000 | NOCA | Completed | Bathe, Stefan | GSU | Procurement | John Lajoie | ISU | POM02.1.04.04.01 | 003 | 01 | yes |  | L4 | Outer HCal test sectors | null | C |  |  |  |  | B_T |  |  | 16711 |  |  |  |  |  |  |  |  |  |  |
| S202900 |  | Procure Table for Outer HCAL sector assembly and testing area (Preproduction) - M&S |  | 111d | 2018-10-16 A | 2019-03-28 A | S203700, S206900, S207300 | 100% |  |  |  |  |  | S202900 | 50 | S186100 | x | S186100 | NOCA | Completed | Bathe, Stefan | GSU | Fab & Assy | John Lajoie | ISU | POM02.1.04.04.01 | 003 | 01 | yes |  | M5 | Outer HCal test sectors | OPC | C |  |  |  | Yes | A-OPC |  |  | 16703 | OPC001600 |  |  |  |  |  |  |  |  |  |
| S208700 |  | Procure Contracted Labor Georgia State Univ. (GSU) - Vendor Selection |  | 93d | 2018-10-16 A | 2019-03-04 A | S208600 | 100% |  |  |  |  |  | S208700 | 0 |  | 0 | S339520 | NOCA | Completed | Bathe, Stefan | GSU | Procurement | John Lajoie | BNL | POM02.1.04.04.01 | 003 | 01 | yes | 2018-11-30 |  |  |  |  |  | PP3 | MP203101 |  |  |  |  |  |  |  |  |  |  |  |  |  |  |  |
| S202800 |  | Procure Miscellaneous Tools for Outer HCAL sector assembly and testing area (Preproduction) - Labor |  | 65d | 2019-03-01 A | 2019-05-31 A | S319100, S203700, S206900, S207300 | 100% |  |  |  |  |  | S202800 | 0 | S186000 | x | S186025 | NOCA | Completed | Bathe, Stefan | GSU | Procurement | John Lajoie | ISU | POM02.1.04.04.01 | 003 | 01 | yes |  | L4 | Outer HCal test sectors | null | C |  |  |  |  | B_T |  |  | 16711 |  |  |  |  |  |  |  |  |  |  |
| S203000 |  | Procure Miscellaneous Tools for Outer HCAL sector assembly and testing area (Preproduction) - M&S |  | 65d | 2019-03-01 A | 2019-05-31 A | S203700, S206900, S207300, S319100 | 100% |  |  |  |  |  | S203000 | 0 | S186100 | x | S186125 | NOCA | Completed | Bathe, Stefan | GSU | Fab & Assy | John Lajoie | ISU | POM02.1.04.04.01 | 003 | 01 | yes |  | M5 | Outer HCal test sectors | OPC | C |  |  |  |  | A-OPC |  |  | 16703 | OPC001600 |  |  |  |  |  |  |  |  |  |
| S202200 |  | Procure Outer HCAL Scint. Tiles for Preproduction - Delivery Acceptance Batch 1 |  | 12d | 2019-03-12 A | 2019-03-27 A | S202100 | 100% |  |  |  |  |  | S202200 | 0 | S185500 | 0 | S185500 | NOCA | Completed | Bathe, Stefan | Russia | Fab & Assy | John Lajoie | ISU | POM02.1.04.04.01 | 003 | 01 | yes |  | M5 |  | OPC | F |  | PP6 | MP200000 | Yes | A-OPC | MP6LA |  | 16703 | OPC001600 |  |  |  |  |  |  |  |  |  |
| S202300 |  | Procure Outer HCAL Scint. Tiles for Preproduction - Delivery Acceptance Batch 2 |  | 15d | 2019-04-03 A | 2019-04-23 A | S202100, S202200 | 100% |  |  |  |  |  | S202300 | 0 | S185500 | 0 | S185510 | NOCA | Completed | Bathe, Stefan | Russia | Fab & Assy | John Lajoie | ISU | POM02.1.04.04.01 | 003 | 01 | yes |  | M5 |  | OPC | F |  | PP6 | MP200010 | Yes | A-OPC | MP6LA |  | 16703 | OPC001600 |  |  |  |  |  |  |  |  |  |
| S202400 |  | Procure Outer HCAL Scint. Tiles for Preproduction - Delivery Acceptance Batch 3 |  | 16d | 2019-05-02 A | 2019-05-23 A | S202300 | 100% |  |  |  |  |  | S202400 | 0 | S185500 | 0 | S185520 | NOCA | Completed | Bathe, Stefan | Russia | Fab & Assy | John Lajoie | ISU | POM02.1.04.04.01 | 003 | 01 | yes |  | M5 |  | OPC | F |  | PP6 | MP200020 | Yes | A-OPC | MP6LA |  | 16703 | OPC001600 |  |  |  |  |  |  |  |  |  |
| S202500 |  | Outer HCAL Scintillating Tile Acceptance Testing (Preproduction), Contributed Labor |  | 5d | 2019-05-24 A | 2019-05-31 A | S202200, S202400 FF+20d | 100% |  |  |  |  |  | S202500 | 0 | S185700 | 0 | S185700 | NOCA | Completed | Bathe, Stefan | GSU | Test_System | John Lajoie | ISU | POM02.1.04.04.01 | 003 | 01 | yes |  | L4 | Outer HCal test sectors | null | C |  |  |  |  | B_T |  |  | 16711 |  |  |  |  |  |  |  |  |  |  |
| S202510 |  | Outer HCAL Scintillating Tile Acceptance Testing (Preproduction) |  | 5d | 2019-05-24 A | 2019-05-31 A | S202200, S202400 FF+20d | 100% |  |  |  |  |  | S202500 | 0 | S185700 | 0 | S185700 | NOCA | Completed | Bathe, Stefan | GSU | Test_System | John Lajoie | ISU | POM02.1.04.04.01 | 003 | 01 | yes |  | L4 | Outer HCal test sectors | null | C |  | PP6 | MP203101 | Yes | A-OPC |  |  | 16703 |  | FAB |  |  |  |  |  |  |  |  |
| S202802 |  | Procure Miscellaneous Tools for Outer HCAL sector assembly and testing area (Preproduction) Labor Split |  | 84d | 2019-06-03 A | 2019-11-25 A | S202800 | 100% | 2019-06-03 | 2019-09-30 |  | CRAFT3 [1 h]; POSTDOC GSU - Unpaid [1 h]; STUDENT GSU - Unpaid [1 h]; TECH3 PO M [1 h] | 232.23 | S202800 | 0 | S186000 | x | S186025 | CA | Completed | Bathe, Stefan | GSU | Procurement | John Lajoie | ISU | POM02.1.04.04.01 | 003 | 01 |  |  | L4 | Outer HCal test sectors | null | C |  |  |  |  | B_T |  |  | 16711 |  |  | S202802 | 1.04 | 1.04B | 1 |  |  |  |  |
| S203002 |  | Procure Miscellaneous Tools for Outer HCAL sector assembly and testing area (Preproduction) - M&S Split |  | 77d | 2019-06-03 A | 2019-11-25 A | S203000 | 100% | 2019-06-03 | 2019-09-19 |  | Material (Purchase (1st $2M) [2000 h] | 2,206.53 | S203000 | 0 | S186100 | x | S186125 | CA | Completed | Bathe, Stefan | GSU | Fab & Assy | John Lajoie | ISU | POM02.1.04.04.01 | 003 | 01 |  |  | M5 | Outer HCal test sectors | OPC | C |  |  |  |  | A-OPC |  |  | 16703 | OPC001600 |  | S203002 | 1.04 | 1.04A |  | UDF_G2 |  |  |  |
| S202502 |  | Outer HCAL Scintillating Tile Acceptance Testing (Preproduction), Contributed Labor Split |  | 10d | 2019-07-01 A | 2019-07-15 A | S202500 | 100% |  |  |  | PROF3 PO E [13 h]; PROF4 PO M [6 h]; SCI 4 PO [57 h]; SCI3 PO [13 h]; STUDENT GSU OnC - Purchased Services [125 h]; TECH3 PO D [6 h] | 18,803.34 | S202500 | 0 | S185700 | 0 | S185700 | CA | Completed | Bathe, Stefan | GSU | Test_System | John Lajoie | ISU | POM02.1.04.04.01 | 003 | 01 |  |  | L4 | Outer HCal test sectors | null | C |  |  |  |  | B_T |  |  | 16711 |  |  | S202502 | 1.04 | 1.04B |  |  |  |  |  |
| S202512 |  | Outer HCAL Scintillating Tile Acceptance Testing (Preproduction) Split |  | 10d | 2019-07-01 A | 2019-07-15 A | S202510 | 100% |  |  |  | STUDENT GSU OnC - Purchased Services [125 h] | 2,116.89 | S202500 | 0 | S185700 | 0 | S185700 | CA | Completed | Bathe, Stefan | GSU | Test_System | John Lajoie | ISU | POM02.1.04.04.01 | 003 | 01 |  |  | L4 | Outer HCal test sectors | null | C |  | PP6 | MP203101 | Yes | A-OPC |  |  | 16703 |  | FAB | S202512 | 1.04 | 1.04A |  |  |  |  |  |
| S202600 |  | Completion of Outer HCAL Scintillating Tile Procurement (Preproduction) | milestone | 0d | 2019-07-01 A | 2019-07-01 A | S202400 FF | 100% |  |  |  |  |  | S202600 | 0 | S185800 | 0 | S185800 | NOCA | Completed | Bathe, Stefan | GSU | Procurement | John Lajoie | ISU | POM02.1.04.04.01 | 003 | 01 |  |  |  | Outer HCal test sectors |  |  | L5 |  |  |  |  |  |  |  |  |  |  |  |  |  |  |  |  |  |
| S203200 |  | Populate Outer HCAL sectors with electronics (Preproduction) |  | 60d | 2019-08-01 A | 2020-11-30 A | S203100 SS+10d, S236900, S237200, S237500, S236300, S237900, S203110 SS+10d | 100% | 2020-02-04 | 2020-04-28 |  | STUDENT GSU OffC - Purchased Services [248 h] | 3,590.65 | S203200 | 0 | S186300 | x | S186300 | CA | In Progress | Bathe, Stefan | GSU | Fab & Assy | John Lajoie | ISU | POM02.1.04.04.01 | 003 | 01 |  |  | L4 | Outer HCal test sectors | null | C |  | PP6 | MP203101 | Yes | A-OPC |  |  | 16703 |  | FAB | S203200 | 1.04 | 1.04A |  |  |  |  |  |
| S203210 |  | Populate Outer HCAL sectors with electronics (Preproduction) - Contributed Labor_50% |  | 42d | 2019-08-01 A | 2020-11-30 A | S203100 SS+10d, S236900, S237200, S237500, S236300, S237900, S203110 SS+10d | 100% | 2019-08-01 | 2019-09-30 |  | POSTDOC GSU - Unpaid [62 h]; SCI 4 PO [97 h]; TECH3 PO M [372 h] | 60,608.21 | S203200 | 0 | S186300 | x | S186300 | CA | In Progress | Bathe, Stefan | GSU | Fab & Assy | John Lajoie | ISU | POM02.1.04.04.01 | 003 | 01 |  |  | L4 | Outer HCal test sectors | null | C |  |  |  |  | B_T |  |  | 16711 |  |  | S203210 | 1.04 | 1.04B | 1 |  |  |  |  |
| S203100 |  | Populate Outer HCAL sectors with scintillating tiles (Preproduction) |  | 21d | 2019-08-02 A | 2019-08-30 A | S203050 | 100% |  |  |  | STUDENT GSU OffC - Purchased Services [248 h] | 3,447.48 | S203100 | 0 | S186200 | x | S186200 | CA | Completed | Bathe, Stefan | GSU | Fab & Assy | John Lajoie | ISU | POM02.1.04.04.01 | 003 | 01 |  |  | L4 | Outer HCal test sectors | null | C |  | PP6 | MP203101 | Yes | A-OPC |  |  | 16703 |  | FAB | S203100 | 1.04 | 1.04A |  |  |  |  |  |
| S203110 |  | Populate Outer HCAL sectors with scintillating tiles (Preproduction) - Contributed Labor |  | 21d | 2019-08-02 A | 2019-08-30 A | S203050 | 100% |  |  |  | POSTDOC GSU - Unpaid [62 h]; SCI 4 PO [97 h]; TECH3 PO M [372 h] | 60,608.21 | S203100 | 0 | S186200 | x | S186200 | CA | Completed | Bathe, Stefan | GSU | Fab & Assy | John Lajoie | ISU | POM02.1.04.04.01 | 003 | 01 |  |  | L4 | Outer HCal test sectors | null | C |  |  |  |  | B_T |  |  | 16711 |  |  | S203110 | 1.04 | 1.04B |  |  |  |  |  |
| S208800 |  | Procure Contracted Labor Georgia State Univ. (GSU), Phase 1 - Contract Award | milestone | 0d | 2019-08-07 A | 2019-08-07 A | S208700, S100500 | 100% |  |  | start on or after 2019-08-07 |  |  | S208800 | 0 |  | 0 | S339560 | NOCA | Completed | Bathe, Stefan | GSU | Procurement | John Lajoie | BNL | POM02.1.04.04.01 | 003,004 | 01 |  |  |  |  |  |  | L5 | PP5 | MP203101 |  | A-OPC |  |  |  |  |  |  |  |  |  |  |  |  |  |
| S208900 |  | Procure Contracted Labor Georgia State Univ. (GSU), Phase 1 - Delivery Acceptance |  | 60d | 2019-08-07 A | 2019-08-30 A | S208800 SS, OBLG208810 SS | 100% | 2019-08-07 | 2019-10-31 | start on or after 2019-08-07 |  |  | S208900 | 0 |  | 0 | S339600 | NOCA | Completed | Bathe, Stefan | GSU | Fab & Assy | John Lajoie | BNL | POM02.1.04.04.01 | 003,004 | 01 |  |  | M4 |  | OPC | F |  | PP6 | MP203101 |  | A-OPC | MP6LA |  | 16703 | OPC001600 | FAB |  |  |  |  |  |  |  |  |
| OBLG208810 |  | Procure Contracted Labor Georgia State Univ. (GSU), Phase 1 - Obligation |  | 1d | 2019-09-03 A | 2019-09-03 A | S208700, S100500 | 100% |  |  |  | Obligation Resource [16503 h] | 16,503 | S208800 | 0 |  | 0 | S339560 |  | Completed | Bathe, Stefan | GSU | Procurement | John Lajoie | BNL | POM02.1.04.04.01 |  | 01 |  |  |  |  |  |  | L5 | PP5 | MP203101 |  | A-OPC |  |  |  |  | OBLG |  |  |  |  |  |  |  |  |
| S203300 |  | Outer HCAL Sector LED testing and Light Tighting (Preproduction) Labor |  | 60d | 2019-11-04 A | 2020-12-30 A | S203200 SS+10d | 100% | 2020-03-04 | 2020-05-27 |  | STUDENT GSU OffC - Purchased Services [248 h] | 3,590.65 | S203300 | 0 | S186400 | x | S186400 | CA | In Progress | Bathe, Stefan | GSU | Test_System | John Lajoie | ISU | POM02.1.04.04.01 | 003 | 01 |  |  | L4 | Outer HCal test sectors | null | C |  | PP6 | MP203101 | Yes | A-OPC |  |  | 16703 |  | FAB | S203300 | 1.04 | 1.04A |  |  |  |  |  |
| S203310 |  | Outer HCAL Sector LED testing and Light Tighting (Preproduction) - Contributed Labor |  | 60d | 2019-11-04 A | 2020-12-30 A | S203210 SS+10d | 100% | 2020-03-04 | 2020-05-27 |  | TECH3 PO M [248 h]; POSTDOC GSU - Unpaid [62 h]; SCI 4 PO [97 h] | 48,275.31 | S203300 | 0 | S186400 | x | S186400 | CA | In Progress | Bathe, Stefan | GSU | Test_System | John Lajoie | ISU | POM02.1.04.04.01 | 003 | 01 |  |  | L4 | Outer HCal test sectors | null | C |  |  |  |  | B_T |  |  | 16711 |  |  | S203310 | 1.04 | 1.04B |  |  |  |  |  |
| S203400 |  | Outer HCAL Sector LED testing and Light Tighting (Preproduction) M&S |  | 60d | 2019-11-04 A | 2020-12-30 A | S203200 SS+10d, S203210 SS+10d | 100% | 2020-03-04 | 2020-05-27 |  | Material (Purchase (1st $2M) [4800 h] | 5,462.04 | S203400 | 0 | S186500 | x | S186500 | CA | In Progress | Bathe, Stefan | GSU | Test_Components | John Lajoie | ISU | POM02.1.04.04.01 | 003 | 01 |  |  | M5 | Outer HCal test sectors | OPC | C |  |  |  |  | A-OPC |  |  | 16703 | OPC001600 |  | S203400 | 1.04 | 1.04A |  | UDF_G1 | UDF_G1 | 4588.11678528 | 0.84 |
| S203050 |  | Production Readiness Review - Outer HCAL Sector Assembly 1-6 |  | 1d | 2019-11-13 A | 2019-11-18 A | S320500, S236300, S236600, S202700 SS, S202900 SS, S321000, S202200, S202502, S202512, S203002 SS, S202802 | 100% | 2019-12-18 | 2019-12-18 |  | FACULTY ISU - Unpaid [8 h]; PROF3 PO M [4 h]; SCI 4 PO [4 h] | 1,329.67 | S203100 | 0 | S186200 | x | S186200 | CA | Completed | Bathe, Stefan | GSU | Fab & Assy | John Lajoie | ISU | POM02.1.04.04.01 | 003,004 | 01 |  |  | L4 | Outer HCal test sectors | null | C |  | PP6 | MP203101 | Yes | B_T |  |  | 16711 |  |  | S203050 | 1.04 | 1.04B |  |  |  |  |  |
| S203500 |  | Outer HCAL Cosmics testing and initial calibration (Preproduction) |  | 60d | 2019-11-25 A | 2020-12-30 A | S203300 SS+10d, S203400 SS+10d | 100% | 2020-03-04 | 2020-05-27 |  | STUDENT GSU OffC - Purchased Services [248 h] | 3,590.65 | S203500 | 0 | S186600 | x | S186600 | CA | In Progress | Bathe, Stefan | GSU | Test_System | John Lajoie | ISU | POM02.1.04.04.01 | 003 | 01 |  |  | L4 | Outer HCal test sectors | null | C |  | PP6 | MP203101 | Yes | A-OPC |  |  | 16703 |  | FAB | S203500 | 1.04 | 1.04A |  |  |  |  |  |
| S203510 |  | Outer HCAL Cosmics testing and initial calibration (Preproduction) - Contributed Labor |  | 60d | 2019-11-25 A | 2020-12-30 A | S203310 SS+10d, S203400 SS+10d | 100% | 2020-03-04 | 2020-05-27 |  | POSTDOC GSU - Unpaid [62 h]; SCI 4 PO [97 h] | 19,973.02 | S203500 | 0 | S186600 | x | S186600 | CA | In Progress | Bathe, Stefan | GSU | Test_System | John Lajoie | ISU | POM02.1.04.04.01 | 003 | 01 |  |  | L4 | Outer HCal test sectors | null | C |  |  |  |  | B_T |  |  | 16711 |  |  | S203510 | 1.04 | 1.04B |  |  |  |  |  |
| S203600 |  | Outer HCAL Sector Transportation to Storage Area (Preproduction) |  | 60d | 2020-11-23 A | 2021-01-22 A | S203500 FF+10d, S203510 FF+10d | 100% | 2020-12-01 | 2021-02-26 |  | TECH3 PO M [12 h]; CRAFT3 [48 h] | 7,594.08 | S203600 | 0 | S186700 | x | S186700 | CA | Not Started | Bathe, Stefan | GSU | Fab & Assy | John Lajoie | ISU | POM02.1.04.04.01 | 003 | 01 |  |  | L5 | Outer HCal test sectors | null | C |  |  |  |  | B |  |  | 16711 |  |  | S203600 | 1.04 | 1.04B |  |  |  |  |  |

Notes:
- S200200: BNL_UDF_Status Comments: 190314 ELM move activity to new WBS / BNL_UDF_Old Activity Name 181221: Outer HCAL Prototype v2.0 Test Beam Operation
- S200400: BNL_UDF_Status Comments: 190314 ELM move activity to new WBS / BNL_UDF_Old Activity Name 181221: Procurement for Outer HCAL Prototype v2.1 Mechanical Structure
- S203700: BNL_UDF_Status Comments: 190314 ELM move activity to new WBS / BNL_UDF_Old Activity Name 181221: Build Tile Test Box/Fixture Labor
- S203800: BNL_UDF_Status Comments: 190314 ELM move activity to new WBS / BNL_UDF_Old Activity Name 181221: Build Tile Test Box/Fixture M&S
- S200300: BNL_UDF_Status Comments: 190314 ELM move activity to new WBS / BNL_UDF_Old Activity Name 181221: Complete Outer HCAL Prototype v2.0
- S200500: BNL_UDF_Status Comments: 190314 ELM move activity to new WBS / BNL_UDF_Old Activity Name 181221: Award Procurement for Outer HCAL Prototype v2.1 Mechanical Structure
- S200600: BNL_UDF_Status Comments: 190314 ELM move activity to new WBS / BNL_UDF_Old Activity Name 181221: Outer HCAL Prototype v2.1 Mechanical Structure Production
- S200900: BNL_UDF_Status Comments: 190314 ELM move activity to new WBS / BNL_UDF_Old Activity Name 181221: Procure Scintillating Tiles for HCAL Prototype v2.1
- S201000: BNL_UDF_Status Comments: 190314 ELM move activity to new WBS / BNL_UDF_Old Activity Name 181221: Award Procurement for Scintillating Tiles for HCAL Test Beam Prototype v2.1
- S201100: BNL_UDF_Status Comments: 190314 ELM move activity to new WBS / BNL_UDF_Old Activity Name 181221: Fabricate HCAL Prototype v2.1 Tiles & Ship to BNL
- S200700: BNL_UDF_Status Comments: 190314 ELM move activity to new WBS / BNL_UDF_Old Activity Name 181221: Incorporate Feedback from Prototype v2.1 into Outer HCAL Design
- S200800: BNL_UDF_Status Comments: 190314 ELM move activity to new WBS / BNL_UDF_Old Activity Name 181221: Complete Outer HCAL Prototype v2.1
- S200801: BNL_UDF_Status Comments: 190508 ELM add per GRY / BNL_UDF_Old Activity Name 181221: Complete Outer HCAL Prototype v2.1
- S201200: BNL_UDF_Status Comments: 190415 ELM name per GRY; 190314 ELM move activity to new WBS / BNL_UDF_Old Activity Name 181221: Inspect HCAL Prototype v2.1 Scintillating Tiles
- S201201: BNL_UDF_Status Comments: 190508 ELM add per GRY / BNL_UDF_Old Activity Name 181221: Inspect HCAL Prototype v2.1 Scintillating Tiles
- S201300: BNL_UDF_Status Comments: 190314 ELM move activity to new WBS / BNL_UDF_Adhoc Comments: 180220 ELM added MP & PP Nos. / BNL_UDF_Old Activity Name 181221: Procure Outer HCAL Scint. Tiles for Preproduction - Provide Requirements to Procurement
- S201400: BNL_UDF_Status Comments: 190314 ELM move activity to new WBS / BNL_UDF_Adhoc Comments: 180220 ELM added MP & PP Nos. / BNL_UDF_Old Activity Name 181221: Procure Outer HCAL Scint. Tiles for Preproduction - Prepare & Send Solicitation
- S201500: BNL_UDF_Status Comments: 190314 ELM move activity to new WBS / BNL_UDF_Adhoc Comments: 180220 ELM added MP & PP Nos. / BNL_UDF_Old Activity Name 181221: Procure Outer HCAL Scint. Tiles for Preproduction - Vendor Responses
- S201600: BNL_UDF_Status Comments: 190314 ELM move activity to new WBS / BNL_UDF_Adhoc Comments: 180220 ELM added MP & PP Nos. / BNL_UDF_Old Activity Name 181221: Procure Outer HCAL Scint. Tiles for Preproduction - Vendor Selection
- OBLG201710: BNL_UDF_Adhoc Comments: 180420 ELM pred/succ per GRY; 180220 ELM added MP & PP Nos. / BNL_UDF_Old Activity Name 181221: Procure Outer HCAL Scint. Tiles for Preproduction - Contract Award(s) Batch 1
- OBLG201810: BNL_UDF_Adhoc Comments: 180420 ELM pred/succ per GRY; 180220 ELM added MP & PP Nos. / BNL_UDF_Old Activity Name 181221: Procure Outer HCAL Scint. Tiles for Preproduction - Contract Award(s) Batch 2
- OBLG201910: BNL_UDF_Adhoc Comments: 180420 ELM pred/succ per GRY; 180220 ELM added MP & PP Nos. / BNL_UDF_Old Activity Name 181221: Procure Outer HCAL Scint. Tiles for Preproduction - Contract Award(s) Batch 3
- S201700: BNL_UDF_Status Comments: 190314 ELM move activity to new WBS / BNL_UDF_Adhoc Comments: 180420 ELM pred/succ per GRY; 180220 ELM added MP & PP Nos. / BNL_UDF_Old Activity Name 181221: Procure Outer HCAL Scint. Tiles for Preproduction - Contract Award(s) Batch 1
- S201800: BNL_UDF_Status Comments: 190314 ELM move activity to new WBS / BNL_UDF_Adhoc Comments: 180420 ELM pred/succ per GRY; 180220 ELM added MP & PP Nos. / BNL_UDF_Old Activity Name 181221: Procure Outer HCAL Scint. Tiles for Preproduction - Contract Award(s) Batch 2
- S201900: BNL_UDF_Status Comments: 190314 ELM move activity to new WBS / BNL_UDF_Adhoc Comments: 180420 ELM pred/succ per GRY; 180220 ELM added MP & PP Nos. / BNL_UDF_Old Activity Name 181221: Procure Outer HCAL Scint. Tiles for Preproduction - Contract Award(s) Batch 3
- S202000: BNL_UDF_Status Comments: 190314 ELM move activity to new WBS / BNL_UDF_Adhoc Comments: 180220 ELM added MP & PP Nos. / BNL_UDF_Old Activity Name 181221: Procure Outer HCAL Scint. Tiles for Preproduction - Contract lead time FY18
- S202100: BNL_UDF_Status Comments: 190314 ELM move activity to new WBS / BNL_UDF_Adhoc Comments: 180220 ELM added MP & PP Nos. / BNL_UDF_Old Activity Name 181221: Procure Outer HCAL Scint. Tiles for Preproduction - Contract lead time FY19
- S208600: BNL_UDF_Status Comments: 190314 ELM move activity to new WBS / BNL_UDF_Adhoc Comments: 180330 ELM pre per GRY; 180220 ELM Added Procurement String for GSU Contracted labor / BNL_UDF_Old Activity Name 181221: Procure Contracted Labor Georgia State Univ. (GSU) - Provide Requirements to Procurement
- S202700: BNL_UDF_Status Comments: 190314 ELM move activity to new WBS / BNL_UDF_Adhoc Comments: 180420 ELM rsrc GRY; 180406 ELM pred/succ per GRY; 180220 ELM recoded GSA resource from A - MIE to TP - contracted Labor (kept hours) / BNL_UDF_Old Activity Name 181221: Procure Table for Outer HCAL sector assembly and testing area (Preproduction) - Labor
- S202900: BNL_UDF_Status Comments: 190314 ELM move activity to new WBS / BNL_UDF_Adhoc Comments: 180406 ELM pred/succ per GRY / BNL_UDF_Old Activity Name 181221: Procure Table for Outer HCAL sector assembly and testing area (Preproduction) - M&S
- S208700: BNL_UDF_Status Comments: 190314 ELM move activity to new WBS / BNL_UDF_Adhoc Comments: 180220 ELM Added Procurement String for GSU Contracted labor / BNL_UDF_Old Activity Name 181221: Procure Contracted Labor Georgia State Univ. (GSU) - Vendor Selection
- S202800: BNL_UDF_Status Comments: 190314 ELM move activity to new WBS / BNL_UDF_Adhoc Comments: 180420 ELM rsrc GRY; 180406 ELM pred/succ per GRY; 180220 ELM recoded GSA resource from A - MIE to TP - contracted Labor (kept hours) / BNL_UDF_Old Activity Name 181221: Procure Miscellaneous Tools for Outer HCAL sector assembly and testing area (Preproduction) - Labor
- S203000: BNL_UDF_Status Comments: 190314 ELM move activity to new WBS / BNL_UDF_Adhoc Comments: 180406 ELM pred/succ per GRY / BNL_UDF_Old Activity Name 181221: Procure Miscellaneous Tools for Outer HCAL sector assembly and testing area (Preproduction) - M&S
- S202200: BNL_UDF_Status Comments: 190314 ELM move activity to new WBS / BNL_UDF_Adhoc Comments: 180227 ELM chg budgeted units per JLajoie/GRY; 180220 ELM added MP & PP Nos. / BNL_UDF_Old Activity Name 181221: Procure Outer HCAL Scint. Tiles for Preproduction - Delivery Acceptance Batch 1
- S202300: BNL_UDF_Status Comments: 190314 ELM move activity to new WBS / BNL_UDF_Adhoc Comments: 180227 ELM chg budgeted units per JLajoie/GRY; 180220 ELM added MP & PP Nos. / BNL_UDF_Old Activity Name 181221: Procure Outer HCAL Scint. Tiles for Preproduction - Delivery Acceptance Batch 2
- S202400: BNL_UDF_Status Comments: 190314 ELM move activity to new WBS / BNL_UDF_Adhoc Comments: 180227 ELM chg budgeted units per JLajoie/GRY; 180220 ELM added MP & PP Nos. / BNL_UDF_Old Activity Name 181221: Procure Outer HCAL Scint. Tiles for Preproduction - Delivery Acceptance Batch 3
- S202500: BNL_UDF_Status Comments: 190314 ELM move activity to new WBS / BNL_UDF_Adhoc Comments: 180423 ELM rsrc per GRY; 180220 ELM recoded GSA resource from A - MIE to TP - contracted Labor (kept hours) / BNL_UDF_Old Activity Name 181221: Outer HCAL Scintillating Tile Acceptance Testing (Preproduction)
- S202510: BNL_UDF_Status Comments: 190314 ELM move activity to new WBS / BNL_UDF_Adhoc Comments: 180423 ELM rsrc per GRY; 180220 ELM recoded GSA resource from A - MIE to TP - contracted Labor (kept hours) / BNL_UDF_Old Activity Name 181221: Outer HCAL Scintillating Tile Acceptance Testing (Preproduction)
- S202802: BNL_UDF_Status Comments: 190314 ELM move activity to new WBS / BNL_UDF_Adhoc Comments: 180420 ELM rsrc GRY; 180406 ELM pred/succ per GRY; 180220 ELM recoded GSA resource from A - MIE to TP - contracted Labor (kept hours) / BNL_UDF_Old Activity Name 181221: Procure Miscellaneous Tools for Outer HCAL sector assembly and testing area (Preproduction) - Labor
- S203002: BNL_UDF_Status Comments: 190314 ELM move activity to new WBS / BNL_UDF_Adhoc Comments: 180406 ELM pred/succ per GRY / BNL_UDF_Old Activity Name 181221: Procure Miscellaneous Tools for Outer HCAL sector assembly and testing area (Preproduction) - M&S
- S202502: BNL_UDF_Status Comments: 190314 ELM move activity to new WBS / BNL_UDF_Adhoc Comments: 180423 ELM rsrc per GRY; 180220 ELM recoded GSA resource from A - MIE to TP - contracted Labor (kept hours) / BNL_UDF_Old Activity Name 181221: Outer HCAL Scintillating Tile Acceptance Testing (Preproduction)
- S202512: BNL_UDF_Status Comments: 190314 ELM move activity to new WBS / BNL_UDF_Adhoc Comments: 180423 ELM rsrc per GRY; 180220 ELM recoded GSA resource from A - MIE to TP - contracted Labor (kept hours) / BNL_UDF_Old Activity Name 181221: Outer HCAL Scintillating Tile Acceptance Testing (Preproduction)
- S202600: BNL_UDF_Status Comments: 190314 ELM move activity to new WBS / BNL_UDF_Old Activity Name 181221: Completion of Outer HCAL Scintillating Tile Procurement (Preproduction)
- S203200: BNL_UDF_Status Comments: 190314 ELM move activity to new WBS; 190313 ELM Activity split for fund src / BNL_UDF_Adhoc Comments: 180423 ELM rsrc per GRY; 180410 ELM pred/succ per GRY; 180220 ELM recoded GSA resource from A - MIE to TP - contracted Labor (kept hours) / BNL_UDF_Old Activity Name 181221: Populate Outer HCAL sectors with electronics (Preproduction)
- S203210: BNL_UDF_Status Comments: 190314 ELM move activity to new WBS; 190313 ELM Activity split for fund src / BNL_UDF_Adhoc Comments: 180423 ELM rsrc per GRY; 180410 ELM pred/succ per GRY; 180220 ELM recoded GSA resource from A - MIE to TP - contracted Labor (kept hours) / BNL_UDF_Old Activity Name 181221: Populate Outer HCAL sectors with electronics (Preproduction)
- S203100: BNL_UDF_Status Comments: 190314 ELM move activity to new WBS; 190313 ELM Activity split for fund src / BNL_UDF_Adhoc Comments: 180423 ELM rsrc per GRY; 180220 ELM recoded GSA resource from A - MIE to TP - contracted Labor (kept hours) / BNL_UDF_Old Activity Name 181221: Populate Outer HCAL sectors with scintillating tiles (Preproduction)
- S203110: BNL_UDF_Status Comments: 190314 ELM move activity to new WBS; 190313 ELM Activity split for fund src / BNL_UDF_Adhoc Comments: 180423 ELM rsrc per GRY; 180220 ELM recoded GSA resource from A - MIE to TP - contracted Labor (kept hours) / BNL_UDF_Old Activity Name 181221: Populate Outer HCAL sectors with scintillating tiles (Preproduction)
- S208800: BNL_UDF_Status Comments: 190417 ELM name; 190317 ELM name; 190314 ELM move activity to new WBS / BNL_UDF_Adhoc Comments: 180410 ELM pred/succ; 180330 ELM remove constraint per GRY; 180330 ELM pre per GRY; 180220 ELM Added Procurement String for GSU Contracted labor / BNL_UDF_Old Activity Name 181221: Procure Contracted Labor Georgia State Univ. (GSU) - Contract Award FY 18 - OPC
- S208900: BNL_UDF_Status Comments: 190417 ELM name; 190317 ELM name; 190314 ELM move activity to new WBS / BNL_UDF_Adhoc Comments: 180220 ELM Added Procurement String for GSU Contracted labor / BNL_UDF_Old Activity Name 181221: Procure Contracted Labor Georgia State Univ. (GSU) - Delivery Acceptance FY 18 - OPC
- OBLG208810: BNL_UDF_Adhoc Comments: 180410 ELM pred/succ; 180330 ELM remove constraint per GRY; 180330 ELM pre per GRY; 180220 ELM Added Procurement String for GSU Contracted labor / BNL_UDF_Old Activity Name 181221: Procure Contracted Labor Georgia State Univ. (GSU) - Contract Award FY 18 - OPC
- S203300: BNL_UDF_Status Comments: 190314 ELM move activity to new WBS; 190313 ELM Activity split for fund src / BNL_UDF_Adhoc Comments: 180423 ELM rsrc per GRY; 180410 ELM pred/succ per GRY; 180220 ELM recoded GSA resource from A - MIE to TP - contracted Labor (kept hours) / BNL_UDF_Old Activity Name 181221: Outer HCAL Sector LED testing and Light Tighting (Preproduction) Labor
- S203310: BNL_UDF_Status Comments: 190314 ELM move activity to new WBS; 190313 ELM Activity split for fund src / BNL_UDF_Adhoc Comments: 180423 ELM rsrc per GRY; 180410 ELM pred/succ per GRY; 180220 ELM recoded GSA resource from A - MIE to TP - contracted Labor (kept hours) / BNL_UDF_Old Activity Name 181221: Outer HCAL Sector LED testing and Light Tighting (Preproduction) Labor
- S203400: BNL_UDF_Status Comments: 190314 ELM move activity to new WBS / BNL_UDF_Old Activity Name 181221: Outer HCAL Sector LED testing and Light Tighting (Preproduction) M&S
- S203050: BNL_UDF_Status Comments: 190606 IVS change start to Jul 12; 190508 ELM name per GRY; 190415 ELM add per GRY; 190314 ELM move activity to new WBS; 190313 ELM Activity split for fund src / BNL_UDF_Adhoc Comments: 180423 ELM rsrc per GRY; 180220 ELM recoded GSA resource from A - MIE to TP - contracted Labor (kept hours) / BNL_UDF_Old Activity Name 181221: Populate Outer HCAL sectors with scintillating tiles (Preproduction)
- S203500: BNL_UDF_Status Comments: 190314 ELM move activity to new WBS; 190313 ELM Activity split for fund src / BNL_UDF_Adhoc Comments: 180423 ELM rsrc per GRY; 180220 ELM recoded GSA resource from A - MIE to TP - contracted Labor (kept hours) / BNL_UDF_Old Activity Name 181221: Outer HCAL Cosmics testing and initial calibration (Preproduction)
- S203510: BNL_UDF_Status Comments: 190314 ELM move activity to new WBS; 190313 ELM Activity split for fund src / BNL_UDF_Adhoc Comments: 180423 ELM rsrc per GRY; 180220 ELM recoded GSA resource from A - MIE to TP - contracted Labor (kept hours) / BNL_UDF_Old Activity Name 181221: Outer HCAL Cosmics testing and initial calibration (Preproduction)
- S203600: BNL_UDF_Status Comments: 190314 ELM move activity to new WBS / BNL_UDF_Old Activity Name 181221: Outer HCAL Sector Transportation to Storage Area (Preproduction)

| ID | WBS | Activity | Type | Duration | Start | Finish | Predecessors | Complete | Planned start | Planned finish | Constraint | Resources | Cost | BNL_UDF_Exclude | BNL_UDF_Temp Text 01 | BNL_UDF_Percent Complete | BNL_UDF_Temp Text 02 | BNL_UDF_Old Activity ID 181221 | BNL_Activity Status | BNL_Fund Source | BNL_Estimator | BNL_Location | BNL_EDIA | BNL_Milestone Level | BNL_Proc Sig Phase | BNL_Proc Sig | BNL_CAM | BNL_Institution | BNL_WBS | BNL_Obligation | BNL_WBS_Hierarchical | RG Check | BNL_PCR ID | BNL_Cost Basis | BNL_DOE OPC | BNL_OPC TEC (deprecated) | BNL_EVT | BNL_Account Number | Additional EVT documentation required | BNL_UDF_OPC TEC (deprecated) | BNL_Cobra WP | BNL_Master Control Account | BNL_Cobra Control Account | Indicator - Procurement | Indicator - Float | SPH Proc Register | BNL_UDF_Remaining Tot Cost | BNL_UDF_Percent_remaining | Target Milestone Date | Variance | PMP Milestones |
| --- | --- | --- | --- | --- | --- | --- | --- | --- | --- | --- | --- | --- | --- | --- | --- | --- | --- | --- | --- | --- | --- | --- | --- | --- | --- | --- | --- | --- | --- | --- | --- | --- | --- | --- | --- | --- | --- | --- | --- | --- | --- | --- | --- | --- | --- | --- | --- | --- | --- | --- | --- |
|  | 02 | **Outer HCAL Sector Assembly and Testing - Production** |  |  | 2019-09-03 | 2021-04-30 |  |  |  |  |  |  |  |  |  |  |  |  |  |  |  |  |  |  |  |  |  |  |  |  |  |  |  |  |  |  |  |  |  |  |  |  |  |  |  |  |  |  |  |  |  |
| OBLG210610 |  | Procure Contracted Labor Georgia State Univ. (GSU) - Obligation |  | 1d | 2019-09-03 A | 2019-09-03 A | S208900 | 100% |  |  |  | Obligation Resource [73453.7 h] | 73,453.74 | MP6LA | S210600 | 0 | 0 | S339640 | Completed | A-TEC | Bathe, Stefan | GSU | Procurement | L5 | PP5 | MP203102 | John Lajoie | BNL | POM02.1.04.04.02 | OBLG | 02 |  |  |  |  |  |  |  |  |  |  |  |  |  |  |  |  |  |  |  |  |
| S210600 |  | Procure Contracted Labor Georgia State Univ. (GSU), Phase 2 - Contract Award | milestone | 0d | 2019-12-02 A | 2019-12-02 A | S208900, S101000 | 100% |  |  | start on or after 2019-11-19 |  |  | MP6LA | S210600 | 0 | 0 | S339640 | Not Started | A-TEC | Bathe, Stefan | GSU | Procurement | L5 | PP5 | MP203102 | John Lajoie | BNL | POM02.1.04.04.02 |  | 02 | NOCA | 003,004 |  |  |  |  |  |  |  |  |  |  |  |  |  |  |  |  |  |  |
| S210700 |  | Procure Contracted Labor Georgia State Univ. (GSU), Phase 2 - Delivery Acceptance |  | 250d | 2019-12-02 A | 2019-12-31 A | S210600 SS, OBLG210610 SS | 100% | 2019-12-02 | 2020-11-30 | start on or after 2019-11-19 |  |  |  | S210700 | 0 | 0 | S339680 | Not Started | A-TEC | Bathe, Stefan | GSU | Procurement |  | PP6 | MP203102 | John Lajoie | BNL | POM02.1.04.04.02 | FAB | 02 | NOCA | 003,004 | M4 | OPC001600 | OPC | F | 16703 | Yes |  |  |  |  |  |  |  |  |  |  |  |  |
| S209000 |  | Procure Outer HCAL Assembly & Testing Equipment - Provide Requirements to Procurement |  | 5d | 2020-06-03 A | 2020-06-05 A | S100500, S203500, S203510 | 100% | 2020-08-03 | 2020-08-07 |  | TECH3 PO M [40 h]; CRAFT3 [40 h]; STUDENT GSU - Unpaid [40 h]; POSTDOC GSU - Unpaid [40 h] | 9,567.74 |  | S209000 | 0 | 0 | S192400 | Not Started | B_T | Bathe, Stefan | GSU | Fab & Assy |  | PP1 | MP105300 | John Lajoie | ISU | POM02.1.04.04.02 |  | 02 | CA | 003 | L4 |  | null | C | 16711 |  | S192400 | S209000 | 1.04 | 1.04B |  |  |  |  |  |  |  |  |
| S209100 |  | Procure Outer HCAL Assembly & Testing Equipment - Prepare & Send Solicitation |  | 30d | 2020-06-03 A | 2020-06-05 A | S209000 | 100% | 2020-08-10 | 2020-09-21 |  |  |  |  | S209100 | 0 | 0 | S192500 | Not Started |  | Bathe, Stefan | GSU | Procurement |  | PP2 | MP105300 | John Lajoie | ISU | POM02.1.04.04.02 |  | 02 | NOCA | 003 |  |  |  |  |  |  | S192500 |  |  |  |  |  |  |  |  |  |  |  |
| S209200 |  | Procure Outer HCAL Assembly & Testing Equipment - Vendor Responses |  | 10d | 2020-06-03 A | 2020-06-05 A | S209100 | 100% | 2020-09-22 | 2020-10-05 |  |  |  |  | S209200 | 0 | 0 | S192600 | Not Started |  | Bathe, Stefan | GSU | Procurement |  | PP3 | MP105300 | John Lajoie | ISU | POM02.1.04.04.02 |  | 02 | NOCA | 003 |  |  |  |  |  |  | S192600 |  |  |  |  |  |  |  |  |  |  |  |
| S209300 |  | Procure Outer HCAL Assembly & Testing Equipment - Vendor Selection |  | 20d | 2020-06-03 A | 2020-06-05 A | S209200 | 100% | 2020-10-06 | 2020-11-03 |  |  |  | MP6LA | S209300 | 0 | 0 | S192700 | Not Started |  | Bathe, Stefan | GSU | Procurement |  | PP4 | MP105300 | John Lajoie | ISU | POM02.1.04.04.02 |  | 02 | NOCA | 003 |  |  |  |  |  |  | S192700 |  |  |  |  |  |  |  |  |  |  |  |
| S209400 |  | Procure Outer HCAL Assembly & Testing Equipment - Contract Award(s) | milestone | 0d | 2020-06-05 A | 2020-06-05 A | S209300, S100600, S206500, S206900, S207300 | 100% | 2020-11-04 | 2020-11-04 |  |  |  | MP6LA | S209400 | 0 | 0 | S192800 | Not Started | A-TEC | Bathe, Stefan | GSU | Procurement | L5 | PP5 | MP105300 | John Lajoie | ISU | POM02.1.04.04.02 |  | 02 | NOCA | 003 |  |  |  |  |  |  | S192800 |  |  |  | UDF_G2 | UDF_G3 | Contract Award |  |  |  |  |  |
| S209500 |  | Procure Outer HCAL Assembly & Testing Equipment - Contract/PO - Leadtime |  | 40d | 2020-06-08 A | 2020-07-15 A | S209400 SS, OBLG209410 SS | 100% | 2020-11-04 | 2021-01-05 |  |  |  | MP6LA | S209500 | 0 | 0 | S192900 | Not Started |  | Bathe, Stefan | GSU | Procurement |  | PP6 | MP105300 | John Lajoie | ISU | POM02.1.04.04.02 |  | 02 | NOCA | 003 |  |  |  |  |  |  | S192900 |  |  |  |  |  |  |  |  |  |  |  |
| S209600 |  | Procure Outer HCAL Assembly & Testing Equipment- Delivery Acceptance |  | 5d | 2020-07-20 A | 2020-07-30 A | S209500 | 100% | 2020-09-01 | 2020-09-08 |  | Material (Purchase (1st $2M) [75000 h] | 85,344.43 | MP6LA | S209600 | 0 | 0 | S193000 | Not Started | A-TEC | Bathe, Stefan | GSU | Procurement |  | PP6 | MP105300 | John Lajoie | ISU | POM02.1.04.04.02 | FAB | 02 | CA | 003 | M5 |  | TEC | C | 59713 |  | S193000 | S209600 | 1.04 | 1.04A | UDF_G3 | UDF_G3 | Delivery | 87051.32325 | 1 |  |  |  |
| S209700 |  | Prepare Outer HCal Assembly Area for Production |  | 20d | 2020-08-10 A | 2020-08-24 A | S203600 | 100% | 2020-12-01 | 2020-12-29 |  | TECH3 PO M [320 h]; POSTDOC GSU - Unpaid [160 h]; STUDENT GSU - Unpaid [160 h]; CRAFT3 [160 h] | 58,226.41 |  | S209700 | 0 | x | S193050 | Not Started | B_T | Bathe, Stefan | GSU | Fab & Assy |  |  |  | John Lajoie | ISU | POM02.1.04.04.02 |  | 02 | CA | 003 | L3 |  | null | C | 16711 |  |  | S209700 | 1.04 | 1.04B |  |  |  |  |  |  |  |  |
| S209800 |  | Populate Outer HCAL sectors with scintillating tiles |  | 130d | 2020-08-17 A | 2021-03-30 A | S208400 SS+20d, S323900, S206200, S208500 FF, S239300 SS+20d, S208410 SS+20d, S209701 | 100% | 2021-02-17 | 2021-08-19 |  | STUDENT GSU OffC - Purchased Services [1040 h] | 15,509.3 |  | S209800 | 0 | x | S193100 | Not Started | A-TEC | Bathe, Stefan | GSU | Fab & Assy |  | PP6 | MP203102 | John Lajoie | ISU | POM02.1.04.04.02 | FAB | 02 | CA | 003 | L4 |  | null | C | 59713 | Yes | S193100 | S209800 | 1.04 | 1.04A |  |  |  |  |  |  |  |  |
| S209810 |  | Populate Outer HCAL sectors with scintillating tiles - Contributed Labor |  | 130d | 2020-08-17 A | 2021-03-30 A | S208400 SS+20d, S323900, S206200, S208500 FF, S239300 SS+20d, S208410 SS+20d, S209701 | 100% | 2021-02-17 | 2021-08-19 |  | TECH3 PO M [1318 h]; POSTDOC GSU - Unpaid [260 h]; SCI 4 PO [209 h] | 199,251.07 |  | S209800 | 0 | x | S193100 | Not Started | B_T | Bathe, Stefan | GSU | Fab & Assy |  |  |  | John Lajoie | ISU | POM02.1.04.04.02 |  | 02 | CA | 003 | L4 |  | null | C | 16711 | Yes | S193100 | S209810 | 1.04 | 1.04B |  |  |  |  |  |  |  |  |
| S209701 |  | Production Readiness Review - OHCal Sector Assembly 7-32 |  | 1d | 2020-08-25 A | 2020-08-31 A | S209700 FF | 100% | 2020-12-29 | 2020-12-29 |  | SCI3 Other - Unpaid [8 h]; SCI 4 PO [4 h]; PROF3 PO M [4 h] | 1,369.56 |  | S209700 | 0 | x | S193050 | Not Started | B | Bathe, Stefan | GSU | Management Tech Reviews |  |  |  | John Lajoie | ISU | POM02.1.04.04.02 |  | 02 | CA | 003,004 | L3 |  | null | F | 16711 |  |  | S209701 | 1.04 | 1.04B |  |  |  |  |  |  |  |  |
| OBLG209410 |  | Procure Outer HCAL Assembly & Testing Equipment - Obligation |  | 1d | 2020-09-02 A | 2020-09-02 A | S209300, S100600, S206500, S206900, S207300 | 100% |  |  |  | Obligation Resource [87051.3 h] | 87,051.34 | MP6LA | S209400 | 0 | 0 | S192800 | Not Started | A-TEC | Bathe, Stefan | GSU | Procurement | L5 | PP5 | MP105300 | John Lajoie | ISU | POM02.1.04.04.02 | OBLG | 02 |  |  |  |  |  |  |  |  | S192800 |  |  |  |  |  |  |  |  |  |  |  |
| S209900 |  | Populate Outer HCAL sectors with electronics |  | 130d | 2020-12-15 A | 2021-03-30 A | S209800 SS+5d, S240800 FS+5d, S241800 SS+5d, S242100 SS+5d, S243000 SS+5d, S243700, S240700 FF, S240800 FF, S240900 FF, S241000 FF, S240600 FF | 100% | 2021-03-01 | 2021-08-31 |  | STUDENT GSU OffC - Purchased Services [1040 h] | 15,509.3 |  | S209900 | 0 | x | S193200 | Not Started | A-TEC | Bathe, Stefan | GSU | Fab & Assy |  | PP6 | MP203102 | John Lajoie | ISU | POM02.1.04.04.02 | FAB | 02 | CA | 003 | L4 |  | null | C | 59713 | Yes | S193200 | S209900 | 1.04 | 1.04A |  |  |  |  |  |  |  |  |
| S209910 |  | Populate Outer HCAL sectors with electronics - Contributed Labor |  | 130d | 2020-12-15 A | 2021-03-30 A | S209810 SS+5d, S240800 FS+5d, S241800 SS+5d, S242100 SS+5d, S243000 SS+5d, S243700, S240700 FF, S240800 FF, S240900 FF, S241000 FF, S240600 FF | 100% | 2021-03-01 | 2021-08-31 |  | TECH3 PO M [1318 h]; POSTDOC GSU - Unpaid [260 h]; SCI 4 PO [209 h] | 199,251.07 |  | S209900 | 0 | x | S193200 | Not Started | B_T | Bathe, Stefan | GSU | Fab & Assy |  |  |  | John Lajoie | ISU | POM02.1.04.04.02 |  | 02 | CA | 003 | L4 |  | null | C | 16711 | Yes | S193200 | S209910 | 1.04 | 1.04B |  |  |  |  |  |  |  |  |
| S210000 |  | Outer HCAL Sector LED testing and Light Tighting |  | 130d | 2020-12-15 A | 2021-03-30 A | S209900 SS+5d, S210100 FF, S207600, S207500 | 100% | 2021-03-08 | 2021-09-08 |  | STUDENT GSU OffC - Purchased Services [1040 h] | 15,509.3 |  | S210000 | 0 | x | S193300 | Not Started | A-TEC | Bathe, Stefan | GSU | Procurement |  | PP6 | MP203102 | John Lajoie | ISU | POM02.1.04.04.02 | FAB | 02 | CA | 003 | L4 |  | null | C | 59713 | Yes | S193300 | S210000 | 1.04 | 1.04A |  |  |  |  |  |  |  |  |
| S210010 |  | Outer HCAL Sector LED testing and Light Tighting - Contributed Labor |  | 130d | 2020-12-15 A | 2021-03-30 A | S209910 SS+5d, S210100 FF, S207600, S207500 | 100% | 2021-03-08 | 2021-09-08 |  | TECH3 PO M [1318 h]; POSTDOC GSU - Unpaid [260 h]; SCI 4 PO [209 h] | 199,251.07 |  | S210000 | 0 | x | S193300 | Not Started | B_T | Bathe, Stefan | GSU | Procurement |  |  |  | John Lajoie | ISU | POM02.1.04.04.02 |  | 02 | CA | 003 | L4 |  | null | C | 16711 | Yes | S193300 | S210010 | 1.04 | 1.04B |  |  |  |  |  |  |  |  |
| S210100 |  | Procure Outer HCAL LED Testing & Light Tighting M&S |  | 130d | 2020-12-15 A | 2021-03-30 A | S209900 SS+5d, S207600, S207500, S209910 SS+5d | 100% | 2021-03-08 | 2021-09-08 |  | Material (Purchase (1st $2M) [19200 h] | 22,285.14 |  | S210100 | 0 | x | S193400 | Not Started | A-TEC | Bathe, Stefan | GSU | Procurement |  |  |  | John Lajoie | ISU | POM02.1.04.04.02 |  | 02 | CA | 003 | M5 |  | TEC | C | 59713 | Yes | S193400 | S210100 | 1.04 | 1.04A | UDF_G2 | UDF_G1 |  | 22285.138752 | 1 |  |  |  |
| S210200 |  | Outer HCAL Cosmics testing and initial calibration |  | 130d | 2020-12-15 A | 2021-03-30 A | S210000 SS+5d | 100% | 2021-03-15 | 2021-09-15 |  | STUDENT GSU OffC - Purchased Services [1040 h] | 15,509.3 |  | S210200 | 0 | x | S193500 | Not Started | A-TEC | Bathe, Stefan | GSU | Test_System |  | PP6 | MP203102 | John Lajoie | ISU | POM02.1.04.04.02 | FAB | 02 | CA | 003 | L4 |  | null | C | 59713 | Yes | S193500 | S210200 | 1.04 | 1.04A |  |  |  |  |  |  |  |  |
| S210210 |  | Outer HCAL Cosmics testing and initial calibration - Contributed Labor |  | 130d | 2020-12-15 A | 2021-03-30 A | S210010 SS+5d | 100% | 2021-03-15 | 2021-09-15 |  | POSTDOC GSU - Unpaid [260 h]; SCI 4 PO [209 h] | 44,325.7 |  | S210200 | 0 | x | S193500 | Not Started | B_T | Bathe, Stefan | GSU | Test_System |  |  |  | John Lajoie | ISU | POM02.1.04.04.02 |  | 02 | CA | 003 | L4 |  | null | C | 16711 | Yes | S193500 | S210210 | 1.04 | 1.04B |  |  |  |  |  |  |  |  |
| S210300 |  | Outer HCAL Sector Transportation to Temp Storage |  | 130d | 2021-01-11 A | 2021-04-30 A | S210200 SS+5d, S210210 SS+5d | 100% | 2021-03-01 | 2021-08-31 |  | TECH3 PO M [104 h]; CRAFT3 [208 h] | 39,020.04 |  | S210300 | 0 | x | S193600 | Not Started | B | Bathe, Stefan | GSU | Fab & Assy |  |  |  | John Lajoie | ISU | POM02.1.04.04.02 |  | 02 | CA | 003 | L5 |  | null | C | 16711 | Yes | S193600 | S210300 | 1.04 | 1.04B |  |  |  |  |  |  |  |  |
| S210400 |  | First Outer HCAL Sector and Splice Plates Ready to Install | milestone | 0d | 2021-02-25 A | 2021-02-25 A | S205100 FF, S203500 FS+10d | 100% | 2021-03-05 | 2021-03-05 |  |  |  |  | S210400 | 0 | x | S193700 | Not Started |  | Bathe, Stefan | GSU | Fab & Assy | L2 |  |  | John Lajoie | ISU | POM02.1.04.04.02 |  | 02 | NOCA | 003 |  |  |  |  |  |  | S193700 |  |  |  | UDF_G3 | UDF_G3 |  |  |  | 2021-04-30 | 46 | PMP_1x |
| S210310 |  | Technical support labor for HCal |  | 119d | 2021-03-01 A | 2021-03-31 A |  | 100% | 2021-04-01 | 2021-09-17 | start on or after 2021-04-01 | TECH1 |  |  | S210100 | 0 | x | S193400 | Not Started | A-TEC | Bathe, Stefan | GSU | Fab & Assy |  |  |  | John Lajoie | ISU | POM02.1.04.04.02 |  | 02 | CA | 020 | M5 |  | TEC | C | 59713 | Yes | S193400 | S210310 | 1.04 | 1.04A | UDF_G2 | UDF_G1 |  | 22285.138752 | 1 |  |  |  |
| S210500 |  | Last Outer HCAL Sector Ready to Install | milestone | 0d | 2021-03-29 A | 2021-03-29 A | S210300, S202600 FF, S210700 SF, S209600 | 100% | 2021-08-31 | 2021-08-31 |  |  |  |  | S210500 | 0 | x | S193800 | Not Started |  | Bathe, Stefan | GSU | Fab & Assy | L2 |  |  | John Lajoie | ISU | POM02.1.04.04.02 |  | 02 | NOCA | 003 |  |  |  |  |  |  | S193800 |  |  |  | UDF_G3 | UDF_G3 |  |  |  | 2021-10-29 | 150 | PMP_1x |

Notes:
- OBLG210610: BNL_UDF_Adhoc Comments: 180410 ELM pred/succ; 180220 ELM Added Procurement String for GSU Contracted labor / BNL_UDF_Old Activity Name 181221: Procure Contracted Labor Georgia State Univ. (GSU) - Contract Award FY 19 - OPC
- S210600: BNL_UDF_Status Comments: 190417 ELM name; 190317 ELM name; 190313 ELM Activity split for fund src / BNL_UDF_Adhoc Comments: 180410 ELM pred/succ; 180220 ELM Added Procurement String for GSU Contracted labor / BNL_UDF_Old Activity Name 181221: Procure Contracted Labor Georgia State Univ. (GSU) - Contract Award FY 19 - OPC
- S210700: BNL_UDF_Status Comments: 190417 ELM name; 190317 ELM logic; 190317 ELM name; 190313 ELM Activity split for fund src / BNL_UDF_Adhoc Comments: 180220 ELM Added Procurement String for GSU Contracted labor / BNL_UDF_Old Activity Name 181221: Procure Contracted Labor Georgia State Univ. (GSU) - Delivery Acceptance FY 19 - OPC
- S209000: BNL_UDF_Status Comments: 190314 ELM move activity to new WBS; fix zeroed RAs / BNL_UDF_Adhoc Comments: 180220 ELM recoded GSA resource from A - MIE to TP - contracted Labor (kept hours) / BNL_UDF_Old Activity Name 181221: Procure Outer HCAL Assembly & Testing Equipment - Provide Requirements to Procurement
- S209100: BNL_UDF_Status Comments: 190314 ELM move activity to new WBS / BNL_UDF_Old Activity Name 181221: Procure Outer HCAL Assembly & Testing Equipment - Prepare & Send Solicitation
- S209200: BNL_UDF_Status Comments: 190314 ELM move activity to new WBS / BNL_UDF_Old Activity Name 181221: Procure Outer HCAL Assembly & Testing Equipment - Vendor Responses
- S209300: BNL_UDF_Status Comments: 190314 ELM move activity to new WBS / BNL_UDF_Old Activity Name 181221: Procure Outer HCAL Assembly & Testing Equipment - Vendor Selection
- S209400: BNL_UDF_Status Comments: 190314 ELM move activity to new WBS / BNL_UDF_Adhoc Comments: 180420 ELM pred/succ per GRY / BNL_UDF_Old Activity Name 181221: Procure Outer HCAL Assembly & Testing Equipment - Contract Award(s)
- S209500: BNL_UDF_Status Comments: 190314 ELM move activity to new WBS / BNL_UDF_Old Activity Name 181221: Procure Outer HCAL Assembly & Testing Equipment - Contract/PO - Leadtime
- S209600: BNL_UDF_Status Comments: 190314 ELM move activity to new WBS / BNL_UDF_Old Activity Name 181221: Procure Outer HCAL Assembly & Testing Equipment- Delivery Acceptance
- S209700: Scheduler's Notes: 180413 ELM per GRY: / assume 2 people do this / BNL_UDF_Status Comments: 190314 ELM move activity to new WBS / BNL_UDF_Adhoc Comments: 180220 ELM recoded GSA resource from A - MIE to TP - contracted Labor (kept hours) / BNL_UDF_Old Activity Name 181221: Prepare Outer HCal Assembly Area for Production
- S209800: Scheduler's Notes: 180413 ELM per GRY: / assume 2 people do this / BNL_UDF_Status Comments: 190314 ELM move activity to new WBS; 190313 ELM Activity split for fund src / BNL_UDF_Adhoc Comments: 180423 ELM rsrc per GRY; 180410 ELM pred/succ per GRY; 180330 ELM pred per GRY; 180220 ELM recoded GSA resource from A - MIE to TP - contracted Labor (kept hours) / BNL_UDF_Old Activity Name 181221: Populate Outer HCAL sectors with scintillating tiles
- S209810: Scheduler's Notes: 180413 ELM per GRY: / assume 2 people do this / BNL_UDF_Status Comments: 190314 ELM move activity to new WBS; 190313 ELM Activity split for fund src / BNL_UDF_Adhoc Comments: 180423 ELM rsrc per GRY; 180410 ELM pred/succ per GRY; 180330 ELM pred per GRY; 180220 ELM recoded GSA resource from A - MIE to TP - contracted Labor (kept hours) / BNL_UDF_Old Activity Name 181221: Populate Outer HCAL sectors with scintillating tiles
- S209701: Scheduler's Notes: 180413 ELM per GRY: / assume 2 people do this / BNL_UDF_Status Comments: 190508 ELM add per GRY / BNL_UDF_Adhoc Comments: 180220 ELM recoded GSA resource from A - MIE to TP - contracted Labor (kept hours) / BNL_UDF_Old Activity Name 181221: Prepare Outer HCal Assembly Area for Production
- OBLG209410: BNL_UDF_Adhoc Comments: 180420 ELM pred/succ per GRY / BNL_UDF_Old Activity Name 181221: Procure Outer HCAL Assembly & Testing Equipment - Contract Award(s)
- S209900: Scheduler's Notes: 180413 ELM per GRY: / assume 2 people do this / BNL_UDF_Status Comments: 190314 ELM move activity to new WBS; 190313 ELM Activity split for fund src / BNL_UDF_Adhoc Comments: 180423 ELM rsrc per GRY; 180220 ELM recoded GSA resource from A - MIE to TP - contracted Labor (kept hours) / BNL_UDF_Old Activity Name 181221: Populate Outer HCAL sectors with electronics
- S209910: Scheduler's Notes: 180413 ELM per GRY: / assume 2 people do this / BNL_UDF_Status Comments: 190314 ELM move activity to new WBS; 190313 ELM Activity split for fund src / BNL_UDF_Adhoc Comments: 180423 ELM rsrc per GRY; 180220 ELM recoded GSA resource from A - MIE to TP - contracted Labor (kept hours) / BNL_UDF_Old Activity Name 181221: Populate Outer HCAL sectors with electronics
- S210000: Scheduler's Notes: 180413 ELM per GRY: / assume 2 people do this / BNL_UDF_Status Comments: 190314 ELM move activity to new WBS; 190313 ELM Activity split for fund src / BNL_UDF_Adhoc Comments: 180423 ELM rsrc per GRY; 180410 ELM pred/succ per GRY; 180330 ELM pred per GRY; 180220 ELM recoded GSA resource from A - MIE to TP - contracted Labor (kept hours) / BNL_UDF_Old Activity Name 181221: Outer HCAL Sector LED testing and Light Tighting
- S210010: Scheduler's Notes: 180413 ELM per GRY: / assume 2 people do this / BNL_UDF_Status Comments: 190314 ELM move activity to new WBS; 190313 ELM Activity split for fund src / BNL_UDF_Adhoc Comments: 180423 ELM rsrc per GRY; 180410 ELM pred/succ per GRY; 180330 ELM pred per GRY; 180220 ELM recoded GSA resource from A - MIE to TP - contracted Labor (kept hours) / BNL_UDF_Old Activity Name 181221: Outer HCAL Sector LED testing and Light Tighting
- S210100: BNL_UDF_Status Comments: 190314 ELM move activity to new WBS / BNL_UDF_Adhoc Comments: 180410 ELM dur per GRY / BNL_UDF_Old Activity Name 181221: Procure Outer HCAL LED Testing & Light Tighting M&S
- S210200: BNL_UDF_Status Comments: 190314 ELM move activity to new WBS; 190313 ELM Activity split for fund src / BNL_UDF_Adhoc Comments: 180423 ELM rsrc per GRY; 180330 ELM pred per GRY; 180220 ELM recoded GSA resource from A - MIE to TP - contracted Labor (kept hours) / BNL_UDF_Old Activity Name 181221: Outer HCAL Cosmics testing and initial calibration
- S210210: BNL_UDF_Status Comments: 190313 ELM Activity split for fund src / BNL_UDF_Adhoc Comments: 180423 ELM rsrc per GRY; 180330 ELM pred per GRY; 180220 ELM recoded GSA resource from A - MIE to TP - contracted Labor (kept hours) / BNL_UDF_Old Activity Name 181221: Outer HCAL Cosmics testing and initial calibration
- S210300: BNL_UDF_Status Comments: 190313 ELM Activity split for fund src / BNL_UDF_Old Activity Name 181221: Outer HCAL Sector Transportation to Temp Storage
- S210400: BNL_UDF_Status Comments: 190313 ELM Activity split for fund src / BNL_UDF_Old Activity Name 181221: First Outer HCAL Sector Ready to Install
- S210310: BNL_UDF_Status Comments: 190314 ELM move activity to new WBS / BNL_UDF_Adhoc Comments: 180410 ELM dur per GRY / BNL_UDF_Old Activity Name 181221: Procure Outer HCAL LED Testing & Light Tighting M&S
- S210500: BNL_UDF_Status Comments: 190313 ELM Activity split for fund src / BNL_UDF_Old Activity Name 181221: Last Outer HCAL Sector Ready to Install

| ID | WBS | Activity | Type | Duration | Start | Finish | Predecessors | Complete | Planned start | Planned finish | Constraint | Resources | Cost | BNL_UDF_Temp Text 01 | BNL_UDF_Percent Complete | BNL_UDF_Old Activity ID 181221 | BNL_Cobra WP | RG Check | BNL_Activity Status | BNL_Fund Source | BNL_Estimator | BNL_Cost Basis | BNL_Location | BNL_EDIA | BNL_CAM | BNL_Institution | BNL_OPC TEC (deprecated) | BNL_WBS | BNL_Actuals | BNL_FY | BNL_EVT | BNL_Master Control Account | BNL_Account Number | BNL_PCR ID | BNL_Cobra Control Account | BNL_WBS_Hierarchical | Completed | Indicator - Procurement | BNL_DOE OPC | BNL_UDF_Adhoc Comments | BNL_UDF_OPC TEC (deprecated) | BNL_R&D FY18-19 | BNL_Milestone Level | BNL_Proc Sig Phase | BNL_Proc Sig | Cost = Awarded Proc or Mgmt | BNL_Obligation | SPH Proc Register | BNL_UDF_Exclude | BNL_UDF_Temp Date 01 | BNL_LLPs and Precursors | Temp | Additional EVT documentation required | Indicator - Float | Target Milestone Date | Variance | PMP Milestones |
| --- | --- | --- | --- | --- | --- | --- | --- | --- | --- | --- | --- | --- | --- | --- | --- | --- | --- | --- | --- | --- | --- | --- | --- | --- | --- | --- | --- | --- | --- | --- | --- | --- | --- | --- | --- | --- | --- | --- | --- | --- | --- | --- | --- | --- | --- | --- | --- | --- | --- | --- | --- | --- | --- | --- | --- | --- | --- |
|  | 05 | **Calorimeter Electronics** |  |  | 2017-02-01 | 2022-01-28 |  |  |  |  |  |  |  |  |  |  |  |  |  |  |  |  |  |  |  |  |  |  |  |  |  |  |  |  |  |  |  |  |  |  |  |  |  |  |  |  |  |  |  |  |  |  |  |  |  |  |  |
| S211200 |  | Actuals - Labor - sPHENIX Calorimeter Electronics FY17 |  | 169d | 2017-02-01 A | 2017-09-29 A | S100090 SS | 100% |  |  |  | Actual Labor [1634.31 h] | 273,081.59 | S211200 | 100 | S338660 | S211200 | CA | Completed | B | Mannel, Eric | L1 | BNL | Design | Eric Mannel | BNL | null | POM02.1.05 | Yes | 2017 | A | 1.05 | 16712 | 003 | 1.05B | 05 | yes |  |  |  |  |  |  |  |  |  |  |  |  |  |  |  |  |  |  |  |  |
| S211400 |  | Actuals - Nonlabor - sPHENIX Calorimeter Electronics FY17 |  | 169d | 2017-02-01 A | 2017-09-29 A | S100090 SS | 100% |  |  |  | Actual Nonlabor [29927 h] | 33,387 | S211400 | 100 | S339222 | S211400 | CA | Completed | A-OPC | Mannel, Eric | M1 | BNL | Design | Eric Mannel | BNL | OPC | POM02.1.05 | Yes | 2017 | A | 1.05 | 16704 | 003 | 1.05A | 05 | yes | UDF_G3 |  |  |  |  |  |  |  |  |  |  |  |  |  |  |  |  |  |  |  |
| S211300 |  | Actuals - Labor - sPHENIX Calorimeter Electronics FY18 |  | 249d | 2017-10-02 A | 2018-09-28 A | S211200 | 100% |  |  |  | Actual Labor [3553.77 h] | 593,809.71 | S211300 | 100 | S339220 | S211300 | CA | Completed | B | Mannel, Eric | L1 | BNL | Design | Eric Mannel | BNL | null | POM02.1.05 | Yes | 2018 | A | 1.05 | 16712 | 003 | 1.05B | 05 | yes |  | OPC001640 |  |  |  |  |  |  |  |  |  |  |  |  |  |  |  |  |  |  |
| S211500 |  | Actuals - Nonlabor - sPHENIX Calorimeter Electronics FY18 |  | 249d | 2017-10-02 A | 2018-09-28 A | S211400 | 100% |  |  |  | Actual Nonlabor [35131 h] | 39,192.59 | S211500 | 100 | S339225 | S211500 | CA | Completed | A-OPC | Mannel, Eric | M1 | BNL | Design | Eric Mannel | BNL | OPC | POM02.1.05 | Yes | 2018 | A | 1.05 | 16704 | 003 | 1.05A | 05 | yes | UDF_G3 | OPC001640 |  |  |  |  |  |  |  |  |  |  |  |  |  |  |  |  |  |  |
| S1000839 |  | Actuals - Labor - sPHENIX Calorimeter Electronics FY19 M8 |  | 166d | 2018-10-01 A | 2019-05-31 A |  | 100% |  |  |  | Actual Labor [2520.15 h] | 421,099.15 | S211300 | 100 | S339220 | S1000839 | CA | Completed | B | Mannel, Eric | L1 | BNL | Design | Eric Mannel | BNL | null | POM02.1.05 | Yes | 2019 | A | 1.05 | 16712 | 003 | 1.05B | 05 | yes |  | OPC001640 |  |  |  |  |  |  |  |  |  |  |  |  |  |  |  |  |  |  |
| S1000879 |  | Actuals - Nonlabor - sPHENIX Calorimeter Electronics FY19 M8 |  | 166d | 2018-10-01 A | 2019-05-31 A |  | 100% |  |  |  | Actual Nonlabor [347247 h] | 383,105.09 | S211500 | 100 | S339225 | S1000879 | CA | Completed | A-OPC | Mannel, Eric | M1 | BNL | Design | Eric Mannel | BNL | OPC | POM02.1.05 | Yes | 2019 | A | 1.05 | 16704 | 003 | 1.05A | 05 | yes | UDF_G3 | OPC001640 |  |  |  |  |  |  |  |  |  |  |  |  |  |  |  |  |  |  |
| S1001959 |  | Actuals - Nonlabor - sPHENIX Calorimeter Electronics FY19 M8 |  | 166d | 2018-10-01 A | 2019-05-31 A |  | 100% |  |  |  | Actual Nonlabor [58345 h] | 64,370.01 | S211500 | 100 | S339225 | S1001959 | CA | Completed | A-TEC | Mannel, Eric | M1 | BNL | Design | Eric Mannel | BNL | TEC | POM02.1.05 | Yes | 2019 | A | 1.05 | 59714 | 003 | 1.05A | 05 | yes | UDF_G3 | OPC001640 |  |  |  |  |  |  |  |  |  |  |  |  |  |  |  |  |  |  |
|  | 01 | **SiPMs** |  |  | 2017-02-01 | 2020-03-02 |  |  |  |  |  |  |  |  |  |  |  |  |  |  |  |  |  |  |  |  |  |  |  |  |  |  |  |  |  |  |  |  |  |  |  |  |  |  |  |  |  |  |  |  |  |  |  |  |  |  |  |
| S211600 |  | Write and Review Design Change Specifications for Optical Sensors: Sector 0 - Labor |  | 10d | 2017-02-01 A | 2017-02-14 A | S100090 SS | 100% |  |  |  |  |  | S211600 | 100 | S194000 |  | NOCA | Completed |  | Mannel, Eric |  | BNL | Procurement | Eric Mannel | BNL |  | POM02.1.05.01 |  |  |  |  |  | 004 |  | 01 | yes |  |  | 180329 ELM desc | S194000 | EMCal SiPMs |  |  |  |  |  |  |  |  |  |  |  |  |  |  |  |
| S211601 |  | Final Design Review - EMCal, OHCal - Silicon Photomultipliers (LLP) | milestone | 0d | 2017-02-14 A | 2017-02-14 A | S211600 FF | 100% |  |  |  |  |  | S211600 | 100 | S194000 |  | NOCA | Completed |  | Mannel, Eric |  | BNL | Procurement | Eric Mannel | BNL |  | POM02.1.05.01 |  |  |  |  |  | 004 |  | 01 | yes |  |  | 180329 ELM desc | S194000 | EMCal SiPMs |  |  |  |  |  |  |  |  |  |  |  |  |  |  |  |
| S211700 |  | Write and Review Design Change Specifications for Optical Sensors: Sector 0 - M&S |  | 20d | 2017-02-15 A | 2017-03-15 A | S211601 | 100% |  |  |  |  |  | S211700 | 100 | S194100 |  | NOCA | Completed |  | Mannel, Eric |  | BNL | Fab & Assy | Eric Mannel | BNL |  | POM02.1.05.01 |  |  |  |  |  | 004 |  | 01 | yes |  |  | 180329 ELM desc | S194100 | EMCal SiPMs |  |  |  |  |  |  |  |  |  |  |  |  |  |  |  |
| S211800 |  | Order Sensors: Sector 0 - Labor |  | 120d | 2017-03-16 A | 2017-09-01 A | S211700 | 100% |  |  |  |  |  | S211800 | 100 | S194200 |  | NOCA | Completed |  | Mannel, Eric |  | BNL | Procurement | Eric Mannel | BNL |  | POM02.1.05.01 |  |  |  |  |  | 002 |  | 01 | yes |  |  | 180329 ELM desc | S194200 | EMCal SiPMs |  |  |  |  |  |  |  |  |  |  |  |  |  |  |  |
| S211900 |  | Order Sensors: Sector 0 - M&S |  | 120d | 2017-03-16 A | 2017-09-01 A | S211700 | 100% |  |  |  |  |  | S211900 | 100 | S194300 |  | NOCA | Completed |  | Mannel, Eric |  | BNL | Fab & Assy | Eric Mannel | BNL |  | POM02.1.05.01 |  |  |  |  |  | 002 |  | 01 | yes |  |  | 180329 ELM desc | S194300 |  |  |  |  |  |  |  |  |  |  |  |  |  |  |  |  |
| S212000 |  | Q/A Delivered Sensors: Sector 0 - Labor |  | 73d | 2017-09-05 A | 2017-12-20 A | S211900 | 100% |  |  |  |  |  | S212000 | 100 | S194400 |  | NOCA | Completed |  | Mannel, Eric |  | BNL | Procurement | Eric Mannel | BNL |  | POM02.1.05.01 |  |  |  |  |  |  |  | 01 | yes |  |  | 180329 ELM desc | S194400 |  |  |  |  |  |  |  |  |  |  |  |  |  |  |  |  |
| S212100 |  | Q/A Delivered Sensors: Sector 0 - M&S |  | 73d | 2017-09-05 A | 2017-12-20 A | S211800 | 100% |  |  |  |  |  | S212100 | 100 | S194500 |  | NOCA | Completed |  | Mannel, Eric |  | BNL | Fab & Assy | Eric Mannel | BNL |  | POM02.1.05.01 |  |  |  |  |  |  |  | 01 | yes |  |  | 180329 ELM desc | S194500 | EMCal SiPMs |  |  |  |  |  |  |  |  |  |  |  |  |  |  |  |
| S212200 |  | EMCal/HCal Sensors Tested, Delivered and Procurement Readiness Review: Sector 0 | milestone | 0d | 2017-12-20 A | 2017-12-20 A | S212100, S212000 | 100% |  |  |  |  |  | S212200 | 100 | S195500 |  | NOCA | Completed |  | Mannel, Eric |  | Japan | Test_Components | Eric Mannel | BNL |  | POM02.1.05.01 |  |  |  |  |  | 002,004 |  | 01 | yes |  |  | 180329 ELM desc per EJM | S195500 |  | L3 |  |  |  |  |  |  |  |  |  |  |  |  |  |  |
| S212201 |  | Procurement Readiness Review - EMCal, OHCal - Silicon Photomultipliers (LLP) | milestone | 0d | 2017-12-20 A | 2017-12-20 A | S212200 FF | 100% |  |  |  |  |  | S212200 | 100 | S195500 |  | NOCA | Completed |  | Mannel, Eric |  | Japan | Test_Components | Eric Mannel | BNL |  | POM02.1.05.01 |  |  |  |  |  | 002,004 |  | 01 | yes |  |  | 180329 ELM desc per EJM | S195500 |  | L3 |  |  |  |  |  |  |  |  |  |  |  |  |  |  |
| S212300 |  | EMCal/HCal sensors Preproduction - Provide Requirements to Procurement |  | 34d | 2018-04-30 A | 2018-06-15 A | S100340 FS+50d | 100% |  |  |  |  |  | S212300 | 100 | S194600 |  | NOCA | Completed |  | Mannel, Eric | L2 | BNL | Procurement | Eric Mannel | BNL | null | POM02.1.05.01 |  |  | C |  |  | 002 |  | 01 | yes |  |  | 180413 ELM pred/succ per GRY | S194600 | CalEl SiPMs for large tests |  | PP1 | MP108900 | Yes |  |  |  |  |  |  |  |  |  |  |  |
| S212400 |  | EMCal/HCal sensors Preproduction - Prepare & Send Solicitation |  | 45d | 2018-07-02 A | 2018-09-04 A | S212300 | 100% |  |  |  |  |  | S212400 | 100 | S194700 |  | NOCA | Completed |  | Mannel, Eric |  | BNL | Procurement | Eric Mannel | BNL |  | POM02.1.05.01 |  |  |  |  |  | 002 |  | 01 | yes |  |  |  | S194700 | CalEl SiPMs for large tests |  | PP2 | MP108900 | Yes |  |  |  |  |  |  |  |  |  |  |  |
| S212500 |  | EMCal/HCal sensors Preproduction - Vendor Responses & Selection |  | 15d | 2018-08-16 A | 2018-09-06 A | S212400 | 100% |  |  |  |  |  | S212500 | 100 | S194800 |  | NOCA | Completed |  | Mannel, Eric |  | BNL | Procurement | Eric Mannel | BNL |  | POM02.1.05.01 |  |  |  |  |  | 002 |  | 01 | yes |  |  |  | S194800 | CalEl SiPMs for large tests |  | PP3 | MP108900 | Yes |  |  |  |  |  |  |  |  |  |  |  |
| OBLG212600 |  | EMCal/HCal sensors Preproduction - 23K Units - Obligation |  | 2d | 2018-09-12 A | 2018-09-13 A | S212500, S211700, S211601, S212201 | 100% |  |  |  | Obligation Resource |  | S212600 | 100 | S194900 |  | NOCA | Completed | A-OPC | Mannel, Eric |  | BNL | Procurement | Eric Mannel | BNL |  | POM02.1.05.01 |  |  |  |  |  | 003,004 |  | 01 | yes |  |  | 180420 ELM pred/succ per GRY | S194900 | CalEl SiPMs for large tests | L5 | PP5 | MP108900 | Yes | OBLG |  |  |  |  |  |  |  |  |  |  |
| OBLG212710 |  | EMCal/HCal sensors Production - 77K Units - Obligation |  | 1d | 2018-09-12 A | 2018-09-12 A | S212500, S211700, S211601, S212201 | 100% |  |  |  | Obligation Resource |  | S212700 | 100 | S277592764 |  | NOCA | Completed | A-TEC | Mannel, Eric |  | BNL | Procurement | Eric Mannel | BNL |  | POM02.1.05.01 |  |  |  |  |  | 003,004 |  | 01 | yes |  |  | 180420 ELM pred/succ per GRY | S194900 | CalEl SiPMs for large tests | L5 | PP5 | MP108910 |  | OBLG |  |  |  |  |  |  |  |  |  |  |
| S212600 |  | EMCal/HCal sensors Preproduction - 23K Units - Contract Award | milestone | 0d | 2018-09-12 A | 2018-09-12 A | S212500, S211700, S211601, S212201 | 100% |  |  |  |  |  | S212600 | 100 | S194900 |  | NOCA | Completed | A-OPC | Mannel, Eric |  | BNL | Procurement | Eric Mannel | BNL |  | POM02.1.05.01 |  |  |  |  |  |  |  | 01 | yes |  |  | 180420 ELM pred/succ per GRY | S194900 | CalEl SiPMs for large tests | L5 | PP5 | MP108900 | Yes |  |  |  |  |  |  |  |  |  |  |  |
| S212700 |  | EMCal/HCal sensors Production - 77K Units - Contract Award | milestone | 0d | 2018-09-12 A | 2018-09-12 A | S212500, S211700, S211601, S212201 | 100% |  |  |  |  |  | S212700 | 100 | S277592764 |  | NOCA | Completed | A-TEC | Mannel, Eric |  | BNL | Procurement | Eric Mannel | BNL |  | POM02.1.05.01 |  |  |  |  |  | 002,004 |  | 01 | yes |  |  | 180420 ELM pred/succ per GRY | S194900 | CalEl SiPMs for large tests | L5 | PP5 | MP108910 |  |  | Contract Award |  |  |  |  |  |  |  |  |  |
| S212800 |  | EMCal/HCal sensors Preproduction - Vendor Leadtime FY18 |  | 12d | 2018-09-13 A | 2018-09-28 A | S212600 SS, S212500, S211700, OBLG212600 SS, S211601, S212201 | 100% |  |  |  |  |  | S212800 | 100 | S195000 |  | NOCA | Completed |  | Mannel, Eric |  | Japan | Fab & Assy | Eric Mannel | BNL |  | POM02.1.05.01 |  |  |  |  |  | 002 |  | 01 | yes |  |  |  | S195000 | CalEl SiPMs for large tests |  | PP6 | MP108900 | Yes |  |  | MP6LA |  |  |  |  |  |  |  |  |
| S212900 |  | EMCal/HCal sensors Preproduction - Vendor Leadtime FY19 |  | 102d | 2018-11-01 A | 2019-04-02 A | S212800 | 100% |  |  |  |  |  | S212900 | 95 | S195050 |  | NOCA | Completed |  | Mannel, Eric |  | Japan | Fab & Assy | Eric Mannel | BNL |  | POM02.1.05.01 |  |  |  |  |  | 002,004 |  | 01 | yes |  |  |  | S195000 | CalEl SiPMs for large tests |  | PP6 | MP108900 | Yes |  |  | MP6LA | 2019-03-01 |  |  |  |  |  |  |  |
| S213010 |  | EMCal/HCal sensors Preproduction - 8K Units - Delivery Acceptance No. 2 |  | 25d | 2019-02-04 A | 2019-03-11 A | S213000 | 100% |  |  |  |  |  | S213100 | 0 | S195200 |  | NOCA | Completed | A-OPC | Mannel, Eric | M3 | Japan | Fab & Assy | Eric Mannel | BNL | OPC | POM02.1.05.01 |  |  | F |  | 16704 | 002 |  | 01 | yes |  | OPC001650 | 180405 ELM name. units per GRY; 180329 ELM units per EJM | S195200 | CalEl SiPMs for large tests |  | PP6 | MP108900 | Yes |  |  | MP6LA |  |  |  |  |  |  |  |  |
| S213000 |  | EMCal/HCal sensors Preproduction - 8K Units - Delivery Acceptance No. 1 |  | 27d | 2019-03-04 A | 2019-04-09 A | S212900 | 100% |  |  |  |  |  | S213000 | 0 | S195100 |  | NOCA | Completed | A-OPC | Mannel, Eric | M3 | Japan | Fab & Assy | Eric Mannel | BNL | OPC | POM02.1.05.01 |  |  | F |  | 16704 | 002 |  | 01 | yes |  | OPC001650 | 180405 ELM units per GRY; 180329 ELM units per EJM | S195100 | CalEl SiPMs for large tests |  | PP6 | MP108900 | Yes |  |  | MP6LA |  |  |  |  |  |  |  |  |
| S213100 |  | EMCal/HCal sensors Preproduction - 7K Units - Delivery Acceptance No. 3 |  | 25d | 2019-04-16 A | 2019-05-20 A | S213010 | 100% |  |  |  |  |  | S213100 | 0 | S195200 |  | NOCA | Completed | A-OPC | Mannel, Eric | M3 | Japan | Fab & Assy | Eric Mannel | BNL | OPC | POM02.1.05.01 |  |  | F |  | 16704 | 002 |  | 01 | yes |  | OPC001650 | 180405 ELM name. units per GRY; 180329 ELM units per EJM | S195200 | CalEl SiPMs for large tests |  | PP6 | MP108900 | Yes |  |  | MP6LA |  |  |  |  |  |  |  |  |
| S214700 |  | EMCal/HCal sensors Production - 8K Units - Delivery Acceptance No. 4 |  | 9d | 2019-05-21 A | 2019-06-03 A | S213100, S212700 SS, OBLG212710, S212201 | 100% |  |  |  |  |  | S214700 | 0 | S196100 |  | NOCA | Completed | A-TEC | Mannel, Eric | M3 | Japan | Fab & Assy | Eric Mannel | BNL | TEC | POM02.1.05.01 |  |  | F |  | 59714 | 002 |  | 01 |  |  |  | 180405 units per GRY; 180329 ELM units per EJM | S196100 |  |  | PP6 | MP108910 |  |  | Delivery |  |  | SiPMs |  |  |  |  |  |  |
| S213200 |  | Prepro Q/A Tested & Sorted devices 8 K Units Delivery Batch No. 1 |  | 42d | 2019-06-03 A | 2019-07-31 A | S213000 | 100% |  |  |  | STUDENT UM - Purchased Services [80 h] | 1,225.95 | S213200 | 0 | S195300 | S213200 | CA | Completed | A-OPC | Mannel, Eric | L3 | BNL | Test_System | Eric Mannel | BNL | null | POM02.1.05.01 |  |  | C | 1.05 | 16704 | 002,003 | 1.05A | 01 |  |  |  | 180423 ELM rsrc per GRY | S195300 | CalEl SiPMs for large tests |  |  |  | Yes |  |  |  |  |  |  |  |  |  |  |  |
| S213205 |  | Prepro Q/A Tested & Sorted devices 8 K Units Delivery Batch No. 1 - Contributed Labor |  | 42d | 2019-06-03 A | 2019-07-31 A | S213000 | 100% |  |  |  | SCI2 UM - Unpaid [9.99 h]; STUDENT GRAD UM - Unpaid [79.94 h]; PROF4 PO E [67 h] | 9,579.37 | S213200 | 0 | S195300 | S213205 | CA | Completed | B_T | Mannel, Eric | L3 | BNL | Test_System | Eric Mannel | BNL | null | POM02.1.05.01 |  |  | C | 1.05 | 16712 | 002,003 | 1.05B | 01 |  |  |  | 180423 ELM rsrc per GRY | S195300 | CalEl SiPMs for large tests |  |  |  |  |  |  |  |  |  |  |  |  |  |  |  |
| S214800 |  | EMCal/HCal sensors Production - 8K Units - Delivery Acceptance No. 5 |  | 20d | 2019-06-03 A | 2019-06-28 A | S214700 | 100% |  |  |  | Material (Purchase (1st $2M) [69520 h] | 76,698.99 | S214800 | 0 | S196200 | S214800 | CA | Completed | A-TEC | Mannel, Eric | M3 | Japan | Fab & Assy | Eric Mannel | BNL | TEC | POM02.1.05.01 |  |  | F | 1.05 | 59714 | 002,004 | 1.05A | 01 |  | UDF_G3 |  | 180405 units per GRY; 180329 ELM units per EJM | S196200 |  |  | PP6 | MP108910 |  |  | Delivery |  |  | SiPMs |  |  |  |  |  |  |
| S215600 |  | Production Q/A Tested & Sorted devices 8 K Units Delivery Batch No. 4 |  | 64d | 2019-07-01 A | 2019-09-30 A | S214700, S245100 SS, OBLG245110 | 100% |  |  |  | STUDENT UM - Purchased Services [80 h] | 1,225.95 | S215600 | 0 | S196800 | S215600 | CA | Completed | A-TEC | Mannel, Eric | L3 | BNL | Test_System | Eric Mannel | BNL | null | POM02.1.05.01 |  |  | C | 1.05 | 59714 | 002 | 1.05A | 01 |  |  |  | 180423 ELM rsrc per GRY | S196800 |  |  | PP6 | MP203250 |  | FAB |  |  |  |  |  |  |  |  |  |  |
| S215605 |  | Production Q/A Tested & Sorted devices 8 K Units Delivery Batch No. 4 - Contributed Labor |  | 64d | 2019-07-01 A | 2019-09-30 A | S214700 | 100% |  |  |  | STUDENT GRAD UM - Unpaid [79.94 h]; SCI2 UM - Unpaid [9.99 h]; PROF4 PO E [67 h] | 9,579.37 | S215600 | 0 | S196800 | S215605 | CA | Completed | B_T | Mannel, Eric | L3 | BNL | Test_System | Eric Mannel | BNL | null | POM02.1.05.01 |  |  | C | 1.05 | 16712 | 003 | 1.05B | 01 |  |  |  | 180423 ELM rsrc per GRY | S196800 |  |  |  |  |  |  |  |  |  |  |  |  |  |  |  |  |
| S215800 |  | Production Q/A Tested & Sorted devices 8 K Units Delivery Batch No. 5 |  | 20d | 2019-07-01 A | 2019-12-31 A | S215600 | 100% | 2019-10-31 | 2019-12-02 |  | STUDENT UM - Purchased Services [80 h] | 1,276.86 | S215800 | 0 | S196900 | S215800 | CA | In Progress | A-TEC | Mannel, Eric | L3 | BNL | Test_System | Eric Mannel | BNL | null | POM02.1.05.01 |  |  | C | 1.05 | 59714 | 002 | 1.05A | 01 |  |  |  | 180423 ELM rsrc per GRY; 180405 units per GRY | S196900 |  |  | PP6 | MP203250 |  | FAB |  |  |  |  |  |  |  |  |  |  |
| S215805 |  | Production Q/A Tested & Sorted devices 8 K Units Delivery Batch No. 5 - Contributed Labor |  | 64d | 2019-07-01 A | 2019-12-31 A | S214800, S215605 SS | 100% | 2019-07-01 | 2019-09-30 |  | PROF4 PO E [67 h]; SCI2 UM - Unpaid [10 h]; STUDENT GRAD UM - Unpaid [80 h] | 9,579.37 | S215800 | 0 | S196900 | S215805 | CA | In Progress | B_T | Mannel, Eric | L3 | BNL | Test_System | Eric Mannel | BNL | null | POM02.1.05.01 |  |  | C | 1.05 | 16712 | 003 | 1.05B | 01 |  |  |  | 180423 ELM rsrc per GRY; 180405 units per GRY | S196900 |  |  |  |  |  |  |  |  |  |  | 1 |  |  |  |  |  |
| S213210 |  | Prepro Q/A Tested & Sorted devices 8 K Units Delivery Batch No. 2 |  | 10d | 2019-07-01 A | 2019-07-15 A | S213010 | 100% |  |  |  | STUDENT UM - Purchased Services [80 h] | 1,225.95 | S213300 | 0 | S195400 | S213210 | CA | Completed | A-OPC | Mannel, Eric | L3 | BNL | Test_System | Eric Mannel | BNL | null | POM02.1.05.01 |  |  | C | 1.05 | 16704 | 002,003 | 1.05A | 01 |  |  |  | 180423 ELM rsrc per GRY; 180405 name per GRY | S195400 | CalEl SiPMs for large tests |  |  |  | Yes |  |  |  |  |  |  |  |  |  |  |  |
| S213215 |  | Prepro Q/A Tested & Sorted devices 8 K Units Delivery Batch No. 2 - Contributed Labor |  | 10d | 2019-07-01 A | 2019-07-15 A | S213010 | 100% |  |  |  | STUDENT GRAD UM - Unpaid [79.94 h]; PROF4 PO E [67 h]; SCI2 UM - Unpaid [10 h] | 9,579.37 | S213300 | 0 | S195400 | S213215 | CA | Completed | B_T | Mannel, Eric | L3 | BNL | Test_System | Eric Mannel | BNL | null | POM02.1.05.01 |  |  | C | 1.05 | 16712 | 002,003 | 1.05B | 01 |  |  |  | 180423 ELM rsrc per GRY; 180405 name per GRY | S195400 | CalEl SiPMs for large tests |  |  |  |  |  |  |  |  |  |  |  |  |  |  |  |
| S213300 |  | Prepro Q/A Tested & Sorted devices 7 K Units Delivery Batch No. 3 |  | 22d | 2019-07-01 A | 2019-07-31 A | S213100 | 100% |  |  |  | STUDENT UM - Purchased Services [70 h] | 1,072.7 | S213300 | 0 | S195400 | S213300 | CA | Completed | A-OPC | Mannel, Eric | L3 | BNL | Test_System | Eric Mannel | BNL | null | POM02.1.05.01 |  |  | C | 1.05 | 16704 | 002,003 | 1.05A | 01 |  |  |  | 180423 ELM rsrc per GRY; 180405 name per GRY | S195400 | CalEl SiPMs for large tests |  |  |  | Yes |  |  |  |  |  |  |  |  |  |  |  |
| S213305 |  | Prepro Q/A Tested & Sorted devices 7 K Units Delivery Batch No. 3 - Contributed Labor |  | 22d | 2019-07-01 A | 2019-07-31 A | S213100 | 100% |  |  |  | STUDENT GRAD UM - Unpaid [69.94 h]; SCI2 UM - Unpaid [8.74 h]; PROF4 PO E [58 h] | 8,292.59 | S213300 | 0 | S195400 | S213305 | CA | Completed | B_T | Mannel, Eric | L3 | BNL | Test_System | Eric Mannel | BNL | null | POM02.1.05.01 |  |  | C | 1.05 | 16712 | 002,003 | 1.05B | 01 |  |  |  | 180423 ELM rsrc per GRY; 180405 name per GRY | S195400 | CalEl SiPMs for large tests |  |  |  |  |  |  |  |  |  |  |  |  |  |  |  |
| S214900 |  | EMCal/HCal sensors Production - 8K Units - Delivery Acceptance No. 6 |  | 19d | 2019-07-01 A | 2019-07-26 A | S214800 | 100% |  |  |  | Material (Purchase (1st $2M) [69520 h] | 76,698.99 | S214900 | 0 | S196300 | S214900 | CA | Completed | A-TEC | Mannel, Eric | M3 | Japan | Fab & Assy | Eric Mannel | BNL | TEC | POM02.1.05.01 |  |  | F | 1.05 | 59714 | 002 | 1.05A | 01 |  | UDF_G3 |  | 180405 units per GRY; 180329 ELM units per EJM | S196300 |  |  | PP6 | MP108910 |  |  | Delivery |  |  | SiPMs |  |  |  |  |  |  |
| S215900 |  | Production Q/A Tested & Sorted devices 8 K Units Delivery Batch No. 6 |  | 20d | 2019-08-01 A | 2019-12-31 A | S214900, S215800 SS+20d, S245100 SS, OBLG245110 | 100% | 2020-01-02 | 2020-01-30 |  | STUDENT UM - Purchased Services [80 h] | 1,276.86 | S215900 | 0 | S197000 | S215900 | CA | In Progress | A-TEC | Mannel, Eric | L3 | BNL | Test_System | Eric Mannel | BNL | null | POM02.1.05.01 |  |  | C | 1.05 | 59714 | 002,003 | 1.05A | 01 |  |  |  | 180423 ELM rsrc per GRY | S197000 |  |  | PP6 | MP203250 |  | FAB |  |  |  |  |  |  |  |  |  |  |
| S215905 |  | Production Q/A Tested & Sorted devices 8 K Units Delivery Batch No. 6 - Contributed Labor |  | 42d | 2019-08-01 A | 2019-12-31 A | S214900 | 100% | 2019-08-01 | 2019-09-30 |  | PROF4 PO E [67 h]; SCI2 UM - Unpaid [10 h]; STUDENT GRAD UM - Unpaid [80 h] | 9,579.37 | S215900 | 0 | S197000 | S215905 | CA | In Progress | B_T | Mannel, Eric | L3 | BNL | Test_System | Eric Mannel | BNL | null | POM02.1.05.01 |  |  | C | 1.05 | 16712 | 002,003 | 1.05B | 01 |  |  |  | 180423 ELM rsrc per GRY | S197000 |  |  |  |  |  |  |  |  |  |  | 1 |  |  |  |  |  |
| S245000 |  | Procure Test stand for SiPMs |  | 42d | 2019-08-01 A | 2019-12-30 A | S244800 SS, S101009 FS+60d, OBLG244810 SS | 100% | 2019-08-01 | 2019-09-30 |  | UM Contracted Purchase <$2M M&S [22000 h] | 24,271.83 | S245000 | 0 | S343195 | S245000 | CA | In Progress | A-OPC | Mannel, Eric | M4 | BNL | Fab & Assy | Eric Mannel |  | TEC | POM02.1.05.01 |  |  | C | 1.05 | 16704 | 003 | 1.05A | 01 |  | UDF_G2 |  | 180719 ELM added procurement string |  |  |  | PP6 | MP203240 | Yes | FAB |  |  | 2019-09-30 |  |  | Yes |  |  |  |  |
| S215000 |  | EMCal/HCal sensors Production - 8K Units - Delivery Acceptance No. 7 |  | 11d | 2019-08-16 A | 2019-08-31 A | S214900 | 100% | 2019-08-16 | 2019-08-30 | start on or after 2019-08-29 | Material (Purchase (1st $2M) [69520 h] | 76,698.99 | S215000 | 0 | S196400 | S215000 | CA | Completed | A-TEC | Mannel, Eric | M3 | Japan | Fab & Assy | Eric Mannel | BNL | TEC | POM02.1.05.01 |  |  | F | 1.05 | 59714 | 002,004 | 1.05A | 01 |  | UDF_G2 |  | 180405 units per GRY; 180329 ELM units per EJM | S196400 |  |  | PP6 | MP108910 |  |  | Delivery |  |  | SiPMs |  |  |  |  |  |  |
| S215100 |  | EMCal/HCal sensors Production - 8K Units - Delivery Acceptance No. 8 |  | 11d | 2019-10-01 A | 2019-10-03 A | S215000 | 100% | 2019-10-01 | 2019-10-16 | start on or after 2019-10-01 | Material (Purchase (1st $2M) [69520 h] | 77,557.45 | S215100 | 0 | S196500 | S215100 | CA | Completed | A-TEC | Mannel, Eric | M3 | Japan | Fab & Assy | Eric Mannel | BNL | TEC | POM02.1.05.01 |  |  | F | 1.05 | 59714 | 002 | 1.05A | 01 |  | UDF_G2 |  | 180405 units per GRY; 180329 ELM units per EJM | S196500 |  |  | PP6 | MP108910 |  |  | Delivery |  |  | SiPMs |  |  |  |  |  |  |
| S215200 |  | EMCal/HCal sensors Production - 8K Units - Delivery Acceptance No. 9 |  | 9d | 2019-11-01 A | 2019-11-14 A | S215100 | 100% |  |  | start on or after 2019-10-25 | Material (Purchase (1st $2M) [69520 h] | 77,557.45 | S215200 | 0 | S196600 | S215200 | CA | Completed | A-TEC | Mannel, Eric | M3 | Japan | Fab & Assy | Eric Mannel | BNL | TEC | POM02.1.05.01 |  |  | F | 1.05 | 59714 | 002 | 1.05A | 01 |  | UDF_G2 |  | 180405 name, units per GRY; 180329 ELM units per EJM | S196600 |  |  | PP6 | MP108910 |  |  | Delivery |  |  | SiPMs |  |  |  |  |  |  |
| S215300 |  | EMCal/HCal sensors Production - 8K Units - Delivery Acceptance No. 10 |  | 10d | 2019-12-16 A | 2019-12-31 A | S215200 | 100% | 2020-01-02 | 2020-01-15 | start on or after 2019-11-27 | Material (Purchase (1st $2M) [69520 h] | 77,557.45 | S215300 | 0 | S196620 | S215300 | CA | Not Started | A-TEC | Mannel, Eric | M3 | Japan | Fab & Assy | Eric Mannel | BNL | TEC | POM02.1.05.01 |  |  | F | 1.05 | 59714 | 002 | 1.05A | 01 |  | UDF_G2 |  | 180405 added activity per GRY | S196600 |  |  | PP6 | MP108910 |  |  | Delivery |  |  | SiPMs |  |  |  |  |  |  |
| S215310 |  | EMCal/HCal sensors Production - 8K Units - Delivery Acceptance No. 11 |  | 11d | 2020-01-02 A | 2020-01-16 A | S215300 | 100% |  |  | start on or after 2020-01-02 | Material (Purchase (1st $2M) [69520 h] | 77,557.45 | S215300 | 0 | S196620 | S215310 | CA | Not Started | A-TEC | Mannel, Eric | M3 | Japan | Fab & Assy | Eric Mannel | BNL | TEC | POM02.1.05.01 |  |  | F | 1.05 | 59714 | 002 | 1.05A | 01 |  | UDF_G2 |  | 180405 added activity per GRY | S196600 |  |  | PP6 | MP108910 |  |  | Delivery |  |  | SiPMs |  |  | UDF_G3 |  |  |  |
| S216000 |  | Production Q/A Tested & Sorted devices 8 K Units Delivery Batch No. 7 |  | 20d | 2020-01-02 A | 2020-01-30 A | S215000, S215900, S245100 SS, OBLG245110 | 100% |  |  |  | STUDENT UM - Purchased Services [80 h] | 1,276.86 | S216000 | 0 | S197100 | S216000 | CA | Not Started | A-TEC | Mannel, Eric | L3 | BNL | Test_System | Eric Mannel | BNL | null | POM02.1.05.01 |  |  | C | 1.05 | 59714 | 002 | 1.05A | 01 |  |  |  | 180423 ELM rsrc per GRY | S197100 |  |  | PP6 | MP203250 |  | FAB |  |  |  |  |  |  |  |  |  |  |
| S216005 |  | Production Q/A Tested & Sorted devices 8 K Units Delivery Batch No. 7 - Contributed Labor |  | 20d | 2020-01-02 A | 2020-01-30 A | S215000, S215905 | 100% |  |  |  | STUDENT GRAD UM - Unpaid [79.94 h]; SCI2 UM - Unpaid [9.99 h]; PROF4 PO E [67 h] | 9,866.76 | S216000 | 0 | S197100 | S216005 | CA | Not Started | B_T | Mannel, Eric | L3 | BNL | Test_System | Eric Mannel | BNL | null | POM02.1.05.01 |  |  | C | 1.05 | 16712 | 003 | 1.05B | 01 |  |  |  | 180423 ELM rsrc per GRY | S197100 |  |  |  |  |  |  |  |  |  |  |  |  |  |  |  |  |
| S215320 |  | EMCal/HCal sensors Production - 8K Units - Delivery Acceptance No. 12 |  | 12d | 2020-02-03 A | 2020-02-04 A | S215310 | 100% | 2020-03-02 | 2020-03-17 | start on or after 2020-01-30 | Material (Purchase (1st $2M) [69520 h] | 77,557.45 | S215300 | 0 | S196620 | S215320 | CA | Not Started | A-TEC | Mannel, Eric | M3 | Japan | Fab & Assy | Eric Mannel | BNL | TEC | POM02.1.05.01 |  |  | F | 1.05 | 59714 | 002 | 1.05A | 01 |  | UDF_G2 |  | 180405 added activity per GRY | S196600 |  |  | PP6 | MP108910 |  |  | Delivery |  |  | SiPMs |  |  | UDF_G3 |  |  |  |
| S215400 |  | EMCal/HCal sensors Production - 5K Units - Delivery Acceptance No. 13 |  | 19d | 2020-02-03 A | 2020-02-04 A | S215320 | 100% | 2020-03-18 | 2020-04-13 |  | Material (Purchase (1st $2M) [43450 h] | 48,473.41 | S215400 | 0 | S196640 | S215400 | CA | Not Started | A-TEC | Mannel, Eric | M3 | Japan | Fab & Assy | Eric Mannel | BNL | TEC | POM02.1.05.01 |  |  | F | 1.05 | 59714 | 002 | 1.05A | 01 |  | UDF_G2 |  | 180405 added activity per GRY | S196600 |  |  | PP6 | MP108910 |  |  | Delivery |  |  | SiPMs |  |  | UDF_G3 |  |  |  |
| S216100 |  | Production Q/A Tested & Sorted devices 8 K Units Delivery Batch No. 8 |  | 20d | 2020-02-03 A | 2020-02-28 A | S215100, S216000, S245100 SS, OBLG245110 | 100% | 2020-03-02 | 2020-03-27 |  | STUDENT UM - Purchased Services [80 h] | 1,276.86 | S216100 | 0 | S197200 | S216100 | CA | Not Started | A-TEC | Mannel, Eric | L3 | BNL | Test_System | Eric Mannel | BNL | null | POM02.1.05.01 |  |  | C | 1.05 | 59714 | 002 | 1.05A | 01 |  |  |  | 180423 ELM rsrc per GRY | S197200 |  |  | PP6 | MP203250 |  | FAB |  |  |  |  |  |  |  |  |  |  |
| S216105 |  | Production Q/A Tested & Sorted devices 8 K Units Delivery Batch No. 8 - Contributed Labor |  | 20d | 2020-02-03 A | 2020-02-28 A | S215100, S216005 | 100% | 2020-03-02 | 2020-03-27 |  | STUDENT GRAD UM - Unpaid [79.94 h]; SCI2 UM - Unpaid [9.99 h]; PROF4 PO E [67 h] | 9,866.76 | S216100 | 0 | S197200 | S216105 | CA | Not Started | B_T | Mannel, Eric | L3 | BNL | Test_System | Eric Mannel | BNL | null | POM02.1.05.01 |  |  | C | 1.05 | 16712 | 003 | 1.05B | 01 |  |  |  | 180423 ELM rsrc per GRY | S197200 |  |  |  |  |  |  |  |  |  |  |  |  |  |  |  |  |
| S216200 |  | Production Q/A Tested & Sorted devices 8 K Units Delivery Batch No. 9 |  | 20d | 2020-02-03 A | 2020-02-28 A | S215200, S216100, S245100 SS, OBLG245110 | 100% | 2020-03-30 | 2020-04-24 |  | STUDENT UM - Purchased Services [80 h] | 1,276.86 | S216200 | 0 | S197300 | S216200 | CA | Not Started | A-TEC | Mannel, Eric | L3 | BNL | Test_System | Eric Mannel | BNL | null | POM02.1.05.01 |  |  | C | 1.05 | 59714 | 002 | 1.05A | 01 |  |  |  | 180423 ELM rsrc per GRY; 180405 name per GRY | S197300 |  |  | PP6 | MP203250 |  | FAB |  |  |  |  |  |  |  |  |  |  |
| S216205 |  | Production Q/A Tested & Sorted devices 8 K Units Delivery Batch No. 9 - Contributed Labor |  | 20d | 2020-02-03 A | 2020-02-28 A | S215200, S216105 | 100% | 2020-03-30 | 2020-04-24 |  | STUDENT GRAD UM - Unpaid [79.94 h]; SCI2 UM - Unpaid [9.99 h]; PROF4 PO E [67 h] | 9,866.76 | S216200 | 0 | S197300 | S216205 | CA | Not Started | B_T | Mannel, Eric | L3 | BNL | Test_System | Eric Mannel | BNL | null | POM02.1.05.01 |  |  | C | 1.05 | 16712 | 003 | 1.05B | 01 |  |  |  | 180423 ELM rsrc per GRY; 180405 name per GRY | S197300 |  |  |  |  |  |  |  |  |  |  |  |  |  |  |  |  |
| S216300 |  | Production Q/A Tested & Sorted devices 8 K Units Delivery Batch No. 10 |  | 20d | 2020-02-03 A | 2020-02-28 A | S216200, S215300, S245100 SS, OBLG245110 | 100% | 2020-04-27 | 2020-05-22 |  | STUDENT UM - Purchased Services [80 h] | 1,276.86 | S216300 | 0 | S197350 | S216300 | CA | Not Started | A-TEC | Mannel, Eric | L3 | BNL | Test_System | Eric Mannel | BNL | null | POM02.1.05.01 |  |  | C | 1.05 | 59714 | 002 | 1.05A | 01 |  |  |  | 180423 ELM rsrc per GRY; 180405 added activity per GRY | S197300 |  |  | PP6 | MP203250 |  | FAB |  |  |  |  |  |  |  |  |  |  |
| S216305 |  | Production Q/A Tested & Sorted devices 8 K Units Delivery Batch No. 10 - Contributed Labor |  | 20d | 2020-02-03 A | 2020-02-28 A | S216205, S215300 | 100% | 2020-04-27 | 2020-05-22 |  | STUDENT GRAD UM - Unpaid [79.94 h]; SCI2 UM - Unpaid [9.99 h]; PROF4 PO E [67 h] | 9,866.76 | S216300 | 0 | S197350 | S216305 | CA | Not Started | B_T | Mannel, Eric | L3 | BNL | Test_System | Eric Mannel | BNL | null | POM02.1.05.01 |  |  | C | 1.05 | 16712 | 003 | 1.05B | 01 |  |  |  | 180423 ELM rsrc per GRY; 180405 added activity per GRY | S197300 |  |  |  |  |  |  |  |  |  |  |  |  |  |  |  |  |
| S216310 |  | Production Q/A Tested & Sorted devices 8 K Units Delivery Batch No. 11 |  | 20d | 2020-02-03 A | 2020-02-28 A | S215310, S216300, S245100 SS, OBLG245110 | 100% | 2020-05-26 | 2020-06-22 |  | STUDENT UM - Purchased Services [80 h] | 1,276.86 | S216300 | 0 | S197350 | S216310 | CA | Not Started | A-TEC | Mannel, Eric | L3 | BNL | Test_System | Eric Mannel | BNL | null | POM02.1.05.01 |  |  | C | 1.05 | 59714 | 002 | 1.05A | 01 |  |  |  | 180423 ELM rsrc per GRY; 180405 added activity per GRY | S197300 |  |  | PP6 | MP203250 |  | FAB |  |  |  |  |  |  |  |  |  |  |
| S216315 |  | Production Q/A Tested & Sorted devices 8 K Units Delivery Batch No. 11 - Contributed Labor |  | 20d | 2020-02-03 A | 2020-02-28 A | S215310, S216305 | 100% | 2020-05-26 | 2020-06-22 |  | STUDENT GRAD UM - Unpaid [79.94 h]; SCI2 UM - Unpaid [9.99 h]; PROF4 PO E [67 h] | 9,866.76 | S216300 | 0 | S197350 | S216315 | CA | Not Started | B_T | Mannel, Eric | L3 | BNL | Test_System | Eric Mannel | BNL | null | POM02.1.05.01 |  |  | C | 1.05 | 16712 | 003 | 1.05B | 01 |  |  |  | 180423 ELM rsrc per GRY; 180405 added activity per GRY | S197300 |  |  |  |  |  |  |  |  |  |  |  |  |  |  |  |  |
| S216320 |  | Production Q/A Tested & Sorted devices 8 K Units Delivery Batch No. 12 |  | 20d | 2020-02-03 A | 2020-02-28 A | S215320, S216310, S245100 SS, OBLG245110 | 100% | 2020-06-23 | 2020-07-21 |  | STUDENT UM - Purchased Services [80 h] | 1,276.86 | S216300 | 0 | S197350 | S216320 | CA | Not Started | A-TEC | Mannel, Eric | L3 | BNL | Test_System | Eric Mannel | BNL | null | POM02.1.05.01 |  |  | C | 1.05 | 59714 | 002 | 1.05A | 01 |  |  |  | 180423 ELM rsrc per GRY; 180405 added activity per GRY | S197300 |  |  | PP6 | MP203250 |  | FAB |  |  |  |  |  |  |  |  |  |  |
| S216325 |  | Production Q/A Tested & Sorted devices 8 K Units Delivery Batch No. 12 - Contributed Labor |  | 20d | 2020-02-03 A | 2020-02-28 A | S215320, S216315 | 100% | 2020-06-23 | 2020-07-21 |  | STUDENT GRAD UM - Unpaid [79.94 h]; SCI2 UM - Unpaid [9.99 h]; PROF4 PO E [67 h] | 9,866.76 | S216300 | 0 | S197350 | S216325 | CA | Not Started | B_T | Mannel, Eric | L3 | BNL | Test_System | Eric Mannel | BNL | null | POM02.1.05.01 |  |  | C | 1.05 | 16712 | 003 | 1.05B | 01 |  |  |  | 180423 ELM rsrc per GRY; 180405 added activity per GRY | S197300 |  |  |  |  |  |  |  |  |  |  |  |  |  |  |  |  |
| S216400 |  | Production Q/A Tested & Sorted devices 5 K Units Delivery Batch No. 13 |  | 20d | 2020-02-03 A | 2020-02-28 A | S215400, S216320, S245100 SS, OBLG245110 | 100% | 2020-07-22 | 2020-08-18 |  | STUDENT UM - Purchased Services [50 h] | 798.04 | S216400 | 0 | S197370 | S216400 | CA | Not Started | A-TEC | Mannel, Eric | L3 | BNL | Test_System | Eric Mannel | BNL | null | POM02.1.05.01 |  |  | C | 1.05 | 59714 | 002 | 1.05A | 01 |  |  |  | 180423 ELM rsrc per GRY; 180405 added activity per GRY | S197300 |  |  | PP6 | MP203250 |  | FAB |  |  |  |  |  |  |  |  |  |  |
| S216405 |  | Production Q/A Tested & Sorted devices 5 K Units Delivery Batch No. 13 - Contributed Labor |  | 20d | 2020-02-03 A | 2020-02-28 A | S215400, S216325 | 100% | 2020-07-22 | 2020-08-18 |  | STUDENT GRAD UM - Unpaid [49.96 h]; SCI2 UM - Unpaid [6.25 h]; PROF4 PO E [42 h] | 6,185.13 | S216400 | 0 | S197370 | S216405 | CA | Not Started | B_T | Mannel, Eric | L3 | BNL | Test_System | Eric Mannel | BNL | null | POM02.1.05.01 |  |  | C | 1.05 | 16712 | 003 | 1.05B | 01 |  |  |  | 180423 ELM rsrc per GRY; 180405 added activity per GRY | S197300 |  |  |  |  |  |  |  |  |  |  |  |  |  |  |  |  |
| S216500 |  | EMCal/HCal SiPM Sensor Procurement Complete | milestone | 0d | 2020-02-28 A | 2020-02-28 A | S216400 FF, S215500, S216405 FF | 100% | 2020-08-18 | 2020-08-18 |  |  |  | S216500 | 0 | S197400 |  | NOCA | Not Started |  | Mannel, Eric |  | BNL | Procurement | Eric Mannel | BNL |  | POM02.1.05.01 |  |  |  |  |  | 002 |  | 01 |  |  |  |  | S197400 |  | L2 |  |  |  |  |  |  |  |  |  |  |  | 2020-10-30 | 171 | PMP_1x |
| S215500 |  | EMCal/HCal sensors Production: - delivery complete | milestone | 0d | 2020-03-02 A | 2020-03-02 A | S215400 | 100% |  |  |  |  |  | S215500 | 0 | S196700 |  | NOCA | Not Started |  | Mannel, Eric |  | Japan | Fab & Assy | Eric Mannel | BNL |  | POM02.1.05.01 |  |  |  |  |  | 002 |  | 01 |  |  |  |  | S196700 |  | L3 |  |  |  |  |  |  |  |  |  |  |  |  |  |  |

Notes:
- S211200: BNL_UDF_Status Comments: 190315 DurType to align with EVT / BNL_UDF_Old Activity Name 181221: Actuals - Labor - sPHENIX Calorimeter Electronics FY17
- S211400: BNL_UDF_Status Comments: 190315 DurType to align with EVT / BNL_UDF_Old Activity Name 181221: Actuals - Nonlabor - sPHENIX Calorimeter Electronics FY17
- S211300: BNL_UDF_Status Comments: 190315 DurType to align with EVT / BNL_UDF_Old Activity Name 181221: Actuals - Labor - sPHENIX Calorimeter Electronics FY18
- S211500: BNL_UDF_Status Comments: 190315 DurType to align with EVT / BNL_UDF_Old Activity Name 181221: Actuals - Nonlabor - sPHENIX Calorimeter Electronics FY18
- S1000839: BNL_UDF_Status Comments: 190315 DurType to align with EVT / BNL_UDF_Old Activity Name 181221: Actuals - Labor - sPHENIX Calorimeter Electronics FY18
- S1000879: BNL_UDF_Status Comments: 190315 DurType to align with EVT / BNL_UDF_Old Activity Name 181221: Actuals - Nonlabor - sPHENIX Calorimeter Electronics FY18
- S1001959: BNL_UDF_Status Comments: 190315 DurType to align with EVT / BNL_UDF_Old Activity Name 181221: Actuals - Nonlabor - sPHENIX Calorimeter Electronics FY18
- S211600: BNL_UDF_Status Comments: 190415 ELM name per GRY / BNL_UDF_Old Activity Name 181221: Write Design Change Specifications for Optical Sensors: Sector 0 - Labor
- S211601: BNL_UDF_Status Comments: 190508 ELM add per GRY; 190415 ELM name per GRY / BNL_UDF_Old Activity Name 181221: Write Design Change Specifications for Optical Sensors: Sector 0 - Labor
- S211700: BNL_UDF_Status Comments: 190415 ELM name per GRY / BNL_UDF_Old Activity Name 181221: Write Design Change Specifications for Optical Sensors: Sector 0 - M&S
- S211800: BNL_UDF_Old Activity Name 181221: Order Sensors: Sector 0 - Labor
- S211900: BNL_UDF_Old Activity Name 181221: Order Sensors: Sector 0 - M&S
- S212000: BNL_UDF_Old Activity Name 181221: Q/A Delivered Sensors: Sector 0 - Labor
- S212100: BNL_UDF_Old Activity Name 181221: Q/A Delivered Sensors: Sector 0 - M&S
- S212200: BNL_UDF_Status Comments: 190415 ELM name per GRY / BNL_UDF_Old Activity Name 181221: EMCal/HCal Sensors Tested and Delivered: Sector 0
- S212201: BNL_UDF_Status Comments: 190508 ELM add per GRY / BNL_UDF_Old Activity Name 181221: EMCal/HCal Sensors Tested and Delivered: Sector 0
- S212300: BNL_UDF_Old Activity Name 181221: EMCal/HCal sensors Preproduction - Provide Requirements to Procurement
- S212400: BNL_UDF_Old Activity Name 181221: EMCal/HCal sensors Preproduction - Prepare & Send Solicitation
- S212500: BNL_UDF_Old Activity Name 181221: EMCal/HCal sensors Preproduction - Vendor Responses & Selection
- OBLG212600: BNL_UDF_Status Comments: 190416 ELM name, dur; 190316 ELM add / BNL_UDF_Old Activity Name 181221: EMCal/HCal sensors Preproduction - Contract Award(s)- deliver units 1 - 10K
- OBLG212710: BNL_UDF_Status Comments: 190522 IVS remove CD-2/3 pred. 190316 ELM add / BNL_UDF_Old Activity Name 181221: EMCal/HCal sensors Preproduction - Contract Award(s)- deliver units 10 - 23K
- S212600: BNL_UDF_Old Activity Name 181221: EMCal/HCal sensors Preproduction - Contract Award(s)- deliver units 1 - 10K
- S212700: BNL_UDF_Status Comments: 190522 IVS remove CD-2/3 pred. / BNL_UDF_Old Activity Name 181221: EMCal/HCal sensors Preproduction - Contract Award(s)- deliver units 10 - 23K
- S212800: BNL_UDF_Old Activity Name 181221: EMCal/HCal sensors Preproduction - Vendor Leadtime FY18
- S212900: BNL_UDF_Status Comments: 190604 IVS; 190522 IVS move Start from Nov 1 to Oct 1 2019 / BNL_UDF_Old Activity Name 181221: EMCal/HCal sensors Preproduction - Vendor Leadtime FY19
- S213010: BNL_UDF_Status Comments: 190604 IVS status; / BNL_UDF_Old Activity Name 181221: EMCal/HCal sensors Preproduction - deliver units 10K - 23K
- S213000: BNL_UDF_Status Comments: 190604 IVS status; / BNL_UDF_Old Activity Name 181221: EMCal/HCal sensors Preproduction - deliver units 1 - 10K
- S213100: BNL_UDF_Status Comments: 190604 IVS status; / BNL_UDF_Old Activity Name 181221: EMCal/HCal sensors Preproduction - deliver units 10K - 23K
- S214700: BNL_UDF_Old Activity Name 181221: EMCal/HCal sensors Production - deliver units 1 - 10K
- S213200: BNL_UDF_Status Comments: 190313 ELM Activity split for fund src / BNL_UDF_Old Activity Name 181221: Prepro Q/A Tested & Sorted devices 1 - 10K
- S213205: BNL_UDF_Status Comments: 190313 ELM Activity split for fund src / BNL_UDF_Old Activity Name 181221: Prepro Q/A Tested & Sorted devices 1 - 10K
- S214800: BNL_UDF_Status Comments: 190522 IVS dur to 20d / BNL_UDF_Old Activity Name 181221: EMCal/HCal sensors Production - deliver units 10K - 20K
- S215600: BNL_UDF_Status Comments: 190313 ELM Activity split for fund src / BNL_UDF_Old Activity Name 181221: Q/A Tested & Sorted Production devices 1 - 10K - labor
- S215605: BNL_UDF_Status Comments: 190313 ELM Activity split for fund src / BNL_UDF_Old Activity Name 181221: Q/A Tested & Sorted Production devices 1 - 10K - labor
- S215800: BNL_UDF_Status Comments: 190522 IVS remove REL pred 245100, 214800, OBLG245110; 190313 ELM Activity split for fund src / BNL_UDF_Old Activity Name 181221: Q/A Tested & Sorted Production devices 10 - 20K
- S215805: BNL_UDF_Status Comments: 190313 ELM Activity split for fund src / BNL_UDF_Old Activity Name 181221: Q/A Tested & Sorted Production devices 10 - 20K
- S213210: BNL_UDF_Status Comments: 190313 ELM Activity split for fund src / BNL_UDF_Old Activity Name 181221: Prepro Q/A Tested & Sorted devices 10 - 23K
- S213215: BNL_UDF_Status Comments: 190313 ELM Activity split for fund src / BNL_UDF_Old Activity Name 181221: Prepro Q/A Tested & Sorted devices 10 - 23K
- S213300: BNL_UDF_Status Comments: 190313 ELM Activity split for fund src / BNL_UDF_Old Activity Name 181221: Prepro Q/A Tested & Sorted devices 10 - 23K
- S213305: BNL_UDF_Status Comments: 190313 ELM Activity split for fund src / BNL_UDF_Old Activity Name 181221: Prepro Q/A Tested & Sorted devices 10 - 23K
- S214900: BNL_UDF_Old Activity Name 181221: EMCal/HCal sensors Production - deliver units 20K - 30K
- S215900: BNL_UDF_Status Comments: 190313 ELM Activity split for fund src / BNL_UDF_Old Activity Name 181221: Q/A Tested & Sorted Production devices 20 - 30K
- S215905: BNL_UDF_Status Comments: 190313 ELM Activity split for fund src / BNL_UDF_Old Activity Name 181221: Q/A Tested & Sorted Production devices 20 - 30K
- S245000: BNL_UDF_Status Comments: 190316 ELM move act to wbs / BNL_UDF_Old Activity Name 181221: Procure Teststand for SiPMs
- S215000: BNL_UDF_Status Comments: 190522 IVS dur to 24d / BNL_UDF_Old Activity Name 181221: EMCal/HCal sensors Production - deliver units 30K - 40K
- S215100: BNL_UDF_Old Activity Name 181221: EMCal/HCal sensors Production - deliver units 40K - 50K
- S215200: BNL_UDF_Old Activity Name 181221: EMCal/HCal sensors Production - deliver units 50K - 60K
- S215300: BNL_UDF_Old Activity Name 181221: EMCal/HCal sensors Production - deliver units 60K - 70K
- S215310: BNL_UDF_Old Activity Name 181221: EMCal/HCal sensors Production - deliver units 60K - 70K
- S216000: BNL_UDF_Status Comments: 190313 ELM Activity split for fund src / BNL_UDF_Old Activity Name 181221: Q/A Tested & Sorted Production devices 30 - 40K
- S216005: BNL_UDF_Status Comments: 190313 ELM Activity split for fund src / BNL_UDF_Old Activity Name 181221: Q/A Tested & Sorted Production devices 30 - 40K
- S215320: BNL_UDF_Old Activity Name 181221: EMCal/HCal sensors Production - deliver units 60K - 70K
- S215400: BNL_UDF_Old Activity Name 181221: EMCal/HCal sensors Production - deliver units 70K - 77K
- S216100: BNL_UDF_Status Comments: 190313 ELM Activity split for fund src / BNL_UDF_Old Activity Name 181221: Q/A Tested & Sorted Production devices 40 - 50K
- S216105: BNL_UDF_Status Comments: 190313 ELM Activity split for fund src / BNL_UDF_Old Activity Name 181221: Q/A Tested & Sorted Production devices 40 - 50K
- S216200: BNL_UDF_Status Comments: 190313 ELM Activity split for fund src / BNL_UDF_Old Activity Name 181221: Q/A Tested & Sorted Production devices 50 - 60K
- S216205: BNL_UDF_Status Comments: 190313 ELM Activity split for fund src / BNL_UDF_Old Activity Name 181221: Q/A Tested & Sorted Production devices 50 - 60K
- S216300: BNL_UDF_Status Comments: 190313 ELM Activity split for fund src / BNL_UDF_Old Activity Name 181221: Q/A Tested & Sorted Production devices 60 - 70K
- S216305: BNL_UDF_Status Comments: 190313 ELM Activity split for fund src / BNL_UDF_Old Activity Name 181221: Q/A Tested & Sorted Production devices 60 - 70K
- S216310: BNL_UDF_Status Comments: 190313 ELM Activity split for fund src / BNL_UDF_Old Activity Name 181221: Q/A Tested & Sorted Production devices 60 - 70K
- S216315: BNL_UDF_Status Comments: 190313 ELM Activity split for fund src / BNL_UDF_Old Activity Name 181221: Q/A Tested & Sorted Production devices 60 - 70K
- S216320: BNL_UDF_Status Comments: 190313 ELM Activity split for fund src / BNL_UDF_Old Activity Name 181221: Q/A Tested & Sorted Production devices 60 - 70K
- S216325: BNL_UDF_Status Comments: 190313 ELM Activity split for fund src / BNL_UDF_Old Activity Name 181221: Q/A Tested & Sorted Production devices 60 - 70K
- S216400: BNL_UDF_Status Comments: 190313 ELM Activity split for fund src / BNL_UDF_Old Activity Name 181221: Q/A Tested & Sorted Production devices 70 - 77K
- S216405: BNL_UDF_Status Comments: 190313 ELM Activity split for fund src / BNL_UDF_Old Activity Name 181221: Q/A Tested & Sorted Production devices 70 - 77K
- S216500: BNL_UDF_Old Activity Name 181221: EMCal/HCal SiPM Sensor Production Complete
- S215500: BNL_UDF_Old Activity Name 181221: EMCal/HCal sensors Production: - delivery complete

| ID | WBS | Activity | Type | Duration | Start | Finish | Predecessors | Complete | Planned start | Planned finish | Resources | Cost | BNL_UDF_Temp Text 01 | BNL_UDF_Percent Complete | BNL_UDF_OPC TEC (deprecated) | BNL_UDF_Old Activity ID 181221 | RG Check | BNL_Activity Status | BNL_Estimator | BNL_Cost Basis | BNL_EDIA | BNL_CAM | BNL_Institution | BNL_R&D FY18-19 | BNL_OPC TEC (deprecated) | BNL_WBS | BNL_EVT | BNL_WBS_Hierarchical | Completed | BNL_PCR ID | BNL_UDF_Temp Date 01 | BNL_Milestone Level | BNL_DOE OPC | BNL_Fund Source | BNL_Account Number | BNL_Cobra WP | BNL_Master Control Account | BNL_Cobra Control Account | Indicator - Procurement | BNL_Proc Sig | BNL_Proc Sig Phase | Indicator - Float | BNL_UDF_Remaining Tot Cost | BNL_UDF_Percent_remaining |
| --- | --- | --- | --- | --- | --- | --- | --- | --- | --- | --- | --- | --- | --- | --- | --- | --- | --- | --- | --- | --- | --- | --- | --- | --- | --- | --- | --- | --- | --- | --- | --- | --- | --- | --- | --- | --- | --- | --- | --- | --- | --- | --- | --- | --- |
|  | 02 | **Calorimeter Front End Electronics** |  |  | 2018-04-01 | 2022-01-28 |  |  |  |  |  |  |  |  |  |  |  |  |  |  |  |  |  |  |  |  |  |  |  |  |  |  |  |  |  |  |  |  |  |  |  |  |  |  |
|  | 01 | **EMCal Electronics: Preproduction** |  |  | 2018-04-01 | 2021-05-28 |  |  |  |  |  |  |  |  |  |  |  |  |  |  |  |  |  |  |  |  |  |  |  |  |  |  |  |  |  |  |  |  |  |  |  |  |  |  |
| S216600 |  | Review and write design specification: EMCal Preproduction Prototype [Sector 0] |  | 21d | 2018-04-01 A | 2018-04-30 A | S189400 | 100% | 2018-04-02 | 2018-04-30 |  |  | S216600 | 100 | S197700 | S197700 | NOCA | Completed | Mannel, Eric | L2 | Design | Eric Mannel | BNL | CalEl EMCal FEE tests | null | POM02.1.05.02.01 | C | 01 | yes |  |  |  |  |  |  |  |  |  |  |  |  |  |  |  |
| S216601 |  | Preliminary Design Review - EMCal FEE sectors 1-12 | milestone | 0d | 2018-04-30 A | 2018-04-30 A | S216600 FF | 100% |  |  |  |  | S216600 | 100 | S197700 | S197700 | NOCA | Completed | Mannel, Eric | L2 | Design | Eric Mannel | BNL | CalEl EMCal FEE tests | null | POM02.1.05.02.01 | C | 01 | yes | 004 |  |  |  |  |  |  |  |  |  |  |  |  |  |  |
| S216700 |  | Design EMCal SiPM Daughter Board: Preproduction [Sector 0] |  | 52d | 2018-04-30 A | 2018-07-12 A | S216601 | 100% |  |  |  |  | S216700 | 100 | S197900 | S197900 | NOCA | Completed | Mannel, Eric | L3 | Design | Eric Mannel | BNL | CalEl EMCal FEE tests | null | POM02.1.05.02.01 | C | 01 | yes |  | 2018-07-12 |  |  |  |  |  |  |  |  |  |  |  |  |  |
| S216800 |  | Layout EMCal SiPM Daughter Board: Preproduction [Sector 0] |  | 52d | 2018-04-30 A | 2018-07-12 A | S216700 FF | 100% |  |  |  |  | S216800 | 100 | S198500 | S198500 | NOCA | Completed | Mannel, Eric | L3 | Fab & Assy | Eric Mannel | BNL | CalEl EMCal FEE tests | null | POM02.1.05.02.01 | C | 01 | yes |  | 2018-07-12 |  |  |  |  |  |  |  |  |  |  |  |  |  |
| S216900 |  | Design EMCal Preamp: Preproduction [Sector 0] |  | 52d | 2018-04-30 A | 2018-07-12 A | S216601 | 100% |  |  |  |  | S216900 | 100 | S198000 | S198000 | NOCA | Completed | Mannel, Eric | L3 | Design | Eric Mannel | BNL | CalEl EMCal FEE tests | null | POM02.1.05.02.01 | C | 01 | yes |  | 2018-07-12 |  |  |  |  |  |  |  |  |  |  |  |  |  |
| S217000 |  | Layout EMCal Preamp: Preproduction [Sector 0] |  | 52d | 2018-04-30 A | 2018-07-12 A | S216900 FF | 100% |  |  |  |  | S217000 | 100 | S198600 | S198600 | NOCA | Completed | Mannel, Eric | L3 | Fab & Assy | Eric Mannel | BNL | CalEl EMCal FEE tests | null | POM02.1.05.02.01 | C | 01 | yes |  | 2018-07-12 |  |  |  |  |  |  |  |  |  |  |  |  |  |
| S217100 |  | Design EMCal Interface Board: Preproduction [Sector 0] |  | 52d | 2018-04-30 A | 2018-07-12 A | S216601 | 100% |  |  |  |  | S217100 | 100 | S198100 | S198100 | NOCA | Completed | Mannel, Eric | L3 | Design | Eric Mannel | BNL | CalEl EMCal FEE tests | null | POM02.1.05.02.01 | C | 01 | yes |  | 2018-07-12 |  |  |  |  |  |  |  |  |  |  |  |  |  |
| S217200 |  | Layout EMCal Interface: Preproduction [Sector 0] |  | 52d | 2018-04-30 A | 2018-07-12 A | S217100 FF | 100% |  |  |  |  | S217200 | 100 | S198700 | S198700 | NOCA | Completed | Mannel, Eric | L3 | Fab & Assy | Eric Mannel | BNL | CalEl EMCal FEE tests | null | POM02.1.05.02.01 | C | 01 | yes |  | 2018-07-12 |  |  |  |  |  |  |  |  |  |  |  |  |  |
| S217300 |  | Design Calorimeter Controller: Preproduction [Sector 0] |  | 52d | 2018-04-30 A | 2018-07-12 A | S216601 | 100% |  |  |  |  | S217300 | 100 | S198200 | S198200 | NOCA | Completed | Mannel, Eric | L3 | Design | Eric Mannel | BNL | CalEl EMCal FEE tests | null | POM02.1.05.02.01 | C | 01 | yes |  | 2018-07-12 |  |  |  |  |  |  |  |  |  |  |  |  |  |
| S217400 |  | Layout Calorimeter Controller: Preproduction [Sector 0] |  | 52d | 2018-04-30 A | 2018-07-12 A | S217300 FF | 100% |  |  |  |  | S217400 | 100 | S198800 | S198800 | NOCA | Completed | Mannel, Eric | L3 | Fab & Assy | Eric Mannel | BNL | CalEl EMCal FEE tests | null | POM02.1.05.02.01 | C | 01 | yes |  | 2018-07-12 |  |  |  |  |  |  |  |  |  |  |  |  |  |
| S217500 |  | Specify Signal and Power Cables for EMCal: Preproduction [Sector 0] |  | 52d | 2018-04-30 A | 2018-07-12 A | S216601 | 100% |  |  |  |  | S217500 | 100 | S198300 | S198300 | NOCA | Completed | Mannel, Eric | L3 | Procurement | Eric Mannel | BNL | CalEl EMCal FEE tests | null | POM02.1.05.02.01 | C | 01 | yes |  | 2018-07-12 |  |  |  |  |  |  |  |  |  |  |  |  |  |
| S217600 |  | Specify Power System for EMCal: Preproduction [Sector 0] |  | 52d | 2018-04-30 A | 2018-07-12 A | S216601 | 100% |  |  |  |  | S217600 | 100 | S198400 | S198400 | NOCA | Completed | Mannel, Eric | L3 | Procurement | Eric Mannel | BNL | CalEl EMCal FEE tests | null | POM02.1.05.02.01 | C | 01 | yes |  | 2018-07-12 |  |  |  |  |  |  |  |  |  |  |  |  |  |
| S217700 |  | Final Design Review, Safety Review - EMCal Preproduction Electronics [Sector 0] |  | 5d | 2018-07-13 A | 2018-07-19 A | S217500, S217600, S216800, S217000, S217200, S217400 | 100% |  |  |  |  | S217700 | 100 | S198900 | S198900 | NOCA | Completed | Mannel, Eric | L2 | Management Safety Reviews | Eric Mannel | BNL | CalEl EMCal FEE tests | null | POM02.1.05.02.01 | C | 01 | yes | 004 |  |  |  |  |  |  |  |  |  |  |  |  |  |  |
| S217800 |  | Completed: Final Design Review, Safety Review - EMCal Preproduction Electronics [Sector 0] | milestone | 0d | 2018-07-19 A | 2018-07-19 A | S217700 | 100% |  |  |  |  | S217800 | 100 | S199000 | S199000 | NOCA | Completed | Mannel, Eric |  | Management Safety Reviews | Eric Mannel | BNL | CalEl EMCal FEE tests |  | POM02.1.05.02.01 |  | 01 | yes | 004 |  | L5 |  |  |  |  |  |  |  |  |  |  |  |  |
| S217900 |  | Review Safety and Design Review Report: EMCal Preproduction Electronics [Sector 0] |  | 5d | 2018-07-20 A | 2018-07-26 A | S217700, S217800 | 100% |  |  |  |  | S217900 | 100 | S199100 | S199100 | NOCA | Completed | Mannel, Eric | L2 | Management Safety Reviews | Eric Mannel | BNL | CalEl EMCal FEE tests | null | POM02.1.05.02.01 | C | 01 | yes |  |  |  |  |  |  |  |  |  |  |  |  |  |  |  |
| S218000 |  | Procure Components for EMCal SiPM Boards: Preproduction [Sector 0] Labor |  | 62d | 2018-07-27 A | 2018-10-24 A | S217900 | 100% |  |  |  |  | S218000 | 100 | S199200 | S199200 | NOCA | Completed | Mannel, Eric | L2 | Procurement | Eric Mannel | BNL | CalEl EMCal FEE tests | null | POM02.1.05.02.01 | C | 01 | yes |  |  |  |  |  |  |  |  |  |  |  |  |  |  |  |
| S218100 |  | Procure Components for EMCal SiPM Boards: Preproduction [Sector 0] M&S |  | 62d | 2018-07-27 A | 2018-10-24 A | S217900 | 100% |  |  |  |  | S218100 | 100 | S199700 | S199300 | NOCA | Completed | Mannel, Eric | M3 | Fab & Assy | Eric Mannel | BNL | CalEl EMCal FEE tests | OPC | POM02.1.05.02.01 | C | 01 | yes |  |  |  | OPC001800 |  |  |  |  |  |  |  |  |  |  |  |
| S218400 |  | Fabricate EMCal Preamp Boards: Preproduction [Sector 0] Labor FY18 |  | 15d | 2018-09-10 A | 2018-09-28 A | S217900 | 100% |  |  |  |  | S218400 | 100 | S200000 | S199910 | NOCA | Completed | Mannel, Eric | M3 | Procurement | Eric Mannel | BNL | CalEl EMCal FEE tests | null | POM02.1.05.02.01 | C | 01 | yes |  |  |  | OPC001800 |  |  |  |  |  |  |  |  |  |  |  |
| S218600 |  | Fabricate EMCal Preamp Boards: Preproduction [Sector 0] M&S FY18 |  | 15d | 2018-09-10 A | 2018-09-28 A | S217900 | 100% |  |  |  |  | S218600 | 100 | S200000 | S200000 | NOCA | Completed | Mannel, Eric | M3 | Fab & Assy | Eric Mannel | BNL | CalEl EMCal FEE tests | OPC | POM02.1.05.02.01 | C | 01 | yes |  |  |  | OPC001800 |  |  |  |  |  |  |  |  |  |  |  |
| S219200 |  | Procure EMCal Internal Signal/Test/Comm/LV/Bias Cables: Preproduction [Sector 0] Labor |  | 166d | 2018-10-01 A | 2019-05-31 A | S217900 | 100% |  |  |  |  | S219200 | 40 | S200200 | S200200 | NOCA | Completed | Mannel, Eric | L2 | Procurement | Eric Mannel | BNL | CalEl EMCal FEE tests | null | POM02.1.05.02.01 | C | 01 | yes |  | 2019-04-01 |  |  | B | 16712 |  |  |  |  |  |  |  |  |  |
| S219300 |  | Procure EMCal Internal Signal/Test/Comm/LV/Bias Cables: Preproduction [Sector 0] M&S |  | 134d | 2018-10-01 A | 2019-04-16 A | S217900 | 100% |  |  |  |  | S219300 | 100 | S200100 | S200100 | NOCA | Completed | Mannel, Eric | M3 | Fab & Assy | Eric Mannel | BNL | CalEl EMCal FEE tests | OPC | POM02.1.05.02.01 | F | 01 | yes | 003 | 2019-04-01 |  | OPC001800 | A-OPC | 16704 |  |  |  |  |  |  |  |  |  |
| S219400 |  | Procure EMCal External Signal and Power Cables, and Power Systems: Preproduction [Sector 0] Labor |  | 166d | 2018-10-01 A | 2019-05-31 A | S217900 | 100% |  |  |  |  | S219400 | 15 | S200200 | S277590364 | NOCA | Completed | Mannel, Eric | L2 | Procurement | Eric Mannel | BNL | CalEl EMCal FEE tests | null | POM02.1.05.02.01 | C | 01 | yes |  | 2019-04-01 |  |  | B | 16712 |  |  |  |  |  |  |  |  |  |
| S219500 |  | Procure EMCal External Signal and Power Cables, and Power Systems: Preproduction [Sector 0] M&S |  | 134d | 2018-10-01 A | 2019-04-16 A | S217900 | 100% |  |  |  |  | S219500 | 15 | S200100 | S277590404 | NOCA | Completed | Mannel, Eric | M3 | Fab & Assy | Eric Mannel | BNL | CalEl EMCal FEE tests | OPC | POM02.1.05.02.01 | F | 01 | yes | 003 | 2019-04-01 |  | OPC001800 | A-OPC | 16704 |  |  |  |  |  |  |  |  |  |
| S218200 |  | Fabricate EMCal SiPM Daughter Boards: Preproduction [Sector 0] Labor |  | 34d | 2018-11-01 A | 2018-12-21 A | S218000 | 100% |  |  |  |  | S218200 | 100 | S199300 | S200650 | NOCA | Completed | Mannel, Eric | L3 | Fab & Assy | Eric Mannel | BNL | CalEl EMCal FEE tests | null | POM02.1.05.02.01 | C | 01 | yes | 003 |  |  |  | B | 16712 |  |  |  |  |  |  |  |  |  |
| S218300 |  | Fabricate EMCal SiPM Daughter Boards: Preproduction [Sector 0] M&S |  | 34d | 2018-11-01 A | 2018-12-21 A | S218100 | 100% |  |  |  |  | S218300 | 100 | S200600 | S200600 | NOCA | Completed | Mannel, Eric | M4 | Fab & Assy | Eric Mannel | BNL | CalEl EMCal FEE tests | OPC | POM02.1.05.02.01 | F | 01 | yes | 003 |  |  | OPC001800 | A-OPC | 16704 |  |  |  |  |  |  |  |  |  |
| S218500 |  | Fabricate EMCal Preamp Boards: Preproduction [Sector 0] Labor FY19 |  | 7d | 2018-11-01 A | 2018-11-09 A | S218400 | 100% |  |  |  |  | S218500 | 100 | S200000 | S199911 | NOCA | Completed | Mannel, Eric | M3 | Procurement | Eric Mannel | BNL | CalEl EMCal FEE tests | null | POM02.1.05.02.01 | C | 01 | yes |  |  |  | OPC001800 | B | 16712 |  |  |  |  |  |  |  |  |  |
| S218700 |  | Fabricate EMCal Preamp Boards: Preproduction [Sector 0] M&S FY19 |  | 7d | 2018-11-01 A | 2018-11-09 A | S218600 | 100% |  |  |  |  | S218700 | 100 | S200000 | S200001 | NOCA | Completed | Mannel, Eric | M3 | Fab & Assy | Eric Mannel | BNL | CalEl EMCal FEE tests | OPC | POM02.1.05.02.01 | C | 01 | yes | 003 |  |  | OPC001800 | A-OPC | 16704 |  |  |  |  |  |  |  |  |  |
| S218900 |  | Fabricate EMCal Interface Board: Preproduction [Sector 0] Labor |  | 27d | 2018-11-01 A | 2018-12-12 A | S217900 | 100% |  |  |  |  | S218900 | 100 | S199600 | S199600 | NOCA | Completed | Mannel, Eric | L2 | Procurement | Eric Mannel | BNL | CalEl EMCal FEE tests | null | POM02.1.05.02.01 | C | 01 | yes |  |  |  |  | B | 16712 |  |  |  |  |  |  |  |  |  |
| S219000 |  | Fabricate EMCal Interface Board: Preproduction [Sector 0] M&S |  | 27d | 2018-11-01 A | 2018-12-12 A | S217900 | 100% |  |  |  |  | S219000 | 100 | S199500 | S199500 | NOCA | Completed | Mannel, Eric | M3 | Fab & Assy | Eric Mannel | BNL | CalEl EMCal FEE tests | OPC | POM02.1.05.02.01 | C | 01 | yes | 003 |  |  | OPC001800 | A-OPC | 16704 |  |  |  |  |  |  |  |  |  |
| S218800 |  | Test EMCal Preamp Boards: Preproduction [Sector 0] |  | 104d | 2018-11-13 A | 2019-04-15 A | S218500, S218700 | 100% |  |  |  |  | S218800 | 100 | S199300 | S200675 | NOCA | Completed | Mannel, Eric | L3 | Fab & Assy | Eric Mannel | BNL | CalEl EMCal FEE tests | null | POM02.1.05.02.01 | C | 01 | yes | 003 |  |  |  | B | 16712 |  |  |  |  |  |  |  |  |  |
| S219100 |  | Test EMCal Interface Boards: Preproduction [Sector 0] |  | 82d | 2018-12-13 A | 2019-04-11 A | S218900, S219000 | 100% |  |  |  |  | S219100 | 100 | S199400 | S200350 | NOCA | Completed | Mannel, Eric | L3 | Fab & Assy | Eric Mannel | BNL | CalEl EMCal FEE tests | null | POM02.1.05.02.01 | C | 01 | yes | 003 |  |  |  | B | 16712 |  |  |  |  |  |  |  |  |  |
| S219900 |  | Update Design per Change Specification - EMCal SiPM Daughter Board: Sectors 1-12 |  | 32d | 2019-04-09 A | 2019-05-22 A | S219800 | 100% |  |  |  |  | S219900 | 0 | S200800 | S200800 | NOCA | Completed | Mannel, Eric | L3 | Design | Eric Mannel | BNL | CalEl EMCal FEE tests | null | POM02.1.05.02.01 | C | 01 | yes | 003 |  |  |  | B | 16712 |  |  |  |  |  |  |  |  |  |
| S220000 |  | Layout per Change Specification - EMCal SiPM Daughter Board: Sectors 1-12 |  | 11d | 2019-04-10 A | 2019-04-24 A | S189700, S189900, S219900 | 100% |  |  |  |  | S220000 | 0 | S202100 | S202100 | NOCA | Completed | Mannel, Eric | L3 | Fab & Assy | Eric Mannel | BNL | CalEl EMCal FEE tests | null | POM02.1.05.02.01 | C | 01 | yes |  |  |  |  | B | 16712 |  |  |  |  |  |  |  |  |  |
| S223200 |  | Fabricate Calorimeter Controller Boards: Sectors 1-12 Labor |  | 17d | 2019-05-08 A | 2019-05-31 A | S221100 | 100% |  |  |  |  | S223200 | 0 | S203000 | S201650 | NOCA | Completed | Mannel, Eric | L2 | Procurement | Eric Mannel | BNL | CalEl EMCal FEE tests | null | POM02.1.05.02.01 | C | 01 | yes |  |  |  |  | B | 16712 |  |  |  |  |  |  |  |  |  |
| S221400 |  | Fabricate EMCal SiPM Boards: Sectors 1-12 - Labor |  | 10d | 2019-05-15 A | 2019-05-29 A | S221100, S213210, S213300, S213215, S213305 | 100% |  |  |  |  | S221400 | 0 | S201400 | S201410 | NOCA | Completed | Mannel, Eric | M3 | Fab & Assy | Eric Mannel | BNL | CalEl EMCal FEE tests | null | POM02.1.05.02.01 | C | 01 | yes |  |  |  | OPC001900 | B | 16712 |  |  |  |  |  |  |  |  |  |
| S219210 |  | Procure EMCal Internal Signal/Test/Comm/LV/Bias Cables: Preproduction [Sector 0] Labor Split |  | 42d | 2019-06-03 A | 2019-07-31 A | S219200 | 100% |  |  | PROF3 PO E [7 h]; TECH3 PO D [7 h]; TECH3 PO E [10 h] | 2,743.34 | S219200 | 40 | S200200 | S200200 | CA | Completed | Mannel, Eric | L2 | Procurement | Eric Mannel | BNL | CalEl EMCal FEE tests | null | POM02.1.05.02.01 | C | 01 |  |  | 2019-04-01 |  |  | B | 16712 | S219210 | 1.05 | 1.05B |  |  |  |  |  |  |
| S219402 |  | Procure EMCal External Signal and Power Cables, and Power Systems: Preproduction [Sector 0] Labor Split |  | 42d | 2019-06-03 A | 2019-07-31 A | S219400 | 100% |  |  | TECH3 PO D [10 h]; TECH3 PO E [14 h]; PROF3 PO E [10 h] | 3,887.4 | S219400 | 15 | S200200 | S277590364 | CA | Completed | Mannel, Eric | L2 | Procurement | Eric Mannel | BNL | CalEl EMCal FEE tests | null | POM02.1.05.02.01 | C | 01 |  |  | 2019-04-01 |  |  | B | 16712 | S219402 | 1.05 | 1.05B |  |  |  |  |  |  |
| S220100 |  | Update Design per Change Specification - EMCal Preamp: Sectors 1-12 |  | 22d | 2019-07-01 A | 2019-07-31 A |  | 100% |  |  | PROF3 PO E [70 h] | 8,597.74 | S220100 | 0 | S200900 | S200900 | CA | Completed | Mannel, Eric | L3 | Design | Eric Mannel | BNL | CalEl EMCal FEE tests | null | POM02.1.05.02.01 | C | 01 |  |  |  |  |  | B | 16712 | S220100 | 1.05 | 1.05B |  |  |  |  |  |  |
| S220200 |  | Layout per Change Specification - EMCal Preamp: Sectors 1-12 |  | 22d | 2019-07-01 A | 2019-07-31 A | S189700, S189900, S220100 | 100% |  |  | PROF3 PO E [46 h]; TECH3 PO E [32 h] | 9,195.48 | S220200 | 0 | S202200 | S202200 | CA | Completed | Mannel, Eric | L3 | Fab & Assy | Eric Mannel | BNL | CalEl EMCal FEE tests | null | POM02.1.05.02.01 | C | 01 |  |  |  |  |  | B | 16712 | S220200 | 1.05 | 1.05B |  |  |  |  |  |  |
| S220300 |  | Update Design per Change Specification - EMCal Interface Board: Sectors 1-12 |  | 22d | 2019-07-01 A | 2019-07-31 A | S219800 | 100% |  |  | PROF3 PO E [70 h] | 8,597.74 | S220300 | 0 | S201200 | S201200 | CA | Completed | Mannel, Eric | L3 | Design | Eric Mannel | BNL | CalEl EMCal FEE tests | null | POM02.1.05.02.01 | C | 01 |  |  |  |  |  | B | 16712 | S220300 | 1.05 | 1.05B |  |  |  |  |  |  |
| S220400 |  | Layout per Change Specification - EMCal Interface: Sectors 1-12 |  | 22d | 2019-07-01 A | 2019-07-31 A | S189700, S189900, S220300 | 100% |  |  | PROF3 PO E [54 h]; TECH3 PO E [60 h] | 13,280.43 | S220400 | 0 | S202300 | S202300 | CA | Completed | Mannel, Eric | L3 | Fab & Assy | Eric Mannel | BNL | CalEl EMCal FEE tests | null | POM02.1.05.02.01 | C | 01 |  |  |  |  |  | B | 16712 | S220400 | 1.05 | 1.05B |  |  |  |  |  |  |
| S220500 |  | Update Design per Change Specification - Calorimeter Controller: Sectors 1-12 |  | 22d | 2019-07-01 A | 2019-07-31 A | S219800 | 100% |  |  | PROF3 PO E [70 h] | 8,597.74 | S220500 | 0 | S201300 | S201300 | CA | Completed | Mannel, Eric | L3 | Design | Eric Mannel | BNL | CalEl EMCal FEE tests | null | POM02.1.05.02.01 | C | 01 |  |  |  |  |  | B | 16712 | S220500 | 1.05 | 1.05B |  |  |  |  |  |  |
| S220600 |  | Layout per Change Specification - Calorimeter Controller: Sectors 1-12 |  | 22d | 2019-07-01 A | 2019-07-31 A | S220500 | 100% |  |  | PROF3 PO E [24 h]; TECH3 PO E [40 h] | 7,379.72 | S220600 | 0 | S202400 | S202400 | CA | Completed | Mannel, Eric | L3 | Fab & Assy | Eric Mannel | BNL | CalEl EMCal FEE tests | null | POM02.1.05.02.01 | C | 01 |  |  |  |  |  | B | 16712 | S220600 | 1.05 | 1.05B |  |  |  |  |  |  |
| S223202 |  | Fabricate Calorimeter Controller Boards: Sectors 1-12 Labor Split |  | 32d | 2019-07-01 A | 2019-08-15 A | S223200 | 100% | 2019-07-01 | 2019-08-14 | TECH3 PO E [50 h]; PROF3 PO E [110 h] | 19,050.64 | S223200 | 0 | S203000 | S201650 | CA | Completed | Mannel, Eric | L2 | Procurement | Eric Mannel | BNL | CalEl EMCal FEE tests | null | POM02.1.05.02.01 | C | 01 |  |  |  |  |  | B | 16712 | S223202 | 1.05 | 1.05B |  |  |  |  |  |  |
| S223300 |  | Fabricate Calorimeter Controller Boards: Sectors 1-12 M&S |  | 33d | 2019-07-01 A | 2019-08-15 A | S221100 | 100% |  |  | Material (Purchase (1st $2M) [20221 h] | 22,309.12 | S223300 | 0 | S201600 | S201600 | CA | Completed | Mannel, Eric | M3 | Fab & Assy | Eric Mannel | BNL | CalEl EMCal FEE tests | OPC | POM02.1.05.02.01 | C | 01 |  | 003 |  |  | OPC001900 | A-OPC | 16704 | S223300 | 1.05 | 1.05A | UDF_G3 | TBD |  |  |  |  |
| S219600 |  | Sector 0 Production Complete | milestone | 0d | 2019-08-07 A | 2019-08-07 A | S218200 FF, S219100 FF, S218800 FF, S217900 FF | 100% | 2019-08-01 | 2019-08-01 |  |  | S219600 | 0 | S200100 | S200150 | NOCA | Completed | Mannel, Eric |  | Fab & Assy | Eric Mannel | BNL | CalEl EMCal FEE tests |  | POM02.1.05.02.01 |  | 01 |  |  |  | L4 | OPC001800 |  |  |  |  |  |  |  |  |  |  |  |
| S220700 |  | Specify Signal and Power Cables per Change Specification - for EMCal: Sectors 1-12 |  | 15d | 2019-08-12 A | 2019-08-30 A |  | 100% |  |  | PROF3 PO E [60 h]; SCI3 PO [60 h] | 17,395.06 | S220700 | 0 | S201000 | S201000 | CA | Completed | Mannel, Eric | L3 | Procurement | Eric Mannel | BNL | CalEl EMCal FEE tests | null | POM02.1.05.02.01 | C | 01 |  |  |  |  |  | B | 16712 | S220700 | 1.05 | 1.05B |  |  |  |  |  |  |
| S220800 |  | Specify Power System per Change Specification - for EMCal: Sectors 1-12 |  | 15d | 2019-08-12 A | 2019-08-30 A |  | 100% |  |  | SCI3 PO [60 h]; PROF3 PO E [60 h] | 17,395.06 | S220800 | 0 | S201100 | S201100 | CA | Completed | Mannel, Eric | L3 | Procurement | Eric Mannel | BNL | CalEl EMCal FEE tests | null | POM02.1.05.02.01 | C | 01 |  |  |  |  |  | B | 16712 | S220800 | 1.05 | 1.05B |  |  |  |  |  |  |
| S219700 |  | Review and Write EMCal Electronics Design Change Specifications: Sector 1-12 Labor |  | 12d | 2019-08-15 A | 2019-08-31 A | S218200, S219100, S219300, S218300, S219600, S218800, S217900, S219500, S219210 SS+24d, S219402 SS+24d | 100% | 2019-08-15 | 2019-08-30 | PROF3 PO E [20 h]; SCI3 PO [20 h] | 5,798.35 | S219700 | 0 | S200700 | S200700 | CA | Completed | Mannel, Eric | L3 | Design | Eric Mannel | BNL | CalEl EMCal FEE tests | null | POM02.1.05.02.01 | C | 01 |  |  |  |  |  | B | 16712 | S219700 | 1.05 | 1.05B |  |  |  |  |  |  |
| S220900 |  | Safety and Final Design Review to ensure Change Specifications have been met: EMCal Sectors 1-12 |  | 10d | 2019-09-11 A | 2019-09-24 A | S220000, S220200, S220400, S220600, S220700, S220800, S219800 | 100% |  |  | PROF3 PO E [20 h]; SCI3 PO [20 h]; TECH3 PO E [8 h] | 6,684.74 | S220900 | 0 | S202500 | S202500 | CA | Completed | Mannel, Eric | L2 | Design | Eric Mannel | BNL | CalEl EMCal FEE tests | null | POM02.1.05.02.01 | C | 01 |  | 004 |  |  |  | B | 16712 | S220900 | 1.05 | 1.05B |  |  |  |  |  |  |
| S221100 |  | Review Safety and Design Review Report and Procurement Readiness Review Sectors 1-12 |  | 10d | 2019-09-11 A | 2019-09-24 A | S220900, S221000 | 100% |  |  | PROF3 PO E [20 h]; SCI3 PO [20 h] | 5,798.35 | S221100 | 0 | S202700 | S202700 | CA | Completed | Mannel, Eric | L2 | Design | Eric Mannel | BNL |  | null | POM02.1.05.02.01 | C | 01 |  | 004 |  |  |  | B | 16712 | S221100 | 1.05 | 1.05B |  |  |  |  |  |  |
| S221000 |  | Safety and Design Review to ensure Change Specifications have been met -complete: EMCal Electronics: Sectors 1-12 | milestone | 0d | 2019-09-24 A | 2019-09-24 A | S220900 | 100% | 2019-09-16 | 2019-09-16 |  |  | S221000 | 0 | S202600 | S202600 | NOCA | Completed | Mannel, Eric |  | Design | Eric Mannel | BNL | CalEl EMCal FEE tests |  | POM02.1.05.02.01 |  | 01 |  |  |  | L5 |  |  |  |  |  |  |  |  |  |  |  |  |
| S221200 |  | Complete: Production Readiness Review, Safety Review - EMCal FEE sectors 1-12 | milestone | 0d | 2019-09-24 A | 2019-09-24 A | S221000 | 100% | 2019-09-16 | 2019-09-16 |  |  | S221200 | 0 | S197600 | S197600 | NOCA | Completed | Mannel, Eric |  | Fab & Assy | Eric Mannel | BNL | CalEl EMCal FEE tests |  | POM02.1.05.02.01 |  | 01 |  | 004 |  | L5 |  |  |  |  |  |  |  |  |  |  |  |  |
| S219800 |  | EMCal Electronics Review Complete: Preproduction Prototype [Sector 0] | milestone | 0d | 2019-09-25 A | 2019-09-25 A | S219700 FF | 100% | 2019-09-03 | 2019-09-03 |  |  | S219800 | 0 | S197800 | S197800 | NOCA | Completed | Mannel, Eric |  | Fab & Assy | Eric Mannel | BNL | CalEl EMCal FEE tests |  | POM02.1.05.02.01 |  | 01 |  |  |  | L5 |  |  |  |  |  |  |  |  |  |  |  |  |
| S221600 |  | Fabricate EMCal Preamp Boards: Sectors 1-12 - Provide Requirements to Fabricator |  | 5d | 2019-10-01 A | 2019-10-22 A | S221100 | 100% | 2019-10-01 | 2019-10-07 | TECH3 PO E [60 h]; PROF3 PO M [84 h] | 17,474.13 | S221600 | 0 | S202800 | S339920 | CA | Completed | Mannel, Eric |  | Procurement | Eric Mannel | BNL | CalEl EMCal FEE tests |  | POM02.1.05.02.01 | C | 01 |  | 003 |  |  |  | B | 16712 | S221600 | 1.05 | 1.05B |  | MP201050 | PP1 |  |  |  |
| S222400 |  | Fabricate EMCal Interface Board: Sectors 1-12 - Provide Requirements to Fabricator |  | 5d | 2019-10-01 A | 2019-10-07 A | S221100 | 100% |  |  | PROF3 PO E [86 h]; TECH3 PO E [64 h] | 18,183.64 | S222400 | 0 | S202900 | S201550 | CA | Completed | Mannel, Eric | L2 | Procurement | Eric Mannel | BNL | CalEl EMCal FEE tests | null | POM02.1.05.02.01 | C | 01 |  |  |  |  |  | B | 16712 | S222400 | 1.05 | 1.05B |  | MP201900 | PP1 |  |  |  |
| S223400 |  | Test calorimeter controller boards: Sectors 1-12 |  | 30d | 2019-10-01 A | 2019-11-25 A | S223300, S223202 | 100% | 2019-10-01 | 2019-11-13 | PROF3 PO E [60 h]; TECH3 PO E [24 h]; POSTDOC ISU - Unpaid [20 h]; STUDENT Other - Unpaid [60 h]; SCI3 PO [45 h] | 18,074.26 | S223400 | 0 | S203400 | S203400 | CA | Completed | Mannel, Eric | L4 | Fab & Assy | Eric Mannel | BNL | CalEl EMCal FEE tests | null | POM02.1.05.02.01 | C | 01 |  | 003 |  |  |  | B_T | 16712 | S223400 | 1.05 | 1.05B |  |  |  |  |  |  |
| S223600 |  | Procure EMCal Internal Signal/Test/Comm/LV/Bias Cables: Sectors 1-12 - Labor |  | 10d | 2019-10-01 A | 2019-11-25 A | S221100 | 100% | 2019-10-01 | 2019-10-15 | PROF3 PO E [23 h]; TECH3 PO E [32 h]; TECH3 PO D [23 h] | 9,186.44 | S223600 | 0 | S203100 | S277590444 | CA | Completed | Mannel, Eric | L2 | Procurement | Eric Mannel | BNL | CalEl EMCal FEE tests | null | POM02.1.05.02.01 | C | 01 |  |  |  |  |  | B | 16712 | S223600 | 1.05 | 1.05B |  |  |  |  |  |  |
| S223610 |  | Procure EMCal Internal Signal/Test/Comm/LV/Bias Cables: Sectors 1-12 - Contract Award | milestone | 0d | 2019-10-01 A | 2019-10-01 A | S221100, S101000 | 100% |  |  |  |  | S223600 | 0 | S203100 | S277590444 | NOCA | Completed | Mannel, Eric | L2 | Procurement | Eric Mannel | BNL | CalEl EMCal FEE tests | null | POM02.1.05.02.01 | C | 01 |  | 003 |  | L5 |  | A-TEC | 16712 |  |  |  |  |  |  |  |  |  |
| S223700 |  | Procure EMCal Internal Signal/Test/Comm/LV/Bias Cables: Sectors 1-12, Phase 1 - M&S |  | 5d | 2019-10-01 A | 2020-04-30 A | S221100 | 100% | 2019-10-01 | 2019-10-07 | Material (Purchase (1st $2M) [42072 h] | 47,874.81 | S223700 | 0 | S201700 | S277590484 | CA | In Progress | Mannel, Eric | M3 | Fab & Assy | Eric Mannel | BNL | CalEl EMCal FEE tests | OPC | POM02.1.05.02.01 | C | 01 |  | 003,004 |  |  | OPC001900 | A-OPC | 16704 | S223700 | 1.05 | 1.05A | UDF_G1 | TBD |  | UDF_G3 |  |  |
| S223701 |  | Procure EMCal Internal Signal/Test/Comm/LV/Bias Cables: Sectors 1-12, Phase 2 - M&S |  | 5d | 2019-10-01 A | 2020-04-30 A | S221100, S223610 SS | 100% | 2019-10-01 | 2019-10-07 | Material (Purchase (1st $2M) [42072 h] | 47,874.81 | S223700 | 0 | S201700 | S277590484 | CA | In Progress | Mannel, Eric | M3 | Fab & Assy | Eric Mannel | BNL | CalEl EMCal FEE tests | OPC | POM02.1.05.02.01 | C | 01 |  | 003,004 |  |  | OPC001900 | A-TEC | 59715 | S223701 | 1.05 | 1.05A | UDF_G1 | TBD |  | UDF_G3 |  |  |
| S224200 |  | Procure EMCal Low Voltage Power Systems: Sectors 1-12 - Labor |  | 10d | 2019-10-01 A | 2021-05-28 A | S221100 | 100% | 2019-10-01 | 2019-10-15 | PROF3 PO E [23 h]; TECH3 PO E [32 h]; TECH3 PO D [23 h] | 9,186.44 | S224200 | 0 | S203100 | S277590924 | CA | In Progress | Mannel, Eric | L2 | Procurement | Eric Mannel | BNL | CalEl EMCal FEE tests | null | POM02.1.05.02.01 | C | 01 |  |  |  |  |  | B | 16712 | S224200 | 1.05 | 1.05B |  |  |  |  |  |  |
| S224300 |  | Procure EMCal Low Voltage Power Systems: Sectors 1-12, Phase 1 - M&S |  | 5d | 2019-10-01 A | 2021-05-28 A | S221100 | 100% | 2019-10-01 | 2019-10-07 | Material (Purchase (1st $2M) [3080 h] | 3,504.81 | S224300 | 0 | S201700 | S277590964 | CA | In Progress | Mannel, Eric | M3 | Fab & Assy | Eric Mannel | BNL | CalEl EMCal FEE tests | OPC | POM02.1.05.02.01 | C | 01 |  | 003,004 |  |  | OPC001900 | A-OPC | 16704 | S224300 | 1.05 | 1.05A | UDF_G1 | TBD |  | UDF_G3 | 3154.3302897 | 0.9 |
| S224400 |  | Procure EMCal Low Voltage Power Systems: Sectors 1-12, Phase 2 - M&S |  | 5d | 2019-10-01 A | 2021-05-28 A | S221100, S101000 | 100% | 2019-10-01 | 2019-10-07 | Material (Purchase (1st $2M) [12320 h] | 14,019.25 | S224400 | 0 | S201700 | S277594484 | CA | In Progress | Mannel, Eric | M3 | Fab & Assy | Eric Mannel | BNL | CalEl EMCal FEE tests | OPC | POM02.1.05.02.01 | C | 01 |  | 003,004 |  |  | OPC001900 | A-TEC | 59715 | S224400 | 1.05 | 1.05A | UDF_G1 | TBD |  | UDF_G3 | 12617.3211597 | 0.9 |
| S221900 |  | Fabricate EMCal Preamp Boards: Sectors 1-12 - Vendor Selection |  | 10d | 2019-10-02 A | 2019-10-22 A | S221800 | 100% | 2019-12-02 | 2019-12-13 |  |  | S221900 | 0 | S201400 | S341080 | NOCA | Completed | Mannel, Eric |  | Procurement | Eric Mannel | BNL | CalEl EMCal FEE tests |  | POM02.1.05.02.01 |  | 01 |  |  |  |  | OPC001900 |  |  |  |  |  |  | MP201050 | PP4 |  |  |  |
| S221700 |  | Fabricate EMCal Preamp Boards: Sectors 1-12 - Prepare & Send Solicitation |  | 20d | 2019-10-08 A | 2019-10-22 A | S221600 | 100% | 2019-10-08 | 2019-11-05 |  |  | S221700 | 0 | S201400 | S339880 | NOCA | Completed | Mannel, Eric |  | Procurement | Eric Mannel | BNL | CalEl EMCal FEE tests |  | POM02.1.05.02.01 |  | 01 |  |  |  |  | OPC001900 |  |  |  |  |  |  | MP201050 | PP2 |  |  |  |
| S222500 |  | Fabricate EMCal Interface Board: Sectors 1-12 - Prepare & Send Solicitation |  | 20d | 2019-10-08 A | 2019-10-10 A | S222400 | 100% | 2019-10-08 | 2019-11-05 |  |  | S222500 | 0 | S202900 | S341480 | NOCA | Completed | Mannel, Eric |  | Procurement | Eric Mannel | BNL | CalEl EMCal FEE tests |  | POM02.1.05.02.01 |  | 01 |  |  |  |  |  |  |  |  |  |  |  | MP201900 | PP2 |  |  |  |
| S221800 |  | Fabricate EMCal Preamp Boards: Sectors 1-12 - Vendor Responses |  | 15d | 2019-10-09 A | 2019-10-22 A | S221700 | 100% | 2019-11-06 | 2019-11-27 |  |  | S221800 | 0 | S201400 | S341040 | NOCA | Completed | Mannel, Eric |  | Procurement | Eric Mannel | BNL | CalEl EMCal FEE tests |  | POM02.1.05.02.01 |  | 01 |  |  |  |  | OPC001900 |  |  |  |  |  |  | MP201050 | PP3 |  |  |  |

Notes:
- S216600: BNL_UDF_Old Activity Name 181221: Review and write design specification: EMCal Preproduction Prototype [Sector 0]
- S216601: BNL_UDF_Status Comments: 190508 ELM add per GRY / BNL_UDF_Old Activity Name 181221: Review and write design specification: EMCal Preproduction Prototype [Sector 0]
- S216700: BNL_UDF_Old Activity Name 181221: Design EMCal SiPM Daughter Board: Preproduction [Sector 0]
- S216800: BNL_UDF_Old Activity Name 181221: Layout EMCal SiPM Daughter Board: Preproduction [Sector 0]
- S216900: BNL_UDF_Old Activity Name 181221: Design EMCal Preamp: Preproduction [Sector 0]
- S217000: BNL_UDF_Old Activity Name 181221: Layout EMCal Preamp: Preproduction [Sector 0]
- S217100: BNL_UDF_Old Activity Name 181221: Design EMCal Interface Board: Preproduction [Sector 0]
- S217200: BNL_UDF_Old Activity Name 181221: Layout EMCal Interface: Preproduction [Sector 0]
- S217300: BNL_UDF_Old Activity Name 181221: Design Calorimeter Controller: Preproduction [Sector 0]
- S217400: BNL_UDF_Old Activity Name 181221: Layout Calorimeter Controller: Preproduction [Sector 0]
- S217500: BNL_UDF_Old Activity Name 181221: Specify Signal and Power Cables for EMCal: Preproduction [Sector 0]
- S217600: BNL_UDF_Old Activity Name 181221: Specify Power System for EMCal: Preproduction [Sector 0]
- S217700: BNL_UDF_Status Comments: 190508 ELM name per GRY; 190415 ELM name per GRY / BNL_UDF_Adhoc Comments: 180329 ELM desc per EJM / BNL_UDF_Old Activity Name 181221: Safety and Design Review: EMCal Preproduction Electronics [Sector 0]
- S217800: BNL_UDF_Status Comments: 190508 ELM name per GRY / BNL_UDF_Adhoc Comments: 180329 ELM desc per EJM / BNL_UDF_Old Activity Name 181221: Safety and Design Review Complete: EMCal Preproduction Electronics [Sector 0]
- S217900: BNL_UDF_Adhoc Comments: 180329 ELM desc per EJM / BNL_UDF_Old Activity Name 181221: Review Safety and Design Review Report: EMCal Preproduction Electronics [Sector 0]
- S218000: BNL_UDF_Adhoc Comments: 180329 ELM desc per EJM / BNL_UDF_Old Activity Name 181221: Procure Components for EMCal SiPM Boards: Preproduction [Sector 0] Labor
- S218100: BNL_UDF_Old Activity Name 181221: Procure Components for EMCal SiPM Boards: Preproduction [Sector 0] M&S
- S218400: BNL_UDF_Adhoc Comments: 180410 ELM pred/succ per GRY; 180329 ELM add activity per EJM / BNL_UDF_Old Activity Name 181221: Fabricate EMCal Preamp Boards: Preproduction [Sector 0] Labor FY18
- S218600: BNL_UDF_Adhoc Comments: 180410 ELM pred/succ per GRY / BNL_UDF_Old Activity Name 181221: Fabricate EMCal Preamp Boards: Preproduction [Sector 0] M&S FY18
- S219200: BNL_UDF_Status Comments: 190604 IVS need splitting ?? / BNL_UDF_Old Activity Name 181221: Procure EMCal Internal Signal/Test/Comm/LV/Bias Cables: Preproduction [Sector 0] Labor
- S219300: BNL_UDF_Status Comments: 190604 IVS back to 0%; 190322 ELM BNL Units; 190317 BNLU per L2; 190315 ELM chg % to align with EVT 15>0, remove AS, use EF / BNL_UDF_Old Activity Name 181221: Procure EMCal Internal Signal/Test/Comm/LV/Bias Cables: Preproduction [Sector 0] M&S
- S219400: BNL_UDF_Status Comments: 190605 IVS ask Eric Meritech cables; 190604 IVS need splitting?? / BNL_UDF_Old Activity Name 181221: Procure EMCal External Signal and Power Cables, and Power Systems: Preproduction [Sector 0] Labor
- S219500: BNL_UDF_Status Comments: 190604 IVS back to 0%; 190322 ELM BNL Units; 190317 ELM BLNU per L2; 190315 ELM chg % to align with EVT 15>0, remove AS, use EF / BNL_UDF_Old Activity Name 181221: Procure EMCal External Signal and Power Cables, and Power Systems: Preproduction [Sector 0] M&S
- S218200: BNL_UDF_Status Comments: 190317 ELM name per GRY / BNL_UDF_Old Activity Name 181221: Assemble and Test EMCal SiPM Daughter Boards: Preproduction [Sector 0] Labor
- S218300: BNL_UDF_Status Comments: 190317 ELM name per GRY; BNLU per L2 / BNL_UDF_Old Activity Name 181221: Assemble and Test EMCal SiPM Daughter Boards: Preproduction [Sector 0] M&S
- S218500: BNL_UDF_Adhoc Comments: 180410 ELM pred/succ per GRY; 180329 ELM add activity per EJM / BNL_UDF_Old Activity Name 181221: Fabricate EMCal Preamp Boards: Preproduction [Sector 0] Labor FY19
- S218700: BNL_UDF_Status Comments: 190317 BNLU per L2 / BNL_UDF_Adhoc Comments: 180410 ELM pred/succ per GRY / BNL_UDF_Old Activity Name 181221: Fabricate EMCal Preamp Boards: Preproduction [Sector 0] M&S FY19
- S218900: BNL_UDF_Old Activity Name 181221: Fabricate EMCal Interface Board: Preproduction [Sector 0] Labor
- S219000: BNL_UDF_Status Comments: 190322 ELM BNL Units; 190317 BNLU per L2 / BNL_UDF_Old Activity Name 181221: Fabricate EMCal Interface Board: Preproduction [Sector 0] M&S
- S218800: BNL_UDF_Status Comments: 190604 IVS; 190314 ELM re-load zeroed RA units / BNL_UDF_Old Activity Name 181221: Test EMCal Preamp Boards: Preproduction [Sector 0]
- S219100: BNL_UDF_Status Comments: 190604 IVS; 190314 ELM re-load zeroed RA units / BNL_UDF_Old Activity Name 181221: Test EMCal Interface Boards: Preproduction [Sector 0]
- S219900: BNL_UDF_Status Comments: 190605 IVS status; 190317 ELM name per GRY / BNL_UDF_Adhoc Comments: 180423 ELM rsrc per GRY / BNL_UDF_Old Activity Name 181221: Redesign per Change Specification - EMCal SiPM Daughter Board: Sectors 1-12
- S220000: BNL_UDF_Status Comments: 190605 IVS status / BNL_UDF_Adhoc Comments: 180423 ELM rsrc per GRY / BNL_UDF_Old Activity Name 181221: Layout per Change Specification - EMCal SiPM Daughter Board: Sectors 1-12
- S223200: BNL_UDF_Status Comments: 190605 IVS restructure; / BNL_UDF_Adhoc Comments: 180406 ELM pred/succ per GRY / BNL_UDF_Old Activity Name 181221: Fabricate Calorimeter Controller Boards: Sectors 1-12 Labor
- S221400: BNL_UDF_Adhoc Comments: 180406 ELM dur per GRY; 180405 ELM pred per GRY; 180329 ELM units per EJM, name, dur per GRY / BNL_UDF_Old Activity Name 181221: Fabricate EMCal SiPM Boards: Sectors 1-12 - Labor
- S219210: BNL_UDF_Status Comments: 190604 IVS need splitting ?? / BNL_UDF_Old Activity Name 181221: Procure EMCal Internal Signal/Test/Comm/LV/Bias Cables: Preproduction [Sector 0] Labor
- S219402: BNL_UDF_Status Comments: 190605 IVS ask Eric Meritech cables; 190604 IVS need splitting?? / BNL_UDF_Old Activity Name 181221: Procure EMCal External Signal and Power Cables, and Power Systems: Preproduction [Sector 0] Labor
- S220100: BNL_UDF_Status Comments: 190613 IVS dur to 15 from 20 / BNL_UDF_Adhoc Comments: 180423 ELM rsrc per GRY / BNL_UDF_Old Activity Name 181221: Update Design per Change Specification - EMCal Preamp: Sectors 1-12
- S220200: BNL_UDF_Status Comments: 190613 IVS dur to 15 from 20 / BNL_UDF_Adhoc Comments: 180423 ELM rsrc per GRY / BNL_UDF_Old Activity Name 181221: Layout per Change Specification - EMCal Preamp: Sectors 1-12
- S220300: BNL_UDF_Status Comments: 190613 IVS dur to 15 from 20 / BNL_UDF_Adhoc Comments: 180423 ELM rsrc per GRY / BNL_UDF_Old Activity Name 181221: Update Design per Change Specification - EMCal Interface Board: Sectors 1-12
- S220400: BNL_UDF_Status Comments: 190613 IVS dur to 15 from 30 / BNL_UDF_Adhoc Comments: 180423 ELM rsrc per GRY / BNL_UDF_Old Activity Name 181221: Layout per Change Specification - EMCal Interface: Sectors 1-12
- S220500: BNL_UDF_Status Comments: 190613 IVS dur to 15 from 20 / BNL_UDF_Adhoc Comments: 180423 ELM rsrc per GRY / BNL_UDF_Old Activity Name 181221: Update Design per Change Specification - Calorimeter Controller: Sectors 1-12
- S220600: BNL_UDF_Status Comments: 190613 IVS dur to 15 from 20 / BNL_UDF_Adhoc Comments: 180423 ELM rsrc per GRY / BNL_UDF_Old Activity Name 181221: Layout per Change Specification - Calorimeter Controller: Sectors 1-12
- S223202: BNL_UDF_Status Comments: 190605 IVS restructure; / BNL_UDF_Adhoc Comments: 180406 ELM pred/succ per GRY / BNL_UDF_Old Activity Name 181221: Fabricate Calorimeter Controller Boards: Sectors 1-12 Labor
- S223300: BNL_UDF_Status Comments: 190605 IVS change F to C; 190317 BNLU per L2 / BNL_UDF_Adhoc Comments: 180406 ELM pred/succ per GRY / BNL_UDF_Old Activity Name 181221: Fabricate Calorimeter Controller Boards: Sectors 1-12 M&S
- S219600: BNL_UDF_Adhoc Comments: 180329 ELM add activity per EJM / BNL_UDF_Old Activity Name 181221: Sector 0 Production Complete
- S220700: BNL_UDF_Status Comments: 190613 IVS dur to 15 from 20 / BNL_UDF_Old Activity Name 181221: Specify Signal and Power Cables per Change Specification - for EMCal: Sectors 1-12
- S220800: BNL_UDF_Status Comments: 190613 IVS dur to 15 from 20 / BNL_UDF_Old Activity Name 181221: Specify Power System per Change Specification - for EMCal: Sectors 1-12
- S219700: BNL_UDF_Adhoc Comments: 180329 ELM desc / BNL_UDF_Old Activity Name 181221: Review and Write EMCal Electronics Design Change Specifications: Sector 1-12 Labor
- S220900: General Comments: 180420 GYoung: concerning Safety / and Design Review - Safety here refers to BNL check that new designs are / safe to operate before fabricating / them / BNL_UDF_Status Comments: 190415 ELM name per GRY / BNL_UDF_Old Activity Name 181221: Safety and Design Review to ensure Change Specifications have been met: EMCal Sector 1-12
- S221100: General Comments: 180420 GYoung: concerning Review / of Safety and Design Review - Check-up that review recommendations were / addressed / BNL_UDF_Status Comments: 190523 ELM name; 190415 ELM name per GRY / BNL_UDF_Old Activity Name 181221: Review Safety and Design Review Report to ensure Change Specifications have been met -[12 sector]
- S221000: BNL_UDF_Adhoc Comments: 180405 ELM succ per GRY / BNL_UDF_Old Activity Name 181221: Safety and Design Review to ensure Change Specifications have been met -complete: EMCal Electronics: Sectors 1-12
- S221200: BNL_UDF_Status Comments: 190523 ELM name / BNL_UDF_Adhoc Comments: 180329 ELM pred per EJM / BNL_UDF_Old Activity Name 181221: EMCal Electronics Review Complete: Sectors 1-12
- S219800: BNL_UDF_Old Activity Name 181221: EMCal Electronics Review Complete: Preproduction Prototype [Sector 0]
- S221600: BNL_UDF_Status Comments: 190319 ELM rsrc per GRY / BNL_UDF_Adhoc Comments: 180406 ELM pred/succ per GRY; 180329 ELM add activity per EJM, GRY / BNL_UDF_Old Activity Name 181221: Fabricate EMCal Preamp Boards: Sectors 1-12 - Provide Requirements to Fabricator
- S222400: BNL_UDF_Old Activity Name 181221: Fabricate EMCal Interface Board: Sectors 1-12 - Provide Requirements to Fabricator
- S223400: BNL_UDF_Status Comments: 190314 ELM re-load zeroed RA units / BNL_UDF_Adhoc Comments: 180423 ELM rsrc per GRY / BNL_UDF_Old Activity Name 181221: Test calorimeter controller boards: Sectors 1-12
- S223600: BNL_UDF_Old Activity Name 181221: Procure EMCal Internal Signal/Test/Comm/LV/Bias Cables: Sectors 1-12 - Labor
- S223610: BNL_UDF_Status Comments: 190319 ELM split OPC,TEC per GRY / BNL_UDF_Old Activity Name 181221: Procure EMCal Internal Signal/Test/Comm/LV/Bias Cables: Sectors 1-12 - Labor
- S223700: BNL_UDF_Status Comments: 190417 ELM name; 190322 ELM BNL Units; 190319 ELM split OPC,TEC per GRY; 190317 BNLU per L2 / BNL_UDF_Adhoc Comments: 180406 ELM pred/succ per GRY; 180402 ELM added activity (Proc String), need duration adjusted and logic to rest of proc string / BNL_UDF_Old Activity Name 181221: Procure EMCal Internal Signal/Test/Comm/LV/Bias Cables: Sectors 1-12 - M&S
- S223701: BNL_UDF_Status Comments: 190417 ELM name; 190322 ELM BNL Units; 190319 ELM split OPC,TEC per GRY / BNL_UDF_Adhoc Comments: 180406 ELM pred/succ per GRY; 180402 ELM added activity (Proc String), need duration adjusted and logic to rest of proc string / BNL_UDF_Old Activity Name 181221: Procure EMCal Internal Signal/Test/Comm/LV/Bias Cables: Sectors 1-12 - M&S
- S224200: BNL_UDF_Old Activity Name 181221: Procure EMCal Low Voltage Power Systems:Sectors 1-12 - Labor
- S224300: BNL_UDF_Status Comments: 190417 ELM name; 190317 BNLU per L2 / BNL_UDF_Adhoc Comments: 180406 ELM pred/succ per GRY; 180402 ELM added activity (Proc String), need duration adjusted and logic to rest of proc string / BNL_UDF_Old Activity Name 181221: Procure EMCal Low Voltage Power Systems:Sectors 1-12 - M&S - OPC Funds
- S224400: BNL_UDF_Status Comments: 190417 ELM name; 190317 BNLU per L2; logic per GRY / BNL_UDF_Adhoc Comments: 180406 ELM pred/succ per GRY; 180402 ELM added activity (Proc String), need duration adjusted and logic to rest of proc string / BNL_UDF_Old Activity Name 181221: Procure EMCal Low Voltage Power Systems:Sectors 1-12 - M&S - TEC Funds
- S221900: BNL_UDF_Adhoc Comments: 180406 ELM pred/succ per GRY; 180329 ELM add activity per EJM, GRY / BNL_UDF_Old Activity Name 181221: Fabricate EMCal Preamp Boards: Sectors 1-12 - Vendor Selection
- S221700: BNL_UDF_Adhoc Comments: 180406 ELM pred/succ per GRY; 180329 ELM add activity per EJM, GRY / BNL_UDF_Old Activity Name 181221: Fabricate EMCal Preamp Boards: Sectors 1-12 - Prepare & Send Solicitation
- S222500: BNL_UDF_Adhoc Comments: 180406 ELM pred/succ per GRY; 180402 ELM add activity for proc strg / BNL_UDF_Old Activity Name 181221: Fabricate EMCal Interface Board: Sectors 1-12 - Prepare & Send Solicitation
- S221800: BNL_UDF_Adhoc Comments: 180412 dur per GRY; 180406 ELM pred/succ per GRY; 180329 ELM add activity per EJM, GRY / BNL_UDF_Old Activity Name 181221: Fabricate EMCal Preamp Boards: Sectors 1-12 - Vendor Responses

| ID | Activity | Type | Duration | Start | Finish | Predecessors | Complete | Planned start | Planned finish | Resources | Cost | BNL_UDF_Temp Text 01 | BNL_UDF_Percent Complete | BNL_UDF_OPC TEC (deprecated) | BNL_UDF_Old Activity ID 181221 | RG Check | BNL_Activity Status | BNL_Estimator | BNL_EDIA | BNL_Proc Sig Phase | BNL_Proc Sig | BNL_CAM | BNL_Institution | BNL_R&D FY18-19 | BNL_WBS | BNL_WBS_Hierarchical | BNL_Fund Source | BNL_Milestone Level | BNL_DOE OPC | BNL_PCR ID | SPH Proc Register | BNL_Obligation | BNL_Cobra WP | BNL_Cost Basis | BNL_OPC TEC (deprecated) | BNL_EVT | BNL_Master Control Account | BNL_Account Number | BNL_Cobra Control Account | Indicator - Procurement | Indicator - Float | BNL_UDF_Remaining Tot Cost | BNL_UDF_Percent_remaining | Cost = Awarded Proc or Mgmt | Target Milestone Date | Variance | PMP Milestones |
| --- | --- | --- | --- | --- | --- | --- | --- | --- | --- | --- | --- | --- | --- | --- | --- | --- | --- | --- | --- | --- | --- | --- | --- | --- | --- | --- | --- | --- | --- | --- | --- | --- | --- | --- | --- | --- | --- | --- | --- | --- | --- | --- | --- | --- | --- | --- | --- |
| S222600 | Fabricate EMCal Interface Board: Sectors 1-12 - Vendor Responses |  | 10d | 2019-10-10 A | 2019-10-14 A | S222500 | 100% | 2019-11-06 | 2019-11-20 |  |  | S222600 | 0 | S202900 | S341520 | NOCA | Completed | Mannel, Eric | Procurement | PP3 | MP201900 | Eric Mannel | BNL | CalEl EMCal FEE tests | POM02.1.05.02.01 | 01 |  |  |  |  |  |  |  |  |  |  |  |  |  |  |  |  |  |  |  |  |  |
| S222700 | Fabricate EMCal Interface Board: Sectors 1-12 - Vendor Selection |  | 10d | 2019-10-15 A | 2019-10-16 A | S222600 | 100% | 2019-11-21 | 2019-12-06 |  |  | S222700 | 0 | S202900 | S341560 | NOCA | Completed | Mannel, Eric | Procurement | PP4 | MP201900 | Eric Mannel | BNL | CalEl EMCal FEE tests | POM02.1.05.02.01 | 01 |  |  |  |  |  |  |  |  |  |  |  |  |  |  |  |  |  |  |  |  |  |
| S222000 | Fabricate EMCal Preamp Boards: Sectors 1-12, Phase 1 - Contract Award(s) | milestone | 0d | 2019-10-22 A | 2019-10-22 A | S221900 | 100% | 2019-12-16 | 2019-12-16 |  |  | S222000 | 0 | S201400 | S341120 | NOCA | Completed | Mannel, Eric | Procurement | PP5 | MP201050 | Eric Mannel | BNL | CalEl EMCal FEE tests | POM02.1.05.02.01 | 01 | A-OPC | L5 | OPC001900 | 003,004 | Contract Award |  |  |  |  |  |  |  |  |  |  |  |  |  |  |  |  |
| S222001 | Fabricate EMCal Preamp Boards: Sectors 1-12, Phase 2 - Contract Award(s) | milestone | 0d | 2019-10-22 A | 2019-10-22 A | S221900, S101000 | 100% | 2019-12-16 | 2019-12-16 |  |  | S222000 | 0 | S201400 | S341120 | NOCA | Completed | Mannel, Eric | Procurement | PP5 | MP201051 | Eric Mannel | BNL | CalEl EMCal FEE tests | POM02.1.05.02.01 | 01 | A-TEC | L5 | OPC001900 | 003,004 | Contract Award |  |  |  |  |  |  |  |  |  |  |  |  |  |  |  |  |
| OBLG222010 | Fabricate EMCal Preamp Boards: Sectors 1-12 Phase 2 - Obligation |  | 1d | 2019-11-01 A | 2019-11-01 A | S221900, S222001 SS | 100% |  |  | Obligation Resource [89810.8 h] | 89,810.79 | S222000 | 0 | S201400 | S341120 |  | Completed | Mannel, Eric | Procurement | PP5 | MP201051 | Eric Mannel | BNL | CalEl EMCal FEE tests | POM02.1.05.02.01 | 01 | A-TEC | L5 | OPC001900 | 003,004 |  | OBLG |  |  |  |  |  |  |  |  |  |  |  |  |  |  |  |
| OBLG222011 | Fabricate EMCal Preamp Boards: Sectors 1-12 Phase 1 - Obligation |  | 1d | 2019-11-01 A | 2019-11-01 A | S221900 | 100% |  |  | Obligation Resource [89810.8 h] | 89,810.79 | S222000 | 0 | S201400 | S341120 |  | Completed | Mannel, Eric | Procurement | PP5 | MP201050 | Eric Mannel | BNL | CalEl EMCal FEE tests | POM02.1.05.02.01 | 01 | A-OPC | L5 | OPC001900 | 003,004 |  | OBLG |  |  |  |  |  |  |  |  |  |  |  |  |  |  |  |
| OBLG222810 | Fabricate EMCal Interface Board: Sectors 1-12, Phase 1 - Obligation |  | 1d | 2019-11-01 A | 2019-11-01 A | S222700 SS | 100% |  |  | Obligation Resource [33494.8 h] | 33,494.85 | S222800 | 0 | S202900 | S341600 |  | Completed | Mannel, Eric | Procurement | PP5 | MP201900 | Eric Mannel | BNL | CalEl EMCal FEE tests | POM02.1.05.02.01 | 01 | A-OPC | L5 |  | 003,004 |  | OBLG |  |  |  |  |  |  |  |  |  |  |  |  |  |  |  |
| OBLG222811 | Fabricate EMCal Interface Board: Sectors 1-12, Phase 2 - Obligation |  | 1d | 2019-11-01 A | 2019-11-01 A | S222700, S222801 SS | 100% |  |  | Obligation Resource [33494.8 h] | 33,494.85 | S222800 | 0 | S202900 | S341600 |  | Completed | Mannel, Eric | Procurement | PP5 | MP201901 | Eric Mannel | BNL | CalEl EMCal FEE tests | POM02.1.05.02.01 | 01 | A-TEC | L5 |  | 003,004 |  | OBLG |  |  |  |  |  |  |  |  |  |  |  |  |  |  |  |
| S222100 | Fabricate EMCal Preamp Boards: Sectors 1-12 - Contract/PO - Leadtime |  | 35d | 2019-11-01 A | 2020-01-02 A | S222000 SS, OBLG222010 SS, S222001 SS, OBLG222011 SS | 100% | 2019-11-01 | 2019-12-24 |  |  | S222100 | 0 | S201400 | S341200 | NOCA | In Progress | Mannel, Eric | Fab & Assy | PP6 | MP201050 | Eric Mannel | BNL | CalEl EMCal FEE tests | POM02.1.05.02.01 | 01 |  |  | OPC001900 |  |  |  |  |  |  |  |  |  |  |  |  |  |  |  |  |  |  |
| S222800 | Fabricate EMCal Interface Board: Sectors 1-12, Phase 1 - Contract Award(s) | milestone | 0d | 2019-11-01 A | 2019-11-01 A | S222700 | 100% |  |  |  |  | S222800 | 0 | S202900 | S341600 | NOCA | Completed | Mannel, Eric | Procurement | PP5 | MP201900 | Eric Mannel | BNL | CalEl EMCal FEE tests | POM02.1.05.02.01 | 01 | A-OPC | L5 |  | 003,004 | Contract Award |  |  |  |  |  |  |  |  |  |  |  |  |  |  |  |  |
| S222801 | Fabricate EMCal Interface Board: Sectors 1-12, Phase 2 - Contract Award(s) | milestone | 0d | 2019-11-01 A | 2019-11-01 A | S222700, S101000 | 100% |  |  |  |  | S222800 | 0 | S202900 | S341600 | NOCA | Completed | Mannel, Eric | Procurement | PP5 | MP201901 | Eric Mannel | BNL | CalEl EMCal FEE tests | POM02.1.05.02.01 | 01 | A-TEC | L5 |  | 003,004 | Contract Award |  |  |  |  |  |  |  |  |  |  |  |  |  |  |  |  |
| S222900 | Fabricate EMCal Interface Board: Sectors 1-12 - Contract/PO - Leadtime |  | 30d | 2019-11-01 A | 2020-02-28 A | S222800 SS, OBLG222810 SS, OBLG222811 SS | 100% | 2019-11-01 | 2019-12-17 |  |  | S222900 | 0 | S202900 | S341640 | NOCA | In Progress | Mannel, Eric | Fab & Assy | PP6 | MP201900 | Eric Mannel | BNL | CalEl EMCal FEE tests | POM02.1.05.02.01 | 01 |  |  |  |  |  |  |  |  |  |  |  |  |  |  |  |  |  |  |  |  |  |
| S223800 | Procure EMCal External LV/Bias Cables: Sectors 1-12 - Labor |  | 10d | 2019-11-01 A | 2020-04-30 A | S221100 | 100% | 2019-11-01 | 2019-11-15 | PROF3 PO E [23 h]; TECH3 PO E [32 h]; TECH3 PO D [23 h] | 9,186.44 | S223800 | 0 | S203100 | S277590524 | CA | In Progress | Mannel, Eric | Procurement |  |  | Eric Mannel | BNL | CalEl EMCal FEE tests | POM02.1.05.02.01 | 01 | B |  |  |  |  |  | S223800 | L2 | null | C | 1.05 | 16712 | 1.05B |  |  |  |  |  |  |  |  |
| S221300 | Fabricate EMCal SiPM Boards: Sectors 1-12 - M&S |  | 30d | 2019-11-25 A | 2020-05-20 A | S221100, S213210, S213300, S213215, S213305 | 100% | 2019-11-01 | 2019-12-17 | Material (Purchase (1st $2M) [25487 h] | 29,002.31 | S221300 | 0 | S201400 | S201400 | CA | In Progress | Mannel, Eric | Fab & Assy |  | TBD | Eric Mannel | BNL | CalEl EMCal FEE tests | POM02.1.05.02.01 | 01 | A-OPC |  | OPC001900 | 003 |  |  | S221300 | M3 | OPC | C | 1.05 | 16704 | 1.05A | UDF_G1 | UDF_G1 | 24651.9674185 | 0.85 |  |  |  |  |
| S226500 | Review and Write EMCal Electronics Design Change Specifications: Final Production |  | 10d | 2019-11-25 A | 2020-05-28 A | S223400, S222300 SS+59d, S221400, S223600, S213300, S213305, S221100, S212201 | 100% | 2020-06-01 | 2020-06-12 | PROF3 PO E [20 h]; SCI3 PO [20 h] | 5,972.3 | S226500 | 0 | S203500 | S203500 | CA | In Progress | Mannel, Eric | Design |  |  | Eric Mannel | BNL | CalEl EMCal FEE tests | POM02.1.05.02.01 | 01 | B |  |  |  |  |  | S226500 | L2 | null | C | 1.05 | 16712 | 1.05B |  |  |  |  |  |  |  |  |
| S225500 | Procure EMCal External Bias Power System: Sectors 1-12 - Provide Requirements to Procurement |  | 10d | 2020-01-02 A | 2020-01-15 A | S221100 | 100% |  |  | PROF3 PO E [23 h]; TECH3 PO E [32 h]; TECH3 PO D [23 h] | 9,186.44 | S225500 | 0 | S203100 | S277590644 | CA | Not Started | Mannel, Eric | Procurement | PP1 | MP200310 | Eric Mannel | BNL | CalEl EMCal FEE tests | POM02.1.05.02.01 | 01 | B |  |  |  |  |  | S225500 | L2 | null | C | 1.05 | 16712 | 1.05B |  |  |  |  |  |  |  |  |
| S222200 | Fabricate EMCal Preamp Boards: Sectors 1-12, Phase 1 - Delivery Acceptance |  | 5d | 2020-01-03 A | 2020-01-09 A | S222100 | 100% |  |  | Material (Purchase (1st $2M) [78925 h] | 89,810.79 | S222200 | 0 | S201400 | S341240 | CA | Not Started | Mannel, Eric | Fab & Assy | PP6 | MP201050 | Eric Mannel | BNL | CalEl EMCal FEE tests | POM02.1.05.02.01 | 01 | A-OPC |  | OPC001900 | 003,004 | Delivery | FAB | S222200 | M3 | OPC | C | 1.05 | 16704 | 1.05A | UDF_G3 | UDF_G1 |  |  |  |  |  |  |
| S222201 | Fabricate EMCal Preamp Boards: Sectors 1-12, Phase 2 - Delivery Acceptance |  | 5d | 2020-01-03 A | 2020-01-09 A | S222100, S222001 SS | 100% |  |  | Material (Purchase (1st $2M) [78925 h] | 89,810.79 | S222200 | 0 | S201400 | S341240 | CA | Not Started | Mannel, Eric | Fab & Assy | PP6 | MP201051 | Eric Mannel | BNL | CalEl EMCal FEE tests | POM02.1.05.02.01 | 01 | A-TEC |  | OPC001900 | 003,004 | Delivery | FAB | S222201 | M3 | OPC | C | 1.05 | 59715 | 1.05A | UDF_G3 | UDF_G1 |  |  |  |  |  |  |
| S222300 | Test EMCal Preamp Boards: Sectors 1-12 |  | 5d | 2020-01-10 A | 2020-09-29 A | S222200, S222201 | 100% | 2020-01-10 | 2020-01-16 | STUDENT UM - Purchased Services [120 h] | 1,915.29 | S222300 | 0 | S201800 | S340000 | CA | Not Started | Mannel, Eric | Fab & Assy |  |  | Eric Mannel | BNL | CalEl EMCal FEE tests | POM02.1.05.02.01 | 01 | A-OPC |  | OPC001900 | 003 |  |  | S222300 | M4 | OPC | C | 1.05 | 16704 | 1.05A |  |  |  |  | Yes |  |  |  |
| S221500 | Test EMCal SiPM Daughter Boards: Sectors 1-12 |  | 53d | 2020-01-15 A | 2020-11-30 A | S221300 SS+60d, S221400 SS+70d, S212201 | 100% | 2020-02-25 | 2020-05-07 | PROF3 PO E [53 h]; TECH3 PO E [28 h]; STUDENT Other - Unpaid [60 h]; POSTDOC ISU - Unpaid [20 h]; SCI3 PO [14 h] | 12,309.9 | S221500 | 0 | S203200 | S203200 | CA | Not Started | Mannel, Eric | Fab & Assy |  |  | Eric Mannel | BNL | CalEl EMCal FEE tests | POM02.1.05.02.01 | 01 | B_T |  |  |  |  |  | S221500 | L4 | null | C | 1.05 | 16712 | 1.05B |  |  |  |  |  |  |  |  |
| S225600 | Procure EMCal External Bias Power System: Sectors 1-12 - Prepare & Send Solicitation |  | 20d | 2020-01-16 A | 2020-01-29 A | S225500 | 100% | 2020-01-16 | 2020-02-13 |  |  | S225600 | 0 | S201700 | S277590684 | NOCA | Not Started | Mannel, Eric | Procurement | PP2 | MP200310 | Eric Mannel | BNL | CalEl EMCal FEE tests | POM02.1.05.02.01 | 01 |  |  | OPC001900 |  |  |  |  |  |  |  |  |  |  |  |  |  |  |  |  |  |  |
| S223000 | Fabricate EMCal Interface Board: Sectors 1-12, Phase 1 - Delivery Acceptance |  | 5d | 2020-02-19 A | 2020-02-28 A | S222900 | 100% | 2020-03-19 | 2020-03-25 | Material (Purchase (1st $2M) [29435 h] | 33,494.85 | S223000 | 0 | S201500 | S201500 | CA | Not Started | Mannel, Eric | Fab & Assy | PP6 | MP201900 | Eric Mannel | BNL | CalEl EMCal FEE tests | POM02.1.05.02.01 | 01 | A-OPC |  | OPC001900 | 003,004 | Delivery | FAB | S223000 | M3 | OPC | C | 1.05 | 16704 | 1.05A | UDF_G2 | UDF_G1 |  |  |  |  |  |  |
| S223001 | Fabricate EMCal Interface Board: Sectors 1-12, Phase 2 - Delivery Acceptance |  | 5d | 2020-02-19 A | 2020-02-28 A | S222900, S222801 | 100% | 2020-03-19 | 2020-03-25 | Material (Purchase (1st $2M) [29435 h] | 33,494.85 | S223000 | 0 | S201500 | S201500 | CA | Not Started | Mannel, Eric | Fab & Assy | PP6 | MP201901 | Eric Mannel | BNL | CalEl EMCal FEE tests | POM02.1.05.02.01 | 01 | A-TEC |  | OPC001900 | 003,004 | Delivery | FAB | S223001 | M3 | OPC | C | 1.05 | 59715 | 1.05A | UDF_G2 | UDF_G1 |  |  |  |  |  |  |
| S223100 | Test EMCal Interface Boards: Sectors 1-12 |  | 6d | 2020-02-19 A | 2020-03-16 A | S221100, S223000, S223001 | 100% | 2020-03-26 | 2020-04-02 | PROF3 PO E [45 h]; TECH3 PO E [32 h]; POSTDOC ISU - Unpaid [20 h]; STUDENT Other - Unpaid [60 h]; SCI3 PO [24 h] | 13,475.37 | S223100 | 0 | S203300 | S203300 | CA | Not Started | Mannel, Eric | Fab & Assy |  |  | Eric Mannel | BNL | CalEl EMCal FEE tests | POM02.1.05.02.01 | 01 | B_T |  |  | 003 |  |  | S223100 | L4 | null | C | 1.05 | 16712 | 1.05B |  |  |  |  |  |  |  |  |
| S225700 | Procure EMCal External Bias Power System: Sectors 1-12 - Vendor Responses |  | 10d | 2020-02-19 A | 2020-02-28 A | S225600 | 100% | 2020-03-02 | 2020-03-13 |  |  | S225700 | 0 | S201700 | S277590724 | NOCA | Not Started | Mannel, Eric | Procurement | PP3 | MP200310 | Eric Mannel | BNL | CalEl EMCal FEE tests | POM02.1.05.02.01 | 01 |  |  | OPC001900 |  |  |  |  |  |  |  |  |  |  |  |  |  |  |  |  |  |  |
| S225800 | Procure EMCal External Bias Power System: Sectors 1-12 - Vendor Selection |  | 10d | 2020-02-19 A | 2020-02-28 A | S225700 | 100% | 2020-03-16 | 2020-03-27 |  |  | S225800 | 0 | S201700 | S277590764 | NOCA | Not Started | Mannel, Eric | Procurement | PP4 | MP200310 | Eric Mannel | BNL | CalEl EMCal FEE tests | POM02.1.05.02.01 | 01 |  |  | OPC001900 |  |  |  |  |  |  |  |  |  |  |  |  |  |  |  |  |  |  |
| S223900 | Procure EMCal External LV/Bias Signal/Comm/Test Cables: Sectors 1-12, Phase 1 - M&S |  | 5d | 2020-04-01 A | 2020-04-07 A | S221100 | 100% |  |  | Material (Purchase (1st $2M) [10720 h] | 11,959.38 | S223900 | 0 | S201700 | S277590564 | CA | Not Started | Mannel, Eric | Fab & Assy |  | TBD | Eric Mannel | BNL | CalEl EMCal FEE tests | POM02.1.05.02.01 | 01 | A-OPC |  | OPC001900 | 003,004 |  |  | S223900 | M3 | OPC | C | 1.05 | 16704 | 1.05A | UDF_G1 | UDF_G3 |  |  |  |  |  |  |
| S224000 | Procure EMCal External LV/Bias Signal/Comm/Test Cables: Sectors 1-12, Phase 2 - M&S |  | 5d | 2020-04-01 A | 2020-04-07 A | S221100, S101000 | 100% |  |  | Material (Purchase (1st $2M) [42880 h] | 47,837.51 | S224000 | 0 | S201700 | S277594404 | CA | Not Started | Mannel, Eric | Fab & Assy |  | TBD | Eric Mannel | BNL | CalEl EMCal FEE tests | POM02.1.05.02.01 | 01 | A-TEC |  | OPC001900 | 003,004 |  |  | S224000 | M3 | OPC | C | 1.05 | 59715 | 1.05A | UDF_G1 | UDF_G3 |  |  |  |  |  |  |
| S224500 | Test Pulse Boards 1-12 - Labor |  | 10d | 2020-04-01 A | 2020-05-28 A | S221100 | 100% | 2020-04-01 | 2020-04-14 | PROF3 PO E [23 h]; TECH3 PO E [32 h]; TECH3 PO D [23 h] | 9,186.44 | S224500 | 0 | S203100 | S201750 | CA | Not Started | Mannel, Eric | Procurement |  |  | Eric Mannel | BNL | CalEl EMCal FEE tests | POM02.1.05.02.01 | 01 | B |  |  | 003 |  |  | S224500 | L2 | null | C | 1.05 | 16712 | 1.05B |  |  |  |  |  |  |  |  |
| S225900 | Procure EMCal External Bias Power System: Sectors 1-12, Phase 1 - Contract Award(s) | milestone | 0d | 2020-04-01 A | 2020-04-01 A | S225800 | 100% |  |  |  |  | S225900 | 0 | S201700 | S277590804 | NOCA | Not Started | Mannel, Eric | Procurement | PP5 | MP200310 | Eric Mannel | BNL | CalEl EMCal FEE tests | POM02.1.05.02.01 | 01 | A-OPC | L5 | OPC001900 | 004 | Contract Award |  |  |  |  |  |  |  |  |  |  |  |  |  |  |  |  |
| S226000 | Procure EMCal External Bias Power System: Sectors 1-12, Phase 2 - Contract Award(s) | milestone | 0d | 2020-04-01 A | 2020-04-01 A | S225800, S101000 | 100% |  |  |  |  | S226000 | 0 | S201700 | S277590805 | NOCA | Not Started | Mannel, Eric | Procurement | PP5 | MP200311 | Eric Mannel | BNL | CalEl EMCal FEE tests | POM02.1.05.02.01 | 01 | A-TEC | L5 | OPC001900 | 003,004 | Contract Award |  |  |  |  |  |  |  |  |  |  |  |  |  |  |  |  |
| S226100 | Procure EMCal External Bias Power System: Sectors 1-12, Phase 1 - Contract/PO - Leadtime |  | 40d | 2020-04-01 A | 2021-02-23 A | S225900 SS, OBLG225910 SS | 100% | 2020-04-01 | 2020-05-27 |  |  | S226100 | 0 | S201700 | S277590844 | NOCA | Not Started | Mannel, Eric | Fab & Assy | PP6 | MP200310 | Eric Mannel | BNL | CalEl EMCal FEE tests | POM02.1.05.02.01 | 01 | A-OPC |  | OPC001900 | 004 |  |  |  |  |  |  |  |  |  |  |  |  |  |  |  |  |  |
| S226200 | Procure EMCal External Bias Power System: Sectors 1-12, Phase 2 - Contract/PO - Leadtime |  | 40d | 2020-04-01 A | 2021-02-24 A | S226000 SS, OBLG226010 SS | 100% | 2020-04-01 | 2020-05-27 |  |  | S226200 | 0 | S201700 | S277590845 | NOCA | Not Started | Mannel, Eric | Fab & Assy | PP6 | MP200311 | Eric Mannel | BNL | CalEl EMCal FEE tests | POM02.1.05.02.01 | 01 | A-TEC |  | OPC001900 | 004 |  |  |  |  |  |  |  |  |  |  |  |  |  |  |  |  |  |
| OBLG225910 | Procure EMCal External Bias Power System: Sectors 1-12, Phase 1 - Obligation |  | 1d | 2020-04-29 A | 2020-04-30 A | S225800 | 100% | 2020-05-01 | 2020-05-01 | Obligation Resource [8663.48 h] | 8,663.48 | S225900 | 0 | S201700 | S277590804 |  | Not Started | Mannel, Eric | Procurement | PP5 | MP200310 | Eric Mannel | BNL | CalEl EMCal FEE tests | POM02.1.05.02.01 | 01 | A-OPC | L5 | OPC001900 | 004 |  | OBLG |  |  |  |  |  |  |  |  |  |  |  |  |  |  |  |
| OBLG226010 | Procure EMCal External Bias Power System: Sectors 1-12, Phase 2 - Obligation |  | 1d | 2020-04-29 A | 2020-04-30 A | S225800, S101000 | 100% | 2020-05-01 | 2020-05-01 | Obligation Resource [34653.9 h] | 34,653.94 | S226000 | 0 | S201700 | S277590805 |  | Not Started | Mannel, Eric | Procurement | PP5 | MP200311 | Eric Mannel | BNL | CalEl EMCal FEE tests | POM02.1.05.02.01 | 01 | A-TEC | L5 | OPC001900 | 004 |  | OBLG |  |  |  |  |  |  |  |  |  |  |  |  |  |  |  |
| S226600 | EMCal Electronics Preproduction Complete | milestone | 0d | 2020-05-28 A | 2020-05-28 A | S226500 FF, S223800, S223700, S223701, S223900, S224000, S224500, S225300, S224200, S224300, S224400, S226100, S226200, S226300, S226400 | 100% |  |  |  |  | S226600 | 0 | S203500 | S203550 | NOCA | Not Started | Mannel, Eric | Design |  |  | Eric Mannel | BNL | CalEl EMCal FEE tests | POM02.1.05.02.01 | 01 |  | L2 |  |  |  |  |  | L2 | null |  |  |  |  | UDF_G2 | UDF_G3 |  |  |  | 2020-05-29 | 0 | PMP_1x |
| S225300 | Test Pulse Boards 1-12 - M&S |  | 10d | 2020-08-03 A | 2020-08-14 A | S221100 | 100% |  |  | Material (Purchase (1st $2M) [4222 h] | 4,804.32 | S225300 | 0 | S201700 | S341000 | CA | Not Started | Mannel, Eric | Fab & Assy |  | TBD | Eric Mannel | BNL | CalEl EMCal FEE tests | POM02.1.05.02.01 | 01 | A-OPC |  | OPC001900 | 003 |  |  | S225300 | M3 | OPC | C | 1.05 | 16704 | 1.05A | UDF_G1 | UDF_G3 | 4804.322685 | 1 |  |  |  |  |
| S226300 | Procure EMCal External Bias Power System: Sectors 1-12, Phase 1 - Delivery Acceptance |  | 5d | 2020-12-15 A | 2021-02-24 A | S226100 | 100% | 2021-05-03 | 2021-05-07 | Material (Purchase (1st $2M) [7613.4 h] | 8,836.75 | S226300 | 0 | S201700 | S277590884 | CA | Not Started | Mannel, Eric | Fab & Assy | PP6 | MP200310 | Eric Mannel | BNL | CalEl EMCal FEE tests | POM02.1.05.02.01 | 01 | A-OPC |  | OPC001900 | 004 | Delivery | FAB | S226300 | M3 | OPC | C | 1.05 | 16704 | 1.05A | UDF_G1 | UDF_G3 | 8836.753926 | 1 |  |  |  |  |
| S226400 | Procure EMCal External Bias Power System: Sectors 1-12, Phase 2 - Delivery Acceptance |  | 5d | 2020-12-15 A | 2021-02-24 A | S226200 | 100% | 2021-05-03 | 2021-05-07 | Material (Purchase (1st $2M) [30453.6 h] | 35,347.02 | S226400 | 0 | S201700 | S277594444 | CA | Not Started | Mannel, Eric | Fab & Assy | PP6 | MP200311 | Eric Mannel | BNL | CalEl EMCal FEE tests | POM02.1.05.02.01 | 01 | A-TEC |  | OPC001900 | 004 | Delivery | FAB | S226400 | M3 | OPC | C | 1.05 | 59715 | 1.05A | UDF_G1 | UDF_G3 | 35347.015703 | 1 |  |  |  |  |
| S224100 | Assemble EMCal External Power Cables: Sectors 1-12 |  | 10d | 2021-02-15 A | 2021-02-26 A | S221100 | 100% | 2021-03-01 | 2021-03-12 | PROF3 PO E [23 h]; TECH3 PO E [32 h]; TECH3 PO D [23 h] | 9,462.03 | S224100 | 0 | S203100 | S277590604 | CA | Not Started | Mannel, Eric | Procurement |  |  | Eric Mannel | BNL | CalEl EMCal FEE tests | POM02.1.05.02.01 | 01 | B |  |  |  |  |  | S224100 | L2 | null | C | 1.05 | 16712 | 1.05B |  |  |  |  |  |  |  |  |

Notes:
- S222600: BNL_UDF_Adhoc Comments: 180406 ELM pred/succ per GRY; 180402 ELM add activity for proc strg / BNL_UDF_Old Activity Name 181221: Fabricate EMCal Interface Board: Sectors 1-12 - Vendor Responses
- S222700: BNL_UDF_Adhoc Comments: 180406 ELM pred/succ per GRY; 180402 ELM add activity for proc strg / BNL_UDF_Old Activity Name 181221: Fabricate EMCal Interface Board: Sectors 1-12 - Vendor Selection
- S222000: BNL_UDF_Status Comments: 190417 ELM name; 190319 ELM split OPC,TEC per GRY / BNL_UDF_Adhoc Comments: 180406 ELM pred/succ per GRY; 180329 ELM add activity per EJM, GRY / BNL_UDF_Old Activity Name 181221: Fabricate EMCal Preamp Boards: Sectors 1-12 - Contract Award(s)
- S222001: BNL_UDF_Status Comments: 190417 ELM name; 190319 ELM split OPC,TEC per GRY / BNL_UDF_Adhoc Comments: 180406 ELM pred/succ per GRY; 180329 ELM add activity per EJM, GRY / BNL_UDF_Old Activity Name 181221: Fabricate EMCal Preamp Boards: Sectors 1-12 - Contract Award(s)
- OBLG222010: BNL_UDF_Status Comments: 190417 ELM name; 190319 ELM split OPC,TEC per GRY / BNL_UDF_Adhoc Comments: 180406 ELM pred/succ per GRY; 180329 ELM add activity per EJM, GRY / BNL_UDF_Old Activity Name 181221: Fabricate EMCal Preamp Boards: Sectors 1-12 - Contract Award(s)
- OBLG222011: BNL_UDF_Status Comments: 190417 ELM name; 190319 ELM split OPC,TEC per GRY / BNL_UDF_Adhoc Comments: 180406 ELM pred/succ per GRY; 180329 ELM add activity per EJM, GRY / BNL_UDF_Old Activity Name 181221: Fabricate EMCal Preamp Boards: Sectors 1-12 - Contract Award(s)
- OBLG222810: BNL_UDF_Status Comments: 190417 ELM name; 190319 ELM split OPC,TEC per GRY / BNL_UDF_Adhoc Comments: 180406 ELM pred/succ per GRY; 180402 ELM add activity for proc strg / BNL_UDF_Old Activity Name 181221: Fabricate EMCal Interface Board: Sectors 1-12 - Contract Award(s)
- OBLG222811: BNL_UDF_Status Comments: 190417 ELM name; 190319 ELM split OPC,TEC per GRY / BNL_UDF_Adhoc Comments: 180406 ELM pred/succ per GRY; 180402 ELM add activity for proc strg / BNL_UDF_Old Activity Name 181221: Fabricate EMCal Interface Board: Sectors 1-12 - Contract Award(s)
- S222100: BNL_UDF_Adhoc Comments: 180412 ELM dur per GRY; 180406 ELM pred/succ per GRY; 180329 ELM add activity per EJM, GRY / BNL_UDF_Old Activity Name 181221: Fabricate EMCal Preamp Boards: Sectors 1-12 - Contract/PO - Leadtime
- S222800: BNL_UDF_Status Comments: 190417 ELM name; 190319 ELM split OPC,TEC per GRY / BNL_UDF_Adhoc Comments: 180406 ELM pred/succ per GRY; 180402 ELM add activity for proc strg / BNL_UDF_Old Activity Name 181221: Fabricate EMCal Interface Board: Sectors 1-12 - Contract Award(s)
- S222801: BNL_UDF_Status Comments: 190417 ELM name; 190319 ELM split OPC,TEC per GRY / BNL_UDF_Adhoc Comments: 180406 ELM pred/succ per GRY; 180402 ELM add activity for proc strg / BNL_UDF_Old Activity Name 181221: Fabricate EMCal Interface Board: Sectors 1-12 - Contract Award(s)
- S222900: BNL_UDF_Adhoc Comments: 180411 ELM dur per GRY; 180406 ELM pred/succ per GRY; 180402 ELM add activity for proc strg / BNL_UDF_Old Activity Name 181221: Fabricate EMCal Interface Board: Sectors 1-12 - Contract/PO - Leadtime
- S223800: BNL_UDF_Old Activity Name 181221: Procure EMCal External LV/Bias Cables: Sectors 1-12 - Labor
- S221300: BNL_UDF_Status Comments: 190605 IVS change F to C; 190317 BNLU per L2 / BNL_UDF_Adhoc Comments: 180406 ELM dur per GRY; 180405 ELM pred per GRY; 180329 ELM units per EJM, name, dur per GRY / BNL_UDF_Old Activity Name 181221: Fabricate EMCal SiPM Boards: Sectors 1-12 - M&S
- S226500: BNL_UDF_Adhoc Comments: 180329 ELM desc / BNL_UDF_Old Activity Name 181221: Review and Write EMCal Electronics Design Change Specifications: Final Production
- S225500: BNL_UDF_Old Activity Name 181221: Procure EMCal External Bias Power System: Sectors 1-12 - Provide Requirements to Procurement
- S222200: BNL_UDF_Status Comments: 190417 ELM name; 190319 ELM split OPC,TEC per GRY; 190317 BNLU per L2 / BNL_UDF_Adhoc Comments: 180406 ELM pred/succ per GRY; 180329 ELM add activity per EJM, GRY / BNL_UDF_Old Activity Name 181221: Fabricate EMCal Preamp Boards: Sectors 1-12 - Delivery Acceptance
- S222201: BNL_UDF_Status Comments: 190417 ELM name; 190319 ELM split OPC,TEC per GRY; 190317 BNLU per L2 / BNL_UDF_Adhoc Comments: 180406 ELM pred/succ per GRY; 180329 ELM add activity per EJM, GRY / BNL_UDF_Old Activity Name 181221: Fabricate EMCal Preamp Boards: Sectors 1-12 - Delivery Acceptance
- S222300: BNL_UDF_Status Comments: 190319 ELM rsrc per GRY / BNL_UDF_Adhoc Comments: 180406 ELM pred/succ per GRY; 180329 ELM add activity per EJM, GRY / BNL_UDF_Old Activity Name 181221: Test EMCal Preamp Boards: Sectors 1-12
- S221500: BNL_UDF_Adhoc Comments: 180423 ELM rsrc per GRY; 180405 ELM pred per GRY; 180329 ELM desc per EJM / BNL_UDF_Old Activity Name 181221: Test EMCal SiPM Daughter Boards: Sectors 1-12
- S225600: BNL_UDF_Old Activity Name 181221: Procure EMCal External Bias Power System: Sectors 1-12 - Prepare & Send Solicitation
- S223000: BNL_UDF_Status Comments: 190417 ELM name; 190322 ELM BNL Units; 190319 ELM split OPC,TEC per GRY; 190317 BNLU per L2 / BNL_UDF_Adhoc Comments: 180406 ELM pred/succ per GRY / BNL_UDF_Old Activity Name 181221: Fabricate EMCal Interface Board: Sectors 1-12 - Delivery Acceptance
- S223001: BNL_UDF_Status Comments: 190417 ELM name; 190322 ELM BNL Units; 190319 ELM split OPC,TEC per GRY; 190317 BNLU per L2 / BNL_UDF_Adhoc Comments: 180406 ELM pred/succ per GRY / BNL_UDF_Old Activity Name 181221: Fabricate EMCal Interface Board: Sectors 1-12 - Delivery Acceptance
- S223100: BNL_UDF_Status Comments: 190314 ELM re-load zeroed RA units / BNL_UDF_Adhoc Comments: 180423 ELM rsrc per GRY / BNL_UDF_Old Activity Name 181221: Test EMCal Interface Boards: Sectors 1-12
- S225700: BNL_UDF_Adhoc Comments: 180406 ELM pred/succ per GRY; 180402 ELM added activity (Proc String), need duration adjusted and logic to rest of proc string / BNL_UDF_Old Activity Name 181221: Procure EMCal External Bias Power System: Sectors 1-12 - Vendor Responses
- S225800: BNL_UDF_Adhoc Comments: 180406 ELM pred/succ per GRY; 180402 ELM added activity (Proc String), need duration adjusted and logic to rest of proc string / BNL_UDF_Old Activity Name 181221: Procure EMCal External Bias Power System: Sectors 1-12 - Vendor Selection
- S223900: BNL_UDF_Status Comments: 190417 ELM name; 190322 ELM BNL Units; 190317 BNLU per L2 / BNL_UDF_Adhoc Comments: 180406 ELM pred/succ per GRY; 180402 ELM added activity (Proc String), need duration adjusted and logic to rest of proc string / BNL_UDF_Old Activity Name 181221: Procure EMCal External LV/Bias Cables: Sectors 1-12 - M&S - OPC Funds
- S224000: BNL_UDF_Status Comments: 190417 ELM name; 190322 ELM BNL Units; 190317 BNLU per L2; logic per GRY / BNL_UDF_Adhoc Comments: 180406 ELM pred/succ per GRY; 180402 ELM added activity (Proc String), need duration adjusted and logic to rest of proc string / BNL_UDF_Old Activity Name 181221: Procure EMCal External LV/Bias Cables: Sectors 1-12 - M&S - TEC Funds
- S224500: BNL_UDF_Status Comments: 190317 ELM logic; 190317 BLU, Convert from Proc to simple Labor & M&S per GRY / BNL_UDF_Old Activity Name 181221: Procure EMCal External Signal/Comm/Test Cables: Sectors 1-12 - Provide Requirements to Procurement
- S225900: BNL_UDF_Status Comments: 190417 ELM name / BNL_UDF_Adhoc Comments: 180406 ELM pred/succ per GRY; 180402 ELM added activity (Proc String), need duration adjusted and logic to rest of proc string / BNL_UDF_Old Activity Name 181221: Procure EMCal External Bias Power System: Sectors 1-12 - Contract Award(s) - OPC Funds
- S226000: BNL_UDF_Status Comments: 190417 ELM name; 190317 Logic per GRY / BNL_UDF_Adhoc Comments: 180406 ELM pred/succ per GRY; 180402 ELM added activity (Proc String), need duration adjusted and logic to rest of proc string / BNL_UDF_Old Activity Name 181221: Procure EMCal External Bias Power System: Sectors 1-12 - Contract Award(s) - TEC Funds
- S226100: BNL_UDF_Status Comments: 190417 ELM name / BNL_UDF_Adhoc Comments: 180406 ELM pred/succ per GRY; 180402 ELM added activity (Proc String), need duration adjusted and logic to rest of proc string / BNL_UDF_Old Activity Name 181221: Procure EMCal External Bias Power System: Sectors 1-12 - Contract/PO - Leadtime - OPC Funds
- S226200: BNL_UDF_Status Comments: 190417 ELM name / BNL_UDF_Adhoc Comments: 180406 ELM pred/succ per GRY; 180402 ELM added activity (Proc String), need duration adjusted and logic to rest of proc string / BNL_UDF_Old Activity Name 181221: Procure EMCal External Bias Power System: Sectors 1-12 - Contract/PO - Leadtime - TEC Funds
- OBLG225910: BNL_UDF_Status Comments: 190417 ELM name / BNL_UDF_Adhoc Comments: 180406 ELM pred/succ per GRY; 180402 ELM added activity (Proc String), need duration adjusted and logic to rest of proc string / BNL_UDF_Old Activity Name 181221: Procure EMCal External Bias Power System: Sectors 1-12 - Contract Award(s) - OPC Funds
- OBLG226010: BNL_UDF_Status Comments: 190417 ELM name / BNL_UDF_Adhoc Comments: 180406 ELM pred/succ per GRY; 180402 ELM added activity (Proc String), need duration adjusted and logic to rest of proc string / BNL_UDF_Old Activity Name 181221: Procure EMCal External Bias Power System: Sectors 1-12 - Contract Award(s) - TEC Funds
- S226600: BNL_UDF_Adhoc Comments: 180329 ELM desc / BNL_UDF_Old Activity Name 181221: EMCal Electronics Preproduction Complete
- S225300: BNL_UDF_Status Comments: 190317 ELM dur, BNLU per L2, Convert from Proc to simple Labor & M&S per GRY / BNL_UDF_Adhoc Comments: 180406 ELM pred/succ per GRY; 180402 ELM added activity (Proc String), need duration adjusted and logic to rest of proc string / BNL_UDF_Old Activity Name 181221: Procure EMCal External Signal/Comm/Test Cables: Sectors 1-12 - Delivery Acceptance - OPC Funds
- S226300: BNL_UDF_Status Comments: 190417 ELM name / BNL_UDF_Adhoc Comments: 180406 ELM pred/succ per GRY; 180402 ELM added activity (Proc String), need duration adjusted and logic to rest of proc string / BNL_UDF_Old Activity Name 181221: Procure EMCal External Bias Power System: Sectors 1-12 - Delivery Acceptance - OPC Funds
- S226400: BNL_UDF_Status Comments: 190417 ELM name / BNL_UDF_Adhoc Comments: 180406 ELM pred/succ per GRY; 180402 ELM added activity (Proc String), need duration adjusted and logic to rest of proc string / BNL_UDF_Old Activity Name 181221: Procure EMCal External Bias Power System: Sectors 1-12 - Delivery Acceptance - TEC Funds
- S224100: BNL_UDF_Old Activity Name 181221: Assemble EMCal External Power Cables: Sectors 1-12

| ID | WBS | Activity | Type | Duration | Start | Finish | Predecessors | Complete | Remaining | Planned start | Planned finish | Total float | Free float | Constraint | Expected finish | Resources | Cost | BNL_UDF_Temp Text 01 | BNL_UDF_Percent Complete | BNL_UDF_OPC TEC (deprecated) | BNL_UDF_Old Activity ID 181221 | BNL_Cobra WP | RG Check | BNL_Activity Status | BNL_Fund Source | BNL_Estimator | BNL_Cost Basis | BNL_EDIA | BNL_Proc Sig Phase | BNL_Proc Sig | BNL_CAM | BNL_Institution | BNL_OPC TEC (deprecated) | BNL_WBS | BNL_EVT | BNL_Master Control Account | BNL_Account Number | BNL_Cobra Control Account | BNL_WBS_Hierarchical | BNL_UDF_Status Comments | BNL_PCR ID | BNL_Milestone Level | SPH Proc Register | Indicator - Procurement | Indicator - Float | BNL_UDF_Remaining Tot Cost | BNL_UDF_Percent_remaining | BNL_Obligation | Additional EVT documentation required |
| --- | --- | --- | --- | --- | --- | --- | --- | --- | --- | --- | --- | --- | --- | --- | --- | --- | --- | --- | --- | --- | --- | --- | --- | --- | --- | --- | --- | --- | --- | --- | --- | --- | --- | --- | --- | --- | --- | --- | --- | --- | --- | --- | --- | --- | --- | --- | --- | --- | --- |
|  | 02 | **EMCal Electronics: Production** |  |  | 2020-03-11 | 2022-01-28 |  |  |  |  |  |  |  |  |  |  |  |  |  |  |  |  |  |  |  |  |  |  |  |  |  |  |  |  |  |  |  |  |  |  |  |  |  |  |  |  |  |  |  |
| S231200 |  | Procure Internal EMCal Signal/Test/Comm and LV/Bias Cables: Production - Provide Requirements to Procurement |  | 5d | 2020-03-11 A | 2020-03-25 A | S226901 | 100% |  | 2020-04-21 | 2020-04-27 |  |  |  |  | PROF3 PO E [32 h]; TECH3 PO E [16 h]; TECH3 PO D [32 h] | 9,526.17 | S231200 | 0 | S205900 | S205900 | S231200 | CA | Not Started | B | Mannel, Eric | L2 | Procurement | PP1 | MP202800 | Eric Mannel | BNL | null | POM02.1.05.02.02 | C | 1.05 | 16712 | 1.05B | 02 |  |  |  |  |  |  |  |  |  |  |
| S227000 |  | Fabricate SiPM Daughter Boards Sectors 13-64 - Provide Requirements to Procurement |  | 5d | 2020-03-18 A | 2020-03-31 A | S221100, S226901 | 100% |  | 2020-04-21 | 2020-04-27 |  |  |  |  | PROF3 PO E [40 h]; SCI3 PO [24 h]; TECH3 PO E [56 h] | 15,581.76 | S227000 | 0 | S206700 | S206700 | S227000 | CA | Not Started | B | Mannel, Eric | L4 | Procurement | PP1 | MP105500 | Eric Mannel | BNL | null | POM02.1.05.02.02 | C | 1.05 | 16712 | 1.05B | 02 |  |  |  |  |  |  |  |  |  |  |
| S227200 |  | Fabricate SiPM Daughter Boards Sectors 13-64 - Vendor Responses |  | 10d | 2020-03-18 A | 2020-03-30 A | S227100 | 100% |  | 2020-05-27 | 2020-06-09 |  |  |  |  |  |  | S227200 | 0 | S206900 | S206900 |  | NOCA | Not Started |  | Mannel, Eric |  | Procurement | PP3 | MP105500 | Eric Mannel | BNL |  | POM02.1.05.02.02 |  |  |  |  | 02 |  |  |  |  |  |  |  |  |  |  |
| S227100 |  | Fabricate SiPM Daughter Boards Sectors 13-64 - Prepare & Send Solicitation |  | 20d | 2020-03-19 A | 2020-03-31 A | S227000 | 100% |  | 2020-04-28 | 2020-05-26 |  |  |  |  |  |  | S227100 | 0 | S206800 | S206800 |  | NOCA | Not Started |  | Mannel, Eric |  | Procurement | PP2 | MP105500 | Eric Mannel | BNL |  | POM02.1.05.02.02 |  |  |  |  | 02 |  |  |  |  |  |  |  |  |  |  |
| S231500 |  | Procure Internal EMCal Signal/Test/Comm and LV/Bias: Production - Vendor Selection |  | 10d | 2020-03-23 A | 2020-03-31 A | S231400 | 100% |  | 2020-05-27 | 2020-06-09 |  |  |  |  |  |  | S231500 | 0 | S205800 | S340200 |  | NOCA | Not Started |  | Mannel, Eric |  | Procurement | PP4 | MP202800 | Eric Mannel | BNL |  | POM02.1.05.02.02 |  |  |  |  | 02 |  |  |  |  |  |  |  |  |  |  |
| S231400 |  | Procure Internal EMCal Signal/Test/Comm and LV/Bias: Production - Vendor Solicitation |  | 10d | 2020-03-24 A | 2020-03-31 A | S231300 | 100% |  | 2020-05-12 | 2020-05-26 |  |  |  |  |  |  | S231400 | 0 | S205800 | S340160 |  | NOCA | Not Started |  | Mannel, Eric |  | Procurement | PP3 | MP202800 | Eric Mannel | BNL |  | POM02.1.05.02.02 |  |  |  |  | 02 |  |  |  |  |  |  |  |  |  |  |
| S227300 |  | Fabricate SiPM Daughter Boards Sectors 13-64 - Vendor Selection |  | 10d | 2020-03-25 A | 2020-03-31 A | S227200 | 100% |  | 2020-06-10 | 2020-06-23 |  |  |  |  |  |  | S227300 | 0 | S207000 | S207000 |  | NOCA | Not Started |  | Mannel, Eric |  | Procurement | PP4 | MP105500 | Eric Mannel | BNL |  | POM02.1.05.02.02 |  |  |  |  | 02 |  |  |  |  |  |  |  |  |  |  |
| S231300 |  | Procure Internal EMCal Signal/Test/Comm and LV/Bias: Production - Prepare & Send Solicitation |  | 10d | 2020-03-25 A | 2020-03-30 A | S231200 | 100% |  | 2020-04-28 | 2020-05-11 |  |  |  |  |  |  | S231300 | 0 | S205800 | S340120 |  | NOCA | Not Started |  | Mannel, Eric |  | Procurement | PP2 | MP202800 | Eric Mannel | BNL |  | POM02.1.05.02.02 |  |  |  |  | 02 |  |  |  |  |  |  |  |  |  |  |
| S226700 |  | Production Readiness and Safety Review: EMCal Production Electronics |  | 5d | 2020-03-31 A | 2020-04-22 A | S221200, S226500 | 100% |  | 2020-03-31 | 2020-04-06 |  |  |  |  | PROF3 PO E [24 h]; SCI3 PO [24 h]; TECH3 PO E [8 h] | 8,079.74 | S226700 | 0 | S208700 | S208700 | S226700 | CA | Not Started | B | Mannel, Eric | L2 | Fab & Assy |  |  | Eric Mannel | BNL | null | POM02.1.05.02.02 | C | 1.05 | 16712 | 1.05B | 02 | 190508 ELM name; 190415 ELM name per GRY | 004 |  |  |  |  |  |  |  |  |
| S233400 |  | Procure EMCal Bias Power System Sectors 13-64 - Provide Requirements to Procurement |  | 5d | 2020-04-07 A | 2020-04-20 A | S226901 | 100% |  | 2020-05-07 | 2020-05-13 |  |  |  |  | PROF3 PO E [32 h]; SCI3 PO [32 h]; TECH3 PO E [16 h] | 11,381.64 | S233400 | 0 | S206000 | S277591284 | S233400 | CA | Not Started | B | Mannel, Eric | L2 | Procurement | PP1 | MP105920 | Eric Mannel | BNL | null | POM02.1.05.02.02 | C | 1.05 | 16712 | 1.05B | 02 |  |  |  |  |  |  |  |  |  |  |
| S233500 |  | Procure EMCal Bias Power System Sectors 13-64 - Prepare & Send Solicitation |  | 30d | 2020-04-07 A | 2020-04-20 A | S233400 | 100% |  | 2020-05-14 | 2020-06-25 |  |  |  |  |  |  | S233500 | 0 | S206100 | S277591324 |  | NOCA | Not Started |  | Mannel, Eric |  | Procurement | PP2 | MP105920 | Eric Mannel | BNL |  | POM02.1.05.02.02 |  |  |  |  | 02 |  |  |  |  |  |  |  |  |  |  |
| S233600 |  | Procure EMCal Bias Power System Sectors 13-64 - Vendor Responses |  | 10d | 2020-04-07 A | 2020-04-20 A | S233500 | 100% |  | 2020-06-26 | 2020-07-10 |  |  |  |  |  |  | S233600 | 0 | S206200 | S277591364 |  | NOCA | Not Started |  | Mannel, Eric |  | Procurement | PP3 | MP105920 | Eric Mannel | BNL |  | POM02.1.05.02.02 |  |  |  |  | 02 |  |  |  |  |  |  |  |  |  |  |
| S233700 |  | Procure EMCal Bias Power System Sectors 13-64 - Vendor Selection |  | 20d | 2020-04-07 A | 2020-04-20 A | S233600 | 100% |  | 2020-07-13 | 2020-08-07 |  |  |  |  |  |  | S233700 | 0 | S206300 | S277591404 |  | NOCA | Not Started |  | Mannel, Eric |  | Procurement | PP4 | MP105920 | Eric Mannel | BNL |  | POM02.1.05.02.02 |  |  |  |  | 02 |  |  |  |  |  |  |  |  |  |  |
| S233800 |  | Procure EMCal Bias Power System Sectors 13-64 - Contract Award(s) | milestone | 0d | 2020-04-07 A | 2020-04-07 A | S233700, S101015 SS, S101000 | 100% |  | 2020-10-01 | 2020-10-01 |  |  |  |  |  |  | S233800 | 0 | S206400 | S277591444 |  | NOCA | Not Started | A-TEC | Mannel, Eric |  | Procurement | PP5 | MP105920 | Eric Mannel | BNL |  | POM02.1.05.02.02 |  |  |  |  | 02 |  |  | L5 | Contract Award |  |  |  |  |  |  |
| S233900 |  | Procure EMCal Bias Power System Sectors 13-64 - Contract/PO - Leadtime |  | 140d | 2020-04-07 A | 2021-03-15 A | S233800 SS, OBLG233810 SS | 100% |  | 2020-10-01 | 2021-04-26 |  |  |  |  |  |  | S233900 | 0 | S206500 | S277591484 |  | NOCA | Not Started |  | Mannel, Eric |  | Fab & Assy | PP6 | MP105920 | Eric Mannel | BNL |  | POM02.1.05.02.02 |  |  |  |  | 02 |  |  |  |  |  |  |  |  |  |  |
| S226800 |  | Production Readiness & Safety Review: EMCal Electronics | milestone | 0d | 2020-04-22 A | 2020-04-22 A | S226700 | 100% |  |  |  |  |  |  |  |  |  | S226800 | 0 | S208800 | S208800 |  | NOCA | Not Started |  | Mannel, Eric |  | Management Safety Reviews |  |  | Eric Mannel | BNL |  | POM02.1.05.02.02 |  |  |  |  | 02 |  |  | L5 |  |  |  |  |  |  |  |
| S231900 |  | Fabricate Test-pulse Boards 13 - 64 - Labor |  | 5d | 2020-05-12 A | 2020-05-28 A | S226901 | 100% |  | 2020-06-12 | 2020-06-18 |  |  |  |  | PROF3 PO E [32 h]; SCI3 PO [32 h]; TECH3 PO E [16 h] | 11,381.64 | S231900 | 0 | S206000 | S206000 | S231900 | CA | Not Started | B | Mannel, Eric | L2 | Procurement |  |  | Eric Mannel | BNL | null | POM02.1.05.02.02 | C | 1.05 | 16712 | 1.05B | 02 | 190317 BLU, Convert from Proc to simple Labor & M&S per GRY | 003 |  |  |  |  |  |  |  |  |
| S227500 |  | Fabricate SiPM Daughter Boards Sectors 13-64 - Contract/PO - Leadtime |  | 160d | 2020-05-13 A | 2020-05-29 A | S227400 SS, OBLG227410 SS | 100% |  | 2020-06-12 | 2021-02-03 |  |  |  |  |  |  | S227500 | 0 | S207200 | S207200 |  | NOCA | Not Started |  | Mannel, Eric |  | Fab & Assy | PP6 | MP105500 | Eric Mannel | BNL |  | POM02.1.05.02.02 |  |  |  |  | 02 |  |  |  |  |  |  |  |  |  |  |
| S227600 |  | Fabricate SiPM Daughter Boards Sectors 13-64 - Delivery Acceptance |  | 2d | 2020-05-13 A | 2020-05-29 A |  | 100% |  | 2020-06-22 | 2020-06-23 |  |  | start on or after 2020-06-22 |  | Material (Purchase (1st $2M) [34668 h] | 38,676.09 | S227600 | 0 | S207300 | S207300 | S227600 | CA | Not Started | A-TEC | Mannel, Eric | M4 | Fab & Assy | PP6 | MP105500 | Eric Mannel | BNL | TEC | POM02.1.05.02.02 | C | 1.05 | 59715 | 1.05A | 02 |  | 014 |  | Delivery | UDF_G3 | UDF_G3 | 75665.010169 | 1 |  |  |
| S227400 |  | Fabricate SiPM Daughter Boards Sectors 13-64 - Contract Award(s) | milestone | 0d | 2020-05-19 A | 2020-05-19 A | S227300, S101000 | 100% |  | 2020-06-12 | 2020-06-12 |  |  |  |  |  |  | S227400 | 0 | S207100 | S207100 |  | NOCA | Not Started | A-TEC | Mannel, Eric |  | Procurement | PP5 | MP105500 | Eric Mannel | BNL |  | POM02.1.05.02.02 |  |  |  |  | 02 |  |  | L5 | Contract Award | UDF_G3 | UDF_G1 |  |  |  |  |
| S227510 |  | 20% EMCal SiPM Daughter Boards Delivered: Production Sectors 13-64 |  | 32d | 2020-05-20 A | 2020-05-29 A | S227500 SS, S215800, S215805 | 100% |  | 2020-06-12 | 2020-07-28 |  |  |  |  |  |  | S227700 | 0 | S209000 | S209000 |  | NOCA | Not Started |  | Mannel, Eric |  | Fab & Assy |  |  | Eric Mannel | BNL |  | POM02.1.05.02.02 |  |  |  |  | 02 | 190313 ELM PRED/SUCC | 003 | L5 |  | UDF_G3 | UDF_G1 |  |  |  |  |
| S227520 |  | 40% EMCal SiPM Daughter Boards Delivered: Production Sectors 13-64 |  | 32d | 2020-05-20 A | 2020-05-29 A | S227510, S216000, S216005 | 100% |  | 2020-07-29 | 2020-09-11 |  |  |  |  |  |  | S227800 | 0 | S209100 | S209100 |  | NOCA | Not Started |  | Mannel, Eric |  | Fab & Assy |  |  | Eric Mannel | BNL |  | POM02.1.05.02.02 |  |  |  |  | 02 | 190313 ELM PRED/SUCC | 003 | L5 |  | UDF_G3 | UDF_G3 |  |  |  |  |
| S231600 |  | Procure Internal EMCal Signal/Test/Comm and LV/Bias: Production - Contract Award(s) | milestone | 0d | 2020-05-28 A | 2020-05-28 A | S231500, S101000 | 100% |  | 2020-06-12 | 2020-06-12 |  |  |  |  |  |  | S231600 | 0 | S205800 | S340240 |  | NOCA | Not Started | A-TEC | Mannel, Eric |  | Procurement | PP5 | MP202800 | Eric Mannel | BNL |  | POM02.1.05.02.02 |  |  |  |  | 02 |  |  | L5 | Contract Award | UDF_G2 | UDF_G3 |  |  |  |  |
| S231700 |  | Procure Internal EMCal Signal/Test/Comm and LV/Bias: Production - Contract PO / Leadtime |  | 100d | 2020-05-29 A | 2021-02-24 A | S231600 SS, OBLG231610 SS | 100% |  | 2020-06-12 | 2020-11-03 |  |  |  |  |  |  | S231700 | 0 | S205800 | S340280 |  | NOCA | Not Started |  | Mannel, Eric |  | Fab & Assy | PP6 | MP202800 | Eric Mannel | BNL |  | POM02.1.05.02.02 |  |  |  |  | 02 |  |  |  |  |  |  |  |  |  |  |
| S226900 |  | Respond to Results of EMCal Production Readiness and Safety Review |  | 10d | 2020-05-29 A | 2020-06-08 A | S226800 | 100% |  | 2020-05-29 | 2020-06-11 |  |  |  |  | PROF3 PO E [16 h]; SCI3 PO [16 h] | 4,777.84 | S226900 | 0 | S208900 | S208900 | S226900 | CA | Not Started | B | Mannel, Eric | L2 | Management Safety Reviews |  |  | Eric Mannel | BNL | null | POM02.1.05.02.02 | C | 1.05 | 16712 | 1.05B | 02 |  |  |  |  |  |  |  |  |  |  |
| S229500 |  | Fabricate EMCAL Interface Board Sectors 13-64 - Provide Requirements to Fabricator |  | 5d | 2020-06-02 A | 2020-06-05 A | S226901 | 100% |  | 2020-07-01 | 2020-07-08 |  |  |  |  | PROF3 PO E [36 h]; TECH3 PO E [36 h]; PROF4 PO E [24 h] | 12,197.1 | S229500 | 0 | S205100 | S205100 | S229500 | CA | Not Started | B | Mannel, Eric | L2 | Procurement | PP1 | MP105700 | Eric Mannel | BNL | null | POM02.1.05.02.02 | C | 1.05 | 16712 | 1.05B | 02 |  |  |  |  |  |  |  |  |  |  |
| S229600 |  | Fabricate EMCAL Interface Board Sectors 13-64 - Prepare & Send Solicitation |  | 25d | 2020-06-08 A | 2020-06-09 A | S229500 | 100% |  | 2020-07-09 | 2020-08-12 |  |  |  |  |  |  | S229600 | 0 | S205200 | S205200 |  | NOCA | Not Started |  | Mannel, Eric |  | Procurement | PP2 | MP105700 | Eric Mannel | BNL |  | POM02.1.05.02.02 |  |  |  |  | 02 |  |  |  |  |  |  |  |  |  |  |
| S229700 |  | Fabricate EMCAL Interface Board Sectors 13-64 - Vendor Responses |  | 10d | 2020-06-09 A | 2020-06-11 A | S229600 | 100% |  | 2020-08-13 | 2020-08-26 |  |  |  |  |  |  | S229700 | 0 | S205300 | S205300 |  | NOCA | Not Started |  | Mannel, Eric |  | Procurement | PP3 | MP105700 | Eric Mannel | BNL |  | POM02.1.05.02.02 |  |  |  |  | 02 |  |  |  |  |  |  |  |  |  |  |
| S227530 |  | 60% EMCal SiPM Daughter Boards Delivered: Production Sectors 13-64 |  | 32d | 2020-06-09 A | 2020-06-30 A | S227520, S216200, S216205 | 100% |  | 2020-06-09 | 2020-07-23 |  |  |  |  |  |  | S227900 | 0 | S209200 | S209200 |  | NOCA | Not Started |  | Mannel, Eric |  | Fab & Assy |  |  | Eric Mannel | BNL |  | POM02.1.05.02.02 |  |  |  |  | 02 | 190313 ELM PRED/SUCC | 003 | L5 |  | UDF_G3 | UDF_G3 |  |  |  |  |
| S229800 |  | Fabricate EMCAL Interface Board Sectors 13-64 - Vendor Selection |  | 15d | 2020-06-11 A | 2020-06-12 A | S229700 | 100% |  | 2020-08-27 | 2020-09-17 |  |  |  |  |  |  | S229800 | 0 | S205400 | S205400 |  | NOCA | Not Started |  | Mannel, Eric |  | Procurement | PP4 | MP105700 | Eric Mannel | BNL |  | POM02.1.05.02.02 |  |  |  |  | 02 |  |  |  |  |  |  |  |  |  |  |
| S228190 |  | 5% EMCal SiPM Daughter Boards Tested: Production Sectors 13-64 | milestone | 0d | 2020-06-12 A | 2020-06-12 A | S227510 FS+5d | 100% |  |  |  |  |  |  |  |  |  | S228200 | 0 | S210200 | S210200 |  | NOCA | Not Started |  | Mannel, Eric |  | Test_System |  |  | Eric Mannel | BNL |  | POM02.1.05.02.02 |  |  |  |  | 02 | 190614 ELM add per GRY; 190313 ELM PRED/SUCC | 003 | L5 |  | UDF_G3 | UDF_G1 |  |  |  |  |
| S229900 |  | Fabricate EMCAL Interface Board Sectors 13-64 - Contract Award(s) | milestone | 0d | 2020-06-15 A | 2020-06-15 A | S229800, S101000 | 100% |  | 2020-09-18 | 2020-09-18 |  |  |  |  |  |  | S229900 | 0 | S205500 | S205500 |  | NOCA | Not Started | A-TEC | Mannel, Eric |  | Procurement | PP5 | MP105700 | Eric Mannel | BNL |  | POM02.1.05.02.02 |  |  |  |  | 02 |  |  | L5 | Contract Award | UDF_G2 | UDF_G1 |  |  |  |  |
| S230000 |  | Fabricate EMCAL Interface Board Sectors 13-64 - Contract/PO - Leadtime |  | 60d | 2020-06-16 A | 2020-11-02 A | S229900 SS, OBLG229910 SS | 100% |  | 2020-09-18 | 2020-12-16 |  |  |  |  |  |  | S230000 | 0 | S205600 | S205600 |  | NOCA | Not Started |  | Mannel, Eric |  | Fab & Assy | PP6 | MP105700 | Eric Mannel | BNL |  | POM02.1.05.02.02 |  |  |  |  | 02 |  |  |  |  |  |  |  |  |  |  |
| S226901 |  | Completed: Production Readiness Review, Safety Review - EMCal FEE sectors 13-64 | milestone | 0d | 2020-08-03 A | 2020-08-03 A | S226900 FF | 100% |  |  |  |  |  |  |  |  |  | S226900 | 0 | S208900 | S208900 |  | NOCA | Not Started |  | Mannel, Eric | L2 | Management Safety Reviews |  |  | Eric Mannel | BNL | null | POM02.1.05.02.02 | C |  | 16712 |  | 02 | 190508 ELM add per GRY | 004 |  |  |  |  |  |  |  |  |
| S228700 |  | Fabricate EMCAL Production Preamp Boards Sectors 13-64 - Provide Requirements to Procure & Assem |  | 5d | 2020-08-03 A | 2020-08-07 A | S226901 | 100% |  |  |  |  |  |  |  | PROF3 PO E [36 h]; TECH3 PO E [36 h]; PROF4 PO E [24 h] | 12,197.1 | S228700 | 0 | S203700 | S203700 | S228700 | CA | Not Started | B | Mannel, Eric | L2 | Procurement | PP1 | MP105800 | Eric Mannel | BNL | null | POM02.1.05.02.02 | C | 1.05 | 16712 | 1.05B | 02 |  |  |  |  |  |  |  |  |  |  |
| S230400 |  | Fabricate Calorimeter Production Controller Boards - Provide Requirements to Procurement |  | 5d | 2020-08-03 A | 2020-08-07 A | S226901 | 100% |  |  |  |  |  |  |  |  |  | S230400 | 0 | S207900 | S207900 |  | NOCA | Not Started |  | Mannel, Eric | M4 | Fab & Assy | PP1 | MP203010 | Eric Mannel | BNL | TEC | POM02.1.05.02.02 | K |  |  |  | 02 | 190317 ELM logic | 003 |  |  |  |  |  |  |  |  |
| S230500 |  | Fabricate Calorimeter Production Controller Boards M&S - Prepare & Send Solicitation |  | 10d | 2020-08-10 A | 2020-08-21 A | S230400 | 100% |  |  |  |  |  |  |  |  |  | S230500 | 0 | S207900 | S207910 |  | NOCA | Not Started |  | Mannel, Eric | M4 | Fab & Assy | PP2 | MP203010 | Eric Mannel | BNL | TEC | POM02.1.05.02.02 | K |  |  |  | 02 |  |  |  |  |  |  |  |  |  |  |
| S230600 |  | Fabricate Calorimeter Production Controller Boards - Vendor Responses |  | 10d | 2020-08-10 A | 2020-08-26 A | S230500 | 100% |  | 2020-08-24 | 2020-09-04 |  |  |  |  |  |  | S230600 | 0 | S207900 | S207920 |  | NOCA | Not Started |  | Mannel, Eric | M4 | Fab & Assy | PP3 | MP203010 | Eric Mannel | BNL | TEC | POM02.1.05.02.02 | K |  |  |  | 02 |  |  |  |  |  |  |  |  |  |  |
| S230700 |  | Fabricate Calorimeter Production Controller Boards - Vendor Selection |  | 10d | 2020-08-10 A | 2020-08-26 A | S230600 | 100% |  | 2020-09-08 | 2020-09-21 |  |  |  |  |  |  | S230700 | 0 | S207900 | S207930 |  | NOCA | Not Started |  | Mannel, Eric | M4 | Fab & Assy | PP4 | MP203010 | Eric Mannel | BNL | TEC | POM02.1.05.02.02 | K |  |  |  | 02 |  |  |  |  |  |  |  |  |  |  |
| S230800 |  | Fabricate Calorimeter Production Controller Boards - Contract Award(s) | milestone | 0d | 2020-08-10 A | 2020-08-10 A | S230700, S101000 | 100% |  | 2020-09-22 | 2020-09-22 |  |  |  |  |  |  | S230800 | 0 | S207900 | S207940 |  | NOCA | Not Started | A-TEC | Mannel, Eric | M4 | Fab & Assy | PP5 | MP203010 | Eric Mannel | BNL | TEC | POM02.1.05.02.02 | K |  |  |  | 02 |  |  | L5 | Contract Award | UDF_G2 | UDF_G3 |  |  |  |  |
| S230900 |  | Fabricate Calorimeter Production Controller Boards - Contract/PO - Leadtime |  | 40d | 2020-08-10 A | 2020-08-26 A | S230800, OBLG230810 | 100% |  | 2020-09-23 | 2020-11-19 |  |  |  |  |  |  | S230900 | 0 | S207900 | S207950 |  | NOCA | Not Started |  | Mannel, Eric | M4 | Fab & Assy | PP6 | MP203010 | Eric Mannel | BNL | TEC | POM02.1.05.02.02 | K |  |  |  | 02 |  |  |  |  |  |  |  |  |  |  |
| S231000 |  | Fabricate Calorimeter Production Controller Boards - Delivery Acceptance |  | 5d | 2020-08-10 A | 2020-08-26 A | S230900 | 100% |  | 2021-01-11 | 2021-01-15 |  |  | start on or after 2021-01-11 |  | Material (Purchase (1st $2M) [79397 h] | 92,154.85 | S231000 | 0 | S207900 | S207960 | S231000 | CA | Not Started | A-TEC | Mannel, Eric | M4 | Fab & Assy | PP6 | MP203010 | Eric Mannel | BNL | TEC | POM02.1.05.02.02 | C | 1.05 | 59715 | 1.05A | 02 | 190317 ELM BLNU per L2 | 015 |  | Delivery | UDF_G1 | UDF_G3 | 91793.460519 | 1 | FAB |  |
| S231100 |  | Test Calorimeter Controller Boards: Production Sectors 13-64 |  | 40d | 2020-08-10 A | 2020-08-26 A | S231000, S245100 SS, OBLG245110 | 100% |  | 2021-01-19 | 2021-03-16 |  |  |  |  | STUDENT UM - Purchased Services [120 h] | 1,972.75 | S231100 | 0 | S210100 | S210100 | S231100 | CA | Not Started | A-TEC | Mannel, Eric | L4 | Test_Components |  |  | Eric Mannel | BNL | null | POM02.1.05.02.02 | C | 1.05 | 59715 | 1.05A | 02 | 190313 ELM Activity split for fund src | 003 |  |  |  |  |  |  |  |  |
| S231105 |  | Test Calorimeter Controller Boards: Production Sectors 13-64 - Contributed Labor |  | 40d | 2020-08-10 A | 2020-08-26 A | S231000 | 100% |  | 2021-01-19 | 2021-03-16 |  |  |  |  | PROF3 PO E [92 h]; TECH3 PO E [96 h] | 23,272.44 | S231100 | 0 | S210100 | S210100 | S231105 | CA | Not Started | B | Mannel, Eric | L4 | Test_Components |  |  | Eric Mannel | BNL | null | POM02.1.05.02.02 | C | 1.05 | 16712 | 1.05B | 02 | 190313 ELM Activity split for fund src | 003 |  |  |  |  |  |  |  |  |
| S234100 |  | EMCal Low Voltage Power System Sectors 13-64 - M&S |  | 140d | 2020-08-31 A | 2021-06-28 | S226901 | 70% | 20d | 2020-09-01 | 2021-03-26 | 150d | 0d |  | 2021-06-28 | Material (Purchase (1st $2M) [35200 h] | 39,269.6 | S234100 | 0 | S206600 | S277591604 | S234100 | CA | Not Started | A-TEC | Mannel, Eric | M3 | Fab & Assy |  | TBD | Eric Mannel | BNL | TEC | POM02.1.05.02.02 | C | 1.05 | 59715 | 1.05A | 02 | 190317 ELM BLNU per L2 | 003 |  |  | UDF_G1 | UDF_G3 | 39269.595904 | 1 |  | Yes |
| OBLG227410 |  | Fabricate SiPM Daughter Boards Sectors 13-64 - Obligation |  | 1d | 2020-09-01 A | 2020-09-01 A | S227300, S101000 | 100% |  |  |  |  |  |  |  | Obligation Resource [75665 h] | 75,665.02 | S227400 | 0 | S207100 | S207100 |  |  | Not Started | A-TEC | Mannel, Eric |  | Procurement | PP5 | MP105500 | Eric Mannel | BNL |  | POM02.1.05.02.02 |  |  |  |  | 02 |  |  | L5 |  |  |  |  |  | OBLG |  |
| OBLG229910 |  | Fabricate EMCAL Interface Board Sectors 13-64 - Obligation |  | 1d | 2020-09-01 A | 2020-09-01 A | S229800, S101000 | 100% |  |  |  |  |  |  |  | Obligation Resource [217849 h] | 217,848.87 | S229900 | 0 | S205500 | S205500 |  |  | Not Started | A-TEC | Mannel, Eric |  | Procurement | PP5 | MP105700 | Eric Mannel | BNL |  | POM02.1.05.02.02 |  |  |  |  | 02 |  |  | L5 |  |  |  |  |  | OBLG |  |
| OBLG230810 |  | Fabricate Calorimeter Production Controller Boards - Obligation |  | 1d | 2020-09-01 A | 2020-09-01 A | S230700 | 100% |  |  |  |  |  |  |  | Obligation Resource [90347.9 h] | 90,347.89 | S230800 | 0 | S207900 | S207940 |  |  | Not Started | A-TEC | Mannel, Eric | M4 | Fab & Assy | PP5 | MP203010 | Eric Mannel | BNL | TEC | POM02.1.05.02.02 | C |  |  |  | 02 |  |  |  |  |  |  |  |  | OBLG |  |
| OBLG231610 |  | Procure Internal EMCal Signal/Test/Comm and LV/Bias: Production - Obligation |  | 1d | 2020-09-01 A | 2020-09-01 A | S231500, S101000 | 100% |  |  |  |  |  |  |  | Obligation Resource [288193 h] | 288,193.32 | S231600 | 0 | S205800 | S340240 |  |  | Not Started | A-TEC | Mannel, Eric |  | Procurement | PP5 | MP202800 | Eric Mannel | BNL |  | POM02.1.05.02.02 |  |  |  |  | 02 |  |  | L5 |  |  |  |  |  | OBLG |  |
| S228800 |  | Fabricate EMCAL Production Preamp Boards Sectors 13-64 - Prepare & Send Solicitation |  | 25d | 2020-09-01 A | 2020-09-14 A | S228700 | 100% |  | 2020-09-01 | 2020-10-06 |  |  |  |  |  |  | S228800 | 0 | S203800 | S203800 |  | NOCA | Not Started |  | Mannel, Eric |  | Procurement | PP2 | MP105800 | Eric Mannel | BNL |  | POM02.1.05.02.02 |  |  |  |  | 02 |  |  |  |  |  |  |  |  |  |  |
| OBLG233810 |  | Procure EMCal Bias Power System Sectors 13-64 - Obligation |  | 1d | 2020-10-01 A | 2020-10-01 A | S233700, S101015 SS, S101000 | 100% |  |  |  |  |  |  |  | Obligation Resource [155680 h] | 155,680.29 | S233800 | 0 | S206400 | S277591444 |  |  | Not Started | A-TEC | Mannel, Eric |  | Procurement | PP5 | MP105920 | Eric Mannel | BNL |  | POM02.1.05.02.02 |  |  |  |  | 02 |  |  | L5 |  |  |  |  |  | OBLG |  |
| OBLG229110 |  | Fabricate EMCAL Production Preamp Boards Sectors 13-64 - Obligation |  | 1d | 2020-10-09 A | 2020-10-20 A | S229000, S101000 | 100% |  | 2020-12-10 | 2020-12-10 |  |  |  |  | Obligation Resource [549642 h] | 549,642.14 | S229100 | 0 | S204100 | S204100 |  |  | Not Started | A-TEC | Mannel, Eric |  | Procurement | PP5 | MP105800 | Eric Mannel | BNL |  | POM02.1.05.02.02 |  |  |  |  | 02 |  |  | L5 |  |  |  |  |  | OBLG |  |
| S228900 |  | Fabricate EMCAL Production Preamp Boards Sectors 13-64 - Vendor Responses |  | 10d | 2020-10-14 A | 2020-10-20 A | S228800 | 100% |  | 2020-11-02 | 2020-11-16 |  |  |  |  |  |  | S228900 | 0 | S203900 | S203900 |  | NOCA | Not Started |  | Mannel, Eric |  | Procurement | PP3 | MP105800 | Eric Mannel | BNL |  | POM02.1.05.02.02 |  |  |  |  | 02 |  |  |  |  |  |  |  |  |  |  |
| S229000 |  | Fabricate EMCAL Production Preamp Boards Sectors 13-64 - Vendor Selection |  | 15d | 2020-10-14 A | 2020-10-20 A | S228900 | 100% |  | 2020-11-17 | 2020-12-09 |  |  |  |  |  |  | S229000 | 0 | S204000 | S204000 |  | NOCA | Not Started |  | Mannel, Eric |  | Procurement | PP4 | MP105800 | Eric Mannel | BNL |  | POM02.1.05.02.02 |  |  |  |  | 02 |  |  |  |  |  |  |  |  |  |  |
| S229100 |  | Fabricate EMCAL Production Preamp Boards Sectors 13-64 - Contract Award(s) | milestone | 0d | 2020-10-14 A | 2020-10-14 A | S229000, S101000 | 100% |  | 2020-12-10 | 2020-12-10 |  |  |  |  |  |  | S229100 | 0 | S204100 | S204100 |  | NOCA | Not Started | A-TEC | Mannel, Eric |  | Procurement | PP5 | MP105800 | Eric Mannel | BNL |  | POM02.1.05.02.02 |  |  |  |  | 02 |  |  | L5 | Contract Award | UDF_G2 | UDF_G1 |  |  |  |  |
| S230100 |  | Fabricate EMCAL Interface Board Sectors 13-64 - Delivery Acceptance |  | 5d | 2020-10-26 A | 2020-12-31 A | S230000 | 100% |  | 2020-11-02 | 2020-11-06 |  |  |  |  | Material (Purchase (1st $2M) [187690 h] | 217,848.84 | S230100 | 0 | S205700 | S205700 | S230100 | CA | Not Started | A-TEC | Mannel, Eric | M3 | Fab & Assy | PP6 | MP105700 | Eric Mannel | BNL | TEC | POM02.1.05.02.02 | C | 1.05 | 59715 | 1.05A | 02 | 190322 ELM BNL Units; 190317 ELM BLNU per L2 |  |  | Delivery | UDF_G1 | UDF_G1 | 217848.838144 | 1 | FAB |  |
| S234200 |  | EMCal Crates for Controllers - M&S |  | 140d | 2020-10-26 A | 2021-05-28 A | S234100 SS | 100% |  | 2020-11-02 | 2021-05-25 |  |  |  |  | Material (Purchase (1st $2M) [5332 h] | 5,948.45 | S234200 | 0 | S206600 | S277592804 | S234200 | CA | Not Started | A-TEC | Mannel, Eric | M3 | Fab & Assy |  | TBD | Eric Mannel | BNL | TEC | POM02.1.05.02.02 | C | 1.05 | 59715 | 1.05A | 02 | 190317 ELM BLNU per L2 | 003 |  |  | UDF_G1 | UDF_G3 | 5948.451289 | 1 |  | Yes |
| S229200 |  | Fabricate EMCAL Production Preamp Boards Sectors 13-64 - Contract/PO - Leadtime |  | 60d | 2020-11-23 A | 2021-02-26 A | S229100 SS, OBLG229110 SS | 100% |  | 2020-12-01 | 2021-02-26 |  |  |  |  |  |  | S229200 | 0 | S204200 | S204200 |  | NOCA | Not Started |  | Mannel, Eric |  | Fab & Assy | PP6 | MP105800 | Eric Mannel | BNL |  | POM02.1.05.02.02 |  |  |  |  | 02 |  |  |  |  |  |  |  |  |  |  |
| S227605 |  | Fabricate SiPM Daughter Boards Sectors 13-64 - Delivery Acceptance |  | 2d | 2020-12-01 A | 2021-04-30 A | S227600 | 100% |  | 2020-12-01 | 2020-12-02 |  |  | start on or after 2020-11-02 |  | Material (Purchase (1st $2M) [20801 h] | 23,205.88 | S227600 | 0 | S207300 | S207300 | S227605 | CA | Not Started | A-TEC | Mannel, Eric | M4 | Fab & Assy | PP6 | MP105500 | Eric Mannel | BNL | TEC | POM02.1.05.02.02 | C | 1.05 | 59715 | 1.05A | 02 |  | 014 |  | Delivery | UDF_G1 | UDF_G3 | 75665.010169 | 1 | FAB |  |
| S228100 |  | Test SiPM Daughter Boards Production Sectors 13-64 |  | 160d | 2020-12-01 A | 2021-07-20 | S227540 FF+10d, S227500 SS+40d, S245100 SS, OBLG245110 | 55% | 35d |  |  | 133d | 0d |  | 2021-07-20 | STUDENT UM - Purchased Services [176 h] | 2,893.36 | S228100 | 0 | S209900 | S209900 | S228100 | CA | Not Started | A-TEC | Mannel, Eric | L4 | Test_System |  |  | Eric Mannel | BNL | null | POM02.1.05.02.02 | C | 1.05 | 59715 | 1.05A | 02 | 190313 ELM Activity split for fund src | 003 |  |  |  |  |  |  |  | Yes |
| S228110 |  | Test SiPM Daughter Boards Production Sectors 13-64 - Contributed Labor |  | 160d | 2020-12-01 A | 2021-07-20 | S227540 FF+10d, S227500 SS+40d | 55% | 35d |  |  | 133d | 0d |  | 2021-07-20 | PROF3 PO E [321 h]; SCI3 PO [80 h]; TECH3 PO E [80 h]; SCI2 UM - Unpaid [176 h]; STUDENT GRAD UM - Unpaid [176 h] | 65,413.02 | S228100 | 0 | S209900 | S209900 | S228110 | CA | Not Started | B_T | Mannel, Eric | L4 | Test_System |  |  | Eric Mannel | BNL | null | POM02.1.05.02.02 | C | 1.05 | 16712 | 1.05B | 02 | 190313 ELM Activity split for fund src | 003 |  |  |  |  |  |  |  | Yes |
| S230200 |  | Test EMCal Interface Boards: Production Sectors 13-64 |  | 80d | 2020-12-01 A | 2020-12-30 A | S230100, S245100 SS, OBLG245110 | 100% |  | 2020-12-01 | 2021-03-26 |  |  |  |  | STUDENT UM - Purchased Services [384 h] | 6,312.8 | S230200 | 0 | S210000 | S277591684 | S230200 | CA | Not Started | A-TEC | Mannel, Eric | L4 | Test_System |  |  | Eric Mannel | BNL | null | POM02.1.05.02.02 | C | 1.05 | 59715 | 1.05A | 02 | 190313 ELM Activity split for fund src | 003 |  |  |  |  |  |  |  | Yes |
| S230205 |  | Test EMCal Interface Boards: Production Sectors 13-64 - Contributed Labor |  | 80d | 2020-12-01 A | 2020-12-30 A | S230100 | 100% |  | 2020-12-01 | 2021-03-26 |  |  |  |  | TECH3 PO E [96 h]; PROF3 PO E [153 h] | 31,221.04 | S230200 | 0 | S210000 | S277591684 | S230205 | CA | Not Started | B | Mannel, Eric | L4 | Test_System |  |  | Eric Mannel | BNL | null | POM02.1.05.02.02 | C | 1.05 | 16712 | 1.05B | 02 | 190313 ELM Activity split for fund src | 003 |  |  |  |  |  |  |  | Yes |
| S233300 |  | Assemble Power Cables |  | 5d | 2020-12-08 A | 2020-12-29 A | S231800, S233200, S231900, S244450, S233250 | 100% |  | 2021-08-04 | 2021-08-10 |  |  |  |  | PROF3 PO E [32 h]; SCI3 PO [32 h]; TECH3 PO E [16 h] | 11,723.09 | S233300 | 0 | S206000 | S277591564 | S233300 | CA | Not Started | B | Mannel, Eric | L2 | Procurement |  |  | Eric Mannel | BNL | null | POM02.1.05.02.02 | C | 1.05 | 16712 | 1.05B | 02 |  |  |  |  |  |  |  |  |  |  |
| S231800 |  | Procure Internal EMCal Signal/Test/Comm and LV/Bias: Production - Delivery Acceptance |  | 5d | 2020-12-31 A | 2021-05-28 A | S231700 | 100% |  | 2020-12-31 | 2021-01-07 |  |  |  |  | Material (Purchase (1st $2M) [248296 h] | 288,193.27 | S231800 | 0 | S205800 | S205800 | S231800 | CA | Not Started | A-TEC | Mannel, Eric | M3 | Fab & Assy | PP6 | MP202800 | Eric Mannel | BNL | TEC | POM02.1.05.02.02 | C | 1.05 | 59715 | 1.05A | 02 | 190322 ELM BNL Units; 190317 ELM BLNU per L2 | 003 |  | Delivery | UDF_G1 | UDF_G3 | 288193.271436 | 1 | FAB |  |
| S232600 |  | Procure EMCal External LV/Bias Signal/Comm/Test Cables Sectors 13-64 - Provide Requirements to Procurement |  | 5d | 2021-02-22 A | 2021-06-28 | S226901 | 90% | 20d | 2021-03-01 | 2021-03-05 | 5d | 0d |  | 2021-06-28 | PROF3 PO E [32 h]; SCI3 PO [32 h]; TECH3 PO E [16 h] | 11,723.09 | S232600 | 0 | S206000 | S277591004 | S232600 | CA | Not Started | B | Mannel, Eric | L2 | Procurement | PP1 | MP105910 | Eric Mannel | BNL | null | POM02.1.05.02.02 | C | 1.05 | 16712 | 1.05B | 02 | 190317 ELM name per GRY | 003 |  |  |  |  |  |  |  |  |
| S234000 |  | Procure EMCal Bias Power System Sectors 13-64 - Delivery Acceptance |  | 5d | 2021-02-22 A | 2021-03-15 A | S233900 | 100% |  | 2021-03-01 | 2021-03-05 |  |  |  |  | Material (Purchase (1st $2M) [134128 h] | 155,680.27 | S234000 | 0 | S206600 | S277591524 | S234000 | CA | Not Started | A-TEC | Mannel, Eric | M3 | Fab & Assy | PP6 | MP105920 | Eric Mannel | BNL | TEC | POM02.1.05.02.02 | C | 1.05 | 59715 | 1.05A | 02 | 190317 ELM BLNU per L2 | 003 |  | Delivery | UDF_G3 | UDF_G3 | 155680.265132 | 1 | FAB |  |
| S229300 |  | Fabricate EMCAL Production Preamp Boards Sectors 13-64 - Delivery Acceptance |  | 5d | 2021-02-26 A | 2021-05-28 A | S229200 | 100% |  | 2021-03-01 | 2021-03-05 |  |  |  |  | Material (Purchase (1st $2M) [473550 h] | 549,642.06 | S229300 | 0 | S204300 | S204300 | S229300 | CA | Not Started | A-TEC | Mannel, Eric | M3 | Fab & Assy | PP6 | MP105800 | Eric Mannel | BNL | TEC | POM02.1.05.02.02 | C | 1.05 | 59715 | 1.05A | 02 | 190317 ELM BLNU per L2 | 003 |  | Delivery | UDF_G1 | UDF_G1 | 549642.055 | 1 | FAB |  |
| S229400 |  | Test EMCal Preamp Boards: Production Sectors 13-64 |  | 80d | 2021-02-26 A | 2021-06-14 | S229300, S245100 SS, OBLG245110 | 30% | 10d | 2021-03-08 | 2021-06-28 | 0d |  |  | 2021-06-14 | STUDENT UM - Purchased Services [384 h] | 6,312.8 | S229400 | 0 | S210000 | S210000 | S229400 | CA | Not Started | A-TEC | Mannel, Eric | L4 | Test_System |  |  | Eric Mannel | BNL | null | POM02.1.05.02.02 | C | 1.05 | 59715 | 1.05A | 02 | 190313 ELM Activity split for fund src | 015 |  |  |  |  |  |  |  | Yes |

Notes:
- S231200: BNL_UDF_Adhoc Comments: 180330 ELM desc, add proc strg per EJM, GRY / BNL_UDF_Old Activity Name 181221: Procure Internal EMCal Signal/Test/Comm and LV/Bias Cables: Production - Provide Requirements to Procurement
- S227000: BNL_UDF_Adhoc Comments: 180406 ELM pred/succ per GRY; 180329 ELM name per EJM, GRY / BNL_UDF_Old Activity Name 181221: Fabricate SiPM Daughter Boards Sectors 13-64 - Provide Requirements to Procurement
- S227200: BNL_UDF_Adhoc Comments: 180329 ELM name per EJM, GRY / BNL_UDF_Old Activity Name 181221: Fabricate SiPM Daughter Boards Sectors 13-64 - Vendor Responses
- S227100: BNL_UDF_Adhoc Comments: 180329 ELM name per EJM, GRY / BNL_UDF_Old Activity Name 181221: Fabricate SiPM Daughter Boards Sectors 13-64 - Prepare & Send Solicitation
- S231500: BNL_UDF_Adhoc Comments: 180330 ELM add proc strg per EJM, GRY / BNL_UDF_Old Activity Name 181221: Procure Internal EMCal Signal/Test/Comm and LV/Bias: Production - Vendor Selection
- S231400: BNL_UDF_Adhoc Comments: 180330 ELM add proc strg per EJM, GRY / BNL_UDF_Old Activity Name 181221: Procure Internal EMCal Signal/Test/Comm and LV/Bias: Production - Vendor Solicitation
- S227300: BNL_UDF_Adhoc Comments: 180329 ELM name per EJM, GRY / BNL_UDF_Old Activity Name 181221: Fabricate SiPM Daughter Boards Sectors 13-64 - Vendor Selection
- S231300: BNL_UDF_Adhoc Comments: 180330 ELM add proc strg per EJM, GRY / BNL_UDF_Old Activity Name 181221: Procure Internal EMCal Signal/Test/Comm and LV/Bias: Production - Prepare & Send Solicitation
- S226700: BNL_UDF_Adhoc Comments: 180329 ELM pred per GRY / BNL_UDF_Old Activity Name 181221: Production Readiness and Safety Review: EMCal Production Electronics
- S233400: BNL_UDF_Adhoc Comments: 180330 ELM desc, per EJM, GRY / BNL_UDF_Old Activity Name 181221: Procure EMCal Bias Power System Sectors 13-64 - Provide Requirements to Procurement
- S233500: BNL_UDF_Adhoc Comments: 180330 ELM desc, per EJM, GRY / BNL_UDF_Old Activity Name 181221: Procure EMCal Bias Power System Sectors 13-64 - Prepare & Send Solicitation
- S233600: BNL_UDF_Adhoc Comments: 180330 ELM desc, per EJM, GRY / BNL_UDF_Old Activity Name 181221: Procure EMCal Bias Power System Sectors 13-64 - Vendor Responses
- S233700: BNL_UDF_Adhoc Comments: 180330 ELM desc, per EJM, GRY / BNL_UDF_Old Activity Name 181221: Procure EMCal Bias Power System Sectors 13-64 - Vendor Selection
- S233800: BNL_UDF_Adhoc Comments: 180330 ELM desc, per EJM, GRY / BNL_UDF_Old Activity Name 181221: Procure EMCal Bias Power System Sectors 13-64 - Contract Award(s)
- S233900: BNL_UDF_Adhoc Comments: 180330 ELM desc, per EJM, GRY / BNL_UDF_Old Activity Name 181221: Procure EMCal Bias Power System Sectors 13-64 - Contract/PO - Leadtime
- S226800: General Comments: 180420 GYoung: concerning / Production Readiness and Safety Review - Safety here refers to BNL check / that designs are safe to operate before fabricating / them / BNL_UDF_Old Activity Name 181221: Production Readiness & Safety Review: EMCal Electronics
- S231900: BNL_UDF_Adhoc Comments: 180330 ELM desc, per EJM, GRY / BNL_UDF_Old Activity Name 181221: Procure EMCal External Signal/Comm/Test (& pulse splitter) Cables Sectors 13-64 - Provide Requirements to Procurement
- S227500: BNL_UDF_Adhoc Comments: 180329 ELM name per EJM, GRY / BNL_UDF_Old Activity Name 181221: Fabricate SiPM Daughter Boards Sectors 13-64 - Contract/PO - Leadtime
- S227600: BNL_UDF_Adhoc Comments: 180329 ELM name per EJM, GRY / BNL_UDF_Old Activity Name 181221: Fabricate SiPM Daughter Boards Sectors 13-64 - Delivery Acceptance
- S227400: BNL_UDF_Adhoc Comments: 180329 ELM name per EJM, GRY / BNL_UDF_Old Activity Name 181221: Fabricate SiPM Daughter Boards Sectors 13-64 - Contract Award(s)
- S227510: BNL_UDF_Adhoc Comments: 180329 ELM desc per EJM / BNL_UDF_Old Activity Name 181221: 25% EMCal SiPM Daughter Boards Delivered: Production Sectors 13-64
- S227520: BNL_UDF_Adhoc Comments: 180329 ELM desc per EJM / BNL_UDF_Old Activity Name 181221: 50% EMCal SiPM Daughter Boards Delivered: Production Sectors 13-64
- S231600: BNL_UDF_Adhoc Comments: 180330 ELM add proc strg per EJM, GRY / BNL_UDF_Old Activity Name 181221: Procure Internal EMCal Signal/Test/Comm and LV/Bias: Production - Contract Award(s)
- S231700: BNL_UDF_Adhoc Comments: 180330 ELM add proc strg per EJM, GRY / BNL_UDF_Old Activity Name 181221: Procure Internal EMCal Signal/Test/Comm and LV/Bias: Production - Contract PO / Leadtime
- S226900: BNL_UDF_Adhoc Comments: 180329 ELM desc per GRY / BNL_UDF_Old Activity Name 181221: Respond to Results of EMCal Production Readiness and Safety Review
- S229500: BNL_UDF_Adhoc Comments: 180330 pred per GRY; 180329 ELM desc per EJM, GRY / BNL_UDF_Old Activity Name 181221: Fabricate EMCAL Interface Board Sectors 13-64 - Provide Requirements to Fabricator
- S229600: BNL_UDF_Adhoc Comments: 180329 ELM desc per EJM, GRY / BNL_UDF_Old Activity Name 181221: Fabricate EMCAL Interface Board Sectors 13-64 - Prepare & Send Solicitation
- S229700: BNL_UDF_Adhoc Comments: 180329 ELM desc per EJM, GRY / BNL_UDF_Old Activity Name 181221: Fabricate EMCAL Interface Board Sectors 13-64 - Vendor Responses
- S227530: BNL_UDF_Adhoc Comments: 180329 ELM desc per EJM / BNL_UDF_Old Activity Name 181221: 75% EMCal SiPM Daughter Boards Delivered: Production Sectors 13-64
- S229800: BNL_UDF_Adhoc Comments: 180329 ELM desc per EJM, GRY / BNL_UDF_Old Activity Name 181221: Fabricate EMCAL Interface Board Sectors 13-64 - Vendor Selection
- S228190: BNL_UDF_Adhoc Comments: 180329 ELM desc per EJM / BNL_UDF_Old Activity Name 181221: 25% EMCal SiPM Daughter Boards Tested: Production Sectors 13-64
- S229900: BNL_UDF_Adhoc Comments: 180329 ELM desc per EJM, GRY / BNL_UDF_Old Activity Name 181221: Fabricate EMCAL Interface Board Sectors 13-64 - Contract Award(s)
- S230000: BNL_UDF_Adhoc Comments: 180329 ELM desc per EJM, GRY / BNL_UDF_Old Activity Name 181221: Fabricate EMCAL Interface Board Sectors 13-64 - Contract/PO - Leadtime
- S226901: BNL_UDF_Adhoc Comments: 180329 ELM desc per GRY / BNL_UDF_Old Activity Name 181221: Respond to Results of EMCal Production Readiness and Safety Review
- S228700: BNL_UDF_Adhoc Comments: 180329 ELM desc per EJM, GRY / BNL_UDF_Old Activity Name 181221: Fabricate EMCAL Production Preamp Boards Sectors 13-64 - Provide Requirements to Procure & Assem
- S230400: BNL_UDF_Adhoc Comments: 180329 ELM name, dur pred, succ per EJM, GRY / BNL_UDF_Old Activity Name 181221: Fabricate Calorimeter Production Controller Boards - Provide Requirements to Procurement
- S230500: BNL_UDF_Adhoc Comments: 180329 ELM name, dur pred, succ per EJM, GRY / BNL_UDF_Old Activity Name 181221: Fabricate Calorimeter Production Controller Boards M&S - Prepare & Send Solicitation
- S230600: BNL_UDF_Adhoc Comments: 180329 ELM name, dur pred, succ per EJM, GRY / BNL_UDF_Old Activity Name 181221: Fabricate Calorimeter Production Controller Boards - Vendor Responses
- S230700: BNL_UDF_Adhoc Comments: 180329 ELM name, dur pred, succ per EJM, GRY / BNL_UDF_Old Activity Name 181221: Fabricate Calorimeter Production Controller Boards - Vendor Selection
- S230800: BNL_UDF_Adhoc Comments: 180329 ELM name, dur pred, succ per EJM, GRY / BNL_UDF_Old Activity Name 181221: Fabricate Calorimeter Production Controller Boards - Contract Award(s)
- S230900: BNL_UDF_Adhoc Comments: 180329 ELM name, dur pred, succ per EJM, GRY / BNL_UDF_Old Activity Name 181221: Fabricate Calorimeter Production Controller Boards - Contract/PO - Leadtime
- S231000: BNL_UDF_Adhoc Comments: 180329 ELM name, dur pred, succ per EJM, GRY / BNL_UDF_Old Activity Name 181221: Fabricate Calorimeter Production Controller Boards - Delivery Acceptance
- S231100: BNL_UDF_Adhoc Comments: 180423 ELM rsrc per GRY; 180329 ELM desc per EJM, GRY / BNL_UDF_Old Activity Name 181221: Test Calorimeter Controller Boards: Production Sectors 13-64
- S231105: BNL_UDF_Adhoc Comments: 180423 ELM rsrc per GRY; 180329 ELM desc per EJM, GRY / BNL_UDF_Old Activity Name 181221: Test Calorimeter Controller Boards: Production Sectors 13-64
- S234100: BNL_UDF_Adhoc Comments: 180330 ELM desc, per EJM, GRY / BNL_UDF_Old Activity Name 181221: EMCal Low Voltage Power System Sectors 13-64 - M&S
- OBLG227410: BNL_UDF_Adhoc Comments: 180329 ELM name per EJM, GRY / BNL_UDF_Old Activity Name 181221: Fabricate SiPM Daughter Boards Sectors 13-64 - Contract Award(s)
- OBLG229910: BNL_UDF_Adhoc Comments: 180329 ELM desc per EJM, GRY / BNL_UDF_Old Activity Name 181221: Fabricate EMCAL Interface Board Sectors 13-64 - Contract Award(s)
- OBLG230810: BNL_UDF_Adhoc Comments: 180329 ELM name, dur pred, succ per EJM, GRY / BNL_UDF_Old Activity Name 181221: Fabricate Calorimeter Production Controller Boards - Contract Award(s)
- OBLG231610: BNL_UDF_Adhoc Comments: 180330 ELM add proc strg per EJM, GRY / BNL_UDF_Old Activity Name 181221: Procure Internal EMCal Signal/Test/Comm and LV/Bias: Production - Contract Award(s)
- S228800: BNL_UDF_Adhoc Comments: 180329 ELM desc per EJM, GRY / BNL_UDF_Old Activity Name 181221: Fabricate EMCAL Production Preamp Boards Sectors 13-64 - Prepare & Send Solicitation
- OBLG233810: BNL_UDF_Adhoc Comments: 180330 ELM desc, per EJM, GRY / BNL_UDF_Old Activity Name 181221: Procure EMCal Bias Power System Sectors 13-64 - Contract Award(s)
- OBLG229110: BNL_UDF_Adhoc Comments: 180329 ELM desc per EJM, GRY / BNL_UDF_Old Activity Name 181221: Fabricate EMCAL Production Preamp Boards Sectors 13-64 - Contract Award(s)
- S228900: BNL_UDF_Adhoc Comments: 180329 ELM desc per EJM, GRY / BNL_UDF_Old Activity Name 181221: Fabricate EMCAL Production Preamp Boards Sectors 13-64 - Vendor Responses
- S229000: BNL_UDF_Adhoc Comments: 180329 ELM desc per EJM, GRY / BNL_UDF_Old Activity Name 181221: Fabricate EMCAL Production Preamp Boards Sectors 13-64 - Vendor Selection
- S229100: BNL_UDF_Adhoc Comments: 180329 ELM desc per EJM, GRY / BNL_UDF_Old Activity Name 181221: Fabricate EMCAL Production Preamp Boards Sectors 13-64 - Contract Award(s)
- S230100: BNL_UDF_Adhoc Comments: 180329 ELM desc per EJM, GRY / BNL_UDF_Old Activity Name 181221: Fabricate EMCAL Interface Board Sectors 13-64 - Delivery Acceptance
- S234200: BNL_UDF_Adhoc Comments: 180330 ELM desc, per EJM, GRY / BNL_UDF_Old Activity Name 181221: EMCal Crates for Controllers - M&S
- S229200: BNL_UDF_Adhoc Comments: 180329 ELM desc per EJM, GRY / BNL_UDF_Old Activity Name 181221: Fabricate EMCAL Production Preamp Boards Sectors 13-64 - Contract/PO - Leadtime
- S227605: BNL_UDF_Adhoc Comments: 180329 ELM name per EJM, GRY / BNL_UDF_Old Activity Name 181221: Fabricate SiPM Daughter Boards Sectors 13-64 - Delivery Acceptance
- S228100: BNL_UDF_Adhoc Comments: 180423 ELM rsrc per GRY; 180226 ELM add activity in lieu of lag per CL / BNL_UDF_Old Activity Name 181221: Test SiPM Daughter Boards Production Sectors 13-64
- S228110: BNL_UDF_Adhoc Comments: 180423 ELM rsrc per GRY; 180226 ELM add activity in lieu of lag per CL / BNL_UDF_Old Activity Name 181221: Test SiPM Daughter Boards Production Sectors 13-64
- S230200: BNL_UDF_Adhoc Comments: 180423 ELM rsrc per GRY; 180410 ELM pred/succ per GRY; 180329 ELM desc per EJM / BNL_UDF_Old Activity Name 181221: Test EMCal Interface Boards: Production Sectors 13-64
- S230205: BNL_UDF_Adhoc Comments: 180423 ELM rsrc per GRY; 180410 ELM pred/succ per GRY; 180329 ELM desc per EJM / BNL_UDF_Old Activity Name 181221: Test EMCal Interface Boards: Production Sectors 13-64
- S233300: BNL_UDF_Adhoc Comments: 180330 ELM desc, per EJM, GRY / BNL_UDF_Old Activity Name 181221: Assemble Power Cables
- S231800: BNL_UDF_Adhoc Comments: 180417 ELM pred/succ per GRY; 180330 ELM desc, add proc strg per EJM, GRY / BNL_UDF_Old Activity Name 181221: Procure Internal EMCal Signal/Test/Comm and LV/Bias: Production - Delivery Acceptance
- S232600: BNL_UDF_Adhoc Comments: 180330 ELM desc, per EJM, GRY / BNL_UDF_Old Activity Name 181221: Procure EMCal External LV/Bias Cables Sectors 13-64 - Provide Requirements to Procurement
- S234000: BNL_UDF_Adhoc Comments: 180330 ELM desc, per EJM, GRY / BNL_UDF_Old Activity Name 181221: Procure EMCal Bias Power System Sectors 13-64 - Delivery Acceptance
- S229300: BNL_UDF_Adhoc Comments: 180330 ELM pre per GRY; 180329 ELM desc per EJM, GRY / BNL_UDF_Old Activity Name 181221: Fabricate EMCAL Production Preamp Boards Sectors 13-64 - Delivery Acceptance
- S229400: BNL_UDF_Adhoc Comments: 180423 ELM rsrc per GRY; 180410 ELM pred/succ per GRY; 180329 ELM desc per EJM / BNL_UDF_Old Activity Name 181221: Test EMCal Preamp Boards: Production Sectors 13-64

| ID | WBS | Activity | Type | Duration | Start | Finish | Predecessors | Complete | Remaining | Planned start | Planned finish | Total float | Free float | Expected finish | Resources | Cost | BNL_UDF_Temp Text 01 | BNL_UDF_Percent Complete | BNL_UDF_OPC TEC (deprecated) | BNL_UDF_Old Activity ID 181221 | BNL_Cobra WP | RG Check | BNL_Activity Status | BNL_Fund Source | BNL_Estimator | BNL_Cost Basis | BNL_EDIA | BNL_CAM | BNL_Institution | BNL_OPC TEC (deprecated) | BNL_WBS | BNL_EVT | BNL_Master Control Account | BNL_Account Number | BNL_PCR ID | BNL_Cobra Control Account | BNL_WBS_Hierarchical | Additional EVT documentation required | Indicator - Procurement | Indicator - Float | BNL_Milestone Level | BNL_Proc Sig Phase | BNL_Proc Sig | Target Milestone Date | Variance | PMP Milestones | BNL_UDF_Remaining Tot Cost | BNL_UDF_Percent_remaining | BNL_Obligation | SPH Proc Register | BNL_R&D FY18-19 | Completed | BNL_UDF_Temp Date 01 | BNL_DOE OPC |
| --- | --- | --- | --- | --- | --- | --- | --- | --- | --- | --- | --- | --- | --- | --- | --- | --- | --- | --- | --- | --- | --- | --- | --- | --- | --- | --- | --- | --- | --- | --- | --- | --- | --- | --- | --- | --- | --- | --- | --- | --- | --- | --- | --- | --- | --- | --- | --- | --- | --- | --- | --- | --- | --- | --- |
| S229405 |  | Test EMCal Preamp Boards: Production Sectors 13-64 - Contributed Labor |  | 80d | 2021-03-29 A | 2021-06-14 | S229300 | 30% | 10d | 2021-04-06 | 2021-07-28 | 0d |  | 2021-06-14 | TECH3 PO E [96 h]; PROF3 PO E [153 h] | 31,221.04 | S229400 | 0 | S210000 | S210000 | S229405 | CA | Not Started | B | Mannel, Eric | L4 | Test_System | Eric Mannel | BNL | null | POM02.1.05.02.02 | C | 1.05 | 16712 | 003 | 1.05B | 02 | Yes |  |  |  |  |  |  |  |  |  |  |  |  |  |  |  |  |
| S227550 |  | 100% EMCal SiPM Daughter Boards Delivered: Production Sectors 13-64 |  | 32d | 2021-04-01 A | 2021-04-30 A | S227540, S216400, S216405 | 100% |  | 2021-05-17 | 2021-06-30 |  |  |  |  |  | S228000 | 0 | S209300 | S209300 |  | NOCA | Not Started |  | Mannel, Eric |  | Fab & Assy | Eric Mannel | BNL |  | POM02.1.05.02.02 |  |  |  | 003 |  | 02 |  | UDF_G3 | UDF_G3 | L3 |  |  |  |  |  |  |  |  |  |  |  |  |  |
| S227540 |  | 80% EMCal SiPM Daughter Boards Delivered: Production Sectors 13-64 |  | 32d | 2021-04-01 A | 2021-04-30 A | S227530, S216310, S216315 | 100% |  | 2021-04-01 | 2021-05-14 |  |  |  |  |  | S228000 | 0 | S209300 | S209300 |  | NOCA | Not Started |  | Mannel, Eric |  | Fab & Assy | Eric Mannel | BNL |  | POM02.1.05.02.02 |  |  |  | 003 |  | 02 |  | UDF_G3 | UDF_G3 | L3 |  |  |  |  |  |  |  |  |  |  |  |  |  |
| S228200 |  | 20% EMCal SiPM Daughter Boards Tested: Production Sectors 13-64 | milestone | 0d | 2021-04-01 A | 2021-04-01 A | S227510 FS+20d | 100% |  |  |  |  |  |  |  |  | S228200 | 0 | S210200 | S210200 |  | NOCA | Not Started |  | Mannel, Eric |  | Test_System | Eric Mannel | BNL |  | POM02.1.05.02.02 |  |  |  | 003 |  | 02 |  | UDF_G3 | UDF_G3 | L5 |  |  |  |  |  |  |  |  |  |  |  |  |  |
| S228300 |  | 40% EMCal SiPM Daughter Boards Tested: Production Sectors 13-64 | milestone | 0d | 2021-04-01 A | 2021-04-01 A | S227520 FS+20d | 100% |  |  |  |  |  |  |  |  | S228300 | 0 | S210300 | S210300 |  | NOCA | Not Started |  | Mannel, Eric |  | Test_System | Eric Mannel | BNL |  | POM02.1.05.02.02 |  |  |  | 003 |  | 02 |  | UDF_G3 | UDF_G3 | L5 |  |  |  |  |  |  |  |  |  |  |  |  |  |
| S232800 |  | Procure EMCal External LV/Bias Signal/Comm/Test Cables Sectors 13-64 - Vendor Responses |  | 10d | 2021-04-14 A | 2021-07-27 | S232700 SS | 50% | 40d | 2021-07-14 | 2021-07-27 | 5d | 0d | 2021-07-27 |  |  | S232800 | 0 | S206200 | S277591084 |  | NOCA | Not Started |  | Mannel, Eric |  | Procurement | Eric Mannel | BNL |  | POM02.1.05.02.02 |  |  |  | 003 |  | 02 |  |  |  |  | PP3 | MP105910 |  |  |  |  |  |  |  |  |  |  |  |
| S232700 |  | Procure EMCal External LV/Bias Signal/Comm/Test Cables Sectors 13-64 - Prepare & Send Solicitation |  | 30d | 2021-04-23 A | 2021-07-13 | S232600 SS | 50% | 30d | 2021-06-01 | 2021-07-13 | 5d | 0d | 2021-07-13 |  |  | S232700 | 0 | S206100 | S277591044 |  | NOCA | Not Started |  | Mannel, Eric |  | Procurement | Eric Mannel | BNL |  | POM02.1.05.02.02 |  |  |  | 003 |  | 02 |  |  |  |  | PP2 | MP105910 |  |  |  |  |  |  |  |  |  |  |  |
| S228600 |  | EMCal SiPM Boards Production Complete | milestone | 0d | 2021-04-30 A | 2021-04-30 A | S228500 FF | 100% |  | 2021-06-30 | 2021-06-30 |  |  |  |  |  | S228600 | 0 | S210500 | S210550 |  | NOCA | Not Started |  | Mannel, Eric |  | Test_System | Eric Mannel | BNL |  | POM02.1.05.02.02 |  |  |  |  |  | 02 |  | UDF_G3 | UDF_G3 | L2 |  |  | 2021-05-27 | 19 | PMP_1x |  |  |  |  |  |  |  |  |
| S232500 |  | Fabricate Test-pulse Boards 13 - 64 - M&S |  | 5d | 2021-05-17 A | 2021-05-28 A | S101000, S226901 | 100% |  | 2021-06-01 | 2021-06-07 |  |  |  | Material (Purchase (1st $2M) [7050 h] | 8,182.82 | S232500 | 0 | S206600 | S206600 | S232500 | CA | Not Started | A-TEC | Mannel, Eric | M3 | Fab & Assy | Eric Mannel | BNL | TEC | POM02.1.05.02.02 | C | 1.05 | 59715 | 003 | 1.05A | 02 |  | UDF_G1 | UDF_G3 |  |  | TBD |  |  |  | 8022.376819 | 1 |  |  |  |  |  |  |
| S228400 |  | 60% EMCal SiPM Daughter Boards Tested: Production Sectors 13-64 | milestone | 0d | 2021-05-31 A | 2021-05-31 A | S227530 FS+20d | 100% |  | 2021-06-01 | 2021-06-01 |  |  |  |  |  | S228400 | 0 | S210400 | S210400 |  | NOCA | Not Started |  | Mannel, Eric |  | Test_System | Eric Mannel | BNL |  | POM02.1.05.02.02 |  |  |  | 003 |  | 02 |  | UDF_G3 | UDF_G3 | L5 |  |  |  |  |  |  |  |  |  |  |  |  |  |
| S228450 |  | 80% EMCal SiPM Daughter Boards Tested: Production Sectors 13-64 | milestone | 0d | 2021-06-01 | 2021-06-01 | S227540 |  |  |  |  | 169d |  |  |  |  | S228400 | 0 | S210400 | S210400 |  | NOCA | Not Started |  | Mannel, Eric |  | Test_System | Eric Mannel | BNL |  | POM02.1.05.02.02 |  |  |  | 003 |  | 02 |  | UDF_G3 | UDF_G3 | L5 |  |  |  |  |  |  |  |  |  |  |  |  |  |
| S228500 |  | 100% EMCal SiPM Daughter Boards Tested: Production Sectors 13-64 | milestone | 0d | 2021-06-01 | 2021-06-01 | S227550 |  |  |  |  | 169d | 0d |  |  |  | S228500 | 0 | S210500 | S210500 |  | NOCA | Not Started |  | Mannel, Eric |  | Test_System | Eric Mannel | BNL |  | POM02.1.05.02.02 |  |  |  | 003 |  | 02 |  | UDF_G3 | UDF_G3 | L3 |  |  |  |  |  |  |  |  |  |  |  |  |  |
| S232900 |  | Procure EMCal External LV/Bias Signal/Comm/Test Cables Sectors 13-64 - Vendor Selection |  | 20d | 2021-07-28 | 2021-08-24 | S232800 |  |  |  |  | 5d | 0d |  |  |  | S232900 | 0 | S206300 | S277591124 |  | NOCA | Not Started |  | Mannel, Eric |  | Procurement | Eric Mannel | BNL |  | POM02.1.05.02.02 |  |  |  | 003 |  | 02 |  |  |  |  | PP4 | MP105910 |  |  |  |  |  |  |  |  |  |  |  |
| OBLG233010 |  | Procure EMCal External LV/Bias Cables Sectors 13-64 - Obligation |  | 1d | 2021-08-25 | 2021-08-25 | S232900, S101015 SS, S101000 |  |  |  |  | 5d | 0d |  | Obligation Resource [205854 h] | 205,854.36 | S233000 | 0 | S206400 | S277591164 |  |  | Not Started | A-TEC | Mannel, Eric |  | Procurement | Eric Mannel | BNL |  | POM02.1.05.02.02 |  |  |  |  |  | 02 |  |  |  | L5 | PP5 | MP105910 |  |  |  |  |  | OBLG |  |  |  |  |  |
| S233000 |  | Procure EMCal External LV/Bias Signal/Comm/Test Cables Sectors 13-64 - Contract Award(s) | milestone | 0d | 2021-08-25 | 2021-08-25 | S232900, S101015 SS, S101000 |  |  |  |  | 5d | 0d |  |  |  | S233000 | 0 | S206400 | S277591164 |  | NOCA | Not Started | A-TEC | Mannel, Eric |  | Procurement | Eric Mannel | BNL |  | POM02.1.05.02.02 |  |  |  | 003 |  | 02 |  | UDF_G3 | UDF_G3 | L5 | PP5 | MP105910 |  |  |  |  |  |  | Contract Award |  |  |  |  |
| S233100 |  | Procure EMCal External LV/Bias Signal/Comm/Test Cables Sectors 13-64 - Contract/PO - Leadtime |  | 100d | 2021-08-25 | 2022-01-21 | S233000 SS, OBLG233010 SS |  |  |  |  | 5d | 0d |  |  |  | S233100 | 0 | S206500 | S277591204 |  | NOCA | Not Started |  | Mannel, Eric |  | Fab & Assy | Eric Mannel | BNL |  | POM02.1.05.02.02 |  |  |  | 003 |  | 02 |  |  |  |  | PP6 | MP105910 |  |  |  |  |  |  |  |  |  |  |  |
| S233250 |  | Trunk Signal Cables - EMCal |  | 100d | 2021-08-25 | 2022-01-21 | S233000 SS |  |  |  |  | 10d | 5d |  | Material (Purchase (1st $2M) [670160 h] | 789,356.29 | S233200 | 0 | S206600 | S277591244 | S233250 | CA | Not Started | A-TEC | Mannel, Eric | M3 | Fab & Assy | Eric Mannel | BNL | TEC | POM02.1.05.02.02 | F | 1.05 | 59715 | 017 | 1.05A | 02 |  | UDF_G1 | UDF_G1 |  | PP6 | MP105910 |  |  |  | 205854.326484 | 1 | FAB | Delivery |  |  |  |  |
| S244450 |  | Trunk Signal Cables - OuterHCal |  | 100d | 2021-08-25 | 2022-01-21 | S233000 SS |  |  |  |  | 10d | 5d |  | Material (Purchase (1st $2M) [128640 h] | 151,520.22 | S233300 | 0 | S206000 | S277591564 | S244450 | CA | Not Started | A-TEC | Mannel, Eric | L2 | Procurement | Eric Mannel | BNL | null | POM02.1.05.02.02 | C | 1.05 | 16712 | 017 | 1.05A | 02 |  | UDF_G1 | UDF_G1 |  |  |  |  |  |  |  |  |  |  |  |  |  |  |
| S233200 |  | Procure EMCal External LV/Bias Signal/Comm/Test Cables Sectors 13-64 - Delivery Acceptance |  | 5d | 2022-01-24 | 2022-01-28 | S233100 |  |  |  |  | 5d | 0d |  | Material (Purchase (1st $2M) [177356 h] | 209,971.41 | S233200 | 0 | S206600 | S277591244 | S233200 | CA | Not Started | A-TEC | Mannel, Eric | M3 | Fab & Assy | Eric Mannel | BNL | TEC | POM02.1.05.02.02 | C | 1.05 | 59715 | 003 | 1.05A | 02 |  | UDF_G1 | UDF_G1 |  | PP6 | MP105910 |  |  |  | 205854.326484 | 1 | FAB | Delivery |  |  |  |  |
| S234300 |  | EMCal Electronics Complete | milestone | 0d | 2022-01-28 | 2022-01-28 | S227600 FF, S231100 FF, S230100 FF, S234000 FF, S233300 FF, S234100 FF, S234200 FF, S231000 FF, S231105 FF, S226600, S227605, S232500, S224100 |  |  |  |  | 5d | 0d |  |  |  | S234300 | 0 | S210600 | S210600 |  | NOCA | Not Started |  | Mannel, Eric |  | Fab & Assy | Eric Mannel | BNL |  | POM02.1.05.02.02 |  |  |  |  |  | 02 |  | UDF_G3 | UDF_G3 | L2 |  |  | 2021-10-28 | -61 | PMP_1x |  |  |  |  |  |  |  |  |
|  | 03 | **HCal Electronics: Preproduction** |  |  | 2018-04-15 | 2020-01-29 |  |  |  |  |  |  |  |  |  |  |  |  |  |  |  |  |  |  |  |  |  |  |  |  |  |  |  |  |  |  |  |  |  |  |  |  |  |  |  |  |  |  |  |  |  |  |  |  |
| S234400 |  | Review and Write Design Hcal Frontend Electronics Specifications: (6 Modules) |  | 25d | 2018-04-15 A | 2018-05-18 A | S100340 | 100% |  | 2018-04-16 | 2018-05-18 |  |  |  |  |  | S234400 | 100 | S210900 | S210900 |  | NOCA | Completed |  | Mannel, Eric | L2 | Design | Eric Mannel | BNL | null | POM02.1.05.02.03 | C |  |  |  |  | 03 |  |  |  |  |  |  |  |  |  |  |  |  |  | CalEl HCal FEE tests | yes |  |  |
| S234401 |  | Preliminary Design Review - HCal FEE Sectors 1-6 | milestone | 0d | 2018-05-18 A | 2018-05-18 A | S234400 FF | 100% |  |  |  |  |  |  |  |  | S234400 | 100 | S210900 | S210900 |  | NOCA | Completed |  | Mannel, Eric | L2 | Design | Eric Mannel | BNL | null | POM02.1.05.02.03 | C |  |  | 004 |  | 03 |  |  |  |  |  |  |  |  |  |  |  |  |  | CalEl HCal FEE tests | yes |  |  |
| S234600 |  | Design HCal SiPM Board: (6 Modules) |  | 73d | 2018-05-21 A | 2018-08-31 A | S234401 | 100% |  |  |  |  |  |  |  |  | S234600 | 100 | S211000 | S211000 |  | NOCA | Completed |  | Mannel, Eric | L3 | Design | Eric Mannel | BNL | null | POM02.1.05.02.03 | C |  |  |  |  | 03 |  |  |  |  |  |  |  |  |  |  |  |  |  | CalEl HCal FEE tests | yes | 2018-06-29 |  |
| S234700 |  | Layout HCal SiPM Board: (6 Modules) |  | 73d | 2018-05-21 A | 2018-08-31 A | S234600 | 100% |  |  |  |  |  |  |  |  | S234700 | 100 | S211700 | S211700 |  | NOCA | Completed |  | Mannel, Eric | L3 | Fab & Assy | Eric Mannel | BNL | null | POM02.1.05.02.03 | C |  |  |  |  | 03 |  |  |  |  |  |  |  |  |  |  |  |  |  | CalEl HCal FEE tests | yes | 2018-06-29 |  |
| S234800 |  | Design HCal Preamp: (6 Modules) |  | 73d | 2018-05-21 A | 2018-08-31 A | S234401 | 100% |  |  |  |  |  |  |  |  | S234800 | 100 | S211100 | S211100 |  | NOCA | Completed |  | Mannel, Eric | L3 | Design | Eric Mannel | BNL | null | POM02.1.05.02.03 | C |  |  |  |  | 03 |  |  |  |  |  |  |  |  |  |  |  |  |  | CalEl HCal FEE tests | yes | 2018-06-29 |  |
| S234900 |  | Layout HCal Preamp: (6 Modules) |  | 73d | 2018-05-21 A | 2018-08-31 A | S234800 | 100% |  |  |  |  |  |  |  |  | S234900 | 100 | S211800 | S211800 |  | NOCA | Completed |  | Mannel, Eric | L3 | Fab & Assy | Eric Mannel | BNL | null | POM02.1.05.02.03 | C |  |  |  |  | 03 |  |  |  |  |  |  |  |  |  |  |  |  |  | CalEl HCal FEE tests | yes | 2018-06-29 |  |
| S235000 |  | Design HCal LED Driver Board: (6 Modules) |  | 73d | 2018-05-21 A | 2018-08-31 A | S234401 | 100% |  |  |  |  |  |  |  |  | S235000 | 100 | S211200 | S211200 |  | NOCA | Completed |  | Mannel, Eric | L3 | Design | Eric Mannel | BNL | null | POM02.1.05.02.03 | C |  |  |  |  | 03 |  |  |  |  |  |  |  |  |  |  |  |  |  | CalEl HCal FEE tests | yes | 2018-06-29 |  |
| S235100 |  | Layout HCal LED Driver Board: (6 Modules) |  | 73d | 2018-05-21 A | 2018-08-31 A | S235000 | 100% |  |  |  |  |  |  |  |  | S235100 | 100 | S212000 | S212000 |  | NOCA | Completed |  | Mannel, Eric | L3 | Fab & Assy | Eric Mannel | BNL | null | POM02.1.05.02.03 | C |  |  |  |  | 03 |  |  |  |  |  |  |  |  |  |  |  |  |  | CalEl HCal FEE tests | yes | 2018-06-29 |  |
| S235200 |  | Design HCal Interface Board: (6 Modules) |  | 73d | 2018-05-21 A | 2018-08-31 A | S234401 | 100% |  |  |  |  |  |  |  |  | S235200 | 100 | S211300 | S211300 |  | NOCA | Completed |  | Mannel, Eric | L3 | Design | Eric Mannel | BNL | null | POM02.1.05.02.03 | C |  |  |  |  | 03 |  |  |  |  |  |  |  |  |  |  |  |  |  | CalEl HCal FEE tests | yes | 2018-06-29 |  |
| S235300 |  | Layout HCal Interface Board: (6 Modules) |  | 73d | 2018-05-21 A | 2018-08-31 A | S235200 | 100% |  |  |  |  |  |  |  |  | S235300 | 100 | S211900 | S211900 |  | NOCA | Completed |  | Mannel, Eric | L3 | Fab & Assy | Eric Mannel | BNL | null | POM02.1.05.02.03 | C |  |  |  |  | 03 |  |  |  |  |  |  |  |  |  |  |  |  |  | CalEl HCal FEE tests | yes | 2018-06-29 |  |
| S235400 |  | Design HCal Backplane: (6 Modules) |  | 73d | 2018-05-21 A | 2018-08-31 A | S234401 | 100% |  |  |  |  |  |  |  |  | S235400 | 100 | S211400 | S211400 |  | NOCA | Completed |  | Mannel, Eric | L3 | Design | Eric Mannel | BNL | null | POM02.1.05.02.03 | C |  |  |  |  | 03 |  |  |  |  |  |  |  |  |  |  |  |  |  | CalEl HCal FEE tests | yes | 2018-06-29 |  |
| S235500 |  | Layout HCal Backplane: (6 Modules) |  | 73d | 2018-05-21 A | 2018-08-31 A | S235400 | 100% |  |  |  |  |  |  |  |  | S235500 | 100 | S212100 | S212100 |  | NOCA | Completed |  | Mannel, Eric | L3 | Fab & Assy | Eric Mannel | BNL | null | POM02.1.05.02.03 | C |  |  |  |  | 03 |  |  |  |  |  |  |  |  |  |  |  |  |  | CalEl HCal FEE tests | yes | 2018-06-29 |  |
| S235600 |  | Specify HCal Signal and Power Cables: (6 Modules) |  | 73d | 2018-05-21 A | 2018-08-31 A | S234401 | 100% |  |  |  |  |  |  |  |  | S235600 | 100 | S211500 | S211500 |  | NOCA | Completed |  | Mannel, Eric | L3 | Procurement | Eric Mannel | BNL | null | POM02.1.05.02.03 | C |  |  |  |  | 03 |  |  |  |  |  |  |  |  |  |  |  |  |  | CalEl HCal FEE tests | yes | 2018-06-29 |  |
| S235700 |  | Design HCal power system: (6 Modules) |  | 73d | 2018-05-21 A | 2018-08-31 A | S234401 | 100% |  |  |  |  |  |  |  |  | S235700 | 100 | S211600 | S211600 |  | NOCA | Completed |  | Mannel, Eric | L3 | Design | Eric Mannel | BNL | null | POM02.1.05.02.03 | C |  |  |  |  | 03 |  |  |  |  |  |  |  |  |  |  |  |  |  | CalEl HCal FEE tests | yes | 2018-08-01 |  |
| S235800 |  | Final Design Review, Production Readiness Review, Safety Review - HCal FEE Sectors 1-6 |  | 1d | 2018-10-17 A | 2018-10-17 A | S235700 FF, S235600, S235500, S235100, S234900, S234700 | 100% |  |  |  |  |  |  |  |  | S235800 | 100 | S212300 | S212300 |  | NOCA | Completed | B | Mannel, Eric | L2 | Management Safety Reviews | Eric Mannel | BNL | null | POM02.1.05.02.03 | C |  | 16712 | 003,004 |  | 03 |  |  |  |  |  |  |  |  |  |  |  |  |  | CalEl HCal FEE tests | yes |  |  |
| S235900 |  | HCal Electronics Safety & Design Review Complete | milestone | 0d | 2018-10-17 A | 2018-10-17 A | S235800, S235300 | 100% |  |  |  |  |  |  |  |  | S235900 | 100 | S212400 | S212400 |  | NOCA | Completed |  | Mannel, Eric |  | Management Safety Reviews | Eric Mannel | BNL |  | POM02.1.05.02.03 |  |  |  |  |  | 03 |  |  |  | L5 |  |  |  |  |  |  |  |  |  | CalEl HCal FEE tests | yes |  |  |
| S236000 |  | Review Hcal Electronics Safety & Design Review Report |  | 4d | 2018-10-17 A | 2018-10-22 A | S235800, S235900 | 100% |  |  |  |  |  |  |  |  | S236000 | 100 | S212500 | S212500 |  | NOCA | Completed | B | Mannel, Eric | L2 | Management Safety Reviews | Eric Mannel | BNL | null | POM02.1.05.02.03 | C |  | 16712 |  |  | 03 |  |  |  |  |  |  |  |  |  |  |  |  |  | CalEl HCal FEE tests | yes |  |  |
| S236400 |  | Fabricate HCal Preamp Boards: (6 Modules) Labor |  | 122d | 2018-11-01 A | 2019-04-30 A | S236000 | 100% |  |  |  |  |  |  |  |  | S236400 | 100 | S212200 | S340320 |  | NOCA | Completed | B | Mannel, Eric | L2 | Procurement | Eric Mannel | BNL | null | POM02.1.05.02.03 | C |  | 16712 |  |  | 03 |  |  |  |  |  |  |  |  |  |  |  |  |  | CalEl HCal FEE tests | yes |  |  |
| S236500 |  | Fabricate HCal Preamp Boards: (6 Modules) M&S |  | 122d | 2018-11-01 A | 2019-04-30 A | S236000, S236400 SS | 100% |  |  |  |  |  |  |  |  | S236500 | 10 | S210800 | S340360 |  | NOCA | Completed | A-OPC | Mannel, Eric | M3 | Fab & Assy | Eric Mannel | BNL | OPC | POM02.1.05.02.03 | C |  | 16704 | 003 |  | 03 |  |  |  |  |  |  |  |  |  |  |  |  |  | CalEl HCal FEE tests | yes | 2019-03-28 | OPC001950 |
| S236700 |  | Fabricate HCal LED Boards: (6 Modules) Labor |  | 39d | 2019-01-02 A | 2019-02-27 A | S236000 | 100% |  |  |  |  |  |  |  |  | S236700 | 100 | S212600 | S212600 |  | NOCA | Completed | B | Mannel, Eric | L2 | Procurement | Eric Mannel | BNL | null | POM02.1.05.02.03 | C |  | 16712 |  |  | 03 | Yes |  |  |  |  |  |  |  |  |  |  |  |  | CalEl HCal FEE tests | yes |  |  |
| S237000 |  | Fabricate HCal Interface Boards: (6 Modules) Labor |  | 39d | 2019-01-02 A | 2019-02-27 A | S236000 | 100% |  |  |  |  |  |  |  |  | S237000 | 100 | S212800 | S212800 |  | NOCA | Completed | B | Mannel, Eric | L2 | Procurement | Eric Mannel | BNL | null | POM02.1.05.02.03 | C |  | 16712 |  |  | 03 | Yes |  |  |  |  |  |  |  |  |  |  |  |  | CalEl HCal FEE tests | yes |  |  |
| S237100 |  | Fabricate HCal Interface Boards: (6 Modules) M&S |  | 82d | 2019-01-02 A | 2019-04-29 A | S236000 | 100% |  |  |  |  |  |  |  |  | S237100 | 10 | S212900 | S212900 |  | NOCA | Completed | A-OPC | Mannel, Eric | M3 | Fab & Assy | Eric Mannel | BNL | OPC | POM02.1.05.02.03 | C |  | 16704 | 003 |  | 03 | Yes |  |  |  |  |  |  |  |  |  |  |  |  | CalEl HCal FEE tests | yes | 2019-04-29 | OPC001950 |
| S237300 |  | Fabricate HCal Backplane: (6 Modules) Labor |  | 39d | 2019-01-02 A | 2019-02-27 A | S236000 | 100% |  |  |  |  |  |  |  |  | S237300 | 100 | S213000 | S213000 |  | NOCA | Completed | B | Mannel, Eric | L2 | Procurement | Eric Mannel | BNL | null | POM02.1.05.02.03 | C |  | 16712 |  |  | 03 | Yes |  |  |  |  |  |  |  |  |  |  |  |  | CalEl HCal FEE tests | yes |  |  |
| S237400 |  | Fabricate HCal Backplane: (6 Modules) M&S |  | 37d | 2019-01-02 A | 2019-02-25 A | S236000 | 100% |  |  |  |  |  |  |  |  | S237400 | 100 | S213100 | S213100 |  | NOCA | Completed | A-OPC | Mannel, Eric | M3 | Fab & Assy | Eric Mannel | BNL | OPC | POM02.1.05.02.03 | C |  | 16704 | 003 |  | 03 | Yes |  |  |  |  |  |  |  |  |  |  |  |  | CalEl HCal FEE tests | yes |  | OPC001950 |
| S237600 |  | Procure Hcal Power and Signal Cables and Power System: (6 Modules) - Labor |  | 105d | 2019-01-02 A | 2019-05-31 A | S236000 | 100% |  |  |  |  |  |  |  |  | S237600 | 25 | S213200 | S213200 |  | NOCA | Completed | B | Mannel, Eric | L2 | Procurement | Eric Mannel | BNL | null | POM02.1.05.02.03 | C |  | 16712 |  |  | 03 | Yes |  |  |  |  |  |  |  |  |  |  |  |  | CalEl HCal FEE tests | yes | 2019-04-29 |  |
| S237700 |  | Procure Hcal Power and Signal Cables and Power System: (6 Modules), Phase 1 - M&S |  | 105d | 2019-01-02 A | 2019-05-31 A | S236000 | 100% |  |  |  |  |  |  |  |  | S237700 | 20 | S213300 | S213300 |  | NOCA | Completed | A-OPC | Mannel, Eric | M3 | Fab & Assy | Eric Mannel | BNL | OPC | POM02.1.05.02.03 | C |  | 16704 | 003,004 |  | 03 | Yes |  |  |  |  |  |  |  |  |  |  |  |  | CalEl HCal FEE tests | yes | 2019-04-25 | OPC001950 |
| S237500 |  | Test HCal Backplane: (6 Modules) |  | 16d | 2019-02-01 A | 2019-02-25 A | S237300, S237400 | 100% |  |  |  |  |  |  |  |  | S237500 | 100 | S213700 | S338980 |  | NOCA | Completed | B_T | Mannel, Eric | L4 | Fab & Assy | Eric Mannel | BNL | null | POM02.1.05.02.03 | C |  | 16712 |  |  | 03 |  |  |  |  |  |  |  |  |  |  |  |  |  | CalEl HCal FEE tests | yes |  |  |
| S236100 |  | Fabricate HCal SiPM Boards: (6 Modules) Labor |  | 39d | 2019-04-08 A | 2019-05-31 A | S236000, S213200, S213205 | 100% |  |  |  |  |  |  |  |  | S236100 | 0 | S212200 | S212200 |  | NOCA | Completed | B | Mannel, Eric | L2 | Procurement | Eric Mannel | BNL | null | POM02.1.05.02.03 | C |  | 16712 |  |  | 03 |  |  |  |  |  |  |  |  |  |  |  |  |  | CalEl HCal FEE tests | yes |  |  |
| S237200 |  | Test HCal Interface Boards: (6 Modules) |  | 23d | 2019-04-30 A | 2019-05-31 A | S237000, S237100 | 100% |  |  |  |  |  |  |  |  | S237200 | 0 | S213600 | S338940 |  | NOCA | Completed | B_T | Mannel, Eric | L4 | Fab & Assy | Eric Mannel | BNL | null | POM02.1.05.02.03 | C |  | 16712 |  |  | 03 |  |  |  |  |  |  |  |  |  |  |  |  |  | CalEl HCal FEE tests | yes |  |  |
| S236600 |  | Test HCal Preamp Boards: (6 Modules) |  | 5d | 2019-05-24 A | 2019-05-31 A | S236400, S236500 | 100% |  |  |  |  |  |  |  |  | S236600 | 0 | S213400 | S340400 |  | NOCA | Completed | B_T | Mannel, Eric | L4 | Fab & Assy | Eric Mannel | BNL | null | POM02.1.05.02.03 | C |  | 16712 |  |  | 03 |  |  |  |  |  |  |  |  |  |  |  |  |  | CalEl HCal FEE tests | yes |  |  |
| S236800 |  | Fabricate HCal LED Boards: (6 Modules) M&S |  | 20d | 2019-06-03 A | 2019-06-28 A | S236000 | 100% |  |  |  |  |  |  | Material (Purchase (1st $2M) [13070 h] | 14,419.67 | S236800 | 10 | S212700 | S212700 | S236800 | CA | Completed | A-OPC | Mannel, Eric | M3 | Fab & Assy | Eric Mannel | BNL | OPC | POM02.1.05.02.03 | C | 1.05 | 16704 | 003 | 1.05A | 03 | Yes | UDF_G3 |  |  |  | TBD |  |  |  |  |  |  |  | CalEl HCal FEE tests |  | 2019-04-26 | OPC001950 |
| S237602 |  | Procure Hcal Power and Signal Cables and Power System: (6 Modules) - Labor Split |  | 84d | 2019-06-03 A | 2019-09-30 A | S237600 | 100% |  |  |  |  |  |  | TECH3 PO E [77 h]; PROF3 PO E [39 h] | 13,321.63 | S237600 | 25 | S213200 | S213200 | S237602 | CA | Completed | B | Mannel, Eric | L2 | Procurement | Eric Mannel | BNL | null | POM02.1.05.02.03 | C | 1.05 | 16712 |  | 1.05B | 03 | Yes |  |  |  |  |  |  |  |  |  |  |  |  | CalEl HCal FEE tests |  | 2019-04-29 |  |
| S237710 |  | Procure Hcal Power and Signal Cables and Power System: (6 Modules), Phase 1 - M&S Split |  | 64d | 2019-06-03 A | 2019-08-30 A | S237700 | 100% |  |  |  |  |  |  | Material (Purchase (1st $2M) [4957 h] | 5,468.88 | S237700 | 20 | S213300 | S213300 | S237710 | CA | Completed | A-OPC | Mannel, Eric | M3 | Fab & Assy | Eric Mannel | BNL | OPC | POM02.1.05.02.03 | C | 1.05 | 16704 | 003,004 | 1.05A | 03 | Yes | UDF_G3 |  |  |  | TBD |  |  |  |  |  |  |  | CalEl HCal FEE tests |  | 2019-04-25 | OPC001950 |
| S237800 |  | Procure Hcal Power and Signal Cables and Power System: (6 Modules), Phase 2 - M&S |  | 64d | 2019-06-03 A | 2019-08-30 A | S236000 | 100% |  |  |  |  |  |  | Material (Purchase (1st $2M) [19828 h] | 21,875.54 | S237800 | 0 | S213300 | S277594564 | S237800 | CA | Completed | A-TEC | Mannel, Eric | M3 | Fab & Assy | Eric Mannel | BNL | OPC | POM02.1.05.02.03 | C | 1.05 | 59715 | 003,004 | 1.05A | 03 | Yes | UDF_G3 |  |  |  | TBD |  |  |  |  |  |  |  | CalEl HCal FEE tests |  |  | OPC001950 |
| S236102 |  | Fabricate HCal SiPM Boards: (6 Modules) Labor Split |  | 6d | 2019-07-02 A | 2019-07-10 A | S236100 | 100% |  |  |  |  |  |  | PROF3 PO E [24 h]; TECH3 PO E [28 h] | 6,050.14 | S236100 | 0 | S212200 | S212200 | S236102 | CA | Completed | B | Mannel, Eric | L2 | Procurement | Eric Mannel | BNL | null | POM02.1.05.02.03 | C | 1.05 | 16712 |  | 1.05B | 03 |  |  |  |  |  |  |  |  |  |  |  |  |  | CalEl HCal FEE tests |  |  |  |
| S236200 |  | Fabricate HCal SiPM Boards: (6 Modules) M&S |  | 5d | 2019-07-11 A | 2019-07-17 A | S236000, S213200, S213205 | 100% |  |  |  |  |  |  | Material (Purchase (1st $2M) [28710 h] | 31,674.74 | S236200 | 0 | S210800 | S210800 | S236200 | CA | Completed | A-OPC | Mannel, Eric | M3 | Fab & Assy | Eric Mannel | BNL | OPC | POM02.1.05.02.03 | C | 1.05 | 16704 | 003 | 1.05A | 03 |  | UDF_G3 |  |  |  | TBD |  |  |  |  |  |  |  | CalEl HCal FEE tests |  |  | OPC001950 |
| S236300 |  | Test HCal SiPM Boards: (6 Modules) |  | 10d | 2019-07-18 A | 2019-07-31 A | S236200, S236102 | 100% |  |  |  |  |  |  | TECH3 PO E [16 h]; PROF3 PO E [24 h] | 4,720.57 | S236300 | 0 | S213400 | S338860 | S236300 | CA | Completed | B | Mannel, Eric | L4 | Fab & Assy | Eric Mannel | BNL | null | POM02.1.05.02.03 | C | 1.05 | 16712 |  | 1.05B | 03 |  |  |  |  |  |  |  |  |  |  |  |  |  | CalEl HCal FEE tests |  |  |  |
| S236900 |  | Test HCal LED Boards: (6 Modules) |  | 32d | 2019-08-15 A | 2019-09-30 A | S236700, S236800 | 100% |  |  |  |  |  |  | STUDENT Other - Unpaid [40 h]; POSTDOC ISU - Unpaid [40 h]; PROF3 PO E [24 h]; SCI3 PO [40 h]; TECH3 PO E [24 h] | 12,290.67 | S236900 | 0 | S213500 | S338900 | S236900 | CA | Completed | B_T | Mannel, Eric | L4 | Fab & Assy | Eric Mannel | BNL | null | POM02.1.05.02.03 | C | 1.05 | 16712 |  | 1.05B | 03 |  |  |  |  |  |  |  |  |  |  |  |  |  | CalEl HCal FEE tests |  |  |  |
| S237900 |  | Assemble HCal Power and Signal Cables and Power System: (6 Modules) |  | 103d | 2019-10-01 A | 2020-01-29 A | S237000, S237100, S237800, S237710, S237602 | 100% |  | 2019-10-01 | 2020-03-03 |  |  |  | STUDENT Other - Unpaid [20 h]; PROF3 PO E [52 h]; TECH3 PO E [103 h]; POSTDOC ISU - Unpaid [20 h] | 18,333.08 | S237900 | 0 | S213600 | S277591644 | S237900 | CA | In Progress | B_T | Mannel, Eric | L4 | Fab & Assy | Eric Mannel | BNL | null | POM02.1.05.02.03 | C | 1.05 | 16712 | 004 | 1.05B | 03 |  |  |  |  |  |  |  |  |  |  |  |  |  | CalEl HCal FEE tests |  |  |  |
| S238000 |  | HCal Preproduction Electronics Complete | milestone | 0d | 2020-01-22 A | 2020-01-22 A | S237900 | 100% |  | 2020-03-03 | 2020-03-03 |  |  |  |  |  | S238000 | 0 | S213900 | S213900 |  | NOCA | Not Started |  | Mannel, Eric |  | Fab & Assy | Eric Mannel | BNL |  | POM02.1.05.02.03 |  |  |  |  |  | 03 |  |  |  | L3 |  |  |  |  |  |  |  |  |  | CalEl HCal FEE tests |  |  |  |
| S238100 |  | HCal Preproduction FEE Complete | milestone | 0d | 2020-01-22 A | 2020-01-22 A | S238000 FF | 100% |  | 2020-03-03 | 2020-03-03 |  |  |  |  |  | S238100 | 0 | S213900 | S213950 |  | NOCA | Not Started |  | Mannel, Eric |  | Fab & Assy | Eric Mannel | BNL |  | POM02.1.05.02.03 |  |  |  |  |  | 03 |  |  |  | L2 |  |  | 2020-04-30 | 70 | PMP_1x |  |  |  |  | CalEl HCal FEE tests |  |  |  |

Notes:
- S229405: BNL_UDF_Status Comments: 190313 ELM Activity split for fund src / BNL_UDF_Adhoc Comments: 180423 ELM rsrc per GRY; 180410 ELM pred/succ per GRY; 180329 ELM desc per EJM / BNL_UDF_Old Activity Name 181221: Test EMCal Preamp Boards: Production Sectors 13-64
- S227550: BNL_UDF_Status Comments: 190313 ELM PRED/SUCC / BNL_UDF_Adhoc Comments: 180329 ELM desc per EJM / BNL_UDF_Old Activity Name 181221: 100% EMCal SiPM Daughter Boards Delivered: Production Sectors 13-64
- S227540: BNL_UDF_Status Comments: 190313 ELM PRED/SUCC / BNL_UDF_Adhoc Comments: 180329 ELM desc per EJM / BNL_UDF_Old Activity Name 181221: 100% EMCal SiPM Daughter Boards Delivered: Production Sectors 13-64
- S228200: BNL_UDF_Status Comments: 190614 ELM PRED/SUCC PER gry; 190313 ELM PRED/SUCC / BNL_UDF_Adhoc Comments: 180329 ELM desc per EJM / BNL_UDF_Old Activity Name 181221: 25% EMCal SiPM Daughter Boards Tested: Production Sectors 13-64
- S228300: BNL_UDF_Status Comments: 190313 ELM PRED/SUCC / BNL_UDF_Adhoc Comments: 180329 ELM desc per EJM / BNL_UDF_Old Activity Name 181221: 50% EMCal SiPM Daughter Boards Tested: Production Sectors 13-64
- S232800: BNL_UDF_Status Comments: 190317 ELM name per GRY / BNL_UDF_Adhoc Comments: 180330 ELM desc, per EJM, GRY / BNL_UDF_Old Activity Name 181221: Procure EMCal External LV/Bias Cables Sectors 13-64 - Vendor Responses
- S232700: BNL_UDF_Status Comments: 190317 ELM name per GRY / BNL_UDF_Adhoc Comments: 180330 ELM desc, per EJM, GRY / BNL_UDF_Old Activity Name 181221: Procure EMCal External LV/Bias Cables Sectors 13-64 - Prepare & Send Solicitation
- S228600: BNL_UDF_Adhoc Comments: 180329 ELM desc per EJM / BNL_UDF_Old Activity Name 181221: EMCal SiPM Boards Production Complete
- S232500: BNL_UDF_Status Comments: 190317 BNLU per L2, Convert from Proc to simple Labor & M&S per GRY / BNL_UDF_Adhoc Comments: 180330 ELM desc, per EJM, GRY / BNL_UDF_Old Activity Name 181221: Procure EMCal External Signal/Comm/Test (& pulse splitter) Cables Sectors 13-64 - Delivery Acceptance
- S228400: BNL_UDF_Status Comments: 190313 ELM PRED/SUCC / BNL_UDF_Adhoc Comments: 180329 ELM desc per EJM / BNL_UDF_Old Activity Name 181221: 75% EMCal SiPM Daughter Boards Tested: Production Sectors 13-64
- S228450: BNL_UDF_Status Comments: 190313 ELM PRED/SUCC / BNL_UDF_Adhoc Comments: 180329 ELM desc per EJM / BNL_UDF_Old Activity Name 181221: 75% EMCal SiPM Daughter Boards Tested: Production Sectors 13-64
- S228500: BNL_UDF_Status Comments: 190313 ELM PRED/SUCC / BNL_UDF_Adhoc Comments: 180329 ELM desc per EJM / BNL_UDF_Old Activity Name 181221: 100% EMCal SiPM Daughter Boards Tested: Production Sectors 13-64
- S232900: BNL_UDF_Status Comments: 190317 ELM name per GRY / BNL_UDF_Adhoc Comments: 180330 ELM desc, per EJM, GRY / BNL_UDF_Old Activity Name 181221: Procure EMCal External LV/Bias Cables Sectors 13-64 - Vendor Selection
- OBLG233010: BNL_UDF_Adhoc Comments: 180330 ELM desc, per EJM, GRY / BNL_UDF_Old Activity Name 181221: Procure EMCal External LV/Bias Cables Sectors 13-64 - Contract Award(s)
- S233000: BNL_UDF_Status Comments: 190317 ELM name per GRY / BNL_UDF_Adhoc Comments: 180330 ELM desc, per EJM, GRY / BNL_UDF_Old Activity Name 181221: Procure EMCal External LV/Bias Cables Sectors 13-64 - Contract Award(s)
- S233100: BNL_UDF_Status Comments: 190317 ELM name per GRY / BNL_UDF_Adhoc Comments: 180330 ELM desc, per EJM, GRY / BNL_UDF_Old Activity Name 181221: Procure EMCal External LV/Bias Cables Sectors 13-64 - Contract/PO - Leadtime
- S233250: BNL_UDF_Status Comments: 190322 ELM BNL Units; 190317 ELM BLNU per L2; name per GRY / BNL_UDF_Adhoc Comments: 180330 ELM desc, per EJM, GRY / BNL_UDF_Old Activity Name 181221: Procure EMCal External LV/Bias Cables Sectors 13-64 - Delivery Acceptance
- S244450: BNL_UDF_Adhoc Comments: 180330 ELM desc, per EJM, GRY / BNL_UDF_Old Activity Name 181221: Assemble Power Cables
- S233200: BNL_UDF_Status Comments: 190322 ELM BNL Units; 190317 ELM BLNU per L2; name per GRY / BNL_UDF_Adhoc Comments: 180330 ELM desc, per EJM, GRY / BNL_UDF_Old Activity Name 181221: Procure EMCal External LV/Bias Cables Sectors 13-64 - Delivery Acceptance
- S234300: BNL_UDF_Old Activity Name 181221: EMCal Electronics Complete
- S234400: BNL_UDF_Adhoc Comments: 180413 ELM status per GRY / BNL_UDF_Old Activity Name 181221: Review and Write Design Hcal Frontend Electronics Specifications: (6 Modules)
- S234401: BNL_UDF_Status Comments: 190508 ELM add per GRY / BNL_UDF_Adhoc Comments: 180413 ELM status per GRY / BNL_UDF_Old Activity Name 181221: Review and Write Design Hcal Frontend Electronics Specifications: (6 Modules)
- S234600: BNL_UDF_Old Activity Name 181221: Design HCal SiPM Board: (6 Modules)
- S234700: BNL_UDF_Old Activity Name 181221: Layout HCal SiPM Board: (6 Modules)
- S234800: BNL_UDF_Old Activity Name 181221: Design HCal Preamp: (6 Modules)
- S234900: BNL_UDF_Old Activity Name 181221: Layout HCal Preamp: (6 Modules)
- S235000: BNL_UDF_Old Activity Name 181221: Design HCal LED Driver Board: (6 Modules)
- S235100: BNL_UDF_Old Activity Name 181221: Layout HCal LED Driver Board: (6 Modules)
- S235200: BNL_UDF_Old Activity Name 181221: Design HCal Interface Board: (6 Modules)
- S235300: BNL_UDF_Old Activity Name 181221: Layout HCal Interface Board: (6 Modules)
- S235400: BNL_UDF_Old Activity Name 181221: Design HCal Backplane: (6 Modules)
- S235500: BNL_UDF_Old Activity Name 181221: Layout HCal Backplane: (6 Modules)
- S235600: BNL_UDF_Old Activity Name 181221: Specify HCal Signal and Power Cables: (6 Modules)
- S235700: BNL_UDF_Old Activity Name 181221: Design HCal power system: (6 Modules)
- S235800: BNL_UDF_Status Comments: 190508 ELM name per GRY; 190416 ELM dur per GRY; 190415 ELM name per GRY; 190314 ELM restore RA BLU (were zeroed) / BNL_UDF_Old Activity Name 181221: Safety & Design Review: HCal Electronics
- S235900: BNL_UDF_Old Activity Name 181221: HCal Electronics Safety & Design Review Complete
- S236000: BNL_UDF_Old Activity Name 181221: Review Hcal Electronics Safety & Design Review Report
- S236400: BNL_UDF_Status Comments: 190604 IVS Finish; / BNL_UDF_Adhoc Comments: 180330 ELM add activity per EJM, GRY / BNL_UDF_Old Activity Name 181221: Fabricate HCal Preamp Boards: (6 Modules) Labor
- S236500: BNL_UDF_Status Comments: 190604 IVS 100%; 190317 ELM BLNU per L2; 190315 ELM chg % to align with EVT 10>0, remove AS, use EF / BNL_UDF_Adhoc Comments: 180330 ELM add activity per EJM, GRY / BNL_UDF_Old Activity Name 181221: Fabricate HCal Preamp Boards: (6 Modules) M&S
- S236700: BNL_UDF_Old Activity Name 181221: Fabricate HCal LED Boards: (6 Modules) Labor
- S237000: BNL_UDF_Old Activity Name 181221: Fabricate HCal Interface Boards: (6 Modules) Labor
- S237100: BNL_UDF_Status Comments: 190604 IVS 100%; 190317 ELM BLNU per L2 / BNL_UDF_Old Activity Name 181221: Fabricate HCal Interface Boards: (6 Modules) M&S
- S237300: BNL_UDF_Old Activity Name 181221: Fabricate HCal Backplane: (6 Modules) Labor
- S237400: BNL_UDF_Status Comments: 190317 ELM BLNU per L2 / BNL_UDF_Old Activity Name 181221: Fabricate HCal Backplane: (6 Modules) M&S
- S237600: BNL_UDF_Old Activity Name 181221: Procure Hcal Power and Signal Cables and Power System: (6 Modules) Labor
- S237700: BNL_UDF_Status Comments: 190604 IVS 0%;190417 ELM name; 190322 ELM BNL Units; 190317 ELM BLNU per L2 / BNL_UDF_Old Activity Name 181221: Procure Hcal Power and Signal Cables and Power System: (6 Modules) M&S - OPC Funds
- S237500: BNL_UDF_Old Activity Name 181221: Test HCal Backplane: (6 Modules)
- S236100: BNL_UDF_Status Comments: 190604 IVS; / BNL_UDF_Adhoc Comments: 180406 ELM name; 180330 ELM desc per EJM, GRY / BNL_UDF_Old Activity Name 181221: Fabricate HCal SiPM Boards: (6 Modules) Labor
- S237200: BNL_UDF_Status Comments: 190604 IVS 100%; / BNL_UDF_Old Activity Name 181221: Test HCal Interface Boards: (6 Modules)
- S236600: BNL_UDF_Status Comments: 190604 IVS 100%; / BNL_UDF_Adhoc Comments: 180330 ELM add activity per EJM, GRY / BNL_UDF_Old Activity Name 181221: Test HCal Preamp Boards: (6 Modules)
- S236800: BNL_UDF_Status Comments: 190604 IVS 0%; 190317 ELM BLNU per L2 / BNL_UDF_Old Activity Name 181221: Fabricate HCal LED Boards: (6 Modules) M&S
- S237602: BNL_UDF_Old Activity Name 181221: Procure Hcal Power and Signal Cables and Power System: (6 Modules) Labor
- S237710: BNL_UDF_Status Comments: 190604 IVS 0%;190417 ELM name; 190322 ELM BNL Units; 190317 ELM BLNU per L2 / BNL_UDF_Old Activity Name 181221: Procure Hcal Power and Signal Cables and Power System: (6 Modules) M&S - OPC Funds
- S237800: BNL_UDF_Status Comments: 190417 ELM name; 190322 ELM BNL Units; 190317 ELM BLNU per L2 / BNL_UDF_Old Activity Name 181221: Procure Hcal Power and Signal Cables and Power System: (6 Modules) M&S - TEC Funds
- S236102: BNL_UDF_Status Comments: 190604 IVS; / BNL_UDF_Adhoc Comments: 180406 ELM name; 180330 ELM desc per EJM, GRY / BNL_UDF_Old Activity Name 181221: Fabricate HCal SiPM Boards: (6 Modules) Labor
- S236200: BNL_UDF_Status Comments: 190322 ELM BNL Units; 190317 ELM BLNU per L2 / BNL_UDF_Adhoc Comments: 180330 ELM desc, units per EJM, GRY / BNL_UDF_Old Activity Name 181221: Fabricate HCal SiPM Boards: (6 Modules) M&S
- S236300: BNL_UDF_Adhoc Comments: 180330 ELM desc per EJM, GRY / BNL_UDF_Old Activity Name 181221: Test HCal SiPM Boards: (6 Modules)
- S236900: BNL_UDF_Old Activity Name 181221: Test HCal LED Boards: (6 Modules)
- S237900: BNL_UDF_Status Comments: 190416 ELM name per GRY / BNL_UDF_Old Activity Name 181221: Assemble HCal Power and Signal Cables and System: (6 Modules)
- S238000: BNL_UDF_Old Activity Name 181221: HCal Preproduction Electronics Complete
- S238100: BNL_UDF_Old Activity Name 181221: HCal Preproduction FEE Complete

| ID | WBS | Activity | Type | Duration | Start | Finish | Predecessors | Complete | Remaining | Planned start | Planned finish | Total float | Free float | Constraint | Expected finish | Resources | Cost | BNL_UDF_Status Comments | BNL_UDF_Temp Text 01 | BNL_UDF_Percent Complete | BNL_UDF_OPC TEC (deprecated) | BNL_UDF_Old Activity ID 181221 | BNL_Cobra WP | RG Check | BNL_Activity Status | BNL_Fund Source | BNL_Estimator | BNL_Cost Basis | BNL_EDIA | BNL_CAM | BNL_Institution | BNL_OPC TEC (deprecated) | BNL_WBS | BNL_EVT | BNL_Master Control Account | BNL_Account Number | BNL_PCR ID | BNL_Cobra Control Account | BNL_WBS_Hierarchical | BNL_Milestone Level | BNL_Proc Sig Phase | BNL_Proc Sig | SPH Proc Register | BNL_Obligation | Indicator - Procurement | Indicator - Float | Additional EVT documentation required | BNL_UDF_Remaining Tot Cost | BNL_UDF_Percent_remaining | Target Milestone Date | Variance | PMP Milestones |
| --- | --- | --- | --- | --- | --- | --- | --- | --- | --- | --- | --- | --- | --- | --- | --- | --- | --- | --- | --- | --- | --- | --- | --- | --- | --- | --- | --- | --- | --- | --- | --- | --- | --- | --- | --- | --- | --- | --- | --- | --- | --- | --- | --- | --- | --- | --- | --- | --- | --- | --- | --- | --- |
|  | 04 | **HCal Electronics: Production** |  |  | 2020-02-03 | 2021-07-29 |  |  |  |  |  |  |  |  |  |  |  |  |  |  |  |  |  |  |  |  |  |  |  |  |  |  |  |  |  |  |  |  |  |  |  |  |  |  |  |  |  |  |  |  |  |  |
| S238200 |  | Production Readiness Review, Safety Review - HCal FEE Sectors 7-32 |  | 10d | 2020-02-03 A | 2020-02-05 A | S238000, S238100, S234401 | 100% |  | 2020-03-02 | 2020-03-13 |  |  |  |  | PROF3 PO E [16 h]; SCI3 PO [16 h]; TECH3 PO E [16 h] | 6,603.8 | 190508 ELM name per GRY; 190415 ELM name per GRY | S238200 | 0 | S214100 | S214100 | S238200 | CA | Not Started | B | Mannel, Eric | L2 | Management Safety Reviews | Eric Mannel | BNL | null | POM02.1.05.02.04 | C | 1.05 | 16712 | 004 | 1.05B | 04 |  |  |  |  |  |  |  |  |  |  |  |  |  |
| S238400 |  | Review Hcal Production Readiness & Safety Review Report |  | 20d | 2020-02-03 A | 2020-02-05 A | S238200, S238300 | 100% |  | 2020-03-16 | 2020-04-10 |  |  |  |  | PROF3 PO E [10 h]; SCI3 PO [10 h] | 2,986.15 |  | S238400 | 0 | S214300 | S214300 | S238400 | CA | Not Started | B | Mannel, Eric | L2 | Management Safety Reviews | Eric Mannel | BNL | null | POM02.1.05.02.04 | C | 1.05 | 16712 |  | 1.05B | 04 |  |  |  |  |  |  |  |  |  |  |  |  |  |
| S238300 |  | Hcal Frontend Electronics Production Review | milestone | 0d | 2020-02-05 A | 2020-02-05 A | S238200 | 100% |  | 2020-03-13 | 2020-03-13 |  |  |  |  |  |  |  | S238300 | 0 | S214200 | S214200 |  | NOCA | Not Started |  | Mannel, Eric |  | Fab & Assy | Eric Mannel | BNL |  | POM02.1.05.02.04 |  |  |  |  |  | 04 | L5 |  |  |  |  |  |  |  |  |  |  |  |  |
| S238500 |  | Fabricate HCal SiPM Boards - Provide Requirements to Procurement |  | 5d | 2020-03-02 A | 2020-03-06 A | S238400 | 100% |  |  |  |  |  |  |  | PROF3 PO E [44 h]; TECH3 PO E [88 h] | 15,609.17 |  | S238500 | 0 | S215100 | S215100 | S238500 | CA | Not Started | B | Mannel, Eric | L4 | Procurement | Eric Mannel | BNL | null | POM02.1.05.02.04 | C | 1.05 | 16712 |  | 1.05B | 04 |  | PP1 | MP108100 |  |  |  |  |  |  |  |  |  |  |
| S239800 |  | Fabricate HCal Preamp Boards - Provide Requirements to Procurement |  | 10d | 2020-03-02 A | 2020-03-13 A | S238400 | 100% |  |  |  |  |  |  |  | PROF3 PO E [88 h]; TECH3 PO E [136 h] | 26,653.45 |  | S239800 | 0 | S214400 | S340480 | S239800 | CA | Not Started | B | Mannel, Eric | L2 | Procurement | Eric Mannel | BNL | null | POM02.1.05.02.04 | C | 1.05 | 16712 |  | 1.05B | 04 |  | PP1 | MP202900 |  |  |  |  |  |  |  |  |  |  |
| S239900 |  | Fabricate HCal Preamp Boards - Prepare & Send Solicitation |  | 30d | 2020-03-02 A | 2020-04-10 A | S239800 SS | 100% |  |  |  |  |  |  |  |  |  |  | S239900 | 0 | S214500 | S340520 |  | NOCA | Not Started |  | Mannel, Eric |  | Procurement | Eric Mannel | BNL |  | POM02.1.05.02.04 |  |  |  |  |  | 04 |  | PP2 | MP202900 |  |  |  |  |  |  |  |  |  |  |
| S238600 |  | Fabricate HCal SiPM Boards - Prepare & Send Solicitation |  | 5d | 2020-03-09 A | 2020-03-13 A | S238500 | 100% |  |  |  |  |  |  |  |  |  |  | S238600 | 0 | S215200 | S215200 |  | NOCA | Not Started |  | Mannel, Eric |  | Procurement | Eric Mannel | BNL |  | POM02.1.05.02.04 |  |  |  |  |  | 04 |  | PP2 | MP108100 |  |  |  |  |  |  |  |  |  |  |
| S238700 |  | Fabricate HCal SiPM Boards - Vendor Responses |  | 5d | 2020-03-16 A | 2020-03-20 A | S238600 | 100% |  |  |  |  |  |  |  |  |  |  | S238700 | 0 | S215300 | S215300 |  | NOCA | Not Started |  | Mannel, Eric |  | Procurement | Eric Mannel | BNL |  | POM02.1.05.02.04 |  |  |  |  |  | 04 |  | PP3 | MP108100 |  |  |  |  |  |  |  |  |  |  |
| S238800 |  | Fabricate HCal SiPM Boards - Vendor Selection |  | 5d | 2020-03-23 A | 2020-03-27 A | S238700 | 100% |  |  |  |  |  |  |  |  |  |  | S238800 | 0 | S215400 | S215400 |  | NOCA | Not Started |  | Mannel, Eric |  | Procurement | Eric Mannel | BNL |  | POM02.1.05.02.04 |  |  |  |  |  | 04 |  | PP4 | MP108100 |  |  |  |  |  |  |  |  |  |  |
| S238900 |  | Fabricate HCal SiPM Boards - Contract Award(s) | milestone | 0d | 2020-03-30 A | 2020-03-30 A | S238800, S101000 | 100% |  |  |  |  |  |  |  |  |  |  | S238900 | 0 | S215500 | S215500 |  | NOCA | Not Started | A-TEC | Mannel, Eric |  | Procurement | Eric Mannel | BNL |  | POM02.1.05.02.04 |  |  |  |  |  | 04 | L4 | PP5 | MP108100 | Contract Award |  |  |  |  |  |  |  |  |  |
| S239000 |  | Fabricate HCal SiPM Boards - Contract/PO - Leadtime |  | 40d | 2020-03-30 A | 2020-09-30 A | S238900 SS, OBLG238910 SS | 100% |  | 2020-03-30 | 2020-05-22 |  |  |  |  |  |  |  | S239000 | 0 | S215600 | S215600 |  | NOCA | Not Started |  | Mannel, Eric |  | Fab & Assy | Eric Mannel | BNL |  | POM02.1.05.02.04 |  |  |  |  |  | 04 |  | PP6 | MP108100 |  |  |  |  |  |  |  |  |  |  |
| S243800 |  | HCal Electronics Prod Pwr & Sig Cables & LV/Bias Supplies & Controller (External) - Provide Requirements to Procurements |  | 5d | 2020-04-01 A | 2020-12-31 A | S238400 | 100% |  | 2020-04-01 | 2020-04-07 |  |  |  |  | PROF3 PO E [48 h]; TECH3 PO E [80 h]; SCI3 PO [24 h] | 19,332.77 |  | S243800 | 0 | S221200 | S221200 | S243800 | CA | Not Started | B | Mannel, Eric | L4 | Procurement | Eric Mannel | BNL | null | POM02.1.05.02.04 | C | 1.05 | 16712 |  | 1.05B | 04 |  | PP1 | MP106450 |  |  |  |  |  |  |  |  |  |  |
| S240000 |  | Fabricate HCal Preamp Boards - Vendor Responses |  | 10d | 2020-04-01 A | 2020-04-14 A | S239900 | 100% |  |  |  |  |  |  |  |  |  |  | S240000 | 0 | S214600 | S340560 |  | NOCA | Not Started |  | Mannel, Eric |  | Procurement | Eric Mannel | BNL |  | POM02.1.05.02.04 |  |  |  |  |  | 04 |  | PP3 | MP202900 |  |  |  |  |  |  |  |  |  |  |
| S241100 |  | Fabricate HCal LED Boards - Provide Requirements to Procurement |  | 5d | 2020-04-01 A | 2020-04-07 A | S238400 | 100% |  |  |  |  |  |  |  | PROF3 PO E [44 h]; TECH3 PO E [28 h] | 8,761.84 |  | S241100 | 0 | S218400 | S218400 | S241100 | CA | Not Started | B | Mannel, Eric | L4 | Procurement | Eric Mannel | BNL | null | POM02.1.05.02.04 | C | 1.05 | 16712 |  | 1.05B | 04 |  | PP1 | MP202100 |  |  |  |  |  |  |  |  |  |  |
| S242300 |  | Fabricate HCal Interface Boards Production - Provide Requirements to Procurement |  | 5d | 2020-04-01 A | 2020-04-07 A | S238400 | 100% |  |  |  |  |  |  |  |  |  |  | S242300 | 0 | S219800 | S219800 |  | NOCA | Not Started | A-TEC | Mannel, Eric | M3 | Fab & Assy | Eric Mannel | BNL | TEC | POM02.1.05.02.04 | K |  |  |  |  | 04 |  | PP1 | MP203020 |  |  |  |  |  |  |  |  |  |  |
| S243900 |  | HCal Electronics Prod Pwr & Sig Cables & LV/Bias Supplies & Controller (External) - Prepare & Send Solicitation |  | 30d | 2020-04-01 A | 2021-06-29 | S243800 | 90% | 21d | 2020-04-08 | 2020-05-19 | 128d | 0d |  | 2021-06-29 |  |  |  | S243900 | 0 | S221300 | S221300 |  | NOCA | Not Started |  | Mannel, Eric |  | Procurement | Eric Mannel | BNL |  | POM02.1.05.02.04 |  |  |  |  |  | 04 |  | PP2 | MP106450 |  |  |  |  |  |  |  |  |  |  |
| S244000 |  | HCal Electronics Prod Pwr & Sig Cables & LV/Bias Supplies & Controller (External) - Vendor Responses |  | 10d | 2020-04-01 A | 2021-06-30 | S243900 | 75% | 1d | 2020-05-20 | 2020-06-03 | 128d | 0d |  | 2021-06-30 |  |  |  | S244000 | 0 | S221400 | S221400 |  | NOCA | Not Started |  | Mannel, Eric |  | Procurement | Eric Mannel | BNL |  | POM02.1.05.02.04 |  |  |  |  |  | 04 |  | PP3 | MP106450 |  |  |  |  |  |  |  |  |  |  |
| S244100 |  | HCal Electronics Prod Pwr & Sig Cables & LV/Bias Supplies & Controller (External) - Vendor Selection |  | 20d | 2020-04-01 A | 2021-07-01 | S244000 | 75% | 0d | 2020-06-04 | 2020-07-01 | 128d | 0d |  | 2021-06-30 |  |  |  | S244100 | 0 | S221500 | S221500 |  | NOCA | Not Started |  | Mannel, Eric |  | Procurement | Eric Mannel | BNL |  | POM02.1.05.02.04 |  |  |  |  |  | 04 |  | PP4 | MP106450 |  |  |  |  |  |  |  |  |  |  |
| S241200 |  | Fabricate HCal LED Boards - Prepare & Send Solicitation |  | 30d | 2020-04-08 A | 2020-04-28 A | S241100 | 100% |  | 2020-04-08 | 2020-05-19 |  |  |  |  |  |  |  | S241200 | 0 | S218500 | S218500 |  | NOCA | Not Started |  | Mannel, Eric |  | Procurement | Eric Mannel | BNL |  | POM02.1.05.02.04 |  |  |  |  |  | 04 |  | PP2 | MP202100 |  |  |  |  |  |  |  |  |  |  |
| S241300 |  | Fabricate HCal LED Boards - Vendor Responses |  | 10d | 2020-04-08 A | 2020-04-28 A | S241200 | 100% |  | 2020-05-20 | 2020-06-03 |  |  |  |  |  |  |  | S241300 | 0 | S218600 | S218600 |  | NOCA | Not Started |  | Mannel, Eric |  | Procurement | Eric Mannel | BNL |  | POM02.1.05.02.04 |  |  |  |  |  | 04 |  | PP3 | MP202100 |  |  |  |  |  |  |  |  |  |  |
| S241400 |  | Fabricate HCal LED Boards - Vendor Selection |  | 20d | 2020-04-08 A | 2020-04-28 A | S241300 | 100% |  | 2020-06-04 | 2020-07-01 |  |  |  |  |  |  |  | S241400 | 0 | S218700 | S218700 |  | NOCA | Not Started |  | Mannel, Eric |  | Procurement | Eric Mannel | BNL |  | POM02.1.05.02.04 |  |  |  |  |  | 04 |  | PP4 | MP202100 |  |  |  |  |  |  |  |  |  |  |
| S241500 |  | Fabricate HCal LED Boards - Contract Award(s) | milestone | 0d | 2020-04-08 A | 2020-04-08 A | S241400, S101000, S238400 | 100% |  | 2020-07-02 | 2020-07-02 |  |  |  |  |  |  |  | S241500 | 0 | S218800 | S218800 |  | NOCA | Not Started | A-TEC | Mannel, Eric |  | Procurement | Eric Mannel | BNL |  | POM02.1.05.02.04 |  |  |  |  |  | 04 | L5 | PP5 | MP202100 | Contract Award |  |  |  |  |  |  |  |  |  |
| S241600 |  | Fabricate HCal LED Boards - Contract/PO - Leadtime |  | 40d | 2020-04-08 A | 2020-05-08 A | S241500 SS, OBLG241510 SS | 100% |  | 2020-07-02 | 2020-08-27 |  |  |  |  |  |  |  | S241600 | 0 | S218900 | S218900 |  | NOCA | Not Started |  | Mannel, Eric |  | Fab & Assy | Eric Mannel | BNL |  | POM02.1.05.02.04 |  |  |  |  |  | 04 |  | PP6 | MP202100 |  |  |  |  |  |  |  |  |  |  |
| S242400 |  | Fabricate HCal Interface Boards Production - Prepare & Send Solicitation |  | 5d | 2020-04-08 A | 2020-04-14 A | S242300 | 100% |  |  |  |  |  |  |  |  |  |  | S242400 | 0 | S219800 | S219810 |  | NOCA | Not Started |  | Mannel, Eric | M3 | Fab & Assy | Eric Mannel | BNL | TEC | POM02.1.05.02.04 | K |  |  |  |  | 04 |  | PP2 | MP203020 |  |  |  |  |  |  |  |  |  |  |
| S240100 |  | Fabricate HCal Preamp Boards - Vendor Selection |  | 20d | 2020-04-15 A | 2020-04-30 A | S240000 | 100% |  | 2020-04-15 | 2020-05-12 |  |  |  |  |  |  |  | S240100 | 0 | S214700 | S340600 |  | NOCA | Not Started |  | Mannel, Eric |  | Procurement | Eric Mannel | BNL |  | POM02.1.05.02.04 |  |  |  |  |  | 04 |  | PP4 | MP202900 |  |  |  |  |  |  |  |  |  |  |
| S242500 |  | Fabricate HCal Interface Boards Production - Vendor Responses |  | 5d | 2020-04-15 A | 2020-04-21 A | S242400 | 100% |  |  |  |  |  |  |  |  |  |  | S242500 | 0 | S219800 | S219820 |  | NOCA | Not Started |  | Mannel, Eric | M3 | Fab & Assy | Eric Mannel | BNL | TEC | POM02.1.05.02.04 | K |  |  |  |  | 04 |  | PP3 | MP203020 |  |  |  |  |  |  |  |  |  |  |
| S242600 |  | Fabricate HCal Interface Boards Production - Vendor Selection |  | 5d | 2020-04-22 A | 2020-04-28 A | S242500 | 100% |  |  |  |  |  |  |  |  |  |  | S242600 | 0 | S219800 | S219830 |  | NOCA | Not Started |  | Mannel, Eric | M3 | Fab & Assy | Eric Mannel | BNL | TEC | POM02.1.05.02.04 | K |  |  |  |  | 04 |  | PP4 | MP203020 |  |  |  |  |  |  |  |  |  |  |
| OBLG238910 |  | Fabricate HCal SiPM Boards - Obligation |  | 1d | 2020-04-29 A | 2020-04-29 A | S238800, S101000 | 100% |  | 2020-05-01 | 2020-05-01 |  |  |  |  | Obligation Resource [108649 h] | 108,649.16 |  | S238900 | 0 | S215500 | S215500 |  |  | Not Started | A-TEC | Mannel, Eric |  | Procurement | Eric Mannel | BNL |  | POM02.1.05.02.04 |  |  |  |  |  | 04 | L4 | PP5 | MP108100 |  | OBLG |  |  |  |  |  |  |  |  |
| S244300 |  | HCal Electronics Prod Pwr & Sig Cables & LV/Bias Supplies & Controller (External) - Contract/PO - Leadtime |  | 60d | 2020-04-29 A | 2021-07-01 | S244200 SS, OBLG244210 SS | 75% | 0d | 2020-07-02 | 2020-09-25 | 128d | 0d |  | 2021-06-30 |  |  |  | S244300 | 0 | S221700 | S221700 |  | NOCA | Not Started |  | Mannel, Eric |  | Fab & Assy | Eric Mannel | BNL |  | POM02.1.05.02.04 |  |  |  |  |  | 04 |  | PP6 | MP106450 |  |  |  |  |  |  |  |  |  |  |
| S242700 |  | Fabricate HCal Interface Boards Production - Contract Award(s) | milestone | 0d | 2020-04-29 A | 2020-04-29 A | S242600, S101000 | 100% |  |  |  |  |  |  |  |  |  |  | S242700 | 0 | S219800 | S219840 |  | NOCA | Not Started | A-TEC | Mannel, Eric | M3 | Fab & Assy | Eric Mannel | BNL | TEC | POM02.1.05.02.04 | K |  |  |  |  | 04 | L5 | PP5 | MP203020 | Contract Award |  |  |  |  |  |  |  |  |  |
| S242800 |  | Fabricate HCal Interface Boards Production - Contract/PO - Leadtime |  | 15d | 2020-04-30 A | 2020-10-30 A | S242700, OBLG242710 | 100% |  | 2020-04-30 | 2020-05-20 |  |  |  |  |  |  |  | S242800 | 0 | S219800 | S219850 |  | NOCA | Not Started |  | Mannel, Eric | M3 | Fab & Assy | Eric Mannel | BNL | TEC | POM02.1.05.02.04 | K |  |  |  |  | 04 |  | PP6 | MP203020 |  |  |  |  |  |  |  |  |  |  |
| S240200 |  | Fabricate HCal Preamp Boards - Contract Award(s) | milestone | 0d | 2020-05-01 A | 2020-05-01 A | S240100, S101000 | 100% |  |  |  |  |  |  |  |  |  |  | S240200 | 0 | S214800 | S340640 |  | NOCA | Not Started | A-TEC | Mannel, Eric |  | Procurement | Eric Mannel | BNL |  | POM02.1.05.02.04 |  |  |  |  |  | 04 | L5 | PP5 | MP202900 | Contract Award |  | UDF_G3 | UDF_G3 |  |  |  |  |  |  |
| S240300 |  | Fabricate HCal Preamp Boards - Contract/PO - Leadtime |  | 80d | 2020-05-01 A | 2020-08-31 A | S240200 SS, OBLG240210 SS | 100% |  | 2020-05-01 | 2020-08-24 |  |  |  |  |  |  |  | S240300 | 0 | S214900 | S340680 |  | NOCA | Not Started |  | Mannel, Eric |  | Fab & Assy | Eric Mannel | BNL |  | POM02.1.05.02.04 |  |  |  |  |  | 04 |  | PP6 | MP202900 |  |  |  |  |  |  |  |  |  |  |
| S241900 |  | Fabricate HCal Backplane Boards: Production - Labor |  | 40d | 2020-05-01 A | 2020-05-28 A | S238400, S101000 | 100% |  | 2020-05-01 | 2020-06-26 |  |  |  |  | PROF3 PO E [48 h]; TECH3 PO E [80 h] | 15,202.23 |  | S241900 | 0 | S220200 | S220200 | S241900 | CA | Not Started | B | Mannel, Eric | L2 | Procurement | Eric Mannel | BNL | null | POM02.1.05.02.04 | C | 1.05 | 16712 |  | 1.05B | 04 |  |  |  |  |  |  |  | Yes |  |  |  |  |  |
| S242000 |  | Fabricate HCal Backplane Boards: Production - M&S |  | 40d | 2020-05-01 A | 2020-05-28 A | S238400, S101000 | 100% |  | 2020-05-01 | 2020-06-26 |  |  |  |  | Material (Purchase (1st $2M) [15416 h] | 17,542.26 | 190317 ELM BLNU per L2 | S242000 | 0 | S220100 | S220100 | S242000 | CA | Not Started | A-TEC | Mannel, Eric | M3 | Fab & Assy | Eric Mannel | BNL | TEC | POM02.1.05.02.04 | C | 1.05 | 59715 | 003 | 1.05A | 04 |  |  | TBD |  |  | UDF_G3 | UDF_G3 | Yes | 17542.263979 | 1 |  |  |  |
| S243100 |  | Procure HCal Electronics Production Power & Signal Cables (Internal) - Provide Requirements to Procurement |  | 5d | 2020-05-01 A | 2020-05-07 A | S238400 | 100% |  |  |  |  |  |  |  | PROF3 PO E [48 h]; SCI3 PO [24 h]; TECH3 PO E [80 h] | 19,332.77 |  | S243100 | 0 | S220500 | S220500 | S243100 | CA | Not Started | B | Mannel, Eric | L2 | Procurement | Eric Mannel | BNL | null | POM02.1.05.02.04 | C | 1.05 | 16712 |  | 1.05B | 04 |  | PP1 | MP106400 |  |  |  |  |  |  |  |  |  |  |
| S243200 |  | Procure HCal Electronics Production Power & Signal Cables (Internal) - Prepare & Send Solicitation |  | 5d | 2020-05-08 A | 2020-05-14 A | S243100 | 100% |  |  |  |  |  |  |  |  |  |  | S243200 | 0 | S220600 | S220600 |  | NOCA | Not Started |  | Mannel, Eric |  | Procurement | Eric Mannel | BNL |  | POM02.1.05.02.04 |  |  |  |  |  | 04 |  | PP2 | MP106400 |  |  |  |  |  |  |  |  |  |  |
| S241700 |  | Fabricate HCal LED Boards - Delivery Acceptance |  | 5d | 2020-05-11 A | 2020-05-15 A | S241600 | 100% |  |  |  |  |  |  |  | Material (Purchase (1st $2M) [44067 h] | 50,144.98 | 190317 ELM BLNU per L2 | S241700 | 0 | S219000 | S219000 | S241700 | CA | Not Started | A-TEC | Mannel, Eric | M4 | Fab & Assy | Eric Mannel | BNL | TEC | POM02.1.05.02.04 | C | 1.05 | 59715 | 003 | 1.05A | 04 |  | PP6 | MP202100 | Delivery | FAB | UDF_G3 | UDF_G3 |  | 50144.975788 | 1 |  |  |  |
| S243300 |  | Procure HCal Electronics Production Power & Signal Cables (Internal) - Vendor Responses |  | 5d | 2020-05-15 A | 2020-05-21 A | S243200 | 100% |  |  |  |  |  |  |  |  |  |  | S243300 | 0 | S220700 | S220700 |  | NOCA | Not Started |  | Mannel, Eric |  | Procurement | Eric Mannel | BNL |  | POM02.1.05.02.04 |  |  |  |  |  | 04 |  | PP3 | MP106400 |  |  |  |  |  |  |  |  |  |  |
| S243400 |  | Procure HCal Electronics Production Power & Signal Cables (Internal) - Vendor Selection |  | 5d | 2020-05-22 A | 2020-05-29 A | S243300 | 100% |  |  |  |  |  |  |  |  |  |  | S243400 | 0 | S220800 | S220800 |  | NOCA | Not Started |  | Mannel, Eric |  | Procurement | Eric Mannel | BNL |  | POM02.1.05.02.04 |  |  |  |  |  | 04 |  | PP4 | MP106400 |  |  |  |  |  |  |  |  |  |  |
| S243500 |  | Procure HCal Electronics Production Power & Signal Cables (Internal) - Contract Award(s) | milestone | 0d | 2020-05-27 A | 2020-05-27 A | S243400, S101000 | 100% |  | 2020-06-01 | 2020-06-01 |  |  |  |  |  |  |  | S243500 | 0 | S220900 | S220900 |  | NOCA | Not Started | A-TEC | Mannel, Eric |  | Procurement | Eric Mannel | BNL |  | POM02.1.05.02.04 |  |  |  |  |  | 04 | L5 | PP5 | MP106400 | Contract Award |  | UDF_G3 | UDF_G3 |  |  |  |  |  |  |
| S243600 |  | Procure HCal Electronics Production Power & Signal Cables (Internal) - Contract/PO - Leadtime |  | 40d | 2020-05-27 A | 2020-05-29 A | S243500 SS, OBLG243510 SS | 100% |  | 2020-06-01 | 2020-07-27 |  |  |  |  |  |  |  | S243600 | 0 | S221000 | S221000 |  | NOCA | Not Started |  | Mannel, Eric |  | Procurement | Eric Mannel | BNL |  | POM02.1.05.02.04 |  |  |  |  |  | 04 |  | PP6 | MP106400 |  |  |  |  |  |  |  |  |  |  |
| S243700 |  | Procure HCal Electronics Production Power & Signal Cables (Internal) - Delivery Acceptance |  | 5d | 2020-05-27 A | 2020-05-29 A | S243600 | 100% |  | 2020-07-28 | 2020-08-03 |  |  |  |  | Material (Purchase (1st $2M) [81327 h] | 92,544.09 | 190322 ELM BNL Units; 190317 ELM BLNU per L2 | S243700 | 0 | S221100 | S221100 | S243700 | CA | Not Started | A-TEC | Mannel, Eric | M3 | Fab & Assy | Eric Mannel | BNL | TEC | POM02.1.05.02.04 | C | 1.05 | 59715 | 003 | 1.05A | 04 |  | PP6 | MP106400 | Delivery | FAB | UDF_G3 | UDF_G3 |  | 92544.090723 | 1 |  |  |  |
| S244200 |  | HCal Electronics Prod Pwr & Sig Cables & LV/Bias Supplies & Controller (External) - Contract Award(s) | milestone | 0d | 2020-05-27 A | 2020-05-27 A | S244100, S101000 | 100% |  | 2020-06-09 | 2020-06-09 |  |  |  |  |  |  |  | S244200 | 0 | S221600 | S221600 |  | NOCA | Not Started | A-TEC | Mannel, Eric |  | Procurement | Eric Mannel | BNL |  | POM02.1.05.02.04 |  |  |  |  |  | 04 | L5 | PP5 | MP106450 | Contract Award |  | UDF_G3 | UDF_G3 |  |  |  |  |  |  |
| S240400 |  | Fabricate HCal Preamp Boards - Delivery Acceptance |  | 5d | 2020-08-11 A | 2020-08-31 A | S240300 | 100% |  | 2020-09-01 | 2020-09-08 |  |  |  |  | Material (Purchase (1st $2M) [41364 h] | 47,069.16 | 190317 ELM BLNU per L2 | S240400 | 0 | S215000 | S340720 | S240400 | CA | Not Started | A-TEC | Mannel, Eric | M3 | Fab & Assy | Eric Mannel | BNL | TEC | POM02.1.05.02.04 | C | 1.05 | 59715 | 003 | 1.05A | 04 |  | PP6 | MP202900 | Delivery | FAB | UDF_G3 | UDF_G3 |  | 47069.162378 | 1 |  |  |  |
| S240500 |  | 50% HCal Preamp Board Assembly complete: Production | milestone | 0d | 2020-08-31 A | 2020-08-31 A | S240400 | 100% |  | 2020-09-08 | 2020-09-08 |  |  |  |  |  |  |  | S240500 | 0 | S217000 | S217000 |  | NOCA | Not Started |  | Mannel, Eric |  | Fab & Assy | Eric Mannel | BNL |  | POM02.1.05.02.04 |  |  |  |  |  | 04 | L4 |  |  |  |  | UDF_G3 | UDF_G3 |  |  |  |  |  |  |
| S240600 |  | Hcal Preamp Board Assembly Complete: Production | milestone | 0d | 2020-08-31 A | 2020-08-31 A | S240500, S240400 FF | 100% |  | 2020-09-08 | 2020-09-08 |  |  |  |  |  |  |  | S240600 | 0 | S217100 | S217100 |  | NOCA | Not Started |  | Mannel, Eric |  | Fab & Assy | Eric Mannel | BNL |  | POM02.1.05.02.04 |  |  |  |  |  | 04 | L4 |  |  |  |  | UDF_G3 | UDF_G3 |  |  |  |  |  |  |
| OBLG240210 |  | Fabricate HCal Preamp Boards - Obligation |  | 1d | 2020-09-01 A | 2020-09-01 A | S240100, S101000 | 100% |  |  |  |  |  |  |  | Obligation Resource [48010.6 h] | 48,010.55 |  | S240200 | 0 | S214800 | S340640 |  |  | Not Started | A-TEC | Mannel, Eric |  | Procurement | Eric Mannel | BNL |  | POM02.1.05.02.04 |  |  |  |  |  | 04 | L5 | PP5 | MP202900 |  | OBLG |  |  |  |  |  |  |  |  |
| OBLG241510 |  | Fabricate HCal LED Boards - Obligation |  | 1d | 2020-09-01 A | 2020-09-01 A | S241400, S101000, S238400 | 100% |  |  |  |  |  |  |  | Obligation Resource [50145 h] | 50,144.98 |  | S241500 | 0 | S218800 | S218800 |  |  | Not Started | A-TEC | Mannel, Eric |  | Procurement | Eric Mannel | BNL |  | POM02.1.05.02.04 |  |  |  |  |  | 04 | L5 | PP5 | MP202100 |  | OBLG |  |  |  |  |  |  |  |  |
| OBLG242710 |  | Fabricate HCal Interface Boards Production - Obligation |  | 1d | 2020-09-01 A | 2020-09-01 A | S242600 | 100% |  |  |  |  |  |  |  | Obligation Resource [33329.8 h] | 33,329.85 |  | S242700 | 0 | S219800 | S219840 |  |  | Not Started | A-TEC | Mannel, Eric | M3 | Fab & Assy | Eric Mannel | BNL | TEC | POM02.1.05.02.04 | K |  |  |  |  | 04 |  | PP5 | MP203020 |  | OBLG |  |  |  |  |  |  |  |  |
| OBLG243510 |  | Procure HCal Electronics Production Power & Signal Cables (Internal) - Obligation |  | 1d | 2020-09-01 A | 2020-09-01 A | S243400, S101000 | 100% |  |  |  |  |  |  |  | Obligation Resource [94395 h] | 94,394.99 |  | S243500 | 0 | S220900 | S220900 |  |  | Not Started | A-TEC | Mannel, Eric |  | Procurement | Eric Mannel | BNL |  | POM02.1.05.02.04 |  |  |  |  |  | 04 | L5 | PP5 | MP106400 |  | OBLG |  |  |  |  |  |  |  |  |
| S239100 |  | Fabricate HCal SiPM Boards - Delivery Acceptance |  | 5d | 2020-09-14 A | 2020-09-30 A | S239000 | 100% |  | 2021-01-11 | 2021-01-15 |  |  | start on or after 2021-01-11 |  | Material (Purchase (1st $2M) [95480 h] | 110,822.14 | 190322 ELM BNL Units; 190317 ELM BLNU per L2 | S239100 | 0 | S215700 | S215700 | S239100 | CA | Not Started | A-TEC | Mannel, Eric | M3 | Fab & Assy | Eric Mannel | BNL | TEC | POM02.1.05.02.04 | C | 1.05 | 59715 | 015 | 1.05A | 04 |  | PP6 | MP108100 | Delivery | FAB | UDF_G1 | UDF_G1 |  | 108649.154429 | 1 |  |  |  |
| S239300 |  | Test HCal SiPM Boards: Production |  | 80d | 2020-09-15 A | 2020-09-22 A | S239200 | 100% |  | 2021-01-19 | 2021-05-11 |  |  |  |  | PROF3 PO E [145 h]; TECH3 PO E [48 h] | 24,536.4 |  | S239300 | 0 | S216000 | S216000 | S239300 | CA | Not Started | B | Mannel, Eric | L4 | Test_Components | Eric Mannel | BNL | null | POM02.1.05.02.04 | C | 1.05 | 16712 |  | 1.05B | 04 |  |  |  |  |  |  |  | Yes |  |  |  |  |  |
| S239200 |  | HCal SiPM Boards Assembly Complete | milestone | 0d | 2020-09-22 A | 2020-09-22 A | S239100 FF | 100% |  | 2021-01-15 | 2021-01-15 |  |  |  |  |  |  |  | S239200 | 0 | S215900 | S215900 |  | NOCA | Not Started |  | Mannel, Eric |  | Fab & Assy | Eric Mannel | BNL |  | POM02.1.05.02.04 |  |  |  |  |  | 04 | L2 |  |  |  |  | UDF_G3 | UDF_G3 |  |  |  | 2020-11-30 | 45 | PMP_1x |
| S239400 |  | 25% Hcal SiPM Board testing complete: Production | milestone | 0d | 2020-09-22 A | 2020-09-22 A | S239300 FF+20d | 100% |  | 2021-06-09 | 2021-06-09 |  |  |  |  |  |  |  | S239400 | 0 | S216100 | S216100 |  | NOCA | Not Started |  | Mannel, Eric |  | Test_System | Eric Mannel | BNL |  | POM02.1.05.02.04 |  |  |  |  |  | 04 | L4 |  |  |  |  | UDF_G3 | UDF_G3 |  |  |  |  |  |  |
| S239500 |  | 50% Hcal SiPM Board testing complete: Production | milestone | 0d | 2020-09-22 A | 2020-09-22 A | S239300 FF+40d | 100% |  | 2021-07-08 | 2021-07-08 |  |  |  |  |  |  |  | S239500 | 0 | S216200 | S216200 |  | NOCA | Not Started |  | Mannel, Eric |  | Test_System | Eric Mannel | BNL |  | POM02.1.05.02.04 |  |  |  |  |  | 04 | L4 |  |  |  |  | UDF_G3 | UDF_G3 |  |  |  |  |  |  |
| S239600 |  | 75% Hcal SiPM Board testing complete: Production | milestone | 0d | 2020-09-22 A | 2020-09-22 A | S239300 FF+60d | 100% |  | 2021-08-05 | 2021-08-05 |  |  |  |  |  |  |  | S239600 | 0 | S216300 | S216300 |  | NOCA | Not Started |  | Mannel, Eric |  | Test_System | Eric Mannel | BNL |  | POM02.1.05.02.04 |  |  |  |  |  | 04 | L4 |  |  |  |  | UDF_G3 | UDF_G3 |  |  |  |  |  |  |
| S239700 |  | Hcal SiPM Board testing Complete: Production | milestone | 0d | 2020-09-22 A | 2020-09-22 A | S239300 FF, S239400 FF, S239500 FF, S239600 FF | 100% |  | 2021-08-05 | 2021-08-05 |  |  |  |  |  |  |  | S239700 | 0 | S216400 | S216400 |  | NOCA | Not Started |  | Mannel, Eric |  | Test_System | Eric Mannel | BNL |  | POM02.1.05.02.04 |  |  |  |  |  | 04 | L3 |  |  |  |  | UDF_G3 | UDF_G3 |  |  |  |  |  |  |
| S240700 |  | Test HCal Preamp Boards: Production |  | 80d | 2020-09-28 A | 2021-03-30 A | S240500 | 100% |  | 2020-10-01 | 2021-01-29 |  |  |  |  | PROF3 PO E [161 h]; SCI3 PO [40 h]; TECH3 PO E [80 h]; SCI2 UM - Unpaid [80 h]; STUDENT GRAD UM - Unpaid [192 h] | 37,473.49 |  | S240700 | 0 | S217200 | S217200 | S240700 | CA | Not Started | B_T | Mannel, Eric | L4 | Test_Components | Eric Mannel | BNL | null | POM02.1.05.02.04 | C | 1.05 | 16712 |  | 1.05B | 04 |  |  |  |  |  |  |  | Yes |  |  |  |  |  |
| S242900 |  | Fabricate HCal Interface Boards Production - Delivery Acceptance |  | 5d | 2020-10-14 A | 2020-11-16 A | S242800 | 100% |  | 2020-11-02 | 2020-11-06 |  |  |  |  | Material (Purchase (1st $2M) [29290 h] | 33,996.44 | 190317 ELM BLNU per L2 | S242900 | 0 | S219800 | S219860 | S242900 | CA | Not Started | A-TEC | Mannel, Eric | M3 | Fab & Assy | Eric Mannel | BNL | TEC | POM02.1.05.02.04 | C | 1.05 | 59715 | 003 | 1.05A | 04 |  | PP6 | MP203020 | Delivery | FAB | UDF_G1 | UDF_G3 |  | 33329.846389 | 1 |  |  |  |
| OBLG244210 |  | HCal Electronics Prod Pwr & Sig Cables & LV/Bias Supplies & Controller (External) - Obligation |  | 1d | 2020-10-15 A | 2021-02-02 A | S244100, S101000 | 100% |  | 2021-02-02 | 2021-02-02 |  |  |  |  | Obligation Resource [101939 h] | 101,939.44 |  | S244200 | 0 | S221600 | S221600 |  |  | Not Started | A-TEC | Mannel, Eric |  | Procurement | Eric Mannel | BNL |  | POM02.1.05.02.04 |  |  |  |  |  | 04 | L5 | PP5 | MP106450 |  | OBLG |  |  |  |  |  |  |  |  |
| S242100 |  | Test Hcal Backplane Boards: Production |  | 60d | 2020-10-15 A | 2020-12-01 A | S241900, S242000 | 100% |  | 2020-11-02 | 2021-02-01 |  |  |  |  | PROF3 PO E [211 h]; SCI3 PO [60 h]; TECH3 PO E [240 h]; SCI3 UM - Unpaid [60 h]; STUDENT GRAD UM - Unpaid [160 h] | 66,341.44 |  | S242100 | 0 | S220400 | S220400 | S242100 | CA | Not Started | B_T | Mannel, Eric | L4 | Test_Components | Eric Mannel | BNL | null | POM02.1.05.02.04 | C | 1.05 | 16712 |  | 1.05B | 04 |  |  |  |  |  |  |  |  |  |  |  |  |  |
| S243000 |  | Test HCal Interface Boards: Production |  | 60d | 2020-10-15 A | 2020-11-16 A | S242900 | 100% |  | 2020-11-09 | 2021-02-08 |  |  |  |  | PROF3 PO E [99 h]; SCI3 PO [8 h]; TECH3 PO E [8 h]; SCI2 UM - Unpaid [8 h]; STUDENT GRAD UM - Unpaid [40 h] | 15,258.69 |  | S243000 | 0 | S220000 | S220000 | S243000 | CA | Not Started | B_T | Mannel, Eric | L4 | Test_Components | Eric Mannel | BNL | null | POM02.1.05.02.04 | C | 1.05 | 16712 |  | 1.05B | 04 |  |  |  |  |  |  |  |  |  |  |  |  |  |
| S241800 |  | Test HCal LED Boards: Production |  | 60d | 2020-11-20 A | 2020-12-31 A | S241700 | 100% |  | 2020-12-01 | 2021-02-26 |  |  |  |  | PROF3 PO E [151 h]; SCI3 PO [60 h]; TECH3 PO E [240 h]; SCI2 UM - Unpaid [60 h]; STUDENT GRAD Other - Unpaid [160 h] | 58,523.15 |  | S241800 | 0 | S219100 | S219100 | S241800 | CA | Not Started | B_T | Mannel, Eric | L4 | Test_Components | Eric Mannel | BNL | null | POM02.1.05.02.04 | C | 1.05 | 16712 |  | 1.05B | 04 |  |  |  |  |  |  |  |  |  |  |  |  |  |
| S244400 |  | HCal Electronics Prod Pwr & Sig Cables & LV/Bias Supplies & Controller (External) - Delivery Acceptance |  | 5d | 2020-12-14 A | 2021-07-29 | S244300 | 50% | 20d | 2021-02-02 | 2021-02-08 | 128d | 0d |  | 2021-07-29 | Material (Purchase (1st $2M) [87827 h] | 101,939.42 | 190322 ELM BNL Units; 190317 ELM BLNU per L2 | S244400 | 0 | S221800 | S221800 | S244400 | CA | Not Started | A-TEC | Mannel, Eric | M3 | Fab & Assy | Eric Mannel | BNL | TEC | POM02.1.05.02.04 | C | 1.05 | 59715 | 003 | 1.05A | 04 |  | PP6 | MP106450 | Delivery | FAB | UDF_G1 | UDF_G3 |  | 101139.89588 | 1 |  |  |  |
| S240800 |  | 25% HCal Preamp Boards testing complete: Production | milestone | 0d | 2021-01-29 A | 2021-01-29 A | S240700 SF+20d | 100% |  | 2021-02-01 | 2021-02-01 |  |  |  |  |  |  |  | S240800 | 0 | S217300 | S217300 |  | NOCA | Not Started |  | Mannel, Eric |  | Test_System | Eric Mannel | BNL |  | POM02.1.05.02.04 |  |  |  |  |  | 04 | L4 |  |  |  |  | UDF_G3 | UDF_G3 |  |  |  |  |  |  |
| S240900 |  | 50% HCal Preamp Boards testing complete: Production | milestone | 0d | 2021-02-25 A | 2021-02-25 A | S240700 SF+40d | 100% |  | 2021-03-01 | 2021-03-01 |  |  |  |  |  |  |  | S240900 | 0 | S217400 | S217400 |  | NOCA | Not Started |  | Mannel, Eric |  | Test_System | Eric Mannel | BNL |  | POM02.1.05.02.04 |  |  |  |  |  | 04 | L4 |  |  |  |  | UDF_G3 | UDF_G3 |  |  |  |  |  |  |
| S241000 |  | 75% HCal Preamp Boards testing complete: Production | milestone | 0d | 2021-03-31 A | 2021-03-31 A | S240700 SF+60d | 100% |  | 2021-04-01 | 2021-04-01 |  |  |  |  |  |  |  | S241000 | 0 | S217500 | S217500 |  | NOCA | Not Started |  | Mannel, Eric |  | Test_System | Eric Mannel | BNL |  | POM02.1.05.02.04 |  |  |  |  |  | 04 | L4 |  |  |  |  | UDF_G3 | UDF_G3 |  |  |  |  |  |  |
| S244500 |  | HCal Electronics Complete: Production | milestone | 0d | 2021-07-29 | 2021-07-29 | S239100 FF, S241700 FF, S243700 FF, S244400 FF, S239700 FF, S241900 FF+60d, S242000 FF, S242900 FF |  |  |  |  | 128d | 123d |  |  |  |  |  | S244500 | 0 | S222000 | S222000 |  | NOCA | Not Started |  | Mannel, Eric |  | Fab & Assy | Eric Mannel | BNL |  | POM02.1.05.02.04 |  |  |  |  |  | 04 | L2 |  |  |  |  | UDF_G3 | UDF_G3 |  |  |  | 2021-06-30 | -21 | PMP_1x |

Notes:
- S238200: General Comments: 180420 GYoung: concerning / Production Readiness and Safety Review - Safety here refers to BNL check / that designs are safe to operate before fabricating / them / BNL_UDF_Old Activity Name 181221: Production Readiness & Safety Review: HCal Electronics
- S238400: General Comments: 180420 GYoung: concerning Review / Production Readiness and Safety Review report Review - respond to / recommendations from prior / reviews / BNL_UDF_Old Activity Name 181221: Review Hcal Production Readiness & Safety Review Report
- S238300: BNL_UDF_Old Activity Name 181221: Hcal Frontend Electronics Production Review
- S238500: BNL_UDF_Adhoc Comments: 180330 ELM desc per EJM, GRY / BNL_UDF_Old Activity Name 181221: Fabricate HCal SiPM Boards - Provide Requirements to Procurement
- S239800: BNL_UDF_Adhoc Comments: 180413 ELM dur, pred/succ per GRY; 180330 ELM new activity per EJM, GRY / BNL_UDF_Old Activity Name 181221: Fabricate HCal Preamp Boards - Provide Requirements to Procurement
- S239900: BNL_UDF_Adhoc Comments: 180330 ELM new activity per EJM, GRY / BNL_UDF_Old Activity Name 181221: Fabricate HCal Preamp Boards - Prepare & Send Solicitation
- S238600: BNL_UDF_Adhoc Comments: 180330 ELM desc per EJM, GRY / BNL_UDF_Old Activity Name 181221: Fabricate HCal SiPM Boards - Prepare & Send Solicitation
- S238700: BNL_UDF_Adhoc Comments: 180330 ELM desc per EJM, GRY / BNL_UDF_Old Activity Name 181221: Fabricate HCal SiPM Boards - Vendor Responses
- S238800: BNL_UDF_Adhoc Comments: 180330 ELM desc per EJM, GRY / BNL_UDF_Old Activity Name 181221: Fabricate HCal SiPM Boards - Vendor Selection
- S238900: BNL_UDF_Adhoc Comments: 180330 ELM desc per EJM, GRY / BNL_UDF_Old Activity Name 181221: Fabricate HCal SiPM Boards - Contract Award(s)
- S239000: BNL_UDF_Adhoc Comments: 180330 ELM desc per EJM, GRY / BNL_UDF_Old Activity Name 181221: Fabricate HCal SiPM Boards - Contract/PO - Leadtime
- S243800: Scheduler's Notes: 180413 ELM per GRY: / assume 2 people do this / BNL_UDF_Adhoc Comments: 180406 RFG filled in BNL_Cost Basis; 180330 ELM rsrc, pred,dur per GRY / BNL_UDF_Old Activity Name 181221: HCal Electronics Prod Pwr & Sig Cables & LV/Bias Supplies & Controller (External) - Provide Requirements to Procurements
- S240000: BNL_UDF_Adhoc Comments: 180330 ELM new activity per EJM, GRY / BNL_UDF_Old Activity Name 181221: Fabricate HCal Preamp Boards - Vendor Responses
- S241100: BNL_UDF_Adhoc Comments: 180330 pred per GRY / BNL_UDF_Old Activity Name 181221: Fabricate HCal LED Boards - Provide Requirements to Procurement
- S242300: BNL_UDF_Adhoc Comments: 180406 ELM rmv proc strg, pred/succ, dur / BNL_UDF_Old Activity Name 181221: Fabricate HCal Interface Boards Production - Provide Requirements to Procurement
- S243900: BNL_UDF_Old Activity Name 181221: HCal Electronics Prod Pwr & Sig Cables & LV/Bias Supplies & Controller (External) - Prepare & Send Solicitation
- S244000: BNL_UDF_Old Activity Name 181221: HCal Electronics Prod Pwr & Sig Cables & LV/Bias Supplies & Controller (External) - Vendor Responses
- S244100: BNL_UDF_Old Activity Name 181221: HCal Electronics Prod Pwr & Sig Cables & LV/Bias Supplies & Controller (External) - Vendor Selection
- S241200: BNL_UDF_Old Activity Name 181221: Fabricate HCal LED Boards - Prepare & Send Solicitation
- S241300: BNL_UDF_Old Activity Name 181221: Fabricate HCal LED Boards - Vendor Responses
- S241400: BNL_UDF_Old Activity Name 181221: Fabricate HCal LED Boards - Vendor Selection
- S241500: BNL_UDF_Adhoc Comments: 180330 pred per GRY / BNL_UDF_Old Activity Name 181221: Fabricate HCal LED Boards - Contract Award(s)
- S241600: BNL_UDF_Old Activity Name 181221: Fabricate HCal LED Boards - Contract/PO - Leadtime
- S242400: BNL_UDF_Adhoc Comments: 180406 ELM rmv proc strg, pred/succ, dur / BNL_UDF_Old Activity Name 181221: Fabricate HCal Interface Boards Production - Prepare & Send Solicitation
- S240100: BNL_UDF_Adhoc Comments: 180330 ELM new activity per EJM, GRY / BNL_UDF_Old Activity Name 181221: Fabricate HCal Preamp Boards - Vendor Selection
- S242500: BNL_UDF_Adhoc Comments: 180406 ELM rmv proc strg, pred/succ, dur / BNL_UDF_Old Activity Name 181221: Fabricate HCal Interface Boards Production - Vendor Responses
- S242600: BNL_UDF_Adhoc Comments: 180406 ELM rmv proc strg, pred/succ, dur / BNL_UDF_Old Activity Name 181221: Fabricate HCal Interface Boards Production - Vendor Selection
- OBLG238910: BNL_UDF_Adhoc Comments: 180330 ELM desc per EJM, GRY / BNL_UDF_Old Activity Name 181221: Fabricate HCal SiPM Boards - Contract Award(s)
- S244300: BNL_UDF_Old Activity Name 181221: HCal Electronics Prod Pwr & Sig Cables & LV/Bias Supplies & Controller (External) - Contract/PO - Leadtime
- S242700: BNL_UDF_Adhoc Comments: 180406 ELM rmv proc strg, pred/succ, dur / BNL_UDF_Old Activity Name 181221: Fabricate HCal Interface Boards Production - Contract Award(s)
- S242800: BNL_UDF_Adhoc Comments: 180406 ELM rmv proc strg, pred/succ, dur / BNL_UDF_Old Activity Name 181221: Fabricate HCal Interface Boards Production - Contract/PO - Leadtime
- S240200: BNL_UDF_Adhoc Comments: 180330 ELM new activity per EJM, GRY / BNL_UDF_Old Activity Name 181221: Fabricate HCal Preamp Boards - Contract Award(s)
- S240300: BNL_UDF_Adhoc Comments: 180330 ELM new activity per EJM, GRY / BNL_UDF_Old Activity Name 181221: Fabricate HCal Preamp Boards - Contract/PO - Leadtime
- S241900: BNL_UDF_Old Activity Name 181221: Fabricate HCal Backplane Boards: Production - Labor
- S242000: BNL_UDF_Old Activity Name 181221: Fabricate HCal Backplane Boards: Production - M&S
- S243100: Scheduler's Notes: 180413 ELM per GRY: / assume 2 people do this / BNL_UDF_Adhoc Comments: 180330 ELM pred per GRY / BNL_UDF_Old Activity Name 181221: Procure HCal Electronics Production Power & Signal Cables (Internal) - Provide Requirements to Procurement
- S243200: BNL_UDF_Old Activity Name 181221: Procure HCal Electronics Production Power & Signal Cables (Internal) - Prepare & Send Solicitation
- S241700: BNL_UDF_Old Activity Name 181221: Fabricate HCal LED Boards - Delivery Acceptance
- S243300: BNL_UDF_Old Activity Name 181221: Procure HCal Electronics Production Power & Signal Cables (Internal) - Vendor Responses
- S243400: BNL_UDF_Old Activity Name 181221: Procure HCal Electronics Production Power & Signal Cables (Internal) - Vendor Selection
- S243500: BNL_UDF_Adhoc Comments: RG set constraint to push obligation across fiscal boundary, must verify with L2 / BNL_UDF_Old Activity Name 181221: Procure HCal Electronics Production Power & Signal Cables (Internal) - Contract Award(s)
- S243600: BNL_UDF_Old Activity Name 181221: Procure HCal Electronics Production Power & Signal Cables (Internal) - Contract/PO - Leadtime
- S243700: BNL_UDF_Old Activity Name 181221: Procure HCal Electronics Production Power & Signal Cables (Internal) - Delivery Acceptance
- S244200: BNL_UDF_Old Activity Name 181221: HCal Electronics Prod Pwr & Sig Cables & LV/Bias Supplies & Controller (External) - Contract Award(s)
- S240400: BNL_UDF_Adhoc Comments: 180330 ELM new activity per EJM, GRY / BNL_UDF_Old Activity Name 181221: Fabricate HCal Preamp Boards - Delivery Acceptance
- S240500: BNL_UDF_Old Activity Name 181221: 50% HCal Preamp Board Assembly complete: Production
- S240600: BNL_UDF_Old Activity Name 181221: Hcal Preamp Board Assembly Complete: Production
- OBLG240210: BNL_UDF_Adhoc Comments: 180330 ELM new activity per EJM, GRY / BNL_UDF_Old Activity Name 181221: Fabricate HCal Preamp Boards - Contract Award(s)
- OBLG241510: BNL_UDF_Adhoc Comments: 180330 pred per GRY / BNL_UDF_Old Activity Name 181221: Fabricate HCal LED Boards - Contract Award(s)
- OBLG242710: BNL_UDF_Adhoc Comments: 180406 ELM rmv proc strg, pred/succ, dur / BNL_UDF_Old Activity Name 181221: Fabricate HCal Interface Boards Production - Contract Award(s)
- OBLG243510: BNL_UDF_Adhoc Comments: RG set constraint to push obligation across fiscal boundary, must verify with L2 / BNL_UDF_Old Activity Name 181221: Procure HCal Electronics Production Power & Signal Cables (Internal) - Contract Award(s)
- S239100: BNL_UDF_Adhoc Comments: 180330 ELM desc, units per EJM, GRY / BNL_UDF_Old Activity Name 181221: Fabricate HCal SiPM Boards - Delivery Acceptance
- S239300: BNL_UDF_Adhoc Comments: 180423 ELM rsrc per GRY / BNL_UDF_Old Activity Name 181221: Test HCal SiPM Boards: Production
- S239200: BNL_UDF_Old Activity Name 181221: HCal SiPM Boards Assembly Complete
- S239400: BNL_UDF_Old Activity Name 181221: 25% Hcal SiPM Board testing complete: Production
- S239500: BNL_UDF_Old Activity Name 181221: 50% Hcal SiPM Board testing complete: Production
- S239600: BNL_UDF_Old Activity Name 181221: 75% Hcal SiPM Board testing complete: Production
- S239700: BNL_UDF_Old Activity Name 181221: Hcal SiPM Board testing Complete: Production
- S240700: BNL_UDF_Adhoc Comments: 180423 ELM rsrc per GRY / BNL_UDF_Old Activity Name 181221: Test HCal Preamp Boards: Production
- S242900: BNL_UDF_Adhoc Comments: 180406 ELM rmv proc strg, pred/succ, dur / BNL_UDF_Old Activity Name 181221: Fabricate HCal Interface Boards Production - Delivery Acceptance
- OBLG244210: BNL_UDF_Old Activity Name 181221: HCal Electronics Prod Pwr & Sig Cables & LV/Bias Supplies & Controller (External) - Contract Award(s)
- S242100: BNL_UDF_Adhoc Comments: 180423 ELM rsrc per GRY / BNL_UDF_Old Activity Name 181221: Test Hcal Backplane Boards: Production
- S243000: BNL_UDF_Adhoc Comments: 180423 ELM rsrc per GRY; 180406 ELM pred/succ per GRY / BNL_UDF_Old Activity Name 181221: Test HCal Interface Boards: Production
- S241800: BNL_UDF_Adhoc Comments: 180423 ELM rsrc per GRY / BNL_UDF_Old Activity Name 181221: Test HCal LED Boards: Production
- S244400: BNL_UDF_Adhoc Comments: 180410 ELM pred/succ per GRY / BNL_UDF_Old Activity Name 181221: HCal Electronics Prod Pwr & Sig Cables & LV/Bias Supplies & Controller (External) - Delivery Acceptance
- S240800: BNL_UDF_Old Activity Name 181221: 25% HCal Preamp Boards testing complete: Production
- S240900: BNL_UDF_Old Activity Name 181221: 50% HCal Preamp Boards testing complete: Production
- S241000: BNL_UDF_Old Activity Name 181221: 75% HCal Preamp Boards testing complete: Production
- S244500: BNL_UDF_Old Activity Name 181221: HCal Electronics Complete: Production

| ID | WBS | Activity | Type | Duration | Start | Finish | Predecessors | Complete | Planned start | Planned finish | Resources | Cost | BNL_UDF_Exclude | BNL_UDF_Status Comments | BNL_UDF_Temp Text 01 | BNL_UDF_Percent Complete | BNL_UDF_Old Activity ID 181221 | RG Check | BNL_Activity Status | BNL_Estimator | BNL_Location | BNL_EDIA | BNL_Proc Sig Phase | BNL_Proc Sig | BNL_CAM | BNL_Institution | BNL_OPC TEC (deprecated) | BNL_WBS | BNL_PCR ID | BNL_WBS_Hierarchical | BNL_Fund Source | BNL_Milestone Level | BNL_Obligation | BNL_UDF_OPC TEC (deprecated) | BNL_R&D FY18-19 | Completed | BNL_Cost Basis | BNL_EVT | Cost = Awarded Proc or Mgmt | BNL_UDF_Temp Date 01 | BNL_DOE OPC | SPH Proc Register | BNL_Account Number | BNL_Cobra WP | BNL_Master Control Account | BNL_Cobra Control Account | Indicator - Procurement |
| --- | --- | --- | --- | --- | --- | --- | --- | --- | --- | --- | --- | --- | --- | --- | --- | --- | --- | --- | --- | --- | --- | --- | --- | --- | --- | --- | --- | --- | --- | --- | --- | --- | --- | --- | --- | --- | --- | --- | --- | --- | --- | --- | --- | --- | --- | --- | --- |
|  | 05 | **Calorimeter Front End Electronics Procure Contracted Labor and M&S** |  |  | 2019-06-03 | 2019-10-01 |  |  |  |  |  |  |  |  |  |  |  |  |  |  |  |  |  |  |  |  |  |  |  |  |  |  |  |  |  |  |  |  |  |  |  |  |  |  |  |  |  |
| S244600 |  | Procure Contracted Labor & M&S Univ. Michigan (UM) - Provide Requirements to Procurement |  | 5d | 2019-06-03 A | 2019-06-07 A | S100090 SS+90d, S101009 FS+60d | 100% |  |  |  |  | MP6LAEXCLUDE | 190316 ELM WBS Name | S244600 | 0 | S342980 | NOCA | Completed | Mannel, Eric | BNL | Design | PP1 | MP203240 | Eric Mannel | BNL | null | POM02.1.05.02.05 | 003 | 05 |  |  |  |  |  |  |  |  |  |  |  |  |  |  |  |  |  |
| S244700 |  | Procure Contracted Labor & M&S Univ. Michigan (UM) - Vendor Selection |  | 30d | 2019-06-10 A | 2019-06-28 A | S244600 | 100% | 2019-06-10 | 2019-07-22 |  |  | MP6LAEXCLUDE |  | S244700 | 0 | S343020 | NOCA | Completed | Mannel, Eric | BNL | Design | PP4 | MP203240 | Eric Mannel | BNL | null | POM02.1.05.02.05 |  | 05 |  |  |  |  |  |  |  |  |  |  |  |  |  |  |  |  |  |
| OBLG244810 |  | Procure Contracted Labor & M&S Univ. Michigan (UM), Phase 1 - Obligation |  | 1d | 2019-06-27 A | 2019-06-28 A | S244700 | 100% | 2019-07-23 | 2019-07-23 | Obligation Resource [24543.5 h] | 24,543.51 | MP6LAEXCLUDE | 190417 ELM name | S244800 | 0 | S343060 |  | Completed | Mannel, Eric | BNL | Design | PP5 | MP203240 | Eric Mannel | BNL |  | POM02.1.05.02.05 | 004 | 05 | A-OPC | L5 | OBLG |  |  |  |  |  |  |  |  |  |  |  |  |  |  |
| S244800 |  | Procure Contracted Labor & M&S Univ. Michigan (UM), Phase 1 - Contract Award | milestone | 0d | 2019-06-28 A | 2019-06-28 A | S244700 | 100% | 2019-07-23 | 2019-07-23 |  |  | MP6LAEXCLUDE | 190417 ELM name | S244800 | 0 | S343060 | NOCA | Completed | Mannel, Eric | BNL | Design | PP5 | MP203240 | Eric Mannel | BNL |  | POM02.1.05.02.05 | 004 | 05 | A-OPC | L5 |  |  |  |  |  |  |  |  |  |  |  |  |  |  |  |
| OBLG245110 |  | Procure Contracted Labor & M&S Univ. Michigan (UM), Phase 2 - Obligation |  | 1d | 2019-07-03 A | 2019-07-05 A | S244700 | 100% | 2019-10-01 | 2019-10-01 | Obligation Resource [12289.8 h] | 12,289.78 |  | 190417 ELM name | S245100 | 0 | S343220 |  | Completed | Mannel, Eric | BNL | Design | PP5 | MP203250 | Eric Mannel |  |  | POM02.1.05.02.05 | 004 | 05 | A-TEC | L5 | OBLG |  |  |  |  |  |  |  |  |  |  |  |  |  |  |
| S245100 |  | Procure Contracted Labor & M&S Univ. Michigan (UM), Phase 2 - Contract Award | milestone | 0d | 2019-10-01 A | 2019-10-01 A | S244700, S101010 | 100% |  |  |  |  |  | 190417 ELM name | S245100 | 0 | S343220 | NOCA | Completed | Mannel, Eric | BNL | Design | PP5 | MP203250 | Eric Mannel |  |  | POM02.1.05.02.05 | 004 | 05 | A-TEC | L5 |  |  |  |  |  |  |  |  |  |  |  |  |  |  |  |
|  | 03 | **Calorimeter Digitizer System** |  |  | 2017-02-01 | 2022-01-28 |  |  |  |  |  |  |  |  |  |  |  |  |  |  |  |  |  |  |  |  |  |  |  |  |  |  |  |  |  |  |  |  |  |  |  |  |  |  |  |  |  |
|  | 01 | **Calorimeter Digitizer: Preproduction Prototype** |  |  | 2017-02-01 | 2020-09-30 |  |  |  |  |  |  |  |  |  |  |  |  |  |  |  |  |  |  |  |  |  |  |  |  |  |  |  |  |  |  |  |  |  |  |  |  |  |  |  |  |  |
| S245500 |  | Review and write design change specifications for calorimeter digitizer system: 1/2-Crate Prototype |  | 40d | 2017-02-01 A | 2017-03-29 A | S100090 SS | 100% |  |  |  |  |  | 190523 ELM name; 190415 ELM name per GRY | S245500 | 100 | S222200 | NOCA | Completed | Mannel, Eric |  | Design |  |  | Eric Mannel | BNL |  | POM02.1.05.03.01 | 004 | 01 |  |  |  | S222200 | CalEl Digitizer v2 | yes |  |  |  |  |  |  |  |  |  |  |  |
| S245600 |  | Design Digitizer ADC Boards: 1/2-Crate Prototype |  | 40d | 2017-03-30 A | 2017-05-24 A | S245500 | 100% |  |  |  |  |  |  | S245600 | 100 | S222300 | NOCA | Completed | Mannel, Eric |  | Design |  |  | Eric Mannel | BNL |  | POM02.1.05.03.01 |  | 01 |  |  |  | S222300 | CalEl Digitizer v2 | yes |  |  |  |  |  |  |  |  |  |  |  |
| S245700 |  | Design Digitizer Controller Board: 1/2-Crate Prototype |  | 40d | 2017-03-30 A | 2017-05-24 A | S245500 | 100% |  |  |  |  |  |  | S245700 | 100 | S222400 | NOCA | Completed | Mannel, Eric |  | Design |  |  | Eric Mannel | BNL |  | POM02.1.05.03.01 |  | 01 |  |  |  | S222400 | CalEl Digitizer v2 | yes |  |  |  |  |  |  |  |  |  |  |  |
| S245800 |  | Design Digitizer XMIT Board: 1/2-Crate Prototype |  | 40d | 2017-03-30 A | 2017-05-24 A | S245500 | 100% |  |  |  |  |  |  | S245800 | 100 | S222500 | NOCA | Completed | Mannel, Eric |  | Design |  |  | Eric Mannel | BNL |  | POM02.1.05.03.01 |  | 01 |  |  |  | S222500 | CalEl Digitizer v2 | yes |  |  |  |  |  |  |  |  |  |  |  |
| S245900 |  | Design Digitizer Clock Master: 1/2-Crate Prototype |  | 60d | 2017-03-30 A | 2017-06-22 A | S245500 | 100% |  |  |  |  |  |  | S245900 | 100 | S222600 | NOCA | Completed | Mannel, Eric |  | Design |  |  | Eric Mannel | BNL |  | POM02.1.05.03.01 |  | 01 |  |  |  | S222600 | CalEl Digitizer v2 | yes |  |  |  |  |  |  |  |  |  |  |  |
| S246000 |  | Design Digitizer Crate: 1/2-Crate Prototype |  | 30d | 2017-03-30 A | 2017-05-10 A | S245500 | 100% |  |  |  |  |  |  | S246000 | 100 | S222700 | NOCA | Completed | Mannel, Eric |  | Design |  |  | Eric Mannel | BNL |  | POM02.1.05.03.01 |  | 01 |  |  |  | S222700 | CalEl Digitizer v2 | yes |  |  |  |  |  |  |  |  |  |  |  |
| S246100 |  | Layout Digitizer ADC Board: 1/2-Crate Prototype |  | 40d | 2017-05-25 A | 2017-07-21 A | S245600 | 100% |  |  |  |  |  |  | S246100 | 100 | S222800 | NOCA | Completed | Mannel, Eric |  | Fab & Assy |  |  | Eric Mannel | BNL |  | POM02.1.05.03.01 |  | 01 |  |  |  | S222800 | CalEl Digitizer v2 | yes |  |  |  |  |  |  |  |  |  |  |  |
| S246200 |  | Layout Digitizer Controller Board: 1/2-Crate Prototype |  | 40d | 2017-05-25 A | 2017-07-21 A | S245700 | 100% |  |  |  |  |  |  | S246200 | 100 | S222900 | NOCA | Completed | Mannel, Eric |  | Fab & Assy |  |  | Eric Mannel | BNL |  | POM02.1.05.03.01 |  | 01 |  |  |  | S222900 | CalEl Digitizer v2 | yes |  |  |  |  |  |  |  |  |  |  |  |
| S246300 |  | Layout Digitizer XMIT Board: 1/2-Crate Prototype |  | 40d | 2017-05-25 A | 2017-07-21 A | S245800 | 100% |  |  |  |  |  |  | S246300 | 100 | S223000 | NOCA | Completed | Mannel, Eric |  | Fab & Assy |  |  | Eric Mannel | BNL |  | POM02.1.05.03.01 |  | 01 |  |  |  | S223000 | CalEl Digitizer v2 | yes |  |  |  |  |  |  |  |  |  |  |  |
| S246400 |  | Layout Digitizer Clock Master: 1/2-Crate |  | 151d | 2017-06-23 A | 2018-02-01 A | S245900 | 100% |  |  |  |  |  |  | S246400 | 100 | S223100 | NOCA | Completed | Mannel, Eric |  | Fab & Assy |  |  | Eric Mannel | BNL |  | POM02.1.05.03.01 |  | 01 |  |  |  | S223100 | CalEl Digitizer v2 | yes |  |  |  |  |  |  |  |  |  |  |  |
| S246800 |  | Procure 1/2-Crate Digitizer - Parts - Provide Requirements to Procurement |  | 6d | 2018-03-09 A | 2018-03-16 A | S246600, S246700, S246701 | 100% |  |  |  |  |  |  | S246800 | 100 | S223900 | NOCA | Completed | Mannel, Eric |  | Procurement | PP1 | MP108200 | Eric Mannel | BNL | null | POM02.1.05.03.01 |  | 01 |  |  |  | S223900 |  | yes | L4 | C | Yes |  |  |  |  |  |  |  |  |
| S246900 |  | Procure 1/2-Crate Digitizer - Parts - Prepare & Send Solicitation |  | 10d | 2018-04-02 A | 2018-04-13 A | S246800 | 100% |  |  |  |  |  |  | S246900 | 100 | S224000 | NOCA | Completed | Mannel, Eric |  | Procurement | PP2 | MP108200 | Eric Mannel | BNL |  | POM02.1.05.03.01 |  | 01 |  |  |  | S224000 |  | yes |  |  | Yes |  |  |  |  |  |  |  |  |
| S247000 |  | Procure 1/2-Crate Digitizer - Parts - Vendor Responses |  | 11d | 2018-04-16 A | 2018-04-30 A | S246900 | 100% |  |  |  |  |  |  | S247000 | 100 | S224100 | NOCA | Completed | Mannel, Eric |  | Procurement | PP3 | MP108200 | Eric Mannel | BNL |  | POM02.1.05.03.01 |  | 01 |  |  |  | S224100 |  | yes |  |  | Yes |  |  |  |  |  |  |  |  |
| S246500 |  | Calorimeter Digitizer System Electrical Safety Review |  | 2d | 2018-05-01 A | 2018-05-02 A | S246000, S246100, S246200, S246300, S246400 FS+50d | 100% |  |  |  |  |  |  | S246500 | 100 | S223200 | NOCA | Completed | Mannel, Eric |  | Management Safety Reviews |  |  | Eric Mannel | BNL | null | POM02.1.05.03.01 |  | 01 |  |  |  | S223200 | CalEl Digitizer v2 | yes | L4 | C |  |  |  |  |  |  |  |  |  |
| S247100 |  | Procure 1/2-Crate Digitizer - Parts - Vendor Selection |  | 0d | 2018-05-01 A | 2018-05-01 A | S247000 | 100% |  |  |  |  |  |  | S247100 | 100 | S224200 | NOCA | Completed | Mannel, Eric |  | Procurement | PP4 | MP108200 | Eric Mannel | BNL |  | POM02.1.05.03.01 |  | 01 |  |  |  | S224200 |  | yes |  |  | Yes |  |  |  |  |  |  |  |  |
| S246600 |  | Calorimeter Digitizer Safety Review Complete | milestone | 0d | 2018-05-02 A | 2018-05-02 A | S246500 | 100% |  |  |  |  |  |  | S246600 | 100 | S223300 | NOCA | Completed | Mannel, Eric |  | Management Safety Reviews |  |  | Eric Mannel | BNL |  | POM02.1.05.03.01 |  | 01 |  | L5 |  | S223300 | CalEl Digitizer v2 | yes |  |  |  |  |  |  |  |  |  |  |  |
| S246700 |  | Review Calorimeter Digitizer Safety Review Report |  | 13d | 2018-05-02 A | 2018-05-18 A | S246600 | 100% |  |  |  |  |  |  | S246700 | 100 | S223400 | NOCA | Completed | Mannel, Eric |  | Management Safety Reviews |  |  | Eric Mannel | BNL | null | POM02.1.05.03.01 |  | 01 |  |  |  | S223400 | CalEl Digitizer v2 | yes | L4 | C |  |  |  |  |  |  |  |  |  |
| S246701 |  | Preliminary Design Review - Calorimeter Digitizer 7-crate | milestone | 0d | 2018-05-02 A | 2018-05-02 A | S246600 | 100% |  |  |  |  |  | 190508 ELM add per GRY | S246700 | 100 | S223400 | NOCA | Completed | Mannel, Eric |  | Management Safety Reviews |  |  | Eric Mannel | BNL | null | POM02.1.05.03.01 | 004 | 01 |  |  |  | S223400 | CalEl Digitizer v2 | yes | L4 | C |  |  |  |  |  |  |  |  |  |
| OBLG247210 |  | Procure 1/2-Crate Digitizer - Parts - Obligation |  | 1d | 2018-05-07 A | 2018-05-07 A | S247100 | 100% |  |  | Obligation Resource |  |  |  | S247200 | 100 | S224300 | NOCA | Completed | Mannel, Eric |  | Procurement | PP5 | MP108200 | Eric Mannel | BNL |  | POM02.1.05.03.01 |  | 01 | A-OPC | L5 |  | S224300 |  | yes |  |  | Yes |  |  |  |  |  |  |  |  |
| OBLG247310 |  | Procure 1/2-Crate Digitizer - Boards - Obligation |  | 1d | 2018-05-07 A | 2018-05-07 A | S247100 | 100% |  |  | Obligation Resource |  |  |  | S247300 | 100 | S277592044 | NOCA | Completed | Mannel, Eric |  | Procurement | PP5 | MP108210 | Eric Mannel | BNL |  | POM02.1.05.03.01 |  | 01 | A-OPC | L5 |  | S224300 |  | yes |  |  | Yes |  |  |  |  |  |  |  |  |
| OBLG247410 |  | Procure 1/2-Crate Digitizer - Assembly & Tests - Obligation |  | 1d | 2018-05-07 A | 2018-05-07 A | S247100 | 100% |  |  | Obligation Resource |  |  |  | S247400 | 100 | S277592084 | NOCA | Completed | Mannel, Eric |  | Procurement | PP5 | MP108220 | Eric Mannel | BNL |  | POM02.1.05.03.01 |  | 01 | A-OPC | L5 |  | S224300 |  | yes |  |  | Yes |  |  |  |  |  |  |  |  |
| S247200 |  | Procure 1/2-Crate Digitizer - Parts - Contract Award(s) | milestone | 0d | 2018-05-07 A | 2018-05-07 A | S247100 | 100% |  |  |  |  |  |  | S247200 | 100 | S224300 | NOCA | Completed | Mannel, Eric |  | Procurement | PP5 | MP108200 | Eric Mannel | BNL |  | POM02.1.05.03.01 |  | 01 | A-OPC | L5 |  | S224300 |  | yes |  |  | Yes |  |  |  |  |  |  |  |  |
| S247300 |  | Procure 1/2-Crate Digitizer - Boards - Contract Award(s) | milestone | 0d | 2018-05-07 A | 2018-05-07 A | S247100 | 100% |  |  |  |  |  |  | S247300 | 100 | S277592044 | NOCA | Completed | Mannel, Eric |  | Procurement | PP5 | MP108210 | Eric Mannel | BNL |  | POM02.1.05.03.01 |  | 01 | A-OPC | L5 |  | S224300 |  | yes |  |  | Yes |  |  |  |  |  |  |  |  |
| S247400 |  | Procure 1/2-Crate Digitizer - Assembly & Tests - Contract Award(s) | milestone | 0d | 2018-05-07 A | 2018-05-07 A | S247100 | 100% |  |  |  |  |  |  | S247400 | 100 | S277592084 | NOCA | Completed | Mannel, Eric |  | Procurement | PP5 | MP108220 | Eric Mannel | BNL |  | POM02.1.05.03.01 |  | 01 | A-OPC | L5 |  | S224300 |  | yes |  |  | Yes |  |  |  |  |  |  |  |  |
| S247500 |  | Procure 1/2-Crate Digitizer - Parts - Leadtime - FY18 |  | 84d | 2018-06-01 A | 2018-09-28 A | S247200 SS, OBLG247210 SS | 100% |  |  |  |  |  |  | S247500 | 100 | S224500 | NOCA | Completed | Mannel, Eric |  | Fab & Assy | PP6 | MP108200 | Eric Mannel | BNL |  | POM02.1.05.03.01 |  | 01 |  |  |  | S224500 | CalEl Digitizer v2 | yes |  |  | Yes | 2018-09-10 | OPC002000 |  |  |  |  |  |  |
| S247800 |  | Procure 1/2-Crate Digitizer - Boards - Contract/PO - Leadtime FY18 |  | 84d | 2018-06-01 A | 2018-09-28 A | S247300 SS, OBLG247310 SS | 100% |  |  |  |  |  |  | S247800 | 100 | S224550 | NOCA | Completed | Mannel, Eric |  | Fab & Assy | PP6 | MP108210 | Eric Mannel | BNL |  | POM02.1.05.03.01 |  | 01 |  |  |  | S223500 | CalEl Digitizer v2 | yes |  |  | Yes | 2018-09-10 | OPC002000 |  |  |  |  |  |  |
| S249700 |  | Procure EMCAL 7-Crate Digitizer - Provide Requirements to Procurement FY18 |  | 32d | 2018-08-15 A | 2018-09-28 A | S246600, S246700, S246701 | 100% |  |  |  |  |  |  | S249700 | 100 | S226340 | NOCA | Completed | Mannel, Eric |  | Procurement | PP1 | MP109400 | Eric Mannel | BNL | null | POM02.1.05.03.01 |  | 01 |  |  |  |  |  | yes | L4 | C |  |  |  |  |  |  |  |  |  |
| S249900 |  | Procure EMCAL 7-Crate Digitizer - Prepare & Send Solicitation FY18 |  | 32d | 2018-08-15 A | 2018-09-28 A | S249700 SS | 100% |  |  |  |  |  |  | S249900 | 100 | S226380 | NOCA | Completed | Mannel, Eric |  | Procurement | PP2 | MP109400 | Eric Mannel | BNL |  | POM02.1.05.03.01 |  | 01 |  |  |  |  |  | yes |  |  |  |  |  |  |  |  |  |  |  |
| S250100 |  | Procure EMCAL 7-Crate Digitizer - Vendor Responses FY18 |  | 32d | 2018-08-15 A | 2018-09-28 A | S249900 SS | 100% |  |  |  |  |  |  | S250100 | 100 | S337880 | NOCA | Completed | Mannel, Eric |  | Procurement | PP3 | MP109400 | Eric Mannel | BNL |  | POM02.1.05.03.01 |  | 01 |  |  |  |  |  | yes |  |  |  |  |  |  |  |  |  |  |  |
| S248100 |  | Procure 1/2-Crate Digitizer - Contract/PO - Leadtime for Assembly & Tests |  | 166d | 2018-10-01 A | 2019-05-31 A | S247400 SS, OBLG247410 SS | 100% |  |  |  |  |  |  | S248100 | 75 | S224570 | NOCA | Completed | Mannel, Eric |  | Fab & Assy | PP6 | MP108220 | Eric Mannel | BNL |  | POM02.1.05.03.01 |  | 01 | A-OPC |  |  | S223600 | CalEl Digitizer v2 |  |  |  | Yes | 2019-01-07 | OPC002000 | Contract Award |  |  |  |  |  |
| S247600 |  | Procure 1/2-Crate Digitizer - Parts - Leadtime - FY19 |  | 0d | 2018-11-01 A | 2018-11-01 A | S247500 | 100% |  |  |  |  |  |  | S247600 | 100 | S224501 | NOCA | Completed | Mannel, Eric |  | Fab & Assy | PP6 | MP108200 | Eric Mannel | BNL |  | POM02.1.05.03.01 |  | 01 |  |  |  | S224500 | CalEl Digitizer v2 | yes |  |  | Yes | 2018-09-10 | OPC002000 |  |  |  |  |  |  |
| S247700 |  | Procure 1/2-Crate Digitizer - Parts - Delivery Acceptance |  | 5d | 2018-11-01 A | 2018-11-07 A | S247600 | 100% |  |  |  |  |  |  | S247700 | 100 | S224510 | NOCA | Completed | Mannel, Eric |  | Fab & Assy | PP6 | MP108200 | Eric Mannel | BNL | OPC | POM02.1.05.03.01 |  | 01 | A-OPC |  |  | S224500 | CalEl Digitizer v2 | yes | M5 | C | Yes |  | OPC002000 |  | 16704 |  |  |  |  |
| S247900 |  | Procure 1/2-Crate Digitizer - Boards - Contract/PO - Leadtime FY19 |  | 0d | 2018-11-01 A | 2018-11-01 A | S247800 | 100% |  |  |  |  |  |  | S247900 | 100 | S224551 | NOCA | Completed | Mannel, Eric |  | Fab & Assy | PP6 | MP108210 | Eric Mannel | BNL |  | POM02.1.05.03.01 |  | 01 |  |  |  | S223500 | CalEl Digitizer v2 | yes |  |  | Yes | 2018-09-10 | OPC002000 |  |  |  |  |  |  |
| S248000 |  | Procure 1/2-Crate Digitizer - Boards - Delivery Acceptance |  | 5d | 2018-11-01 A | 2018-11-07 A | S247900 | 100% |  |  |  |  |  |  | S248000 | 100 | S224560 | NOCA | Completed | Mannel, Eric |  | Fab & Assy | PP6 | MP108210 | Eric Mannel | BNL | OPC | POM02.1.05.03.01 |  | 01 | A-OPC |  |  | S223500 | CalEl Digitizer v2 | yes | M3 | C | Yes |  | OPC002000 |  | 16704 |  |  |  |  |
| S249800 |  | Procure EMCAL 7-Crate Digitizer - Provide Requirements to Procurement FY19 |  | 22d | 2019-01-02 A | 2019-02-01 A | S249700 | 100% |  |  |  |  |  |  | S249800 | 100 | S226341 | NOCA | Completed | Mannel, Eric |  | Procurement | PP1 | MP109400 | Eric Mannel | BNL | null | POM02.1.05.03.01 |  | 01 | B |  |  |  |  | yes | L4 | C |  |  |  |  | 16712 |  |  |  |  |
| S250000 |  | Procure EMCAL 7-Crate Digitizer - Prepare & Send Solicitation FY19 |  | 0d | 2019-01-02 A | 2019-01-02 A | S249900, S249800 SS | 100% |  |  |  |  |  |  | S250000 | 100 | S226381 | NOCA | Completed | Mannel, Eric |  | Procurement | PP2 | MP109400 | Eric Mannel | BNL |  | POM02.1.05.03.01 |  | 01 |  |  |  |  |  | yes |  |  |  |  |  |  |  |  |  |  |  |
| S250200 |  | Procure EMCAL 7-Crate Digitizer - Vendor Responses FY19 |  | 0d | 2019-01-02 A | 2019-01-02 A | S250100, S250000 | 100% |  |  |  |  |  |  | S250200 | 100 | S337881 | NOCA | Completed | Mannel, Eric |  | Procurement | PP3 | MP109400 | Eric Mannel | BNL |  | POM02.1.05.03.01 |  | 01 |  |  |  |  |  | yes |  |  |  |  |  |  |  |  |  |  |  |
| S250300 |  | Procure EMCAL 7-Crate Digitizer - Vendor Selection |  | 20d | 2019-01-02 A | 2019-01-30 A | S250200 | 100% |  |  |  |  |  |  | S250300 | 100 | S337980 | NOCA | Completed | Mannel, Eric |  | Procurement | PP4 | MP109400 | Eric Mannel | BNL |  | POM02.1.05.03.01 |  | 01 |  |  |  |  |  | yes |  |  |  |  |  |  |  |  |  |  |  |
| S248500 |  | Design Digitizer ADC Boards: 7-Crate Preproduction |  | 10d | 2019-01-23 A | 2019-02-05 A | S248400 | 100% |  |  |  |  |  |  | S248500 | 100 | S224700 | NOCA | Completed | Mannel, Eric |  | Design |  |  | Eric Mannel | BNL | null | POM02.1.05.03.01 |  | 01 | B |  |  | S224700 |  | yes | L4 | C |  |  |  |  | 16712 |  |  |  |  |
| S248600 |  | Design Digitizer Controller Board: 7-Crate Preproduction |  | 10d | 2019-01-23 A | 2019-02-05 A | S248400 | 100% |  |  |  |  |  |  | S248600 | 100 | S224800 | NOCA | Completed | Mannel, Eric |  | Design |  |  | Eric Mannel | BNL | null | POM02.1.05.03.01 |  | 01 | B |  |  | S224800 |  | yes | L4 | C |  |  |  |  | 16712 |  |  |  |  |
| S248700 |  | Design Digitizer XMIT Board: 7-Crate Preproduction |  | 10d | 2019-01-23 A | 2019-02-05 A | S248400 | 100% |  |  |  |  |  |  | S248700 | 100 | S224900 | NOCA | Completed | Mannel, Eric |  | Design |  |  | Eric Mannel | BNL | null | POM02.1.05.03.01 |  | 01 | B |  |  | S224900 |  | yes | L4 | C |  |  |  |  | 16712 |  |  |  |  |
| S248800 |  | Design Digitizer Clock Master: 7-Crate Preproduction |  | 91d | 2019-01-23 A | 2019-05-31 A | S248400 | 100% |  |  |  |  |  |  | S248800 | 75 | S225000 | NOCA | Completed | Mannel, Eric |  | Design |  |  | Eric Mannel | BNL | null | POM02.1.05.03.01 |  | 01 | B |  |  | S225000 | CalEl Clock Master | yes | L4 | C |  | 2019-03-29 |  |  | 16712 |  |  |  |  |
| S248900 |  | Design Digitizer Crate: 7-Crate Preproduction |  | 10d | 2019-01-23 A | 2019-02-05 A | S248400 | 100% |  |  |  |  |  |  | S248900 | 100 | S225100 | NOCA | Completed | Mannel, Eric |  | Design |  |  | Eric Mannel | BNL | null | POM02.1.05.03.01 |  | 01 | B |  |  | S225100 |  | yes | L4 | C |  |  |  |  | 16712 |  |  |  |  |
| OBLG250410 |  | Procure EMCAL 7-Crate Digitizer - Parts - Obligation |  | 1d | 2019-01-31 A | 2019-01-31 A | S250300 | 100% |  |  | Obligation Resource |  |  | 190418 ELM BNLU per GRY | S250400 | 100 | S338080 | NOCA | Completed | Mannel, Eric |  | Procurement | PP5 | MP109400 | Eric Mannel | BNL |  | POM02.1.05.03.01 |  | 01 | A-OPC | L5 |  |  |  | yes |  |  |  |  |  |  |  |  |  |  |  |
| OBLG250510 |  | Procure EMCAL 7-Crate Digitizer (Boards) - Obligation |  | 1d | 2019-01-31 A | 2019-01-31 A | S250300 | 100% |  |  | Obligation Resource |  |  | 190418 ELM BNLU per GRY | S250500 | 100 | S277592364 | NOCA | Completed | Mannel, Eric |  | Procurement | PP5 | MP109410 | Eric Mannel | BNL |  | POM02.1.05.03.01 |  | 01 | A-OPC | L5 |  |  |  | yes |  |  |  |  |  |  |  |  |  |  |  |
| OBLG250610 |  | Procure EMCAL 7-Crate Digitizer (Assembly & Tests) - Obligation |  | 1d | 2019-01-31 A | 2019-01-31 A | S250300 | 100% |  |  | Obligation Resource |  |  | 190418 ELM BNLU per GRY | S250600 | 100 | S277592404 | NOCA | Completed | Mannel, Eric |  | Procurement | PP5 | MP109420 | Eric Mannel | BNL |  | POM02.1.05.03.01 |  | 01 | A-OPC | L5 |  |  |  | yes |  |  |  |  |  |  |  |  |  |  |  |
| S249000 |  | Layout Digitizer ADC Board: 7-Crate Preproduction |  | 10d | 2019-02-06 A | 2019-02-20 A | S248500 | 100% |  |  |  |  |  |  | S249000 | 100 | S225200 | NOCA | Completed | Mannel, Eric |  | Fab & Assy |  |  | Eric Mannel | BNL | null | POM02.1.05.03.01 |  | 01 | B |  |  | S225200 |  | yes | L4 | C |  |  |  |  | 16712 |  |  |  |  |
| S249100 |  | Layout Digitizer Controller Board: 7-Crate Preproduction |  | 10d | 2019-02-06 A | 2019-02-20 A | S248600 | 100% |  |  |  |  |  |  | S249100 | 100 | S225300 | NOCA | Completed | Mannel, Eric |  | Fab & Assy |  |  | Eric Mannel | BNL | null | POM02.1.05.03.01 |  | 01 | B |  |  | S225300 |  | yes | L4 | C |  |  |  |  | 16712 |  |  |  |  |
| S249200 |  | Layout Digitizer XMIT Board: 7-Crate Preproduction |  | 10d | 2019-02-06 A | 2019-02-20 A | S248700 | 100% |  |  |  |  |  |  | S249200 | 100 | S225400 | NOCA | Completed | Mannel, Eric |  | Fab & Assy |  |  | Eric Mannel | BNL | null | POM02.1.05.03.01 |  | 01 | B |  |  | S225400 |  | yes | L4 | C |  |  |  |  | 16712 |  |  |  |  |
| S249300 |  | Layout Digitizer Clock Master: 7-Crate Preproduction |  | 81d | 2019-02-06 A | 2019-05-31 A | S248810 | 100% |  |  |  |  |  |  | S249300 | 75 | S225500 | NOCA | Completed | Mannel, Eric |  | Fab & Assy |  |  | Eric Mannel | BNL | null | POM02.1.05.03.01 |  | 01 | B |  |  | S225500 | CalEl Clock Master | yes | L4 | C |  | 2019-03-29 |  |  | 16712 |  |  |  |  |
| S250700 |  | Procure EMCAL 7-Crate Digitizer - Parts - Leadtime |  | 19d | 2019-05-06 A | 2019-05-31 A | S250400 SS, S249600, OBLG250410 SS | 100% |  |  |  |  |  |  | S250700 | 1 | S338180 | NOCA | Completed | Mannel, Eric |  | Fab & Assy | PP6 | MP109400 | Eric Mannel | BNL |  | POM02.1.05.03.01 |  | 01 |  |  |  |  |  |  |  |  |  | 2019-07-23 | OPC002100 |  |  |  |  |  |  |
| S250800 |  | Procure EMCAL 7-Crate Digitizer - Boards - Leadtime |  | 19d | 2019-05-06 A | 2019-05-31 A | S249600, S250500 SS, OBLG250510 SS | 100% |  |  |  |  |  |  | S250800 | 1 | S338280 | NOCA | Completed | Mannel, Eric |  | Fab & Assy | PP6 | MP109410 | Eric Mannel | BNL |  | POM02.1.05.03.01 |  | 01 |  |  |  |  |  |  |  |  |  | 2019-07-23 | OPC002100 |  |  |  |  |  |  |
| S248810 |  | Design Digitizer Clock Master: 7-Crate Preproduction Split |  | 20d | 2019-06-03 A | 2019-06-28 A | S248800 | 100% |  |  | PROF4 PO E [10 h] | 1,429.76 |  |  | S248800 | 75 | S225000 | CA | Completed | Mannel, Eric |  | Design |  |  | Eric Mannel | BNL | null | POM02.1.05.03.01 |  | 01 | B |  |  | S225000 | CalEl Clock Master |  | L4 | C |  | 2019-03-29 |  |  | 16712 | S248810 | 1.05 | 1.05B |  |
| S249310 |  | Layout Digitizer Clock Master: 7-Crate Preproduction Split |  | 20d | 2019-06-03 A | 2019-06-28 A | S249300 | 100% |  |  | PROF4 PO E [10 h] | 1,429.76 |  |  | S249300 | 75 | S225500 | CA | Completed | Mannel, Eric |  | Fab & Assy |  |  | Eric Mannel | BNL | null | POM02.1.05.03.01 |  | 01 | B |  |  | S225500 | CalEl Clock Master |  | L4 | C |  | 2019-03-29 |  |  | 16712 | S249310 | 1.05 | 1.05B |  |
| S248110 |  | Procure 1/2-Crate Digitizer - Contract/PO - Leadtime for Assembly & Tests Split |  | 27d | 2019-06-03 A | 2019-06-19 A | S248100 | 100% | 2019-06-03 | 2019-07-10 |  |  |  |  | S248100 | 75 | S224570 | NOCA | Completed | Mannel, Eric |  | Fab & Assy | PP6 | MP108220 | Eric Mannel | BNL |  | POM02.1.05.03.01 |  | 01 |  |  |  | S223600 | CalEl Digitizer v2 |  |  |  | Yes | 2019-01-07 | OPC002000 |  |  |  |  |  |  |
| S248200 |  | Procure 1/2-Crate Digitizer - Contract/PO - Delivery Acceptance for Assembly & Tests |  | 7d | 2019-06-20 A | 2019-06-28 A | S247700, S248000, S248110 | 100% |  |  | Material (Purchase (1st $2M) [50000 h] | 55,163.25 |  |  | S248200 | 0 | S224580 | CA | Completed | Mannel, Eric |  | Fab & Assy | PP6 | MP108220 | Eric Mannel | BNL | OPC | POM02.1.05.03.01 |  | 01 | A-OPC |  |  | S223600 | CalEl Digitizer v2 |  | M5 | C | Yes |  | OPC002000 | Delivery | 16704 | S248200 | 1.05 | 1.05A | UDF_G3 |
| S248300 |  | Calorimeter Digitizer 1/2-Crate Complete | milestone | 0d | 2019-07-01 A | 2019-07-01 A | S248200 | 100% |  |  |  |  |  |  | S248300 | 0 | S223800 | NOCA | Completed | Mannel, Eric |  | Fab & Assy |  |  | Eric Mannel | BNL |  | POM02.1.05.03.01 |  | 01 |  | L5 |  | S223800 | CalEl Digitizer v2 |  |  |  |  |  |  |  |  |  |  |  |  |
| S250710 |  | Procure EMCAL 7-Crate Digitizer - Parts - Leadtime Split |  | 0d | 2019-07-30 A | 2019-07-30 A | S250700 | 100% |  |  |  |  |  |  | S250700 | 1 | S338180 | NOCA | Completed | Mannel, Eric |  | Fab & Assy | PP6 | MP109400 | Eric Mannel | BNL |  | POM02.1.05.03.01 |  | 01 |  |  |  |  |  |  |  |  |  | 2019-07-23 | OPC002100 |  |  |  |  |  |  |
| S250810 |  | Procure EMCAL 7-Crate Digitizer - Boards - Leadtime Split |  | 0d | 2019-07-30 A | 2019-07-30 A | S250800 | 100% |  |  |  |  |  |  | S250800 | 1 | S338280 | NOCA | Completed | Mannel, Eric |  | Fab & Assy | PP6 | MP109410 | Eric Mannel | BNL |  | POM02.1.05.03.01 |  | 01 |  |  |  |  |  |  |  |  |  | 2019-07-23 | OPC002100 |  |  |  |  |  |  |
| S250400 |  | Procure EMCAL 7-Crate Digitizer - Parts - Contract Award | milestone | 0d | 2019-08-01 A | 2019-08-01 A | S250300 | 100% |  |  |  |  |  |  | S250400 | 0 | S338080 | NOCA | Completed | Mannel, Eric |  | Procurement | PP5 | MP109400 | Eric Mannel | BNL |  | POM02.1.05.03.01 |  | 01 | A-OPC | L5 |  |  |  |  |  |  |  |  |  | Contract Award |  |  |  |  |  |
| S250500 |  | Procure EMCAL 7-Crate Digitizer - Boards - Contract Award | milestone | 0d | 2019-08-01 A | 2019-08-01 A | S250300 | 100% |  |  |  |  |  |  | S250500 | 0 | S277592364 | NOCA | Completed | Mannel, Eric |  | Procurement | PP5 | MP109410 | Eric Mannel | BNL |  | POM02.1.05.03.01 |  | 01 | A-OPC | L5 |  |  |  |  |  |  |  |  |  | Contract Award |  |  |  |  |  |

Notes:
- S244600: BNL_UDF_Adhoc Comments: 180719 ELM added procurement string / BNL_UDF_Old Activity Name 181221: Procure Contracted Labor & M&S Univ. Michigan (UM) - Provide Requirements to Procurement
- S244700: BNL_UDF_Adhoc Comments: 180719 ELM added procurement string / BNL_UDF_Old Activity Name 181221: Procure Contracted Labor & M&S Univ. Michigan (UM) - Vendor Selection
- OBLG244810: BNL_UDF_Adhoc Comments: 180719 ELM added procurement string / BNL_UDF_Old Activity Name 181221: Procure Contracted Labor & M&S Univ. Michigan (UM) - Contract Award No. 1 - FY19
- S244800: BNL_UDF_Adhoc Comments: 180719 ELM added procurement string / BNL_UDF_Old Activity Name 181221: Procure Contracted Labor & M&S Univ. Michigan (UM) - Contract Award No. 1 - FY19
- OBLG245110: BNL_UDF_Adhoc Comments: 180719 ELM added procurement string / BNL_UDF_Old Activity Name 181221: Procure Contracted Labor & M&S Univ. Michigan (UM) - Contract Award No. 2 - FY 20
- S245100: BNL_UDF_Adhoc Comments: 180719 ELM added procurement string / BNL_UDF_Old Activity Name 181221: Procure Contracted Labor & M&S Univ. Michigan (UM) - Contract Award No. 2 - FY 20
- S245500: General Comments: 180420 GYoung: concerning Design / changes Review - from working prototype / digitizer / BNL_UDF_Old Activity Name 181221: Review and write design change specifications for calorimeter digitizer system: 1/2-Crate Prototype
- S245600: BNL_UDF_Old Activity Name 181221: Design Digitzer ADC Boards: 1/2-Crate Prototype
- S245700: BNL_UDF_Old Activity Name 181221: Design Digitizer Controller Board: 1/2-Crate Prototype
- S245800: BNL_UDF_Old Activity Name 181221: Design Digitizer XMIT Board: 1/2-Crate Prototype
- S245900: BNL_UDF_Old Activity Name 181221: Design Digitizer Clock Master: 1/2-Crate Prototype
- S246000: BNL_UDF_Old Activity Name 181221: Design Digitzer Crate: 1/2-Crate Prototype
- S246100: BNL_UDF_Old Activity Name 181221: Layout Digitizer ADC Board: 1/2-Crate Prototype
- S246200: BNL_UDF_Old Activity Name 181221: Layout Digitizer Controller Board: 1/2-Crate Prototype
- S246300: BNL_UDF_Old Activity Name 181221: Layout Digitzer XMIT Board: 1/2-Crate Prototype
- S246400: BNL_UDF_Adhoc Comments: 180410 ELM pred/succ per GRY / BNL_UDF_Old Activity Name 181221: Layout Digitizer Clock Master: 1/2-Crate
- S246800: BNL_UDF_Old Activity Name 181221: Procure 1/2-Crate Digitizer - Parts - Provide Requirements to Procurement
- S246900: BNL_UDF_Old Activity Name 181221: Procure 1/2-Crate Digitizer - Parts - Prepare & Send Solicitation
- S247000: BNL_UDF_Old Activity Name 181221: Procure 1/2-Crate Digitizer - Parts - Vendor Responses
- S246500: General Comments: 180420 GYoung: concerning Safety / Review - Safety here refers to BNL check that designs are safe to operate / before fabricating them / BNL_UDF_Adhoc Comments: 180413 ELM pred/succ, status per GRY / BNL_UDF_Old Activity Name 181221: Calorimeter Digitzer System Electrical Safety Review
- S247100: BNL_UDF_Old Activity Name 181221: Procure 1/2-Crate Digitizer - Parts - Vendor Selection
- S246600: BNL_UDF_Old Activity Name 181221: Calorimeter Digitizer Safety Review Complete
- S246700: BNL_UDF_Old Activity Name 181221: Review Calorimeter Digitizer Safety Review Report
- S246701: BNL_UDF_Old Activity Name 181221: Review Calorimeter Digitizer Safety Review Report
- OBLG247210: BNL_UDF_Old Activity Name 181221: Procure 1/2-Crate Digitizer - Parts - Contract Award(s)
- OBLG247310: BNL_UDF_Old Activity Name 181221: Procure 1/2-Crate Digitizer - Boards - Contract Award(s)
- OBLG247410: BNL_UDF_Old Activity Name 181221: Procure 1/2-Crate Digitizer - Assembly & Tests - Contract Award(s)
- S247200: BNL_UDF_Old Activity Name 181221: Procure 1/2-Crate Digitizer - Parts - Contract Award(s)
- S247300: BNL_UDF_Old Activity Name 181221: Procure 1/2-Crate Digitizer - Boards - Contract Award(s)
- S247400: BNL_UDF_Old Activity Name 181221: Procure 1/2-Crate Digitizer - Assembly & Tests - Contract Award(s)
- S247500: BNL_UDF_Adhoc Comments: 180402 ELM dur / BNL_UDF_Old Activity Name 181221: Procure 1/2-Crate Digitizer - Parts - Leadtime - FY18
- S247800: BNL_UDF_Adhoc Comments: 180402 ELM dur / BNL_UDF_Old Activity Name 181221: Procure 1/2-Crate Digitizer - Boards - Contract/PO - Leadtime FY18
- S249700: BNL_UDF_Adhoc Comments: 180412 ELM dur per GRY; 180410 ELM pred/succ per GRY / BNL_UDF_Old Activity Name 181221: Procure EMCAL 7-Crate Digitizer - Provide Requirements to Procurement FY18
- S249900: BNL_UDF_Old Activity Name 181221: Procure EMCAL 7-Crate Digitizer - Prepare & Send Solicitation FY18
- S250100: BNL_UDF_Old Activity Name 181221: Procure EMCAL 7-Crate Digitizer - Vendor Responses FY18
- S248100: BNL_UDF_Adhoc Comments: 180402 ELM dur / BNL_UDF_Old Activity Name 181221: Procure 1/2-Crate Digitizer - Contract/PO - Leadtime for Assembly & Tests
- S247600: BNL_UDF_Adhoc Comments: 180402 ELM dur / BNL_UDF_Old Activity Name 181221: Procure 1/2-Crate Digitizer - Parts - Leadtime - FY19
- S247700: BNL_UDF_Adhoc Comments: 180406 RFG filled in BNL_Cost Basis; 180402 ELM Added Activity / BNL_UDF_Old Activity Name 181221: Procure 1/2-Crate Digitizer - Parts - Delivery Acceptance
- S247900: BNL_UDF_Adhoc Comments: 180402 ELM dur / BNL_UDF_Old Activity Name 181221: Procure 1/2-Crate Digitizer - Boards - Contract/PO - Leadtime FY19
- S248000: BNL_UDF_Adhoc Comments: 180402 ELM Added Activity / BNL_UDF_Old Activity Name 181221: Procure 1/2-Crate Digitizer - Boards - Delivery Acceptance
- S249800: BNL_UDF_Adhoc Comments: 180412 ELM dur per GRY; 180410 ELM pred/succ per GRY / BNL_UDF_Old Activity Name 181221: Procure EMCAL 7-Crate Digitizer - Provide Requirements to Procurement FY19
- S250000: BNL_UDF_Old Activity Name 181221: Procure EMCAL 7-Crate Digitizer - Prepare & Send Solicitation FY19
- S250200: BNL_UDF_Old Activity Name 181221: Procure EMCAL 7-Crate Digitizer - Vendor Responses FY19
- S250300: BNL_UDF_Old Activity Name 181221: Procure EMCAL 7-Crate Digitizer - Vendor Selection
- S248500: BNL_UDF_Adhoc Comments: 180718 ELM rsrc per GRY; 180423 ELM rsrc per GRY / BNL_UDF_Old Activity Name 181221: Design Digitzer ADC Boards: 7-Crate Preproduction
- S248600: BNL_UDF_Adhoc Comments: 180718 ELM rsrc per GRY; 180423 ELM rsrc per GRY / BNL_UDF_Old Activity Name 181221: Design Digitizer Controller Board: 7-Crate Preproduction
- S248700: BNL_UDF_Adhoc Comments: 180718 ELM rsrc per GRY; 180423 ELM rsrc per GRY / BNL_UDF_Old Activity Name 181221: Design Digitizer XMIT Board: 7-Crate Preproduction
- S248800: BNL_UDF_Adhoc Comments: 180718 ELM rsrc per GRY; 180423 ELM rsrc per GRY / BNL_UDF_Old Activity Name 181221: Design Digitizer Clock Master: 7-Crate Preproduction
- S248900: BNL_UDF_Adhoc Comments: 180718 ELM rsrc per GRY; 180423 ELM rsrc per GRY / BNL_UDF_Old Activity Name 181221: Design Digitzer Crate: 7-Crate Preproduction
- OBLG250410: BNL_UDF_Old Activity Name 181221: Procure EMCAL 7-Crate Digitizer - Parts - Contract Award
- OBLG250510: BNL_UDF_Old Activity Name 181221: Procure EMCAL 7-Crate Digitizer - Boards - Contract Award
- OBLG250610: BNL_UDF_Old Activity Name 181221: Procure EMCAL 7-Crate Digitizer - Assembly & Tests - Contract Award
- S249000: BNL_UDF_Adhoc Comments: 180718 ELM rsrc per GRY; 180423 ELM rsrc per GRY / BNL_UDF_Old Activity Name 181221: Layout Digitizer ADC Board: 7-Crate Preproduction
- S249100: BNL_UDF_Adhoc Comments: 180718 ELM rsrc per GRY; 180423 ELM rsrc per GRY / BNL_UDF_Old Activity Name 181221: Layout Digitizer Controller Board: 7-Crate Preproduction
- S249200: BNL_UDF_Adhoc Comments: 180718 ELM rsrc per GRY; 180423 ELM rsrc per GRY / BNL_UDF_Old Activity Name 181221: Layout Digitzer XMIT Board: 7-Crate Preproduction
- S249300: BNL_UDF_Adhoc Comments: 180718 ELM rsrc per GRY; 180423 ELM rsrc per GRY / BNL_UDF_Old Activity Name 181221: Layout Digitizer Clock Master: 7-Crate Preproduction
- S250700: BNL_UDF_Adhoc Comments: 180402 ELM dur / BNL_UDF_Old Activity Name 181221: Procure EMCAL 7-Crate Digitizer - Parts - Leadtime
- S250800: BNL_UDF_Adhoc Comments: 180402 ELM dur / BNL_UDF_Old Activity Name 181221: Procure EMCAL 7-Crate Digitizer - Boards - Leadtime
- S248810: BNL_UDF_Adhoc Comments: 180718 ELM rsrc per GRY; 180423 ELM rsrc per GRY / BNL_UDF_Old Activity Name 181221: Design Digitizer Clock Master: 7-Crate Preproduction
- S249310: BNL_UDF_Adhoc Comments: 180718 ELM rsrc per GRY; 180423 ELM rsrc per GRY / BNL_UDF_Old Activity Name 181221: Layout Digitizer Clock Master: 7-Crate Preproduction
- S248110: BNL_UDF_Adhoc Comments: 180402 ELM dur / BNL_UDF_Old Activity Name 181221: Procure 1/2-Crate Digitizer - Contract/PO - Leadtime for Assembly & Tests
- S248200: BNL_UDF_Adhoc Comments: 180406 RFG filled in BNL_Cost Basis; 180402 ELM Added Activity / BNL_UDF_Old Activity Name 181221: Procure 1/2-Crate Digitizer - Contract/PO - Delivery Acceptance for Assembly & Tests
- S248300: BNL_UDF_Old Activity Name 181221: Calorimeter Digitizer 1/2-Crate Complete
- S250710: BNL_UDF_Adhoc Comments: 180402 ELM dur / BNL_UDF_Old Activity Name 181221: Procure EMCAL 7-Crate Digitizer - Parts - Leadtime
- S250810: BNL_UDF_Adhoc Comments: 180402 ELM dur / BNL_UDF_Old Activity Name 181221: Procure EMCAL 7-Crate Digitizer - Boards - Leadtime
- S250400: BNL_UDF_Old Activity Name 181221: Procure EMCAL 7-Crate Digitizer - Parts - Contract Award
- S250500: BNL_UDF_Old Activity Name 181221: Procure EMCAL 7-Crate Digitizer - Boards - Contract Award

| ID | WBS | Activity | Type | Duration | Start | Finish | Predecessors | Complete | Remaining | Planned start | Planned finish | Total float | Free float | Constraint | Expected finish | Resources | Cost | BNL_UDF_Status Comments | BNL_UDF_Temp Text 01 | BNL_UDF_Adhoc Comments | BNL_UDF_Percent Complete | BNL_UDF_OPC TEC (deprecated) | BNL_UDF_Old Activity ID 181221 | BNL_Cobra WP | RG Check | BNL_Activity Status | BNL_Fund Source | BNL_Estimator | BNL_Cost Basis | BNL_EDIA | BNL_CAM | BNL_Institution | BNL_OPC TEC (deprecated) | BNL_WBS | BNL_EVT | BNL_Master Control Account | BNL_Account Number | BNL_PCR ID | BNL_Cobra Control Account | BNL_WBS_Hierarchical | BNL_Milestone Level | Indicator - Procurement | BNL_Proc Sig Phase | BNL_Proc Sig | BNL_DOE OPC | SPH Proc Register | Indicator - Float | BNL_UDF_Remaining Tot Cost | BNL_UDF_Percent_remaining | BNL_UDF_Temp Date 01 | BNL_Obligation | Target Milestone Date | Variance | PMP Milestones |
| --- | --- | --- | --- | --- | --- | --- | --- | --- | --- | --- | --- | --- | --- | --- | --- | --- | --- | --- | --- | --- | --- | --- | --- | --- | --- | --- | --- | --- | --- | --- | --- | --- | --- | --- | --- | --- | --- | --- | --- | --- | --- | --- | --- | --- | --- | --- | --- | --- | --- | --- | --- | --- | --- | --- |
| S249400 |  | Final Design Review, Procurement Readiness Review, Electrical Safety Review - Calorimeter Digitizer 7-crate |  | 6d | 2019-08-15 A | 2019-08-22 A | S248900, S249000, S249100, S249200, S249310 | 100% |  |  |  |  |  | start on or after 2019-09-02 |  | PROF4 PO E [80 h] | 11,438.06 | 190508 ELM name per GRY; 190415 ELM name per GRY | S249400 | 180718 ELM rsrc per GRY; 180423 ELM rsrc per GRY | 0 | S225600 | S225600 | S249400 | CA | Completed | B | Mannel, Eric | L4 | Management Safety Reviews | Eric Mannel | BNL | null | POM02.1.05.03.01 | C | 1.05 | 16712 | 004 | 1.05B | 01 |  |  |  |  |  |  |  |  |  |  |  |  |  |  |
| S248400 |  | Review and write design change specifications for calorimeter digitizer system: 7-Crate Preproduction |  | 12d | 2019-08-15 A | 2019-08-30 A | S248300 | 100% |  |  |  |  |  | start on or after 2019-08-15 |  | PROF4 PO E [28 h] | 4,003.32 |  | S248400 |  | 0 | S224600 | S224600 | S248400 | CA | Completed | B | Mannel, Eric | L4 | Design | Eric Mannel | BNL | null | POM02.1.05.03.01 | C | 1.05 | 16712 |  | 1.05B | 01 |  |  |  |  |  |  |  |  |  |  |  |  |  |  |
| S249600 |  | Review Calorimeter Digitizer Safety Review Report |  | 6d | 2019-08-22 A | 2019-08-30 A | S249500 | 100% |  | 2019-08-22 | 2019-08-29 |  |  | start on or after 2019-09-20 |  | PROF4 PO E [120 h] | 17,157.09 |  | S249600 | 180423 ELM rsrc per GRY | 0 | S225800 | S225800 | S249600 | CA | Completed | B | Mannel, Eric | L4 | Management Safety Reviews | Eric Mannel | BNL | null | POM02.1.05.03.01 | C | 1.05 | 16712 |  | 1.05B | 01 |  |  |  |  |  |  |  |  |  |  |  |  |  |  |
| S249500 |  | Calorimeter Digitizer Safety Review Complete | milestone | 0d | 2019-08-30 A | 2019-08-30 A | S249400 | 100% |  | 2019-09-30 | 2019-09-30 |  |  |  |  |  |  |  | S249500 |  | 0 | S225700 | S225700 |  | NOCA | Completed |  | Mannel, Eric |  | Management Safety Reviews | Eric Mannel | BNL |  | POM02.1.05.03.01 |  |  |  |  |  | 01 | L5 |  |  |  |  |  |  |  |  |  |  |  |  |  |
| S251000 |  | Procure EMCAL 7-Crate Digitizer - Parts - Delivery Acceptance |  | 61d | 2019-09-03 A | 2019-11-25 A | S250710 | 100% |  | 2019-09-03 | 2019-12-02 |  |  | start on or after 2019-09-02 |  | Material (Purchase (1st $2M) [177359 h] | 199,805.84 | 190418 ELM BNLU per GRY | S251000 | 180406 ELM pred per GRY; 180402 ELM dur | 0 |  | S341800 | S251000 | CA | Completed | A-OPC | Mannel, Eric | M3 | Fab & Assy | Eric Mannel | BNL | OPC | POM02.1.05.03.01 | C | 1.05 | 16704 | 004 | 1.05A | 01 |  | UDF_G2 | PP6 | MP109400 | OPC002100 | Delivery |  |  |  |  |  |  |  |  |
| S251100 |  | Procure EMCAL 7-Crate Digitizer (Boards) - Delivery Acceptance |  | 61d | 2019-11-19 A | 2020-06-30 A | S250810 | 100% |  | 2019-11-01 | 2020-02-03 |  |  | start on or after 2019-11-01 |  | Material (Purchase (1st $2M) [39371 h] | 44,801.28 | 190418 ELM BNLU per GRY | S251100 | 180406 ELM pred per GRY; 180402 ELM dur | 0 |  | S341840 | S251100 | CA | In Progress | A-OPC | Mannel, Eric | M3 | Fab & Assy | Eric Mannel | BNL | OPC | POM02.1.05.03.01 | C | 1.05 | 16704 | 004 | 1.05A | 01 |  | UDF_G1 | PP6 | MP109410 | OPC002100 | Delivery | UDF_G3 | 33600.9572085 | 0.75 |  |  |  |  |  |
| S250600 |  | Procure EMCAL 7-Crate Digitizer - Assembly & Tests - Contract Award | milestone | 0d | 2019-12-02 A | 2019-12-02 A | S250300 | 100% |  |  |  |  |  | start on or after 2019-12-02 |  |  |  |  | S250600 |  | 0 |  | S277592404 |  | NOCA | Completed | A-OPC | Mannel, Eric |  | Procurement | Eric Mannel | BNL |  | POM02.1.05.03.01 |  |  |  |  |  | 01 | L5 |  | PP5 | MP109420 |  | Contract Award |  |  |  |  |  |  |  |  |
| S250900 |  | Procure EMCAL 7-Crate Digitizer - Assembly & Tests - Leadtime |  | 40d | 2020-05-04 A | 2020-07-31 A | S251000, S251100, S249600, S247400 SS, S250600 SS, OBLG250610 SS, OBLG247410 SS | 100% |  | 2020-05-04 | 2020-06-29 |  |  |  |  |  |  |  | S250900 | 180406 ELM pred per GRY; 180402 ELM dur | 0 |  | S338380 |  | NOCA | Not Started |  | Mannel, Eric |  | Procurement | Eric Mannel | BNL |  | POM02.1.05.03.01 |  |  |  |  |  | 01 |  |  | PP6 | MP109420 | OPC002100 |  |  |  |  | 2019-10-17 |  |  |  |  |
| S251200 |  | Procure EMCAL 7-Crate Digitizer (Assembly & Tests) - Delivery Acceptance |  | 5d | 2020-08-03 A | 2020-09-30 A | S250900 | 100% |  | 2020-08-03 | 2020-08-07 |  |  |  |  | Material (Purchase (1st $2M) [79858 h] | 90,872.48 | 190418 ELM BNLU per GRY | S251200 | 180406 ELM pred per GRY; 180402 ELM dur | 0 |  | S341880 | S251200 | CA | Not Started | A-OPC | Mannel, Eric | M3 | Fab & Assy | Eric Mannel | BNL | OPC | POM02.1.05.03.01 | C | 1.05 | 16704 | 004 | 1.05A | 01 |  | UDF_G1 | PP6 | MP109420 | OPC002100 | Delivery | UDF_G3 | 90872.477738 | 1 |  |  |  |  |  |
| S251300 |  | Preprod Calorimeter Digitizer 7-Crate Complete | milestone | 0d | 2020-09-30 A | 2020-09-30 A | S251200 | 100% |  | 2020-11-02 | 2020-11-02 |  |  |  |  |  |  |  | S251300 |  | 0 | S226300 | S226300 |  | NOCA | Not Started |  | Mannel, Eric |  | Fab & Assy | Eric Mannel | BNL |  | POM02.1.05.03.01 |  |  |  |  |  | 01 | L5 | UDF_G1 |  |  |  |  | UDF_G3 |  |  |  |  |  |  |  |
|  | 02 | **Calorimeter Digitizers: Production** |  |  | 2020-05-13 | 2022-01-28 |  |  |  |  |  |  |  |  |  |  |  |  |  |  |  |  |  |  |  |  |  |  |  |  |  |  |  |  |  |  |  |  |  |  |  |  |  |  |  |  |  |  |  |  |  |  |  |  |
| S251700 |  | Procure Production Digitizer - Provide Requirements to Procurement |  | 20d | 2020-05-13 A | 2020-05-27 A | S251600 | 100% |  | 2020-07-29 | 2020-08-25 |  |  |  |  | PROF4 PO E [160 h] | 23,562.4 |  | S251700 | 180718 ELM rsrc per GRY; 180412 ELM dur per GRY | 0 | S226800 | S226350 | S251700 | CA | Not Started | B | Mannel, Eric | L4 | Procurement | Eric Mannel | BNL | null | POM02.1.05.03.02 | C | 1.05 | 16712 |  | 1.05B | 02 |  |  | PP1 | MP106500 |  |  |  |  |  |  |  |  |  |  |
| S251800 |  | Procure Production Digitizer - Prepare & Send Solicitation |  | 30d | 2020-05-13 A | 2020-05-27 A | S251700 | 100% |  | 2020-08-26 | 2020-10-07 |  |  |  |  |  |  |  | S251800 |  | 0 | S226900 | S226360 |  | NOCA | Not Started |  | Mannel, Eric |  | Procurement | Eric Mannel | BNL |  | POM02.1.05.03.02 |  |  |  |  |  | 02 |  |  | PP2 | MP106500 |  |  |  |  |  |  |  |  |  |  |
| S251900 |  | Procure Production Digitizer - Vendor Responses |  | 20d | 2020-05-13 A | 2020-05-27 A | S251800 | 100% |  | 2020-10-08 | 2020-11-05 |  |  |  |  |  |  |  | S251900 |  | 0 | S226400 | S226400 |  | NOCA | Not Started |  | Mannel, Eric |  | Procurement | Eric Mannel | BNL |  | POM02.1.05.03.02 |  |  |  |  |  | 02 |  |  | PP3 | MP106500 |  |  |  |  |  |  |  |  |  |  |
| S252000 |  | Procure Production Digitizer - Vendor Selection |  | 40d | 2020-05-13 A | 2020-05-27 A | S251900 | 100% |  | 2020-11-06 | 2021-01-07 |  |  |  |  |  |  |  | S252000 |  | 0 | S226500 | S226500 |  | NOCA | Not Started |  | Mannel, Eric |  | Procurement | Eric Mannel | BNL |  | POM02.1.05.03.02 |  |  |  |  |  | 02 |  |  | PP4 | MP106500 |  |  |  |  |  |  |  |  |  |  |
| S252100 |  | Procure Production Digitizer (Parts) Contract Award(s) | milestone | 0d | 2020-11-02 A | 2020-11-02 A | S252000, S101000, S101015 SS | 100% |  | 2020-12-22 | 2020-12-22 |  |  |  |  |  |  |  | S252100 |  | 0 | S226600 | S226600 |  | NOCA | Not Started | A-TEC | Mannel, Eric |  | Procurement | Eric Mannel | BNL |  | POM02.1.05.03.02 |  |  |  |  |  | 02 | L5 | UDF_G1 | PP5 | MP106500 |  | Contract Award | UDF_G3 |  |  |  |  |  |  |  |
| S252200 |  | Procure Production Digitizer (Boards) Contract Award(s) | milestone | 0d | 2020-11-02 A | 2020-11-02 A | S252000, S101000, S101015 SS | 100% |  | 2020-12-22 | 2020-12-22 |  |  |  |  |  |  |  | S252200 |  | 0 | S226600 | S277591964 |  | NOCA | Not Started | A-TEC | Mannel, Eric |  | Procurement | Eric Mannel | BNL |  | POM02.1.05.03.02 |  |  |  |  |  | 02 | L5 | UDF_G1 | PP5 | MP106510 |  | Contract Award | UDF_G3 |  |  |  |  |  |  |  |
| S252300 |  | Procure Production Digitizer (Assembly & Tests) - Contract Award(s) | milestone | 0d | 2020-11-02 A | 2020-11-02 A | S252000, S101000, S101015 SS | 100% |  | 2020-12-22 | 2020-12-22 |  |  |  |  |  |  |  | S252300 |  | 0 | S226600 | S277592004 |  | NOCA | Not Started | A-TEC | Mannel, Eric |  | Procurement | Eric Mannel | BNL |  | POM02.1.05.03.02 |  |  |  |  |  | 02 | L5 | UDF_G1 | PP5 | MP106520 |  | Contract Award | UDF_G3 |  |  |  |  |  |  |  |
| S252400 |  | Procure Production Digitizer - Contract/PO - Leadtime for Parts |  | 55d | 2020-11-16 A | 2021-05-31 A | S252100 SS, OBLG252110 SS | 100% |  | 2020-12-22 | 2021-03-12 |  |  |  |  |  |  |  | S252400 | 180402 ELM dur | 0 | S226700 | S226700 |  | NOCA | Not Started |  | Mannel, Eric |  | Fab & Assy | Eric Mannel | BNL |  | POM02.1.05.03.02 |  |  |  |  |  | 02 |  |  | PP6 | MP106500 |  |  |  |  |  |  |  |  |  |  |
| S252500 |  | Procure Production Digitizer - Contract/PO - Leadtime for Boards |  | 55d | 2020-11-16 A | 2021-08-02 | S252200 SS, OBLG252210 SS | 50% | 44d | 2020-12-22 | 2021-03-12 | 61d | 0d |  | 2021-08-02 |  |  |  | S252500 | 180402 ELM dur | 0 | S227000 | S227000 |  | NOCA | Not Started |  | Mannel, Eric |  | Fab & Assy | Eric Mannel | BNL |  | POM02.1.05.03.02 |  |  |  |  |  | 02 |  |  | PP6 | MP106500 |  |  |  |  |  |  |  |  |  |  |
| S251400 |  | Production Readiness & Safety Review: Calorimeter Digitizers |  | 5d | 2020-12-01 A | 2020-12-07 A | S251300 | 100% |  |  |  |  |  |  |  | PROF4 PO E [160 h] | 24,269.27 | 190523 ELM name; 190415 ELM name per GRY | S251400 | 180423 ELM rsrc per GRY; 180411 ELM dur per GRY | 0 | S228600 | S228600 | S251400 | CA | Not Started | B | Mannel, Eric | L4 | Management Safety Reviews | Eric Mannel | BNL | null | POM02.1.05.03.02 | C | 1.05 | 16712 | 004 | 1.05B | 02 |  |  |  |  |  |  |  |  |  |  |  |  |  |  |
| S251500 |  | Complete: Procurement Readiness Review, Safety Review - Calorimeter Digitizer Final Order | milestone | 0d | 2020-12-07 A | 2020-12-07 A | S251400 | 100% |  |  |  |  |  |  |  |  |  | 190508 ELM name per GRY | S251500 |  | 0 | S228700 | S228700 |  | NOCA | Not Started |  | Mannel, Eric |  | Management Safety Reviews | Eric Mannel | BNL |  | POM02.1.05.03.02 |  |  |  | 004 |  | 02 | L2 | UDF_G1 |  |  |  |  | UDF_G3 |  |  |  |  |  |  |  |
| S251600 |  | Review Calorimeter Electronics Readiness & Safety Review Report |  | 10d | 2020-12-08 A | 2020-12-21 A | S251400, S251500 | 100% |  |  |  |  |  |  |  | PROF4 PO E [136 h] | 20,628.88 |  | S251600 | 180423 ELM rsrc per GRY | 0 | S228800 | S228800 | S251600 | CA | Not Started | B | Mannel, Eric | L4 | Management Safety Reviews | Eric Mannel | BNL | null | POM02.1.05.03.02 | C | 1.05 | 16712 |  | 1.05B | 02 |  |  |  |  |  |  |  |  |  |  |  |  |  |  |
| OBLG252110 |  | Procure Production Digitizer (Parts) Obligation |  | 1d | 2020-12-22 A | 2020-12-22 A | S252000, S101000, S101015 SS | 100% |  |  |  |  |  |  |  | Obligation Resource [678538 h] | 678,538.48 |  | S252100 |  | 0 | S226600 | S226600 |  |  | Not Started | A-TEC | Mannel, Eric |  | Procurement | Eric Mannel | BNL |  | POM02.1.05.03.02 |  |  |  |  |  | 02 | L5 |  | PP5 | MP106500 |  |  |  |  |  |  | OBLG |  |  |  |
| OBLG252210 |  | Procure Production Digitizer (Boards) - Obligation |  | 1d | 2020-12-22 A | 2020-12-22 A | S252000, S101000, S101015 SS | 100% |  |  |  |  |  |  |  | Obligation Resource [149785 h] | 149,785.17 |  | S252200 |  | 0 | S226600 | S277591964 |  |  | Not Started | A-TEC | Mannel, Eric |  | Procurement | Eric Mannel | BNL |  | POM02.1.05.03.02 |  |  |  |  |  | 02 | L5 |  | PP5 | MP106510 |  |  |  |  |  |  | OBLG |  |  |  |
| OBLG252310 |  | Procure Production Digitizer (Assembly & Tests) - Obligation |  | 1d | 2020-12-22 A | 2020-12-22 A | S252000, S101000, S101015 SS | 100% |  |  |  |  |  |  |  | Obligation Resource [231066 h] | 231,065.59 |  | S252300 |  | 0 | S226600 | S277592004 |  |  | Not Started | A-TEC | Mannel, Eric |  | Procurement | Eric Mannel | BNL |  | POM02.1.05.03.02 |  |  |  |  |  | 02 | L5 |  | PP5 | MP106520 |  |  |  |  |  |  | OBLG |  |  |  |
| S252700 |  | Procure Production Digitizer (Parts) - Delivery Acceptance |  | 5d | 2021-04-30 A | 2021-08-09 | S252400 | 37% | 49d | 2021-08-03 | 2021-08-09 | 61d | 0d |  | 2021-08-09 | Material (Purchase (1st $2M) [584602 h] | 678,538.37 |  | S252700 | 180402 ELM added activithy for delivery acc. | 0 | S226700 | S341680 | S252700 | CA | Not Started | A-TEC | Mannel, Eric | M3 | Fab & Assy | Eric Mannel | BNL | TEC | POM02.1.05.03.02 | C | 1.05 | 59716 |  | 1.05A | 02 |  | UDF_G1 | PP6 | MP106500 |  | Delivery | UDF_G3 | 678538.368995 | 1 |  | FAB |  |  |  |
| S252800 |  | Procure Production Digitizer (Boards) - Delivery Acceptance |  | 5d | 2021-08-03 | 2021-08-09 | S252500 |  |  |  |  | 61d | 0d |  |  | Material (Purchase (1st $2M) [129049 h] | 149,785.15 |  | S252800 | 180402 ELM added activithy for delivery acc. | 0 | S227000 | S341720 | S252800 | CA | Not Started | A-TEC | Mannel, Eric | M3 | Fab & Assy | Eric Mannel | BNL | TEC | POM02.1.05.03.02 | C | 1.05 | 59716 |  | 1.05A | 02 |  | UDF_G1 | PP6 | MP106510 |  | Delivery | UDF_G3 | 149785.149521 | 1 |  | FAB |  |  |  |
| S252600 |  | Procure Production Digitizer - Contract/PO - Leadtime for Assembly & Tests |  | 55d | 2021-08-10 | 2021-10-27 | S252700, S252800, S252300 SS, OBLG252310 SS |  |  |  |  | 61d | 0d |  |  |  |  |  | S252600 | 180402 ELM dur | 0 | S227700 | S227700 |  | NOCA | Not Started |  | Mannel, Eric |  | Fab & Assy | Eric Mannel | BNL |  | POM02.1.05.03.02 |  |  |  |  |  | 02 |  |  | PP6 | MP106500 |  |  |  |  |  |  |  |  |  |  |
| S252900 |  | Procure Production Digitizer (Assembly & Tests) - Delivery Acceptance |  | 5d | 2021-10-28 | 2021-11-03 | S252600 |  |  |  |  | 61d | 0d |  |  | Material (Purchase (1st $2M) [199077 h] | 235,686.86 |  | S252900 | 180402 ELM added activithy for delivery acc. | 0 | S227700 | S341760 | S252900 | CA | Not Started | A-TEC | Mannel, Eric | M3 | Fab & Assy | Eric Mannel | BNL | TEC | POM02.1.05.03.02 | C | 1.05 | 59716 |  | 1.05A | 02 |  | UDF_G1 | PP6 | MP106520 |  | Delivery | UDF_G3 | 231065.550382 | 1 |  | FAB |  |  |  |
| S253000 |  | Calorimeter Digitizer Production Complete | milestone | 0d | 2021-11-03 | 2021-11-03 | S252900 |  |  |  |  | 61d | 56d |  |  |  |  |  | S253000 |  | 0 | S229000 | S229000 |  | NOCA | Not Started |  | Mannel, Eric |  | Fab & Assy | Eric Mannel | BNL |  | POM02.1.05.03.02 |  |  |  |  |  | 02 | L2 | UDF_G1 |  |  |  |  | UDF_G3 |  |  |  |  |  |  |  |
| S253100 |  | Calorimeter Electronics Complete | milestone | 0d | 2022-01-28 | 2022-01-28 | S234300 FF, S244500 FF, S248300 FF, S253000 FF, S216500 FF |  |  |  |  | 5d |  |  |  |  |  |  | S253100 |  | 0 | S229100 | S229100 |  | NOCA | Not Started |  | Mannel, Eric |  | Fab & Assy | Eric Mannel | BNL |  | POM02.1.05.03.02 |  |  |  |  |  | 02 | L2 | UDF_G2 |  |  |  |  | UDF_G3 |  |  |  |  | 2021-10-28 | -61 | PMP_1x |

Notes:
- S249400: BNL_UDF_Old Activity Name 181221: Calorimeter Digitzer System Electrical Safety Review
- S248400: BNL_UDF_Old Activity Name 181221: Review and write design change specifications for calorimeter digitizer system: 7-Crate Preproduction
- S249600: BNL_UDF_Old Activity Name 181221: Review Calorimeter Digitizer Safety Review Report
- S249500: General Comments: 180420 GYoung: concerning / Electrical Safety Review - Safety here refers to BNL check that designs / are safe to operate before fabricating / them / BNL_UDF_Old Activity Name 181221: Calorimeter Digitizer Safety Review Complete
- S251000: BNL_UDF_Old Activity Name 181221: Procure EMCAL 7-Crate Digitizer - Parts - Delivery Acceptance
- S251100: BNL_UDF_Old Activity Name 181221: Procure EMCAL 7-Crate Digitizer - Boards - Delivery Acceptance
- S250600: BNL_UDF_Old Activity Name 181221: Procure EMCAL 7-Crate Digitizer - Assembly & Tests - Contract Award
- S250900: BNL_UDF_Old Activity Name 181221: Procure EMCAL 7-Crate Digitizer - Assembly & Tests - Leadtime
- S251200: BNL_UDF_Old Activity Name 181221: Procure EMCAL 7-Crate Digitizer - Assembly & Tests - Delivery Acceptance
- S251300: BNL_UDF_Old Activity Name 181221: Preprod Calorimeter Digitizer 7-Crate Complete
- S251700: BNL_UDF_Old Activity Name 181221: Procure Production Digitizer - Provide Requirements to Procurement
- S251800: BNL_UDF_Old Activity Name 181221: Procure Production Digitizer - Prepare & Send Solicitation
- S251900: BNL_UDF_Old Activity Name 181221: Procure Production Digitizer - Vendor Responses
- S252000: BNL_UDF_Old Activity Name 181221: Procure Production Digitizer - Vendor Selection
- S252100: BNL_UDF_Old Activity Name 181221: Procure Production Digitizer - Parts - Contract Award(s)
- S252200: BNL_UDF_Old Activity Name 181221: Procure Production Digitizer - Boards - Contract Award(s)
- S252300: BNL_UDF_Old Activity Name 181221: Procure Production Digitizer - Assembly & Tests - Contract Award(s)
- S252400: BNL_UDF_Old Activity Name 181221: Procure Production Digitizer - Contract/PO - Leadtime for Parts
- S252500: BNL_UDF_Old Activity Name 181221: Procure Production Digitizer - Contract/PO - Leadtime for Boards
- S251400: General Comments: 180420 GYoung: concerning / Production Readiness and Safety Review - Safety here refers to BNL check / that designs are safe to operate before fabricating / them / BNL_UDF_Old Activity Name 181221: Production Readiness & Safety Review: Calorimeter Digitizers
- S251500: BNL_UDF_Old Activity Name 181221: Calorimeter Digitizer Readiness & Safety Review Complete
- S251600: BNL_UDF_Old Activity Name 181221: Review Calorimeter Electronics Readiness & Safety Review Report
- OBLG252110: BNL_UDF_Old Activity Name 181221: Procure Production Digitizer - Parts - Contract Award(s)
- OBLG252210: BNL_UDF_Old Activity Name 181221: Procure Production Digitizer - Boards - Contract Award(s)
- OBLG252310: BNL_UDF_Old Activity Name 181221: Procure Production Digitizer - Assembly & Tests - Contract Award(s)
- S252700: BNL_UDF_Old Activity Name 181221: Procure Production Digitizer - Contract/PO - Delivery Acceptance for Parts
- S252800: BNL_UDF_Old Activity Name 181221: Procure Production Digitizer - Boards - Delivery Acceptance
- S252600: BNL_UDF_Old Activity Name 181221: Procure Production Digitizer - Contract/PO - Leadtime for Assembly & Tests
- S252900: BNL_UDF_Old Activity Name 181221: Procure Production Digitizer - Assembly & Tests - Delivery Acceptance
- S253000: BNL_UDF_Old Activity Name 181221: Calorimeter Digitizer Production Complete
- S253100: BNL_UDF_Old Activity Name 181221: Calorimeter Electronics Complete

| ID | WBS | Activity | Duration | Start | Finish | Predecessors | Complete | Planned start | Planned finish | Resources | Cost | BNL_UDF_Temp Text 01 | BNL_UDF_Percent Complete | BNL_UDF_Old Activity ID 181221 | BNL_Cobra WP | RG Check | BNL_Activity Status | BNL_Fund Source | BNL_Estimator | BNL_Cost Basis | BNL_Location | BNL_EDIA | BNL_CAM | BNL_Institution | BNL_OPC TEC (deprecated) | BNL_WBS | BNL_Actuals | BNL_FY | BNL_EVT | BNL_Master Control Account | BNL_Account Number | BNL_PCR ID | BNL_Cobra Control Account | BNL_WBS_Hierarchical | Completed | Indicator - Procurement | BNL_UDF_OPC TEC (deprecated) | BNL_UDF_Temp Date 01 | BNL_UDF_Adhoc Comments | BNL_Split Activity | Additional EVT documentation required | Temp | Indicator - Float | BNL_Milestone Level |
| --- | --- | --- | --- | --- | --- | --- | --- | --- | --- | --- | --- | --- | --- | --- | --- | --- | --- | --- | --- | --- | --- | --- | --- | --- | --- | --- | --- | --- | --- | --- | --- | --- | --- | --- | --- | --- | --- | --- | --- | --- | --- | --- | --- | --- |
|  | 06 | **DAQ/Trigger** |  | 2017-02-01 | 2022-01-28 |  |  |  |  |  |  |  |  |  |  |  |  |  |  |  |  |  |  |  |  |  |  |  |  |  |  |  |  |  |  |  |  |  |  |  |  |  |  |  |
| S253200 |  | Actuals - Labor - sPHENIX DAQ&Trigger FY17 | 169d | 2017-02-01 A | 2017-09-29 A | S100090 SS | 100% |  |  | Actual Labor [765.62 h] | 127,929.66 | S253200 | 100 | S338620 | S253200 | CA | Completed | B | Purschke, Martin | L1 | BNL | Design | Martin Purschke | BNL | null | POM02.1.06 | Yes | 2017 | A | 1.06 | 16713 | 003 | 1.06B | 06 | yes |  |  |  |  |  |  |  |  |  |
| S253400 |  | Actuals - Nonlabor - sPHENIX DAQ&Trigger FY17 | 169d | 2017-02-01 A | 2017-09-29 A | S100090 SS | 100% |  |  |  |  | S253400 | 100 | S339262 |  | NOCA | Completed | A-OPC | Purschke, Martin | M1 | BNL | Design | Martin Purschke | BNL | OPC | POM02.1.06 | Yes | 2017 | A |  | 16705 | 003 |  | 06 | yes |  |  |  |  |  |  |  |  |  |
| S253300 |  | Actuals - Labor - sPHENIX DAQ&Trigger FY18 | 249d | 2017-10-02 A | 2018-09-28 A | S253200 | 100% |  |  | Actual Labor [2563.35 h] | 428,317.57 | S253300 | 100 | S339260 | S253300 | CA | Completed | B | Purschke, Martin | L1 | BNL | Design | Martin Purschke | BNL | null | POM02.1.06 | Yes | 2018 | A | 1.06 | 16713 | 003 | 1.06B | 06 | yes |  |  |  |  |  |  |  |  |  |
| S253500 |  | Actuals - Nonlabor - sPHENIX DAQ&Trigger FY18 | 249d | 2017-10-02 A | 2018-09-28 A | S253400 | 100% |  |  | Actual Nonlabor [2493.26 h] | 2,781.51 | S253500 | 100 | S339265 | S253500 | CA | Completed | A-OPC | Purschke, Martin | M1 | BNL | Design | Martin Purschke | BNL | OPC | POM02.1.06 | Yes | 2018 | A | 1.06 | 16705 | 003 | 1.06A | 06 | yes | UDF_G3 |  |  |  |  |  |  |  |  |
| S1000919 |  | Actuals - Labor - sPHENIX DAQ&Trigger FY19 M8 | 166d | 2018-10-01 A | 2019-05-31 A |  | 100% |  |  | Actual Labor [1638.9 h] | 273,848.54 | S253300 | 100 | S339260 | S1000919 | CA | Completed | B | Purschke, Martin | L1 | BNL | Design | Martin Purschke | BNL | null | POM02.1.06 | Yes | 2019 | A | 1.06 | 16713 | 003 | 1.06B | 06 | yes |  |  |  |  |  |  |  |  |  |
| S1000959 |  | Actuals - Nonlabor - sPHENIX DAQ&Trigger FY18 | 166d | 2018-10-01 A | 2019-05-31 A |  | 100% |  |  | Actual Nonlabor [21020.1 h] | 23,190.7 | S253500 | 100 | S339265 | S1000959 | CA | Completed | A-OPC | Purschke, Martin | M1 | BNL | Design | Martin Purschke | BNL | OPC | POM02.1.06 | Yes | 2019 | A | 1.06 | 16705 | 003 | 1.06A | 06 | yes | UDF_G3 |  |  |  |  |  |  |  |  |
|  | 01 | **DAQ** |  | 2017-02-01 | 2022-01-28 |  |  |  |  |  |  |  |  |  |  |  |  |  |  |  |  |  |  |  |  |  |  |  |  |  |  |  |  |  |  |  |  |  |  |  |  |  |  |  |
|  | 01 | **DAQ Design** |  | 2017-02-01 | 2018-08-13 |  |  |  |  |  |  |  |  |  |  |  |  |  |  |  |  |  |  |  |  |  |  |  |  |  |  |  |  |  |  |  |  |  |  |  |  |  |  |  |
| S253600 |  | DAQ Design: DAQ Prototype Design | 100d | 2017-02-01 A | 2017-06-22 A | S100090 SS | 100% |  |  |  |  | S253600 | 100 | S229200 |  | NOCA | Completed |  | Purschke, Martin |  | BNL | Design | Martin Purschke | BNL |  | POM02.1.06.01.01 |  |  |  |  |  |  |  | 01 | yes |  | S229200 |  |  |  |  |  |  |  |
| S253700 |  | DAQ Design: Specify front-end layout | 240d | 2017-06-23 A | 2018-06-10 A | S253600 | 100% | 2017-06-23 | 2018-06-08 |  |  | S253700 | 100 | S229300 |  | NOCA | Completed |  | Purschke, Martin | L3 | BNL | Design | Martin Purschke | BNL | null | POM02.1.06.01.01 |  |  | C |  |  |  |  | 01 | yes |  | S229300 | 2018-08-30 |  |  |  |  |  |  |
| S253800 |  | DAQ Design: Specify the event Builder and back-end layout | 50d | 2018-03-30 A | 2018-06-10 A | S253700 | 100% | 2018-03-30 | 2018-06-08 |  |  | S253800 | 100 | S229400 |  | NOCA | Completed |  | Purschke, Martin | L3 | BNL | Design | Martin Purschke | BNL | null | POM02.1.06.01.01 |  |  | C |  |  |  |  | 01 | yes |  | S229400 | 2018-10-30 |  |  |  |  |  |  |
| S253900 |  | DAQ Design: Specify the high-level components | 11d | 2018-06-11 A | 2018-06-25 A | S253800 | 100% |  |  |  |  | S253900 | 100 | S229500 |  | NOCA | Completed |  | Purschke, Martin | L3 | BNL | Design | Martin Purschke | BNL | null | POM02.1.06.01.01 |  |  | C |  |  |  |  | 01 | yes |  | S229500 |  |  |  |  |  |  |  |
| S254000 |  | Final Design Review - DAQ Design | 30d | 2018-07-02 A | 2018-08-13 A | S253900 | 100% |  |  |  |  | S254000 | 100 | S229600 |  | NOCA | Completed |  | Purschke, Martin | L3 | BNL | Design | Martin Purschke | BNL | null | POM02.1.06.01.01 |  |  | C |  |  | 004 |  | 01 | yes |  | S229600 |  | 180503 ELM name per MP |  |  |  |  |  |
|  | 02 | **DAQ Prototype** |  | 2018-07-31 | 2021-03-15 |  |  |  |  |  |  |  |  |  |  |  |  |  |  |  |  |  |  |  |  |  |  |  |  |  |  |  |  |  |  |  |  |  |  |  |  |  |  |  |
| S254400 |  | DAQ Prototype: Software development - Calorimeters & TPC FY18 | 43d | 2018-07-31 A | 2018-09-28 A | S253900 | 100% |  |  |  |  | S254400 | 100 | S230600 |  | NOCA | Completed |  | Purschke, Martin | L4 | BNL | Programming | Martin Purschke | BNL | null | POM02.1.06.01.02 |  |  |  |  |  |  |  | 02 | yes |  | S230600 |  |  | FY18 |  |  |  |  |
| S254100 |  | DAQ Prototype: Select which hardware to re-use: computers, a network switch, and storage for the prototype, as specified | 10d | 2018-08-14 A | 2018-08-27 A | S253900, S254000 | 100% |  |  |  |  | S254100 | 100 | S229700 |  | NOCA | Completed |  | Purschke, Martin | L3 | BNL | Fab & Assy | Martin Purschke | BNL | null | POM02.1.06.01.02 |  |  | C |  |  |  |  | 02 | yes |  | S229700 |  |  |  |  |  |  |  |
| S254200 |  | DAQ Prototype: Setup and install the various operating systems FY18 | 23d | 2018-08-28 A | 2018-09-28 A | S254100 | 100% |  |  |  |  | S254200 | 100 | S230500 |  | NOCA | Completed |  | Purschke, Martin | L2 | BNL | Fab & Assy | Martin Purschke | BNL | null | POM02.1.06.01.02 |  |  |  |  |  |  |  | 02 | yes |  | S230500 |  | 180410 ELM pred/succ per GRY | FY18 |  |  |  |  |
| S254300 |  | DAQ Prototype: Setup and install the various operating systems FY19 | 102d | 2018-10-01 A | 2019-03-01 A | S254200 | 100% |  |  |  |  | S254300 | 20 | S230550 |  | NOCA | Completed | B | Purschke, Martin | L2 | BNL | Fab & Assy | Martin Purschke | BNL | null | POM02.1.06.01.02 |  |  | C |  | 16713 |  |  | 02 | yes |  | S230500 | 2019-03-05 | 180410 ELM pred/succ per GRY | FY19 | Yes |  |  |  |
| S254500 |  | DAQ Prototype: Software development - Calorimeters & TPC FY19 | 166d | 2018-10-01 A | 2019-05-31 A | S254400 | 100% |  |  |  |  | S254500 | 20 | S230650 |  | NOCA | Completed | B | Purschke, Martin | L4 | BNL | Programming | Martin Purschke | BNL | null | POM02.1.06.01.02 |  |  | C |  | 16713 |  |  | 02 | yes |  | S230600 | 2019-03-19 |  | FY19 | Yes |  |  |  |
| S254502 |  | DAQ Prototype: Software development - Calorimeters & TPC FY19 Split | 42d | 2019-06-03 A | 2020-01-02 A | S254500 | 100% | 2019-06-03 | 2019-07-31 | PROF4 PO E [461 h]; SCI3 PO [134 h] | 88,302.26 | S254500 | 20 | S230650 | S254502 | CA | In Progress | B | Purschke, Martin | L4 | BNL | Programming | Martin Purschke | BNL | null | POM02.1.06.01.02 |  |  | C | 1.06 | 16713 |  | 1.06B | 02 |  |  | S230600 | 2019-03-19 |  | FY19 | Yes | 1 |  |  |
| S254600 |  | DAQ Prototype: Software development - INTT FELIX readout test_80% | 84d | 2019-06-03 A | 2019-09-30 A | S254400 FS+80d | 100% |  |  | SCI3 PO [134 h]; TECH3 PO D [200 h] | 44,550.09 | S254600 | 0 | S230660 | S254600 | CA | Completed | B | Purschke, Martin | L4 | BNL | Programming | Martin Purschke | BNL | null | POM02.1.06.01.02 |  |  | C | 1.06 | 16713 | 005 | 1.06B | 02 |  |  | S230600 |  |  | FY19 | Yes | 1 |  |  |
| S254800 |  | DAQ Prototype: Software development - Multiple Subsystem Test | 84d | 2019-06-03 A | 2021-03-15 A | S254300 | 100% | 2019-06-03 | 2019-09-30 | PROF3 PO E [640 h]; SCI3 PO [96 h]; STUDENT Other - Unpaid [72 h] | 94,648.78 | S254800 | 0 | S230700 | S254800 | CA | In Progress | B_T | Purschke, Martin | L5 | BNL | Programming | Martin Purschke | BNL | null | POM02.1.06.01.02 |  |  | C | 1.06 | 16713 | 005 | 1.06B | 02 |  |  | S230700 |  | 180413 ELM dur per GRY |  | Yes | 1 |  |  |
| S254700 |  | DAQ Prototype: Software development - INTT FELIX/DCM2 Downselect Review | 2d | 2019-11-13 A | 2019-11-20 A | S254600 FS+60d | 100% | 2019-12-30 | 2019-12-31 | SCI3 PO [134 h]; TECH3 PO D [200 h] | 45,886.59 | S254700 | 0 | S230665 | S254700 | CA | Completed | B | Purschke, Martin | L4 | BNL | Programming | Martin Purschke | BNL | null | POM02.1.06.01.02 |  |  | C | 1.06 | 16713 | 005 | 1.06B | 02 |  |  | S230600 |  |  | FY19 | Yes |  |  |  |
| S255000 |  | DAQ Prototype: Review of DAQ Prototype Results and Production Readiness Review | 5d | 2020-01-07 A | 2020-01-30 A | S254900 | 100% | 2020-03-31 | 2020-04-06 | SCI3 PO [80 h]; PROF4 PO M [40 h] | 19,659.05 | S255000 | 0 | S230850 | S255000 | CA | Not Started | B | Purschke, Martin | L2 | BNL | Fab & Assy | Martin Purschke | BNL | null | POM02.1.06.01.02 |  |  | C | 1.06 | 16713 | 004 | 1.06B | 02 |  |  | S230800 |  |  |  |  |  |  |  |
| S254900 |  | DAQ Prototype: Installation and testing | 20d | 2020-01-15 A | 2020-01-29 A | S254700, S254502, S254800 | 100% | 2020-03-03 | 2020-03-30 | SCI3 PO [16 h]; TECH3 PO E [40 h]; STUDENT Other - Unpaid [40 h] | 7,318.58 | S254900 | 0 | S230800 | S254900 | CA | Not Started | B_T | Purschke, Martin | L2 | BNL | Fab & Assy | Martin Purschke | BNL | null | POM02.1.06.01.02 |  |  | C | 1.06 | 16713 |  | 1.06B | 02 |  |  | S230800 |  |  |  |  |  |  |  |
| S255100 |  | Production Readiness Review - DAQ | 1d | 2020-08-24 A | 2020-08-26 A | S255000 FF | 100% | 2020-09-30 | 2020-09-30 | SCI3 PO [4 h]; PROF3 PO E [4 h]; PROF3 IO E [4 h]; SCI 4 PO [4 h]; SCI3 Other - Unpaid [4 h] | 2,524.13 | S255100 | 0 | S230860 | S255100 | CA | Not Started | B | Purschke, Martin |  | BNL | Fab & Assy | Martin Purschke | BNL |  | POM02.1.06.01.02 |  |  | C | 1.06 | 16713 | 004 | 1.06B | 02 |  | UDF_G1 | S230800 |  |  |  |  |  | UDF_G1 | L3 |

Notes:
- S253200: BNL_UDF_Status Comments: 190315 DurType to align with EVT / BNL_UDF_Old Activity Name 181221: Actuals - Labor - sPHENIX DAQ&Trigger FY17
- S253400: BNL_UDF_Status Comments: 190315 DurType to align with EVT / BNL_UDF_Old Activity Name 181221: Actuals - Nonlabor - sPHENIX DAQ&Trigger FY17
- S253300: BNL_UDF_Status Comments: 190315 DurType to align with EVT / BNL_UDF_Old Activity Name 181221: Actuals - Labor - sPHENIX DAQ&Trigger FY18
- S253500: BNL_UDF_Status Comments: 190315 DurType to align with EVT / BNL_UDF_Old Activity Name 181221: Actuals - Nonlabor - sPHENIX DAQ&Trigger FY18
- S1000919: BNL_UDF_Status Comments: 190315 DurType to align with EVT / BNL_UDF_Old Activity Name 181221: Actuals - Labor - sPHENIX DAQ&Trigger FY18
- S1000959: BNL_UDF_Status Comments: 190315 DurType to align with EVT / BNL_UDF_Old Activity Name 181221: Actuals - Nonlabor - sPHENIX DAQ&Trigger FY18
- S253600: BNL_UDF_Old Activity Name 181221: DAQ Design: DAQ Prototype Design
- S253700: BNL_UDF_Old Activity Name 181221: DAQ Design: Specify front-end layout
- S253800: BNL_UDF_Old Activity Name 181221: DAQ Design: Specify the event Builder and back-end layout
- S253900: BNL_UDF_Old Activity Name 181221: DAQ Design: Specify the high-level components
- S254000: BNL_UDF_Status Comments: 190508 ELM name / BNL_UDF_Old Activity Name 181221: DAQ Design: Final Design Review
- S254400: Scheduler's Notes: 180413 ELM per GRY: / assume 2 people / BNL_UDF_Old Activity Name 181221: DAQ Prototype: Software development - Calorimeters & TPC FY18
- S254100: BNL_UDF_Old Activity Name 181221: DAQ Prototype: Select which hardware to re-use: computers, a network switch, and storage for the prototype, as specified
- S254200: BNL_UDF_Old Activity Name 181221: DAQ Prototype: Setup and install the various operating systems FY18
- S254300: BNL_UDF_Status Comments: 190605 IVS status / BNL_UDF_Old Activity Name 181221: DAQ Prototype: Setup and install the various operating systems FY19
- S254500: Scheduler's Notes: 180413 ELM per GRY: / assume 2 people / BNL_UDF_Status Comments: 190605 IVS status / BNL_UDF_Old Activity Name 181221: DAQ Prototype: Software development - Calorimeters & TPC FY19
- S254502: Scheduler's Notes: 180413 ELM per GRY: / assume 2 people / BNL_UDF_Status Comments: 190605 IVS status / BNL_UDF_Old Activity Name 181221: DAQ Prototype: Software development - Calorimeters & TPC FY19
- S254600: Scheduler's Notes: 180413 ELM per GRY: / assume 2 people / BNL_UDF_Status Comments: 190607 change pred.; 190605 IVS have yet to take the decision to do so / BNL_UDF_Old Activity Name 181221: DAQ Prototype: Software development - INTT FELIX readout test
- S254800: BNL_UDF_Status Comments: 190607 change start; 190605 IVS waiting for Chi's firmware modifications / BNL_UDF_Old Activity Name 181221: DAQ Prototype: Software development - Multiple Subsystem Test
- S254700: Scheduler's Notes: 180413 ELM per GRY: / assume 2 people / BNL_UDF_Status Comments: 190607 IVS fix hours / BNL_UDF_Old Activity Name 181221: DAQ Prototype: Software development - INTT FELIX/DCM2 Downselect Review
- S255000: BNL_UDF_Status Comments: 190415 ELM name per GRY / BNL_UDF_Old Activity Name 181221: DAQ Prototype: Review of DAQ Prototype Results
- S254900: BNL_UDF_Old Activity Name 181221: DAQ Prototype: Installation and testing
- S255100: BNL_UDF_Status Comments: 190508 ELM name per GRY / BNL_UDF_Old Activity Name 181221: DAQ Prototype: Ready For Production

| ID | WBS | Activity | Type | Duration | Start | Finish | Predecessors | Complete | Remaining | Planned start | Planned finish | Total float | Free float | Expected finish | Resources | Cost | BNL_UDF_Temp Text 01 | BNL_UDF_Percent Complete | BNL_UDF_OPC TEC (deprecated) | BNL_UDF_Old Activity ID 181221 | BNL_Cobra WP | RG Check | BNL_Activity Status | BNL_Fund Source | BNL_Estimator | BNL_Cost Basis | BNL_Location | BNL_EDIA | BNL_Proc Sig Phase | BNL_Proc Sig | BNL_CAM | BNL_Institution | BNL_OPC TEC (deprecated) | BNL_WBS | BNL_EVT | BNL_Master Control Account | BNL_Account Number | BNL_Cobra Control Account | BNL_WBS_Hierarchical | BNL_Milestone Level | SPH Proc Register | BNL_UDF_Status Comments | Indicator - Procurement | Indicator - Float | BNL_Obligation | BNL_PCR ID | BNL_UDF_Adhoc Comments | BNL_UDF_Remaining Tot Cost | BNL_UDF_Percent_remaining | Additional EVT documentation required | Target Milestone Date | Variance | PMP Milestones |
| --- | --- | --- | --- | --- | --- | --- | --- | --- | --- | --- | --- | --- | --- | --- | --- | --- | --- | --- | --- | --- | --- | --- | --- | --- | --- | --- | --- | --- | --- | --- | --- | --- | --- | --- | --- | --- | --- | --- | --- | --- | --- | --- | --- | --- | --- | --- | --- | --- | --- | --- | --- | --- | --- |
|  | 03 | **DAQ Production** |  |  | 2020-02-04 | 2022-01-28 |  |  |  |  |  |  |  |  |  |  |  |  |  |  |  |  |  |  |  |  |  |  |  |  |  |  |  |  |  |  |  |  |  |  |  |  |  |  |  |  |  |  |  |  |  |  |  |
| S257000 |  | Procure DAQ Production SEBs - Provide Requirements to Procurement |  | 5d | 2020-02-04 A | 2020-02-18 A | S256900 | 100% |  | 2020-07-24 | 2020-07-30 |  |  |  | PROF4 PO M [80 h]; SCI3 PO [80 h] | 25,549.65 | S257000 | 0 | S232700 | S232700 | S257000 | CA | Not Started | B | Purschke, Martin | L3 | BNL | Procurement | PP1 | MP107200 | Martin Purschke | BNL | null | POM02.1.06.01.03 | C | 1.06 | 16713 | 1.06B | 03 |  |  |  |  |  |  |  |  |  |  |  |  |  |  |
| S259700 |  | Procure DAQ Production Main Switches - Provide Requirements to Procurement |  | 5d | 2020-03-02 A | 2020-03-16 A | S256900 | 100% |  | 2020-07-24 | 2020-07-30 |  |  |  | PROF4 PO M [96 h]; SCI3 PO [96 h] | 30,659.59 | S259700 | 0 | S235100 | S235100 | S259700 | CA | Not Started | B | Purschke, Martin | L4 | BNL | Procurement | PP1 | MP107300 | Martin Purschke | BNL | null | POM02.1.06.01.03 | C | 1.06 | 16713 | 1.06B | 03 |  |  |  |  |  |  |  |  |  |  |  |  |  |  |
| S259800 |  | Procure DAQ Production Main Switches - Prepare & Send Solicitation |  | 30d | 2020-03-10 A | 2020-03-31 A | S259700 | 100% |  | 2020-07-31 | 2020-09-11 |  |  |  |  |  | S259800 | 0 | S235200 | S235200 |  | NOCA | Not Started |  | Purschke, Martin |  | BNL | Procurement | PP2 | MP107300 | Martin Purschke | BNL |  | POM02.1.06.01.03 |  |  |  |  | 03 |  |  |  |  |  |  |  |  |  |  |  |  |  |  |
| S257100 |  | Procure DAQ Production SEBs - Prepare & Send Solicitation |  | 30d | 2020-03-16 A | 2020-08-24 A | S257000 | 100% |  | 2020-07-31 | 2020-09-11 |  |  |  |  |  | S257100 | 0 | S232800 | S232800 |  | NOCA | Not Started |  | Purschke, Martin |  | BNL | Procurement | PP2 | MP107200 | Martin Purschke | BNL |  | POM02.1.06.01.03 |  |  |  |  | 03 |  |  |  |  |  |  |  |  |  |  |  |  |  |  |
| S257200 |  | Procure DAQ Production SEBs - Vendor Responses |  | 10d | 2020-03-16 A | 2020-08-24 A | S257100 | 100% |  | 2020-09-14 | 2020-09-25 |  |  |  |  |  | S257200 | 0 | S232900 | S232900 |  | NOCA | Not Started |  | Purschke, Martin |  | BNL | Procurement | PP3 | MP107200 | Martin Purschke | BNL |  | POM02.1.06.01.03 |  |  |  |  | 03 |  |  |  |  |  |  |  |  |  |  |  |  |  |  |
| S259900 |  | Procure DAQ Production Main Switches - Vendor Responses |  | 10d | 2020-03-17 A | 2020-03-25 A | S259800 | 100% |  | 2020-09-14 | 2020-09-25 |  |  |  |  |  | S259900 | 0 | S235300 | S235300 |  | NOCA | Not Started |  | Purschke, Martin |  | BNL | Procurement | PP3 | MP107300 | Martin Purschke | BNL |  | POM02.1.06.01.03 |  |  |  |  | 03 |  |  |  |  |  |  |  |  |  |  |  |  |  |  |
| S260000 |  | Procure DAQ Production Main Switches - Vendor Selection |  | 20d | 2020-03-17 A | 2020-03-30 A | S259900 | 100% |  | 2020-09-28 | 2020-10-26 |  |  |  |  |  | S260000 | 0 | S235400 | S235400 |  | NOCA | Not Started |  | Purschke, Martin |  | BNL | Procurement | PP4 | MP107300 | Martin Purschke | BNL |  | POM02.1.06.01.03 |  |  |  |  | 03 |  |  |  |  |  |  |  |  |  |  |  |  |  |  |
| S257300 |  | Procure DAQ Production SEBs - Vendor Selection |  | 20d | 2020-03-24 A | 2020-09-29 A | S257200 | 100% |  | 2020-09-28 | 2020-10-26 |  |  |  |  |  | S257300 | 0 | S233000 | S233000 |  | NOCA | Not Started |  | Purschke, Martin |  | BNL | Procurement | PP4 | MP107200 | Martin Purschke | BNL |  | POM02.1.06.01.03 |  |  |  |  | 03 |  |  |  |  |  |  |  |  |  |  |  |  |  |  |
| S260100 |  | Procure DAQ Production Main Switches - Contract Award(s) | milestone | 0d | 2020-03-30 A | 2020-03-30 A | S260000, S101000 | 100% |  | 2020-10-27 | 2020-10-27 |  |  |  |  |  | S260100 | 0 | S235500 | S235500 |  | NOCA | Not Started | A-TEC | Purschke, Martin |  | BNL | Procurement | PP5 | MP107300 | Martin Purschke | BNL |  | POM02.1.06.01.03 |  |  |  |  | 03 | L5 | Contract Award |  |  |  |  |  |  |  |  |  |  |  |  |
| S260200 |  | Procure DAQ Production Main Switches - Contract/PO - Leadtime |  | 120d | 2020-04-01 A | 2020-04-20 A | S260100 SS, OBLG260110 SS | 100% |  | 2020-09-23 | 2021-03-19 |  |  |  |  |  | S260200 | 0 | S235600 | S235600 |  | NOCA | Not Started |  | Purschke, Martin |  | BNL | Fab & Assy | PP6 | MP107300 | Martin Purschke | BNL |  | POM02.1.06.01.03 |  |  |  |  | 03 |  |  |  |  |  |  |  |  |  |  |  |  |  |  |
| S260300 |  | Procure DAQ Production Main Switches - Delivery Acceptance |  | 5d | 2020-04-21 A | 2020-04-24 A | S260200 | 100% |  | 2021-03-22 | 2021-03-26 |  |  |  | Material (Purchase (1st $2M) [86151 h] | 99,994.11 | S260300 | 0 | S235700 | S235700 | S260300 | CA | Not Started | A-TEC | Purschke, Martin | M3 | BNL | Fab & Assy | PP6 | MP107300 | Martin Purschke | BNL | TEC | POM02.1.06.01.03 | C | 1.06 | 59718 | 1.06A | 03 |  | Delivery | 190315 ELM BNL Units per MP | UDF_G2 | UDF_G3 | FAB | 003 |  |  |  |  |  |  |  |
| S257800 |  | Procure DAQ Production ATPs - Provide Requirements to Procurement |  | 5d | 2020-06-30 A | 2020-08-25 A |  | 100% |  | 2020-10-26 | 2020-10-30 |  |  |  | PROF4 PO M [80 h]; SCI3 PO [80 h] | 26,316.14 | S257800 | 0 | S233400 | S233400 | S257800 | CA | Not Started | B | Purschke, Martin | L2 | BNL | Procurement | PP1 | MP107000 | Martin Purschke | BNL | null | POM02.1.06.01.03 | C | 1.06 | 16713 | 1.06B | 03 |  |  |  |  |  |  |  |  |  |  |  |  |  |  |
| S258600 |  | DAQ Production: Procure jSEB Slow control computers |  | 5d | 2020-07-20 A | 2021-06-30 | S256900, S258200 SS, OBLG258210 SS | 50% | 22d | 2021-03-19 | 2021-03-25 | 120d | 0d | 2021-06-30 | PROF4 PO M [80 h]; SCI3 PO [80 h] | 26,316.14 | S258600 | 0 | S234100 | S234100 | S258600 | CA | Not Started | B | Purschke, Martin | L2 | BNL | Procurement |  |  | Martin Purschke | BNL | null | POM02.1.06.01.03 | C | 1.06 | 16713 | 1.06B | 03 |  |  |  |  |  |  |  |  |  |  |  |  |  |  |
| S255200 |  | DAQ Production: Design and layout the various types of front-end boards |  | 40d | 2020-08-03 A | 2020-08-07 A | S101000, S255100 | 100% |  | 2020-10-01 | 2020-12-01 |  |  |  | PROF4 PO E [32 h]; SCI3 PO [64 h] | 16,199.06 | S255200 | 0 | S230900 | S230900 | S255200 | CA | Not Started | B | Purschke, Martin | L4 | BNL | Design |  |  | Martin Purschke | BNL | null | POM02.1.06.01.03 | C | 1.06 | 16713 | 1.06B | 03 |  |  |  |  |  |  |  |  |  |  |  |  |  |  |
| S258000 |  | Procure DAQ Production ATPs - Vendor Responses |  | 10d | 2020-08-04 A | 2020-08-25 A | S257900 | 100% |  | 2021-02-04 | 2021-02-18 |  |  |  |  |  | S258000 | 0 | S233600 | S233600 |  | NOCA | Not Started |  | Purschke, Martin |  | BNL | Procurement | PP3 | MP107000 | Martin Purschke | BNL |  | POM02.1.06.01.03 |  |  |  |  | 03 |  |  |  |  |  |  |  |  |  |  |  |  |  |  |
| S255300 |  | Procure DAQ Production Boards - Provide Requirements to Procurement |  | 15d | 2020-08-10 A | 2020-08-12 A | S255200 | 100% |  | 2020-12-02 | 2020-12-22 |  |  |  | PROF4 PO M [64 h] | 9,707.71 | S255300 | 0 | S231000 | S231000 | S255300 | CA | Not Started | B | Purschke, Martin | L2 | BNL | Procurement | PP1 | MP106800 | Martin Purschke | BNL | null | POM02.1.06.01.03 | C | 1.06 | 16713 | 1.06B | 03 |  |  |  |  |  |  |  | 180413 ELM dur per GRY |  |  |  |  |  |  |
| S258900 |  | Procure DAQ Production Buffer Boxes - Provide Requirements to Procurement |  | 5d | 2020-08-10 A | 2020-08-25 A | S256900 | 100% |  | 2021-02-01 | 2021-02-05 |  |  |  | PROF4 PO M [40 h]; SCI3 PO [40 h] | 13,158.07 | S258900 | 0 | S234400 | S234400 | S258900 | CA | Not Started | B | Purschke, Martin | L3 | BNL | Procurement | PP1 | MP107100 | Martin Purschke | BNL | null | POM02.1.06.01.03 | C | 1.06 | 16713 | 1.06B | 03 |  |  |  |  |  |  |  |  |  |  |  |  |  |  |
| S259000 |  | Procure DAQ Production Buffer Boxes - Prepare & Send Solicitation |  | 30d | 2020-08-10 A | 2020-08-25 A | S258900 | 100% |  | 2021-02-08 | 2021-03-22 |  |  |  |  |  | S259000 | 0 | S234500 | S234500 |  | NOCA | Not Started |  | Purschke, Martin |  | BNL | Procurement | PP2 | MP107100 | Martin Purschke | BNL |  | POM02.1.06.01.03 |  |  |  |  | 03 |  |  |  |  |  |  |  |  |  |  |  |  |  |  |
| S259100 |  | Procure DAQ Production Buffer Boxes - Vendor Responses |  | 10d | 2020-08-10 A | 2020-08-25 A | S259000 | 100% |  | 2021-03-23 | 2021-04-05 |  |  |  |  |  | S259100 | 0 | S234600 | S234600 |  | NOCA | Not Started |  | Purschke, Martin |  | BNL | Procurement | PP3 | MP107100 | Martin Purschke | BNL |  | POM02.1.06.01.03 |  |  |  |  | 03 |  |  |  |  |  |  |  |  |  |  |  |  |  |  |
| S255400 |  | Procure DAQ Production Boards - Prepare & Send Solicitation |  | 30d | 2020-08-13 A | 2020-08-17 A | S255300 | 100% |  | 2020-12-23 | 2021-02-05 |  |  |  |  |  | S255400 | 0 | S231100 | S231100 |  | NOCA | Not Started |  | Purschke, Martin |  | BNL | Procurement | PP2 | MP106800 | Martin Purschke | BNL |  | POM02.1.06.01.03 |  |  |  |  | 03 |  |  |  |  |  |  |  |  |  |  |  |  |  |  |
| S255500 |  | Procure DAQ Production Boards - Vendor Responses |  | 15d | 2020-08-18 A | 2020-08-24 A | S255400 | 100% |  | 2021-02-08 | 2021-03-01 |  |  |  |  |  | S255500 | 0 | S231200 | S231200 |  | NOCA | Not Started |  | Purschke, Martin |  | BNL | Procurement | PP3 | MP106800 | Martin Purschke | BNL |  | POM02.1.06.01.03 |  |  |  |  | 03 |  |  |  |  |  |  |  | 180413 ELM dur per GRY |  |  |  |  |  |  |
| S257900 |  | Procure DAQ Production ATPs - Prepare & Send Solicitation |  | 30d | 2020-08-21 A | 2020-08-25 A | S257800 | 100% |  | 2020-12-21 | 2021-02-03 |  |  |  |  |  | S257900 | 0 | S233500 | S233500 |  | NOCA | Not Started |  | Purschke, Martin |  | BNL | Procurement | PP2 | MP107000 | Martin Purschke | BNL |  | POM02.1.06.01.03 |  |  |  |  | 03 |  |  |  |  |  |  |  |  |  |  |  |  |  |  |
| S258100 |  | Procure DAQ Production ATPs - Vendor Selection |  | 20d | 2020-09-01 A | 2020-09-29 A | S258000 | 100% |  |  |  |  |  |  |  |  | S258100 | 0 | S233700 | S233700 |  | NOCA | Not Started |  | Purschke, Martin |  | BNL | Procurement | PP4 | MP107000 | Martin Purschke | BNL |  | POM02.1.06.01.03 |  |  |  |  | 03 |  |  |  |  |  |  |  |  |  |  |  |  |  |  |
| S257400 |  | Procure DAQ Production SEBs - Contract Award(s) | milestone | 0d | 2020-09-30 A | 2020-09-30 A | S257300, S101000 | 100% |  | 2020-12-02 | 2020-12-02 |  |  |  |  |  | S257400 | 0 | S233100 | S233100 |  | NOCA | Not Started | A-TEC | Purschke, Martin |  | BNL | Procurement | PP5 | MP107200 | Martin Purschke | BNL |  | POM02.1.06.01.03 |  |  |  |  | 03 | L5 | Contract Award |  | UDF_G1 | UDF_G3 |  |  |  |  |  |  |  |  |  |
| S258200 |  | Procure DAQ Production ATPs - Contract Award(s) | milestone | 0d | 2020-09-30 A | 2020-09-30 A | S258100, S101000 | 100% |  |  |  |  |  |  |  |  | S258200 | 0 | S233800 | S233800 |  | NOCA | Not Started | A-TEC | Purschke, Martin |  | BNL | Procurement | PP5 | MP107000 | Martin Purschke | BNL |  | POM02.1.06.01.03 |  |  |  |  | 03 | L5 | Contract Award |  | UDF_G1 | UDF_G1 |  |  |  |  |  |  |  |  |  |
| S258300 |  | Procure DAQ Production ATPs - Contract/PO - Leadtime |  | 60d | 2020-10-01 A | 2020-10-30 A | S258200 SS, OBLG258210 SS | 100% |  | 2020-10-01 | 2020-12-30 |  |  |  |  |  | S258300 | 0 | S233900 | S233900 |  | NOCA | Not Started |  | Purschke, Martin |  | BNL | Fab & Assy | PP6 | MP107000 | Martin Purschke | BNL |  | POM02.1.06.01.03 |  |  |  |  | 03 |  |  |  |  |  |  |  |  |  |  |  |  |  |  |
| S259200 |  | Procure DAQ Production Buffer Boxes - Vendor Selection |  | 20d | 2020-10-14 A | 2020-10-30 A | S259100 | 100% |  | 2021-01-04 | 2021-02-01 |  |  |  |  |  | S259200 | 0 | S234700 | S234700 |  | NOCA | Not Started |  | Purschke, Martin |  | BNL | Procurement | PP4 | MP107100 | Martin Purschke | BNL |  | POM02.1.06.01.03 |  |  |  |  | 03 |  |  |  |  |  |  |  |  |  |  |  |  |  |  |
| OBLG260110 |  | Procure DAQ Production Main Switches - Obligation |  | 1d | 2020-10-15 A | 2020-12-02 A | S260000, S101000 | 100% |  | 2020-12-02 | 2020-12-02 |  |  |  | Obligation Resource [99994.1 h] | 99,994.13 | S260100 | 0 | S235500 | S235500 |  |  | Not Started | A-TEC | Purschke, Martin |  | BNL | Procurement | PP5 | MP107300 | Martin Purschke | BNL |  | POM02.1.06.01.03 |  |  |  |  | 03 | L5 |  |  |  |  | OBLG |  |  |  |  |  |  |  |  |
| S257500 |  | Procure DAQ Production SEBs - Contract/PO - Leadtime |  | 80d | 2020-10-15 A | 2020-10-30 A | S257400 SS, OBLG257410 SS | 100% |  | 2021-01-04 | 2021-04-27 |  |  |  |  |  | S257500 | 0 | S233200 | S233200 |  | NOCA | Not Started |  | Purschke, Martin |  | BNL | Fab & Assy | PP6 | MP107200 | Martin Purschke | BNL |  | POM02.1.06.01.03 |  |  |  |  | 03 |  |  |  |  |  |  |  |  |  |  |  |  |  |  |
| S258400 |  | Procure DAQ Production ATPs - Delivery Acceptance |  | 5d | 2020-10-22 A | 2020-11-30 A | S258300 | 100% |  | 2020-12-31 | 2021-01-07 |  |  |  | Material (Purchase (1st $2M) [98048 h] | 113,802.78 | S258400 | 0 | S234000 | S234000 | S258400 | CA | Not Started | A-TEC | Purschke, Martin | M3 | BNL | Fab & Assy | PP6 | MP107000 | Martin Purschke | BNL | TEC | POM02.1.06.01.03 | C | 1.06 | 59718 | 1.06A | 03 |  | Delivery | 190315 ELM BNL Units per MP | UDF_G2 | UDF_G3 | FAB | 015 |  | 113802.775227 | 1 |  |  |  |  |
| S257600 |  | Procure DAQ Production SEBs - Delivery Acceptance |  | 5d | 2020-10-28 A | 2020-11-30 A | S257500 | 100% |  | 2021-04-28 | 2021-05-04 |  |  |  | Material (Purchase (1st $2M) [41040 h] | 47,634.48 | S257600 | 0 | S233300 | S233300 | S257600 | CA | Not Started | A-TEC | Purschke, Martin | M3 | BNL | Fab & Assy | PP6 | MP107200 | Martin Purschke | BNL | TEC | POM02.1.06.01.03 | C | 1.06 | 59718 | 1.06A | 03 |  | Delivery | 190315 ELM BNL Units per MP | UDF_G2 | UDF_G3 | FAB | 015 |  | 47634.484082 | 1 |  |  |  |  |
| S259300 |  | Procure DAQ Production Buffer Boxes - Contract Award(s) | milestone | 0d | 2020-10-28 A | 2020-10-28 A | S259200, S101000 | 100% |  | 2021-02-02 | 2021-02-02 |  |  |  |  |  | S259300 | 0 | S234800 | S234800 |  | NOCA | Not Started | A-TEC | Purschke, Martin |  | BNL | Procurement | PP5 | MP107100 | Martin Purschke | BNL |  | POM02.1.06.01.03 |  |  |  |  | 03 | L5 | Contract Award |  | UDF_G1 | UDF_G3 |  |  |  |  |  |  |  |  |  |
| S259400 |  | Procure DAQ Production Buffer Boxes - Contract/PO - Leadtime |  | 80d | 2020-10-28 A | 2020-11-30 A | S259300 SS, OBLG259310 SS | 100% |  | 2021-01-29 | 2021-05-21 |  |  |  |  |  | S259400 | 0 | S234900 | S234900 |  | NOCA | Not Started |  | Purschke, Martin |  | BNL | Fab & Assy | PP6 | MP107100 | Martin Purschke | BNL |  | POM02.1.06.01.03 |  |  |  |  | 03 |  |  |  |  |  |  |  |  |  |  |  |  |  |  |
| S257700 |  | Production SEBs - Setup Machines |  | 5d | 2020-11-09 A | 2020-11-30 A | S257600 | 100% |  | 2021-02-05 | 2021-02-11 |  |  |  | SCI3 PO [40 h] | 7,090.75 | S257700 | 0 | S233300 | S233350 | S257700 | CA | Not Started | B | Purschke, Martin | L2 | BNL | Fab & Assy |  |  | Martin Purschke | BNL | null | POM02.1.06.01.03 | C | 1.06 | 16713 | 1.06B | 03 |  |  |  |  |  |  |  |  |  |  |  |  |  |  |
| S258500 |  | Production ATPs - Setup Machines |  | 5d | 2020-11-10 A | 2020-11-30 A | S258400 | 100% |  | 2020-12-01 | 2020-12-07 |  |  |  | SCI3 PO [40 h] | 7,090.75 | S258500 | 0 | S233300 | S234050 | S258500 | CA | Not Started | B | Purschke, Martin | L2 | BNL | Fab & Assy |  |  | Martin Purschke | BNL | null | POM02.1.06.01.03 | C | 1.06 | 16713 | 1.06B | 03 |  |  |  |  |  |  |  |  |  |  |  |  |  |  |
| S260600 |  | DAQ Production: DAQ Software development |  | 250d | 2020-11-16 A | 2021-11-30 | S255100 | 80% | 125d | 2020-12-01 | 2021-11-30 | 35d | 0d | 2021-11-30 | PROF4 PO M [880 h]; SCI3 PO [880 h]; STUDENT Other - Unpaid [1760 h] | 290,832.34 | S260600 | 0 | S236100 | S236100 | S260600 | CA | Not Started | B_T | Purschke, Martin | L4 | BNL | Programming |  |  | Martin Purschke | BNL | null | POM02.1.06.01.03 | C | 1.06 | 16713 | 1.06B | 03 |  |  |  |  |  |  |  |  |  |  | Yes |  |  |  |
| S259500 |  | Procure DAQ Production Buffer Boxes - Delivery Acceptance |  | 5d | 2020-11-23 A | 2021-06-01 | S259400 | 16% | 1d | 2021-01-29 | 2021-02-04 | 154d | 0d | 2021-06-01 | Material (Purchase (1st $2M) [223540 h] | 259,459.37 | S259500 | 0 | S235000 | S235000 | S259500 | CA | Not Started | A-TEC | Purschke, Martin | M3 | BNL | Fab & Assy | PP6 | MP107100 | Martin Purschke | BNL | TEC | POM02.1.06.01.03 | C | 1.06 | 59718 | 1.06A | 03 |  | Delivery | 190315 ELM BNL Units per MP | UDF_G2 | UDF_G3 | FAB | 015 |  | 259459.370657 | 1 |  |  |  |  |
| S259600 |  | Production Buffer Boxes - Setup Machines |  | 5d | 2020-11-23 A | 2021-06-08 | S259500 | 16% | 5d | 2021-02-05 | 2021-02-11 | 154d | 0d | 2021-06-01 | SCI3 PO [40 h] | 7,090.75 | S259600 | 0 | S233300 | S235050 | S259600 | CA | Not Started | B | Purschke, Martin | L3 | BNL | Fab & Assy |  |  | Martin Purschke | BNL | null | POM02.1.06.01.03 | C | 1.06 | 16713 | 1.06B | 03 |  |  |  |  |  |  |  |  |  |  |  |  |  |  |
| OBLG258210 |  | Procure DAQ Production ATPs - Obligation |  | 1d | 2020-12-01 A | 2020-12-01 A | S258100, S101000 | 100% |  |  |  |  |  |  | Obligation Resource [113803 h] | 113,802.79 | S258200 | 0 | S233800 | S233800 |  |  | Not Started | A-TEC | Purschke, Martin |  | BNL | Procurement | PP5 | MP107000 | Martin Purschke | BNL |  | POM02.1.06.01.03 |  |  |  |  | 03 | L5 |  |  |  |  | OBLG |  |  |  |  |  |  |  |  |
| OBLG259310 |  | Procure DAQ Production Buffer Boxes - Obligation |  | 1d | 2020-12-01 A | 2020-12-01 A | S259200, S101000 | 100% |  | 2021-02-01 | 2021-02-01 |  |  |  | Obligation Resource [259459 h] | 259,459.41 | S259300 | 0 | S234800 | S234800 |  |  | Not Started | A-TEC | Purschke, Martin |  | BNL | Procurement | PP5 | MP107100 | Martin Purschke | BNL |  | POM02.1.06.01.03 |  |  |  |  | 03 | L5 |  |  |  |  | OBLG |  |  |  |  |  |  |  |  |
| S256900 |  | DAQ Production: Selecting the right technology and brands |  | 40d | 2020-12-02 A | 2020-12-31 A | S255200 | 100% |  | 2020-12-02 | 2021-01-29 |  |  |  | PROF4 PO M [96 h]; SCI3 PO [96 h] | 31,579.37 | S256900 | 0 | S232600 | S232600 | S256900 | CA | Not Started | B | Purschke, Martin | L3 | BNL | Fab & Assy |  |  | Martin Purschke | BNL | null | POM02.1.06.01.03 | C | 1.06 | 16713 | 1.06B | 03 |  |  |  |  |  |  |  |  |  |  |  |  |  |  |
| S256800 |  | DAQ Production: Crate installation |  | 70d | 2020-12-07 A | 2021-11-15 | S256700 | 30% | 11d | 2021-08-05 | 2021-11-15 | 44d | 0d | 2021-11-15 | PROF4 PO M [32 h]; SCI3 PO [32 h]; TECH3 PO M [512 h]; CRAFT3 [32 h] | 75,794.39 | S256800 | 0 | S232500 | S232500 | S256800 | CA | Not Started | B | Purschke, Martin | L2 | BNL | Fab & Assy |  |  | Martin Purschke | BNL | null | POM02.1.06.01.03 | C | 1.06 | 16713 | 1.06B | 03 |  |  |  |  |  |  |  | 180413 ELM dur per GRY |  |  | Yes |  |  |  |
| OBLG255710 |  | Procure DAQ Production Boards - Obligation |  | 1d | 2020-12-08 A | 2020-12-09 A | S255600, S101000 | 100% |  | 2021-01-08 | 2021-01-08 |  |  |  | Obligation Resource [119120 h] | 119,120.35 | S255700 | 0 | S231400 | S231400 |  |  | Not Started | A-TEC | Purschke, Martin |  | BNL | Procurement | PP5 | MP106800 | Martin Purschke | BNL |  | POM02.1.06.01.03 |  |  |  |  | 03 | L5 |  |  |  |  | OBLG |  |  |  |  |  |  |  |  |
| OBLG256510 |  | Procure DAQ Production Crates - Obligation |  | 1d | 2020-12-08 A | 2020-12-09 A | S256400, S101000 | 100% |  | 2021-03-09 | 2021-03-09 |  |  |  | Obligation Resource [72827.2 h] | 72,827.25 | S256500 | 0 | S232200 | S232200 |  |  | Not Started | A-TEC | Purschke, Martin |  | BNL | Procurement | PP5 | MP106900 | Martin Purschke | BNL |  | POM02.1.06.01.03 |  |  |  |  | 03 | L5 |  |  |  |  | OBLG |  |  |  |  |  |  |  |  |
| OBLG257410 |  | Procure DAQ Production SEBs - Obligation |  | 1d | 2020-12-08 A | 2020-12-09 A | S257300, S101000 | 100% |  | 2021-02-01 | 2021-02-01 |  |  |  | Obligation Resource [47634.5 h] | 47,634.49 | S257400 | 0 | S233100 | S233100 |  |  | Not Started | A-TEC | Purschke, Martin |  | BNL | Procurement | PP5 | MP107200 | Martin Purschke | BNL |  | POM02.1.06.01.03 |  |  |  |  | 03 | L5 |  |  |  |  | OBLG |  |  |  |  |  |  |  |  |
| S260400 |  | DAQ Production: Setting up the switches |  | 20d | 2021-02-12 A | 2021-06-28 | S260300 | 60% | 20d | 2021-02-12 | 2021-03-12 | 120d | 0d | 2021-06-28 | PROF4 PO M [56 h]; SCI3 PO [88 h]; TECH3 PO M [44 h] | 29,265.92 | S260400 | 0 | S235800 | S235800 | S260400 | CA | Not Started | B | Purschke, Martin | L3 | BNL | Fab & Assy |  |  | Martin Purschke | BNL | null | POM02.1.06.01.03 | C | 1.06 | 16713 | 1.06B | 03 |  |  |  |  |  |  |  |  |  |  |  |  |  |  |
| S256100 |  | Procure DAQ Production Crates - Provide Requirements to Procurement |  | 5d | 2021-03-16 A | 2021-04-05 A | S255200 | 100% |  | 2021-03-16 | 2021-03-22 |  |  |  | PROF4 PO M [80 h]; SCI3 PO [80 h] | 26,316.14 | S256100 | 0 | S231800 | S231800 | S256100 | CA | Not Started | B | Purschke, Martin | L2 | BNL | Procurement | PP1 | MP106900 | Martin Purschke | BNL | null | POM02.1.06.01.03 | C | 1.06 | 16713 | 1.06B | 03 |  |  |  |  |  |  |  |  |  |  |  |  |  |  |
| S255600 |  | Procure DAQ Production Boards - Vendor Selection |  | 25d | 2021-04-01 A | 2021-04-30 A | S255500 | 100% |  | 2021-05-03 | 2021-06-07 |  |  |  |  |  | S255600 | 0 | S231300 | S231300 |  | NOCA | Not Started |  | Purschke, Martin |  | BNL | Procurement | PP4 | MP106800 | Martin Purschke | BNL |  | POM02.1.06.01.03 |  |  |  |  | 03 |  |  |  |  |  |  |  | 180413 ELM dur per GRY |  |  |  |  |  |  |
| S256300 |  | Procure DAQ Production Crates - Vendor Responses |  | 10d | 2021-04-05 A | 2021-04-09 A | S256200 | 100% |  | 2021-05-03 | 2021-05-14 |  |  |  |  |  | S256300 | 0 | S232000 | S232000 |  | NOCA | Not Started |  | Purschke, Martin |  | BNL | Procurement | PP3 | MP106900 | Martin Purschke | BNL |  | POM02.1.06.01.03 |  |  |  |  | 03 |  |  |  |  |  |  |  |  |  |  |  |  |  |  |
| S256400 |  | Procure DAQ Production Crates - Vendor Selection |  | 20d | 2021-04-05 A | 2021-04-09 A | S256300 | 100% |  | 2021-05-17 | 2021-06-14 |  |  |  |  |  | S256400 | 0 | S232100 | S232100 |  | NOCA | Not Started |  | Purschke, Martin |  | BNL | Procurement | PP4 | MP106900 | Martin Purschke | BNL |  | POM02.1.06.01.03 |  |  |  |  | 03 |  |  |  |  |  |  |  |  |  |  |  |  |  |  |
| S256200 |  | Procure DAQ Production Crates - Prepare & Send Solicitation |  | 30d | 2021-04-06 A | 2021-04-30 A | S256100 | 100% |  | 2021-05-06 | 2021-06-17 |  |  |  |  |  | S256200 | 0 | S231900 | S231900 |  | NOCA | Not Started |  | Purschke, Martin |  | BNL | Procurement | PP2 | MP106900 | Martin Purschke | BNL |  | POM02.1.06.01.03 |  |  |  |  | 03 |  |  |  |  |  |  |  |  |  |  |  |  |  |  |
| S260500 |  | DAQ Production: Modify and Debug event builder software |  | 40d | 2021-04-26 A | 2021-07-27 | S258800, S258500, S257700, S260400 | 80% | 8d | 2021-06-01 | 2021-07-27 | 120d | 0d | 2021-07-27 | PROF4 PO M [320 h]; SCI3 PO [320 h] | 105,264.58 | S260500 | 0 | S234300 | S235850 | S260500 | CA | Not Started | B | Purschke, Martin | L4 | BNL | Programming |  |  | Martin Purschke | BNL | null | POM02.1.06.01.03 | C | 1.06 | 16713 | 1.06B | 03 |  |  |  |  |  |  |  |  |  |  |  |  |  |  |
| S255700 |  | Procure DAQ Production Boards - Contract Award(s) | milestone | 0d | 2021-06-01 | 2021-06-01 | S255600, S101000 |  |  |  |  | 5d | 0d |  |  |  | S255700 | 0 | S231400 | S231400 |  | NOCA | Not Started | A-TEC | Purschke, Martin |  | BNL | Procurement | PP5 | MP106800 | Martin Purschke | BNL |  | POM02.1.06.01.03 |  |  |  |  | 03 | L5 | Contract Award |  | UDF_G1 | UDF_G1 |  |  |  |  |  |  |  |  |  |
| S255800 |  | Procure DAQ Production Boards - Contract/PO - Leadtime |  | 80d | 2021-06-01 | 2021-09-22 | S255700 SS, OBLG255710 SS |  |  |  |  | 5d | 0d |  |  |  | S255800 | 0 | S231500 | S231500 |  | NOCA | Not Started |  | Purschke, Martin |  | BNL | Fab & Assy | PP6 | MP106800 | Martin Purschke | BNL |  | POM02.1.06.01.03 |  |  |  |  | 03 |  |  |  |  |  |  |  |  |  |  |  |  |  |  |
| S256500 |  | Procure DAQ Production Crates - Contract Award(s) | milestone | 0d | 2021-06-01 | 2021-06-01 | S256400, S101000 |  |  |  |  | 44d | 0d |  |  |  | S256500 | 0 | S232200 | S232200 |  | NOCA | Not Started | A-TEC | Purschke, Martin |  | BNL | Procurement | PP5 | MP106900 | Martin Purschke | BNL |  | POM02.1.06.01.03 |  |  |  |  | 03 | L5 | Contract Award |  | UDF_G1 | UDF_G3 |  |  |  |  |  |  |  |  |  |
| S256600 |  | Procure DAQ Production Crates - Contract/PO - Leadtime |  | 100d | 2021-06-01 | 2021-10-21 | S256500 SS, OBLG256510 SS |  |  |  |  | 44d | 0d |  |  |  | S256600 | 0 | S232300 | S232300 |  | NOCA | Not Started |  | Purschke, Martin |  | BNL | Fab & Assy | PP6 | MP106900 | Martin Purschke | BNL |  | POM02.1.06.01.03 |  |  |  |  | 03 |  |  |  |  |  |  |  |  |  |  |  |  |  |  |
| S258700 |  | Procure DAQ Production jSEB Slow control computers - Delivery Acceptance |  | 5d | 2021-07-01 | 2021-07-08 | S258600, S258200 SS, OBLG258210 SS |  |  |  |  | 120d | 0d |  | Material (Purchase (1st $2M) [16856 h] | 19,564.49 | S258700 | 0 | S234200 | S234200 | S258700 | CA | Not Started | A-TEC | Purschke, Martin | M3 | BNL | Fab & Assy |  |  | Martin Purschke | BNL | TEC | POM02.1.06.01.03 | C | 1.06 | 59718 | 1.06A | 03 |  |  | 190315 ELM BNL Units per MP | UDF_G1 | UDF_G3 |  | 003 |  | 19564.494729 | 1 |  |  |  |  |
| S258800 |  | Production jSEB Slow control computers - Setup Machines |  | 5d | 2021-07-09 | 2021-07-15 | S258700 |  |  |  |  | 120d | 0d |  | SCI3 PO [40 h] | 7,090.75 | S258800 | 0 | S233300 | S234250 | S258800 | CA | Not Started | B | Purschke, Martin | L2 | BNL | Fab & Assy |  |  | Martin Purschke | BNL | null | POM02.1.06.01.03 | C | 1.06 | 16713 | 1.06B | 03 |  |  |  |  |  |  |  |  |  |  |  |  |  |  |
| S255900 |  | Procure DAQ Production Boards - Delivery Acceptance |  | 5d | 2021-09-23 | 2021-09-29 | S255800 |  |  |  |  | 5d | 0d |  | Material (Purchase (1st $2M) [104682 h] | 121,502.75 | S255900 | 0 | S231600 | S231600 | S255900 | CA | Not Started | A-TEC | Purschke, Martin | M4 | BNL | Fab & Assy | PP6 | MP106800 | Martin Purschke | BNL | TEC | POM02.1.06.01.03 | C | 1.06 | 59718 | 1.06A | 03 |  | Delivery | 190315 ELM BNL Units per MP | UDF_G1 | UDF_G1 | FAB | 015 |  | 121502.754939 | 1 |  |  |  |  |
| S256000 |  | DAQ Production Boards: Firmware updates |  | 70d | 2021-09-30 | 2022-01-13 | S255900 |  |  |  |  | 5d | 0d |  | SCI3 PO [64 h]; STUDENT Other - Unpaid [240 h]; PROF3 PO E [960 h] | 140,472.5 | S256000 | 0 | S231700 | S231700 | S256000 | CA | Not Started | B_T | Purschke, Martin | L4 | BNL | Programming |  |  | Martin Purschke | BNL | null | POM02.1.06.01.03 | C | 1.06 | 16713 | 1.06B | 03 |  |  |  |  |  |  |  | 180413 ELM dur per GRY |  |  | Yes |  |  |  |
| S256700 |  | Procure DAQ Production Crates - Delivery Acceptance |  | 5d | 2021-10-22 | 2021-10-28 | S256600 |  |  |  |  | 44d | 0d |  | Material (Purchase (1st $2M) [64000 h] | 75,769.47 | S256700 | 0 | S232400 | S232400 | S256700 | CA | Not Started | A-TEC | Purschke, Martin | M3 | BNL | Fab & Assy | PP6 | MP106900 | Martin Purschke | BNL | TEC | POM02.1.06.01.03 | C | 1.06 | 59718 | 1.06A | 03 |  | Delivery |  | UDF_G1 | UDF_G1 | FAB | 015 |  | 74283.79584 | 1 |  |  |  |  |
| S260700 |  | DAQ Production: Internal Readiness Review |  | 10d | 2022-01-14 | 2022-01-28 | S256000, S256800, S260500, S260600, S259600 |  |  |  |  | 5d | 0d |  | PROF4 PO M [80 h]; SCI3 PO [240 h] | 56,319.54 | S260700 | 0 | S236200 | S236200 | S260700 | CA | Not Started | B | Purschke, Martin | L2 | BNL | Fab & Assy |  |  | Martin Purschke | BNL | null | POM02.1.06.01.03 | C | 1.06 | 16713 | 1.06B | 03 |  |  |  |  |  |  |  | 180503 ELM name per MP |  |  |  |  |  |  |
| S260800 |  | DAQ Production: DAQ Ready for Operation | milestone | 0d | 2022-01-28 | 2022-01-28 | S260700 FF |  |  |  |  | 5d |  |  |  |  | S260800 | 0 | S236300 | S236300 |  | NOCA | Not Started |  | Purschke, Martin |  | BNL | Fab & Assy |  |  | Martin Purschke | BNL |  | POM02.1.06.01.03 |  |  |  |  | 03 | L2 |  |  | UDF_G1 | UDF_G1 |  |  |  |  |  |  | 2021-12-30 | -20 | PMP_1x |

Notes:
- S257000: BNL_UDF_Old Activity Name 181221: Procure DAQ Production SEBs - Provide Requirements to Procurement
- S259700: BNL_UDF_Old Activity Name 181221: Procure DAQ Production Main Switches - Provide Requirements to Procurement
- S259800: BNL_UDF_Old Activity Name 181221: Procure DAQ Production Main Switches - Prepare & Send Solicitation
- S257100: BNL_UDF_Old Activity Name 181221: Procure DAQ Production SEBs - Prepare & Send Solicitation
- S257200: BNL_UDF_Old Activity Name 181221: Procure DAQ Production SEBs - Vendor Responses
- S259900: BNL_UDF_Old Activity Name 181221: Procure DAQ Production Main Switches - Vendor Responses
- S260000: BNL_UDF_Old Activity Name 181221: Procure DAQ Production Main Switches - Vendor Selection
- S257300: BNL_UDF_Old Activity Name 181221: Procure DAQ Production SEBs - Vendor Selection
- S260100: BNL_UDF_Old Activity Name 181221: Procure DAQ Production Main Switches - Contract Award(s)
- S260200: BNL_UDF_Old Activity Name 181221: Procure DAQ Production Main Switches - Contract/PO - Leadtime
- S260300: BNL_UDF_Old Activity Name 181221: Procure DAQ Production Main Switches - Delivery Acceptance
- S257800: BNL_UDF_Old Activity Name 181221: Procure DAQ Production ATPs - Provide Requirements to Procurement
- S258600: BNL_UDF_Old Activity Name 181221: DAQ Production: Procure jSEB Slow control computers
- S255200: BNL_UDF_Old Activity Name 181221: DAQ Production: Design and layout the various types of front-end boards
- S258000: BNL_UDF_Old Activity Name 181221: Procure DAQ Production ATPs - Vendor Responses
- S255300: BNL_UDF_Old Activity Name 181221: Procure DAQ Production Boards - Provide Requirements to Procurement
- S258900: BNL_UDF_Old Activity Name 181221: Procure DAQ Production Buffer Boxes - Provide Requirements to Procurement
- S259000: BNL_UDF_Old Activity Name 181221: Procure DAQ Production Buffer Boxes - Prepare & Send Solicitation
- S259100: BNL_UDF_Old Activity Name 181221: Procure DAQ Production Buffer Boxes - Vendor Responses
- S255400: BNL_UDF_Old Activity Name 181221: Procure DAQ Production Boards - Prepare & Send Solicitation
- S255500: BNL_UDF_Old Activity Name 181221: Procure DAQ Production Boards - Vendor Responses
- S257900: BNL_UDF_Old Activity Name 181221: Procure DAQ Production ATPs - Prepare & Send Solicitation
- S258100: BNL_UDF_Old Activity Name 181221: Procure DAQ Production ATPs - Vendor Selection
- S257400: BNL_UDF_Old Activity Name 181221: Procure DAQ Production SEBs - Contract Award(s)
- S258200: BNL_UDF_Old Activity Name 181221: Procure DAQ Production ATPs - Contract Award(s)
- S258300: BNL_UDF_Old Activity Name 181221: Procure DAQ Production ATPs - Contract/PO - Leadtime
- S259200: BNL_UDF_Old Activity Name 181221: Procure DAQ Production Buffer Boxes - Vendor Selection
- OBLG260110: BNL_UDF_Old Activity Name 181221: Procure DAQ Production Main Switches - Contract Award(s)
- S257500: BNL_UDF_Old Activity Name 181221: Procure DAQ Production SEBs - Contract/PO - Leadtime
- S258400: BNL_UDF_Old Activity Name 181221: Procure DAQ Production ATPs - Delivery Acceptance
- S257600: BNL_UDF_Old Activity Name 181221: Procure DAQ Production SEBs - Delivery Acceptance
- S259300: BNL_UDF_Old Activity Name 181221: Procure DAQ Production Buffer Boxes - Contract Award(s)
- S259400: BNL_UDF_Old Activity Name 181221: Procure DAQ Production Buffer Boxes - Contract/PO - Leadtime
- S257700: BNL_UDF_Old Activity Name 181221: Production SEBs - Setup Machines
- S258500: BNL_UDF_Old Activity Name 181221: Production ATPs - Setup Machines
- S260600: BNL_UDF_Old Activity Name 181221: DAQ Production: DAQ Software development
- S259500: BNL_UDF_Old Activity Name 181221: Procure DAQ Production Buffer Boxes - Delivery Acceptance
- S259600: BNL_UDF_Old Activity Name 181221: Production Buffer Boxes - Setup Machines
- OBLG258210: BNL_UDF_Old Activity Name 181221: Procure DAQ Production ATPs - Contract Award(s)
- OBLG259310: BNL_UDF_Old Activity Name 181221: Procure DAQ Production Buffer Boxes - Contract Award(s)
- S256900: General Comments: 180420 GYoung: concerning / Technology selection - Commercial / product / BNL_UDF_Old Activity Name 181221: DAQ Production: Selecting the right technology and brands
- S256800: BNL_UDF_Old Activity Name 181221: DAQ Production: Crate installation
- OBLG255710: BNL_UDF_Old Activity Name 181221: Procure DAQ Production Boards - Contract Award(s)
- OBLG256510: BNL_UDF_Old Activity Name 181221: Procure DAQ Production Crates - Contract Award(s)
- OBLG257410: BNL_UDF_Old Activity Name 181221: Procure DAQ Production SEBs - Contract Award(s)
- S260400: BNL_UDF_Old Activity Name 181221: DAQ Production: Setting up the switches
- S256100: BNL_UDF_Old Activity Name 181221: Procure DAQ Production Crates - Provide Requirements to Procurement
- S255600: BNL_UDF_Old Activity Name 181221: Procure DAQ Production Boards - Vendor Selection
- S256300: BNL_UDF_Old Activity Name 181221: Procure DAQ Production Crates - Vendor Responses
- S256400: BNL_UDF_Old Activity Name 181221: Procure DAQ Production Crates - Vendor Selection
- S256200: BNL_UDF_Old Activity Name 181221: Procure DAQ Production Crates - Prepare & Send Solicitation
- S260500: BNL_UDF_Old Activity Name 181221: DAQ Production: Modify and Debug event builder software
- S255700: BNL_UDF_Old Activity Name 181221: Procure DAQ Production Boards - Contract Award(s)
- S255800: BNL_UDF_Old Activity Name 181221: Procure DAQ Production Boards - Contract/PO - Leadtime
- S256500: BNL_UDF_Old Activity Name 181221: Procure DAQ Production Crates - Contract Award(s)
- S256600: BNL_UDF_Old Activity Name 181221: Procure DAQ Production Crates - Contract/PO - Leadtime
- S258700: BNL_UDF_Old Activity Name 181221: Procure DAQ Production jSEB Slow control computers - Delivery Acceptance
- S258800: BNL_UDF_Old Activity Name 181221: Production jSEB Slow control computers - Setup Machines
- S255900: BNL_UDF_Old Activity Name 181221: Procure DAQ Production Boards - Delivery Acceptance
- S256000: BNL_UDF_Old Activity Name 181221: DAQ Production Boards: Firmware updates
- S256700: BNL_UDF_Old Activity Name 181221: Procure DAQ Production Crates - Delivery Acceptance
- S260700: BNL_UDF_Old Activity Name 181221: DAQ Production: Internal Readiness Review
- S260800: BNL_UDF_Old Activity Name 181221: DAQ Production: DAQ Ready for Operation

| ID | WBS | Activity | Type | Duration | Start | Finish | Predecessors | Complete | Planned start | Planned finish | Resources | Cost | BNL_UDF_Status Comments | BNL_UDF_Temp Text 01 | BNL_UDF_Percent Complete | BNL_UDF_OPC TEC (deprecated) | BNL_UDF_Temp Date 01 | BNL_UDF_Old Activity ID 181221 | RG Check | BNL_Activity Status | BNL_Estimator | BNL_Cost Basis | BNL_Location | BNL_EDIA | BNL_CAM | BNL_Institution | BNL_OPC TEC (deprecated) | BNL_WBS | BNL_EVT | BNL_PCR ID | BNL_WBS_Hierarchical | Completed | BNL_UDF_Adhoc Comments | BNL_Proc Sig Phase | BNL_Proc Sig | BNL_DOE OPC | Cost = Awarded Proc or Mgmt | BNL_Fund Source | BNL_Milestone Level | BNL_Obligation | BNL_UDF_Exclude | BNL_Account Number | SPH Proc Register | BNL_Cobra WP | Indicator - Procurement | Indicator - Float | BNL_Master Control Account | BNL_Cobra Control Account | Additional EVT documentation required |
| --- | --- | --- | --- | --- | --- | --- | --- | --- | --- | --- | --- | --- | --- | --- | --- | --- | --- | --- | --- | --- | --- | --- | --- | --- | --- | --- | --- | --- | --- | --- | --- | --- | --- | --- | --- | --- | --- | --- | --- | --- | --- | --- | --- | --- | --- | --- | --- | --- | --- |
|  | 02 | **Local Level 1 Trigger (LL1)** |  |  | 2017-02-01 | 2021-12-20 |  |  |  |  |  |  |  |  |  |  |  |  |  |  |  |  |  |  |  |  |  |  |  |  |  |  |  |  |  |  |  |  |  |  |  |  |  |  |  |  |  |  |  |
|  | 01 | **LL1 Trigger Design** |  |  | 2017-02-01 | 2019-06-04 |  |  |  |  |  |  |  |  |  |  |  |  |  |  |  |  |  |  |  |  |  |  |  |  |  |  |  |  |  |  |  |  |  |  |  |  |  |  |  |  |  |  |  |
| S260900 |  | Trigger Design: Write design specifications, Preliminary Design Review |  | 290d | 2017-02-01 A | 2018-03-29 A | S100090 SS | 100% |  |  |  |  | 190415 ELM name per GRY | S260900 | 100 | S236400 | 2018-03-29 | S236400 | NOCA | Completed | Nagle, Jamie | L1 | UColorado | Design | Martin Purschke | UCB | null | POM02.1.06.02.01 | C | 004 | 01 | yes |  |  |  |  |  |  |  |  |  |  |  |  |  |  |  |  |  |
| S261000 |  | Trigger Design, Layout Custom LL1 - Provide Requirements to Procurement |  | 5d | 2018-03-30 A | 2018-04-05 A | S260900 | 100% |  |  |  |  |  | S261000 | 100 | S236600 | 2018-04-05 | S236600 | NOCA | Completed | Nagle, Jamie | L1 | UColorado | Procurement | Martin Purschke | UCB | null | POM02.1.06.02.01 | C |  | 01 | yes | 180402 ELM assigned proc values | PP1 | MP200600 | OPC002200 | Yes |  |  |  |  |  |  |  |  |  |  |  |  |
| S261100 |  | Trigger Design, Layout Custom LL1 - Prepare & Send Solicitation |  | 30d | 2018-04-06 A | 2018-05-17 A | S261000 | 100% |  |  |  |  |  | S261100 | 100 | S236600 | 2018-05-17 | S337210 | NOCA | Completed | Nagle, Jamie |  | UColorado | Procurement | Martin Purschke | UCB |  | POM02.1.06.02.01 |  |  | 01 | yes | 180413 ELM status per GRY; 180402 ELM assigned proc values | PP2 | MP200600 | OPC002200 | Yes |  |  |  |  |  |  |  |  |  |  |  |  |
| S261200 |  | Trigger Design, Layout Custom LL1 - Vendor Responses |  | 10d | 2018-05-18 A | 2018-06-01 A | S261100 | 100% |  |  |  |  |  | S261200 | 100 | S236600 | 2018-06-01 | S337220 | NOCA | Completed | Nagle, Jamie |  | UColorado | Procurement | Martin Purschke | UCB |  | POM02.1.06.02.01 |  |  | 01 | yes | 180413 ELM status per GRY; 180402 ELM assigned proc values | PP3 | MP200600 | OPC002200 | Yes |  |  |  |  |  |  |  |  |  |  |  |  |
| S261300 |  | Trigger Design, Layout Custom LL1 - Vendor Selection |  | 40d | 2018-06-04 A | 2018-07-30 A | S261200 | 100% |  |  |  |  |  | S261300 | 100 | S236600 | 2018-07-30 | S337230 | NOCA | Completed | Nagle, Jamie |  | UColorado | Procurement | Martin Purschke | UCB |  | POM02.1.06.02.01 |  |  | 01 | yes | 180413 ELM status per GRY; 180402 ELM assigned proc values | PP4 | MP200600 | OPC002200 | Yes |  |  |  |  |  |  |  |  |  |  |  |  |
| OBLG261410 |  | Trigger Design, Layout Custom LL1 - Obligation |  | 1d | 2018-09-28 A | 2018-09-28 A | S261300 | 100% |  |  | Obligation Resource |  |  | S261400 | 100 | S236600 |  | S337240 |  | Completed | Nagle, Jamie |  | UColorado | Procurement | Martin Purschke | UCB |  | POM02.1.06.02.01 |  |  | 01 | yes | 180413 ELM status per GRY; 180402 ELM assigned proc values | PP5 | MP200600 | OPC002200 | Yes | A-TEC | L5 | OBLG |  |  |  |  |  |  |  |  |  |
| S261400 |  | Trigger Design, Layout Custom LL1 - Contract Award(s) | milestone | 0d | 2018-09-28 A | 2018-09-28 A | S261300 | 100% |  |  |  |  |  | S261400 | 100 | S236600 |  | S337240 | NOCA | Completed | Nagle, Jamie |  | UColorado | Procurement | Martin Purschke | UCB |  | POM02.1.06.02.01 |  |  | 01 | yes | 180413 ELM status per GRY; 180402 ELM assigned proc values | PP5 | MP200600 | OPC002200 | Yes | A-TEC | L5 |  |  |  |  |  |  |  |  |  |  |
| S261500 |  | Trigger Design, Layout Custom LL1 - Contract/PO - Leadtime |  | 167d | 2018-10-01 A | 2019-06-03 A | S261400 SS, OBLG261410 SS | 100% |  |  |  |  | 190614 ELM dur per GRY | S261500 | 60 | S236600 | 2019-01-04 | S337250 | NOCA | Completed | Nagle, Jamie |  | UColorado | Fab & Assy | Martin Purschke | UCB |  | POM02.1.06.02.01 |  |  | 01 |  | 180413 ELM status per GRY; 180402 ELM assigned proc values | PP6 | MP200600 | OPC002200 | Yes |  |  |  | MP6LA |  |  |  |  |  |  |  |  |
| S261700 |  | Trigger Design, per Downselect of gFEX mod versus Layout Custom LL1 |  | 6d | 2019-03-08 A | 2019-03-15 A | S261600 | 100% |  |  |  |  |  | S261700 | 0 | S236600 | 2019-01-16 | S337260 | NOCA | Completed | Nagle, Jamie | L1 | UColorado | Design | Martin Purschke | UCB | null | POM02.1.06.02.01 | C |  | 01 | yes | 180413 ELM status per GRY |  |  |  |  | T |  |  |  |  |  |  |  |  |  |  |  |
| S261800 |  | Trigger Design, gFEX Downselect Intermediate Design Review |  | 1d | 2019-03-18 A | 2019-03-18 A | S261600, S261700 | 100% |  |  |  |  | 190415 ELM name per GRY | S261800 | 0 | S236600 | 2019-01-16 | S337265 | NOCA | Completed | Nagle, Jamie | L1 | UColorado | Design | Martin Purschke | UCB | null | POM02.1.06.02.01 | C | 004 | 01 | yes | 180413 ELM status per GRY |  |  |  |  | T |  |  |  |  |  |  |  |  |  |  |  |
| S261600 |  | Trigger Design, Layout Custom LL1 - Delivery Acceptance |  | 1d | 2019-06-04 A | 2019-06-04 A | S261500 | 100% |  |  |  |  | 190614 ELM dur, rsrc (removed$) per GRY | S261600 | 0 | S236600 | 2019-01-09 | S337255 | NOCA | Completed | Nagle, Jamie | M5 | UColorado | Design | Martin Purschke | UCB | OPC | POM02.1.06.02.01 | F | 005 | 01 |  | 180413 ELM status per GRY; 180402 ELM assigned proc values | PP6 | MP200600 | OPC002200 | Yes | A-TEC |  | FAB | MP6LA | 59719 |  |  |  |  |  |  |  |
|  | 02 | **LL1 Trigger Prototype v1** |  |  | 2019-03-19 | 2021-02-26 |  |  |  |  |  |  |  |  |  |  |  |  |  |  |  |  |  |  |  |  |  |  |  |  |  |  |  |  |  |  |  |  |  |  |  |  |  |  |  |  |  |  |  |
| S261900 |  | Procure Prototype V1 Trigger Board - Provide Requirements to Procurement |  | 5d | 2019-03-19 A | 2019-03-25 A | S261800 | 100% |  |  |  |  |  | S261900 | 0 | S236800 |  | S236650 | NOCA | Completed | Nagle, Jamie | L1 | UColorado | Procurement | Martin Purschke | UCB | null | POM02.1.06.02.02 | C |  | 02 | yes |  | PP1 | MP107400 | OPC002300 |  | T |  |  |  |  |  |  |  |  |  |  |  |
| S262000 |  | Procure Prototype V1 Trigger Board - Prepare & Send Solicitation |  | 18d | 2019-03-26 A | 2019-04-18 A | S261900 | 100% |  |  |  |  |  | S262000 | 0 | S236900 |  | S236900 | NOCA | Completed | Nagle, Jamie |  | UColorado | Procurement | Martin Purschke | UCB |  | POM02.1.06.02.02 |  |  | 02 | yes |  | PP2 | MP107400 | OPC002300 |  |  |  |  |  |  |  |  |  |  |  |  |  |
| S262100 |  | Procure Prototype V1 Trigger Board - Vendor Responses |  | 7d | 2019-06-05 A | 2019-06-13 A | S262000 | 100% |  |  |  |  | 190614 ELM dur per GRY | S262100 | 0 | S237000 |  | S237000 | NOCA | Completed | Nagle, Jamie |  | UColorado | Procurement | Martin Purschke | UCB |  | POM02.1.06.02.02 |  |  | 02 |  |  | PP3 | MP107400 | OPC002300 |  |  |  |  |  |  |  |  |  |  |  |  |  |
| S262200 |  | Procure Prototype V1 Trigger Board - Vendor Selection |  | 13d | 2019-06-14 A | 2019-06-28 A | S262100 | 100% | 2019-06-14 | 2019-07-02 |  |  | 190614 ELM dur per GRY | S262200 | 0 | S237100 |  | S237100 | NOCA | Completed | Nagle, Jamie |  | UColorado | Procurement | Martin Purschke | UCB |  | POM02.1.06.02.02 |  |  | 02 |  |  | PP4 | MP107400 | OPC002300 |  |  |  |  |  |  |  |  |  |  |  |  |  |
| OBLG262310 |  | Procure Prototype V1 Trigger Board - Obligation |  | 1d | 2019-07-01 A | 2019-07-01 A | S262200 | 100% |  |  | Obligation Resource [196861 h] | 196,861.16 |  | S262300 | 0 | S237200 |  | S237200 |  | Completed | Nagle, Jamie |  | UColorado | Procurement | Martin Purschke | UCB |  | POM02.1.06.02.02 |  |  | 02 |  |  | PP5 | MP107400 | OPC002300 |  | A-TEC | L5 | OBLG |  |  |  |  |  |  |  |  |  |
| S262300 |  | Procure Prototype V1 Trigger Board - Contract Award(s) | milestone | 0d | 2019-07-01 A | 2019-07-01 A | S262200 | 100% |  |  |  |  | 190607 IVS make sure finish is in July | S262300 | 0 | S237200 |  | S237200 | NOCA | Completed | Nagle, Jamie |  | UColorado | Procurement | Martin Purschke | UCB |  | POM02.1.06.02.02 |  | 005 | 02 |  |  | PP5 | MP107400 | OPC002300 |  | A-TEC | L5 |  |  |  | Contract Award |  |  |  |  |  |  |
| S262400 |  | Procure Prototype V1 Trigger Board - Contract/PO - Leadtime |  | 170d | 2019-07-01 A | 2020-03-10 A | S262300 SS, OBLG262310 SS | 100% | 2019-07-01 | 2020-03-06 |  |  |  | S262400 | 0 | S237300 |  | S237300 | NOCA | In Progress | Nagle, Jamie |  | UColorado | Fab & Assy | Martin Purschke | UCB |  | POM02.1.06.02.02 |  |  | 02 |  |  | PP6 | MP107400 | OPC002300 |  |  |  |  |  |  |  |  |  |  |  |  |  |
| S262500 |  | Procure Prototype V1 Trigger Board - Delivery Acceptance |  | 5d | 2020-03-11 A | 2020-03-17 A | S262400 | 100% |  |  | Material (Purchase (1st $2M) [173000 h] | 196,861.16 | 190614 ELM rsrc ($ for conceptual + 1st prototype) | S262500 | 0 | S237400 |  | S237400 | CA | Not Started | Nagle, Jamie | M5 | UColorado | Fab & Assy | Martin Purschke | UCB | OPC | POM02.1.06.02.02 | F |  | 02 |  |  | PP6 | MP107400 | OPC002300 |  | A-TEC |  | FAB |  | 59719 | Delivery | S262500 | UDF_G3 | UDF_G1 | 1.06 | 1.06A |  |
| S262600 |  | Trigger Prototype v1: Test trigger systems |  | 80d | 2020-06-01 A | 2021-02-26 A | S262500 | 100% | 2020-06-01 | 2020-09-22 | SCI3 UCol - Unpaid [240 h] |  |  | S262600 | 0 | S237600 |  | S237600 | CA | Not Started | Nagle, Jamie | L1 | UColorado | Test_System | Martin Purschke | UCB | null | POM02.1.06.02.02 | C |  | 02 |  |  |  |  |  |  | T |  |  |  | NA |  | S262600 |  |  | 1.06 | 1.06B | Yes |
| S262800 |  | Trigger Prototype v1: Preproduction Readiness Review and Design Specifications Update |  | 2d | 2021-02-23 A | 2021-02-26 A | S262700 | 100% | 2021-03-16 | 2021-03-17 | SCI3 UCol - Unpaid [32 h]; SCI3 PO [32 h] | 5,672.6 |  | S262800 | 0 | S237800 |  | S237800 | CA | Not Started | Nagle, Jamie | L2 | UColorado | Design | Martin Purschke | UCB | null | POM02.1.06.02.02 | C |  | 02 |  | 180503 ELM name per MP |  |  |  |  | B_T |  |  |  | 16713 |  | S262800 |  |  | 1.06 | 1.06B |  |
| S262801 |  | Preliminary Design Review - DAQ Local Level-1 |  | 1d | 2021-02-23 A | 2021-02-26 A | S262800 FF | 100% | 2021-03-17 | 2021-03-17 | SCI3 UCol - Unpaid [4 h]; SCI3 Other - Unpaid [4 h]; SCI 4 PO [4 h]; SCI3 PO [4 h]; PROF3 IO E [4 h] | 2,078.63 | 190508 ELM add per GRY | S262800 | 0 | S237800 |  | S237800 | CA | Not Started | Nagle, Jamie | L2 | UColorado | Design | Martin Purschke | UCB | null | POM02.1.06.02.02 | C | 004 | 02 |  | 180503 ELM name per MP |  |  |  |  | B |  |  |  | 16713 |  | S262801 |  |  | 1.06 | 1.06B |  |
| S262700 |  | Trigger Prototype v1: Preprod complete | milestone | 0d | 2021-02-26 A | 2021-02-26 A | S262600 FF | 100% | 2021-03-15 | 2021-03-15 |  |  |  | S262700 | 0 | S237700 |  | S237700 | NOCA | Not Started | Nagle, Jamie |  | UColorado | Fab & Assy | Martin Purschke | UCB |  | POM02.1.06.02.02 |  |  | 02 |  |  |  |  |  |  |  | L5 |  |  |  |  |  | UDF_G2 | UDF_G1 |  |  |  |

Notes:
- S260900: General Comments: 180420 GYoung: concerning Design / specifications - Test of prototype / concept / BNL_UDF_Old Activity Name 181221: Trigger Design: Write design specifications
- S261000: BNL_UDF_Old Activity Name 181221: Trigger Design, Layout Custom LL1 - Provide Requirements to Procurement
- S261100: BNL_UDF_Old Activity Name 181221: Trigger Design, Layout Custom LL1 - Prepare & Send Solicitation
- S261200: BNL_UDF_Old Activity Name 181221: Trigger Design, Layout Custom LL1 - Vendor Responses
- S261300: BNL_UDF_Old Activity Name 181221: Trigger Design, Layout Custom LL1 - Vendor Selection
- OBLG261410: BNL_UDF_Old Activity Name 181221: Trigger Design, Layout Custom LL1 - Contract Award(s)
- S261400: BNL_UDF_Old Activity Name 181221: Trigger Design, Layout Custom LL1 - Contract Award(s)
- S261500: BNL_UDF_Old Activity Name 181221: Trigger Design, Layout Custom LL1 - Contract/PO - Leadtime
- S261700: General Comments: 180420 GYoung: concerning Design, / Downselect - choice of existing vs custom design for main / Prototype / BNL_UDF_Old Activity Name 181221: Trigger Design, per Downselect of gFEX mod versus Layout Custom LL1
- S261800: General Comments: 180420 GYoung: concerning Design, / Downselect - choice of existing vs custom design for main / Prototype / BNL_UDF_Old Activity Name 181221: Trigger Design, gFEX Downselect Review
- S261600: BNL_UDF_Old Activity Name 181221: Trigger Design, Layout Custom LL1 - Delivery Acceptance
- S261900: BNL_UDF_Old Activity Name 181221: Procure Prototype V1 Trigger Board - Provide Requirements to Procurement
- S262000: BNL_UDF_Old Activity Name 181221: Procure Prototype V1 Trigger Board - Prepare & Send Solicitation
- S262100: BNL_UDF_Old Activity Name 181221: Procure Prototype V1 Trigger Board - Vendor Responses
- S262200: BNL_UDF_Old Activity Name 181221: Procure Prototype V1 Trigger Board - Vendor Selection
- OBLG262310: BNL_UDF_Old Activity Name 181221: Procure Prototype V1 Trigger Board - Contract Award(s)
- S262300: BNL_UDF_Old Activity Name 181221: Procure Prototype V1 Trigger Board - Contract Award(s)
- S262400: BNL_UDF_Old Activity Name 181221: Procure Prototype V1 Trigger Board - Contract/PO - Leadtime
- S262500: BNL_UDF_Old Activity Name 181221: Procure Prototype V1 Trigger Board - Delivery Acceptance
- S262600: BNL_UDF_Old Activity Name 181221: Trigger Prototype v1: Test trigger systems
- S262800: BNL_UDF_Old Activity Name 181221: Trigger Prototype v1: Preproduction Readiness Review and Design Specifications Update
- S262801: BNL_UDF_Old Activity Name 181221: Trigger Prototype v1: Preproduction Readiness Review and Design Specifications Update
- S262700: BNL_UDF_Old Activity Name 181221: Trigger Prototype v1: Preprod complete

| ID | WBS | Activity | Type | Duration | Start | Finish | Predecessors | Complete | Remaining | Planned start | Planned finish | Total float | Free float | Expected finish | Resources | Cost | BNL_UDF_Status Comments | BNL_UDF_Temp Text 01 | BNL_UDF_Percent Complete | BNL_UDF_OPC TEC (deprecated) | BNL_UDF_Old Activity ID 181221 | BNL_Cobra WP | RG Check | BNL_Activity Status | BNL_Fund Source | BNL_Estimator | BNL_Cost Basis | BNL_Location | BNL_EDIA | BNL_CAM | BNL_Institution | BNL_R&D FY18-19 | BNL_OPC TEC (deprecated) | BNL_WBS | BNL_EVT | BNL_Master Control Account | BNL_Account Number | BNL_PCR ID | BNL_Cobra Control Account | BNL_WBS_Hierarchical | BNL_Proc Sig Phase | BNL_Proc Sig | BNL_DOE OPC | Indicator - Procurement | Indicator - Float | BNL_Milestone Level | SPH Proc Register | BNL_Obligation | BNL_UDF_Remaining Tot Cost | BNL_UDF_Percent_remaining | Target Milestone Date | Variance | PMP Milestones | BNL_UDF_Adhoc Comments |
| --- | --- | --- | --- | --- | --- | --- | --- | --- | --- | --- | --- | --- | --- | --- | --- | --- | --- | --- | --- | --- | --- | --- | --- | --- | --- | --- | --- | --- | --- | --- | --- | --- | --- | --- | --- | --- | --- | --- | --- | --- | --- | --- | --- | --- | --- | --- | --- | --- | --- | --- | --- | --- | --- | --- |
|  | 03 | **LL1 Trigger Preproduction Prototype** |  |  | 2021-02-22 | 2021-07-29 |  |  |  |  |  |  |  |  |  |  |  |  |  |  |  |  |  |  |  |  |  |  |  |  |  |  |  |  |  |  |  |  |  |  |  |  |  |  |  |  |  |  |  |  |  |  |  |  |
| S262900 |  | Trigger LL1 Preproduction Prototype: Electrical Safety and Final Design Review |  | 2d | 2021-02-22 A | 2021-02-26 A | S262801 | 100% |  | 2021-03-18 | 2021-03-19 |  |  |  | SCI3 UCol - Unpaid [10 h] |  | 190415 ELM name per GRY | S262900 | 0 | S238000 | S238000 | S262900 | CA | Not Started | T | Nagle, Jamie | L1 | UColorado | Management Safety Reviews | Martin Purschke | UCB | DAQ LL1 v2 | null | POM02.1.06.02.03 | C | 1.06 | NA | 004 | 1.06B | 03 |  |  |  |  |  |  |  |  |  |  |  |  |  |  |
| S263000 |  | Procure Trigger Preproduction Prototype LL1 - Provide Requirements to Procurement |  | 5d | 2021-02-22 A | 2021-02-26 A | S262900 | 100% |  | 2021-03-18 | 2021-03-24 |  |  |  | SCI3 UCol - Unpaid [48 h] |  |  | S263000 | 0 | S238100 | S238100 | S263000 | CA | Not Started | T | Nagle, Jamie | L1 | UColorado | Procurement | Martin Purschke | UCB | DAQ LL1 v2 | null | POM02.1.06.02.03 | C | 1.06 | NA |  | 1.06B | 03 | PP1 | MP202950 | OPC002400 |  |  |  |  |  |  |  |  |  |  |  |
| S263100 |  | Procure Trigger Preproduction Prototype LL1 - Prepare & Send Solicitation |  | 1d | 2021-02-22 A | 2021-02-26 A | S263000 | 100% |  | 2021-03-25 | 2021-03-25 |  |  |  |  |  | 190614 ELM dur per GRY | S263100 | 0 | S238200 | S238200 |  | NOCA | Not Started |  | Nagle, Jamie |  | UColorado | Procurement | Martin Purschke | UCB |  |  | POM02.1.06.02.03 |  |  |  |  |  | 03 | PP2 | MP202950 | OPC002400 |  |  |  |  |  |  |  |  |  |  |  |
| S263200 |  | Procure Trigger Preproduction Prototype LL1 - Vendor Responses |  | 1d | 2021-02-22 A | 2021-02-26 A | S263100 | 100% |  | 2021-03-26 | 2021-03-26 |  |  |  |  |  | 190614 ELM dur per GRY | S263200 | 0 | S238300 | S238300 |  | NOCA | Not Started |  | Nagle, Jamie |  | UColorado | Procurement | Martin Purschke | UCB |  |  | POM02.1.06.02.03 |  |  |  |  |  | 03 | PP3 | MP202950 | OPC002400 |  |  |  |  |  |  |  |  |  |  |  |
| S263300 |  | Procure Trigger Preproduction Prototype LL1 - Vendor Selection |  | 1d | 2021-03-01 A | 2021-03-01 A | S263200 | 100% |  |  |  |  |  |  |  |  | 190614 ELM dur per GRY | S263300 | 0 | S238400 | S238400 |  | NOCA | Not Started |  | Nagle, Jamie |  | UColorado | Procurement | Martin Purschke | UCB |  |  | POM02.1.06.02.03 |  |  |  |  |  | 03 | PP4 | MP202950 | OPC002400 |  |  |  |  |  |  |  |  |  |  |  |
| S263400 |  | Procure Trigger Preproduction Prototype LL1 - Contract Award(s) | milestone | 0d | 2021-03-01 A | 2021-03-01 A | S263300 | 100% |  | 2021-04-01 | 2021-04-01 |  |  |  |  |  |  | S263400 | 0 | S238500 | S238500 |  | NOCA | Not Started | A-TEC | Nagle, Jamie |  | UColorado | Procurement | Martin Purschke | UCB |  |  | POM02.1.06.02.03 |  |  |  |  |  | 03 | PP5 | MP202950 | OPC002400 | UDF_G2 | UDF_G1 | L5 | Contract Award |  |  |  |  |  |  |  |
| S263500 |  | Procure Trigger Preproduction Prototype LL1 - Contract/PO - Leadtime |  | 60d | 2021-03-31 A | 2021-06-24 | S263400 SS, OBLG263410 SS | 50% | 18d | 2021-04-01 | 2021-06-24 | 31d | 0d | 2021-06-24 |  |  |  | S263500 | 0 | S238600 | S238600 |  | NOCA | Not Started |  | Nagle, Jamie |  | UColorado | Fab & Assy | Martin Purschke | UCB |  |  | POM02.1.06.02.03 |  |  |  |  |  | 03 | PP6 | MP202950 | OPC002400 |  |  |  |  |  |  |  |  |  |  |  |
| OBLG263410 |  | Procure Trigger Preproduction Prototype LL1 - Obligation |  | 1d | 2021-06-01 | 2021-06-01 | S263300 |  |  |  |  | 31d | 0d |  | Obligation Resource [69641.1 h] | 69,641.07 |  | S263400 | 0 | S238500 | S238500 |  |  | Not Started | A-TEC | Nagle, Jamie |  | UColorado | Procurement | Martin Purschke | UCB |  |  | POM02.1.06.02.03 |  |  |  |  |  | 03 | PP5 | MP202950 | OPC002400 |  |  | L5 |  | OBLG |  |  |  |  |  |  |
| S263600 |  | Procure Trigger Preproduction Prototype LL1 - Delivery Acceptance |  | 5d | 2021-06-25 | 2021-07-01 | S263500 |  |  |  |  | 31d | 0d |  | Material (Purchase (1st $2M) [60000 h] | 69,641.06 |  | S263600 | 0 | S238700 | S238700 | S263600 | CA | Not Started | A-TEC | Nagle, Jamie | M5 | UColorado | Fab & Assy | Martin Purschke | UCB | DAQ LL1 v2 | OPC | POM02.1.06.02.03 | F | 1.06 | 59719 | 015 | 1.06A | 03 | PP6 | MP202950 | OPC002400 | UDF_G1 | UDF_G1 |  | Delivery | FAB | 69641.0586 | 1 |  |  |  |  |
| S263700 |  | Trigger LL1 Preproduction Prototype: Test trigger systems |  | 15d | 2021-07-02 | 2021-07-23 | S263600 |  |  |  |  | 31d | 0d |  | SCI3 UCol - Unpaid [280 h] |  |  | S263700 | 0 | S238900 | S238900 | S263700 | CA | Not Started | T | Nagle, Jamie | L1 | UColorado | Test_System | Martin Purschke | UCB | DAQ LL1 v2 | null | POM02.1.06.02.03 | C | 1.06 | NA | 015 | 1.06B | 03 |  |  |  |  |  |  |  |  |  |  |  |  |  |  |
| S263800 |  | Final Design Review - DAQ Local Level-1 |  | 4d | 2021-07-26 | 2021-07-29 | S263700 |  |  |  |  | 31d | 0d |  | SCI3 UCol - Unpaid [32 h]; SCI3 PO [32 h] | 5,672.6 | 190508 ELM name per GRY | S263800 | 0 | S239400 | S239400 | S263800 | CA | Not Started | B_T | Nagle, Jamie | L2 | UColorado | Fab & Assy | Martin Purschke | UCB |  | null | POM02.1.06.02.03 | C | 1.06 | 16713 | 004 | 1.06B | 03 |  |  |  |  |  |  |  |  |  |  |  |  |  |  |
| S263900 |  | Trigger LL1 Preproduction complete | milestone | 0d | 2021-07-29 | 2021-07-29 | S263800 FF |  |  |  |  | 31d | 0d |  |  |  |  | S263900 | 0 | S239300 | S239450 |  | NOCA | Not Started |  | Nagle, Jamie |  | UColorado | Fab & Assy | Martin Purschke | UCB | DAQ LL1 v2 |  | POM02.1.06.02.03 |  |  |  |  |  | 03 |  |  |  | UDF_G2 | UDF_G1 | L2 |  |  |  |  | 2021-06-28 | -23 | PMP_1x |  |
|  | 04 | **LL1 Trigger Production** |  |  | 2021-03-15 | 2021-12-20 |  |  |  |  |  |  |  |  |  |  |  |  |  |  |  |  |  |  |  |  |  |  |  |  |  |  |  |  |  |  |  |  |  |  |  |  |  |  |  |  |  |  |  |  |  |  |  |  |
| S264300 |  | Procure Production LL1 System - Provide Requirements to Procurement |  | 5d | 2021-03-15 A | 2021-03-30 A | S264200 | 100% |  | 2021-09-22 | 2021-09-28 |  |  |  | SCI3 UCol - Unpaid [40 h] |  |  | S264300 | 0 | S239800 | S239800 | S264300 | CA | Not Started | T | Nagle, Jamie | L1 | UColorado | Procurement | Martin Purschke | UCB |  | null | POM02.1.06.02.04 | C | 1.06 | NA |  | 1.06B | 04 | PP1 | MP107600 |  |  |  |  |  |  |  |  |  |  |  |  |
| S264400 |  | Procure Production LL1 System - Prepare & Send Solicitation |  | 30d | 2021-03-15 A | 2021-03-30 A | S264300 | 100% |  | 2021-09-29 | 2021-11-10 |  |  |  |  |  |  | S264400 | 0 | S239900 | S239900 |  | NOCA | Not Started |  | Nagle, Jamie |  | UColorado | Procurement | Martin Purschke | UCB |  |  | POM02.1.06.02.04 |  |  |  |  |  | 04 | PP2 | MP107600 |  |  |  |  |  |  |  |  |  |  |  |  |
| S264500 |  | Procure Production LL1 System - Vendor Responses |  | 5d | 2021-03-15 A | 2021-03-30 A | S264400 | 100% |  | 2021-11-12 | 2021-11-18 |  |  |  |  |  |  | S264500 | 0 | S240000 | S240000 |  | NOCA | Not Started |  | Nagle, Jamie |  | UColorado | Procurement | Martin Purschke | UCB |  |  | POM02.1.06.02.04 |  |  |  |  |  | 04 | PP3 | MP107600 |  |  |  |  |  |  |  |  |  |  |  |  |
| S264600 |  | Procure Production LL1 System - Vendor Selection |  | 5d | 2021-03-15 A | 2021-03-30 A | S264500 | 100% |  | 2021-11-19 | 2021-11-29 |  |  |  |  |  |  | S264600 | 0 | S240100 | S240100 |  | NOCA | Not Started |  | Nagle, Jamie |  | UColorado | Procurement | Martin Purschke | UCB |  |  | POM02.1.06.02.04 |  |  |  |  |  | 04 | PP4 | MP107600 |  |  |  |  |  |  |  |  |  |  |  |  |
| S264700 |  | Procure Production LL1 System - Contract Award(s) | milestone | 0d | 2021-03-31 A | 2021-03-31 A | S264600, S101000 | 100% |  | 2021-09-22 | 2021-09-22 |  |  |  |  |  |  | S264700 | 0 | S240200 | S240200 |  | NOCA | Not Started | A-TEC | Nagle, Jamie |  | UColorado | Procurement | Martin Purschke | UCB |  |  | POM02.1.06.02.04 |  |  |  |  |  | 04 | PP5 | MP107600 |  | UDF_G2 | UDF_G1 | L5 | Contract Award |  |  |  |  |  |  |  |
| S264800 |  | Procure Production LL1 System - Contract/PO - Leadtime |  | 30d | 2021-03-31 A | 2021-11-03 | S264700 SS, OBLG264710 SS | 15% | 30d | 2021-09-22 | 2021-11-03 | 31d | 0d | 2021-11-03 |  |  |  | S264800 | 0 | S240300 | S240300 |  | NOCA | Not Started |  | Nagle, Jamie |  | UColorado | Fab & Assy | Martin Purschke | UCB |  |  | POM02.1.06.02.04 |  |  |  |  |  | 04 | PP6 | MP107600 |  |  |  |  |  |  |  |  |  |  |  |  |
| S264000 |  | Trigger LL1 Production: Updates to trigger board: Production |  | 17d | 2021-07-30 | 2021-08-23 | S263900, S268915 |  |  |  |  | 31d | 0d |  | SCI3 UCol - Unpaid [136 h] |  |  | S264000 | 0 | S239500 | S239500 | S264000 | CA | Not Started | T | Nagle, Jamie | L1 | UColorado | Programming | Martin Purschke | UCB |  | null | POM02.1.06.02.04 | C | 1.06 | NA | 015 | 1.06B | 04 |  |  |  |  |  |  |  |  |  |  |  |  |  |  |
| S264100 |  | Trigger LL1 Production: final updates to trigger crate requirements |  | 10d | 2021-08-24 | 2021-09-07 | S264000 |  |  |  |  | 31d | 0d |  | SCI3 UCol - Unpaid [20 h] |  |  | S264100 | 0 | S239600 | S239600 | S264100 | CA | Not Started | T | Nagle, Jamie | L1 | UColorado | Fab & Assy | Martin Purschke | UCB |  | null | POM02.1.06.02.04 | C | 1.06 | NA |  | 1.06B | 04 |  |  |  |  |  |  |  |  |  |  |  |  |  |  |
| S264200 |  | Production Readiness Review - DAQ Local Level-1 |  | 10d | 2021-09-08 | 2021-09-21 | S264100 |  |  |  |  | 31d | 0d |  | SCI3 UCol - Unpaid [32 h]; SCI3 PO [32 h] | 5,672.6 | 190508 ELM name per GRY | S264200 | 0 | S239700 | S239700 | S264200 | CA | Not Started | B_T | Nagle, Jamie | L2 | UColorado | Fab & Assy | Martin Purschke | UCB |  | null | POM02.1.06.02.04 | C | 1.06 | 16713 | 004 | 1.06B | 04 |  |  |  |  |  |  |  |  |  |  |  |  |  | 180503 ELM name per MP |
| OBLG264710 |  | Procure Production LL1 System - Obligation |  | 1d | 2021-09-22 | 2021-09-22 | S264600, S101000 |  |  |  |  | 31d | 0d |  | Obligation Resource [135800 h] | 135,800.09 |  | S264700 | 0 | S240200 | S240200 |  |  | Not Started | A-TEC | Nagle, Jamie |  | UColorado | Procurement | Martin Purschke | UCB |  |  | POM02.1.06.02.04 |  |  |  |  |  | 04 | PP5 | MP107600 |  |  |  | L5 |  | OBLG |  |  |  |  |  |  |
| S264900 |  | Procure Production LL1 System - Delivery Acceptance |  | 5d | 2021-11-04 | 2021-11-10 | S264800 |  |  |  |  | 31d | 0d |  | Material (Purchase (1st $2M) [117000 h] | 138,516.06 |  | S264900 | 0 | S240400 | S240400 | S264900 | CA | Not Started | A-TEC | Nagle, Jamie | M5 | UColorado | Fab & Assy | Martin Purschke | UCB |  | TEC | POM02.1.06.02.04 | F | 1.06 | 59719 |  | 1.06A | 04 | PP6 | MP107600 |  | UDF_G1 | UDF_G1 |  | Delivery | FAB | 135800.06427 | 1 |  |  |  |  |
| S265000 |  | Trigger LL1 Production: Program and commission trigger boards |  | 15d | 2021-11-12 | 2021-12-06 | S264900 |  |  |  |  | 31d | 0d |  | SCI3 UCol - Unpaid [60 h] |  |  | S265000 | 0 | S240500 | S240500 | S265000 | CA | Not Started | T | Nagle, Jamie | L1 | UColorado | Fab & Assy | Martin Purschke | UCB |  | null | POM02.1.06.02.04 | K | 1.06 | NA |  | 1.06B | 04 |  |  |  |  |  |  |  |  |  |  |  |  |  |  |
| S265100 |  | Trigger LL1 Production: Assemble trigger system |  | 5d | 2021-12-07 | 2021-12-13 | S265000 |  |  |  |  | 31d | 0d |  | SCI3 UCol - Unpaid [120 h] |  |  | S265100 | 0 | S240600 | S240600 | S265100 | CA | Not Started | T | Nagle, Jamie | L1 | UColorado | Fab & Assy | Martin Purschke | UCB |  | null | POM02.1.06.02.04 | K | 1.06 | NA |  | 1.06B | 04 |  |  |  |  |  |  |  |  |  |  |  |  |  |  |
| S265200 |  | Trigger LL1 Production: Commission trigger systems |  | 5d | 2021-12-14 | 2021-12-20 | S265100 |  |  |  |  | 31d | 0d |  | SCI3 UCol - Unpaid [120 h] |  |  | S265200 | 0 | S240700 | S240700 | S265200 | CA | Not Started | T | Nagle, Jamie | L1 | UColorado | Test_System | Martin Purschke | UCB |  | null | POM02.1.06.02.04 | K | 1.06 | NA |  | 1.06B | 04 |  |  |  |  |  |  |  |  |  |  |  |  |  |  |
| S265300 |  | LL1 Trigger Production Complete | milestone | 0d | 2021-12-20 | 2021-12-20 | S265200 FF |  |  |  |  | 31d | 0d |  |  |  |  | S265300 | 0 | S240700 | S343600 |  | NOCA | Not Started |  | Nagle, Jamie | L1 | UColorado | Test_System | Martin Purschke | UCB |  | null | POM02.1.06.02.04 |  |  |  |  |  | 04 |  |  |  | UDF_G2 | UDF_G1 | L2 |  |  |  |  | 2022-01-25 | 22 | PMP_1x |  |
| S265400 |  | LL1 Ready to Operate | milestone | 0d | 2021-12-20 | 2021-12-20 | S265300 FF |  |  |  |  | 31d |  |  |  |  |  | S265400 | 0 | S240700 | S343650 |  | NOCA | Not Started |  | Nagle, Jamie | L1 | UColorado | Test_System | Martin Purschke | UCB |  | null | POM02.1.06.02.04 |  |  |  |  |  | 04 |  |  |  | UDF_G2 | UDF_G1 | L2 |  |  |  |  | 2022-01-25 | 22 | PMP_1x |  |

Notes:
- S262900: General Comments: 180420 GYoung: concerning / Electrical Safety Review - Should mention Design, also here Safety refers / to BNL check that designs are safe to operate before fabricating / them / BNL_UDF_Old Activity Name 181221: Trigger LL1 Preproduction Prototype: Electrical Safety Review
- S263000: BNL_UDF_Old Activity Name 181221: Procure Trigger Preproduction Prototype LL1 - Provide Requirements to Procurement
- S263100: BNL_UDF_Old Activity Name 181221: Procure Trigger Preproduction Prototype LL1 - Prepare & Send Solicitation
- S263200: BNL_UDF_Old Activity Name 181221: Procure Trigger Preproduction Prototype LL1 - Vendor Responses
- S263300: BNL_UDF_Old Activity Name 181221: Procure Trigger Preproduction Prototype LL1 - Vendor Selection
- S263400: BNL_UDF_Old Activity Name 181221: Procure Trigger Preproduction Prototype LL1 - Contract Award(s)
- S263500: BNL_UDF_Old Activity Name 181221: Procure Trigger Preproduction Prototype LL1 - Contract/PO - Leadtime
- OBLG263410: BNL_UDF_Old Activity Name 181221: Procure Trigger Preproduction Prototype LL1 - Contract Award(s)
- S263600: BNL_UDF_Old Activity Name 181221: Procure Trigger Preproduction Prototype LL1 - Delivery Acceptance
- S263700: BNL_UDF_Old Activity Name 181221: Trigger LL1 Preproduction Prototype: Test trigger systems
- S263800: BNL_UDF_Old Activity Name 181221: Review LL1 Preproduction Prototype board
- S263900: BNL_UDF_Old Activity Name 181221: Trigger LL1 Preproduction complete
- S264300: BNL_UDF_Old Activity Name 181221: Procure Production LL1 System - Provide Requirements to Procurement
- S264400: BNL_UDF_Old Activity Name 181221: Procure Production LL1 System - Prepare & Send Solicitation
- S264500: BNL_UDF_Old Activity Name 181221: Procure Production LL1 System - Vendor Responses
- S264600: BNL_UDF_Old Activity Name 181221: Procure Production LL1 System - Vendor Selection
- S264700: BNL_UDF_Old Activity Name 181221: Procure Production LL1 System - Contract Award(s)
- S264800: BNL_UDF_Old Activity Name 181221: Procure Production LL1 System - Contract/PO - Leadtime
- S264000: BNL_UDF_Old Activity Name 181221: Trigger LL1 Production: Updates to trigger board: Production
- S264100: BNL_UDF_Old Activity Name 181221: Trigger LL1 Production: final updates to trigger crate requirements
- S264200: BNL_UDF_Old Activity Name 181221: Trigger LL1 Production: Production Readiness Review
- OBLG264710: BNL_UDF_Old Activity Name 181221: Procure Production LL1 System - Contract Award(s)
- S264900: BNL_UDF_Old Activity Name 181221: Procure Production LL1 System - Delivery Acceptance
- S265000: BNL_UDF_Old Activity Name 181221: Trigger LL1 Production: Program and commission trigger boards
- S265100: BNL_UDF_Old Activity Name 181221: Trigger LL1 Production: Assemble trigger system
- S265200: BNL_UDF_Old Activity Name 181221: Trigger LL1 Production: Commission trigger systems
- S265300: BNL_UDF_Old Activity Name 181221: LL1 Trigger Production Complete
- S265400: BNL_UDF_Old Activity Name 181221: LL1 Ready to Operate

| ID | WBS | Activity | Type | Duration | Start | Finish | Predecessors | Complete | Remaining | Planned start | Planned finish | Total float | Free float | Expected finish | Resources | Cost | BNL_UDF_Temp Text 01 | BNL_UDF_Adhoc Comments | BNL_UDF_Percent Complete | BNL_UDF_OPC TEC (deprecated) | BNL_UDF_Temp Date 01 | BNL_UDF_Old Activity ID 181221 | RG Check | BNL_Activity Status | BNL_Estimator | BNL_Cost Basis | BNL_Location | BNL_EDIA | BNL_CAM | BNL_Institution | BNL_R&D FY18-19 | BNL_OPC TEC (deprecated) | BNL_WBS | BNL_EVT | BNL_PCR ID | BNL_WBS_Hierarchical | Completed | BNL_DOE OPC | BNL_Split Activity | BNL_Fund Source | BNL_Account Number | Additional EVT documentation required | BNL_Cobra WP | BNL_Master Control Account | BNL_Cobra Control Account | Temp | BNL_Proc Sig Phase | BNL_Proc Sig | BNL_Milestone Level | BNL_Obligation | Indicator - Procurement | Indicator - Float | SPH Proc Register | BNL_UDF_Remaining Tot Cost | BNL_UDF_Percent_remaining | Target Milestone Date | Variance | PMP Milestones |
| --- | --- | --- | --- | --- | --- | --- | --- | --- | --- | --- | --- | --- | --- | --- | --- | --- | --- | --- | --- | --- | --- | --- | --- | --- | --- | --- | --- | --- | --- | --- | --- | --- | --- | --- | --- | --- | --- | --- | --- | --- | --- | --- | --- | --- | --- | --- | --- | --- | --- | --- | --- | --- | --- | --- | --- | --- | --- | --- |
|  | 03 | **Global Level 1 Trigger (GL1)** |  |  | 2018-02-13 | 2022-01-21 |  |  |  |  |  |  |  |  |  |  |  |  |  |  |  |  |  |  |  |  |  |  |  |  |  |  |  |  |  |  |  |  |  |  |  |  |  |  |  |  |  |  |  |  |  |  |  |  |  |  |  |  |
|  | 01 | **GL1 Trigger Design** |  |  | 2018-02-13 | 2018-06-15 |  |  |  |  |  |  |  |  |  |  |  |  |  |  |  |  |  |  |  |  |  |  |  |  |  |  |  |  |  |  |  |  |  |  |  |  |  |  |  |  |  |  |  |  |  |  |  |  |  |  |  |  |
| S265500 |  | GL1 Design: Evaluate performance Requirements, Preliminary Design Review |  | 54d | 2018-02-13 A | 2018-04-30 A | S100340 | 100% |  |  |  |  |  |  |  |  | S265500 | 180413 ELM status per GRY | 100 | S240800 | 2018-08-30 | S240800 | NOCA | Completed | Purschke, Martin | L2 | BNL | Design | Martin Purschke | BNL | DAQ LL1 v1 | null | POM02.1.06.03.01 | C | 004 | 01 | yes |  |  |  |  |  |  |  |  |  |  |  |  |  |  |  |  |  |  |  |  |  |
| S265600 |  | GL1 Design: Write design specifications |  | 47d | 2018-04-11 A | 2018-06-15 A | S265501 | 100% |  |  |  |  |  |  |  |  | S265600 |  | 100 | S240900 | 2018-09-30 | S240900 | NOCA | Completed | Purschke, Martin | L2 | BNL | Design | Martin Purschke | BNL | DAQ LL1 v1 | null | POM02.1.06.03.01 | C |  | 01 | yes |  |  |  |  |  |  |  |  |  |  |  |  |  |  |  |  |  |  |  |  |  |
| S265501 |  | Preliminary Design Review - DAQ Global Level-1 | milestone | 0d | 2018-04-30 A | 2018-04-30 A | S265500 FF | 100% |  |  |  |  |  |  |  |  | S265500 | 180413 ELM status per GRY | 100 | S240800 | 2018-08-30 | S240800 | NOCA | Completed | Purschke, Martin | L2 | BNL | Design | Martin Purschke | BNL | DAQ LL1 v1 | null | POM02.1.06.03.01 | C | 004 | 01 | yes |  |  |  |  |  |  |  |  |  |  |  |  |  |  |  |  |  |  |  |  |  |
|  | 02 | **GL1 Trigger Prototype** |  |  | 2018-05-01 | 2021-07-30 |  |  |  |  |  |  |  |  |  |  |  |  |  |  |  |  |  |  |  |  |  |  |  |  |  |  |  |  |  |  |  |  |  |  |  |  |  |  |  |  |  |  |  |  |  |  |  |  |  |  |  |  |
| S265700 |  | GL1 Prototype: Select Hardware |  | 22d | 2018-05-01 A | 2018-05-31 A | S265600 | 100% |  |  |  |  |  |  |  |  | S265700 |  | 100 | S241000 |  | S241000 | NOCA | Completed | Purschke, Martin | L3 | BNL | Fab & Assy | Martin Purschke | BNL | DAQ LL1 v1 | null | POM02.1.06.03.02 | C |  | 02 | yes |  |  |  |  |  |  |  |  |  |  |  |  |  |  |  |  |  |  |  |  |  |
| S265800 |  | GL1 Prototype: Procure hardware Labor |  | 63d | 2018-07-02 A | 2018-09-28 A | S265700 | 100% |  |  |  |  |  |  |  |  | S265800 |  | 100 | S241100 |  | S241100 | NOCA | Completed | Purschke, Martin | L2 | BNL | Procurement | Martin Purschke | BNL | DAQ LL1 v1 | null | POM02.1.06.03.02 | C |  | 02 | yes |  |  |  |  |  |  |  |  |  |  |  |  |  |  |  |  |  |  |  |  |  |
| S265900 |  | GL1 Prototype: Procure hardware M&S |  | 63d | 2018-07-02 A | 2018-09-28 A | S265700 | 100% |  |  |  |  |  |  |  |  | S265900 |  | 100 | S241200 |  | S241200 | NOCA | Completed | Purschke, Martin | M4 | BNL | Fab & Assy | Martin Purschke | BNL | DAQ LL1 v1 | OPC | POM02.1.06.03.02 | C |  | 02 | yes | OPC002500 |  |  |  |  |  |  |  |  |  |  |  |  |  |  |  |  |  |  |  |  |
| S266000 |  | GL1 Prototype: develop firmware FY18 |  | 63d | 2018-07-02 A | 2018-09-28 A | S265700 | 100% |  |  |  |  |  |  |  |  | S266000 |  | 100 | S241300 |  | S241300 | NOCA | Completed | Purschke, Martin | L4 | BNL | Programming | Martin Purschke | BNL | DAQ LL1 v1 | null | POM02.1.06.03.02 |  |  | 02 | yes |  | FY18 |  |  |  |  |  |  |  |  |  |  |  |  |  |  |  |  |  |  |  |
| S266200 |  | GL1 Prototype: Design I/O Transition Module FY18 |  | 63d | 2018-07-02 A | 2018-09-28 A | S265700 | 100% |  |  |  |  |  |  |  |  | S266200 | 180420 ELM pred/succ per GRY; | 100 | S137600 |  | S241350 | NOCA | Completed | Purschke, Martin | L4 | BNL | Design | Martin Purschke | BNL |  | null | POM02.1.06.03.02 |  |  | 02 | yes |  | FY18 |  |  |  |  |  |  |  |  |  |  |  |  |  |  |  |  |  |  |  |
| S266400 |  | GL1 Prototype: setup hardware FY18 |  | 32d | 2018-08-15 A | 2018-09-28 A | S265800, S265900 | 100% |  |  |  |  |  |  |  |  | S266400 |  | 100 | S241400 |  | S241400 | NOCA | Completed | Purschke, Martin | L2 | BNL | Fab & Assy | Martin Purschke | BNL | DAQ LL1 v1 | null | POM02.1.06.03.02 |  |  | 02 | yes |  | FY18 |  |  |  |  |  |  |  |  |  |  |  |  |  |  |  |  |  |  |  |
| S266100 |  | GL1 Prototype: develop firmware FY19 |  | 166d | 2018-10-01 A | 2019-05-31 A | S266000 | 100% |  |  |  |  |  |  |  |  | S266100 |  | 15 | S241300 | 2019-04-19 | S241320 | NOCA | Completed | Purschke, Martin | L4 | BNL | Programming | Martin Purschke | BNL | DAQ LL1 v1 | null | POM02.1.06.03.02 | C |  | 02 | yes |  | FY19 | B | 16713 | Yes |  |  |  |  |  |  |  |  |  |  |  |  |  |  |  |  |
| S266500 |  | GL1 Prototype: setup hardware FY19 |  | 115d | 2018-10-01 A | 2019-03-20 A | S266400 | 100% |  |  |  |  |  |  |  |  | S266500 |  | 60 | S241400 | 2019-03-20 | S241450 | NOCA | Completed | Purschke, Martin | L2 | BNL | Fab & Assy | Martin Purschke | BNL | DAQ LL1 v1 | null | POM02.1.06.03.02 | C | 003 | 02 | yes |  | FY19 | B_T | 16713 | Yes |  |  |  |  |  |  |  |  |  |  |  |  |  |  |  |  |
| S266110 |  | GL1 Prototype: develop firmware FY19 Split |  | 84d | 2019-06-03 A | 2020-01-06 A | S266100 | 100% |  | 2019-06-03 | 2019-09-30 |  |  |  | PROF3 PO E [354 h]; SCI3 PO [97 h] | 59,687.99 | S266100 |  | 15 | S241300 | 2019-04-19 | S241320 | CA | In Progress | Purschke, Martin | L4 | BNL | Programming | Martin Purschke | BNL | DAQ LL1 v1 | null | POM02.1.06.03.02 | C |  | 02 |  |  | FY19 | B | 16713 | Yes | S266110 | 1.06 | 1.06B | 1 |  |  |  |  |  |  |  |  |  |  |  |  |
| S266300 |  | GL1 Prototype: Design I/O Transition Module FY19 |  | 84d | 2019-06-03 A | 2020-02-28 A | S266200 | 100% |  | 2019-06-03 | 2019-09-30 |  |  |  | TECH3 PO D [64 h] | 7,091.08 | S266300 | 180420 ELM pred/succ per GRY; | 0 | S137600 |  | S241370 | CA | In Progress | Purschke, Martin | L4 | BNL | Design | Martin Purschke | BNL |  | null | POM02.1.06.03.02 | C | 005 | 02 |  |  | FY19 | B | 16713 | Yes | S266300 | 1.06 | 1.06B | 1 |  |  |  |  |  |  |  |  |  |  |  |  |
| S266600 |  | GL1 Prototype: test prototype |  | 60d | 2019-12-17 A | 2021-06-30 | S266500, S266110 | 95% | 22d | 2019-12-17 | 2020-03-13 | 127d | 0d | 2021-06-30 | SCI3 PO [80 h]; STUDENT SBU - Unpaid [240 h]; PROF3 PO E [240 h] | 44,130.74 | S266600 |  | 0 | S241500 |  | S241500 | CA | Not Started | Purschke, Martin | L4 | BNL | Test_System | Martin Purschke | BNL | DAQ LL1 v1 | null | POM02.1.06.03.02 | C |  | 02 |  |  |  | B_T | 16713 |  | S266600 | 1.06 | 1.06B |  |  |  |  |  |  |  |  |  |  |  |  |  |
| S266700 |  | GL1 Prototype: evaluate performance, Final Design and Production Readiness Review |  | 40d | 2020-11-03 A | 2021-07-30 | S266600 | 60% | 21d | 2020-11-03 | 2021-01-04 | 127d | 0d | 2021-07-30 | SCI3 PO [80 h]; SCI3 SBU - Unpaid [100 h]; STUDENT SBU - Unpaid [200 h]; PROF3 PO E [80 h] | 24,605.89 | S266700 |  | 0 | S241600 |  | S241600 | CA | Not Started | Purschke, Martin | L3 | BNL | Fab & Assy | Martin Purschke | BNL | DAQ LL1 v1 | null | POM02.1.06.03.02 | C | 004 | 02 |  |  |  | B_T | 16713 |  | S266700 | 1.06 | 1.06B |  |  |  |  |  |  |  |  |  |  |  |  |  |
| S266701 |  | Final Design Review - DAQ Global Level-1 |  | 1d | 2021-06-01 | 2021-06-01 | S266300 |  |  |  |  | 10d | 0d |  | PROF3 IO E [4 h]; SCI3 PO [4 h]; SCI3 Other - Unpaid [4 h]; SCI 4 PO [4 h]; PROF3 PO E [8 h] | 3,121.07 | S266700 |  | 0 | S241600 |  | S241600 | CA | Not Started | Purschke, Martin | L3 | BNL | Management Tech Reviews | Martin Purschke | BNL | DAQ LL1 v1 | null | POM02.1.06.03.02 | F | 004 | 02 |  |  |  | B | 16713 |  | S266701 | 1.06 | 1.06B |  |  |  |  |  |  |  |  |  |  |  |  |  |
| S266702 |  | Procurement Readiness Review - DAQ Global Level-1 |  | 1d | 2021-06-01 | 2021-06-01 | S266701 SS |  |  |  |  | 10d | 0d |  | PROF3 PO E [4 h]; PROF3 IO E [8 h]; SCI3 PO [4 h]; SCI3 Other - Unpaid [4 h]; SCI 4 PO [4 h] | 3,121.07 | S266700 |  | 0 | S241600 |  | S241600 | CA | Not Started | Purschke, Martin | L3 | BNL | Management Tech Reviews | Martin Purschke | BNL | DAQ LL1 v1 | null | POM02.1.06.03.02 | F | 004 | 02 |  |  |  | B | 16713 |  | S266702 | 1.06 | 1.06B |  |  |  |  |  |  |  |  |  |  |  |  |  |
| S266800 |  | GL1 Prototype: Update design specifications; incorporate final design choice |  | 20d | 2021-06-02 | 2021-06-29 | S266701 SS, S266702 |  |  |  |  | 10d | 0d |  | SCI3 PO [64 h]; SCI3 SBU - Unpaid [60 h]; PROF3 PO E [80 h] | 21,769.59 | S266800 | 180420 ELM name per MLP | 0 | S241700 |  | S241700 | CA | Not Started | Purschke, Martin | L2 | BNL | Design | Martin Purschke | BNL | DAQ LL1 v1 | null | POM02.1.06.03.02 | C |  | 02 |  |  |  | B_T | 16713 |  | S266800 | 1.06 | 1.06B |  |  |  |  |  |  |  |  |  |  |  |  |  |
|  | 03 | **GL1 Trigger Production** |  |  | 2021-04-02 | 2022-01-21 |  |  |  |  |  |  |  |  |  |  |  |  |  |  |  |  |  |  |  |  |  |  |  |  |  |  |  |  |  |  |  |  |  |  |  |  |  |  |  |  |  |  |  |  |  |  |  |  |  |  |  |  |
| S267000 |  | Procure Production GL1 Components - Provide Requirements to Procurement |  | 5d | 2021-04-02 A | 2021-04-08 A | S266800 | 100% |  | 2021-06-02 | 2021-06-08 |  |  |  | SCI3 PO [36 h]; SCI3 SBU - Unpaid [36 h] | 6,381.68 | S267000 |  | 0 | S241900 |  | S241900 | CA | Not Started | Purschke, Martin | L2 | BNL | Procurement | Martin Purschke | BNL |  | null | POM02.1.06.03.03 | C |  | 03 |  |  |  | B_T | 16713 |  | S267000 | 1.06 | 1.06B |  | PP1 | MP107700 |  |  |  |  |  |  |  |  |  |  |
| S267100 |  | Procure Production GL1 Components - Prepare & Send Solicitation |  | 5d | 2021-04-09 A | 2021-04-15 A | S267000 | 100% |  | 2021-06-09 | 2021-06-15 |  |  |  |  |  | S267100 |  | 0 | S242000 |  | S242000 | NOCA | Not Started | Purschke, Martin |  | BNL | Procurement | Martin Purschke | BNL |  |  | POM02.1.06.03.03 |  |  | 03 |  |  |  |  |  |  |  |  |  |  | PP2 | MP107700 |  |  |  |  |  |  |  |  |  |  |
| S267200 |  | Procure Production GL1 Components - Vendor Responses |  | 5d | 2021-04-16 A | 2021-04-22 A | S267100 | 100% |  | 2021-06-16 | 2021-06-22 |  |  |  |  |  | S267200 |  | 0 | S242100 |  | S242100 | NOCA | Not Started | Purschke, Martin |  | BNL | Procurement | Martin Purschke | BNL |  |  | POM02.1.06.03.03 |  |  | 03 |  |  |  |  |  |  |  |  |  |  | PP3 | MP107700 |  |  |  |  |  |  |  |  |  |  |
| S267300 |  | Procure Production GL1 Components - Vendor Selection |  | 5d | 2021-04-23 A | 2021-04-29 A | S267200 | 100% |  | 2021-06-23 | 2021-06-29 |  |  |  |  |  | S267300 |  | 0 | S242200 |  | S242200 | NOCA | Not Started | Purschke, Martin |  | BNL | Procurement | Martin Purschke | BNL |  |  | POM02.1.06.03.03 |  |  | 03 |  |  |  |  |  |  |  |  |  |  | PP4 | MP107700 |  |  |  |  |  |  |  |  |  |  |
| OBLG267410 |  | Procure Production GL1 Components - Obligation |  | 1d | 2021-06-30 | 2021-06-30 | S267300, S101000 |  |  |  |  | 35d | 0d |  | Obligation Resource [32545.1 h] | 32,545.14 | S267400 |  | 0 | S242300 |  | S242300 |  | Not Started | Purschke, Martin |  | BNL | Procurement | Martin Purschke | BNL |  |  | POM02.1.06.03.03 |  |  | 03 |  |  |  | A-TEC |  |  |  |  |  |  | PP5 | MP107700 | L5 | OBLG |  |  |  |  |  |  |  |  |
| S266900 |  | GL1 Production: final firmware updates |  | 60d | 2021-06-30 | 2021-09-23 | S266800 |  |  |  |  | 10d | 0d |  | SCI3 SBU - Unpaid [64 h]; SCI3 PO [64 h]; PROF3 PO E [406 h] | 64,248.96 | S266900 |  | 0 | S241800 |  | S241800 | CA | Not Started | Purschke, Martin | L4 | BNL | Programming | Martin Purschke | BNL |  | null | POM02.1.06.03.03 | C |  | 03 |  |  |  | B_T | 16713 | Yes | S266900 | 1.06 | 1.06B |  |  |  |  |  |  |  |  |  |  |  |  |  |
| S267400 |  | Procure Production GL1 Components - Contract Award(s) | milestone | 0d | 2021-06-30 | 2021-06-30 | S267300, S101000 |  |  |  |  | 35d | 0d |  |  |  | S267400 |  | 0 | S242300 |  | S242300 | NOCA | Not Started | Purschke, Martin |  | BNL | Procurement | Martin Purschke | BNL |  |  | POM02.1.06.03.03 |  |  | 03 |  |  |  | A-TEC |  |  |  |  |  |  | PP5 | MP107700 | L5 |  | UDF_G1 | UDF_G1 | Contract Award |  |  |  |  |  |
| S267500 |  | Procure Production GL1 Components - Contract/PO - Leadtime |  | 30d | 2021-06-30 | 2021-08-11 | S267400 SS, OBLG267410 SS |  |  |  |  | 35d | 0d |  |  |  | S267500 |  | 0 | S242400 |  | S242400 | NOCA | Not Started | Purschke, Martin |  | BNL | Fab & Assy | Martin Purschke | BNL |  |  | POM02.1.06.03.03 |  |  | 03 |  |  |  |  |  |  |  |  |  |  | PP6 | MP107700 |  |  |  |  |  |  |  |  |  |  |
| S267600 |  | Procure Production GL1 Components - final hardware - Delivery Acceptance |  | 5d | 2021-08-12 | 2021-08-18 | S267500 |  |  |  |  | 35d | 25d |  | Material (Purchase (1st $2M) [28150 h] | 32,673.26 | S267600 | 180410 ELM pred/succ per GRY | 0 | S242500 |  | S242500 | CA | Not Started | Purschke, Martin | M4 | BNL | Fab & Assy | Martin Purschke | BNL |  | TEC | POM02.1.06.03.03 | C | 015 | 03 |  |  |  | A-TEC | 59720 |  | S267600 | 1.06 | 1.06A |  | PP6 | MP107700 |  | FAB | UDF_G1 | UDF_G1 | Delivery | 32673.263326 | 1 |  |  |  |
| S267900 |  | GL1 Production: install GL1 system |  | 25d | 2021-09-24 | 2021-10-29 | S267000, S266900, S267600 |  |  |  |  | 10d | 0d |  | PROF3 PO E [80 h]; TECH3 PO E [320 h]; STUDENT SBU - Unpaid [160 h] | 49,191.98 | S267900 |  | 0 | S242800 |  | S242800 | CA | Not Started | Purschke, Martin | L3 | BNL | Fab & Assy | Martin Purschke | BNL |  | null | POM02.1.06.03.03 | C |  | 03 |  |  |  | B_T | 16713 |  | S267900 | 1.06 | 1.06B |  |  |  |  |  |  |  |  |  |  |  |  |  |
| S268000 |  | GL1 Production: commission GL1 system |  | 30d | 2021-11-01 | 2021-12-15 | S267900 |  |  |  |  | 10d | 0d |  | SCI3 PO [72 h]; SCI3 UCol - Unpaid [108 h]; PROF3 PO E [108 h] | 27,641.37 | S268000 |  | 0 | S242900 |  | S242900 | CA | Not Started | Purschke, Martin | L4 | BNL | Fab & Assy | Martin Purschke | BNL |  | null | POM02.1.06.03.03 | C | 003 | 03 |  |  |  | B_T | 16713 | Yes | S268000 | 1.06 | 1.06B |  |  |  |  |  |  |  |  |  |  |  |  |  |
| S268010 |  | GL1 Production: commission GL1 system Instr |  | 30d | 2021-11-01 | 2021-12-15 | S267900 |  |  |  |  | 10d | 0d |  | PROF3 IO E [108 h] | 14,495.11 | S268000 |  | 0 | S242900 |  | S242900 | CA | Not Started | Purschke, Martin | L4 | BNL | Fab & Assy | Martin Purschke | BNL |  | null | POM02.1.06.03.03 | C | 003 | 03 |  |  |  | B | 16713 | Yes | S268010 | 1.06 | 1.06B |  |  |  |  |  |  |  |  |  |  |  |  |  |
| S268100 |  | GL1 Production: additional firmware improvements |  | 24d | 2021-12-16 | 2022-01-21 | S268000, S268010 |  |  |  |  | 10d | 0d |  | PROF3 PO E [156 h] | 20,937.38 | S268100 |  | 0 | S242900 |  | S242950 | CA | Not Started | Purschke, Martin | L4 | BNL | Fab & Assy | Martin Purschke | BNL |  | null | POM02.1.06.03.03 | C |  | 03 |  |  |  | B | 16713 |  | S268100 | 1.06 | 1.06B |  |  |  |  |  |  |  |  |  |  |  |  |  |
| S268200 |  | GL1 Ready to Operate | milestone | 0d | 2022-01-21 | 2022-01-21 | S268100 FF, S266700 |  |  |  |  | 10d |  |  |  |  | S268200 |  | 0 | S243000 |  | S243000 | NOCA | Not Started | Purschke, Martin |  | BNL | Fab & Assy | Martin Purschke | BNL |  |  | POM02.1.06.03.03 |  |  | 03 |  |  |  |  |  |  |  |  |  |  |  |  | L2 |  | UDF_G2 | UDF_G1 |  |  |  | 2022-01-24 | 0 | PMP_1x |

Notes:
- S265500: BNL_UDF_Status Comments: 190415 ELM name per GRY / BNL_UDF_Old Activity Name 181221: GL1 Design: Evaluate performance Requirements
- S265600: BNL_UDF_Old Activity Name 181221: GL1 Design: Write design specifications
- S265501: BNL_UDF_Status Comments: 190508 ELM add per GRY / BNL_UDF_Old Activity Name 181221: GL1 Design: Evaluate performance Requirements
- S265700: BNL_UDF_Old Activity Name 181221: GL1 Prototype: Select Hardware
- S265800: BNL_UDF_Old Activity Name 181221: GL1 Prototype: Procure hardware Labor
- S265900: BNL_UDF_Old Activity Name 181221: GL1 Prototype: Procure hardware M&S
- S266000: BNL_UDF_Old Activity Name 181221: GL1 Prototype: develop firmware FY18
- S266200: Scheduler's Notes: EMenter 180329 / 260 day lag on pred in order to buy computers as late as / possible to obtain max performance / BNL_UDF_Old Activity Name 181221: GL1 Prototype: Design I/O Transition Module FY18
- S266400: BNL_UDF_Old Activity Name 181221: GL1 Prototype: setup hardware FY18
- S266100: BNL_UDF_Old Activity Name 181221: GL1 Prototype: develop firmware FY19
- S266500: BNL_UDF_Status Comments: 190313 ELM rsrc / BNL_UDF_Old Activity Name 181221: GL1 Prototype: setup hardware FY19
- S266110: BNL_UDF_Old Activity Name 181221: GL1 Prototype: develop firmware FY19
- S266300: Scheduler's Notes: EMenter 180329 / 260 day lag on pred in order to buy computers as late as / possible to obtain max performance / BNL_UDF_Status Comments: 190607 IVS check Finish is in Aug; 190605 IVS is needed only late in the game / BNL_UDF_Old Activity Name 181221: GL1 Prototype: Design I/O Transition Module FY19
- S266600: BNL_UDF_Old Activity Name 181221: GL1 Prototype: test prototype
- S266700: BNL_UDF_Status Comments: 190415 ELM name per GRY / BNL_UDF_Old Activity Name 181221: GL1 Prototype: evaluate performance
- S266701: BNL_UDF_Status Comments: 190509 ELM act type, rel per GRY; 190508 ELM add per GRY / BNL_UDF_Old Activity Name 181221: GL1 Prototype: evaluate performance
- S266702: BNL_UDF_Status Comments: 190509 ELM add per GRY / BNL_UDF_Old Activity Name 181221: GL1 Prototype: evaluate performance
- S266800: BNL_UDF_Old Activity Name 181221: GL1 Prototype: Update design specifications; incorporate final design choice
- S267000: BNL_UDF_Old Activity Name 181221: Procure Production GL1 Components - Provide Requirements to Procurement
- S267100: BNL_UDF_Old Activity Name 181221: Procure Production GL1 Components - Prepare & Send Solicitation
- S267200: BNL_UDF_Old Activity Name 181221: Procure Production GL1 Components - Vendor Responses
- S267300: BNL_UDF_Old Activity Name 181221: Procure Production GL1 Components - Vendor Selection
- OBLG267410: BNL_UDF_Old Activity Name 181221: Procure Production GL1 Components - Contract Award(s)
- S266900: BNL_UDF_Old Activity Name 181221: GL1 Production: final firmware updates
- S267400: BNL_UDF_Old Activity Name 181221: Procure Production GL1 Components - Contract Award(s)
- S267500: BNL_UDF_Old Activity Name 181221: Procure Production GL1 Components - Contract/PO - Leadtime
- S267600: BNL_UDF_Status Comments: 190315 ELM BNL Units per MP / BNL_UDF_Old Activity Name 181221: Procure Production GL1 Components - final hardware - Delivery Acceptance
- S267900: BNL_UDF_Old Activity Name 181221: GL1 Production: install GL1 system
- S268000: BNL_UDF_Status Comments: 190323 ELM Activity split / BNL_UDF_Old Activity Name 181221: GL1 Production: commission GL1 system
- S268010: BNL_UDF_Status Comments: 190326 ELM rsrc per GRY; 190323 ELM Activity split / BNL_UDF_Old Activity Name 181221: GL1 Production: commission GL1 system
- S268100: BNL_UDF_Old Activity Name 181221: GL1 Production: additional firmware improvements
- S268200: BNL_UDF_Old Activity Name 181221: GL1 Ready to Operate

| ID | WBS | Activity | Type | Duration | Start | Finish | Predecessors | Complete | Remaining | Planned start | Planned finish | Total float | Free float | Expected finish | Resources | Cost | BNL_UDF_Temp Text 01 | BNL_UDF_Adhoc Comments | BNL_UDF_Percent Complete | BNL_UDF_OPC TEC (deprecated) | BNL_UDF_Temp Date 01 | BNL_UDF_Old Activity ID 181221 | RG Check | BNL_Activity Status | BNL_Estimator | BNL_Cost Basis | BNL_Location | BNL_EDIA | BNL_CAM | BNL_Institution | BNL_R&D FY18-19 | BNL_OPC TEC (deprecated) | BNL_WBS | BNL_EVT | BNL_PCR ID | BNL_WBS_Hierarchical | Completed | BNL_Split Activity | BNL_DOE OPC | BNL_Fund Source | BNL_Account Number | Additional EVT documentation required | BNL_Cobra WP | BNL_Master Control Account | BNL_Cobra Control Account | Temp |
| --- | --- | --- | --- | --- | --- | --- | --- | --- | --- | --- | --- | --- | --- | --- | --- | --- | --- | --- | --- | --- | --- | --- | --- | --- | --- | --- | --- | --- | --- | --- | --- | --- | --- | --- | --- | --- | --- | --- | --- | --- | --- | --- | --- | --- | --- | --- |
|  | 04 | **Timing System** |  |  | 2018-02-13 | 2022-01-13 |  |  |  |  |  |  |  |  |  |  |  |  |  |  |  |  |  |  |  |  |  |  |  |  |  |  |  |  |  |  |  |  |  |  |  |  |  |  |  |  |
|  | 01 | **Timing system Design** |  |  | 2018-02-13 | 2018-05-31 |  |  |  |  |  |  |  |  |  |  |  |  |  |  |  |  |  |  |  |  |  |  |  |  |  |  |  |  |  |  |  |  |  |  |  |  |  |  |  |  |
| S268300 |  | Evaluate performance Requirements, Preliminary Design Review |  | 76d | 2018-02-13 A | 2018-05-31 A | S100340 | 100% |  |  |  |  |  |  |  |  | S268300 | 180413 ELM status per GRY | 100 | S243100 | 2018-09-30 | S243100 | NOCA | Completed | Purschke, Martin | L3 | BNL | Fab & Assy | Martin Purschke | BNL | DAQ Timing/Switch | null | POM02.1.06.04.01 | C | 004 | 01 | yes |  |  |  |  |  |  |  |  |  |
| S268400 |  | Timing system Design: Write design specifications |  | 51d | 2018-03-21 A | 2018-05-31 A | S268301 | 100% |  |  |  |  |  |  |  |  | S268400 |  | 100 | S243200 | 2018-09-30 | S243200 | NOCA | Completed | Purschke, Martin | L3 | BNL | Design | Martin Purschke | BNL | DAQ Timing/Switch | null | POM02.1.06.04.01 | C |  | 01 | yes |  |  |  |  |  |  |  |  |  |
| S268301 |  | Preliminary Design Review - DAQ Timing System | milestone | 0d | 2018-05-31 A | 2018-05-31 A | S268300 FF | 100% |  |  |  |  |  |  |  |  | S268300 | 180413 ELM status per GRY | 100 | S243100 | 2018-09-30 | S243100 | NOCA | Completed | Purschke, Martin | L3 | BNL | Fab & Assy | Martin Purschke | BNL | DAQ Timing/Switch | null | POM02.1.06.04.01 | C | 004 | 01 | yes |  |  |  |  |  |  |  |  |  |
|  | 02 | **Timing System Prototype** |  |  | 2018-04-06 | 2021-06-28 |  |  |  |  |  |  |  |  |  |  |  |  |  |  |  |  |  |  |  |  |  |  |  |  |  |  |  |  |  |  |  |  |  |  |  |  |  |  |  |  |
| S268500 |  | Timing System Prototype: Select FPGA Board |  | 12d | 2018-04-06 A | 2018-04-23 A | S268400 | 100% |  |  |  |  |  |  |  |  | S268500 |  | 100 | S243300 |  | S243300 | NOCA | Completed | Purschke, Martin | L3 | BNL | Procurement | Martin Purschke | BNL | DAQ Timing/Switch | null | POM02.1.06.04.02 | C |  | 02 | yes |  |  |  |  |  |  |  |  |  |
| S268800 |  | Timing System Prototype: develop firmware FY18 |  | 111d | 2018-04-24 A | 2018-09-28 A | S268500 | 100% |  |  |  |  |  |  |  |  | S268800 | 180413 ELM dur per GRY | 100 | S243600 |  | S243600 | NOCA | Completed | Purschke, Martin | L4 | BNL | Programming | Martin Purschke | BNL | DAQ Timing/Switch | null | POM02.1.06.04.02 |  |  | 02 | yes | FY18 |  |  |  |  |  |  |  |  |
| S268600 |  | Timing System Prototype: Procure hardware Labor |  | 32d | 2018-07-02 A | 2018-08-15 A | S268500 | 100% |  |  |  |  |  |  |  |  | S268600 |  | 100 | S243400 | 2018-08-15 | S243400 | NOCA | Completed | Purschke, Martin | L2 | BNL | Procurement | Martin Purschke | BNL | DAQ Timing/Switch | null | POM02.1.06.04.02 | C |  | 02 | yes |  |  |  |  |  |  |  |  |  |
| S268700 |  | Timing System Prototype: Procure hardware M&S |  | 32d | 2018-07-02 A | 2018-08-15 A | S268500 | 100% |  |  |  |  |  |  |  |  | S268700 |  | 100 | S243500 | 2018-08-15 | S243500 | NOCA | Completed | Purschke, Martin | M4 | BNL | Fab & Assy | Martin Purschke | BNL | DAQ Timing/Switch | OPC | POM02.1.06.04.02 | C |  | 02 | yes |  | OPC002500 |  |  |  |  |  |  |  |
| S269000 |  | Timing System Prototype: Design I/O Transition Module FY18 |  | 59d | 2018-07-09 A | 2018-09-28 A | S268500 | 100% |  |  |  |  |  |  |  |  | S269000 | 180420 ELM pred/succ per GRY; | 100 | S137600 |  | S243650 | NOCA | Completed | Purschke, Martin | L4 | BNL | Design | Martin Purschke | BNL |  | null | POM02.1.06.04.02 |  |  | 02 | yes | FY18 |  |  |  |  |  |  |  |  |
| S269200 |  | Timing System Prototype: setup hardware FY18 |  | 31d | 2018-08-16 A | 2018-09-28 A | S268600 FS+10d, S268700 FS+10d | 100% |  |  |  |  |  |  |  |  | S269200 |  | 100 | S243700 |  | S243700 | NOCA | Completed | Purschke, Martin | L2 | BNL | Fab & Assy | Martin Purschke | BNL | DAQ Timing/Switch | null | POM02.1.06.04.02 |  |  | 02 | yes | FY18 |  |  |  |  |  |  |  |  |
| S268900 |  | Timing System Prototype: develop firmware FY19 |  | 166d | 2018-10-01 A | 2019-05-31 A | S268800 | 100% |  |  |  |  |  |  |  |  | S268900 | 180413 ELM dur per GRY | 40 | S243600 |  | S243620 | NOCA | Completed | Purschke, Martin | L4 | BNL | Programming | Martin Purschke | BNL | DAQ Timing/Switch | null | POM02.1.06.04.02 | C | 003 | 02 | yes | FY19 |  | B_T | 16713 | Yes |  |  |  |  |
| S268910 |  | Timing System Prototype: develop firmware FY19 |  | 166d | 2018-10-01 A | 2019-05-31 A | S268800 | 100% |  |  |  |  |  |  |  |  | S268900 | 180413 ELM dur per GRY | 40 | S243600 |  | S243620 | NOCA | Completed | Purschke, Martin | L4 | BNL | Programming | Martin Purschke | BNL | DAQ Timing/Switch | null | POM02.1.06.04.02 | C | 003,005 | 02 | yes | FY19 |  | B | 16713 | Yes |  |  |  |  |
| S269300 |  | Timing System Prototype: setup hardware FY19 |  | 45d | 2018-10-01 A | 2018-12-06 A | S269200 | 100% |  |  |  |  |  |  |  |  | S269300 |  | 100 | S243700 |  | S243750 | NOCA | Completed | Purschke, Martin | L2 | BNL | Fab & Assy | Martin Purschke | BNL | DAQ Timing/Switch | null | POM02.1.06.04.02 | C | 003 | 02 | yes | FY19 |  | B | 16713 | Yes |  |  |  |  |
| S269310 |  | Timing System Prototype: setup hardware FY19 |  | 45d | 2018-10-01 A | 2018-12-06 A | S269200 | 100% |  |  |  |  |  |  |  |  | S269300 |  | 100 | S243700 |  | S243750 | NOCA | Completed | Purschke, Martin | L2 | BNL | Fab & Assy | Martin Purschke | BNL | DAQ Timing/Switch | null | POM02.1.06.04.02 | C | 003 | 02 | yes | FY19 |  | B | 16713 | Yes |  |  |  |  |
| S268905 |  | Timing System Prototype: develop firmware FY19 Split |  | 84d | 2019-06-03 A | 2019-12-31 A | S268900 | 100% |  | 2019-06-03 | 2019-09-30 |  |  |  | PROF3 PO E [326 h]; SCI3 PO [19 h]; SCI3 UCol - Unpaid [19 h] | 43,215.65 | S268900 | 180413 ELM dur per GRY | 40 | S243600 |  | S243620 | CA | In Progress | Purschke, Martin | L4 | BNL | Programming | Martin Purschke | BNL | DAQ Timing/Switch | null | POM02.1.06.04.02 | C | 003 | 02 |  | FY19 |  | B_T | 16713 | Yes | S268905 | 1.06 | 1.06B | 1 |
| S268915 |  | Timing System Prototype: develop firmware FY19 Split Instrum |  | 84d | 2019-06-03 A | 2019-12-31 A | S268910 | 100% |  | 2019-06-03 | 2019-09-30 |  |  |  | PROF3 IO E [55 h] | 6,755.36 | S268900 | 180413 ELM dur per GRY | 40 | S243600 |  | S243620 | CA | In Progress | Purschke, Martin | L4 | BNL | Programming | Martin Purschke | BNL | DAQ Timing/Switch | null | POM02.1.06.04.02 | C | 003,005 | 02 |  | FY19 |  | B | 16713 | Yes | S268915 | 1.06 | 1.06B | 1 |
| S269100 |  | Timing System Prototype: Design I/O Transition Module FY19 |  | 84d | 2019-06-03 A | 2020-02-28 A | S269000 | 100% |  | 2019-06-03 | 2019-09-30 |  |  |  | TECH3 PO D [76 h] | 8,420.66 | S269100 | 180420 ELM pred/succ per GRY; | 0 | S137600 |  | S243670 | CA | In Progress | Purschke, Martin | L4 | BNL | Design | Martin Purschke | BNL |  | null | POM02.1.06.04.02 | C |  | 02 |  | FY19 |  | B | 16713 | Yes | S269100 | 1.06 | 1.06B | 1 |
| S269400 |  | Timing System Prototype: test prototype |  | 30d | 2019-12-19 A | 2020-02-28 A | S269300, S269310, S268905 | 100% |  | 2019-12-19 | 2020-02-03 |  |  |  | SCI3 PO [24 h]; STUDENT UCol - Unpaid [120 h]; SCI3 UCol - Unpaid [36 h] | 4,130.54 | S269400 |  | 0 | S243800 |  | S243800 | CA | Not Started | Purschke, Martin | L4 | BNL | Test_Components | Martin Purschke | BNL | DAQ Timing/Switch | null | POM02.1.06.04.02 | C |  | 02 |  |  |  | B_T | 16713 |  | S269400 | 1.06 | 1.06B |  |
| S269500 |  | Timing System Prototype: evaluate performance, Final Design and Production Readiness Review |  | 40d | 2020-02-24 A | 2021-06-14 | S269400 | 95% | 10d | 2020-03-02 | 2020-04-24 | 15d | 0d | 2021-06-14 | SCI3 PO [16 h]; STUDENT UCol - Unpaid [80 h]; SCI3 UCol - Unpaid [40 h] | 2,753.69 | S269500 |  | 0 | S243900 |  | S243900 | CA | Not Started | Purschke, Martin | L3 | BNL | Fab & Assy | Martin Purschke | BNL | DAQ Timing/Switch | null | POM02.1.06.04.02 | C | 004 | 02 |  |  |  | B_T | 16713 |  | S269500 | 1.06 | 1.06B |  |
| S269502 |  | Procurement Readiness Review - DAQ Timing System |  | 1d | 2021-06-14 | 2021-06-14 | S269500 FF, S269100 |  |  |  |  | 15d | 0d |  | SCI 4 PO [4 h]; SCI3 PO [4 h]; SCI3 Other - Unpaid [4 h]; PROF3 PO E [4 h]; PROF3 IO E [8 h] | 3,121.07 | S269500 |  | 0 | S243900 |  | S243900 | CA | Not Started | Purschke, Martin | L3 | BNL | Management Tech Reviews | Martin Purschke | BNL | DAQ Timing/Switch | null | POM02.1.06.04.02 | F | 004 | 02 |  |  |  | B | 16713 |  | S269502 | 1.06 | 1.06B |  |
| S269501 |  | Final Design Review - DAQ Timing System |  | 1d | 2021-06-15 | 2021-06-15 | S269500 |  |  |  |  | 15d | 0d |  | PROF3 IO E [8 h]; PROF3 PO E [4 h]; SCI3 PO [4 h]; SCI3 Other - Unpaid [4 h]; SCI 4 PO [4 h] | 3,121.07 | S269500 |  | 0 | S243900 |  | S243900 | CA | Not Started | Purschke, Martin | L3 | BNL | Management Tech Reviews | Martin Purschke | BNL | DAQ Timing/Switch | null | POM02.1.06.04.02 | F | 004 | 02 |  |  |  | B | 16713 |  | S269501 | 1.06 | 1.06B |  |
| S269600 |  | Update design specifications; incorporate final design choice |  | 10d | 2021-06-15 | 2021-06-28 | S269501 SS, S269502 |  |  |  |  | 15d | 0d |  | SCI3 PO [12 h]; SCI3 UCol - Unpaid [30 h] | 2,127.23 | S269600 | 180420 ELM name per MLP | 0 | S244000 |  | S244000 | CA | Not Started | Purschke, Martin | L2 | BNL | Design | Martin Purschke | BNL | DAQ Timing/Switch | null | POM02.1.06.04.02 | C |  | 02 |  |  |  | B_T | 16713 |  | S269600 | 1.06 | 1.06B |  |

Notes:
- S268300: BNL_UDF_Status Comments: 190415 ELM name per GRY / BNL_UDF_Old Activity Name 181221: Evaluate performance Requirements
- S268400: BNL_UDF_Old Activity Name 181221: Timing system Design: Write design specifications
- S268301: BNL_UDF_Status Comments: 190508 ELM add per GRY / BNL_UDF_Old Activity Name 181221: Evaluate performance Requirements
- S268500: BNL_UDF_Old Activity Name 181221: Timing System Prototype: Select FPGA Board
- S268800: BNL_UDF_Old Activity Name 181221: Timing System Prototype: develop firmware FY18
- S268600: BNL_UDF_Old Activity Name 181221: Timing System Prototype: Procure hardware Labor
- S268700: BNL_UDF_Old Activity Name 181221: Timing System Prototype: Procure hardware M&S
- S269000: Scheduler's Notes: EMenter 180329 / 260 day lag on pred in order to buy computers as late as / possible to obtain max performance / BNL_UDF_Old Activity Name 181221: Timing System Prototype: Design I/O Transition Module FY18
- S269200: BNL_UDF_Old Activity Name 181221: Timing System Prototype: setup hardware FY18
- S268900: BNL_UDF_Status Comments: 190607 IVS Martin needs timing board from Chi, find link 251200; 190323 ELM Activity split / BNL_UDF_Old Activity Name 181221: Timing System Prototype: develop firmware FY19
- S268910: BNL_UDF_Status Comments: 190607 IVS change name; 190326 ELM rsrc per GRY; 190323 ELM Activity split / BNL_UDF_Old Activity Name 181221: Timing System Prototype: develop firmware FY19
- S269300: BNL_UDF_Status Comments: 190323 ELM Activity split / BNL_UDF_Old Activity Name 181221: Timing System Prototype: setup hardware FY19
- S269310: BNL_UDF_Status Comments: 190326 ELM rsrc per GRY; 190323 ELM Activity split / BNL_UDF_Old Activity Name 181221: Timing System Prototype: setup hardware FY19
- S268905: BNL_UDF_Status Comments: 190607 IVS Martin needs timing board from Chi, find link 251200; 190323 ELM Activity split / BNL_UDF_Old Activity Name 181221: Timing System Prototype: develop firmware FY19
- S268915: BNL_UDF_Status Comments: 190607 IVS change name; 190326 ELM rsrc per GRY; 190323 ELM Activity split / BNL_UDF_Old Activity Name 181221: Timing System Prototype: develop firmware FY19
- S269100: Scheduler's Notes: EMenter 180329 / 260 day lag on pred in order to buy computers as late as / possible to obtain max performance / BNL_UDF_Status Comments: 190605 IVS is needed only late in the game / BNL_UDF_Old Activity Name 181221: Timing System Prototype: Design I/O Transition Module FY19
- S269400: BNL_UDF_Old Activity Name 181221: Timing System Prototype: test prototype
- S269500: BNL_UDF_Status Comments: 190415 ELM name per GRY / BNL_UDF_Old Activity Name 181221: Timing System Prototype: evaluate performance
- S269502: BNL_UDF_Status Comments: 190509 ELM add per GRY / BNL_UDF_Old Activity Name 181221: Timing System Prototype: evaluate performance
- S269501: BNL_UDF_Status Comments: 190509 ELM act type, rel per GRY; 190508 ELM add per GRY / BNL_UDF_Old Activity Name 181221: Timing System Prototype: evaluate performance
- S269600: BNL_UDF_Old Activity Name 181221: Update design specifications; incorporate final design choice

| ID | WBS | Activity | Type | Duration | Start | Finish | Predecessors | Complete | Remaining | Planned start | Planned finish | Total float | Free float | Expected finish | Resources | Cost | BNL_UDF_Temp Text 01 | BNL_UDF_Percent Complete | BNL_UDF_Sort Order | BNL_UDF_OPC TEC (deprecated) | BNL_UDF_Old Activity ID 181221 | BNL_Cobra WP | RG Check | BNL_Activity Status | BNL_Fund Source | BNL_Estimator | BNL_Cost Basis | BNL_Location | BNL_EDIA | BNL_CAM | BNL_Institution | BNL_OPC TEC (deprecated) | BNL_WBS | BNL_EVT | BNL_Master Control Account | BNL_Account Number | BNL_PCR ID | BNL_Cobra Control Account | BNL_WBS_Hierarchical | Additional EVT documentation required | BNL_Proc Sig Phase | BNL_Proc Sig | BNL_Milestone Level | BNL_Obligation | Indicator - Procurement | Indicator - Float | SPH Proc Register | BNL_UDF_Adhoc Comments | BNL_UDF_Remaining Tot Cost | BNL_UDF_Percent_remaining | BNL_Actuals | BNL_FY | Completed | BNL_R&D FY18-19 | Cost = Awarded Proc or Mgmt | BNL_UDF_Temp Date 01 | BNL_UDF_Exclude | BNL_DOE OPC | Temp | Target Milestone Date | Variance | PMP Milestones |
| --- | --- | --- | --- | --- | --- | --- | --- | --- | --- | --- | --- | --- | --- | --- | --- | --- | --- | --- | --- | --- | --- | --- | --- | --- | --- | --- | --- | --- | --- | --- | --- | --- | --- | --- | --- | --- | --- | --- | --- | --- | --- | --- | --- | --- | --- | --- | --- | --- | --- | --- | --- | --- | --- | --- | --- | --- | --- | --- | --- | --- | --- | --- |
|  | 03 | **Timing System Production** |  |  | 2021-03-15 | 2022-01-13 |  |  |  |  |  |  |  |  |  |  |  |  |  |  |  |  |  |  |  |  |  |  |  |  |  |  |  |  |  |  |  |  |  |  |  |  |  |  |  |  |  |  |  |  |  |  |  |  |  |  |  |  |  |  |  |  |
| S270500 |  | Timing System Production: final firmware updates |  | 80d | 2021-03-15 A | 2021-07-30 | S269600 | 60% | 23d | 2021-05-07 | 2021-08-30 | 47d | 0d | 2021-07-30 | SCI3 PO [64 h]; SCI3 UCol - Unpaid [64 h]; PROF3 PO E [560 h] | 84,315.91 | S270500 | 0 | 2000 | S244900 | S244900 | S270500 | CA | Not Started | B_T | Purschke, Martin | L4 | BNL | Programming | Martin Purschke | BNL | null | POM02.1.06.04.03 | C | 1.06 | 16713 | 003 | 1.06B | 03 | Yes |  |  |  |  |  |  |  |  |  |  |  |  |  |  |  |  |  |  |  |  |  |  |
| S270510 |  | Timing System Production: final firmware updates IO |  | 80d | 2021-03-15 A | 2021-07-30 | S269600 | 60% | 23d | 2021-05-07 | 2021-08-30 | 47d | 0d | 2021-07-30 | PROF3 IO E [322 h] | 41,958.15 | S270500 | 0 | 2000 | S244900 | S244900 | S270510 | CA | Not Started | B | Purschke, Martin | L4 | BNL | Programming | Martin Purschke | BNL | null | POM02.1.06.04.03 | C | 1.06 | 16713 | 003 | 1.06B | 03 | Yes |  |  |  |  |  |  |  |  |  |  |  |  |  |  |  |  |  |  |  |  |  |  |
| S269700 |  | Timing System Production (FPGA Boards) - Provide Requirements to Procurement |  | 5d | 2021-04-01 A | 2021-04-07 A | S269600 | 100% |  | 2021-06-01 | 2021-06-07 |  |  |  | PROF3 PO E [40 h]; SCI3 PO [80 h]; SCI3 UCol - Unpaid [40 h] | 19,393.7 | S269700 | 0 |  | S244100 | S244100 | S269700 | CA | Not Started | B_T | Purschke, Martin | L2 | BNL | Procurement | Martin Purschke | BNL | null | POM02.1.06.04.03 | C | 1.06 | 16713 |  | 1.06B | 03 |  | PP1 | MP107800 |  |  |  |  |  |  |  |  |  |  |  |  |  |  |  |  |  |  |  |  |
| S269800 |  | Timing System Production (FPGA Boards) - Prepare & Send Solicitation |  | 5d | 2021-04-08 A | 2021-04-14 A | S269700 | 100% |  | 2021-06-08 | 2021-06-14 |  |  |  |  |  | S269800 | 0 |  | S244200 | S244200 |  | NOCA | Not Started |  | Purschke, Martin |  | BNL | Procurement | Martin Purschke | BNL |  | POM02.1.06.04.03 |  |  |  |  |  | 03 |  | PP2 | MP107800 |  |  |  |  |  |  |  |  |  |  |  |  |  |  |  |  |  |  |  |  |
| S269900 |  | Timing System Production (FPGA Boards) - Vendor Responses |  | 5d | 2021-04-15 A | 2021-04-21 A | S269800 | 100% |  | 2021-06-15 | 2021-06-21 |  |  |  |  |  | S269900 | 0 |  | S244300 | S244300 |  | NOCA | Not Started |  | Purschke, Martin |  | BNL | Procurement | Martin Purschke | BNL |  | POM02.1.06.04.03 |  |  |  |  |  | 03 |  | PP3 | MP107800 |  |  |  |  |  |  |  |  |  |  |  |  |  |  |  |  |  |  |  |  |
| S270000 |  | Timing System Production (FPGA Boards) - Vendor Selection |  | 5d | 2021-04-22 A | 2021-04-28 A | S269900 | 100% |  | 2021-06-22 | 2021-06-28 |  |  |  |  |  | S270000 | 0 |  | S244400 | S244400 |  | NOCA | Not Started |  | Purschke, Martin |  | BNL | Procurement | Martin Purschke | BNL |  | POM02.1.06.04.03 |  |  |  |  |  | 03 |  | PP4 | MP107800 |  |  |  |  |  |  |  |  |  |  |  |  |  |  |  |  |  |  |  |  |
| OBLG270110 |  | Timing System Production (FPGA Boards) - Obligation |  | 1d | 2021-06-29 | 2021-06-29 | S270000, S101000 |  |  |  |  | 15d | 0d |  | Obligation Resource [47337.7 h] | 47,337.71 | S270100 | 0 | 1000 | S244500 | S244500 |  |  | Not Started | A-TEC | Purschke, Martin |  | BNL | Procurement | Martin Purschke | BNL |  | POM02.1.06.04.03 |  |  |  | 003 |  | 03 |  | PP5 | MP107800 | L5 | OBLG |  |  |  |  |  |  |  |  |  |  |  |  |  |  |  |  |  |  |
| S270100 |  | Timing System Production (FPGA Boards) - Contract Award(s) | milestone | 0d | 2021-06-29 | 2021-06-29 | S270000, S101000 |  |  |  |  | 15d | 0d |  |  |  | S270100 | 0 |  | S244500 | S244500 |  | NOCA | Not Started | A-TEC | Purschke, Martin |  | BNL | Procurement | Martin Purschke | BNL |  | POM02.1.06.04.03 |  |  |  |  |  | 03 |  | PP5 | MP107800 | L5 |  | UDF_G1 | UDF_G1 | Contract Award |  |  |  |  |  |  |  |  |  |  |  |  |  |  |  |
| S270200 |  | Timing System Production (FPGA Boards) - Contract/PO) - Leadtime |  | 50d | 2021-06-29 | 2021-09-08 | S270100 SS, OBLG270110 SS |  |  |  |  | 15d | 0d |  |  |  | S270200 | 0 |  | S244600 | S244600 |  | NOCA | Not Started |  | Purschke, Martin |  | BNL | Fab & Assy | Martin Purschke | BNL |  | POM02.1.06.04.03 |  |  |  |  |  | 03 |  | PP6 | MP107800 |  |  |  |  |  |  |  |  |  |  |  |  |  |  |  |  |  |  |  |  |
| S270300 |  | Timing System Production (FPGA Boards) - Delivery Acceptance |  | 5d | 2021-09-09 | 2021-09-15 | S270200 |  |  |  |  | 15d | 0d |  | Material (Purchase (1st $2M) [41600 h] | 48,284.47 | S270300 | 0 |  | S244700 | S244700 | S270300 | CA | Not Started | A-TEC | Purschke, Martin | M4 | BNL | Fab & Assy | Martin Purschke | BNL | TEC | POM02.1.06.04.03 | C | 1.06 | 59721 | 015 | 1.06A | 03 |  | PP6 | MP107800 |  | FAB | UDF_G1 | UDF_G1 | Delivery | 180410 ELM pred/succ per GRY | 48284.467296 | 1 |  |  |  |  |  |  |  |  |  |  |  |  |
| S270600 |  | Timing System Production: install timing system |  | 30d | 2021-09-16 | 2021-10-28 | S270500, S270300, S270510 |  |  |  |  | 15d | 0d |  | PROF3 PO E [80 h]; SCI3 PO [40 h]; TECH3 PO E [320 h] | 56,177.26 | S270600 | 0 |  | S245100 | S245100 | S270600 | CA | Not Started | B | Purschke, Martin | L4 | BNL | Fab & Assy | Martin Purschke | BNL | null | POM02.1.06.04.03 | C | 1.06 | 16713 | 003 | 1.06B | 03 |  |  |  |  |  |  |  |  | 180410 ELM pred/succ per GRY |  |  |  |  |  |  |  |  |  |  |  |  |  |  |
| S270610 |  | Timing System Production: install timing system |  | 30d | 2021-09-16 | 2021-10-28 | S270500, S270300, S270510 |  |  |  |  | 15d | 0d |  | PROF3 IO E [160 h] | 21,244.9 | S270600 | 0 |  | S245100 | S245100 | S270610 | CA | Not Started | B | Purschke, Martin | L4 | BNL | Fab & Assy | Martin Purschke | BNL | null | POM02.1.06.04.03 | C | 1.06 | 16713 | 003 | 1.06B | 03 |  |  |  |  |  |  |  |  | 180410 ELM pred/succ per GRY |  |  |  |  |  |  |  |  |  |  |  |  |  |  |
| S270700 |  | Timing System Production: commission timing system |  | 25d | 2021-10-29 | 2021-12-07 | S270600, S270610 |  |  |  |  | 15d | 0d |  | SCI3 PO [128 h]; SCI3 UCol - Unpaid [192 h]; PROF3 PO E [320 h] | 66,319.59 | S270700 | 0 |  | S245200 | S245200 | S270700 | CA | Not Started | B_T | Purschke, Martin | L3 | BNL | Fab & Assy | Martin Purschke | BNL | null | POM02.1.06.04.03 | C | 1.06 | 16713 | 003 | 1.06B | 03 | Yes |  |  |  |  |  |  |  |  |  |  |  |  |  |  |  |  |  |  |  |  |  |  |
| S270710 |  | Timing System Production: commission timing system |  | 25d | 2021-10-29 | 2021-12-07 | S270600, S270610 |  |  |  |  | 15d | 0d |  | PROF3 IO E [192 h] | 25,769.08 | S270700 | 0 |  | S245200 | S245200 | S270710 | CA | Not Started | B | Purschke, Martin | L3 | BNL | Fab & Assy | Martin Purschke | BNL | null | POM02.1.06.04.03 | C | 1.06 | 16713 | 003 | 1.06B | 03 | Yes |  |  |  |  |  |  |  |  |  |  |  |  |  |  |  |  |  |  |  |  |  |  |
| S270800 |  | Timing System Production: additional firmware updates |  | 25d | 2021-12-08 | 2022-01-13 | S270700, S270710 |  |  |  |  | 15d | 0d |  | PROF3 PO E [144 h] | 19,326.81 | S270800 | 0 |  | S245200 | S245250 | S270800 | CA | Not Started | B_T | Purschke, Martin | L3 | BNL | Fab & Assy | Martin Purschke | BNL | null | POM02.1.06.04.03 | C | 1.06 | 16713 |  | 1.06B | 03 |  |  |  |  |  |  |  |  |  |  |  |  |  |  |  |  |  |  |  |  |  |  |  |
| S270900 |  | Timing System Production: Timing system ready to operate | milestone | 0d | 2022-01-13 | 2022-01-13 | S270800 |  |  |  |  | 15d |  |  |  |  | S270900 | 0 |  | S245300 | S245300 |  | NOCA | Not Started |  | Purschke, Martin |  | BNL | Fab & Assy | Martin Purschke | BNL |  | POM02.1.06.04.03 |  |  |  |  |  | 03 |  |  |  | L3 |  | UDF_G1 | UDF_G1 |  |  |  |  |  |  |  |  |  |  |  |  |  |  |  |  |
|  | 07 | **Min Bias Trigger Detector** |  |  | 2017-02-01 | 2021-12-21 |  |  |  |  |  |  |  |  |  |  |  |  |  |  |  |  |  |  |  |  |  |  |  |  |  |  |  |  |  |  |  |  |  |  |  |  |  |  |  |  |  |  |  |  |  |  |  |  |  |  |  |  |  |  |  |  |
| S271000 |  | Actuals - Labor - sPHENIX MinBias Trigger FY17 |  | 169d | 2017-02-01 A | 2017-09-29 A | S100090 SS | 100% |  |  |  |  |  |  | Actual Labor [204.78 h] | 34,217.28 | S271000 | 100 |  |  | S338580 | S271000 | CA | Completed | B | Chiu, Mickey | L1 | BNL | Design | Mickey Chiu | BNL | null | POM02.1.07 | A | 1.07 | 16714 | 003 | 1.07B | 07 |  |  |  |  |  |  |  |  |  |  |  | Yes | 2017 | yes |  |  |  |  |  |  |  |  |  |
| S271200 |  | Actuals - Nonlabor - sPHENIX MinBias Trigger FY17 |  | 169d | 2017-02-01 A | 2017-09-29 A | S100090 SS | 100% |  |  |  |  |  |  |  |  | S271200 | 100 |  |  | S342660 |  | NOCA | Completed | A-OPC | Chiu, Mickey | M1 | BNL | Design | Mickey Chiu | BNL | OPC | POM02.1.07 | A |  | 16706 | 003 |  | 07 |  |  |  |  |  |  |  |  |  |  |  | Yes | 2017 | yes |  |  |  |  |  |  |  |  |  |
| S271400 |  | MBD Detector validation using Laser Labor |  | 189d | 2017-03-02 A | 2017-11-30 A | S100090 SS+20d | 100% |  |  |  |  |  |  |  |  | S271400 | 100 |  | S245400 | S245400 |  | NOCA | Completed |  | Chiu, Mickey |  | BNL | Test_Components | Mickey Chiu | BNL |  | POM02.1.07 |  |  |  |  |  | 07 |  |  |  |  |  |  |  |  |  |  |  |  |  | yes | MinBias mag. test |  |  |  |  |  |  |  |  |
| S271500 |  | MBD Detector validation using Laser M&S |  | 189d | 2017-03-02 A | 2017-11-30 A | S100090 SS+20d | 100% |  |  |  |  |  |  |  |  | S271500 | 100 |  | S245500 | S245500 |  | NOCA | Completed |  | Chiu, Mickey |  | BNL | Test_Components | Mickey Chiu | BNL |  | POM02.1.07 |  |  |  |  |  | 07 |  |  |  |  |  |  |  |  |  |  |  |  |  | yes | MinBias mag. test |  |  |  |  |  |  |  |  |
| S271800 |  | Readout validation of sPHENIX Prototype Digitizers |  | 190d | 2017-03-02 A | 2017-12-01 A | S100090 SS+20d | 100% |  |  |  |  |  |  |  |  | S271800 | 100 |  | S245800 | S245800 |  | NOCA | Completed |  | Chiu, Mickey |  | BNL | Test_Components | Mickey Chiu | BNL |  | POM02.1.07 |  |  |  |  |  | 07 |  |  |  |  |  |  |  |  |  |  |  |  |  | yes | MinBias readout tests |  |  |  |  |  |  |  |  |
| S271100 |  | Actuals - Labor - sPHENIX MinBias Trigger FY18 |  | 249d | 2017-10-01 A | 2018-09-28 A | S271000, S271200 | 100% |  | 2017-10-02 | 2018-09-28 |  |  |  | Actual Labor [489.19 h] | 81,740.17 | S271100 | 100 |  |  | S339300 | S271100 | CA | Completed | B | Chiu, Mickey | L1 | BNL | Design | Mickey Chiu | BNL | null | POM02.1.07 | A | 1.07 | 16714 | 003 | 1.07B | 07 |  |  |  |  |  |  |  |  |  |  |  | Yes | 2018 | yes |  |  |  |  |  |  |  |  |  |
| S271300 |  | Actuals - Nonlabor - sPHENIX MinBias Trigger FY18 |  | 249d | 2017-10-01 A | 2018-09-28 A | S271000, S271200 | 100% |  | 2017-10-02 | 2018-09-28 |  |  |  | Actual Nonlabor [370.8 h] | 413.67 | S271300 | 100 |  |  | S342700 | S271300 | CA | Completed | A-OPC | Chiu, Mickey | M1 | BNL | Design | Mickey Chiu | BNL | OPC | POM02.1.07 | A | 1.07 | 16706 | 003 | 1.07A | 07 |  |  |  |  |  | UDF_G3 |  |  |  |  |  | Yes | 2018 | yes |  |  |  |  |  |  |  |  |  |
| S271600 |  | MBD Detector validation in Magnetic Field Labor |  | 8d | 2017-12-01 A | 2017-12-12 A | S271400 | 100% |  |  |  |  |  |  |  |  | S271600 | 100 |  | S245600 | S245600 |  | NOCA | Completed |  | Chiu, Mickey |  | BNL | Test_Components | Mickey Chiu | BNL |  | POM02.1.07 |  |  |  |  |  | 07 |  |  |  |  |  |  |  |  |  |  |  |  |  | yes | MinBias mag. test |  |  |  |  |  |  |  |  |
| S271700 |  | MBD Detector validation in Magnetic Field M&S |  | 8d | 2017-12-01 A | 2017-12-12 A | S271500 | 100% |  |  |  |  |  |  |  |  | S271700 | 100 |  | S245700 | S245700 |  | NOCA | Completed |  | Chiu, Mickey |  | BNL | Test_Components | Mickey Chiu | BNL |  | POM02.1.07 |  |  |  |  |  | 07 |  |  |  |  |  |  |  |  |  |  |  |  |  | yes | MinBias mag. test |  |  |  |  |  |  |  |  |
| S271900 |  | Preliminary Design Review - MBD (Discriminator/Shaper board) |  | 12d | 2017-12-04 A | 2017-12-19 A | S271800 | 100% |  |  |  |  |  |  |  |  | S271900 | 100 |  | S245900 | S245900 |  | NOCA | Completed |  | Chiu, Mickey |  | BNL | Design | Mickey Chiu | BNL |  | POM02.1.07 |  |  |  | 004 |  | 07 |  |  |  |  |  |  |  |  |  |  |  |  |  | yes | MinBias readout tests |  |  |  |  |  |  |  |  |
| S271901 |  | Develop Scope and Documentation for Shaper/Disc Boards, Preliminary Design Review | milestone | 0d | 2017-12-19 A | 2017-12-19 A | S271900 FF | 100% |  |  |  |  |  |  |  |  | S271900 | 100 |  | S245900 | S245900 |  | NOCA | Completed |  | Chiu, Mickey |  | BNL | Design | Mickey Chiu | BNL |  | POM02.1.07 |  |  |  | 004 |  | 07 |  |  |  |  |  |  |  |  |  |  |  |  |  | yes | MinBias readout tests |  |  |  |  |  |  |  |  |
| S272000 |  | Procure Prototype Shaper/Disc Electronics - Provide Requirements to Procurement |  | 55d | 2018-02-13 A | 2018-05-01 A | S100340 | 100% |  |  |  |  |  |  |  |  | S272000 | 100 |  | S246100 | S246100 |  | NOCA | Completed |  | Chiu, Mickey | L2 | BNL | Procurement | Mickey Chiu | BNL | null | POM02.1.07 | C |  |  |  |  | 07 |  | PP1 | MP107900 |  |  |  |  |  | 180406 ELM rsrc per GRY |  |  |  |  | yes |  | Yes |  |  |  |  |  |  |  |
| S272100 |  | Procure Prototype Shaper/Disc Electronics - Prepare & Send Solicitation |  | 21d | 2018-05-02 A | 2018-05-31 A | S272000 | 100% |  |  |  |  |  |  |  |  | S272100 | 100 |  | S246200 | S246200 |  | NOCA | Completed |  | Chiu, Mickey |  | BNL | Procurement | Mickey Chiu | BNL |  | POM02.1.07 |  |  |  |  |  | 07 |  | PP2 | MP107900 |  |  |  |  |  |  |  |  |  |  | yes |  | Yes |  |  |  |  |  |  |  |
| S272200 |  | Procure Prototype Shaper/Disc Electronics - Vendor Responses |  | 64d | 2018-06-15 A | 2018-09-14 A | S272100 | 100% |  |  |  |  |  |  |  |  | S272200 | 100 |  | S246300 | S246300 |  | NOCA | Completed |  | Chiu, Mickey |  | BNL | Procurement | Mickey Chiu | BNL |  | POM02.1.07 |  |  |  |  |  | 07 |  | PP3 | MP107900 |  |  |  |  |  |  |  |  |  |  | yes |  | Yes | 2018-07-15 |  |  |  |  |  |  |
| S272300 |  | Procure Prototype Shaper/Disc Electronics - Vendor Selection |  | 53d | 2018-07-16 A | 2018-09-27 A | S272200 | 100% |  |  |  |  |  |  |  |  | S272300 | 100 |  | S246400 | S246400 |  | NOCA | Completed |  | Chiu, Mickey |  | BNL | Procurement | Mickey Chiu | BNL |  | POM02.1.07 |  |  |  |  |  | 07 |  | PP4 | MP107900 |  |  |  |  |  |  |  |  |  |  | yes |  | Yes |  |  |  |  |  |  |  |
| OBLG272410 |  | Procure Prototype Shaper/Disc Electronics - Obligation |  | 1d | 2018-09-28 A | 2018-09-28 A | S272300 | 100% |  |  |  |  |  |  | Obligation Resource |  | S272400 | 100 |  | S246500 | S246500 |  | NOCA | Completed | A-OPC | Chiu, Mickey |  | BNL | Procurement | Mickey Chiu | BNL |  | POM02.1.07 |  |  |  |  |  | 07 |  | PP5 | MP107900 | L5 |  |  |  |  |  |  |  |  |  | yes |  | Yes |  |  |  |  |  |  |  |
| S272400 |  | Procure Prototype Shaper/Disc Electronics - Contract Award(s) | milestone | 0d | 2018-09-28 A | 2018-09-28 A | S272300 | 100% |  |  |  |  |  |  |  |  | S272400 | 100 |  | S246500 | S246500 |  | NOCA | Completed | A-OPC | Chiu, Mickey |  | BNL | Procurement | Mickey Chiu | BNL |  | POM02.1.07 |  |  |  |  |  | 07 |  | PP5 | MP107900 | L5 |  |  |  | Contract Award |  |  |  |  |  | yes |  | Yes |  |  |  |  |  |  |  |
| S1000999 |  | Actuals - Labor - sPHENIX MinBias Trigger FY19 M8 |  | 166d | 2018-10-01 A | 2019-05-31 A |  | 100% |  |  |  |  |  |  | Actual Labor [302.17 h] | 50,490.46 | S271100 | 100 |  |  | S339300 | S1000999 | CA | Completed | B | Chiu, Mickey | L1 | BNL | Design | Mickey Chiu | BNL | null | POM02.1.07 | A | 1.07 | 16714 | 003 | 1.07B | 07 |  |  |  |  |  |  |  |  |  |  |  | Yes | 2019 | yes |  |  |  |  |  |  |  |  |  |
| S1001039 |  | Actuals - Nonlabor - sPHENIX MinBias Trigger FY19 M8 |  | 166d | 2018-10-01 A | 2019-05-31 A |  | 100% |  |  |  |  |  |  | Actual Nonlabor [19492.4 h] | 21,505.33 | S271300 | 100 |  |  | S342700 | S1001039 | CA | Completed | A-OPC | Chiu, Mickey | M1 | BNL | Design | Mickey Chiu | BNL | OPC | POM02.1.07 | A | 1.07 | 16706 | 003 | 1.07A | 07 |  |  |  |  |  | UDF_G3 |  |  |  |  |  | Yes | 2019 | yes |  |  |  |  |  |  |  |  |  |
| S272500 |  | Procure Prototype Shaper/Disc Electronics - Contract/PO - Leadtime |  | 186d | 2018-10-01 A | 2019-06-28 A | S272400 SS, OBLG272410 SS | 100% |  |  |  |  |  |  |  |  | S272500 | 100 |  | S246600 | S246600 |  | NOCA | Completed |  | Chiu, Mickey |  | BNL | Fab & Assy | Mickey Chiu | BNL |  | POM02.1.07 |  |  |  |  |  | 07 |  | PP6 | MP107900 |  |  |  |  |  |  |  |  |  |  |  |  | Yes | 2019-04-23 | MP6LA |  |  |  |  |  |
| S272600 |  | Procure Prototype Shaper/Disc Electronics - Delivery Acceptance |  | 25d | 2019-06-03 A | 2019-07-08 A | S272500 | 100% |  |  |  |  |  |  | Material (Purchase (1st $2M) [70000 h] | 77,228.55 | S272600 | 43 |  | S246700 | S246700 | S272600 | CA | Completed | A-OPC | Chiu, Mickey | M5 | BNL | Fab & Assy | Mickey Chiu | BNL | OPC | POM02.1.07 | C | 1.07 | 16706 |  | 1.07A | 07 |  | PP6 | MP107900 |  |  | UDF_G3 |  | Delivery |  |  |  |  |  |  | MinBias readout tests | Yes |  | MP6LA | OPC002600 |  |  |  |  |
| S272700 |  | Prototype Shaper/Disc Board Testing and evaluation, revisions; Final Design and Procurment Readiness Reviews_50% |  | 59d | 2019-07-09 A | 2021-02-25 A | S272600, S271901 | 100% |  | 2019-07-09 | 2019-09-30 |  |  |  | PROF3 PO E [72 h]; SCI3 PO [72 h]; STUDENT Other - Unpaid [72 h] | 20,874.07 | S272700 | 0 |  | S246800 | S246800 | S272700 | CA | In Progress | B_T | Chiu, Mickey | L4 | BNL | Test_System | Mickey Chiu | BNL | null | POM02.1.07 | C | 1.07 | 16714 | 003,004 | 1.07B | 07 |  |  |  |  |  |  |  |  | 180420 name per MChiu; 180406 ELM rsrc per GRY |  |  |  |  |  | MinBias readout tests |  |  |  |  | 1 |  |  |  |
| S272701 |  | Final Design Review, Procurement Readiness Review - MBD (Discriminator/Shaper board) |  | 1d | 2021-02-25 A | 2021-02-26 A | S272700 | 100% |  | 2021-03-16 | 2021-03-16 |  |  |  | SCI3 PO [8 h]; SCI3 Other - Unpaid [8 h]; SCI 4 PO [4 h]; PROF3 PO E [8 h] | 3,308.93 | S272700 | 0 |  | S246800 | S246800 | S272701 | CA | Not Started | B_T | Chiu, Mickey | L4 | BNL | Management Tech Reviews | Mickey Chiu | BNL | null | POM02.1.07 | F | 1.07 | 16714 | 003,004 | 1.07B | 07 |  |  |  |  |  |  |  |  | 180420 name per MChiu; 180406 ELM rsrc per GRY |  |  |  |  |  | MinBias readout tests |  |  |  |  |  |  |  |  |
| S272800 |  | Procure Min/Bias Electronics - Provide Requirements to Procurement |  | 5d | 2021-02-25 A | 2021-02-26 A | S272701 | 100% |  | 2021-03-17 | 2021-03-23 |  |  |  | SCI3 PO [112 h] | 19,854.11 | S272800 | 0 |  | S246900 | S246900 | S272800 | CA | Not Started | B | Chiu, Mickey | L3 | BNL | Procurement | Mickey Chiu | BNL | null | POM02.1.07 | C | 1.07 | 16714 | 003 | 1.07B | 07 |  | PP1 | MP108000 |  |  |  |  |  |  |  |  |  |  |  |  |  |  |  |  |  |  |  |  |
| S272900 |  | Procure Min/Bias Electronics - Prepare & Send Solicitation |  | 20d | 2021-02-25 A | 2021-02-26 A | S272800 | 100% |  | 2021-03-24 | 2021-04-20 |  |  |  |  |  | S272900 | 0 |  | S247000 | S247000 |  | NOCA | Not Started |  | Chiu, Mickey |  | BNL | Procurement | Mickey Chiu | BNL |  | POM02.1.07 |  |  |  |  |  | 07 |  | PP2 | MP108000 |  |  |  |  |  |  |  |  |  |  |  |  |  |  |  |  |  |  |  |  |
| S273000 |  | Procure Min/Bias Electronics - Vendor Responses |  | 5d | 2021-02-25 A | 2021-02-26 A | S272900 | 100% |  | 2021-04-21 | 2021-04-27 |  |  |  |  |  | S273000 | 0 |  | S247100 | S247100 |  | NOCA | Not Started |  | Chiu, Mickey |  | BNL | Procurement | Mickey Chiu | BNL |  | POM02.1.07 |  |  |  |  |  | 07 |  | PP3 | MP108000 |  |  |  |  |  |  |  |  |  |  |  |  |  |  |  |  |  |  |  |  |
| S273100 |  | Procure Min/Bias Electronics - Vendor Selection |  | 5d | 2021-02-25 A | 2021-02-26 A | S273000 | 100% |  | 2021-03-01 | 2021-03-05 |  |  |  |  |  | S273100 | 0 |  | S247200 | S247200 |  | NOCA | Not Started |  | Chiu, Mickey |  | BNL | Procurement | Mickey Chiu | BNL |  | POM02.1.07 |  |  |  |  |  | 07 |  | PP4 | MP108000 |  |  |  |  |  |  |  |  |  |  |  |  |  |  |  |  |  |  |  |  |
| S273200 |  | Procure Min/Bias Electronics - sPHENIX Production Digitizers - Contract Award(s) | milestone | 0d | 2021-02-26 A | 2021-02-26 A | S273100, S101000, S101010 | 100% |  | 2021-03-08 | 2021-03-08 |  |  |  |  |  | S273200 | 0 |  | S247300 | S247300 |  | NOCA | Not Started | A-TEC | Chiu, Mickey |  | BNL | Procurement | Mickey Chiu | BNL |  | POM02.1.07 |  |  |  |  |  | 07 |  | PP5 | MP108000 | L5 |  | UDF_G1 | UDF_G1 | Contract Award |  |  |  |  |  |  |  |  |  |  |  |  |  |  |  |
| OBLG273210 |  | Procure Min/Bias Electronics (sPHENIX Production Digitizers) - Obligation |  | 1d | 2021-03-08 A | 2021-03-08 A | S273100, S101000, S101010 | 100% |  |  |  |  |  |  | Obligation Resource [17143.3 h] | 17,143.31 | S273200 | 0 |  | S247300 | S247300 |  |  | Not Started | A-TEC | Chiu, Mickey |  | BNL | Procurement | Mickey Chiu | BNL |  | POM02.1.07 |  |  |  |  |  | 07 |  | PP5 | MP108000 | L5 | OBLG |  |  |  |  |  |  |  |  |  |  |  |  |  |  |  |  |  |  |
| OBLG273310 |  | Procure MBD Shaper/Disc Board 128 Channels - Obligation |  | 1d | 2021-03-08 A | 2021-03-08 A | S273100, S101000, S101010 | 100% |  |  |  |  |  |  | Obligation Resource [53879 h] | 53,878.97 | S273300 | 0 |  | S247300 | S247350 |  |  | Not Started | A-TEC | Chiu, Mickey |  | BNL | Procurement | Mickey Chiu | BNL |  | POM02.1.07 |  |  |  |  |  | 07 |  | PP5 | MP108010 | L5 | OBLG |  |  |  |  |  |  |  |  |  |  |  |  |  |  |  |  |  |  |
| S273300 |  | Procure Shaper/Disc Board 128 Channels - Contract Award(s) | milestone | 0d | 2021-04-01 A | 2021-04-01 A | S273100, S101000, S101010 | 100% |  |  |  |  |  |  |  |  | S273300 | 0 |  | S247300 | S247350 |  | NOCA | Not Started | A-TEC | Chiu, Mickey |  | BNL | Procurement | Mickey Chiu | BNL |  | POM02.1.07 |  |  |  |  |  | 07 |  | PP5 | MP108010 | L5 |  | UDF_G1 | UDF_G1 |  |  |  |  |  |  |  |  |  |  |  |  |  |  |  |  |
| S273400 |  | Procure Min/Bias Electronics - Contract/PO - Leadtime |  | 105d | 2021-06-01 | 2021-10-28 | S273200 SS, S273300 SS, OBLG273210 SS, OBLG273310 SS |  |  |  |  | 30d | 0d |  |  |  | S273400 | 0 |  | S247400 | S247400 |  | NOCA | Not Started |  | Chiu, Mickey |  | BNL | Fab & Assy | Mickey Chiu | BNL |  | POM02.1.07 |  |  |  |  |  | 07 |  | PP6 | MP108000 |  |  |  |  |  |  |  |  |  |  |  |  |  |  |  |  |  |  |  |  |
| S273700 |  | Oversight of sPHENIX MBD Digitizers Procurement |  | 105d | 2021-06-01 | 2021-10-28 | S272800 SS |  |  |  |  | 35d | 5d |  | SCI3 PO [16 h] | 2,851.7 | S273700 | 0 |  | S247500 | S247500 | S273700 | CA | Not Started | B | Chiu, Mickey | L3 | BNL | Procurement | Mickey Chiu | BNL | null | POM02.1.07 | A | 1.07 | 16714 | 003 | 1.07B | 07 | Yes |  |  |  |  |  |  |  |  |  |  |  |  |  |  |  |  |  |  |  |  |  |  |
| S273500 |  | Procure Min/Bias Electronics (sPHENIX Production Digitizers) - Delivery Acceptance |  | 5d | 2021-10-29 | 2021-11-04 | S273400, S273700 FF |  |  |  |  | 30d | 0d |  | Material (Purchase (1st $2M) [14770 h] | 17,486.17 | S273500 | 0 |  | S247600 | S247450 | S273500 | CA | Not Started | A-TEC | Chiu, Mickey | M5 | BNL | Fab & Assy | Mickey Chiu | BNL | TEC | POM02.1.07 | E | 1.07 | 59722 | 015 | 1.07A | 07 |  | PP6 | MP108000 |  | FAB | UDF_G1 | UDF_G1 | Delivery |  | 17143.307259 | 1 |  |  |  |  |  |  |  |  |  |  |  |  |
| S273600 |  | Procure MBD Shaper/Disc Board 128 Channels - Delivery Acceptance |  | 5d | 2021-10-29 | 2021-11-04 | S273400, S273700 FF, S272701 |  |  |  |  | 30d | 0d |  | Material (Purchase (1st $2M) [46420 h] | 54,956.54 | S273600 | 0 |  | S247800 | S247460 | S273600 | CA | Not Started | A-TEC | Chiu, Mickey | M5 | BNL | Fab & Assy | Mickey Chiu | BNL | TEC | POM02.1.07 | C | 1.07 | 59722 | 015 | 1.07A | 07 |  | PP6 | MP108010 |  | FAB | UDF_G1 | UDF_G1 |  |  | 53878.96567 | 1 |  |  |  |  |  |  |  |  |  |  |  |  |
| S273800 |  | Test Full Min/Bias Electronics |  | 25d | 2021-11-05 | 2021-12-14 | S273500, S273600 |  |  |  |  | 30d | 0d |  | PROF3 PO M [16 h]; SCI3 PO [48 h]; STUDENT Other - Unpaid [48 h] | 10,911.6 | S273800 | 0 |  | S247700 | S247700 | S273800 | CA | Not Started | B_T | Chiu, Mickey | L4 | BNL | Test_Components | Mickey Chiu | BNL | null | POM02.1.07 | C | 1.07 | 16714 | 003 | 1.07B | 07 | Yes |  |  |  |  |  |  |  |  |  |  |  |  |  |  |  |  |  |  |  |  |  |  |
| S273900 |  | MBD Production Complete | milestone | 0d | 2021-12-14 | 2021-12-14 | S273800 FF |  |  |  |  | 30d | 0d |  |  |  | S273900 | 0 |  | S247700 | S247750 |  | NOCA | Not Started |  | Chiu, Mickey | L4 | BNL | Test_Components | Mickey Chiu | BNL | null | POM02.1.07 |  |  |  |  |  | 07 |  |  |  | L2 |  | UDF_G1 | UDF_G1 |  |  |  |  |  |  |  |  |  |  |  |  |  |  |  |  |
| S274000 |  | Bench Test Min/Bias Detector |  | 5d | 2021-12-15 | 2021-12-21 | S271600, S271700, S273900 |  |  |  |  | 30d | 0d |  | SCI3 PO [80 h]; STUDENT Other - Unpaid [80 h] | 14,606.95 | S274000 | 0 |  | S247900 | S247900 | S274000 | CA | Not Started | B_T | Chiu, Mickey | L3 | BNL | Test_System | Mickey Chiu | BNL | null | POM02.1.07 | C | 1.07 | 16714 | 003 | 1.07B | 07 |  |  |  |  |  |  |  |  |  |  |  |  |  |  |  |  |  |  |  |  |  |  |  |
| S274100 |  | MinBias Detector Ready to Install | milestone | 0d | 2021-12-21 | 2021-12-21 | S274000 |  |  |  |  | 30d | 0d |  |  |  | S274100 | 0 |  | S248000 | S248000 |  | NOCA | Not Started |  | Chiu, Mickey |  | BNL | Test_System | Mickey Chiu | BNL |  | POM02.1.07 |  |  |  |  |  | 07 |  |  |  | L2 |  | UDF_G1 | UDF_G1 |  |  |  |  |  |  |  |  |  |  |  |  |  | 2021-12-14 | -6 | PMP_1x |

Notes:
- S270500: BNL_UDF_Status Comments: 190323 ELM Activity split / BNL_UDF_Old Activity Name 181221: Timing System Production: final firmware updates
- S270510: BNL_UDF_Status Comments: 190326 ELM rsrc per GRY; 190323 ELM Activity split / BNL_UDF_Old Activity Name 181221: Timing System Production: final firmware updates
- S269700: BNL_UDF_Old Activity Name 181221: Procure Production Timing Sys Components - Provide Requirements to Procurement
- S269800: BNL_UDF_Old Activity Name 181221: Procure Production Timing Sys Components - Prepare & Send Solicitation
- S269900: BNL_UDF_Old Activity Name 181221: Procure Production Timing Sys Components - Vendor Responses
- S270000: BNL_UDF_Old Activity Name 181221: Procure Production Timing Sys Components - Vendor Selection
- OBLG270110: BNL_UDF_Old Activity Name 181221: Procure Production Timing Sys Components - Contract Award(s)
- S270100: BNL_UDF_Old Activity Name 181221: Procure Production Timing Sys Components - Contract Award(s)
- S270200: BNL_UDF_Old Activity Name 181221: Procure Production Timing Sys Components - Contract/PO - Leadtime
- S270300: BNL_UDF_Status Comments: 190315 ELM BNL Units per MP / BNL_UDF_Old Activity Name 181221: Timing System Production: FPGA Boards - Delivery Acceptance
- S270600: BNL_UDF_Status Comments: 190323 ELM Activity split / BNL_UDF_Old Activity Name 181221: Timing System Production: install timing system
- S270610: BNL_UDF_Status Comments: 190326 ELM rsrc per GRY; 190323 ELM Activity split / BNL_UDF_Old Activity Name 181221: Timing System Production: install timing system
- S270700: BNL_UDF_Status Comments: 190323 ELM Activity split / BNL_UDF_Old Activity Name 181221: Timing System Production: commission timing system
- S270710: BNL_UDF_Status Comments: 190326 ELM rsrc per GRY; 190323 ELM Activity split / BNL_UDF_Old Activity Name 181221: Timing System Production: commission timing system
- S270800: BNL_UDF_Old Activity Name 181221: Timing System Production: additional firmware updates
- S270900: BNL_UDF_Old Activity Name 181221: Timing System Production: Timing system ready to operate
- S271000: BNL_UDF_Status Comments: 190315 DurType to align with EVT / BNL_UDF_Old Activity Name 181221: Actuals - Labor - sPHENIX MinBias Trigger FY17
- S271200: BNL_UDF_Status Comments: 190315 DurType to align with EVT / BNL_UDF_Old Activity Name 181221: Actuals - Nonlabor - sPHENIX MinBias Trigger FY17
- S271400: BNL_UDF_Old Activity Name 181221: MBD Detector validation using Laser Labor
- S271500: BNL_UDF_Old Activity Name 181221: MBD Detector validation using Laser M&S
- S271800: BNL_UDF_Old Activity Name 181221: Readout validation of sPHENIX Prototype Digitizers
- S271100: BNL_UDF_Status Comments: 190315 DurType to align with EVT / BNL_UDF_Old Activity Name 181221: Actuals - Labor - sPHENIX MinBias Trigger FY18
- S271300: BNL_UDF_Status Comments: 190315 DurType to align with EVT / BNL_UDF_Old Activity Name 181221: Actuals - Nonlabor - sPHENIX MinBias Trigger FY18
- S271600: BNL_UDF_Old Activity Name 181221: MBD Detector validation in Magnetic Field Labor
- S271700: BNL_UDF_Old Activity Name 181221: MBD Detector validation in Magnetic Field M&S
- S271900: General Comments: 180420 GYoung: concerning Develop / Scope - Prototype development at collaborating University - Nevis / Lab / BNL_UDF_Status Comments: 190415 ELM name per GRY / BNL_UDF_Old Activity Name 181221: Develop Scope and Documentation for Shaper/Disc Boards
- S271901: General Comments: 180420 GYoung: concerning Develop / Scope - Prototype development at collaborating University - Nevis / Lab / BNL_UDF_Status Comments: 190522 IVS New act / BNL_UDF_Old Activity Name 181221: Develop Scope and Documentation for Shaper/Disc Boards
- S272000: BNL_UDF_Old Activity Name 181221: Procure Prototype Shaper/Disc Electronics - Provide Requirements to Procurement
- S272100: BNL_UDF_Old Activity Name 181221: Procure Prototype Shaper/Disc Electronics - Prepare & Send Solicitation
- S272200: BNL_UDF_Old Activity Name 181221: Procure Prototype Shaper/Disc Electronics - Vendor Responses
- S272300: BNL_UDF_Old Activity Name 181221: Procure Prototype Shaper/Disc Electronics - Vendor Selection
- OBLG272410: BNL_UDF_Old Activity Name 181221: Procure Prototype Shaper/Disc Electronics - Contract Award(s)
- S272400: BNL_UDF_Old Activity Name 181221: Procure Prototype Shaper/Disc Electronics - Contract Award(s)
- S1000999: BNL_UDF_Status Comments: 190315 DurType to align with EVT / BNL_UDF_Old Activity Name 181221: Actuals - Labor - sPHENIX MinBias Trigger FY18
- S1001039: BNL_UDF_Status Comments: 190315 DurType to align with EVT / BNL_UDF_Old Activity Name 181221: Actuals - Nonlabor - sPHENIX MinBias Trigger FY18
- S272500: BNL_UDF_Old Activity Name 181221: Procure Prototype Shaper/Disc Electronics - Contract/PO - Leadtime
- S272600: BNL_UDF_Old Activity Name 181221: Procure Prototype Shaper/Disc Electronics - Delivery Acceptance
- S272700: BNL_UDF_Status Comments: 190607 IVS dur. to 9mo; 190415 ELM name per GRY; 190315 ELM EVT / BNL_UDF_Old Activity Name 181221: Prototype Shaper/Disc Board Testing and evaluation / review; make any revisions to design and layout
- S272701: BNL_UDF_Status Comments: 190522 IVS New act. / BNL_UDF_Old Activity Name 181221: Prototype Shaper/Disc Board Testing and evaluation / review; make any revisions to design and layout
- S272800: BNL_UDF_Status Comments: 190315 ELM EVT / BNL_UDF_Old Activity Name 181221: Procure Min/Bias Electronics - Provide Requirements to Procurement
- S272900: BNL_UDF_Old Activity Name 181221: Procure Min/Bias Electronics - Prepare & Send Solicitation
- S273000: BNL_UDF_Old Activity Name 181221: Procure Min/Bias Electronics - Vendor Responses
- S273100: BNL_UDF_Old Activity Name 181221: Procure Min/Bias Electronics - Vendor Selection
- S273200: BNL_UDF_Old Activity Name 181221: Procure Min/Bias Electronics - sPHENIX Production Digitizers - Contract Award(s)
- OBLG273210: BNL_UDF_Old Activity Name 181221: Procure Min/Bias Electronics - sPHENIX Production Digitizers - Contract Award(s)
- OBLG273310: BNL_UDF_Old Activity Name 181221: Procure Shaper/Disc Board 128 Channels - Contract Award(s)
- S273300: BNL_UDF_Old Activity Name 181221: Procure Shaper/Disc Board 128 Channels - Contract Award(s)
- S273400: BNL_UDF_Old Activity Name 181221: Procure Min/Bias Electronics - Contract/PO - Leadtime
- S273700: BNL_UDF_Status Comments: 190323 ELM ActType, Logic / BNL_UDF_Old Activity Name 181221: Oversight of sPHENIX Digitizers Procurement
- S273500: BNL_UDF_Status Comments: 190315 ELM BNLU per GRY / BNL_UDF_Old Activity Name 181221: Procure sPHENIX Production Digitizers - Delivery Acceptance
- S273600: BNL_UDF_Old Activity Name 181221: Procure Shaper/Disc Board 128 Channels - Delivery Acceptance
- S273800: BNL_UDF_Status Comments: 190315 ELM EVT / BNL_UDF_Old Activity Name 181221: Test Full Min/Bias Electronics
- S273900: BNL_UDF_Old Activity Name 181221: MBD Production Complete
- S274000: BNL_UDF_Status Comments: 190315 ELM EVT / BNL_UDF_Old Activity Name 181221: Bench Test Min/Bias Detector
- S274100: BNL_UDF_Old Activity Name 181221: MinBias Detector Ready to Install

| ID | WBS | Activity | Duration | Start | Finish | Predecessors | Complete | Remaining | Planned start | Planned finish | Total float | Free float | Constraint | Expected finish | Resources | Cost | RG Check | BNL_Activity Status | BNL_CAM | BNL_WBS_Hierarchical | BNL_UDF_Exclude | BNL_UDF_Status Comments | BNL_UDF_Temp Text 01 | BNL_UDF_Percent Complete | BNL_UDF_Old Activity Name 181221 | BNL_UDF_Old Activity ID 181221 | BNL_Cobra WP | BNL_Fund Source | BNL_Estimator | BNL_Cost Basis | BNL_EDIA | BNL_OPC TEC (deprecated) | BNL_WBS | BNL_Actuals | BNL_FY | BNL_EVT | BNL_Master Control Account | BNL_Account Number | BNL_PCR ID | BNL_Cobra Control Account | Completed | BNL_UDF_OPC TEC (deprecated) | BNL_UDF_Temp Date 01 | BNL_Location | BNL_Institution | BNL_Management or Mgmt Travel | Cost = Awarded Proc or Mgmt | Indicator - Procurement |
| --- | --- | --- | --- | --- | --- | --- | --- | --- | --- | --- | --- | --- | --- | --- | --- | --- | --- | --- | --- | --- | --- | --- | --- | --- | --- | --- | --- | --- | --- | --- | --- | --- | --- | --- | --- | --- | --- | --- | --- | --- | --- | --- | --- | --- | --- | --- | --- | --- |
|  | 02 | **Infrastructure/Facility** |  | 2017-02-01 | 2023-01-30 |  |  |  |  |  |  |  |  |  |  |  |  |  |  |  |  |  |  |  |  |  |  |  |  |  |  |  |  |  |  |  |  |  |  |  |  |  |  |  |  |  |  |  |
|  | 01 | **Infrastructure/Facility Management** |  | 2017-02-01 | 2022-10-07 |  |  |  |  |  |  |  |  |  |  |  |  |  |  |  |  |  |  |  |  |  |  |  |  |  |  |  |  |  |  |  |  |  |  |  |  |  |  |  |  |  |  |  |
|  | 01 | **Infrastructure/Facility Overview** |  | 2020-01-06 | 2021-12-30 |  |  |  |  |  |  |  |  |  |  |  |  |  |  |  |  |  |  |  |  |  |  |  |  |  |  |  |  |  |  |  |  |  |  |  |  |  |  |  |  |  |  |  |
| S274300 |  | RHIC FY20 Run | 52d | 2020-01-06 A | 2020-09-15 A |  | 100% |  | 2020-01-15 | 2020-03-30 |  |  | start on 2020-01-06 |  |  |  | NOCA | Not Started | Ed O'Brien | 01 |  |  |  |  |  |  |  |  |  |  |  |  |  |  |  |  |  |  |  |  |  |  |  |  |  |  |  |  |
| S274310 |  | RHIC FY21 Run | 92d | 2021-02-01 A | 2021-07-08 |  | 60% | 27d | 2021-03-01 | 2021-07-08 | 88d | 0d | start on 2021-01-04 | 2021-07-08 |  |  | NOCA | Not Started | Ed O'Brien | 01 |  |  |  |  |  |  |  |  |  |  |  |  |  |  |  |  |  |  |  |  |  |  |  |  |  |  |  |  |
| S274320 |  | RHIC FY22 Run | 81d | 2021-09-01 | 2021-12-30 |  |  |  |  |  | 0d | 268d | start on 2021-09-01 |  |  |  | NOCA | Not Started | Ed O'Brien | 01 |  |  |  |  |  |  |  |  |  |  |  |  |  |  |  |  |  |  |  |  |  |  |  |  |  |  |  |  |
|  | 02 | **Magnet Management and Technical Oversight** |  | 2017-02-01 | 2022-09-30 |  |  |  |  |  |  |  |  |  |  |  |  |  |  |  |  |  |  |  |  |  |  |  |  |  |  |  |  |  |  |  |  |  |  |  |  |  |  |  |  |  |  |  |
| S278400 |  | Actuals - Labor - sPHENIX Magnet FY17 16716 | 169d | 2017-02-01 A | 2017-09-29 A | S100090 SS | 100% |  |  |  |  |  |  |  | Actual Labor [116.95 h] | 19,541.51 | CA | Completed | Ed O'Brien | 02 | MP6LAEXCLUDE | 190315 DurType to align with EVT | S278400 | 100 | Actuals - Labor - sPHENIX Magnet FY17 | S338540 | S278400 | C | Yip, Kin | L1 | Design | null | POM02.2.01.01 | Yes | 2017 | A | 2.01 | 16716 | 003 | 2.01 | yes |  |  |  |  |  |  |  |
| S274400 |  | 2018 Magnet Project Management | 249d | 2017-10-02 A | 2018-09-28 A | S100090 SS | 100% |  |  |  |  |  |  |  |  |  | NOCA | Completed | Irina Sourikova | 02 |  |  | S274400 | 100 | 2018 Magnet Project Management | S248100 |  | C | Yip, Kin | L1 | Management | null | POM02.2.01.01 |  |  | A |  |  |  |  | yes | S248100 | 2018-09-28 | BNL | BNL | Yes | Yes |  |
| S275000 |  | 2018 Cryo L3 Project Management | 249d | 2017-10-02 A | 2018-09-28 A | S100090 SS | 100% |  |  |  |  |  |  |  |  |  | NOCA | Completed | Irina Sourikova | 02 |  |  | S275000 | 100 | 2018 Cryo L3 Project Management | S336910 |  | C | Yip, Kin | L2 | Management | null | POM02.2.01.01 |  |  | A |  |  |  |  | yes | S248100 | 2018-09-28 | BNL | BNL | Yes | Yes |  |
| S275500 |  | 2018 PS & Quench Protection L3 Project Management | 249d | 2017-10-02 A | 2018-09-28 A | S100090 SS | 100% |  |  |  |  |  |  |  |  |  | NOCA | Completed | Irina Sourikova | 02 |  |  | S275500 | 100 | 2018 PS & Quench Protection L3 Project Management | S336960 |  | C | Yip, Kin | L2 | Management | null | POM02.2.01.01 |  |  | A |  |  |  |  | yes | S248100 | 2018-09-28 | BNL | BNL | Yes | Yes |  |
| S278500 |  | Actuals - Labor - sPHENIX Magnet FY18 16716 and 16717 | 249d | 2017-10-02 A | 2018-09-28 A | S278400, S1000039, S1000079, S1000119 | 100% |  |  |  |  |  |  |  | Actual Labor [488.2 h] | 81,575.42 | CA | Completed | Ed O'Brien | 02 | MP6LAEXCLUDE | 190315 DurType to align with EVT | S278500 | 100 | Actuals - Labor - sPHENIX Magnet FY18 | S339340 | S278500 | C | Yip, Kin | L1 | Design | null | POM02.2.01.01 | Yes | 2018 | A | 2.01 | 16716 | 003 | 2.01 | yes |  |  |  |  |  |  |  |
| S278700 |  | Actuals - Nonlabor - sPHENIX Magnet FY18 16716 | 249d | 2017-10-02 A | 2018-09-28 A | S278600 | 100% |  |  |  |  |  |  |  | Actual Nonlabor [25268 h] | 28,189.32 | CA | Completed | Ed O'Brien | 02 | MP6LAEXCLUDE | 190315 DurType to align with EVT | S278700 | 100 | Actuals - Nonlabor - sPHENIX Magnet FY18 | S339345 | S278700 | C | Yip, Kin | M1 | Design | null | POM02.2.01.01 | Yes | 2018 | A | 2.01 | 16716 | 003 | 2.01 | yes |  |  |  |  |  |  | UDF_G3 |
| S274900 |  | Cryogenics System Technical Review | 33d | 2018-01-12 A | 2018-03-01 A | S100090 SS | 100% |  |  |  |  |  |  |  |  |  | NOCA | Completed | Irina Sourikova | 02 |  |  | S274900 | 100 | Cryogenics System Technical Review | S248300 |  | C | Yip, Kin | L2 | Management | null | POM02.2.01.01 |  |  | C |  |  |  |  | yes | S248300 | 2018-01-12 | BNL | BNL |  |  |  |
| S1001199 |  | Actuals - Labor - sPHENIX Magnet FY19 M8 16716 | 166d | 2018-10-01 A | 2019-05-31 A |  | 100% |  |  |  |  |  |  |  | Actual Labor [565.21 h] | 94,442.57 | CA | Completed | Ed O'Brien | 02 | MP6LAEXCLUDE | 190315 DurType to align with EVT | S278500 | 100 | Actuals - Labor - sPHENIX Magnet FY18 | S339340 | S1001199 | C | Yip, Kin | L1 | Design | null | POM02.2.01.01 | Yes | 2019 | A | 2.01 | 16716 | 003 | 2.01 | yes |  |  |  |  |  |  |  |
| S274500 |  | 2019 Magnet Project Management | 166d | 2018-10-01 A | 2019-05-31 A | S274400 | 100% |  |  |  |  |  |  |  |  |  | NOCA | Completed | Irina Sourikova | 02 |  |  | S274500 | 0 | 2019 Magnet Project Management | S248110 |  | C | Yip, Kin | L1 | Management | null | POM02.2.01.01 |  |  | A |  | 16716 |  |  | yes | S248100 | 2019-09-30 | BNL | BNL | Yes | Yes |  |
| S275100 |  | 2019 Cryo L3 Project Management | 166d | 2018-10-01 A | 2019-05-31 A | S275000 | 100% |  |  |  |  |  |  |  |  |  | NOCA | Completed | Irina Sourikova | 02 |  |  | S275100 | 0 | 2019 Cryo L3 Project Management | S336920 |  | C | Yip, Kin | L2 | Management | null | POM02.2.01.01 |  |  | A |  | 16716 |  |  | yes | S248100 | 2019-09-30 | BNL | BNL | Yes | Yes |  |
| S275600 |  | 2019 PS & Quench Protection L3 Project Management | 166d | 2018-10-01 A | 2019-05-31 A | S275500 | 100% |  |  |  |  |  |  |  |  |  | NOCA | Completed | Irina Sourikova | 02 |  |  | S275600 | 0 | 2019 PS & Quench Protection L3 Project Management | S336970 |  | C | Yip, Kin | L2 | Management | null | POM02.2.01.01 |  |  | A |  | 16716 |  |  | yes | S248100 | 2019-09-30 | BNL | BNL | Yes | Yes |  |
| S1004320 |  | Actuals - Labor FY19 Jun-Sep 16716 | 84d | 2019-06-03 A | 2019-09-30 A |  | 100% |  |  |  |  |  |  |  | Actual Labor [347.45 h] | 58,057.09 | CA | Completed | Ed O'Brien | 02 | MP6LAEXCLUDE | 190315 DurType to align with EVT | S278500 | 100 | Actuals - Labor - sPHENIX Magnet FY18 | S339340 | S1004320 | C | Yip, Kin | L1 | Design | null | POM02.2.01.01 | Yes | 2019 | A | 2.01 | 16716 | 003 | 2.01 | yes |  |  |  |  |  |  |  |
| S274510 |  | 2019 Magnet Project Management Split | 64d | 2019-07-01 A | 2019-09-30 A | S274500 | 100% |  |  |  |  |  |  |  |  |  | NOCA | Completed | Irina Sourikova | 02 |  |  | S274500 | 0 | 2019 Magnet Project Management | S248110 |  | C | Yip, Kin | L1 | Management | null | POM02.2.01.01 |  |  | A | 2.01 | 16716 |  |  |  | S248100 | 2019-09-30 | BNL | BNL | Yes | Yes |  |
| S275110 |  | 2019 Cryo L3 Project Management Split | 64d | 2019-07-01 A | 2019-09-30 A | S275100 | 100% |  |  |  |  |  |  |  |  |  | NOCA | Completed | Irina Sourikova | 02 |  |  | S275100 | 0 | 2019 Cryo L3 Project Management | S336920 |  | C | Yip, Kin | L2 | Management | null | POM02.2.01.01 |  |  | A | 2.01 | 16716 |  |  |  | S248100 | 2019-09-30 | BNL | BNL | Yes | Yes |  |
| S275610 |  | 2019 PS & Quench Protection L3 Project Management Split | 64d | 2019-07-01 A | 2019-09-30 A | S275600 | 100% |  |  |  |  |  |  |  |  |  | NOCA | Completed | Irina Sourikova | 02 |  |  | S275600 | 0 | 2019 PS & Quench Protection L3 Project Management | S336970 |  | C | Yip, Kin | L2 | Management | null | POM02.2.01.01 |  |  | A | 2.01 | 16716 |  |  |  | S248100 | 2019-09-30 | BNL | BNL | Yes | Yes |  |
| S274600 |  | 2020 Magnet Project Management | 251d | 2019-10-01 A | 2020-09-30 A | S274510 | 100% |  |  |  |  |  |  |  | SCI3 AD [880 h] | 151,453 | CA | In Progress | Irina Sourikova | 02 |  |  | S274600 | 0 | 2020 Magnet Project Management | S248120 | S274600 | C | Yip, Kin | L1 | Management | null | POM02.2.01.01 |  |  | A | 2.01 | 16716 |  | 2.01 |  | S248100 | 2020-09-30 | BNL | BNL | Yes | Yes |  |
| S275200 |  | 2020 Cryo L3 Project Management | 251d | 2019-10-01 A | 2020-09-30 A | S275110 | 100% |  |  |  |  |  |  |  | PROF6 AD [352 h] | 67,933.51 | CA | In Progress | Irina Sourikova | 02 |  |  | S275200 | 0 | 2020 Cryo L3 Project Management | S336930 | S275200 | C | Yip, Kin | L2 | Management | null | POM02.2.01.01 |  |  | A | 2.01 | 16716 |  | 2.01 |  | S248100 | 2020-09-30 | BNL | BNL | Yes | Yes |  |
| S275700 |  | 2020 PS & Quench Protection L3 Project Management | 251d | 2019-10-01 A | 2020-09-30 A | S275610 | 100% |  |  |  |  |  |  |  | PROF5 AD [352 h] | 59,862.2 | CA | In Progress | Irina Sourikova | 02 |  |  | S275700 | 0 | 2020 PS & Quench Protection L3 Project Management | S336980 | S275700 | C | Yip, Kin | L2 | Management | null | POM02.2.01.01 |  |  | A | 2.01 | 16716 |  | 2.01 |  | S248100 | 2020-09-30 | BNL | BNL | Yes | Yes |  |
| S274700 |  | 2021 Magnet Project Management | 250d | 2020-10-01 A | 2021-09-30 | S274600 | 66% | 86d |  |  | 7d | 0d | start on 2020-10-01 | 2021-09-30 | SCI3 AD [880 h] | 155,996.59 | CA | Not Started | Irina Sourikova | 02 |  |  | S274700 | 0 | 2021 Magnet Project Management | S248130 | S274700 | C | Yip, Kin | L1 | Management | null | POM02.2.01.01 |  |  | A | 2.01 | 16716 |  | 2.01 |  | S248100 | 2021-09-30 | BNL | BNL | Yes | Yes |  |
| S275300 |  | 2021 Cryo L3 Project Management | 250d | 2020-10-01 A | 2021-05-31 A | S275200 | 100% |  | 2020-10-01 | 2021-09-30 |  |  |  |  | PROF6 AD [235 h] | 46,713.94 | CA | Not Started | Irina Sourikova | 02 |  |  | S275300 | 0 | 2021 Cryo L3 Project Management | S336940 | S275300 | C | Yip, Kin | L2 | Management | null | POM02.2.01.01 |  |  | A | 2.01 | 16716 | 025 | 2.01 |  | S248100 | 2021-09-30 | BNL | BNL | Yes | Yes |  |
| S275800 |  | 2021 PS & Quench Protection L3 Project Management | 250d | 2020-10-01 A | 2021-09-30 | S275700 | 66% | 86d |  |  | 7d | 0d |  | 2021-09-30 | PROF5 AD [352 h] | 61,658.07 | CA | Not Started | Irina Sourikova | 02 |  |  | S275800 | 0 | 2021 PS & Quench Protection L3 Project Management | S336990 | S275800 | C | Yip, Kin | L2 | Management | null | POM02.2.01.01 |  |  | A | 2.01 | 16716 |  | 2.01 |  | S248100 | 2021-09-30 | BNL | BNL | Yes | Yes |  |
| S275400 |  | 2022 Cryo L3 Project Management | 250d | 2021-06-01 | 2022-05-31 | S275300 |  |  |  |  | 93d |  |  |  |  |  | CA | Not Started | Irina Sourikova | 02 |  |  | S275400 | 0 | 2022 Cryo L3 Project Management | S336950 | S275400 | C | Yip, Kin | L2 | Management | null | POM02.2.01.01 |  |  | A | 2.01 | 16716 | 025 | 2.01 |  | S248100 | 2022-09-30 | BNL | BNL | Yes | Yes |  |
| S274800 |  | 2022 Magnet Project Management | 250d | 2021-10-01 | 2022-09-30 | S274700 |  |  |  |  | 7d |  |  |  | SCI3 AD [880 h] | 160,676.49 | CA | Not Started | Irina Sourikova | 02 |  |  | S274800 | 0 | 2022 Magnet Project Management | S248140 | S274800 | C | Yip, Kin | L1 | Management | null | POM02.2.01.01 |  |  | A | 2.01 | 16716 |  | 2.01 |  | S248100 | 2022-09-30 | BNL | BNL | Yes | Yes |  |
| S275900 |  | 2022 PS & Quench Protection L3 Project Management | 250d | 2021-10-01 | 2022-09-30 | S275800 |  |  |  |  | 7d |  |  |  | PROF5 AD [352 h] | 63,507.81 | CA | Not Started | Irina Sourikova | 02 |  |  | S275900 | 0 | 2022 PS & Quench Protection L3 Project Management | S337000 | S275900 | C | Yip, Kin | L2 | Management | null | POM02.2.01.01 |  |  | A | 2.01 | 16716 |  | 2.01 |  | S248100 | 2022-09-30 | BNL | BNL | Yes | Yes |  |

| ID | WBS | Activity | Duration | Start | Finish | Predecessors | Complete | Remaining | Planned start | Planned finish | Total float | Free float | Expected finish | Resources | Cost | BNL_UDF_Exclude | BNL_UDF_Status Comments | BNL_UDF_Temp Text 01 | BNL_UDF_Percent Complete | BNL_UDF_Old Activity Name 181221 | BNL_UDF_Old Activity ID 181221 | BNL_Cobra WP | RG Check | BNL_Activity Status | BNL_Fund Source | BNL_Estimator | BNL_Cost Basis | BNL_Location | BNL_EDIA | BNL_CAM | BNL_OPC TEC (deprecated) | BNL_WBS | BNL_Actuals | BNL_FY | BNL_EVT | BNL_Master Control Account | BNL_Account Number | BNL_PCR ID | BNL_Cobra Control Account | BNL_WBS_Hierarchical | Completed | BNL_UDF_OPC TEC (deprecated) | BNL_UDF_Temp Date 01 | BNL_Institution | BNL_Management or Mgmt Travel | Cost = Awarded Proc or Mgmt | BNL_UDF_Adhoc Comments | Indicator - Procurement |
| --- | --- | --- | --- | --- | --- | --- | --- | --- | --- | --- | --- | --- | --- | --- | --- | --- | --- | --- | --- | --- | --- | --- | --- | --- | --- | --- | --- | --- | --- | --- | --- | --- | --- | --- | --- | --- | --- | --- | --- | --- | --- | --- | --- | --- | --- | --- | --- | --- |
|  | 03 | **Carriage and Structural Component Management** |  | 2017-02-01 | 2019-09-30 |  |  |  |  |  |  |  |  |  |  |  |  |  |  |  |  |  |  |  |  |  |  |  |  |  |  |  |  |  |  |  |  |  |  |  |  |  |  |  |  |  |  |  |
| S1000559 |  | Actuals - Labor - sPHENIX Infrastructure FY17 16725 | 169d | 2017-02-01 A | 2017-09-29 A | S100090 SS | 100% |  |  |  |  |  |  | Actual Labor [134.16 h] | 22,417.18 | MP6LAEXCLUDE | 190315 DurType to align with EVT | S309200 | 100 | Actuals - Labor - sPHENIX Infrastructure FY17 | S338500 | S1000559 | CA | Completed | C | Pisani, Rob | L1 | BNL | Design | Ed O'Brien | null | POM02.2.01.02 | Yes | 2017 | A | 2.01 | 16725 | 003 | 2.01 | 03 | yes |  |  |  |  |  |  |  |
| S1000719 |  | Actuals - Labor - sPHENIX Infrastructure FY18 16725 | 249d | 2017-10-01 A | 2018-09-28 A | S309200, S1000439, S1000479, S1000519, S1000559 | 100% |  | 2017-10-02 | 2018-09-28 |  |  |  | Actual Labor [101.9 h] | 17,026.77 | MP6LAEXCLUDE | 190315 DurType to align with EVT | S309300 | 100 | Actuals - Labor - sPHENIX Infrastructure FY18 | S339380 | S1000719 | CA | Completed | C | Pisani, Rob | L1 | BNL | Design | Ed O'Brien | null | POM02.2.01.02 | Yes | 2018 | A | 2.01 | 16725 | 003 | 2.01 | 03 | yes |  |  |  |  |  |  |  |
| S1001719 |  | Actuals - Labor - sPHENIX Infrastructure FY19 M8 16725 | 166d | 2018-10-01 A | 2019-05-31 A |  | 100% |  |  |  |  |  |  | Actual Labor [119.51 h] | 19,969.27 | MP6LAEXCLUDE | 190315 DurType to align with EVT | S309300 | 100 | Actuals - Labor - sPHENIX Infrastructure FY18 | S339380 | S1001719 | CA | Completed | C | Pisani, Rob | L1 | BNL | Design | Ed O'Brien | null | POM02.2.01.02 | Yes | 2019 | A | 2.01 | 16725 | 003 | 2.01 | 03 | yes |  |  |  |  |  |  |  |
| S1004680 |  | Actuals - Labor FY19 Jun-Sep 16725 | 84d | 2019-06-03 A | 2019-09-30 A |  | 100% |  |  |  |  |  |  | Actual Labor [137.29 h] | 22,940.52 | MP6LAEXCLUDE | 190315 DurType to align with EVT | S309300 | 100 | Actuals - Labor - sPHENIX Infrastructure FY18 | S339380 | S1004680 | CA | Completed | C | Pisani, Rob | L1 | BNL | Design | Ed O'Brien | null | POM02.2.01.02 | Yes | 2019 | A | 2.01 | 16725 | 003 | 2.01 | 03 | yes |  |  |  |  |  |  |  |
|  | 04 | **Infrastructure Management** |  | 2017-02-01 | 2022-10-07 |  |  |  |  |  |  |  |  |  |  |  |  |  |  |  |  |  |  |  |  |  |  |  |  |  |  |  |  |  |  |  |  |  |  |  |  |  |  |  |  |  |  |  |
| S309200 |  | Actuals - Labor - sPHENIX Infrastructure FY17 16721 | 169d | 2017-02-01 A | 2017-09-29 A | S100090 SS | 100% |  |  |  |  |  |  | Actual Labor [459.89 h] | 76,844.35 | MP6LAEXCLUDE | 190315 DurType to align with EVT | S309200 | 100 | Actuals - Labor - sPHENIX Infrastructure FY17 | S338500 | S309200 | CA | Completed | C | Pisani, Rob | L1 | BNL | Design | Ed O'Brien | null | POM02.2.01.01 | Yes | 2017 | A | 2.01 | 16721 | 003 | 2.01 | 04 | yes |  |  |  |  |  |  |  |
| S309300 |  | Actuals - Labor - sPHENIX Infrastructure FY18 16721 | 249d | 2017-10-01 A | 2018-09-28 A | S309200, S1000439, S1000479, S1000519, S1000559 | 100% |  | 2017-10-02 | 2018-09-28 |  |  |  | Actual Labor [1176.88 h] | 196,648.28 | MP6LAEXCLUDE | 190315 DurType to align with EVT | S309300 | 100 | Actuals - Labor - sPHENIX Infrastructure FY18 | S339380 | S309300 | CA | Completed | C | Pisani, Rob | L1 | BNL | Design | Ed O'Brien | null | POM02.2.01.01 | Yes | 2018 | A | 2.01 | 16721 | 003 | 2.01 | 04 | yes |  |  |  |  |  |  |  |
| S276000 |  | 2018 Infrastructure Project Management | 249d | 2017-10-02 A | 2018-09-28 A | S100090 SS | 100% |  |  |  |  |  |  |  |  |  |  | S276000 | 100 | 2018 Infrastructure Project Management | S337010 |  | NOCA | Completed | C | Yip, Kin | L2 | BNL | Management | Irina Sourikova | null | POM02.2.01.03 |  |  | A |  |  |  |  | 04 | yes | S248100 | 2018-09-28 | BNL | Yes | Yes |  |  |
| S276600 |  | 2018 Facility Support Systems L3 Project Management | 249d | 2017-10-02 A | 2018-09-28 A | S100090 SS | 100% |  |  |  |  |  |  |  |  |  |  | S276600 | 100 | 2018 Facility Support Systems L3 Project Management | S337060 |  | NOCA | Completed | C | Yip, Kin | L2 | BNL | Management | Irina Sourikova | null | POM02.2.01.03 |  |  | A |  |  |  |  | 04 | yes | S248100 | 2018-09-28 | BNL | Yes | Yes |  |  |
| S277200 |  | 2018 Detector Support Systems L3 Project Management | 249d | 2017-10-02 A | 2018-09-28 A | S100090 SS | 100% |  |  |  |  |  |  |  |  |  |  | S277200 | 100 | 2018 Detector Support Systems L3 Project Management | S337110 |  | NOCA | Completed | C | Yip, Kin | L2 | BNL | Management | Irina Sourikova | null | POM02.2.01.03 |  |  | A |  |  |  |  | 04 | yes | S248100 | 2018-09-28 | BNL | Yes | Yes |  |  |
| S1001519 |  | Actuals - Labor - sPHENIX Infrastructure FY19 M8 16721 | 166d | 2018-10-01 A | 2019-05-31 A |  | 100% |  |  |  |  |  |  | Actual Labor [354.42 h] | 59,221.06 | MP6LAEXCLUDE | 190315 DurType to align with EVT | S309300 | 100 | Actuals - Labor - sPHENIX Infrastructure FY18 | S339380 | S1001519 | CA | Completed | C | Pisani, Rob | L1 | BNL | Design | Ed O'Brien | null | POM02.2.01.01 | Yes | 2019 | A | 2.01 | 16721 | 003 | 2.01 | 04 | yes |  |  |  |  |  |  |  |
| S276100 |  | 2019 Infrastructure Project Management | 166d | 2018-10-01 A | 2019-05-31 A | S276000 | 100% |  |  |  |  |  |  |  |  |  |  | S276100 | 0 | 2019 Infrastructure Project Management | S337020 |  | NOCA | Completed | C | Yip, Kin | L2 | BNL | Management | Irina Sourikova | null | POM02.2.01.03 |  |  | A |  | 16721 |  |  | 04 | yes | S248100 | 2019-09-30 | BNL | Yes | Yes |  |  |
| S276700 |  | 2019 Facility Support Systems L3 Project Management | 166d | 2018-10-01 A | 2019-05-31 A | S276600 | 100% |  |  |  |  |  |  |  |  |  |  | S276700 | 0 | 2019 Facility Support Systems L3 Project Management | S337070 |  | NOCA | Completed | C | Yip, Kin | L2 | BNL | Management | Irina Sourikova | null | POM02.2.01.03 |  |  | A |  | 16721 |  |  | 04 | yes | S248100 | 2019-09-30 | BNL | Yes | Yes |  |  |
| S277300 |  | 2019 Detector Support Systems L3 Project Management | 166d | 2018-10-01 A | 2019-05-31 A | S277200 | 100% |  |  |  |  |  |  |  |  |  |  | S277300 | 0 | 2019 Detector Support Systems L3 Project Management | S337120 |  | NOCA | Completed | C | Yip, Kin | L2 | BNL | Management | Irina Sourikova | null | POM02.2.01.03 |  |  | A |  | 16721 |  |  | 04 | yes | S248100 | 2019-09-30 | BNL | Yes | Yes | 180423 ELM rsrc per GRY |  |
| S1004640 |  | Actuals - Labor FY19 Jun-Sep 16721 | 84d | 2019-06-03 A | 2019-09-30 A |  | 100% |  |  |  |  |  |  | Actual Labor [8.09 h] | 1,351.45 | MP6LAEXCLUDE | 190315 DurType to align with EVT | S309300 | 100 | Actuals - Labor - sPHENIX Infrastructure FY18 | S339380 | S1004640 | CA | Completed | C | Pisani, Rob | L1 | BNL | Design | Ed O'Brien | null | POM02.2.01.01 | Yes | 2019 | A | 2.01 | 16721 | 003 | 2.01 | 04 | yes |  |  |  |  |  |  |  |
| S1004720 |  | Actuals - NonLabor FY19 Jun-Sep 16721 | 84d | 2019-06-03 A | 2019-09-30 A |  | 100% |  |  |  |  |  |  | Actual Nonlabor [6515.6 h] | 7,188.43 | MP6LAEXCLUDE | 190315 DurType to align with EVT | S309300 | 100 | Actuals - Labor - sPHENIX Infrastructure FY18 | S339380 | S1004720 | CA | Completed | C | Pisani, Rob | L1 | BNL | Design | Ed O'Brien | null | POM02.2.01.01 | Yes | 2019 | A | 2.01 | 16721 | 003 | 2.01 | 04 | yes |  |  |  |  |  |  | UDF_G2 |
| S276110 |  | 2019 Infrastructure Project Management Split | 64d | 2019-07-01 A | 2019-09-30 A | S276100 | 100% |  |  |  |  |  |  |  |  |  |  | S276100 | 0 | 2019 Infrastructure Project Management | S337020 |  | NOCA | Completed | C | Yip, Kin | L2 | BNL | Management | Irina Sourikova | null | POM02.2.01.03 |  |  | A | 2.01 | 16721 |  |  | 04 |  | S248100 | 2019-09-30 | BNL | Yes | Yes |  |  |
| S276710 |  | 2019 Facility Support Systems L3 Project Management Split | 64d | 2019-07-01 A | 2019-09-30 A | S276700 | 100% |  |  |  |  |  |  |  |  |  |  | S276700 | 0 | 2019 Facility Support Systems L3 Project Management | S337070 |  | NOCA | Completed | C | Yip, Kin | L2 | BNL | Management | Irina Sourikova | null | POM02.2.01.03 |  |  | A | 2.01 | 16721 |  |  | 04 |  | S248100 | 2019-09-30 | BNL | Yes | Yes |  |  |
| S277310 |  | 2019 Detector Support Systems L3 Project Management Split | 64d | 2019-07-01 A | 2019-09-30 A | S277300 | 100% |  |  |  |  |  |  |  |  |  |  | S277300 | 0 | 2019 Detector Support Systems L3 Project Management | S337120 |  | NOCA | Completed | C | Yip, Kin | L2 | BNL | Management | Irina Sourikova | null | POM02.2.01.03 |  |  | A | 2.01 | 16721 |  |  | 04 |  | S248100 | 2019-09-30 | BNL | Yes | Yes | 180423 ELM rsrc per GRY |  |
| S276200 |  | 2020 Infrastructure Project Management | 251d | 2019-10-01 A | 2020-09-30 A | S276110 | 100% |  |  |  |  |  |  | Project Mgmt Specialist - Purchased Services [890 h]; PROF3 PO E [880 h] | 251,694.43 |  |  | S276200 | 0 | 2020 Infrastructure Project Management | S337030 | S276200 | CA | In Progress | C | Yip, Kin | L2 | BNL | Management | Irina Sourikova | null | POM02.2.01.03 |  |  | A | 2.01 | 16721 | 010 | 2.01 | 04 |  | S248100 |  | BNL | Yes | Yes |  |  |
| S276800 |  | 2020 Facility Support Systems L3 Project Management | 251d | 2019-10-01 A | 2020-09-30 A | S276710 | 100% |  |  |  |  |  |  | PROF2 AD [352 h] | 35,277.18 |  |  | S276800 | 0 | 2020 Facility Support Systems L3 Project Management | S337080 | S276800 | CA | In Progress | C | Yip, Kin | L2 | BNL | Management | Irina Sourikova | null | POM02.2.01.03 |  |  | A | 2.01 | 16721 |  | 2.01 | 04 |  | S248100 |  | BNL | Yes | Yes |  |  |
| S277400 |  | 2020 Detector Support Systems L3 Project Management | 251d | 2019-10-01 A | 2020-09-30 A | S277310 | 100% |  |  |  |  |  |  | PROF5 PO M [352 h]; PROF4 PO E [440 h] | 124,658.81 |  |  | S277400 | 0 | 2020 Detector Support Systems L3 Project Management | S337130 | S277400 | CA | In Progress | C | Yip, Kin | L2 | BNL | Management | Irina Sourikova | null | POM02.2.01.03 |  |  | A | 2.01 | 16721 |  | 2.01 | 04 |  | S248100 |  | BNL | Yes | Yes | 180423 ELM rsrc per GRY |  |
| S276900 |  | 2021 Facility Support Systems L3 Project Management | 250d | 2020-10-01 A | 2021-09-30 | S276800 | 66% | 86d | 2020-11-02 | 2021-11-01 | 2d | 0d | 2021-09-30 | PROF2 AD [352 h] | 36,427.06 |  |  | S276900 | 0 | 2021 Facility Support Systems L3 Project Management | S337090 | S276900 | CA | Not Started | C | Yip, Kin | L2 | BNL | Management | Irina Sourikova | null | POM02.2.01.03 |  |  | A | 2.01 | 16721 |  | 2.01 | 04 |  | S248100 |  | BNL | Yes | Yes |  |  |
| S276300 |  | 2021 Infrastructure Project Management | 250d | 2020-10-01 A | 2021-09-30 | S276200 | 66% | 86d |  |  | 73d | 0d | 2021-09-30 | Project Mgmt Specialist - Purchased Services [890 h]; PROF3 PO E [860 h] | 256,639.17 |  |  | S276300 | 0 | 2021 Infrastructure Project Management | S337040 | S276300 | CA | Not Started | C | Yip, Kin | L2 | BNL | Management | Irina Sourikova | null | POM02.2.01.03 |  |  | A | 2.01 | 16721 | 010 | 2.01 | 04 |  | S248100 |  | BNL | Yes | Yes |  |  |
| S277500 |  | 2021 Detector Support Systems L3 Project Management | 250d | 2020-10-01 A | 2021-09-30 | S277400 | 66% | 86d |  |  | 0d |  | 2021-09-30 | PROF5 PO M [352 h]; PROF4 PO E [440 h] | 128,398.57 |  |  | S277500 | 0 | 2021 Detector Support Systems L3 Project Management | S337140 | S277500 | CA | Not Started | C | Yip, Kin | L2 | BNL | Management | Irina Sourikova | null | POM02.2.01.03 |  |  | A | 2.01 | 16721 |  | 2.01 | 04 |  | S248100 |  | BNL | Yes | Yes | 180423 ELM rsrc per GRY |  |
| S276400 |  | 2022 Infrastructure Project Management | 250d | 2021-10-01 | 2022-09-30 | S276300 |  |  |  |  | 73d | 0d |  | PROF3 PO E [800 h] | 107,371.17 |  |  | S276400 | 0 | 2022 Infrastructure Project Management | S337050 | S276400 | CA | Not Started | C | Yip, Kin | L2 | BNL | Management | Irina Sourikova | null | POM02.2.01.03 |  |  | A | 2.01 | 16721 | 010 | 2.01 | 04 |  | S248100 |  | BNL | Yes | Yes |  |  |
| S277000 |  | 2022 Facility Support Systems L3 Project Management | 250d | 2021-10-01 | 2022-09-30 | S276900 |  |  |  |  | 2d | 0d |  | PROF2 AD [352 h] | 37,425.56 |  |  | S277000 | 0 | 2022 Facility Support Systems L3 Project Management | S337100 | S277000 | CA | Not Started | C | Yip, Kin | L2 | BNL | Management | Irina Sourikova | null | POM02.2.01.03 |  |  | A | 2.01 | 16721 | 025 | 2.01 | 04 |  | S248100 |  | BNL | Yes | Yes |  |  |
| S276500 |  | 2023 Infrastructure Project Management | 5d | 2022-10-03 | 2022-10-07 | S276400 |  |  |  |  | 73d |  |  | PROF3 PO E [40 h] | 5,529.62 |  |  | S276500 | 0 | 2023 Infrastructure Project Management | S337055 | S276500 | CA | Not Started | C | Yip, Kin | L2 | BNL | Management | Irina Sourikova | null | POM02.2.01.03 |  |  | A | 2.01 | 16721 | 010 | 2.01 | 04 |  | S248100 |  | BNL | Yes | Yes |  |  |
| S277100 |  | 2023 Facility Support Systems L3 Project Management | 5d | 2022-10-03 | 2022-10-07 | S277000 |  |  |  |  | 2d |  |  | PROF2 AD [113 h] | 12,374.89 |  |  | S277100 | 0 | 2023 Facility Support Systems L3 Project Management | S337105 | S277100 | CA | Not Started | C | Yip, Kin | L2 | BNL | Management | Irina Sourikova | null | POM02.2.01.03 |  |  | A | 2.01 | 16721 | 025 | 2.01 | 04 |  | S248100 |  | BNL | Yes | Yes |  |  |

| ID | WBS | Activity | Type | Duration | Start | Finish | Predecessors | Complete | Remaining | Planned start | Planned finish | Total float | Free float | Expected finish | Resources | Cost | BNL_UDF_Exclude | BNL_UDF_Status Comments | BNL_UDF_Temp Text 01 | BNL_UDF_Percent Complete | BNL_UDF_Old Activity ID 181221 | BNL_Cobra WP | RG Check | BNL_Activity Status | BNL_Fund Source | BNL_Estimator | BNL_Cost Basis | BNL_Location | BNL_EDIA | BNL_CAM | BNL_OPC TEC (deprecated) | BNL_WBS | BNL_Actuals | BNL_FY | BNL_EVT | BNL_Master Control Account | BNL_Account Number | BNL_PCR ID | BNL_Cobra Control Account | BNL_WBS_Hierarchical | Completed | Indicator - Procurement | BNL_UDF_OPC TEC (deprecated) | BNL_UDF_Temp Date 01 | BNL_Institution | BNL_Management or Mgmt Travel | Cost = Awarded Proc or Mgmt | BNL_UDF_Adhoc Comments | Major SC Activity | Target Milestone Date | Variance | BNL_Milestone Level | PMP Milestones |
| --- | --- | --- | --- | --- | --- | --- | --- | --- | --- | --- | --- | --- | --- | --- | --- | --- | --- | --- | --- | --- | --- | --- | --- | --- | --- | --- | --- | --- | --- | --- | --- | --- | --- | --- | --- | --- | --- | --- | --- | --- | --- | --- | --- | --- | --- | --- | --- | --- | --- | --- | --- | --- | --- |
|  | 05 | **Installation Management** |  |  | 2017-02-01 | 2022-10-05 |  |  |  |  |  |  |  |  |  |  |  |  |  |  |  |  |  |  |  |  |  |  |  |  |  |  |  |  |  |  |  |  |  |  |  |  |  |  |  |  |  |  |  |  |  |  |  |
| S343900 |  | Actuals - Labor - sPHENIX Integration and Installation FY17 16726 |  | 169d | 2017-02-01 A | 2017-09-29 A | S100090 SS | 100% |  |  |  |  |  |  | Actual Labor [511.29 h] | 85,432.93 | MP6LAEXCLUDE | 190315 DurType to align with EVT | S343900 | 100 | S338460 | S343900 | CA | Completed | C | Feder, Russ | L1 | BNL | Design | Ed O'Brien | null | POM02.2.01.04 | Yes | 2017 | A | 2.01 | 16726 | 003 | 2.01 | 05 | yes |  |  |  |  |  |  |  |  |  |  |  |  |
| S344000 |  | Actuals - Labor - sPHENIX Integration and Installation FY18 16726 |  | 249d | 2017-10-01 A | 2018-09-28 A | S343900, S1000279, S1000319 | 100% |  | 2017-10-02 | 2018-09-28 |  |  |  | Actual Labor [706.97 h] | 118,129.66 | MP6LAEXCLUDE | 190315 DurType to align with EVT | S344000 | 100 | S339420 | S344000 | CA | Completed | C | Feder, Russ | L1 | BNL | Design | Ed O'Brien | null | POM02.2.01.04 | Yes | 2018 | A | 2.01 | 16726 | 003 | 2.01 | 05 | yes |  |  |  |  |  |  |  |  |  |  |  |  |
| S344200 |  | Actuals - Nonlabor - sPHENIX Integration and Installation FY18 16726 16727 and 16728 |  | 249d | 2017-10-01 A | 2018-09-28 A | S344100 | 100% |  | 2017-10-02 | 2018-09-28 |  |  |  | Actual Nonlabor [2700.06 h] | 3,012.22 | MP6LAEXCLUDE | 190315 DurType to align with EVT | S344200 | 100 | S339425 | S344200 | CA | Completed | C | Feder, Russ | M1 | BNL | Design | Ed O'Brien | null | POM02.2.01.04 | Yes | 2018 | A | 2.05 | 16726 | 003 | 2.05 | 05 | yes | UDF_G3 |  |  |  |  |  |  |  |  |  |  |  |
| S277800 |  | 2018 Integration & Installation Project Management |  | 249d | 2017-10-02 A | 2018-09-28 A | S100090 SS | 100% |  |  |  |  |  |  |  |  |  |  | S277800 | 100 | S318700 |  | NOCA | Completed |  | Yip, Kin | L2 | BNL | Management | Ed O'Brien | null | POM02.2.01.04 |  |  | A |  |  |  |  | 05 | yes |  | S318700 | 2018-09-28 | BNL | Yes | Yes |  |  |  |  |  |  |
| S1001079 |  | Actuals - Labor - sPHENIX Integration and Installation FY19 M8 16726 |  | 166d | 2018-10-01 A | 2019-05-31 A |  | 100% |  |  |  |  |  |  | Actual Labor [171.93 h] | 28,728.28 | MP6LAEXCLUDE | 190315 DurType to align with EVT | S344000 | 100 | S339420 | S1001079 | CA | Completed | C | Feder, Russ | L1 | BNL | Design | Ed O'Brien | null | POM02.2.01.04 | Yes | 2019 | A | 2.01 | 16726 | 003 | 2.01 | 05 | yes |  |  |  |  |  |  |  |  |  |  |  |  |
| S277900 |  | 2019 Integration & Installation Project Management |  | 166d | 2018-10-01 A | 2019-05-31 A | S277800 | 100% |  |  |  |  |  |  |  |  |  |  | S277900 | 0 | S337170 |  | NOCA | Completed | C | Yip, Kin | L2 | BNL | Management | Irina Sourikova | null | POM02.2.01.04 |  |  | A |  | 16726 |  |  | 05 | yes |  | S318800 | 2019-09-30 | BNL | Yes | Yes | 180424 ELM rsrc per GRY |  |  |  |  |  |
| S1004760 |  | Actuals - Labor FY19 Jun-Sep 16726 |  | 84d | 2019-06-03 A | 2019-09-30 A |  | 100% |  |  |  |  |  |  | Actual Labor [52.23 h] | 8,727.93 | MP6LAEXCLUDE | 190315 DurType to align with EVT | S344000 | 100 | S339420 | S1004760 | CA | Completed | C | Feder, Russ | L1 | BNL | Design | Ed O'Brien | null | POM02.2.01.04 | Yes | 2019 | A | 2.01 | 16726 | 003 | 2.01 | 05 | yes |  |  |  |  |  |  |  |  |  |  |  |  |
| S277910 |  | 2019 Integration & Installation Project Management Split |  | 64d | 2019-07-01 A | 2019-09-30 A | S277900 | 100% |  |  |  |  |  |  |  |  |  |  | S277900 | 0 | S337170 |  | NOCA | Completed | C | Yip, Kin | L2 | BNL | Management | Irina Sourikova | null | POM02.2.01.04 |  |  | A | 2.01 | 16726 |  |  | 05 |  |  | S318800 | 2019-09-30 | BNL | Yes | Yes | 180424 ELM rsrc per GRY |  |  |  |  |  |
| S278000 |  | 2020 Integration & Installation Project Management |  | 251d | 2019-10-01 A | 2020-09-30 A | S277910 | 100% |  |  |  |  |  |  | PROF5 PO M [880 h]; PROF3 PO E [440 h]; SCI3 PO [440 h] | 281,046.2 |  |  | S278000 | 0 | S337180 | S278000 | CA | In Progress | C | Yip, Kin | L2 | BNL | Management | Irina Sourikova | null | POM02.2.01.04 |  |  | A | 2.01 | 16726 |  | 2.01 | 05 |  |  | S318900 |  | BNL | Yes | Yes | 180424 ELM rsrc per GRY |  |  |  |  |  |
| S278100 |  | 2021 Integration & Installation Project Management |  | 250d | 2020-10-02 A | 2021-09-30 | S278000 | 66% | 86d | 2020-10-02 | 2021-10-01 | 4d | 0d | 2021-09-30 | PROF5 PO M [880 h]; PROF3 PO E [440 h]; SCI3 PO [440 h] | 289,512.33 |  |  | S278100 | 0 | S337190 | S278100 | CA | Not Started | C | Yip, Kin | L2 | BNL | Management | Irina Sourikova | null | POM02.2.01.04 |  |  | A | 2.01 | 16726 |  | 2.01 | 05 |  |  | S319000 |  | BNL | Yes | Yes | 180424 ELM rsrc per GRY |  |  |  |  |  |
| S278200 |  | 2022 Integration & Installation Project Management |  | 250d | 2021-10-01 | 2022-09-30 | S278100 |  |  |  |  | 4d | 0d |  | PROF5 PO M [880 h] | 158,769.53 |  |  | S278200 | 0 | S337200 | S278200 | CA | Not Started | C | Yip, Kin | L2 | BNL | Management | Irina Sourikova | null | POM02.2.01.04 |  |  | A | 2.01 | 16726 |  | 2.01 | 05 |  |  | S319100 |  | BNL | Yes | Yes |  |  |  |  |  |  |
| S278300 |  | 2023 Integration & Installation Project Management |  | 3d | 2022-10-03 | 2022-10-05 | S278200 |  |  |  |  | 4d |  |  | PROF5 PO M [282 h] | 52,404.77 |  |  | S278300 | 0 | S337205 | S278300 | CA | Not Started | C | Yip, Kin | L2 | BNL | Management | Irina Sourikova | null | POM02.2.01.04 |  |  | A | 2.01 | 16726 |  | 2.01 | 05 |  |  | S248100 |  | BNL | Yes | Yes |  |  |  |  |  |  |
|  | 02 | **SC Magnet** |  |  | 2017-02-01 | 2022-08-04 |  |  |  |  |  |  |  |  |  |  |  |  |  |  |  |  |  |  |  |  |  |  |  |  |  |  |  |  |  |  |  |  |  |  |  |  |  |  |  |  |  |  |  |  |  |  |  |
| S278600 |  | Actuals - Nonlabor - sPHENIX Magnet FY17 |  | 169d | 2017-02-01 A | 2017-09-29 A | S100090 SS | 100% |  |  |  |  |  |  |  |  | MP6LAEXCLUDE | 190315 DurType to align with EVT | S278600 | 100 | S339342 |  | NOCA | Completed | C | Yip, Kin | M1 |  | Design | Kin Yip | null | POM02.2.02 | Yes | 2017 | A |  |  | 003 |  | 02 | yes |  |  |  |  |  |  |  |  |  |  |  |  |
|  | 01 | **Safety Reviews, Cooldown, Power Tests** |  |  | 2021-03-08 | 2022-06-13 |  |  |  |  |  |  |  |  |  |  |  |  |  |  |  |  |  |  |  |  |  |  |  |  |  |  |  |  |  |  |  |  |  |  |  |  |  |  |  |  |  |  |  |  |  |  |  |
|  | 01 | **Safety Reviews** |  |  | 2021-03-08 | 2022-05-04 |  |  |  |  |  |  |  |  |  |  |  |  |  |  |  |  |  |  |  |  |  |  |  |  |  |  |  |  |  |  |  |  |  |  |  |  |  |  |  |  |  |  |  |  |  |  |  |
| S278800 |  | LESHC-PSSC Review Cryogenic Safety Review |  | 1d | 2021-03-08 A | 2022-05-04 | S281900, S295200 | 50% | 7d | 2022-05-12 | 2022-05-12 | 0d |  | 2022-05-04 | SCI3 AD [16 h]; PROF4 AM [8 h]; PROF6 AD [16 h] | 7,447.2 |  |  | S278800 | 0 | S248400 | S278800 | CA | Not Started | C | Yip, Kin | L2 | BNL | Management Safety Reviews | Kin Yip | null | POM02.2.02.01.01 |  |  | C | 2.02 | 16730 |  | 2.02 | 01 |  |  | S248400 |  | BNL |  |  |  | Yes |  |  |  |  |
| S278900 |  | LESHC Review Magnet Overall System Safety Review |  | 1d | 2022-05-03 | 2022-05-03 | S281600, S287700, S295200, S300600, S301100, S292310 |  |  |  |  | 0d |  |  | SCI3 AD [16 h]; PROF4 AM [8 h]; PROF6 AD [16 h] | 7,447.2 |  |  | S278900 | 0 | S248500 | S278900 | CA | Not Started | C | Yip, Kin | L2 | BNL | Management Safety Reviews | Kin Yip | null | POM02.2.02.01.01 |  |  | C | 2.02 | 16730 |  | 2.02 | 01 |  |  | S248500 |  | BNL |  |  |  | Yes |  |  |  |  |
| S279000 |  | ASSRC REVIEW and Full Walkthrough |  | 1d | 2022-05-04 | 2022-05-04 | S278900 |  |  |  |  | 0d |  |  | SCI3 AD [16 h]; PROF6 AD [16 h] | 6,197.33 |  |  | S279000 | 0 | S248600 | S279000 | CA | Not Started | C | Yip, Kin | L2 | BNL | Management Safety Reviews | Kin Yip | null | POM02.2.02.01.01 |  |  | C | 2.02 | 16730 |  | 2.02 | 01 |  |  | S248600 |  | BNL |  |  |  | Yes |  |  |  |  |
|  | 02 | **Cooldown & Power Tests** |  |  | 2022-05-05 | 2022-06-13 |  |  |  |  |  |  |  |  |  |  |  |  |  |  |  |  |  |  |  |  |  |  |  |  |  |  |  |  |  |  |  |  |  |  |  |  |  |  |  |  |  |  |  |  |  |  |  |
| S279100 |  | Cooldown |  | 15d | 2022-05-05 | 2022-05-25 | S278800, S278900, S279000, S281600, S287700, S295200, S300600, S301100, S292310, S295310 |  |  |  |  | 0d |  |  | PROF3 AD [60 h]; TECH3 AD [60 h]; PROF6 AD [60 h] | 27,601.94 |  |  | S279100 | 0 | S248700 | S279100 | CA | Not Started | C | Yip, Kin | L2 | BNL | Test_System | Kin Yip | null | POM02.2.02.01.02 |  |  | C | 2.02 | 16730 |  | 2.02 | 02 |  |  | S248700 |  | BNL |  |  |  | Yes |  |  |  |  |
| S279200 |  | 4.5K Static Heat Load test |  | 2d | 2022-05-26 | 2022-05-27 | S279100 |  |  |  |  | 0d |  |  | PROF3 AD [8 h]; TECH3 AD [8 h]; PROF6 AD [8 h] | 3,680.26 |  |  | S279200 | 0 | S248800 | S279200 | CA | Not Started | C | Yip, Kin | L2 | BNL | Test_System | Kin Yip | null | POM02.2.02.01.02 |  |  | C | 2.02 | 16730 |  | 2.02 | 02 |  |  | S248800 |  | BNL |  |  |  | Yes |  |  |  |  |
| S279300 |  | 4.5K Low power test |  | 5d | 2022-05-31 | 2022-06-06 | S279200, S307200, S305010, S305110 |  |  |  |  | 0d |  |  | PROF3 AD [20 h]; SCI3 AD [80 h]; TECH3 AD [80 h]; PROF6 AD [80 h] | 43,356.7 |  |  | S279300 | 0 | S248900 | S279300 | CA | Not Started | C | Yip, Kin | L2 | BNL | Test_System | Kin Yip | null | POM02.2.02.01.02 |  |  | C | 2.02 | 16730 |  | 2.02 | 02 |  |  | S248900 |  | BNL |  |  |  | Yes |  |  |  |  |
| S279400 |  | 4.5K High Power Test |  | 5d | 2022-06-07 | 2022-06-13 | S279300 |  |  |  |  | 0d |  |  | PROF3 AD [20 h]; SCI3 AD [80 h]; TECH3 AD [80 h]; PROF6 AD [80 h] | 43,356.7 |  |  | S279400 | 0 | S249000 | S279400 | CA | Not Started | C | Yip, Kin | L2 | BNL | Test_System | Kin Yip | null | POM02.2.02.01.02 |  |  | C | 2.02 | 16730 |  | 2.02 | 02 |  |  | S249000 |  | BNL |  |  |  | Yes |  |  |  |  |
| S279500 |  | Magnet is operational | milestone | 0d | 2022-06-13 | 2022-06-13 | S278800, S278900, S279000, S279400 |  |  |  |  | 0d |  |  |  |  |  |  | S279500 | 0 | S249100 |  | NOCA | Not Started |  | Yip, Kin |  | BNL | Test_System | Kin Yip |  | POM02.2.02.01.02 |  |  |  |  |  |  |  | 02 |  |  | S249100 |  | BNL |  |  |  | Yes | 2022-07-31 | 33 | L3 | PMP_2x |

Notes:
- S343900: BNL_UDF_Old Activity Name 181221: Actuals - Labor - sPHENIX Integration and Installation FY17
- S344000: BNL_UDF_Old Activity Name 181221: Actuals - Labor - sPHENIX Integration and Installation FY18
- S344200: BNL_UDF_Old Activity Name 181221: Actuals - Nonlabor - sPHENIX Integration and Installation FY18
- S277800: BNL_UDF_Old Activity Name 181221: 2018 Integration & Installation Project Management
- S1001079: BNL_UDF_Old Activity Name 181221: Actuals - Labor - sPHENIX Integration and Installation FY18
- S277900: BNL_UDF_Old Activity Name 181221: 2019 Integration & Installation Project Management
- S1004760: BNL_UDF_Old Activity Name 181221: Actuals - Labor - sPHENIX Integration and Installation FY18
- S277910: BNL_UDF_Old Activity Name 181221: 2019 Integration & Installation Project Management
- S278000: BNL_UDF_Old Activity Name 181221: 2020 Integration & Installation Project Management
- S278100: BNL_UDF_Old Activity Name 181221: 2021 Integration & Installation Project Management
- S278200: BNL_UDF_Old Activity Name 181221: 2022 Integration & Installation Project Management
- S278300: BNL_UDF_Old Activity Name 181221: 2023 Integration & Installation Project Management
- S278600: BNL_UDF_Old Activity Name 181221: Actuals - Nonlabor - sPHENIX Magnet FY17
- S278800: BNL_UDF_Old Activity Name 181221: LESHC-PSSC Review Cryogenic Safety Review
- S278900: BNL_UDF_Old Activity Name 181221: LESHC Review Magnet overall system Safety Review
- S279000: BNL_UDF_Old Activity Name 181221: ASSRC REVIEW and Full Walkthrough
- S279100: BNL_UDF_Old Activity Name 181221: Cooldown
- S279200: BNL_UDF_Old Activity Name 181221: 4.5K Static Heat Load test
- S279300: BNL_UDF_Old Activity Name 181221: 4.5K Low power test
- S279400: BNL_UDF_Old Activity Name 181221: 4.5K High Power Test
- S279500: BNL_UDF_Old Activity Name 181221: Magnet is operational

| ID | WBS | Activity | Type | Duration | Start | Finish | Predecessors | Complete | Planned start | Planned finish | Total float | Free float | Resources | Cost | BNL_UDF_Exclude | BNL_UDF_Status Comments | BNL_UDF_Temp Text 01 | BNL_UDF_Percent Complete | BNL_UDF_Old Activity ID 181221 | BNL_Cobra WP | RG Check | BNL_Activity Status | BNL_Fund Source | BNL_Estimator | BNL_Cost Basis | BNL_EDIA | BNL_CAM | BNL_OPC TEC (deprecated) | BNL_WBS | BNL_Actuals | BNL_FY | BNL_EVT | BNL_Master Control Account | BNL_Account Number | BNL_PCR ID | BNL_Cobra Control Account | BNL_WBS_Hierarchical | Completed | Indicator - Procurement | BNL_UDF_OPC TEC (deprecated) | BNL_Location | BNL_Institution | Additional EVT documentation required | BNL_Proc Sig Phase | BNL_Proc Sig | Major SC Activity | BNL_Obligation | SPH Proc Register | BNL_Milestone Level | Target Milestone Date | Variance | PMP Milestones |
| --- | --- | --- | --- | --- | --- | --- | --- | --- | --- | --- | --- | --- | --- | --- | --- | --- | --- | --- | --- | --- | --- | --- | --- | --- | --- | --- | --- | --- | --- | --- | --- | --- | --- | --- | --- | --- | --- | --- | --- | --- | --- | --- | --- | --- | --- | --- | --- | --- | --- | --- | --- | --- |
|  | 02 | **Magnet Transport & Assembly** |  |  | 2017-02-01 | 2021-12-07 |  |  |  |  |  |  |  |  |  |  |  |  |  |  |  |  |  |  |  |  |  |  |  |  |  |  |  |  |  |  |  |  |  |  |  |  |  |  |  |  |  |  |  |  |  |  |
| S1000039 |  | Actuals - Labor - sPHENIX Magnet FY17 16717 |  | 169d | 2017-02-01 A | 2017-09-29 A | S100090 SS | 100% |  |  |  |  | Actual Labor [5.8 h] | 968.97 | MP6LAEXCLUDE | 190315 DurType to align with EVT | S278400 | 100 | S338540 | S1000039 | CA | Completed | C | Yip, Kin | L1 | Design | Kin Yip | null | POM02.2.02.01 | Yes | 2017 | A | 2.02 | 16717 | 003 | 2.02 | 02 | yes |  |  |  |  |  |  |  |  |  |  |  |  |  |  |
| S1001239 |  | Actuals - Labor - sPHENIX Magnet FY19 M8 16717 |  | 166d | 2018-10-01 A | 2019-05-31 A |  | 100% |  |  |  |  | Actual Labor [3.04 h] | 507.96 | MP6LAEXCLUDE | 190315 DurType to align with EVT | S278500 | 100 | S339340 | S1001239 | CA | Completed | C | Yip, Kin | L1 | Design | Kin Yip | null | POM02.2.02.01 | Yes | 2019 | A | 2.02 | 16717 | 003 | 2.02 | 02 | yes |  |  |  |  |  |  |  |  |  |  |  |  |  |  |
| S1001279 |  | Actuals - NonLabor - sPHENIX Magnet FY19 M8 16717 |  | 166d | 2018-10-01 A | 2019-05-31 A |  | 100% |  |  |  |  | Actual Nonlabor [2857.28 h] | 3,152.34 | MP6LAEXCLUDE | 190315 DurType to align with EVT | S278500 | 100 | S339340 | S1001279 | CA | Completed | C | Yip, Kin | L1 | Design | Kin Yip | null | POM02.2.02.01 | Yes | 2019 | A | 2.02 | 16717 | 003 | 2.02 | 02 | yes | UDF_G3 |  |  |  |  |  |  |  |  |  |  |  |  |  |
| S279600 |  | [Magnet] Preliminary Engineering Transport Tooling and Misc. Parts |  | 31d | 2019-01-02 A | 2019-02-14 A | S100090 SS | 100% |  |  |  |  |  |  |  |  | S279600 | 100 | S249200 |  | NOCA | Completed | C | Yip, Kin | L2 | Design | Kin Yip | null | POM02.2.02.02 |  |  | C |  | 16717 |  |  | 02 | yes |  | S249200 | BNL | BNL |  |  |  |  |  |  |  |  |  |  |
| S279700 |  | [Magnet] Preliminary Safety and Design Review |  | 29d | 2019-03-01 A | 2019-04-10 A | S279600 | 100% |  |  |  |  |  |  |  |  | S279700 | 0 | S249300 |  | NOCA | Completed | C | Yip, Kin | L2 | Management Safety Reviews | Kin Yip | null | POM02.2.02.02 |  |  | C |  | 16717 |  |  | 02 | yes |  | S249300 | BNL | BNL |  |  |  |  |  |  |  |  |  |  |
| S279800 |  | [Magnet] Final Design (Magnet Transport) |  | 11d | 2019-05-06 A | 2019-05-20 A | S279700 | 100% |  |  |  |  |  |  |  |  | S279800 | 0 | S249400 |  | NOCA | Completed | C | Yip, Kin | L2 | Design | Kin Yip | null | POM02.2.02.02 |  |  | C |  | 16717 |  |  | 02 | yes |  | S249400 | BNL | BNL | Yes |  |  |  |  |  |  |  |  |  |
| S1004360 |  | Actuals - Labor FY19 Jun-Sep 16717 |  | 84d | 2019-06-03 A | 2019-09-30 A |  | 100% |  |  |  |  | Actual Labor [42.45 h] | 7,093.43 | MP6LAEXCLUDE | 190315 DurType to align with EVT | S278500 | 100 | S339340 | S1004360 | CA | Completed | C | Yip, Kin | L1 | Design | Kin Yip | null | POM02.2.02.01 | Yes | 2019 | A | 2.02 | 16717 | 003 | 2.02 | 02 | yes |  |  |  |  |  |  |  |  |  |  |  |  |  |  |
| S1004400 |  | Actuals - NonLabor FY19 Jun-Sep 16717 |  | 84d | 2019-06-03 A | 2019-09-30 A |  | 100% |  |  |  |  | Actual Nonlabor [19415.9 h] | 21,420.87 | MP6LAEXCLUDE | 190315 DurType to align with EVT | S278500 | 100 | S339340 | S1004400 | CA | Completed | C | Yip, Kin | L1 | Design | Kin Yip | null | POM02.2.02.01 | Yes | 2019 | A | 2.02 | 16717 | 003 | 2.02 | 02 | yes | UDF_G3 |  |  |  |  |  |  |  |  |  |  |  |  |  |
| S279900 |  | [Magnet] Final Design Review (Magnet Transport) |  | 5d | 2019-06-03 A | 2019-06-07 A | S279800 | 100% |  |  |  |  |  |  |  |  | S279900 | 0 | S249500 |  | NOCA | Completed | C | Yip, Kin | L2 | Design | Kin Yip | null | POM02.2.02.02 |  |  | C | 2.02 | 16717 |  |  | 02 |  |  | S249500 | BNL | BNL |  |  |  |  |  |  |  |  |  |  |
| S280000 |  | [Magnet] Procure Parts (for disassembly, transport & reassembly) - Provide requirements to Procurement |  | 5d | 2019-06-10 A | 2019-06-14 A | S279900 | 100% |  |  |  |  |  |  |  |  | S280000 | 0 | S249700 |  | NOCA | Completed | C | Yip, Kin | M7 | Fab & Assy | Kin Yip | null | POM02.2.02.02 |  |  | C | 2.02 | 16717 |  |  | 02 |  |  | S249700 | BNL | BNL |  | PP1 | MP203204 | Yes |  |  |  |  |  |  |
| S280100 |  | [Magnet] Procure Parts (for disassembly, transport & reassembly) - Prepare & Send Solicitation |  | 10d | 2019-06-17 A | 2019-06-28 A | S279900, S280000 | 100% |  |  |  |  |  |  |  |  | S280100 | 0 | S249705 |  | NOCA | Completed | C | Yip, Kin | M7 | Fab & Assy | Kin Yip | null | POM02.2.02.02 |  |  | C |  |  |  |  | 02 |  |  | S249700 | BNL | BNL |  | PP2 | MP203204 |  |  |  |  |  |  |  |
| S280200 |  | [Magnet] Procure Parts (for disassembly, transport & reassembly) - Vendor Responses |  | 10d | 2019-07-01 A | 2019-07-15 A | S280100 | 100% |  |  |  |  |  |  |  |  | S280200 | 0 | S249710 |  | NOCA | Completed | C | Yip, Kin | M7 | Fab & Assy | Kin Yip | null | POM02.2.02.02 |  |  | C |  |  |  |  | 02 |  |  | S249700 | BNL | BNL |  | PP3 | MP203204 |  |  |  |  |  |  |  |
| S280300 |  | [Magnet] Procure Parts (for disassembly, transport & reassembly) - Vendor Selection |  | 10d | 2019-07-16 A | 2019-07-29 A | S280200 | 100% |  |  |  |  |  |  |  |  | S280300 | 0 | S249715 |  | NOCA | Completed | C | Yip, Kin | M7 | Fab & Assy | Kin Yip | null | POM02.2.02.02 |  |  | C |  |  |  |  | 02 |  |  | S249700 | BNL | BNL |  | PP4 | MP203204 |  |  |  |  |  |  |  |
| S280600 |  | [Magnet] Procure Parts (for disassembly, transport & reassembly) - Delivery Acceptance |  | 10d | 2019-07-17 A | 2019-07-31 A | S279900, S280500 FF | 100% | 2019-07-17 | 2019-07-30 |  |  |  |  |  |  | S280600 | 0 | S249790 |  | NOCA | Completed | C | Yip, Kin | M7 | Fab & Assy | Kin Yip | null | POM02.2.02.02 |  |  | C | 2.02 | 16717 |  |  | 02 |  |  | S249700 | BNL | BNL |  | PP6 | MP203204 | Yes | FAB | Delivery |  |  |  |  |
| S280500 |  | [Magnet] Procure Parts (for disassembly, transport & reassembly) - Leadtime |  | 60d | 2019-07-30 A | 2019-07-31 A | S280400, OBLG280410 | 100% | 2019-07-31 | 2019-10-24 |  |  |  |  |  |  | S280500 | 0 | S249725 |  | NOCA | Completed | C | Yip, Kin | M7 | Fab & Assy | Kin Yip | null | POM02.2.02.02 |  |  | C |  |  |  |  | 02 |  |  | S249700 | BNL | BNL |  | PP6 | MP203204 |  |  |  |  |  |  |  |
| OBLG280410 |  | [Magnet] Procure Parts (for disassembly, transport & reassembly) - Obligation |  | 1d | 2019-07-30 A | 2019-07-30 A | S280300 | 100% |  |  |  |  | Obligation Resource [45517 h] | 45,517.03 |  |  | S280400 | 0 | S249720 |  |  | Completed | C | Yip, Kin | M7 | Fab & Assy | Kin Yip | null | POM02.2.02.02 |  |  | C |  |  |  |  | 02 |  |  | S249700 | BNL | BNL |  | PP5 | MP203204 |  | OBLG |  |  |  |  |  |
| S280400 |  | [Magnet] Procure Parts (for disassembly, transport & reassembly) - Contract Award | milestone | 0d | 2019-07-30 A | 2019-07-30 A | S280300 | 100% |  |  |  |  |  |  |  |  | S280400 | 0 | S249720 |  | NOCA | Completed | C | Yip, Kin | M7 | Fab & Assy | Kin Yip | null | POM02.2.02.02 |  |  | K |  |  |  |  | 02 |  |  | S249700 | BNL | BNL |  | PP5 | MP203204 | Yes |  | Contract Award | L5 |  |  |  |
| S280700 |  | [Magnet] Assemble and Prepare Parts (Magnet Transport) Labor |  | 10d | 2019-08-01 A | 2019-08-14 A | S280600 | 100% |  |  |  |  |  |  |  |  | S280700 | 0 | S249800 |  | NOCA | Completed | C | Yip, Kin | L7 | Fab & Assy | Kin Yip | null | POM02.2.02.02 |  |  | C | 2.02 | 16717 |  |  | 02 |  |  | S249800 | BNL | BNL |  |  |  |  |  |  |  |  |  |  |
| S280800 |  | [Magnet] Assemble and Prepare Parts (Magnet Transport) M&S |  | 9d | 2019-08-01 A | 2019-08-14 A | S280600 | 100% | 2019-08-01 | 2019-08-13 |  |  |  |  |  |  | S280800 | 0 | S249900 |  | NOCA | Completed | C | Yip, Kin | M7 | Fab & Assy | Kin Yip | null | POM02.2.02.02 |  |  | C | 2.02 | 16717 |  |  | 02 |  |  | S249900 | BNL | BNL |  |  |  |  |  |  |  |  |  |  |
| S280900 |  | Solenoid Valvebox - Start Disassembly | milestone | 0d | 2019-08-15 A | 2019-08-15 A | S280700, S280800 | 100% |  |  |  |  |  |  |  |  | S280900 | 0 | S250000 |  | NOCA | Completed | C | Yip, Kin |  | Fab & Assy | Kin Yip |  | POM02.2.02.02 |  |  |  |  |  |  |  | 02 |  |  | S250000 | BNL | BNL |  |  |  | Yes |  |  | L5 |  |  |  |
| S281000 |  | Solenoid Valvebox - Disassemble Labor |  | 12d | 2019-08-15 A | 2019-08-30 A | S280900 | 100% |  |  |  |  |  |  |  |  | S281000 | 0 | S250100 |  | NOCA | Completed | C | Yip, Kin | L7 | Fab & Assy | Kin Yip | null | POM02.2.02.02 |  |  | C | 2.02 | 16717 |  |  | 02 |  |  | S250100 | BNL | BNL |  |  |  |  |  |  |  |  |  |  |
| S281100 |  | Solenoid Valvebox - Disassemble M&S |  | 11d | 2019-08-15 A | 2019-08-30 A | S280900 | 100% | 2019-08-15 | 2019-08-29 |  |  |  |  |  |  | S281100 | 0 | S250200 |  | NOCA | Completed | C | Yip, Kin | M7 | Fab & Assy | Kin Yip | null | POM02.2.02.02 |  |  | C | 2.02 | 16717 |  |  | 02 |  |  | S250200 | BNL | BNL |  |  |  |  |  |  |  |  |  |  |
| S281200 |  | Magnet - Prepare for Coil Shipment - Shipping Constraints and Tooling |  | 38d | 2019-10-01 A | 2019-12-30 A | S281000, S281100 | 100% | 2019-11-01 | 2019-12-30 |  |  | TECH3 AM [160 h]; PROF4 AM [16 h] | 20,615.78 |  |  | S281200 | 0 | S250300 | S281200 | CA | In Progress | C | Yip, Kin | L2 | Fab & Assy | Kin Yip | null | POM02.2.02.02 |  |  | C | 2.02 | 16717 |  | 2.02 | 02 |  |  | S250300 | BNL | BNL |  |  |  |  |  |  |  |  |  |  |
| S281300 |  | Magnet - Coil Ready to Ship | milestone | 0d | 2020-01-07 A | 2020-01-07 A | S281200 FS+4d | 100% |  |  |  |  |  |  |  |  | S281300 | 0 | S250400 |  | NOCA | Not Started |  | Yip, Kin |  | Fab & Assy | Kin Yip |  | POM02.2.02.02 |  |  |  |  |  |  |  | 02 |  |  | S250400 | BNL | BNL |  |  |  | Yes |  |  | L4 |  |  |  |
| S281400 |  | Magnet and Solenoid Valvebox - Reinstall |  | 25d | 2021-10-15 | 2021-11-19 | S281300, S353500, S353600, S353510 |  |  |  | 15d | 0d | TECH3 AM [400 h]; PROF4 AM [40 h] | 54,678.21 |  |  | S281400 | 0 | S250500 | S281400 | CA | Not Started | C | Yip, Kin | L2 | Fab & Assy | Kin Yip | null | POM02.2.02.02 |  |  | C | 2.02 | 16717 |  | 2.02 | 02 |  |  | S250500 | BNL | BNL |  |  |  |  |  |  |  |  |  |  |
| S281410 |  | Completed - Magnet and Solenoid Valvebox - Reinstall | milestone | 0d | 2021-11-19 | 2021-11-19 | S281400 FF |  |  |  | 15d | 0d |  |  |  |  | S281400 | 0 | S250500 |  | NOCA | Not Started |  | Yip, Kin |  | Fab & Assy | Kin Yip |  | POM02.2.02.02 |  |  |  |  |  |  |  | 02 |  |  | S250500 | BNL | BNL |  |  |  |  |  |  | L5 | 2022-01-31 | 45 | PMP_2x |
| S281500 |  | Magnet - Readjust Coil and Remove Shipping Tooling |  | 10d | 2021-11-22 | 2021-12-07 | S281410 |  |  |  | 15d | 0d | TECH3 AM [160 h]; PROF4 AM [16 h] | 21,871.28 |  |  | S281500 | 0 | S250600 | S281500 | CA | Not Started | C | Yip, Kin | L2 | Fab & Assy | Kin Yip | null | POM02.2.02.02 |  |  | C | 2.02 | 16717 |  | 2.02 | 02 |  |  | S250600 | BNL | BNL |  |  |  |  |  |  |  |  |  |  |
| S281600 |  | Magnet - Solenoid Valvebox - Complete, Ready for Cryo Connections | milestone | 0d | 2021-12-07 | 2021-12-07 | S281500 |  |  |  | 15d |  |  |  |  |  | S281600 | 0 | S250700 |  | NOCA | Not Started | C | Yip, Kin |  | Fab & Assy | Kin Yip |  | POM02.2.02.02 |  |  |  |  |  |  |  | 02 |  |  | S250700 | BNL | BNL |  |  |  | Yes |  |  | L5 |  |  |  |

Notes:
- 02: 180814 RFG Changed WBS title from Mechanical Disassembly, Transport Prep. / And Reassembly of Valve Box
- S1000039: BNL_UDF_Old Activity Name 181221: Actuals - Labor - sPHENIX Magnet FY17
- S1001239: BNL_UDF_Old Activity Name 181221: Actuals - Labor - sPHENIX Magnet FY18
- S1001279: BNL_UDF_Old Activity Name 181221: Actuals - Labor - sPHENIX Magnet FY18
- S279600: BNL_UDF_Old Activity Name 181221: Magnet - Preliminary Engineering Transport Tooling and Misc. Parts
- S279700: BNL_UDF_Old Activity Name 181221: Magnet - Preliminary Safety and Design Review
- S279800: BNL_UDF_Old Activity Name 181221: Magnet - Final Design (Magnet Transport)
- S1004360: BNL_UDF_Old Activity Name 181221: Actuals - Labor - sPHENIX Magnet FY18
- S1004400: BNL_UDF_Old Activity Name 181221: Actuals - Labor - sPHENIX Magnet FY18
- S279900: BNL_UDF_Old Activity Name 181221: Magnet - Final Design Review (Magnet Transport)
- S280000: BNL_UDF_Old Activity Name 181221: Magnet - Procure Parts (for disassembly, transport & reassembly) - Provide requirements to Procurement
- S280100: BNL_UDF_Old Activity Name 181221: Magnet - Procure Parts (for disassembly, transport & reassembly) - Prepare & Send Solicitation
- S280200: BNL_UDF_Old Activity Name 181221: Magnet - Procure Parts (for disassembly, transport & reassembly) - Vendor Responses
- S280300: BNL_UDF_Old Activity Name 181221: Magnet - Procure Parts (for disassembly, transport & reassembly) - Vendor Selection
- S280600: BNL_UDF_Old Activity Name 181221: Magnet - Procure Parts (for disassembly, transport & reassembly) - Delivery Acceptance
- S280500: BNL_UDF_Old Activity Name 181221: Magnet - Procure Parts (for disassembly, transport & reassembly) - Leadtime
- OBLG280410: BNL_UDF_Old Activity Name 181221: Magnet - Procure Parts (for disassembly, transport & reassembly) - Contract Award
- S280400: BNL_UDF_Old Activity Name 181221: Magnet - Procure Parts (for disassembly, transport & reassembly) - Contract Award
- S280700: BNL_UDF_Old Activity Name 181221: Magnet - Assemble and Prepare Parts (Magnet Transport) Labor
- S280800: BNL_UDF_Old Activity Name 181221: Magnet - Assemble and Prepare Parts (Magnet Transport) M&S
- S280900: BNL_UDF_Old Activity Name 181221: Solenoid Valvebox - Start Disassembly
- S281000: BNL_UDF_Old Activity Name 181221: Solenoid Valvebox - Disassemble Labor
- S281100: BNL_UDF_Old Activity Name 181221: Solenoid Valvebox - Disassemble M&S
- S281200: BNL_UDF_Old Activity Name 181221: Magnet - Prepare for Coil Shipment - Shipping Constraints and Tooling
- S281300: BNL_UDF_Old Activity Name 181221: Magnet - Coil Ready to Ship
- S281400: BNL_UDF_Old Activity Name 181221: Magnet and Solenoid Valvebox - Reinstall
- S281410: BNL_UDF_Old Activity Name 181221: Magnet and Solenoid Valvebox - Reinstall
- S281500: BNL_UDF_Old Activity Name 181221: Magnet - Readjust Coil and Remove Shipping Tooling
- S281600: BNL_UDF_Old Activity Name 181221: Magnet - Solenoid Valvebox - Complete, Ready for Cryo Connections

| ID | WBS | Activity | Type | Duration | Start | Finish | Predecessors | Complete | Planned start | Planned finish | Resources | Cost | BNL_UDF_Exclude | BNL_UDF_Status Comments | BNL_UDF_Temp Text 01 | BNL_UDF_Percent Complete | BNL_UDF_Old Activity ID 181221 | BNL_Cobra WP | RG Check | BNL_Activity Status | BNL_Fund Source | BNL_Estimator | BNL_Cost Basis | BNL_EDIA | BNL_CAM | BNL_OPC TEC (deprecated) | BNL_WBS | BNL_Actuals | BNL_FY | BNL_EVT | BNL_Master Control Account | BNL_Account Number | BNL_PCR ID | BNL_Cobra Control Account | BNL_WBS_Hierarchical | Completed | Indicator - Procurement | BNL_UDF_Adhoc Comments | BNL_UDF_OPC TEC (deprecated) | BNL_UDF_Temp Date 01 | BNL_Location | BNL_Institution | BNL_WBS Manager | Major SC Activity | BNL_Milestone Level | Additional EVT documentation required |
| --- | --- | --- | --- | --- | --- | --- | --- | --- | --- | --- | --- | --- | --- | --- | --- | --- | --- | --- | --- | --- | --- | --- | --- | --- | --- | --- | --- | --- | --- | --- | --- | --- | --- | --- | --- | --- | --- | --- | --- | --- | --- | --- | --- | --- | --- | --- |
|  | 03 | **Magnet Cryogenic Systems** |  |  | 2017-02-01 | 2022-05-02 |  |  |  |  |  |  |  |  |  |  |  |  |  |  |  |  |  |  |  |  |  |  |  |  |  |  |  |  |  |  |  |  |  |  |  |  |  |  |  |  |
| S1000079 |  | Actuals - Labor - sPHENIX Magnet FY17 16718 |  | 169d | 2017-02-01 A | 2017-09-29 A | S100090 SS | 100% |  |  | Actual Labor [15.52 h] | 2,592.95 | MP6LAEXCLUDE | 190315 DurType to align with EVT | S278400 | 100 | S338540 | S1000079 | CA | Completed | C | Yip, Kin | L1 | Design | Kin Yip | null | POM02.2.02.03 | Yes | 2017 | A | 2.02 | 16718 | 003 | 2.02 | 03 | yes |  |  |  |  |  |  |  |  |  |  |
| S1000159 |  | Actuals - Labor - sPHENIX Magnet FY18 16718 |  | 249d | 2017-10-02 A | 2018-09-28 A | S278400, S1000039, S1000079, S1000119 | 100% |  |  | Actual Labor [821.5 h] | 137,266.81 | MP6LAEXCLUDE | 190315 DurType to align with EVT | S278500 | 100 | S339340 | S1000159 | CA | Completed | C | Yip, Kin | L1 | Design | Kin Yip | null | POM02.2.02.03 | Yes | 2018 | A | 2.02 | 16718 | 003 | 2.02 | 03 | yes |  |  |  |  |  |  |  |  |  |  |
| S1001319 |  | Actuals - Labor - sPHENIX Magnet FY19 M8 16718 |  | 166d | 2018-10-01 A | 2019-05-31 A |  | 100% |  |  | Actual Labor [1602 h] | 267,682.81 | MP6LAEXCLUDE | 190315 DurType to align with EVT | S278500 | 100 | S339340 | S1001319 | CA | Completed | C | Yip, Kin | L1 | Design | Kin Yip | null | POM02.2.02.03 | Yes | 2019 | A | 2.02 | 16718 | 003 | 2.02 | 03 | yes |  |  |  |  |  |  |  |  |  |  |
| S1001359 |  | Actuals - NonLabor - sPHENIX Magnet FY19 M8 16718 |  | 166d | 2018-10-01 A | 2019-05-31 A |  | 100% |  |  | Actual Nonlabor [13285.6 h] | 14,657.49 | MP6LAEXCLUDE | 190315 DurType to align with EVT | S278500 | 100 | S339340 | S1001359 | CA | Completed | C | Yip, Kin | L1 | Design | Kin Yip | null | POM02.2.02.03 | Yes | 2019 | A | 2.02 | 16718 | 003 | 2.02 | 03 | yes | UDF_G3 |  |  |  |  |  |  |  |  |  |
| S1004440 |  | Actuals - Labor FY19 Jun-Sep 16718 |  | 84d | 2019-06-03 A | 2019-09-30 A |  | 100% |  |  | Actual Labor [271.69 h] | 45,398.14 | MP6LAEXCLUDE | 190315 DurType to align with EVT | S278400 | 100 | S338540 | S1004440 | CA | Completed | C | Yip, Kin | L1 | Design | Kin Yip | null | POM02.2.02.03 | Yes | 2017 | A | 2.02 | 16718 | 003 | 2.02 | 03 | yes |  |  |  |  |  |  |  |  |  |  |
| S1004480 |  | Actuals - NonLabor FY19 Jun-Sep 16718 |  | 84d | 2019-06-03 A | 2019-09-30 A |  | 100% |  |  | Actual Nonlabor [17881.6 h] | 19,728.14 | MP6LAEXCLUDE | 190315 DurType to align with EVT | S278400 | 100 | S338540 | S1004480 | CA | Completed | C | Yip, Kin | L1 | Design | Kin Yip | null | POM02.2.02.03 | Yes | 2017 | A | 2.02 | 16718 | 003 | 2.02 | 03 | yes | UDF_G3 |  |  |  |  |  |  |  |  |  |
|  | 01 | **Helium System: 1008BColdbox, Transferlines, & IR8 Coldbox** |  |  | 2017-02-01 | 2022-04-25 |  |  |  |  |  |  |  |  |  |  |  |  |  |  |  |  |  |  |  |  |  |  |  |  |  |  |  |  |  |  |  |  |  |  |  |  |  |  |  |  |
|  | 01 | **Engineering and Design** |  |  | 2017-02-01 | 2019-06-21 |  |  |  |  |  |  |  |  |  |  |  |  |  |  |  |  |  |  |  |  |  |  |  |  |  |  |  |  |  |  |  |  |  |  |  |  |  |  |  |  |
| S281700 |  | Cryo System - Process Design |  | 390d | 2017-02-01 A | 2018-08-20 A | S100090 SS | 100% |  |  |  |  |  |  | S281700 | 100 | S250800 |  | NOCA | Completed | C | Yip, Kin | L4 | Design | Kin Yip | null | POM02.2.02.03.01.01 |  |  | C |  |  |  |  | 01 | yes |  | 180404 ELM pred | S250800 | 2018-08-20 | BNL | BNL | Than, Roberto |  |  |  |
| S281800 |  | Cryo System - P&ID development & drawings |  | 387d | 2017-02-01 A | 2018-08-15 A | S100090 SS | 100% |  |  |  |  |  |  | S281800 | 100 | S250900 |  | NOCA | Completed | C | Yip, Kin | L4 | Design | Kin Yip | null | POM02.2.02.03.01.01 |  |  | C |  |  |  |  | 01 | yes |  |  | S250900 | 2018-08-15 | BNL | BNL | Than, Roberto |  |  |  |
| S282000 |  | RHIC Helium Interface - Mechanical Engineering Design Tasks FY18 |  | 148d | 2018-03-02 A | 2018-09-28 A | S281700 FF | 100% |  |  |  |  |  |  | S282000 | 100 | S251100 |  | NOCA | Completed | C | Yip, Kin | L4 | Design | Kin Yip | null | POM02.2.02.03.01.01 |  |  | C |  |  |  |  | 01 | yes |  |  | S251100 | 2018-10-18 | BNL | BNL | Than, Roberto |  |  |  |
| S281900 |  | Cryo System - ODH Analysis |  | 10d | 2019-01-02 A | 2019-01-15 A | S281800 | 100% |  |  |  |  |  |  | S281900 | 100 | S251000 |  | NOCA | Completed | C | Yip, Kin | L4 | Design | Kin Yip | null | POM02.2.02.03.01.01 |  |  | C |  | 16718 |  |  | 01 | yes |  |  | S251000 | 2018-12-01 | BNL | BNL | Than, Roberto |  |  |  |
| S282100 |  | RHIC Helium Interface - Mechanical Engineering Design Tasks FY19 |  | 94d | 2019-01-02 A | 2019-05-15 A | S282000 | 100% |  |  |  |  |  |  | S282100 | 90 | S251150 |  | NOCA | Completed | C | Yip, Kin | L4 | Design | Kin Yip | null | POM02.2.02.03.01.01 |  |  | C |  | 16718 |  |  | 01 | yes |  |  | S251100 | 2019-03-08 | BNL | BNL | Than, Roberto |  |  |  |
| S282200 |  | Cryo System - SOW & Technical Specifications |  | 43d | 2019-01-22 A | 2019-03-22 A | S281700, S281800, S274900, S282100 | 100% |  |  |  |  |  |  | S282200 | 75 | S251200 |  | NOCA | Completed | C | Yip, Kin | L4 | Design | Kin Yip | null | POM02.2.02.03.01.01 |  |  | C |  | 16718 |  |  | 01 | yes |  |  | S251200 | 2019-03-14 | BNL | BNL | Than, Roberto |  |  |  |
| S282400 |  | Cryo System - Final Tech Design Review with Pressure Cryo Safety Subcommittee (PCSS) |  | 1d | 2019-06-03 A | 2019-06-03 A | S282300 SS | 100% |  |  |  |  |  |  | S282400 | 0 | S251350 |  | NOCA | Completed | C | Yip, Kin |  | Procurement | Kin Yip |  | POM02.2.02.03.01.01 |  |  |  |  |  |  |  | 01 |  |  |  | S251300 |  | BNL | BNL | Than, Roberto | Yes |  |  |
| S282410 |  | Completed: Cryo System - Final Tech Design Review with Pressure Cryo Safety Subcommittee (PCSS) | milestone | 0d | 2019-06-03 A | 2019-06-03 A | S282400 FF | 100% |  |  |  |  |  |  | S282400 | 0 | S251350 |  | NOCA | Completed | C | Yip, Kin |  | Procurement | Kin Yip |  | POM02.2.02.03.01.01 |  |  |  |  |  |  |  | 01 |  |  |  | S251300 |  | BNL | BNL | Than, Roberto | Yes | L3 |  |
| S282300 |  | Cryo System - Bid package Helium System | milestone | 0d | 2019-06-21 A | 2019-06-21 A | S282200, S282900 | 100% | 2019-06-03 | 2019-06-03 |  |  |  |  | S282300 | 0 | S251300 |  | NOCA | Completed | C | Yip, Kin |  | Procurement | Kin Yip |  | POM02.2.02.03.01.01 |  |  |  |  |  |  |  | 01 |  |  |  | S251300 |  | BNL | BNL | Than, Roberto | Yes | L3 |  |
|  | 02 | **Design/Drafting** |  |  | 2018-03-02 | 2019-04-22 |  |  |  |  |  |  |  |  |  |  |  |  |  |  |  |  |  |  |  |  |  |  |  |  |  |  |  |  |  |  |  |  |  |  |  |  |  |  |  |  |
| S282500 |  | Helium Lines Routing from 1008B to IP8 hall and LN2 line routing from dewar to IP8 Hall. |  | 129d | 2018-03-02 A | 2018-08-31 A | S281800 FF | 100% |  |  |  |  |  |  | S282500 | 100 | S251400 |  | NOCA | Completed | C | Yip, Kin | L4 | Design | Kin Yip | null | POM02.2.02.03.01.02 |  |  | C |  |  |  |  | 02 | yes |  |  | S251400 | 2018-09-01 | BNL | BNL | Than, Roberto |  |  |  |
| S282600 |  | RHIC interface valvebox and field joint layout at the interconnect where we tie into RHIC VJ lines and modeling FY18 |  | 148d | 2018-03-02 A | 2018-09-28 A | S282500 FF | 100% |  |  |  |  |  |  | S282600 | 100 | S251500 |  | NOCA | Completed | C | Yip, Kin | L4 | Design | Kin Yip | null | POM02.2.02.03.01.02 |  |  | C |  |  |  |  | 02 | yes |  |  | S251500 | 2018-10-01 | BNL | BNL | Than, Roberto |  |  |  |
| S282700 |  | RHIC interface valvebox and field joint layout at the interconnect where we tie into RHIC VJ lines and modeling FY19 |  | 77d | 2019-01-02 A | 2019-04-22 A | S282600 | 100% |  |  |  |  |  | 190317 ELM corrected dur & RA per GRY | S282700 | 90 | S251550 |  | NOCA | Completed | C | Yip, Kin | L4 | Design | Kin Yip | null | POM02.2.02.03.01.02 |  |  | C |  | 16718 | 003 |  | 02 | yes |  |  | S251500 | 2019-03-22 | BNL | BNL | Than, Roberto |  |  |  |
| S282800 |  | Transfer line system from 1008B to IP8 hall, detail layout |  | 76d | 2019-01-03 A | 2019-04-22 A | S282700 | 100% |  |  |  |  |  |  | S282800 | 90 | S251600 |  | NOCA | Completed | C | Yip, Kin | L4 | Design | Kin Yip | null | POM02.2.02.03.01.02 |  |  | C |  | 16718 |  |  | 02 | yes |  |  | S251600 | 2019-03-22 | BNL | BNL | Than, Roberto |  |  |  |
| S282900 |  | RHIC Helium Interface - Detailed drawing package for Procurement |  | 47d | 2019-02-14 A | 2019-04-22 A | S282800 | 100% |  |  |  |  |  |  | S282900 | 50 | S251700 |  | NOCA | Completed | C | Yip, Kin | L4 | Design | Kin Yip | null | POM02.2.02.03.01.02 |  |  | C |  | 16718 |  |  | 02 | yes |  |  | S251700 | 2019-03-29 | BNL | BNL | Than, Roberto | Yes |  | Yes |

Notes:
- S1000079: BNL_UDF_Old Activity Name 181221: Actuals - Labor - sPHENIX Magnet FY17
- S1000159: BNL_UDF_Old Activity Name 181221: Actuals - Labor - sPHENIX Magnet FY18
- S1001319: BNL_UDF_Old Activity Name 181221: Actuals - Labor - sPHENIX Magnet FY18
- S1001359: BNL_UDF_Old Activity Name 181221: Actuals - Labor - sPHENIX Magnet FY18
- S1004440: BNL_UDF_Old Activity Name 181221: Actuals - Labor - sPHENIX Magnet FY17
- S1004480: BNL_UDF_Old Activity Name 181221: Actuals - Labor - sPHENIX Magnet FY17
- S281700: BNL_UDF_Old Activity Name 181221: Cryo System - Process Design
- S281800: BNL_UDF_Old Activity Name 181221: Cryo System - P&ID development&drawings
- S282000: BNL_UDF_Old Activity Name 181221: RHIC Helium Interface - Mechanical Engineering Design Tasks FY18
- S281900: BNL_UDF_Old Activity Name 181221: Cryo System - ODH Analysis
- S282100: BNL_UDF_Old Activity Name 181221: RHIC Helium Interface - Mechanical Engineering Design Tasks FY19
- S282200: BNL_UDF_Old Activity Name 181221: Cryo System - SOW & Technical Specifications
- S282400: BNL_UDF_Old Activity Name 181221: Cryo System - Final Tech Design Review with Pressure Cryo Safety Subcommittee (PCSS)
- S282410: BNL_UDF_Old Activity Name 181221: Cryo System - Final Tech Design Review with Pressure Cryo Safety Subcommittee (PCSS)
- S282300: BNL_UDF_Old Activity Name 181221: Cryo System - Bid package Helium System
- S282500: BNL_UDF_Old Activity Name 181221: Helium Lines Routing from 1008B to IP8 hall and LN2 line routing from dewar to IP8 Hall.
- S282600: BNL_UDF_Old Activity Name 181221: RHIC interface valvebox and field joint layout at the interconnect where we tie into RHIC VJ lines and modeling FY18
- S282700: BNL_UDF_Old Activity Name 181221: RHIC interface valvebox and field joint layout at the interconnect where we tie into RHIC VJ lines and modeling FY19
- S282800: BNL_UDF_Old Activity Name 181221: Transfer line system from 1008B to IP8 hall, detail layout
- S282900: BNL_UDF_Old Activity Name 181221: RHIC Helium Interface - Detailed drawing package for Procurement

| ID | WBS | Activity | Type | Duration | Start | Finish | Predecessors | Complete | Planned start | Planned finish | Constraint | Resources | Cost | BNL_UDF_Temp Text 01 | BNL_UDF_Percent Complete | BNL_UDF_OPC TEC (deprecated) | RG Check | BNL_Activity Status | BNL_Fund Source | BNL_Estimator | BNL_Cost Basis | BNL_Location | BNL_EDIA | BNL_Proc Sig Phase | BNL_Proc Sig | BNL_CAM | BNL_Institution | BNL_OPC TEC (deprecated) | BNL_WBS | BNL_WBS Manager | BNL_EVT | BNL_Master Control Account | BNL_Account Number | BNL_WBS_Hierarchical | BNL_UDF_Old Activity ID 181221 | Temp | BNL_UDF_Temp Text 02 | BNL_Milestone Level | SPH Proc Register | Major SC Activity | BNL_Obligation | BNL_Cobra WP | Indicator - Procurement | Indicator - Float | BNL_Cobra Control Account | BNL_UDF_Remaining Tot Cost | BNL_UDF_Percent_remaining |
| --- | --- | --- | --- | --- | --- | --- | --- | --- | --- | --- | --- | --- | --- | --- | --- | --- | --- | --- | --- | --- | --- | --- | --- | --- | --- | --- | --- | --- | --- | --- | --- | --- | --- | --- | --- | --- | --- | --- | --- | --- | --- | --- | --- | --- | --- | --- | --- |
|  | 03 | **Procurement** |  |  | 2019-06-04 | 2020-03-02 |  |  |  |  |  |  |  |  |  |  |  |  |  |  |  |  |  |  |  |  |  |  |  |  |  |  |  |  |  |  |  |  |  |  |  |  |  |  |  |  |  |
| S282980 |  | RHIC Helium Interface - Procurement Readiness Review |  | 5d | 2019-06-04 A | 2019-06-10 A | S282200, S282300, S282900, S282410 | 100% |  |  |  |  |  | S283000 | 0 | S251800 | NOCA | Completed | C | Yip, Kin | L4 | BNL | Procurement | PP1 | MP210001 | Kin Yip | BNL | null | POM02.2.02.03.01.03 | Than, Roberto | C | 2.02 | 16718 | 03 |  |  |  |  |  |  |  |  |  |  |  |  |  |
| S283000 |  | Procure RHIC Helium Interface - Provide Requirements to Procurement - Physics Resource(s) |  | 4d | 2019-07-24 A | 2019-07-29 A | S101000, S282980 | 100% |  |  |  |  |  | PO&AD | 0 | S251800 | NOCA | Completed | C | Yip, Kin | L4 | BNL | Procurement | PP1 | MP210001 | Kin Yip | BNL | null | POM02.2.02.03.01.03 | Than, Roberto | C | 2.02 | 16718 | 03 | S251800 | PO |  |  |  |  |  |  |  |  |  |  |  |
| S283010 |  | Procure RHIC Helium Interface - Provide Requirements to Procurement - CA-D Resource(s) |  | 4d | 2019-07-24 A | 2019-07-29 A | S283000 SS | 100% |  |  |  |  |  | PO&ADS283010 | 0 | S251800 | NOCA | Completed | C | Yip, Kin | L4 | BNL | Procurement | PP1 | MP210001 | Kin Yip | BNL | null | POM02.2.02.03.01.03 | Than, Roberto | C | 2.02 | 16718 | 03 | S251800 | C-AD | S283010 |  |  |  |  |  |  |  |  |  |  |
| S283100 |  | Procure RHIC Helium Interface - Prepare & Send Solicitation |  | 30d | 2019-07-30 A | 2019-07-31 A | S283000, S283010 | 100% | 2019-07-31 | 2019-09-11 |  |  |  | S283100 | 0 | S251800 | NOCA | Completed | C | Yip, Kin | L4 | BNL | Procurement | PP2 | MP210001 | Kin Yip | BNL | null | POM02.2.02.03.01.03 | Than, Roberto | C | 2.02 |  | 03 | S277592844 |  |  |  |  |  |  |  |  |  |  |  |  |
| S283200 |  | Procure RHIC Helium Interface - Vendor Responses & Selection |  | 17d | 2019-10-01 A | 2019-10-23 A | S283100 | 100% | 2019-11-01 | 2019-11-26 | start on or after 2019-08-13 |  |  | S283200 | 0 | S251800 | NOCA | Completed | C | Yip, Kin | L4 | BNL | Procurement | PP3 | MP210001 | Kin Yip | BNL | null | POM02.2.02.03.01.03 | Than, Roberto | C | 2.02 |  | 03 | S277592884 |  |  |  |  |  |  |  |  |  |  |  |  |
| S283300 |  | Procure RHIC Helium Interface - Contract Award | milestone | 0d | 2019-10-24 A | 2019-10-24 A | S283200 | 100% | 2019-11-27 | 2019-11-27 |  |  |  | S283300 | 0 | S251800 | NOCA | Completed | C | Yip, Kin | L4 | BNL | Procurement | PP5 | MP210001 | Kin Yip | BNL | null | POM02.2.02.03.01.03 | Than, Roberto | F |  |  | 03 | S277592924 |  |  | L5 | Contract Award | Yes |  |  |  |  |  |  |  |
| S283400 |  | Procure RHIC Helium Interface, Phase 2 (Long Lead Items) - Contract Award | milestone | 0d | 2019-10-24 A | 2019-10-24 A | S283200 | 100% | 2019-11-27 | 2019-11-27 |  |  |  | S283400 | 0 | S251800 | NOCA | Completed | C | Yip, Kin | L4 | BNL | Procurement | PP5 | MP210002 | Kin Yip | BNL | null | POM02.2.02.03.01.03 | Than, Roberto | F |  |  | 03 | S277593004 |  |  | L5 | Contract Award | Yes |  |  |  |  |  |  |  |
| S283500 |  | Procure RHIC Helium Interface, Phase 3 (Final Design Review) - Contract Award | milestone | 0d | 2019-10-24 A | 2019-10-24 A | S283200 | 100% | 2019-11-27 | 2019-11-27 |  |  |  | S283500 | 0 | S251800 | NOCA | Completed | C | Yip, Kin | L4 | BNL | Procurement | PP5 | MP210003 | Kin Yip | BNL | null | POM02.2.02.03.01.03 | Than, Roberto | F |  |  | 03 | S277594004 |  |  | L5 | Contract Award | Yes |  |  |  |  |  |  |  |
| S283600 |  | Procure RHIC Helium Interface, Phase 4 (Drawings Approvals) - Contract Award | milestone | 0d | 2019-10-24 A | 2019-10-24 A | S283200 | 100% | 2019-11-27 | 2019-11-27 |  |  |  | S283600 | 0 | S251800 | NOCA | Completed | C | Yip, Kin | L4 | BNL | Procurement | PP5 | MP210004 | Kin Yip | BNL | null | POM02.2.02.03.01.03 | Than, Roberto | F |  |  | 03 | S277594044 |  |  | L5 | Contract Award | Yes |  |  |  |  |  |  |  |
| S283700 |  | Procure RHIC Helium Interface, Phase 5 (Raw Materials) - Contract Award | milestone | 0d | 2019-10-24 A | 2019-10-24 A | S283200 | 100% | 2019-11-27 | 2019-11-27 |  |  |  | S283700 | 0 | S251800 | NOCA | Completed | C | Yip, Kin | L4 | BNL | Procurement | PP5 | MP210005 | Kin Yip | BNL | null | POM02.2.02.03.01.03 | Than, Roberto | F |  |  | 03 | S277594084 |  |  | L5 | Contract Award | Yes |  |  |  |  |  |  |  |
| S283800 |  | Procure RHIC Helium Interface, Phase 6 (BNL Holdpoint Witness) - Contract Award | milestone | 0d | 2019-10-24 A | 2019-10-24 A | S283200 | 100% | 2019-11-27 | 2019-11-27 |  |  |  | S283800 | 0 | S251800 | NOCA | Completed | C | Yip, Kin | L4 | BNL | Procurement | PP5 | MP210006 | Kin Yip | BNL | null | POM02.2.02.03.01.03 | Than, Roberto | F |  |  | 03 | S277594124 |  |  | L5 | Contract Award | Yes |  |  |  |  |  |  |  |
| S283900 |  | Procure RHIC Helium Interface, Phase 7 (Shipping) - Contract Award | milestone | 0d | 2019-10-24 A | 2019-10-24 A | S283200 | 100% | 2019-11-27 | 2019-11-27 |  |  |  | S283900 | 0 | S251800 | NOCA | Completed | C | Yip, Kin | L4 | BNL | Procurement | PP5 | MP210007 | Kin Yip | BNL | null | POM02.2.02.03.01.03 | Than, Roberto | F |  |  | 03 | S277594164 |  |  | L5 | Contract Award | Yes |  |  |  |  |  |  |  |
| OBLG283310 |  | Procure RHIC Helium Interface, Phase 1 (Detailed Drawing Package) - Obligation |  | 1d | 2020-03-02 A | 2020-03-02 A |  | 100% |  |  |  |  |  | S283300 | 0 | S251800 |  | Not Started | C | Yip, Kin | L4 | BNL | Procurement | PP5 | MP210001 | Kin Yip | BNL | null | POM02.2.02.03.01.03 | Than, Roberto | F |  |  | 03 | S277592924 |  |  |  |  |  | OBLG |  |  |  |  |  |  |
| OBLG283410 |  | Procure RHIC Helium Interface, Phase 2 (Long Lead Items) - Obligation |  | 1d | 2020-03-02 A | 2020-03-02 A | S283200 | 100% |  |  |  |  |  | S283400 | 0 | S251800 |  | Not Started | C | Yip, Kin | L4 | BNL | Procurement | PP5 | MP210002 | Kin Yip | BNL | null | POM02.2.02.03.01.03 | Than, Roberto | F |  |  | 03 | S277593004 |  |  |  |  |  | OBLG |  |  |  |  |  |  |
| OBLG283510 |  | Procure RHIC Helium Interface, Phase 3 (Final Design Review) - Obligation |  | 1d | 2020-03-02 A | 2020-03-02 A | S283200 | 100% |  |  |  |  |  | S283500 | 0 | S251800 |  | Not Started | C | Yip, Kin | L4 | BNL | Procurement | PP5 | MP210003 | Kin Yip | BNL | null | POM02.2.02.03.01.03 | Than, Roberto | F |  |  | 03 | S277594004 |  |  |  |  |  | OBLG |  |  |  |  |  |  |
| OBLG283610 |  | Procure RHIC Helium Interface, Phase 4 (Drawings Approvals) - Obligation |  | 1d | 2020-03-02 A | 2020-03-02 A | S283200 | 100% |  |  |  |  |  | S283600 | 0 | S251800 |  | Not Started | C | Yip, Kin | L4 | BNL | Procurement | PP5 | MP210004 | Kin Yip | BNL | null | POM02.2.02.03.01.03 | Than, Roberto | F |  |  | 03 | S277594044 |  |  |  |  |  | OBLG |  |  |  |  |  |  |
| OBLG283710 |  | Procure RHIC Helium Interface, Phase 5 (Raw Materials) - Obligation |  | 1d | 2020-03-02 A | 2020-03-02 A | S283200 | 100% |  |  |  |  |  | S283700 | 0 | S251800 |  | Not Started | C | Yip, Kin | L4 | BNL | Procurement | PP5 | MP210005 | Kin Yip | BNL | null | POM02.2.02.03.01.03 | Than, Roberto | F |  |  | 03 | S277594084 |  |  |  |  |  | OBLG |  |  |  |  |  |  |
| OBLG283810 |  | Procure RHIC Helium Interface, Phase 6 (BNL Holdpoint Witness) - Obligation |  | 1d | 2020-03-02 A | 2020-03-02 A | S283200 | 100% |  |  |  |  |  | S283800 | 0 | S251800 |  | Not Started | C | Yip, Kin | L4 | BNL | Procurement | PP5 | MP210006 | Kin Yip | BNL | null | POM02.2.02.03.01.03 | Than, Roberto | F |  |  | 03 | S277594124 |  |  |  |  |  | OBLG |  |  |  |  |  |  |
| OBLG283910 |  | Procure RHIC Helium Interface, Phase 7 (Shipping) - Obligation |  | 1d | 2020-03-02 A | 2020-03-02 A | S283200 | 100% |  |  |  |  |  | S283900 | 0 | S251800 |  | Not Started | C | Yip, Kin | L4 | BNL | Procurement | PP5 | MP210007 | Kin Yip | BNL | null | POM02.2.02.03.01.03 | Than, Roberto | F |  |  | 03 | S277594164 |  |  |  |  |  | OBLG |  |  |  |  |  |  |
|  | 04 | **Vendor Manufacturing - Helium System: 1008B Coldbox, Transferlines, & IR8 Coldbox** |  |  | 2019-10-23 | 2022-01-13 |  |  |  |  |  |  |  |  |  |  |  |  |  |  |  |  |  |  |  |  |  |  |  |  |  |  |  |  |  |  |  |  |  |  |  |  |  |  |  |  |  |
|  | 01 | **Group 1** |  |  | 2019-11-20 | 2021-05-31 |  |  |  |  |  |  |  |  |  |  |  |  |  |  |  |  |  |  |  |  |  |  |  |  |  |  |  |  |  |  |  |  |  |  |  |  |  |  |  |  |  |
|  | 01 | **5 Multiple Process Line Cryogenixc Spools** |  |  | 2019-11-20 | 2020-09-30 |  |  |  |  |  |  |  |  |  |  |  |  |  |  |  |  |  |  |  |  |  |  |  |  |  |  |  |  |  |  |  |  |  |  |  |  |  |  |  |  |  |
| S1005160 |  | AET submits PDR report to BNL for approval of Multiple Transfer Line Spools and Field Joint Sleeve |  | 20d | 2019-11-20 A | 2020-01-15 A | S284220 | 100% | 2019-12-17 | 2020-01-15 |  |  |  |  |  |  | NOCA | In Progress | C |  |  |  | Procurement |  |  | Kin Yip |  |  |  |  |  |  | 16718 | 01 |  |  |  |  |  |  |  | rg |  |  |  |  |  |
| S1005200 |  | BNL review for PDR approval |  | 10d | 2020-01-16 A | 2020-02-27 A | S1005160 | 100% | 2020-01-16 | 2020-01-30 |  | Material (Purchase (1st $2M) [23484.9 h] | 26,200.08 |  |  |  | CA | Not Started | C |  |  |  | Procurement |  |  | Kin Yip |  |  |  |  | C |  | 16718 | 01 |  |  |  |  |  |  |  | S1005200 | UDF_G2 | UDF_G3 | 2.02 |  |  |
| S1005240 |  | AET submits IDR to BNL for approval |  | 10d | 2020-01-31 A | 2020-03-12 A | S1005200 | 100% | 2020-01-31 | 2020-02-13 |  |  |  |  |  |  | NOCA | Not Started | C |  |  |  | Procurement |  |  | Kin Yip |  |  |  |  |  |  | 16718 | 01 |  |  |  |  |  |  |  | rg |  |  |  |  |  |
| S1005260 |  | BNL review for IDR approval |  | 5d | 2020-03-13 A | 2020-04-10 A | S1005240 | 100% | 2020-03-13 | 2020-03-19 |  | Material (Purchase (1st $2M) [23484.9 h] | 26,200.08 |  |  |  | CA | Not Started | C |  |  |  | Procurement |  |  | Kin Yip |  |  |  |  | C |  | 16718 | 01 |  |  |  |  |  |  |  | S1005260 | UDF_G2 | UDF_G3 | 2.02 |  |  |
| S1005280 |  | AET submits FDR report to BNL for approval |  | 20d | 2020-04-13 A | 2020-05-08 A | S1005260 | 100% |  |  |  | Material (Purchase (1st $2M) [70454.7 h] | 78,600.24 |  |  |  | CA | Not Started | C |  |  |  | Procurement |  |  | Kin Yip |  |  |  |  | C |  | 16718 | 01 |  |  |  |  |  |  |  | S1005280 | UDF_G2 | UDF_G3 | 2.02 | 7860.023818 | 0.1 |
| S1005320 |  | AET begins material procurement |  | 5d | 2020-05-11 A | 2020-05-15 A | S1005280 | 100% |  |  |  |  |  |  |  |  | NOCA | Not Started | C |  |  |  | Procurement |  |  | Kin Yip |  |  |  |  |  |  | 16718 | 01 |  |  |  |  |  |  |  | rg |  |  |  |  |  |
| S1005360 |  | Fabricate Multiple Transfer Line Spool 4 & 5 |  | 35d | 2020-05-18 A | 2020-08-05 A | S1005320 | 100% | 2020-05-18 | 2020-07-07 |  |  |  |  |  |  | NOCA | Not Started | C |  |  |  | Procurement |  |  | Kin Yip |  |  |  |  |  |  | 16718 | 01 |  |  |  |  |  |  |  | rg |  |  |  |  |  |
| S1005400 |  | Fabricate Multiple Transfer Line Spool 1, 2, 3, and Field Joint Sleeve |  | 35d | 2020-07-31 A | 2020-09-18 A | S1005360 | 100% |  |  |  |  |  |  |  |  | NOCA | Not Started | C |  |  |  | Procurement |  |  | Kin Yip |  |  |  |  |  |  | 16718 | 01 |  |  |  |  |  |  |  | rg |  |  |  |  |  |
| S1005440 |  | Delivery Multiple Transfer Line Spool 4 & 5 with Document Package |  | 5d | 2020-07-31 A | 2020-09-30 A | S1005360 | 100% | 2020-07-31 | 2020-08-06 |  |  |  |  |  |  | NOCA | Not Started | C |  |  |  | Procurement |  |  | Kin Yip |  |  |  |  |  |  | 16718 | 01 |  |  |  |  |  |  |  | rg |  |  |  |  |  |
| S1005480 |  | Delivery Multiple Transfer Line Spool 1, 2, 3, and Field Joint Sleeve with Document Package |  | 5d | 2020-08-20 A | 2020-09-30 A | S1005400 FS+20d | 100% | 2020-10-20 | 2020-10-26 |  |  |  |  |  |  | NOCA | Not Started | C |  |  |  | Procurement |  |  | Kin Yip |  |  |  |  |  |  | 16718 | 01 |  |  |  |  |  |  |  | rg |  |  |  |  |  |

Notes:
- S282980: BNL_UDF_Old Activity Name 181221: Procure RHIC Helium Interface - Provide Requirements to Procurement
- S283000: BNL_UDF_Old Activity Name 181221: Procure RHIC Helium Interface - Provide Requirements to Procurement
- S283010: BNL_UDF_Old Activity Name 181221: Procure RHIC Helium Interface - Provide Requirements to Procurement
- S283100: BNL_UDF_Old Activity Name 181221: Procure RHIC Helium Interface - Prepare & Send Solicitation
- S283200: BNL_UDF_Old Activity Name 181221: Procure RHIC Helium Interface - Vendor Responses & Selection
- S283300: BNL_UDF_Old Activity Name 181221: Procure RHIC Helium Interface - Contract Award - Phase 1 - Detailed Drawing Package
- S283400: BNL_UDF_Old Activity Name 181221: Procure RHIC Helium Interface - Contract Award - Phase 2 - Long Lead Items
- S283500: BNL_UDF_Old Activity Name 181221: Procure RHIC Helium Interface - Contract Award - Phase 3 - Final Design Review
- S283600: BNL_UDF_Old Activity Name 181221: Procure RHIC Helium Interface - Contract Award - Phase 4 - Drawings Approvals
- S283700: BNL_UDF_Old Activity Name 181221: Procure RHIC Helium Interface - Contract Award - Phase 5 - Raw Materials
- S283800: BNL_UDF_Old Activity Name 181221: Procure RHIC Helium Interface - Contract Award - Phase 6 - BNL Holdpoint Witness
- S283900: BNL_UDF_Old Activity Name 181221: Procure RHIC Helium Interface - Contract Award - Phase 7 - Shipping
- OBLG283310: BNL_UDF_Old Activity Name 181221: Procure RHIC Helium Interface - Contract Award - Phase 1 - Detailed Drawing Package
- OBLG283410: BNL_UDF_Old Activity Name 181221: Procure RHIC Helium Interface - Contract Award - Phase 2 - Long Lead Items
- OBLG283510: BNL_UDF_Old Activity Name 181221: Procure RHIC Helium Interface - Contract Award - Phase 3 - Final Design Review
- OBLG283610: BNL_UDF_Old Activity Name 181221: Procure RHIC Helium Interface - Contract Award - Phase 4 - Drawings Approvals
- OBLG283710: BNL_UDF_Old Activity Name 181221: Procure RHIC Helium Interface - Contract Award - Phase 5 - Raw Materials
- OBLG283810: BNL_UDF_Old Activity Name 181221: Procure RHIC Helium Interface - Contract Award - Phase 6 - BNL Holdpoint Witness
- OBLG283910: BNL_UDF_Old Activity Name 181221: Procure RHIC Helium Interface - Contract Award - Phase 7 - Shipping

| ID | WBS | Activity | Duration | Start | Finish | Predecessors | Complete | Remaining | Planned start | Planned finish | Total float | Free float | Constraint | Expected finish | Resources | Cost | BNL_Cobra WP | RG Check | BNL_Activity Status | BNL_Fund Source | BNL_EDIA | BNL_CAM | BNL_Account Number | BNL_PCR ID | BNL_WBS_Hierarchical | Indicator - Procurement | Indicator - Float | BNL_UDF_Remaining Tot Cost | BNL_UDF_Percent_remaining | BNL_EVT | BNL_Cobra Control Account |
| --- | --- | --- | --- | --- | --- | --- | --- | --- | --- | --- | --- | --- | --- | --- | --- | --- | --- | --- | --- | --- | --- | --- | --- | --- | --- | --- | --- | --- | --- | --- | --- |
|  | 02 | **3 Interconnect Spools, Vaccum Break, Field Joint Tee and Sleeve** |  | 2020-03-02 | 2020-11-06 |  |  |  |  |  |  |  |  |  |  |  |  |  |  |  |  |  |  |  |  |  |  |  |  |  |  |
| S1005520 |  | AET submits PDR to BNL for approval of S,H,U Interconnect, vac. break, Field Joint Tee and Sleeve | 20d | 2020-03-02 A | 2020-05-26 A | S284220 FS+49d | 100% |  | 2020-03-02 | 2020-03-27 |  |  |  |  |  |  | rg | NOCA | Not Started | C | Procurement | Kin Yip | 16718 | 008C | 02 |  |  |  |  |  |  |
| S1005560 |  | BNL review for PDR approval | 5d | 2020-05-27 A | 2020-06-02 A | S1005520 | 100% |  |  |  |  |  |  |  | Material (Purchase (1st $2M) [31313.2 h] | 34,933.44 | S1005560 | CA | Not Started | C | Procurement | Kin Yip | 16718 |  | 02 | UDF_G1 | UDF_G3 | 34933.440431 | 1 | C | 2.02 |
| S1005600 |  | AET submits IDR to BNL for approval | 5d | 2020-06-03 A | 2020-07-10 A | S1005560 | 100% |  | 2020-06-03 | 2020-06-09 |  |  |  |  |  |  | rg | NOCA | Not Started | C | Procurement | Kin Yip | 16718 |  | 02 |  |  |  |  |  |  |
| S1005620 |  | BNL review for IDR approval | 5d | 2020-06-10 A | 2020-07-13 A | S1005600 | 100% |  | 2020-06-10 | 2020-06-16 |  |  |  |  | Material (Purchase (1st $2M) [31313.2 h] | 34,933.44 | S1005620 | CA | Not Started | C | Procurement | Kin Yip | 16718 |  | 02 | UDF_G1 | UDF_G3 | 34933.440431 | 1 | C | 2.02 |
| S1005640 |  | AET submits FDR report to BNL for approval | 10d | 2020-06-17 A | 2020-07-27 A | S1005620 | 100% |  | 2020-06-17 | 2020-06-30 |  |  |  |  | Material (Purchase (1st $2M) [70454.7 h] | 78,600.24 | S1005640 | CA | Not Started | C | Procurement | Kin Yip | 16718 |  | 02 | UDF_G1 | UDF_G3 | 78600.23818 | 1 | C | 2.02 |
| S1005680 |  | AET begins material procurement | 40d | 2020-07-28 A | 2020-09-30 A | S1005640 | 100% |  | 2020-07-28 | 2020-09-22 |  |  |  |  |  |  | rg | NOCA | Not Started | C | Procurement | Kin Yip | 16718 |  | 02 |  |  |  |  |  |  |
| S1005720 |  | Fabricate Interconnect (S-Line, H-Line, U-Line), vacuum break, Field Joint Tee and Sleeve | 20d | 2020-09-22 A | 2020-10-28 A | S1005680 FS+80d | 100% |  | 2021-02-01 | 2021-03-01 |  |  |  |  |  |  | rg | NOCA | Not Started | C | Procurement | Kin Yip | 16718 |  | 02 |  |  |  |  |  |  |
| S1005760 |  | Delivery Interconnect (S-Line, H-Line, U-Line), vacuum break, Field Joint Tee and Sleeve | 5d | 2020-11-02 A | 2020-11-06 A | S1005720 | 100% |  |  |  |  |  |  |  | Material (Purchase (1st $2M) [93939.6 h] | 104,800.31 | S1005760 | CA | Not Started | C | Procurement | Kin Yip | 16718 |  | 02 | UDF_G2 | UDF_G3 | 104800.310136 | 1 | C | 2.02 |
|  | 03 | **Service Building 1008B Cold Box** |  | 2020-03-02 | 2021-05-31 |  |  |  |  |  |  |  |  |  |  |  |  |  |  |  |  |  |  |  |  |  |  |  |  |  |  |
| S1005800 |  | Draft PDR report of 1008B Cold Box Assembly. (Preliminary Layout) | 20d | 2020-03-02 A | 2020-10-01 A | S1005520 SS | 100% |  | 2020-03-02 | 2020-03-27 |  |  |  |  |  |  | rg | NOCA | Not Started | C | Procurement | Kin Yip | 16718 |  | 03 |  |  |  |  |  |  |
| S1005840 |  | AET submits PDR report to BNL for approval of 1008B Cold Box Assembly | 30d | 2020-09-22 A | 2020-09-30 A | S1005800 | 100% |  | 2020-10-01 | 2020-11-13 |  |  | start on or after 2020-03-30 |  |  |  | rg | NOCA | Not Started | C | Procurement | Kin Yip | 16718 | 008C | 03 |  |  |  |  |  |  |
| S1005880 |  | BNL review for PDR approval | 10d | 2020-10-01 A | 2020-10-15 A | S1005840 | 100% |  |  |  |  |  |  |  | Material (Purchase (1st $2M) [23484.9 h] | 26,200.08 | S1005880 | CA | Not Started | C | Procurement | Kin Yip | 16718 | 012 | 03 | UDF_G3 | UDF_G3 | 26200.083112 | 1 | C | 2.02 |
| S1005920 |  | AET to procure long lead items | 5d | 2020-10-16 A | 2020-10-22 A | S1005880 | 100% |  |  |  |  |  |  |  |  |  | rg | NOCA | Not Started | C | Procurement | Kin Yip | 16718 |  | 03 |  |  |  |  |  |  |
| S1005960 |  | AET submits IDR to BNL for approval | 10d | 2020-12-01 A | 2020-12-14 A | S1005920 | 100% |  |  |  |  |  |  |  |  |  | rg | NOCA | Not Started | C | Procurement | Kin Yip | 16718 |  | 03 |  |  |  |  |  |  |
| S1006000 |  | BNL review for IDR approval | 10d | 2020-12-15 A | 2020-12-29 A | S1005960 | 100% |  |  |  |  |  |  |  | Material (Purchase (1st $2M) [23484.9 h] | 26,200.08 | S1006000 | CA | Not Started | C | Procurement | Kin Yip | 16718 |  | 03 | UDF_G2 | UDF_G3 | 26200.083112 | 1 | C | 2.02 |
| S1006040 |  | AET submits FDR report to BNL for approval | 20d | 2021-01-04 A | 2021-01-27 A | S1006000 | 100% |  | 2021-01-04 | 2021-02-01 |  |  |  |  | Material (Purchase (1st $2M) [93939.6 h] | 104,800.31 | S1006040 | CA | Not Started | C | Procurement | Kin Yip | 16718 |  | 03 | UDF_G2 | UDF_G3 | 104800.310136 | 1 | C | 2.02 |
| S1006080 |  | AET begins material procurement | 5d | 2021-01-19 A | 2021-02-26 A | S1006040 | 100% |  | 2021-02-02 | 2021-02-08 |  |  |  |  |  |  | rg | NOCA | Not Started | C | Procurement | Kin Yip | 16718 |  | 03 |  |  |  |  |  |  |
| S1006120 |  | Fabricate the 1008B Cold Box | 50d | 2021-01-19 A | 2021-05-28 A | S1006080 | 100% |  | 2021-02-09 | 2021-04-20 |  |  |  |  |  |  | rg | NOCA | Not Started | C | Fab & Assy | Kin Yip | 16718 |  | 03 |  |  |  |  |  |  |
| S1006160 |  | Witness test 1008B Cold Box Assembly | 5d | 2021-04-21 A | 2021-04-27 A | S1006120 | 100% |  |  |  |  |  |  |  |  |  | rg | NOCA | Not Started | C | Procurement | Kin Yip | 16718 |  | 03 |  |  |  |  |  |  |
| S1006200 |  | Delivery of the 1008B Cold Box and Document Package | 5d | 2021-04-28 A | 2021-05-31 A | S1006160 | 100% |  | 2021-04-28 | 2021-05-04 |  |  |  |  | Material (Purchase (1st $2M) [93939.6 h] | 104,800.31 | S1006200 | CA | Not Started | C | Procurement | Kin Yip | 16718 |  | 03 | UDF_G2 | UDF_G3 | 104800.310136 | 1 | C | 2.02 |
|  | 02 | **Group 2** |  | 2021-01-11 | 2022-01-13 |  |  |  |  |  |  |  |  |  |  |  |  |  |  |  |  |  |  |  |  |  |  |  |  |  |  |
|  | 01 | **IP8 Cold Box** |  | 2021-01-11 | 2021-12-28 |  |  |  |  |  |  |  |  |  |  |  |  |  |  |  |  |  |  |  |  |  |  |  |  |  |  |
| S1006240 |  | AET submits PDR report to BNL for approval of IP8 Cold Box Assembly | 45d | 2021-01-11 A | 2021-07-02 |  | 15% | 24d | 2021-01-11 | 2021-03-16 | 1d | 0d | start on or after 2021-01-11 | 2021-07-02 |  |  | S1006240 | NOCA | Not Started | C | Procurement | Kin Yip | 16718 | 012 | 01 |  |  |  |  |  |  |
| S1006280 |  | BNL review for PDR approval | 10d | 2021-07-06 | 2021-07-19 | S1006240 |  |  |  |  | 1d | 0d |  |  | Material (Purchase (1st $2M) [31313.2 h] | 34,933.44 | S1006280 | CA | Not Started | C | Design | Kin Yip | 16718 |  | 01 | UDF_G1 | UDF_G1 | 34933.440431 | 1 | C | 2.02 |
| S1006320 |  | AET to procure long lead items | 5d | 2021-07-20 | 2021-07-26 | S1006280 |  |  |  |  | 31d | 30d |  |  |  |  | rg | NOCA | Not Started | C | Procurement | Kin Yip | 16718 |  | 01 |  |  |  |  |  |  |
| S1006360 |  | AET submits IDR to BNL for approval | 10d | 2021-07-20 | 2021-08-02 | S1006280 |  |  |  |  | 1d | 0d |  |  |  |  | rg | NOCA | Not Started | C | Procurement | Kin Yip | 16718 |  | 01 |  |  |  |  |  |  |
| S1006400 |  | BNL review for IDR approval | 5d | 2021-08-03 | 2021-08-09 | S1006360 |  |  |  |  | 1d | 0d |  |  | Material (Purchase (1st $2M) [31313.2 h] | 34,933.44 | S1006400 | CA | Not Started | C | Procurement | Kin Yip | 16718 |  | 01 | UDF_G1 | UDF_G1 | 34933.440431 | 1 | C | 2.02 |
| S1006440 |  | AET submits FDR report to BNL for approval | 20d | 2021-08-10 | 2021-09-07 | S1006400 |  |  |  |  | 1d | 0d |  |  | Material (Purchase (1st $2M) [125253 h] | 139,733.75 | S1006440 | CA | Not Started | C | Procurement | Kin Yip | 16718 |  | 01 | UDF_G1 | UDF_G1 | 139733.750566 | 1 | C | 2.02 |
| S1006480 |  | AET begins material procurement | 5d | 2021-09-08 | 2021-09-14 | S1006440, S1006320 |  |  |  |  | 1d | 0d |  |  |  |  | rg | NOCA | Not Started | C | Procurement | Kin Yip | 16718 |  | 01 |  |  |  |  |  |  |
| S1006520 |  | Fabricate the IP8 Cold Box Assembly | 60d | 2021-09-15 | 2021-12-13 | S1006480 |  |  |  |  | 1d | 0d |  |  |  |  | rg | NOCA | Not Started | C | Procurement | Kin Yip | 16718 |  | 01 |  |  |  |  |  |  |
| S1006560 |  | Witness test IP8 Cold Box Assembly | 5d | 2021-12-14 | 2021-12-20 | S1006520 |  |  |  |  | 1d | 0d |  |  |  |  | rg | NOCA | Not Started | C | Procurement | Kin Yip | 16718 |  | 01 |  |  |  |  |  |  |
| S1006600 |  | Delivery of the IP8 Cold Box Assembly and Document Package | 5d | 2021-12-21 | 2021-12-28 | S1006560 |  |  |  |  | 1d |  |  |  |  |  | rg | NOCA | Not Started | C | Procurement | Kin Yip | 16718 |  | 01 |  |  |  |  |  |  |

| ID | WBS | Activity | Type | Duration | Start | Finish | Predecessors | Complete | Remaining | Planned start | Planned finish | Total float | Free float | Constraint | Expected finish | Resources | Cost | BNL_Cobra WP | RG Check | BNL_Activity Status | BNL_Fund Source | BNL_EDIA | BNL_CAM | BNL_Account Number | BNL_PCR ID | BNL_WBS_Hierarchical | Indicator - Procurement | Indicator - Float | BNL_UDF_Remaining Tot Cost | BNL_UDF_Percent_remaining | BNL_EVT | BNL_Cobra Control Account | BNL_UDF_Temp Text 01 | BNL_UDF_Percent Complete | BNL_UDF_OPC TEC (deprecated) | BNL_UDF_Old Activity ID 181221 | BNL_Estimator | BNL_Location | BNL_Institution | BNL_WBS | BNL_WBS Manager | Major SC Activity | BNL_Cost Basis | BNL_OPC TEC (deprecated) | BNL_Master Control Account | BNL_Milestone Level | BNL_Proc Sig Phase | BNL_Proc Sig |
| --- | --- | --- | --- | --- | --- | --- | --- | --- | --- | --- | --- | --- | --- | --- | --- | --- | --- | --- | --- | --- | --- | --- | --- | --- | --- | --- | --- | --- | --- | --- | --- | --- | --- | --- | --- | --- | --- | --- | --- | --- | --- | --- | --- | --- | --- | --- | --- | --- |
|  | 02 | **Three Manifold Jumper Transfer Lines** |  |  | 2021-06-01 | 2021-10-21 |  |  |  |  |  |  |  |  |  |  |  |  |  |  |  |  |  |  |  |  |  |  |  |  |  |  |  |  |  |  |  |  |  |  |  |  |  |  |  |  |  |  |
| S1006640 |  | Draft PDR of three Manifold Jumper Transfer Lines |  | 10d | 2021-06-01 | 2021-06-14 |  |  |  |  |  | 55d | 0d | start on or after 2021-05-14 |  |  |  | S1006640 | NOCA | Not Started | C | Design | Kin Yip | 16718 | 012 | 02 |  |  |  |  |  |  |  |  |  |  |  |  |  |  |  |  |  |  |  |  |  |  |
| S1006660 |  | AET submits PDR report to BNL for approval of three Manifold Jumper Transfer Lines |  | 10d | 2021-06-15 | 2021-06-28 | S1006640 |  |  |  |  | 105d | 0d | start on or after 2021-05-17 |  |  |  | S1006660 | NOCA | Not Started | C | Procurement | Kin Yip | 16718 | 012 | 02 |  |  |  |  |  |  |  |  |  |  |  |  |  |  |  |  |  |  |  |  |  |  |
| S1006680 |  | BNL review for PDR approval |  | 5d | 2021-06-29 | 2021-07-06 | S1006660 |  |  |  |  | 105d | 0d |  |  | Material (Purchase (1st $2M) [23484.9 h] | 26,200.08 | S1006680 | CA | Not Started | C | Procurement | Kin Yip | 16718 |  | 02 | UDF_G2 | UDF_G3 | 26200.083112 | 1 | C | 2.02 |  |  |  |  |  |  |  |  |  |  |  |  |  |  |  |  |
| S1006720 |  | AET submits IDR to BNL for approval |  | 5d | 2021-07-07 | 2021-07-13 | S1006680 |  |  |  |  | 105d | 0d |  |  |  |  | rg | NOCA | Not Started | C | Procurement | Kin Yip | 16718 |  | 02 |  |  |  |  |  |  |  |  |  |  |  |  |  |  |  |  |  |  |  |  |  |  |
| S1006760 |  | BNL review for IDR approval |  | 5d | 2021-07-14 | 2021-07-20 | S1006720 |  |  |  |  | 105d | 0d |  |  | Material (Purchase (1st $2M) [23484.9 h] | 26,200.08 | S1006760 | CA | Not Started | C | Procurement | Kin Yip | 16718 |  | 02 | UDF_G2 | UDF_G3 | 26200.083112 | 1 | C | 2.02 |  |  |  |  |  |  |  |  |  |  |  |  |  |  |  |  |
| S1006800 |  | AET submits FDR report to BNL for approval |  | 10d | 2021-07-21 | 2021-08-03 | S1006760 |  |  |  |  | 105d | 0d |  |  | Material (Purchase (1st $2M) [93939.6 h] | 104,800.31 | S1006800 | CA | Not Started | C | Procurement | Kin Yip | 16718 |  | 02 | UDF_G2 | UDF_G3 | 104800.310136 | 1 | C | 2.02 |  |  |  |  |  |  |  |  |  |  |  |  |  |  |  |  |
| S1006840 |  | AET begins material procurement |  | 5d | 2021-08-04 | 2021-08-10 | S1006800 |  |  |  |  | 105d | 0d |  |  |  |  | rg | NOCA | Not Started | C | Procurement | Kin Yip | 16718 |  | 02 |  |  |  |  |  |  |  |  |  |  |  |  |  |  |  |  |  |  |  |  |  |  |
| S1006880 |  | Fabricate all three Manifold Jumper Transfer Lines |  | 20d | 2021-08-11 | 2021-09-08 | S1006840 |  |  |  |  | 105d | 0d |  |  |  |  | rg | NOCA | Not Started | C | Procurement | Kin Yip | 16718 |  | 02 |  |  |  |  |  |  |  |  |  |  |  |  |  |  |  |  |  |  |  |  |  |  |
| S1006920 |  | Delivery of all three Manifold Jumper Transfer Lines and Document package |  | 30d | 2021-09-09 | 2021-10-21 | S1006880 |  |  |  |  | 105d | 50d | start on or after 2021-08-11 |  |  |  | S1006920 | NOCA | Not Started | C | Procurement | Kin Yip | 16718 | 012 | 02 |  |  |  |  |  |  |  |  |  |  |  |  |  |  |  |  |  |  |  |  |  |  |
|  | 03 | **Three Solenoid Valve Box Transfer Lines** |  |  | 2021-09-23 | 2022-01-13 |  |  |  |  |  |  |  |  |  |  |  |  |  |  |  |  |  |  |  |  |  |  |  |  |  |  |  |  |  |  |  |  |  |  |  |  |  |  |  |  |  |  |
| S1006940 |  | Draft PDR of three Solenoid Valve Box Transfer Lines |  | 10d | 2021-09-23 | 2021-10-06 | S1006640 SS+80d |  |  |  |  | 55d | 0d |  |  |  |  | S1006940 | NOCA | Not Started | C | Design | Kin Yip | 16718 |  | 03 |  |  |  |  |  |  |  |  |  |  |  |  |  |  |  |  |  |  |  |  |  |  |
| S1006960 |  | AET submits PDR report to BNL for approval of three Solenoid Valve Box Transfer Lines |  | 10d | 2021-10-07 | 2021-10-21 | S1006940 |  |  |  |  | 55d | 0d | start on or after 2021-01-11 |  |  |  | S1006960 | NOCA | Not Started | C | Procurement | Kin Yip | 16718 |  | 03 |  |  |  |  |  |  |  |  |  |  |  |  |  |  |  |  |  |  |  |  |  |  |
| S1007000 |  | BNL review for PDR approval |  | 5d | 2021-10-22 | 2021-10-28 | S1006960 |  |  |  |  | 55d | 0d |  |  | Material (Purchase (1st $2M) [23484.9 h] | 26,200.08 | S1007000 | CA | Not Started | C | Procurement | Kin Yip | 16718 |  | 03 | UDF_G2 | UDF_G1 | 26200.083112 | 1 | C | 2.02 |  |  |  |  |  |  |  |  |  |  |  |  |  |  |  |  |
| S1007040 |  | AET submits IDR to BNL for approval |  | 5d | 2021-10-29 | 2021-11-04 | S1007000 |  |  |  |  | 55d | 0d |  |  |  |  | rg | NOCA | Not Started | C | Procurement | Kin Yip | 16718 |  | 03 |  |  |  |  |  |  |  |  |  |  |  |  |  |  |  |  |  |  |  |  |  |  |
| S1007080 |  | BNL review for IDR approval |  | 5d | 2021-11-05 | 2021-11-12 | S1007040 |  |  |  |  | 55d | 0d |  |  | Material (Purchase (1st $2M) [23484.9 h] | 26,200.08 | S1007080 | CA | Not Started | C | Procurement | Kin Yip | 16718 |  | 03 | UDF_G2 | UDF_G1 | 26200.083112 | 1 | C | 2.02 |  |  |  |  |  |  |  |  |  |  |  |  |  |  |  |  |
| S1007120 |  | AET submits FDR report to BNL for approval |  | 5d | 2021-11-15 | 2021-11-19 | S1007080 |  |  |  |  | 55d | 0d |  |  | Material (Purchase (1st $2M) [93939.6 h] | 104,800.31 | S1007120 | CA | Not Started | C | Procurement | Kin Yip | 16718 |  | 03 | UDF_G2 | UDF_G1 | 104800.310136 | 1 | C | 2.02 |  |  |  |  |  |  |  |  |  |  |  |  |  |  |  |  |
| S1007160 |  | AET begins material procurement |  | 5d | 2021-11-22 | 2021-11-30 | S1007120 |  |  |  |  | 55d | 0d |  |  |  |  | rg | NOCA | Not Started | C | Procurement | Kin Yip | 16718 |  | 03 |  |  |  |  |  |  |  |  |  |  |  |  |  |  |  |  |  |  |  |  |  |  |
| S1007200 |  | Fabricate three Solenoid Valve Box Transfer Lines and two 4" & 5" NPS Field Joint Sleeves |  | 20d | 2021-12-01 | 2021-12-29 | S1007160 |  |  |  |  | 55d | 0d |  |  |  |  | rg | NOCA | Not Started | C | Procurement | Kin Yip | 16718 |  | 03 |  |  |  |  |  |  |  |  |  |  |  |  |  |  |  |  |  |  |  |  |  |  |
| S1007240 |  | Delivery of all three Solenoid Valve Box Transfer Lines and two 4" & 5" NPS Field Joint Sleeves |  | 5d | 2021-12-30 | 2022-01-06 | S1007200 |  |  |  |  | 55d | 0d |  |  | Material (Purchase (1st $2M) [203536 h] | 240,965.68 | S1007240 | CA | Not Started | C | Procurement | Kin Yip | 16718 |  | 03 | UDF_G2 | UDF_G1 | 240965.683708 | 1 | C | 2.02 |  |  |  |  |  |  |  |  |  |  |  |  |  |  |  |  |
| S1007280 |  | Approval of all Data/Documentation/ Reports |  | 5d | 2022-01-07 | 2022-01-13 | S1007240, S1005440, S1005480, S1005760, S1006200, S1006600, S1006920, S1007320 |  |  |  |  | 55d | 0d |  |  | Material (Purchase (1st $2M) [78283 h] | 87,333.57 | S1007280 | CA | Not Started | C | Procurement | Kin Yip | 16718 |  | 03 | UDF_G2 | UDF_G1 | 87333.573186 | 1 | C | 2.02 |  |  |  |  |  |  |  |  |  |  |  |  |  |  |  |  |
|  | 03 | **Group 3** |  |  | 2020-08-03 | 2020-11-30 |  |  |  |  |  |  |  |  |  |  |  |  |  |  |  |  |  |  |  |  |  |  |  |  |  |  |  |  |  |  |  |  |  |  |  |  |  |  |  |  |  |  |
| S1007320 |  | Delivery two male bayonets and one vapor return female bayonet |  | 5d | 2020-08-03 A | 2020-11-30 A |  | 100% |  | 2020-08-03 | 2020-08-07 |  |  | start on or after 2020-04-02 |  | Material (Purchase (1st $2M) [78283 h] | 89,080.27 | S1007320 | CA | Not Started | C | Procurement | Kin Yip | 16718 |  | 03 | UDF_G1 | UDF_G3 | 89080.267377 | 1 | C | 2.02 |  |  |  |  |  |  |  |  |  |  |  |  |  |  |  |  |
|  | 04 | **Vendor Engineering and Design** |  |  | 2019-10-23 | 2022-01-13 |  |  |  |  |  |  |  |  |  |  |  |  |  |  |  |  |  |  |  |  |  |  |  |  |  |  |  |  |  |  |  |  |  |  |  |  |  |  |  |  |  |  |
| S284000 |  | RHIC Helium Interface - Kick off meeting elapsed after contract award |  | 5d | 2019-10-23 A | 2019-10-28 A | S283300 SS | 100% |  | 2019-11-27 | 2019-12-05 |  |  |  |  |  |  |  | NOCA | Completed | C | Design | Kin Yip | 16718 |  | 01 |  |  |  |  |  |  | S284000 | 0 | S252600 | S252600 | Yip, Kin | BNL | BNL | POM02.2.02.03.01.04.01 | Than, Roberto | Yes |  |  |  |  |  |  |
| S284200 |  | Procure RHIC Helium Interface, MS1 (Manufacturing Program Plan) - Leadtime |  | 1d | 2019-11-18 A | 2019-11-25 A | S283300 SS | 100% |  | 2019-12-02 | 2019-12-02 |  |  |  |  | PROF3 AD; PROF6 AD |  |  | NOCA | Completed | C | Design | Kin Yip | 16718 |  | 01 |  |  |  |  | C |  | S284200 | 0 | S252800 | S252800 | Yip, Kin | BNL | BNL | POM02.2.02.03.01.04.01 | Than, Roberto |  | L4 | null | 2.02 |  |  |  |
| S284220 |  | Procure RHIC Helium Interface, MS1 (Manufacturing Program Plan) - Delivery Acceptance |  | 10d | 2019-11-18 A | 2019-11-25 A | S284200 | 100% |  | 2019-12-03 | 2019-12-16 |  |  |  |  | Material (Purchase (1st $2M) [156566 h] | 174,667.19 | S284220 | CA | Completed | C | Design | Kin Yip | 16718 |  | 01 | UDF_G2 |  |  |  | C | 2.02 | S284200 | 0 | S252800 | S252800 | Yip, Kin | BNL | BNL | POM02.2.02.03.01.04.01 | Than, Roberto |  |  |  |  |  |  |  |
| S284100 |  | RHIC Helium Interface - Engineering supervision by BNL |  | 45d | 2019-12-02 A | 2021-11-30 | S284000 | 75% | 125d | 2019-12-02 | 2020-02-05 | 289d | 0d |  | 2021-11-30 | PROF3 AD [240 h]; TECH3 AD [54 h]; PROF6 AD [207 h] | 76,474.42 | S284100 | CA | Not Started | C | Design | Kin Yip | 16718 |  | 01 |  |  |  |  | C | 2.02 | S284100 | 0 | S252700 | S252700 | Yip, Kin | BNL | BNL | POM02.2.02.03.01.04.01 | Than, Roberto |  | L4 | null | 2.02 |  |  |  |
| S285300 |  | Milestone - RHIC Helium Interface Contract Complete | milestone | 0d | 2022-01-13 | 2022-01-13 | S1007280 |  |  |  |  | 55d | 50d |  |  |  |  |  | NOCA | Not Started | C | Design | Kin Yip | 16718 | 008C | 01 |  |  |  |  | F |  | S285300 | 0 | S253200 | S277593124 | Yip, Kin | BNL | BNL | POM02.2.02.03.01.04.01 | Than, Roberto |  | L4 | null |  | L5 | PP6 | MP210004 |

Notes:
- 04: 180420 GYoung: concerning / Reference Design and Bid Package for Procurement - Design-build contract / to vendor; BNL develops requirements, interface specifications and bid / package documents including internal reviews over 2 / years
- S284000: BNL_UDF_Old Activity Name 181221: RHIC Helium Interface - Kick off meeting elapsed after contract award
- S284200: BNL_UDF_Old Activity Name 181221: RHIC Helium Interface - Preliminary Design Review
- S284220: BNL_UDF_Old Activity Name 181221: RHIC Helium Interface - Preliminary Design Review
- S284100: BNL_UDF_Old Activity Name 181221: RHIC Helium Interface - Engineering
- S285300: BNL_UDF_Old Activity Name 181221: Procure RHIC Helium Interface - Contract/PO - Leadtime - Phase 4 - Drawings Approvals

| ID | WBS | Activity | Type | Duration | Start | Finish | Predecessors | Complete | Planned start | Planned finish | Total float | Free float | Constraint | Resources | Cost | BNL_UDF_Temp Text 01 | BNL_UDF_Percent Complete | BNL_UDF_OPC TEC (deprecated) | BNL_UDF_Old Activity ID 181221 | BNL_Cobra WP | RG Check | BNL_Activity Status | BNL_Fund Source | BNL_Estimator | BNL_Cost Basis | BNL_Location | BNL_EDIA | BNL_CAM | BNL_Institution | BNL_OPC TEC (deprecated) | BNL_WBS | BNL_WBS Manager | BNL_EVT | BNL_Master Control Account | BNL_Account Number | BNL_Cobra Control Account | BNL_WBS_Hierarchical | Major SC Activity | BNL_Milestone Level | BNL_PCR ID | Target Milestone Date | Variance | PMP Milestones | BNL_UDF_Temp Date 01 | Completed | BNL_UDF_Status Comments | Additional EVT documentation required |
| --- | --- | --- | --- | --- | --- | --- | --- | --- | --- | --- | --- | --- | --- | --- | --- | --- | --- | --- | --- | --- | --- | --- | --- | --- | --- | --- | --- | --- | --- | --- | --- | --- | --- | --- | --- | --- | --- | --- | --- | --- | --- | --- | --- | --- | --- | --- | --- |
|  | 05 | **Vendor Fabrication** |  |  |  |  |  |  |  |  |  |  |  |  |  |  |  |  |  |  |  |  |  |  |  |  |  |  |  |  |  |  |  |  |  |  |  |  |  |  |  |  |  |  |  |  |  |
|  | 05 | **Delivery and Receiving** |  |  |  |  |  |  |  |  |  |  |  |  |  |  |  |  |  |  |  |  |  |  |  |  |  |  |  |  |  |  |  |  |  |  |  |  |  |  |  |  |  |  |  |  |  |
|  | 06 | **Installation** |  |  | 2020-09-22 | 2022-04-25 |  |  |  |  |  |  |  |  |  |  |  |  |  |  |  |  |  |  |  |  |  |  |  |  |  |  |  |  |  |  |  |  |  |  |  |  |  |  |  |  |  |
| S287000 |  | Helium System: Transfer lines BETWEEN 1008B and IR8 Hall INSTALLATION: Rigging in place |  | 30d | 2020-09-22 A | 2020-11-12 A | S1005480, S274300 | 100% | 2020-10-20 | 2020-12-03 |  |  |  | PROF3 AD [8 h]; TECH3 AD [120 h]; CRAFT3 [80 h] | 25,453.81 | S287000 | 0 | S254400 | S254410 | S287000 | CA | Not Started | C | Yip, Kin | L4 | BNL | Installation | Kin Yip | BNL | null | POM02.2.02.03.01.06 | Than, Roberto | C | 2.02 | 16718 | 2.02 | 06 | Yes |  |  |  |  |  |  |  |  |  |
| S287200 |  | Helium System Transfer lines : Along West wall of IR8 Hall INSTALLATION: Rigging in place |  | 30d | 2020-09-22 A | 2020-12-31 A | S274300, S1005440 | 100% | 2020-10-01 | 2020-11-13 |  |  |  | PROF3 AD [8 h]; TECH3 AD [80 h]; CRAFT3 [20 h] | 13,022.57 | S287200 | 0 | S254400 | S254430 | S287200 | CA | Not Started | C | Yip, Kin | L4 | BNL | Installation | Kin Yip | BNL | null | POM02.2.02.03.01.06 | Than, Roberto | C | 2.02 | 16718 | 2.02 | 06 | Yes |  |  |  |  |  |  |  |  |  |
| S287100 |  | Helium System: Transfer lines BETWEEN 1008B and IR8 Hall INSTALLATION: Field Joint welding |  | 30d | 2020-10-13 A | 2020-12-29 A | S287000 | 100% | 2020-11-13 | 2020-12-29 |  |  |  | PROF3 AD [40 h]; TECH3 AD [320 h]; CRAFT3 [160 h]; TECH3 AD [80 h] | 72,842.27 | S287100 | 0 | S254400 | S254420 | S287100 | CA | Not Started | C | Yip, Kin | L4 | BNL | Installation | Kin Yip | BNL | null | POM02.2.02.03.01.06 | Than, Roberto | C | 2.02 | 16718 | 2.02 | 06 | Yes |  |  |  |  |  |  |  |  |  |
| S287300 |  | Helium System Transfer lines : Along West wall of IR8 Hall INSTALLATION: field Joint welding |  | 30d | 2020-11-04 A | 2020-12-31 A | S287200 | 100% | 2021-01-04 | 2021-02-16 |  |  |  | PROF3 AD [40 h]; TECH3 AD [320 h]; CRAFT3 [160 h]; TECH3 AD [40 h]; PROF6 AD [8 h] | 69,730.7 | S287300 | 0 | S254400 | S254440 | S287300 | CA | Not Started | C | Yip, Kin | L4 | BNL | Installation | Kin Yip | BNL | null | POM02.2.02.03.01.06 | Than, Roberto | C | 2.02 | 16718 | 2.02 | 06 | Yes |  |  |  |  |  |  |  |  |  |
| S287110 |  | Completed - Helium System: Transfer lines BETWEEN 1008B and IR8 Hall INSTALLATION: Field Joint welding | milestone | 0d | 2020-12-29 A | 2020-12-29 A | S287100 | 100% |  |  |  |  |  |  |  | S287100 | 0 | S254400 | S254420 |  | NOCA | Not Started | C | Yip, Kin |  | BNL | Installation | Kin Yip | BNL |  | POM02.2.02.03.01.06 | Than, Roberto |  |  | 16718 |  | 06 | Yes | L5 |  |  |  |  |  |  |  |  |
| S286800 |  | Helium System 1008B Coldbox INSTALLATION: Rigging |  | 5d | 2021-06-01 | 2021-06-07 | S346600 FF, S346500 FF, S346510 FF, S1006200 |  |  |  | 110d | 22d |  | PROF3 AD [20 h]; TECH3 AD [20 h]; CRAFT3 [40 h]; PROF6 AD [8 h] | 11,700.21 | S286800 | 0 | S254300 | S254300 | S286800 | CA | Not Started | C | Yip, Kin | L4 | BNL | Installation | Kin Yip | BNL | null | POM02.2.02.03.01.06 | Than, Roberto | C | 2.02 | 16718 | 2.02 | 06 | Yes |  | 008C |  |  |  |  |  |  |  |
| S286900 |  | Helium System 1008B Coldbox INSTALLATION: Field Joint Welding and leak checking |  | 30d | 2021-07-09 | 2021-08-19 | S286800, S274310 |  |  |  | 88d |  |  | PROF3 AD [24 h]; TECH3 AD [360 h]; CRAFT3 [180 h]; TECH3 AD [40 h]; PROF6 AD [24 h] | 78,104.64 | S286900 | 0 | S254400 | S254400 | S286900 | CA | Not Started | C | Yip, Kin | L4 | BNL | Installation | Kin Yip | BNL | null | POM02.2.02.03.01.06 | Than, Roberto | C | 2.02 | 16718 | 2.02 | 06 | Yes |  |  |  |  |  |  |  |  |  |
| S287400 |  | (Helium System: 1008B Coldbox/Transfer lines / IR8 Coldbox) Installation/Rigging of IR8 Coldbox |  | 30d | 2021-12-30 | 2022-02-11 | S281600, S286900, S349410, S1006600 |  |  |  | 0d |  |  | PROF3 AD [12 h]; TECH3 AD [40 h]; PROF6 AD [12 h] | 8,910.41 | S287400 | 0 | S254500 | S254500 | S287400 | CA | Not Started | C | Yip, Kin | L4 | BNL | Installation | Kin Yip | BNL | null | POM02.2.02.03.01.06 | Than, Roberto | C | 2.02 | 16718 | 2.02 | 06 | Yes |  |  |  |  |  |  |  |  |  |
| S287410 |  | Completed - (Helium System: 1008B Coldbox/Transferlines / IR8 Coldbox) Installation/Rigging of IR8 Coldbox | milestone | 0d | 2022-02-11 | 2022-02-11 | S287400 FF |  |  |  | 0d |  |  |  |  | S287400 | 0 | S254500 | S254500 |  | NOCA | Not Started | C | Yip, Kin |  | BNL | Installation | Kin Yip | BNL |  | POM02.2.02.03.01.06 | Than, Roberto |  |  | 16718 |  | 06 | Yes | L5 |  |  |  |  |  |  |  |  |
| S287500 |  | RHIC Helium Interface - Final Bayonet jumpers lines install, pressure & leak check and valve check out |  | 10d | 2022-03-29 | 2022-04-11 | S287300, S287410, S287110, S285300, S370000 |  |  |  | 5d | 0d |  | PROF3 AD [80 h]; TECH3 AD [120 h]; PROF6 AD [80 h] | 41,645.47 | S287500 | 0 | S254600 | S254600 | S287500 | CA | Not Started | C | Yip, Kin | L4 | BNL | Installation | Kin Yip | BNL | null | POM02.2.02.03.01.06 | Than, Roberto | C | 2.02 | 16718 | 2.02 | 06 | Yes |  |  |  |  |  |  |  |  |  |
| S287600 |  | RHIC Helium Interface - Final pump and purge |  | 10d | 2022-04-12 | 2022-04-25 | S287500 |  |  |  | 5d | 0d |  | PROF3 AD [24 h]; TECH3 AD [120 h]; PROF6 AD [4 h] | 18,568.78 | S287600 | 0 | S254700 | S254700 | S287600 | CA | Not Started | C | Yip, Kin | L4 | BNL | Installation | Kin Yip | BNL | null | POM02.2.02.03.01.06 | Than, Roberto | C | 2.02 | 16718 | 2.02 | 06 | Yes |  |  |  |  |  |  |  |  |  |
| S287700 |  | RHIC Helium Interface - Installation complete | milestone | 0d | 2022-04-25 | 2022-04-25 | S287600 |  |  |  | 5d |  |  |  |  | S287700 | 0 | S254800 | S254800 |  | NOCA | Not Started | C | Yip, Kin |  | BNL | Installation | Kin Yip | BNL |  | POM02.2.02.03.01.06 | Than, Roberto |  |  | 16718 |  | 06 | Yes | L5 |  | 2022-06-30 | 46 | PMP_2x |  |  |  |  |
|  | 02 | **LN2 Supply Transfer Line System** |  |  | 2017-02-01 | 2021-12-30 |  |  |  |  |  |  |  |  |  |  |  |  |  |  |  |  |  |  |  |  |  |  |  |  |  |  |  |  |  |  |  |  |  |  |  |  |  |  |  |  |  |
|  | 01 | **Engineering and Design, LN2 Supply Transfer Line System** |  |  | 2017-02-01 | 2020-09-30 |  |  |  |  |  |  |  |  |  |  |  |  |  |  |  |  |  |  |  |  |  |  |  |  |  |  |  |  |  |  |  |  |  |  |  |  |  |  |  |  |  |
| S287800 |  | (LN2 supply transfer line system) Cryo Process Design |  | 390d | 2017-02-01 A | 2018-08-20 A | S100090 SS | 100% |  |  |  |  |  |  |  | S287800 | 100 | S254900 | S254900 |  | NOCA | Completed | C | Yip, Kin | L4 | BNL | Design | Kin Yip | BNL | null | POM02.2.02.03.02.01 |  | C |  | 16718 |  | 01 |  |  |  |  |  |  | 2018-08-20 | yes |  |  |
| S287900 |  | (LN2 supply transfer line system) P&ID development & drawings |  | 403d | 2017-02-01 A | 2018-09-07 A | S100090 SS | 100% |  |  |  |  |  |  |  | S287900 | 100 | S255000 | S255000 |  | NOCA | Completed | C | Yip, Kin | L4 | BNL | Design | Kin Yip | BNL | null | POM02.2.02.03.02.01 |  | C |  | 16718 |  | 01 |  |  |  |  |  |  | 2018-09-09 | yes |  |  |
| S288000 |  | (LN2 supply transfer line system) Mechanical Engineering Tasks FY18 |  | 148d | 2018-03-02 A | 2018-09-28 A | S287800 | 100% |  |  |  |  |  |  |  | S288000 | 100 | S255100 | S255100 |  | NOCA | Completed | C | Yip, Kin | L4 | BNL | Design | Kin Yip | BNL | null | POM02.2.02.03.02.01 |  | C |  | 16718 |  | 01 |  |  |  |  |  |  | 2019-06-18 | yes |  |  |
| S288100 |  | (LN2 supply transfer line system) Mechanical Engineering Tasks FY19 |  | 48d | 2019-10-01 A | 2020-05-01 A | S288000, S282100 | 100% | 2019-11-01 | 2020-01-14 |  |  | start on or after 2019-10-01 | PROF3 AD [40 h]; PROF6 AD [40 h] | 12,780.1 | S288100 | 0 | S255100 | S255150 | S288100 | CA | In Progress | C | Yip, Kin | L4 | BNL | Design | Kin Yip | BNL | null | POM02.2.02.03.02.01 |  | C | 2.02 | 16718 | 2.02 | 01 |  |  | 003 |  |  |  | 2019-06-18 |  | 190317 ELM Logic per L2 | Yes |
| S288200 |  | (LN2 supply transfer line system) SOW & Technical Specifications |  | 9d | 2019-11-22 A | 2020-05-01 A | S287800, S287900 | 100% | 2019-12-02 | 2019-12-12 |  |  | start on or after 2019-11-11 | PROF3 AD [36 h]; PROF6 AD [36 h] | 11,502.09 | S288200 | 0 | S255200 | S255200 | S288200 | CA | In Progress | C | Yip, Kin | L4 | BNL | Design | Kin Yip | BNL | null | POM02.2.02.03.02.01 |  | C | 2.02 | 16718 | 2.02 | 01 |  |  |  |  |  |  | 2019-06-18 |  |  |  |
| S288300 |  | (LN2 supply transfer line system) Bid package LN2 System Completed | milestone | 0d | 2020-09-30 A | 2020-09-30 A | S288200, S288500, S288100 | 100% | 2020-10-01 | 2020-10-01 |  |  |  |  |  | S288300 | 0 | S255300 | S255300 |  | NOCA | Not Started | C | Yip, Kin |  | BNL | Design | Kin Yip | BNL |  | POM02.2.02.03.02.01 |  |  |  | 16718 |  | 01 | Yes | L5 |  |  |  |  |  |  |  |  |
|  | 02 | **Design/Drafting, LN2 Supply Transfer Line System** |  |  | 2019-01-02 | 2020-07-10 |  |  |  |  |  |  |  |  |  |  |  |  |  |  |  |  |  |  |  |  |  |  |  |  |  |  |  |  |  |  |  |  |  |  |  |  |  |  |  |  |  |
| S288400 |  | (LN2 supply transfer line system) LN2 supply transfer line detail layout |  | 105d | 2019-01-02 A | 2019-05-31 A | S287800, S287900, S282900 | 100% |  |  |  |  |  |  |  | S288400 | 30 | S255400 | S255400 |  | NOCA | Completed | C | Yip, Kin | L4 | BNL | Design | Kin Yip | BNL | null | POM02.2.02.03.02.02 |  | C |  | 16718 |  | 02 |  |  | 003 |  |  |  | 2019-05-09 | yes | 190317 ELM Logic per L2 |  |
| S288410 |  | (LN2 supply transfer line system) LN2 supply transfer line detail layout Split |  | 24d | 2019-10-01 A | 2019-12-09 A | S288400 | 100% | 2019-11-01 | 2019-12-09 |  |  | start on or after 2019-10-01 | PROF3 AD [17 h]; PROF6 AD [17 h] | 5,431.54 | S288400 | 30 | S255400 | S255400 | S288410 | CA | In Progress | C | Yip, Kin | L4 | BNL | Design | Kin Yip | BNL | null | POM02.2.02.03.02.02 |  | C | 2.02 | 16718 | 2.02 | 02 |  |  | 003 |  |  |  | 2019-05-09 |  | 190317 ELM Logic per L2 |  |
| S288500 |  | (LN2 supply transfer line system) Detailed dwg package for Procurement |  | 80d | 2019-12-10 A | 2020-07-10 A | S288410 | 100% | 2019-12-10 | 2020-04-03 |  |  |  | PROF3 AD [120 h]; PROF6 AD [48 h] | 24,444.8 | S288500 | 0 | S255500 | S255500 | S288500 | CA | Not Started | C | Yip, Kin | L4 | BNL | Design | Kin Yip | BNL | null | POM02.2.02.03.02.02 |  | C | 2.02 | 16718 | 2.02 | 02 |  |  |  |  |  |  | 2019-06-18 |  |  |  |

Notes:
- 05: 180420 GYoung: concerning / continuation of contract for valve/interface box - Second phase of / contract after internal stages of design (PDR, IDR, FDR) and fabrication / reviews with vendor
- S287000: BNL_UDF_Old Activity Name 181221: Helium System: Transfer lines BETWEEN 1008B and IR8 Hall INSTALLATION: Rigging in place
- S287200: BNL_UDF_Old Activity Name 181221: Helium System Transfer lines : Along West wall of IR8 Hall INSTALLATION: Rigging in place
- S287100: BNL_UDF_Old Activity Name 181221: Helium System: Transfer lines BETWEEN 1008B and IR8 Hall INSTALLATION: Field Joint welding
- S287300: BNL_UDF_Old Activity Name 181221: Helium System Transfer lines : Along West wall of IR8 Hall INSTALLATION: field Joint welding
- S287110: BNL_UDF_Old Activity Name 181221: Helium System: Transfer lines BETWEEN 1008B and IR8 Hall INSTALLATION: Field Joint welding
- S286800: BNL_UDF_Old Activity Name 181221: Helium System 1008B Coldbox INSTALLATION: Rigging
- S286900: BNL_UDF_Old Activity Name 181221: Helium System 1008B Coldbox INSTALLATION: Field Joint Welding and leak checking
- S287400: BNL_UDF_Old Activity Name 181221: (Helium System: 1008B Coldbox/Transferlines / IR8 Coldbox) Installation/Rigging of IR8 Coldbox
- S287410: BNL_UDF_Old Activity Name 181221: (Helium System: 1008B Coldbox/Transferlines / IR8 Coldbox) Installation/Rigging of IR8 Coldbox
- S287500: BNL_UDF_Old Activity Name 181221: RHIC Helium Interface - Final Bayonet jumpers lines install, pressure & leak check and valve check out
- S287600: BNL_UDF_Old Activity Name 181221: RHIC Helium Interface - Final pump and purge
- S287700: BNL_UDF_Old Activity Name 181221: RHIC Helium Interface - Installation complete
- S287800: BNL_UDF_Old Activity Name 181221: (LN2 supply transfer line system) Cryo Process Design
- S287900: BNL_UDF_Old Activity Name 181221: (LN2 supply transfer line system) P&ID development&drawings
- S288000: BNL_UDF_Old Activity Name 181221: (LN2 supply transfer line system) Mechanical Engineering Tasks FY18
- S288100: BNL_UDF_Old Activity Name 181221: (LN2 supply transfer line system) Mechanical Engineering Tasks FY19
- S288200: BNL_UDF_Old Activity Name 181221: (LN2 supply transfer line system) SOW & Technical Specifications
- S288300: BNL_UDF_Old Activity Name 181221: (LN2 supply transfer line system) Bid package LN2 System Completed
- S288400: BNL_UDF_Old Activity Name 181221: (LN2 supply transfer line system) LN2 supply transfer line detail layout
- S288410: BNL_UDF_Old Activity Name 181221: (LN2 supply transfer line system) LN2 supply transfer line detail layout
- S288500: BNL_UDF_Old Activity Name 181221: (LN2 supply transfer line system) Detailed dwg package for Procurement

| ID | WBS | Activity | Type | Duration | Start | Finish | Predecessors | Complete | Remaining | Planned start | Planned finish | Total float | Free float | Expected finish | Resources | Cost | BNL_UDF_Temp Text 01 | BNL_UDF_Percent Complete | BNL_UDF_OPC TEC (deprecated) | BNL_UDF_Old Activity ID 181221 | BNL_Cobra WP | RG Check | BNL_Activity Status | BNL_Fund Source | BNL_Estimator | BNL_Cost Basis | BNL_Location | BNL_EDIA | BNL_Proc Sig Phase | BNL_Proc Sig | BNL_CAM | BNL_Institution | BNL_OPC TEC (deprecated) | BNL_WBS | BNL_EVT | BNL_Master Control Account | BNL_Account Number | BNL_Cobra Control Account | BNL_WBS_Hierarchical | BNL_Milestone Level | SPH Proc Register | Major SC Activity | BNL_Obligation | BNL_UDF_Status Comments | BNL_PCR ID | Indicator - Procurement | Indicator - Float | BNL_UDF_Remaining Tot Cost | BNL_UDF_Percent_remaining | BNL_UDF_Exclude |
| --- | --- | --- | --- | --- | --- | --- | --- | --- | --- | --- | --- | --- | --- | --- | --- | --- | --- | --- | --- | --- | --- | --- | --- | --- | --- | --- | --- | --- | --- | --- | --- | --- | --- | --- | --- | --- | --- | --- | --- | --- | --- | --- | --- | --- | --- | --- | --- | --- | --- | --- |
|  | 03 | **Procurement, LN2 Supply Transfer Line System** |  |  | 2020-05-04 | 2020-12-01 |  |  |  |  |  |  |  |  |  |  |  |  |  |  |  |  |  |  |  |  |  |  |  |  |  |  |  |  |  |  |  |  |  |  |  |  |  |  |  |  |  |  |  |  |
| S288600 |  | Procure LN2 supply transfer line system - Provide requirements to Procurement |  | 30d | 2020-05-04 A | 2020-07-15 A | S288300, S101000 | 100% |  | 2020-05-04 | 2020-06-15 |  |  |  | PROF3 AD [48 h]; PROF6 AD [88 h] | 23,055.84 | S288600 | 0 | S255600 | S255600 | S288600 | CA | Not Started | C | Yip, Kin | L4 | BNL | Procurement | PP1 | MP210030 | Kin Yip | BNL | null | POM02.2.02.03.02.03 | C | 2.02 | 16718 | 2.02 | 03 |  |  |  |  |  |  |  |  |  |  |  |
| S288700 |  | Procure LN2 supply transfer line system - Prepare & Send Solicitation |  | 15d | 2020-08-03 A | 2020-08-21 A | S288600 | 100% |  |  |  |  |  |  |  |  | S288700 | 0 | S255700 | S255700 |  | NOCA | Not Started | C | Yip, Kin | L4 | BNL | Procurement | PP2 | MP210030 | Kin Yip | BNL | null | POM02.2.02.03.02.03 | C |  | 16718 |  | 03 |  |  |  |  |  |  |  |  |  |  |  |
| S288800 |  | Procure LN2 supply transfer line system - Vendor Responses & Selection |  | 15d | 2020-08-24 A | 2020-11-10 A | S288700 | 100% |  | 2020-08-24 | 2020-09-14 |  |  |  |  |  | S288800 | 0 | S255700 | S255710 |  | NOCA | Not Started | C | Yip, Kin | L4 | BNL | Procurement | PP3 | MP210030 | Kin Yip | BNL | null | POM02.2.02.03.02.03 | C |  | 16718 |  | 03 |  |  |  |  |  |  |  |  |  |  |  |
| S288900 |  | Procure LN2 supply transfer line system, Phase 1 (Preliminary Design Review) - Contract Award | milestone | 0d | 2020-11-02 A | 2020-11-02 A | S288800 | 100% |  |  |  |  |  |  |  |  | S288900 | 0 | S255800 | S255800 |  | NOCA | Not Started | C | Yip, Kin | L4 | BNL | Procurement | PP5 | MP210030 | Kin Yip | BNL | null | POM02.2.02.03.02.03 | F |  | 16718 |  | 03 | L5 | Contract Award | Yes |  |  |  |  |  |  |  |  |
| S289000 |  | Procure LN2 supply transfer line system, Phase 2 (Long lead items) - Contract Award | milestone | 0d | 2020-11-02 A | 2020-11-02 A | S288800 | 100% |  |  |  |  |  |  |  |  | S289000 | 0 | S255800 | S255810 |  | NOCA | Not Started | C | Yip, Kin | L4 | BNL | Procurement | PP5 | MP210031 | Kin Yip | BNL | null | POM02.2.02.03.02.03 | F |  | 16718 |  | 03 | L5 | Contract Award | Yes |  |  |  |  |  |  |  |  |
| S289100 |  | Procure LN2 supply transfer line system, Phase 3 (Final Design Review) - Contract Award | milestone | 0d | 2020-11-02 A | 2020-11-02 A | S288800 | 100% |  |  |  |  |  |  |  |  | S289100 | 0 | S255800 | S255820 |  | NOCA | Not Started | C | Yip, Kin | L4 | BNL | Procurement | PP5 | MP210032 | Kin Yip | BNL | null | POM02.2.02.03.02.03 | F |  | 16718 |  | 03 | L5 | Contract Award | Yes |  |  |  |  |  |  |  |  |
| S289200 |  | Procure LN2 supply transfer line system, Phase 4 (Raw Material) - Contract Award | milestone | 0d | 2020-11-02 A | 2020-11-02 A | S288800 | 100% |  |  |  |  |  |  |  |  | S289200 | 0 | S255800 | S255830 |  | NOCA | Not Started | C | Yip, Kin | L4 | BNL | Procurement | PP5 | MP210033 | Kin Yip | BNL | null | POM02.2.02.03.02.03 | F |  | 16718 |  | 03 | L5 | Contract Award | Yes |  |  |  |  |  |  |  |  |
| S289300 |  | Procure LN2 supply transfer line system - Contract Award - Phase 5 - Shipping | milestone | 0d | 2020-11-02 A | 2020-11-02 A | S288800 | 100% |  |  |  |  |  |  |  |  | S289300 | 0 | S255800 | S255840 |  | NOCA | Not Started | C | Yip, Kin | L4 | BNL | Procurement | PP5 | MP210034 | Kin Yip | BNL | null | POM02.2.02.03.02.03 | F |  | 16718 |  | 03 | L5 | Contract Award | Yes |  |  |  |  |  |  |  |  |
| OBLG288910 |  | Procure LN2 supply transfer line system, Phase 1 (Preliminary Design Review) - Obligation |  | 1d | 2020-12-01 A | 2020-12-01 A | S288800 | 100% |  |  |  |  |  |  | Obligation Resource [25034.4 h] | 25,034.37 | S288900 | 0 | S255800 | S255800 |  |  | Not Started | C | Yip, Kin | L4 | BNL | Procurement | PP5 | MP210030 | Kin Yip | BNL | null | POM02.2.02.03.02.03 | F |  |  |  | 03 |  |  |  | OBLG |  |  |  |  |  |  |  |
| OBLG289010 |  | Procure LN2 supply transfer line system, Phase 2 (Long lead items) - Obligation |  | 1d | 2020-12-01 A | 2020-12-01 A | S288800 | 100% |  |  |  |  |  |  | Obligation Resource [56896.3 h] | 56,896.29 | S289000 | 0 | S255800 | S255810 |  |  | Not Started | C | Yip, Kin | L4 | BNL | Procurement | PP5 | MP210031 | Kin Yip | BNL | null | POM02.2.02.03.02.03 | F |  |  |  | 03 |  |  |  | OBLG |  |  |  |  |  |  |  |
| OBLG289110 |  | Procure LN2 supply transfer line system, Phase 3 (Final Design Review) - Obligation |  | 1d | 2020-12-01 A | 2020-12-01 A | S288800 | 100% |  |  |  |  |  |  | Obligation Resource [56896.3 h] | 56,896.29 | S289100 | 0 | S255800 | S255820 |  |  | Not Started | C | Yip, Kin | L4 | BNL | Procurement | PP5 | MP210032 | Kin Yip | BNL | null | POM02.2.02.03.02.03 | F |  |  |  | 03 |  |  |  | OBLG |  |  |  |  |  |  |  |
| OBLG289210 |  | Procure LN2 supply transfer line system, Phase 4 (Raw Material) - Obligation |  | 1d | 2020-12-01 A | 2020-12-01 A | S288800 | 100% |  |  |  |  |  |  | Obligation Resource [58034.2 h] | 58,034.23 | S289200 | 0 | S255800 | S255830 |  |  | Not Started | C | Yip, Kin | L4 | BNL | Procurement | PP5 | MP210033 | Kin Yip | BNL | null | POM02.2.02.03.02.03 | F |  |  |  | 03 |  |  |  | OBLG |  |  |  |  |  |  |  |
| OBLG289310 |  | Procure LN2 supply transfer line system - Obligation - Phase 5 - Shipping |  | 1d | 2020-12-01 A | 2020-12-01 A | S288800 | 100% |  |  |  |  |  |  | Obligation Resource [55712.9 h] | 55,712.86 | S289300 | 0 | S255800 | S255840 |  |  | Not Started | C | Yip, Kin | L4 | BNL | Procurement | PP5 | MP210034 | Kin Yip | BNL | null | POM02.2.02.03.02.03 | F |  |  |  | 03 |  |  |  | OBLG | 190417 ELM BNLU per GRY | 004 |  |  |  |  |  |
|  | 04 | **Fabrication at Vendor, LN2 Supply Transfer Line System** |  |  | 2020-12-01 | 2021-11-04 |  |  |  |  |  |  |  |  |  |  |  |  |  |  |  |  |  |  |  |  |  |  |  |  |  |  |  |  |  |  |  |  |  |  |  |  |  |  |  |  |  |  |  |  |
|  | 01 | **Vendor Engineering and Design** |  |  | 2020-12-01 | 2021-06-30 |  |  |  |  |  |  |  |  |  |  |  |  |  |  |  |  |  |  |  |  |  |  |  |  |  |  |  |  |  |  |  |  |  |  |  |  |  |  |  |  |  |  |  |  |
| S289400 |  | (LN2 supply transfer line system) Kick off meeting |  | 1d | 2020-12-01 A | 2020-12-01 A | S288900 SS, S289000 SS, S289100 SS, S289200 SS, S289300 SS, OBLG288910 SS, OBLG289010 SS, OBLG289110 SS, OBLG289210 SS, OBLG289310 SS | 100% |  |  |  |  |  |  | PROF6 AD [8 h] | 1,590.26 | S289400 | 0 | S256200 | S256200 | S289400 | CA | Not Started | C | Yip, Kin | L4 | BNL | Procurement |  |  | Kin Yip | BNL | null | POM02.2.02.03.02.04.01 | C | 2.02 | 16718 | 2.02 | 01 |  |  |  |  |  |  |  |  |  |  |  |
| S289500 |  | Engineering Support for Procure LN2 supply transfer line system |  | 45d | 2020-12-02 A | 2021-06-30 | S289400 | 86% | 22d | 2020-12-02 | 2021-02-05 | 84d | 0d | 2021-06-30 | PROF6 AD [36 h] | 7,156.18 | S289500 | 0 | S256300 | S256300 | S289500 | CA | Not Started | C | Yip, Kin | L4 | BNL | Procurement |  |  | Kin Yip | BNL | null | POM02.2.02.03.02.04.01 | C | 2.02 | 16718 | 2.02 | 01 |  |  |  |  |  |  |  |  |  |  |  |
| S289600 |  | (LN2 supply transfer line system) Preliminary Design Review Labor |  | 46d | 2020-12-02 A | 2021-01-27 A | S289400, S288900 SS, OBLG288910 SS | 100% |  | 2020-12-02 | 2021-02-08 |  |  |  | PROF6 AD [8 h] | 1,590.26 | S289600 | 0 | S256400 | S256400 | S289600 | CA | Not Started | C | Yip, Kin | L4 | BNL | Design |  |  | Kin Yip | BNL | null | POM02.2.02.03.02.04.01 | C | 2.02 | 16718 | 2.02 | 01 |  |  |  |  |  |  |  |  |  |  |  |
| S289700 |  | Procure LN2 supply transfer line system, Phase 1 (Preliminary Design Review) - Leadtime |  | 90d | 2020-12-02 A | 2021-01-27 A | S288900 SS, S289400, OBLG288910 SS | 100% |  | 2020-12-02 | 2021-04-12 |  |  |  |  |  | S289700 | 0 | S256300 | S277594204 |  | NOCA | Not Started | C | Yip, Kin | L4 | BNL | Procurement | PP6 | MP210030 | Kin Yip | BNL | null | POM02.2.02.03.02.04.01 | C |  | 16718 |  | 01 |  |  |  |  |  | 016 |  |  |  |  |  |
| S289800 |  | Procure LN2 supply transfer line system, Phase 1 (Preliminary Design Review) - Delivery Acceptance |  | 1d | 2021-01-13 A | 2021-01-27 A | S289700, S289600 FF | 100% |  | 2021-04-13 | 2021-04-13 |  |  |  | Material (Purchase (1st $2M) [22000 h] | 25,535.05 | S289800 | 0 | S255900 | S255900 | S289800 | CA | Not Started | C | Yip, Kin | M4 | BNL | Design | PP6 | MP210030 | Kin Yip | BNL | null | POM02.2.02.03.02.04.01 | C | 2.02 | 16718 | 2.02 | 01 |  | Delivery | Yes | FAB |  |  | UDF_G1 | UDF_G1 | 25535.05482 | 1 |  |
| S289900 |  | (LN2 supply transfer line system) Detail dwg package |  | 30d | 2021-01-18 A | 2021-04-30 A | S289500, S289810 | 100% |  | 2021-04-14 | 2021-05-25 |  |  |  | PROF6 AD [48 h] | 9,541.57 | S289900 | 0 | S256500 | S256500 | S289900 | CA | Not Started | C | Yip, Kin | L4 | BNL | Procurement |  |  | Kin Yip | BNL | null | POM02.2.02.03.02.04.01 | C | 2.02 | 16718 | 2.02 | 01 |  |  |  |  |  |  |  |  |  |  |  |
| S289810 |  | Completed - Procure LN2 supply transfer line system, Phase 1 (Preliminary Design Review) - Delivery Acceptance | milestone | 0d | 2021-01-27 A | 2021-01-27 A | S289800 FF | 100% |  | 2021-04-13 | 2021-04-13 |  |  |  |  |  | S289800 | 0 | S255900 | S255900 |  | NOCA | Not Started | C | Yip, Kin |  | BNL | Design |  |  | Kin Yip | BNL |  | POM02.2.02.03.02.04.01 |  |  | 16718 |  | 01 | L5 |  | Yes |  |  |  |  |  |  |  |  |
| S290000 |  | Long lead items Support Labor for LN2 supply transfer line system |  | 31d | 2021-02-01 A | 2021-03-31 A | S289000 SS, OBLG289010 SS, S289810 | 100% |  | 2021-02-01 | 2021-03-16 |  |  |  | PROF6 AD [24 h] | 4,770.79 | S290000 | 0 | S256700 | S256700 | S290000 | CA | Not Started | C | Yip, Kin | L4 | BNL | Procurement |  |  | Kin Yip | BNL | null | POM02.2.02.03.02.04.01 | C | 2.02 | 16718 | 2.02 | 01 |  |  |  |  |  |  |  |  |  |  |  |
| S290100 |  | Procure LN2 supply transfer line system, Phase 2 (Long lead items) - Leadtime |  | 30d | 2021-02-01 A | 2021-04-01 A | S289000 SS, OBLG289010 SS, S289810 | 100% |  | 2021-02-01 | 2021-03-15 |  |  |  |  |  | S290100 | 0 | S256100 | S277594284 |  | NOCA | Not Started | C | Yip, Kin | M4 | BNL | Fab & Assy | PP6 | MP210031 | Kin Yip | BNL | null | POM02.2.02.03.02.04.01 | C |  | 16718 |  | 01 |  |  |  |  |  |  |  |  |  |  | MP6LAEXCLUDE |
| S290300 |  | (LN2 supply transfer line system) Final Design Review Labor |  | 2d | 2021-02-01 A | 2021-03-30 A | S289100 SS, OBLG289110 SS, S289810 | 100% |  | 2021-02-01 | 2021-02-02 |  |  |  | PROF6 AD [8 h] | 1,590.26 | S290300 | 0 | S256600 | S256600 | S290300 | CA | Not Started | C | Yip, Kin | L4 | BNL | Design |  |  | Kin Yip | BNL | null | POM02.2.02.03.02.04.01 | C | 2.02 | 16718 | 2.02 | 01 |  |  |  |  |  |  |  |  |  |  |  |
| S290400 |  | Procure LN2 supply transfer line system, Phase 3 (Final Design Review) - Leadtime |  | 1d | 2021-02-01 A | 2021-03-30 A | S289100 SS, OBLG289110 SS, S289810 | 100% |  | 2021-02-01 | 2021-02-01 |  |  |  |  |  | S290400 | 0 | S256000 | S277594324 |  | NOCA | Not Started | C | Yip, Kin | M4 | BNL | Design | PP6 | MP210032 | Kin Yip | BNL | null | POM02.2.02.03.02.04.01 | C |  | 16718 |  | 01 |  |  |  |  |  |  |  |  |  |  | MP6LAEXCLUDE |
| S290500 |  | Procure LN2 supply transfer line system, Phase 3 (Final Design Review) - Delivery Acceptance |  | 1d | 2021-02-02 A | 2021-04-30 A | S290400, S290300 FF | 100% |  | 2021-02-02 | 2021-02-02 |  |  |  | Material (Purchase (1st $2M) [50000 h] | 58,034.22 | S290500 | 0 | S256000 | S256000 | S290500 | CA | Not Started | C | Yip, Kin | M4 | BNL | Design | PP6 | MP210032 | Kin Yip | BNL | null | POM02.2.02.03.02.04.01 | C | 2.02 | 16718 | 2.02 | 01 |  | Delivery | Yes | FAB |  |  | UDF_G1 | UDF_G1 | 58034.2155 | 1 | MP6LAEXCLUDE |
| S290200 |  | Procure LN2 supply transfer line system, Phase 2 (Long lead items) - Delivery Acceptance |  | 1d | 2021-03-16 A | 2021-03-30 A | S290100, S290000 FF | 100% |  | 2021-04-16 | 2021-04-16 |  |  |  | Material (Purchase (1st $2M) [50000 h] | 58,034.22 | S290200 | 0 | S256100 | S256100 | S290200 | CA | Not Started | C | Yip, Kin | M4 | BNL | Fab & Assy | PP6 | MP210031 | Kin Yip | BNL |  | POM02.2.02.03.02.04.01 | C | 2.02 | 16718 | 2.02 | 01 |  | Delivery | Yes | FAB |  |  | UDF_G2 | UDF_G3 | 58034.2155 | 1 | MP6LAEXCLUDE |
| S290210 |  | Completed - Procure LN2 supply transfer line system, Phase 2 (Long lead items) - Delivery Acceptance | milestone | 0d | 2021-03-30 A | 2021-03-30 A | S290200 FF | 100% |  | 2021-04-16 | 2021-04-16 |  |  |  |  |  | S290200 | 0 | S256100 | S256100 |  | NOCA | Not Started | C | Yip, Kin |  | BNL | Fab & Assy |  |  | Kin Yip | BNL |  | POM02.2.02.03.02.04.01 |  |  | 16718 |  | 01 | L5 |  | Yes |  |  |  |  |  |  |  | MP6LAEXCLUDE |
| S290600 |  | (LN2 supply transfer line system) Drawings approvals |  | 5d | 2021-04-26 A | 2021-04-30 A | S289900, S290510 | 100% |  | 2021-06-07 | 2021-06-11 |  |  |  | PROF6 AD |  | S290600 | 0 | S256800 | S256800 | S290600 | CA | Not Started | C | Yip, Kin | L4 | BNL | Design |  |  | Kin Yip | BNL | null | POM02.2.02.03.02.04.01 | C | 2.02 | 16718 | 2.02 | 01 |  |  |  |  |  | 018 |  |  |  |  |  |
| S290510 |  | Completed - Procure LN2 supply transfer line system, Phase 3 (Final Design Review) - Delivery Acceptance | milestone | 0d | 2021-04-30 A | 2021-04-30 A | S290500 FF | 100% |  | 2021-06-04 | 2021-06-04 |  |  |  |  |  | S290500 | 0 | S256000 | S256000 |  | NOCA | Not Started | C | Yip, Kin |  | BNL | Design |  |  | Kin Yip | BNL |  | POM02.2.02.03.02.04.01 |  |  | 16718 |  | 01 | L5 |  | Yes |  |  |  |  |  |  |  | MP6LAEXCLUDE |

Notes:
- S288600: BNL_UDF_Old Activity Name 181221: Procure LN2 supply transfer line system - Provide requirements to Procurement
- S288700: BNL_UDF_Old Activity Name 181221: Procure LN2 supply transfer line system - Prepare & Send Solicitation
- S288800: BNL_UDF_Old Activity Name 181221: Procure LN2 supply transfer line system - Vendor Responses & Selection
- S288900: BNL_UDF_Old Activity Name 181221: Procure LN2 supply transfer line system - Contract Award - Phase 1- Preliminary Design Review
- S289000: BNL_UDF_Old Activity Name 181221: Procure LN2 supply transfer line system - Contract Award - Phase 2 - Long lead items
- S289100: BNL_UDF_Old Activity Name 181221: Procure LN2 supply transfer line system - Contract Award - Phase 3 - Final Design Review
- S289200: BNL_UDF_Old Activity Name 181221: Procure LN2 supply transfer line system - Contract Award - Phase 4 - Raw Material
- S289300: BNL_UDF_Old Activity Name 181221: Procure LN2 supply transfer line system - Contract Award - Phase 5 - Shipping
- OBLG288910: BNL_UDF_Old Activity Name 181221: Procure LN2 supply transfer line system - Contract Award - Phase 1- Preliminary Design Review
- OBLG289010: BNL_UDF_Old Activity Name 181221: Procure LN2 supply transfer line system - Contract Award - Phase 2 - Long lead items
- OBLG289110: BNL_UDF_Old Activity Name 181221: Procure LN2 supply transfer line system - Contract Award - Phase 3 - Final Design Review
- OBLG289210: BNL_UDF_Old Activity Name 181221: Procure LN2 supply transfer line system - Contract Award - Phase 4 - Raw Material
- OBLG289310: BNL_UDF_Old Activity Name 181221: Procure LN2 supply transfer line system - Contract Award - Phase 5 - Shipping
- S289400: BNL_UDF_Old Activity Name 181221: (LN2 supply transfer line system) Kick off meeting
- S289500: BNL_UDF_Old Activity Name 181221: Engineering Support for Procure LN2 supply transfer line system
- S289600: BNL_UDF_Old Activity Name 181221: (LN2 supply transfer line system) Preliminary Design Review Labor
- S289700: BNL_UDF_Old Activity Name 181221: Procure LN2 supply transfer line system - Leadtime - Phase 1 - Preliminary Design Review
- S289800: BNL_UDF_Old Activity Name 181221: Procure LN2 supply transfer line system - Delivery Acceptance - Phase 1 - Preliminary Design Review
- S289900: BNL_UDF_Old Activity Name 181221: (LN2 supply transfer line system) Detail dwg package
- S289810: BNL_UDF_Old Activity Name 181221: Procure LN2 supply transfer line system - Delivery Acceptance - Phase 1 - Preliminary Design Review
- S290000: BNL_UDF_Old Activity Name 181221: Long lead items Support Labor for LN2 supply transfer line system
- S290100: BNL_UDF_Old Activity Name 181221: Procure LN2 supply transfer line system - Phase 2 - Long lead items - Leadtime
- S290300: BNL_UDF_Old Activity Name 181221: (LN2 supply transfer line system) Final Design Review Labor
- S290400: BNL_UDF_Old Activity Name 181221: Procure LN2 supply transfer line system - Phase 3 - Final Design Review - Leadtime
- S290500: BNL_UDF_Old Activity Name 181221: Procure LN2 supply transfer line system - Phase 3 - Final Design Review - Delivery Acceptance
- S290200: BNL_UDF_Old Activity Name 181221: Procure LN2 supply transfer line system - Phase 2 - Long lead items - Delivery Acceptance
- S290210: BNL_UDF_Old Activity Name 181221: Procure LN2 supply transfer line system - Phase 2 - Long lead items - Delivery Acceptance
- S290600: BNL_UDF_Old Activity Name 181221: (LN2 supply transfer line system) Drawings approvals
- S290510: BNL_UDF_Old Activity Name 181221: Procure LN2 supply transfer line system - Phase 3 - Final Design Review - Delivery Acceptance

| ID | WBS | Activity | Type | Duration | Start | Finish | Predecessors | Complete | Remaining | Planned start | Planned finish | Total float | Free float | Constraint | Expected finish | Resources | Cost | BNL_UDF_Temp Text 01 | BNL_UDF_Percent Complete | BNL_UDF_OPC TEC (deprecated) | BNL_UDF_Old Activity ID 181221 | BNL_Cobra WP | RG Check | Variance | BNL_UDF_PCR_Labor_Delta | BNL_UDF_PCR_Direct$_Delta | BNL_UDF_PCR_TotCost_Delta | BNL_Activity Status | BNL_Fund Source | BNL_Estimator | BNL_Cost Basis | BNL_Location | BNL_EDIA | BNL_CAM | BNL_Institution | BNL_OPC TEC (deprecated) | BNL_WBS | BNL_EVT | BNL_Master Control Account | BNL_Account Number | BNL_PCR ID | BNL_Cobra Control Account | BNL_WBS_Hierarchical | BNL_UDF_Exclude | BNL_Proc Sig Phase | BNL_Proc Sig | Indicator - Procurement | Indicator - Float | BNL_UDF_Remaining Tot Cost | BNL_UDF_Percent_remaining | BNL_Obligation | SPH Proc Register | Major SC Activity | Additional EVT documentation required | BNL_Milestone Level | BNL_UDF_Status Comments | Target Milestone Date | PMP Milestones | BNL_UDF_Temp Date 01 |
| --- | --- | --- | --- | --- | --- | --- | --- | --- | --- | --- | --- | --- | --- | --- | --- | --- | --- | --- | --- | --- | --- | --- | --- | --- | --- | --- | --- | --- | --- | --- | --- | --- | --- | --- | --- | --- | --- | --- | --- | --- | --- | --- | --- | --- | --- | --- | --- | --- | --- | --- | --- | --- | --- | --- | --- | --- | --- | --- | --- |
|  | 02 | **Vendor Fabrication** |  |  | 2021-04-15 | 2021-11-04 |  |  |  |  |  |  |  |  |  |  |  |  |  |  |  |  |  |  |  |  |  |  |  |  |  |  |  |  |  |  |  |  |  |  |  |  |  |  |  |  |  |  |  |  |  |  |  |  |  |  |  |  |  |
| S1008520 |  | (LN2 supply transfer line system) LOE Supervision Labor |  | 65d | 2021-04-15 A | 2021-07-16 |  | 75% | 33d |  |  | 160d | 0d | start on or after 2021-04-15 | 2021-07-16 | PROF6 AD [140 h] | 27,829.58 | S291300 | 0 | S257500 | S257500 | S1008520 | CA | 0 | 140 | 0 | 27829.58066 | Not Started | C | Yip, Kin | L4 | BNL | Procurement | Kin Yip | BNL | null | POM02.2.02.03.02.04.02 | C | 2.02 | 16718 | 018 | 2.02 | 02 |  |  |  |  |  |  |  |  |  |  |  |  |  |  |  |  |
| S290700 |  | (LN2 supply transfer line system) Raw Material procurement Labor |  | 45d | 2021-04-21 A | 2021-08-16 | S290600 | 75% | 32d | 2021-06-14 | 2021-08-16 | 89d | 0d |  | 2021-08-16 | PROF6 AD |  | S290700 | 0 | S257100 | S257100 | S290700 | CA |  |  |  |  | Not Started | C | Yip, Kin | L4 | BNL | Procurement | Kin Yip | BNL | null | POM02.2.02.03.02.04.02 | C | 2.02 | 16718 | 018 | 2.02 | 02 |  |  |  |  |  |  |  |  |  |  |  |  |  |  |  |  |
| S290800 |  | Procure LN2 supply transfer line system, Phase 4 (Raw Material) - Leadtime |  | 45d | 2021-04-21 A | 2021-08-16 | S290600, S289200 SS, OBLG289210 SS | 75% | 32d | 2021-06-14 | 2021-08-16 | 84d | 0d |  | 2021-08-16 |  |  | S290800 | 0 | S256900 | S277594244 |  | NOCA |  |  |  |  | Not Started | C | Yip, Kin | M4 | BNL | Fab & Assy | Kin Yip | BNL | null | POM02.2.02.03.02.04.02 | C |  | 16718 |  |  | 02 | MP6LAEXCLUDE | PP6 | MP210033 |  |  |  |  |  |  |  |  |  |  |  |  |  |
| S290900 |  | Procure LN2 supply transfer line system, Phase 4 (Raw Material) - Delivery Acceptance |  | 5d | 2021-04-21 A | 2021-08-23 | S290800, S290700 FF | 75% | 5d | 2021-08-17 | 2021-08-23 | 84d | 0d |  | 2021-08-23 | Material (Purchase (1st $2M) |  | S290900 | 0 | S256900 | S256900 | S290900 | CA |  |  |  |  | Not Started | C | Yip, Kin | M4 | BNL | Fab & Assy | Kin Yip | BNL | null | POM02.2.02.03.02.04.02 | C | 2.02 | 16718 | 018 | 2.02 | 02 | MP6LAEXCLUDE | PP6 | MP210033 | UDF_G1 | UDF_G1 | 58034.2155 | 1 | FAB | Delivery | Yes |  |  |  |  |  |  |
| S291000 |  | (LN2 supply transfer line system) Main fabrication items |  | 90d | 2021-04-21 A | 2021-08-31 | S290600, S290210, S290910 | 15% | 6d | 2021-08-24 | 2022-01-05 | 84d | 0d |  | 2021-08-31 | PROF6 AD |  | S291000 | 0 | S257200 | S257200 | S291000 | CA |  |  |  |  | Not Started | C | Yip, Kin | L4 | BNL | Fab & Assy | Kin Yip | BNL | null | POM02.2.02.03.02.04.02 | C | 2.02 | 16718 | 018 | 2.02 | 02 |  |  |  |  |  |  |  |  |  |  | Yes |  |  |  |  |  |
| S290910 |  | Completed - Procure LN2 supply transfer line system, Phase 4 (Raw Material) - Delivery Acceptance | milestone | 0d | 2021-08-23 | 2021-08-23 | S290900 FF |  |  |  |  | 84d | 0d |  |  |  |  | S290900 | 0 | S256900 | S256900 |  | NOCA |  |  |  |  | Not Started | C | Yip, Kin |  | BNL | Fab & Assy | Kin Yip | BNL |  | POM02.2.02.03.02.04.02 |  |  | 16718 |  |  | 02 | MP6LAEXCLUDE |  |  |  |  |  |  |  |  | Yes |  | L5 |  |  |  |  |
| S291100 |  | (LN2 supply transfer line system) Final assemblies |  | 30d | 2021-09-01 | 2021-10-14 | S291000 |  |  |  |  | 84d | 0d |  |  | PROF6 AD |  | S291100 | 0 | S257300 | S257300 | S291100 | CA |  |  |  |  | Not Started | C | Yip, Kin | L4 | BNL | Fab & Assy | Kin Yip | BNL | null | POM02.2.02.03.02.04.02 | C | 2.02 | 16718 | 018 | 2.02 | 02 |  |  |  |  |  |  |  |  |  |  |  |  |  |  |  |  |
| S291200 |  | (LN2 supply transfer line system) BNL Holdpoint witness |  | 1d | 2021-10-15 | 2021-10-15 | S291100 |  |  |  |  | 84d | 0d |  |  | PROF6 AD |  | S291200 | 0 | S257400 | S257400 | S291200 | CA |  |  |  |  | Not Started | C | Yip, Kin | L4 | BNL | Procurement | Kin Yip | BNL | null | POM02.2.02.03.02.04.02 | C | 2.02 | 16718 | 018 | 2.02 | 02 |  |  |  |  |  |  |  |  |  |  |  |  |  |  |  |  |
| S291210 |  | Completed - (LN2 supply transfer line system) BNL Holdpoint witness | milestone | 0d | 2021-10-15 | 2021-10-15 | S291200 FF |  |  |  |  | 84d | 0d |  |  |  |  | S291200 | 0 | S257400 | S257400 |  | NOCA |  |  |  |  | Not Started | C | Yip, Kin |  | BNL | Procurement | Kin Yip | BNL |  | POM02.2.02.03.02.04.02 |  |  | 16718 |  |  | 02 |  |  |  |  |  |  |  |  |  |  |  | L5 |  |  |  |  |
| S291300 |  | (LN2 supply transfer line system) Shipping Labor |  | 13d | 2021-10-18 | 2021-11-03 | S289300 SS, OBLG289310 SS, S291210 |  |  |  |  | 84d | 0d |  |  | PROF6 AD |  | S291300 | 0 | S257500 | S257500 | S291300 | CA |  |  |  |  | Not Started | C | Yip, Kin | L4 | BNL | Procurement | Kin Yip | BNL | null | POM02.2.02.03.02.04.02 | C | 2.02 | 16718 | 018 | 2.02 | 02 |  |  |  |  |  |  |  |  |  |  |  |  |  |  |  |  |
| S291400 |  | Procure LN2 supply transfer line system - Phase 5 - Shipping - Leadtime |  | 10d | 2021-10-18 | 2021-10-29 | S289300 SS, OBLG289310 SS, S291210 |  |  |  |  | 87d | 3d |  |  |  |  | S291400 | 0 | S257000 | S277594364 |  | NOCA |  |  |  |  | Not Started | C | Yip, Kin | M4 | BNL | Fab & Assy | Kin Yip | BNL | null | POM02.2.02.03.02.04.02 | C |  | 16718 |  |  | 02 | MP6LAEXCLUDE | PP6 | MP210034 |  |  |  |  |  |  |  |  |  |  |  |  |  |
| S291500 |  | Procure LN2 supply transfer line system - Phase 5 - Shipping - Delivery Acceptance |  | 0d | 2021-11-04 | 2021-11-04 | S291400, S291300 FF |  |  |  |  | 84d | 0d | start on or after 2021-07-16 |  | Material (Purchase (1st $2M) [107261 h] | 119,661.82 | S291500 | 0 | S257000 | S257000 | S291500 | CA |  |  |  |  | Not Started | C | Yip, Kin | M4 | BNL | Fab & Assy | Kin Yip | BNL | null | POM02.2.02.03.02.04.02 | C | 2.02 | 16718 | 018 | 2.02 | 02 | MP6LAEXCLUDE | PP6 | MP210034 | UDF_G1 | UDF_G3 | 56827.10352 | 1 | FAB | Delivery | Yes |  |  | 190417 ELM BNLU per GRY |  |  |  |
| S291510 |  | Completed - Procure LN2 supply transfer line system - Phase 5 - Shipping - Delivery Acceptance | milestone | 0d | 2021-11-04 | 2021-11-04 | S291500 FF, S1008520 |  |  |  |  | 84d | 0d |  |  |  |  | S291500 | 0 | S257000 | S257000 |  | NOCA | 77 |  |  |  | Not Started | C | Yip, Kin |  | BNL | Fab & Assy | Kin Yip | BNL |  | POM02.2.02.03.02.04.02 |  |  | 16718 |  |  | 02 | MP6LAEXCLUDE |  |  |  |  |  |  |  |  | Yes |  | L5 |  | 2022-03-02 | PMP_2x |  |
|  | 05 | **Delivery and receiving, LN2 Supply Transfer Line System** |  |  | 2021-11-04 | 2021-11-05 |  |  |  |  |  |  |  |  |  |  |  |  |  |  |  |  |  |  |  |  |  |  |  |  |  |  |  |  |  |  |  |  |  |  |  |  |  |  |  |  |  |  |  |  |  |  |  |  |  |  |  |  |  |
| S291600 |  | (LN2 supply transfer line system) Rigging/Truck Unloading |  | 1d | 2021-11-04 | 2021-11-04 | S291510 |  |  |  |  | 84d | 0d |  |  | PROF3 AD [5 h]; CRAFT3 [16 h] | 2,794.08 | S291600 | 0 | S257600 | S257600 | S291600 | CA |  |  |  |  | Not Started | C | Yip, Kin | L4 | BNL | Procurement | Kin Yip | BNL | null | POM02.2.02.03.02.05 | C | 2.02 | 16718 |  | 2.02 | 05 |  |  |  |  |  |  |  |  |  |  |  |  |  |  |  |  |
| S291700 |  | (LN2 supply transfer line system) Inspection |  | 1d | 2021-11-05 | 2021-11-05 | S291600 |  |  |  |  | 84d | 0d |  |  | PROF6 AD [1 h] | 204.75 | S291700 | 0 | S257700 | S257700 | S291700 | CA |  |  |  |  | Not Started | C | Yip, Kin | L4 | BNL | Procurement | Kin Yip | BNL | null | POM02.2.02.03.02.05 | C | 2.02 | 16718 |  | 2.02 | 05 |  |  |  |  |  |  |  |  |  |  |  |  |  |  |  |  |
|  | 06 | **Installation, LN2 Supply Transfer Line System** |  |  | 2021-03-17 | 2021-12-30 |  |  |  |  |  |  |  |  |  |  |  |  |  |  |  |  |  |  |  |  |  |  |  |  |  |  |  |  |  |  |  |  |  |  |  |  |  |  |  |  |  |  |  |  |  |  |  |  |  |  |  |  |  |
| S291800 |  | (LN2 supply transfer line system) Piping supports procure materials M&S |  | 15d | 2021-03-17 A | 2021-03-19 A | S288410, S288500, S338200 | 100% |  | 2021-04-01 | 2021-04-21 |  |  |  |  | Material (Purchase (1st $2M) [13000 h] | 15,088.9 | S291800 | 0 | S257800 | S257800 | S291800 | CA |  |  |  |  | Not Started | C | Yip, Kin | M4 | BNL | Fab & Assy | Kin Yip | BNL | null | POM02.2.02.03.02.06 | C | 2.02 | 16718 | 003 | 2.02 | 06 |  |  | TBD | UDF_G1 | UDF_G3 | 15088.89603 | 1 |  |  |  |  |  | 190317 ELM Logic per L2 |  |  | 2019-06-18 |
| S291900 |  | (LN2 supply transfer line system) Piping supports procure materials Labor |  | 15d | 2021-03-17 A | 2021-03-19 A | S288500, S338200 | 100% |  | 2021-04-01 | 2021-04-21 |  |  |  |  | PROF3 AD [12 h] | 1,563.66 | S291900 | 0 | S257900 | S257900 | S291900 | CA |  |  |  |  | Not Started | C | Yip, Kin | L4 | BNL | Procurement | Kin Yip | BNL | null | POM02.2.02.03.02.06 | C | 2.02 | 16718 |  | 2.02 | 06 |  |  |  |  |  |  |  |  |  |  |  |  |  |  |  | 2019-06-18 |
| S292000 |  | (LN2 supply transfer line system) Install piping supports (Outside pipe run) |  | 20d | 2021-05-17 A | 2021-07-20 | S291900, S291800 | 3% | 35d | 2021-06-01 | 2021-06-28 | 160d | 0d | start on or after 2021-05-14 | 2021-07-20 | PROF3 AD [48 h]; TECH3 AD [40 h] | 10,956.46 | S292000 | 0 | S258000 | S258000 | S292000 | CA |  |  |  |  | Not Started | C | Yip, Kin | L4 | BNL | Installation | Kin Yip | BNL | null | POM02.2.02.03.02.06 | C | 2.02 | 16718 |  | 2.02 | 06 |  |  |  |  |  |  |  |  |  | Yes |  |  |  |  |  |  |
| S292100 |  | (LN2 supply transfer line system) Rigging in place onto piping supports |  | 10d | 2021-11-08 | 2021-11-22 | S291700, S292000 |  |  |  |  | 84d | 0d |  |  | PROF3 AD [16 h]; TECH3 AD [240 h]; CRAFT3 [16 h] | 33,327.76 | S292100 | 0 | S258100 | S258100 | S292100 | CA |  |  |  |  | Not Started | C | Yip, Kin | L4 | BNL | Installation | Kin Yip | BNL | null | POM02.2.02.03.02.06 | C | 2.02 | 16718 |  | 2.02 | 06 |  |  |  |  |  |  |  |  |  | Yes |  |  |  |  |  |  |
| S292110 |  | Completed - (LN2 supply transfer line system) Rigging in place onto piping supports | milestone | 0d | 2021-11-22 | 2021-11-22 | S292100 FF |  |  |  |  | 84d | 0d |  |  |  |  | S292100 | 0 | S258100 | S258100 |  | NOCA |  |  |  |  | Not Started | C | Yip, Kin |  | BNL | Installation | Kin Yip | BNL |  | POM02.2.02.03.02.06 |  |  |  |  |  | 06 |  |  |  |  |  |  |  |  |  | Yes |  | L5 |  |  |  |  |
| S292120 |  | Welding LN2 Segment #1 to LN2 Dewar |  | 10d | 2021-11-23 | 2021-12-08 | S292100 |  |  |  |  | 89d | 5d |  |  | CRAFT3 [80 h] | 10,615.05 | S292100 | 0 | S258100 | S258100 | S292120 | CA |  |  |  |  | Not Started | C | Yip, Kin | L4 | BNL | Installation | Kin Yip | BNL | null | POM02.2.02.03.02.06 | C | 2.02 | 16718 | 018 | 2.02 | 06 |  |  |  |  |  |  |  |  |  | Yes |  |  |  |  |  |  |
| S292200 |  | (LN2 supply transfer line system) Install Instrumentation, reliefs and air supply to valves |  | 15d | 2021-11-23 | 2021-12-15 | S292110 |  |  |  |  | 84d | 0d |  |  | PROF3 AD [24 h]; TECH3 AD [96 h] | 14,844.06 | S292200 | 0 | S258200 | S258200 | S292200 | CA |  |  |  |  | Not Started | C | Yip, Kin | L4 | BNL | Installation | Kin Yip | BNL | null | POM02.2.02.03.02.06 | C | 2.02 | 16718 |  | 2.02 | 06 |  |  |  |  |  |  |  |  |  | Yes |  |  |  |  |  |  |
| S292300 |  | (LN2 supply transfer line system) Final pressure. leak check and equipment shakedown |  | 10d | 2021-12-16 | 2021-12-30 | S292200, S292120 |  |  |  |  | 84d | 0d |  |  | PROF3 AD [20 h]; TECH3 AD [64 h] | 10,432.9 | S292300 | 0 | S258300 | S258300 | S292300 | CA |  |  |  |  | Not Started | C | Yip, Kin | L4 | BNL | Test_System | Kin Yip | BNL | null | POM02.2.02.03.02.06 | C | 2.02 | 16718 |  | 2.02 | 06 |  |  |  |  |  |  |  |  |  | Yes |  |  |  |  |  |  |
| S292310 |  | Completed - (LN2 supply transfer line system) Final pressure. leak check and equipment shakedown | milestone | 0d | 2021-12-30 | 2021-12-30 | S292300 FF |  |  |  |  | 84d |  |  |  |  |  | S292300 | 0 | S258300 | S258300 |  | NOCA |  |  |  |  | Not Started | C | Yip, Kin |  | BNL | Test_System | Kin Yip | BNL |  | POM02.2.02.03.02.06 |  |  |  |  |  | 06 |  |  |  |  |  |  |  |  |  | Yes |  | L5 |  |  |  |  |

Notes:
- S1008520: BNL_UDF_Old Activity Name 181221: (LN2 supply transfer line system) Shipping Labor
- S290700: BNL_UDF_Old Activity Name 181221: (LN2 supply transfer line system) Raw Material procurement Labor
- S290800: BNL_UDF_Old Activity Name 181221: Procure LN2 supply transfer line system - Phase 4 - Raw Material - Leadtime
- S290900: BNL_UDF_Old Activity Name 181221: Procure LN2 supply transfer line system - Phase 4 - Raw Material - Delivery Acceptance
- S291000: BNL_UDF_Old Activity Name 181221: (LN2 supply transfer line system) Main fabrication items
- S290910: BNL_UDF_Old Activity Name 181221: Procure LN2 supply transfer line system - Phase 4 - Raw Material - Delivery Acceptance
- S291100: BNL_UDF_Old Activity Name 181221: (LN2 supply transfer line system) Final assemblies
- S291200: BNL_UDF_Old Activity Name 181221: (LN2 supply transfer line system) BNL Holdpoint witness
- S291210: BNL_UDF_Old Activity Name 181221: (LN2 supply transfer line system) BNL Holdpoint witness
- S291300: BNL_UDF_Old Activity Name 181221: (LN2 supply transfer line system) Shipping Labor
- S291400: BNL_UDF_Old Activity Name 181221: Procure LN2 supply transfer line system - Phase 5 - Shipping - Leadtime
- S291500: BNL_UDF_Old Activity Name 181221: Procure LN2 supply transfer line system - Phase 5 - Shipping - Delivery Acceptance
- S291510: BNL_UDF_Old Activity Name 181221: Procure LN2 supply transfer line system - Phase 5 - Shipping - Delivery Acceptance
- S291600: BNL_UDF_Old Activity Name 181221: (LN2 supply transfer line system) Rigging/Truck Unloading
- S291700: BNL_UDF_Old Activity Name 181221: (LN2 supply transfer line system) Inspection
- S291800: BNL_UDF_Old Activity Name 181221: (LN2 supply transfer line system) Piping supports procure materials M&S
- S291900: BNL_UDF_Old Activity Name 181221: (LN2 supply transfer line system) Piping supports procure materials Labor
- S292000: BNL_UDF_Old Activity Name 181221: (LN2 supply transfer line system) Install piping supports (Outside pipe run)
- S292100: BNL_UDF_Old Activity Name 181221: (LN2 supply transfer line system) Rigging in place onto piping supports
- S292110: BNL_UDF_Old Activity Name 181221: (LN2 supply transfer line system) Rigging in place onto piping supports
- S292120: BNL_UDF_Old Activity Name 181221: (LN2 supply transfer line system) Rigging in place onto piping supports
- S292200: BNL_UDF_Old Activity Name 181221: (LN2 supply transfer line system) Install Instrumentation, reliefs and air supply to valves
- S292300: BNL_UDF_Old Activity Name 181221: (LN2 supply transfer line system) Final pressure. leak check and equipment shakedown
- S292310: BNL_UDF_Old Activity Name 181221: (LN2 supply transfer line system) Final pressure. leak check and equipment shakedown

| ID | WBS | Activity | Type | Duration | Start | Finish | Predecessors | Complete | Remaining | Planned start | Planned finish | Total float | Free float | Constraint | Expected finish | Resources | Cost | BNL_UDF_Temp Text 01 | BNL_UDF_Percent Complete | BNL_UDF_OPC TEC (deprecated) | BNL_UDF_Temp Date 01 | BNL_UDF_Old Activity ID 181221 | RG Check | BNL_Activity Status | BNL_Fund Source | BNL_Estimator | BNL_Cost Basis | BNL_Location | BNL_EDIA | BNL_CAM | BNL_Institution | BNL_OPC TEC (deprecated) | BNL_WBS | BNL_EVT | BNL_WBS_Hierarchical | Completed | BNL_Account Number | BNL_Cobra WP | BNL_Master Control Account | BNL_Cobra Control Account | BNL_Milestone Level | Indicator - Procurement | Indicator - Float | BNL_UDF_Remaining Tot Cost | BNL_UDF_Percent_remaining | BNL_Proc Sig | BNL_UDF_Exclude | BNL_Proc Sig Phase | Major SC Activity | SPH Proc Register | BNL_PCR ID | BNL_Obligation |
| --- | --- | --- | --- | --- | --- | --- | --- | --- | --- | --- | --- | --- | --- | --- | --- | --- | --- | --- | --- | --- | --- | --- | --- | --- | --- | --- | --- | --- | --- | --- | --- | --- | --- | --- | --- | --- | --- | --- | --- | --- | --- | --- | --- | --- | --- | --- | --- | --- | --- | --- | --- | --- |
|  | 03 | **Warm Piping System** |  |  | 2018-03-02 | 2022-04-25 |  |  |  |  |  |  |  |  |  |  |  |  |  |  |  |  |  |  |  |  |  |  |  |  |  |  |  |  |  |  |  |  |  |  |  |  |  |  |  |  |  |  |  |  |  |  |
|  | 01 | **Engineering and Design, Warm Piping System** |  |  | 2018-03-02 | 2021-08-30 |  |  |  |  |  |  |  |  |  |  |  |  |  |  |  |  |  |  |  |  |  |  |  |  |  |  |  |  |  |  |  |  |  |  |  |  |  |  |  |  |  |  |  |  |  |  |
| S292500 |  | (Warm Piping System) P&ID development & drawings |  | 133d | 2018-03-02 A | 2018-09-07 A | S281700 FF | 100% |  |  |  |  |  |  |  |  |  | S292500 | 100 | S258500 | 2018-09-09 | S258500 | NOCA | Completed | C | Yip, Kin | L4 | BNL | Design | Kin Yip | BNL | null | POM02.2.02.03.03.01 | C | 01 | yes |  |  |  |  |  |  |  |  |  |  |  |  |  |  |  |  |
| S292400 |  | (Warm Piping System) Cryo Process Design |  | 11d | 2019-01-02 A | 2019-01-16 A | S100500 | 100% |  |  |  |  |  |  |  |  |  | S292400 | 100 | S258400 |  | S258400 | NOCA | Completed | C | Yip, Kin | L4 | BNL | Design | Kin Yip | BNL | null | POM02.2.02.03.03.01 | C | 01 | yes | 16718 |  |  |  |  |  |  |  |  |  |  |  |  |  |  |  |
| S292600 |  | (Warm Piping System) Mechanical Engineering Tasks |  | 75d | 2019-02-14 A | 2019-05-31 A | S292400 | 100% |  |  |  |  |  |  |  |  |  | S292600 | 20 | S258600 | 2019-06-28 | S258600 | NOCA | Completed | C | Yip, Kin | L4 | BNL | Design | Kin Yip | BNL | null | POM02.2.02.03.03.01 | C | 01 | yes | 16718 |  |  |  |  |  |  |  |  |  |  |  |  |  |  |  |
| S292602 |  | (Warm Piping System) Mechanical Engineering Tasks Split |  | 14d | 2019-12-02 A | 2021-08-30 | S292600 | 80% | 64d | 2019-12-02 | 2019-12-19 | 61d | 0d | start on or after 2019-11-18 | 2021-08-30 | PROF3 AD [19 h]; PROF6 AD [38 h] | 9,737.41 | S292600 | 20 | S258600 | 2019-06-28 | S258600 | CA | Not Started | C | Yip, Kin | L4 | BNL | Design | Kin Yip | BNL | null | POM02.2.02.03.03.01 | C | 01 |  | 16718 | S292602 | 2.02 | 2.02 |  |  |  |  |  |  |  |  |  |  |  |  |
| S292700 |  | (Warm Piping System) Technical Specifications |  | 9d | 2020-05-01 A | 2021-03-29 A | S292400, S292500 | 100% |  | 2020-05-01 | 2020-05-13 |  |  | start on or after 2020-04-01 |  | PROF3 AD [6 h]; PROF6 AD [12 h] | 3,074.97 | S292700 | 0 | S258700 |  | S258700 | CA | Not Started | C | Yip, Kin | L4 | BNL | Design | Kin Yip | BNL | null | POM02.2.02.03.03.01 | C | 01 |  | 16718 | S292700 | 2.02 | 2.02 |  |  |  |  |  |  |  |  |  |  |  |  |
| S292610 |  | Completed - (Warm Piping System) Mechanical Engineering Tasks | milestone | 0d | 2021-08-30 | 2021-08-30 | S292602 |  |  |  |  | 61d | 0d |  |  |  |  | S292600 | 0 | S258600 |  | S258600 | NOCA | Not Started | C | Yip, Kin |  | BNL | Design | Kin Yip | BNL |  | POM02.2.02.03.03.01 |  | 01 |  |  |  |  |  | L5 |  |  |  |  |  |  |  |  |  |  |  |
|  | 02 | **Design/Drafting, Warm Piping System** |  |  | 2019-02-14 | 2021-07-22 |  |  |  |  |  |  |  |  |  |  |  |  |  |  |  |  |  |  |  |  |  |  |  |  |  |  |  |  |  |  |  |  |  |  |  |  |  |  |  |  |  |  |  |  |  |  |
|  | 01 | **Warm Piping tie in to WR header** |  |  | 2020-08-03 | 2021-07-22 |  |  |  |  |  |  |  |  |  |  |  |  |  |  |  |  |  |  |  |  |  |  |  |  |  |  |  |  |  |  |  |  |  |  |  |  |  |  |  |  |  |  |  |  |  |  |
| S292800 |  | (Warm Piping tie in to WR header) General Arrangement Layout |  | 10d | 2020-08-03 A | 2021-07-20 | S288500, S292400, S292500 | 95% | 35d | 2020-08-03 | 2020-08-14 | 86d | 0d |  | 2021-07-20 | PROF3 AD [20 h]; PROF6 AD [80 h] | 17,969.63 | S292800 | 0 | S258800 |  | S258800 | CA | Not Started | C | Yip, Kin | L4 | BNL | Design | Kin Yip | BNL | null | POM02.2.02.03.03.02.01 | C | 01 |  | 16718 | S292800 | 2.02 | 2.02 |  |  |  |  |  |  |  |  |  |  |  |  |
| S292900 |  | (Warm Piping tie in to WR header) Detailed drawing package with weld map |  | 20d | 2020-11-17 A | 2021-07-22 | S282900, S292800 | 79% | 2d | 2020-11-17 | 2020-12-16 | 86d | 0d |  | 2021-06-30 | PROF3 AD [16 h]; PROF6 AD [16 h] | 5,265.4 | S292900 | 0 | S258900 |  | S258900 | CA | Not Started | C | Yip, Kin | L4 | BNL | Design | Kin Yip | BNL | null | POM02.2.02.03.03.02.01 | C | 01 |  | 16718 | S292900 | 2.02 | 2.02 |  |  |  |  |  |  |  |  |  |  |  |  |
| S292910 |  | Completed - (Warm Piping tie in to WR header) Detailed drawing package with weld map | milestone | 0d | 2021-04-30 A | 2021-04-30 A | S292900 FF | 100% |  |  |  |  |  |  |  |  |  | S292900 | 0 | S258900 |  | S258900 | NOCA | Not Started | C | Yip, Kin |  | BNL | Design | Kin Yip | BNL |  | POM02.2.02.03.03.02.01 |  | 01 |  |  |  |  |  | L5 |  |  |  |  |  |  |  |  |  |  |  |
|  | 02 | **Warm Piping tie in Bldg 1010B Compressor** |  |  | 2020-08-03 | 2021-03-30 |  |  |  |  |  |  |  |  |  |  |  |  |  |  |  |  |  |  |  |  |  |  |  |  |  |  |  |  |  |  |  |  |  |  |  |  |  |  |  |  |  |  |  |  |  |  |
| S293000 |  | (Warm Piping tie in bldg. 1010B compressor) General Arrangement Layout |  | 8d | 2020-08-03 A | 2021-03-30 A | S292400, S292500 | 100% |  | 2020-08-03 | 2020-08-12 |  |  | start on or after 2020-04-01 |  | PROF3 AD [16 h]; PROF6 AD [80 h] | 17,463.59 | S293000 | 0 | S259000 |  | S259000 | CA | Not Started | C | Yip, Kin | L4 | BNL | Design | Kin Yip | BNL | null | POM02.2.02.03.03.02.02 | C | 02 |  | 16718 | S293000 | 2.02 | 2.02 |  |  |  |  |  |  |  |  |  |  |  |  |
| S293100 |  | (Warm Piping tie in bldg. 1010B compressor) Detailed drawing package with weld map |  | 5d | 2021-02-16 A | 2021-03-30 A | S282900, S293000 | 100% |  | 2021-03-16 | 2021-03-22 |  |  | start on or after 2020-04-01 |  | PROF3 AD [16 h]; PROF6 AD [80 h] | 17,987.49 | S293100 | 0 | S259100 |  | S259100 | CA | Not Started | C | Yip, Kin | L4 | BNL | Design | Kin Yip | BNL | null | POM02.2.02.03.03.02.02 | C | 02 |  | 16718 | S293100 | 2.02 | 2.02 |  |  |  |  |  |  |  |  |  |  |  |  |
|  | 03 | **GN2 Vent Line from Platform Coldbox** |  |  | 2019-02-14 | 2020-07-15 |  |  |  |  |  |  |  |  |  |  |  |  |  |  |  |  |  |  |  |  |  |  |  |  |  |  |  |  |  |  |  |  |  |  |  |  |  |  |  |  |  |  |  |  |  |  |
| S293200 |  | (GN2 Vent Line from platform coldbox) General Arrangement Layout |  | 75d | 2019-02-14 A | 2019-05-31 A | S292400, S292500 | 100% |  |  |  |  |  |  |  |  |  | S293200 | 30 | S259200 | 2019-06-28 | S259200 | NOCA | Completed | C | Yip, Kin | L4 | BNL | Design | Kin Yip | BNL | null | POM02.2.02.03.03.02.03 | C | 03 | yes | 16718 |  |  |  |  |  |  |  |  |  |  |  |  |  |  |  |
| S293202 |  | (GN2 Vent Line from platform coldbox) General Arrangement Layout Split |  | 20d | 2019-06-03 A | 2019-06-28 A | S293200 | 100% |  |  |  |  |  |  |  |  |  | S293200 | 30 | S259200 | 2019-06-28 | S259200 | NOCA | Completed | C | Yip, Kin | L4 | BNL | Design | Kin Yip | BNL | null | POM02.2.02.03.03.02.03 | C | 03 |  | 16718 |  | 2.02 |  |  |  |  |  |  |  |  |  |  |  |  |  |
| S293300 |  | (GN2 Vent Line from platform coldbox) Detailed drawing package with weld map |  | 5d | 2019-12-09 A | 2020-07-15 A | S293202 | 100% |  | 2019-12-09 | 2019-12-13 |  |  | start on or after 2019-12-09 |  | PROF3 AD [16 h]; PROF6 AD [80 h] | 17,463.59 | S293300 | 0 | S259300 |  | S259300 | CA | Not Started | C | Yip, Kin | L4 | BNL | Design | Kin Yip | BNL | null | POM02.2.02.03.03.02.03 | C | 03 |  | 16718 | S293300 | 2.02 | 2.02 |  |  |  |  |  |  |  |  |  |  |  |  |
|  | 04 | **Warm Piping for Summer 80K Hold Helium Compressor Loop** |  |  | 2019-03-01 | 2021-06-30 |  |  |  |  |  |  |  |  |  |  |  |  |  |  |  |  |  |  |  |  |  |  |  |  |  |  |  |  |  |  |  |  |  |  |  |  |  |  |  |  |  |  |  |  |  |  |
| S293400 |  | (Current Leads Warm Piping) General Arrangement Layout |  | 53d | 2019-03-01 A | 2019-05-14 A | S292400, S292500 | 100% |  |  |  |  |  |  |  |  |  | S293400 | 0 | S259400 |  | S259400 | NOCA | Completed | C | Yip, Kin | L4 | BNL | Design | Kin Yip | BNL | null | POM02.2.02.03.03.02.04 | C | 04 | yes | 16718 |  |  |  |  |  |  |  |  |  |  |  |  |  |  |  |
| S293500 |  | (Current Leads Warm Piping) Detailed drawing package with weld map |  | 5d | 2019-12-16 A | 2021-06-30 | S293400 | 60% | 22d | 2019-12-16 | 2019-12-20 | 101d | 0d | start on or after 2019-12-16 | 2021-06-30 | PROF3 AD [26 h]; PROF6 AD [128 h] | 27,992.34 | S293500 | 0 | S259500 |  | S259500 | CA | Not Started | C | Yip, Kin | L4 | BNL | Design | Kin Yip | BNL | null | POM02.2.02.03.03.02.04 | C | 04 |  | 16718 | S293500 | 2.02 | 2.02 |  |  |  |  |  |  |  |  |  |  |  |  |
|  | 03 | **Procurement of Materials, Warm Piping System** |  |  | 2020-12-31 | 2021-07-26 |  |  |  |  |  |  |  |  |  |  |  |  |  |  |  |  |  |  |  |  |  |  |  |  |  |  |  |  |  |  |  |  |  |  |  |  |  |  |  |  |  |  |  |  |  |  |
| S293600 |  | (Warm Piping System Materials Procurement) Reliefs M&S |  | 90d | 2020-12-31 A | 2021-04-30 A | S292400, S292700, S101000 | 100% |  | 2020-12-31 | 2021-05-10 |  |  | start on or after 2020-04-01 |  | Material (Purchase (1st $2M) [8000 h] | 9,285.47 | S293600 | 0 | S259600 |  | S259600 | CA | Not Started | C | Yip, Kin | M4 | BNL | Fab & Assy | Kin Yip | BNL | null | POM02.2.02.03.03.03 | E | 03 |  | 16718 | S293600 | 2.02 | 2.02 |  | UDF_G1 | UDF_G3 | 9103.40632 | 1 | TBD |  |  |  |  |  |  |
| S293700 |  | (Warm Piping System Materials Procurement) Reliefs Labor |  | 90d | 2020-12-31 A | 2021-04-30 A | S292400, S292700, S101000 | 100% |  | 2020-12-31 | 2021-05-10 |  |  | start on or after 2020-04-01 |  | PROF3 AD [72 h]; PROF6 AD [72 h] | 23,694.3 | S293700 | 0 | S260000 |  | S260000 | CA | Not Started | C | Yip, Kin | L4 | BNL | Procurement | Kin Yip | BNL | null | POM02.2.02.03.03.03 | C | 03 |  | 16718 | S293700 | 2.02 | 2.02 |  |  |  |  |  |  |  |  |  |  |  |  |
| S293800 |  | (Warm Piping System Materials Procurement) Warm Valves M&S |  | 90d | 2020-12-31 A | 2021-04-30 A | S292400, S292700, S101000 | 100% |  | 2020-12-31 | 2021-05-10 |  |  | start on or after 2020-04-01 |  | Material (Purchase (1st $2M) [15000 h] | 17,410.26 | S293800 | 0 | S259700 |  | S259700 | CA | Not Started | C | Yip, Kin | M4 | BNL | Fab & Assy | Kin Yip | BNL | null | POM02.2.02.03.03.03 | E | 03 |  | 16718 | S293800 | 2.02 | 2.02 |  | UDF_G1 | UDF_G3 | 17068.88685 | 1 | TBD |  |  |  |  |  |  |
| S293900 |  | (Warm Piping System Materials Procurement) Warm Valves |  | 90d | 2020-12-31 A | 2021-04-30 A | S292400, S292700, S101000 | 100% |  | 2020-12-31 | 2021-05-10 |  |  | start on or after 2020-04-01 |  | PROF6 AD [36 h] | 7,156.18 | S293900 | 0 | S260100 |  | S260100 | CA | Not Started | C | Yip, Kin | L4 | BNL | Procurement | Kin Yip | BNL | null | POM02.2.02.03.03.03 | C | 03 |  | 16718 | S293900 | 2.02 | 2.02 |  |  |  |  |  |  |  |  |  |  |  |  |
| S294000 |  | Procure Warm Piping and fittings - Provide Requirements to Procurement |  | 20d | 2021-02-01 A | 2021-02-25 A | S292700, S293500, S101000, S293100, S293300, S292910 | 100% |  | 2021-04-01 | 2021-04-28 |  |  |  |  | PROF4 AD [24 h] | 3,640.39 | S294000 | 0 | S259800 |  | S259800 | CA | Not Started | C | Yip, Kin | M4 | BNL | Fab & Assy | Kin Yip | BNL | null | POM02.2.02.03.03.03 | C | 03 |  | 16718 | S294000 | 2.02 | 2.02 |  |  |  |  |  | MP210040 | MP6LAEXCLUDE | PP1 | Yes |  |  |  |
| S294100 |  | Procure Warm Piping and fittings - Prepare and Send Solicitation |  | 20d | 2021-02-01 A | 2021-02-25 A | S294000 | 100% |  | 2021-04-29 | 2021-05-26 |  |  |  |  |  |  | S294100 | 0 | S259800 |  | S259810 | NOCA | Not Started | C | Yip, Kin | M4 | BNL | Fab & Assy | Kin Yip | BNL | null | POM02.2.02.03.03.03 | C | 03 |  |  |  |  |  |  |  |  |  |  | MP210040 | MP6LAEXCLUDE | PP2 |  |  |  |  |
| S294200 |  | Procure Warm Piping and fittings - Vendor Response and Selection |  | 20d | 2021-02-01 A | 2021-02-25 A | S294100 | 100% |  | 2021-05-27 | 2021-06-24 |  |  |  |  |  |  | S294200 | 0 | S259800 |  | S259820 | NOCA | Not Started | C | Yip, Kin | M4 | BNL | Fab & Assy | Kin Yip | BNL | null | POM02.2.02.03.03.03 | C | 03 |  |  |  |  |  |  |  |  |  |  | MP210040 | MP6LAEXCLUDE | PP4 |  |  |  |  |
| S294300 |  | Procure Warm Piping and fittings - Contract award | milestone | 0d | 2021-02-01 A | 2021-02-01 A | S294200 | 100% |  | 2021-06-25 | 2021-06-25 |  |  |  |  |  |  | S294300 | 0 | S259800 |  | S259830 | NOCA | Not Started | C | Yip, Kin | M4 | BNL | Fab & Assy | Kin Yip | BNL | null | POM02.2.02.03.03.03 | K | 03 |  |  |  |  |  | L5 |  |  |  |  | MP210040 | MP6LAEXCLUDE | PP5 | Yes | Contract Award |  |  |
| S294400 |  | Procure Warm Piping and fittings - Leadtime |  | 100d | 2021-02-01 A | 2021-02-25 A | S294300 SS, OBLG294310 | 100% |  | 2021-06-28 | 2021-11-18 |  |  |  |  |  |  | S294400 | 0 | S259800 |  | S259840 | NOCA | Not Started | C | Yip, Kin | M4 | BNL | Fab & Assy | Kin Yip | BNL | null | POM02.2.02.03.03.03 | C | 03 |  |  |  |  |  |  |  |  |  |  | MP210040 | MP6LAEXCLUDE | PP6 |  |  | 016 |  |
| S294600 |  | (Warm Piping System Materials Procurement) Piping supports M&S |  | 30d | 2021-03-08 A | 2021-05-28 A | S292700, S293500, S101000, S293100, S293300, S292910 | 100% |  | 2021-05-04 | 2021-06-15 |  |  |  |  | Material (Purchase (1st $2M) [10000 h] | 11,606.84 | S294600 | 0 | S259900 |  | S259900 | CA | Not Started | C | Yip, Kin | M4 | BNL | Fab & Assy | Kin Yip | BNL | null | POM02.2.02.03.03.03 | E | 03 |  | 16718 | S294600 | 2.02 | 2.02 |  | UDF_G1 | UDF_G3 | 11379.2579 | 1 | TBD |  |  |  |  |  |  |
| S294700 |  | (Warm Piping System Materials Procurement) Piping supports Labor |  | 30d | 2021-03-08 A | 2021-05-28 A | S292700, S293500, S101000, S293100, S293300, S292910 | 100% |  | 2021-05-04 | 2021-06-15 |  |  |  |  | PROF6 AD [24 h] | 4,770.79 | S294700 | 0 | S260300 |  | S260300 | CA | Not Started | C | Yip, Kin | L4 | BNL | Procurement | Kin Yip | BNL | null | POM02.2.02.03.03.03 | C | 03 |  | 16718 | S294700 | 2.02 | 2.02 |  |  |  |  |  |  |  |  |  |  |  |  |
| OBLG294310 |  | Procure Warm Piping and fittings - Obligation |  | 1d | 2021-07-23 | 2021-07-23 | S294200 |  |  |  |  | 86d | 0d |  |  | Obligation Resource [36413.6 h] | 36,413.63 | S294300 | 0 | S259800 |  | S259830 |  | Not Started | C | Yip, Kin | M4 | BNL | Fab & Assy | Kin Yip | BNL | null | POM02.2.02.03.03.03 | K | 03 |  |  |  |  |  |  |  |  |  |  | MP210040 | MP6LAEXCLUDE | PP5 |  |  |  | OBLG |
| S294500 |  | Procure Warm Piping and fittings - Delivery acceptance |  | 1d | 2021-07-26 | 2021-07-26 | S294400 |  |  |  |  | 86d | 0d |  |  | Material (Purchase (1st $2M) [32000 h] | 37,141.9 | S294500 | 0 | S259800 |  | S259850 | CA | Not Started | C | Yip, Kin | M4 | BNL | Fab & Assy | Kin Yip | BNL | null | POM02.2.02.03.03.03 | C | 03 |  | 16718 | S294500 | 2.02 | 2.02 |  | UDF_G1 | UDF_G3 | 37141.89792 | 1 | MP210040 | MP6LAEXCLUDE | PP6 | Yes | Delivery |  | FAB |
| S294510 |  | Completed - Procure Warm Piping and fittings - Delivery acceptance | milestone | 0d | 2021-07-26 | 2021-07-26 | S294500 FF |  |  |  |  | 86d | 25d |  |  |  |  | S294500 | 0 | S259800 |  | S259850 | NOCA | Not Started | C | Yip, Kin |  | BNL | Fab & Assy | Kin Yip | BNL |  | POM02.2.02.03.03.03 |  | 03 |  |  |  |  |  | L5 |  |  |  |  |  | MP6LAEXCLUDE |  | Yes |  |  |  |

Notes:
- S292500: BNL_UDF_Old Activity Name 181221: (Warm Piping System) P&ID development & drawings
- S292400: BNL_UDF_Old Activity Name 181221: (Warm Piping System) Cryo Process Design
- S292600: BNL_UDF_Old Activity Name 181221: (Warm Piping System) Mechanical Engineering Tasks
- S292602: BNL_UDF_Old Activity Name 181221: (Warm Piping System) Mechanical Engineering Tasks
- S292700: BNL_UDF_Old Activity Name 181221: (Warm Piping System) Technical Specifications
- S292610: BNL_UDF_Old Activity Name 181221: (Warm Piping System) Mechanical Engineering Tasks
- S292800: BNL_UDF_Old Activity Name 181221: (Warm Piping tie in to WR header) General Arrangement Layout
- S292900: BNL_UDF_Old Activity Name 181221: (Warm Piping tie in to WR header) Detailed drawing package with weld map
- S292910: BNL_UDF_Old Activity Name 181221: (Warm Piping tie in to WR header) Detailed drawing package with weld map
- S293000: BNL_UDF_Old Activity Name 181221: (Warm Piping tie in bldg. 1010B compressor) General Arrangement Layout
- S293100: BNL_UDF_Old Activity Name 181221: (Warm Piping tie in bldg. 1010B compressor) Detailed drawing package with weld map
- S293200: BNL_UDF_Old Activity Name 181221: (GN2 Vent Line from platform coldbox) General Arrangement Layout
- S293202: BNL_UDF_Old Activity Name 181221: (GN2 Vent Line from platform coldbox) General Arrangement Layout
- S293300: BNL_UDF_Old Activity Name 181221: (GN2 Vent Line from platform coldbox) Detailed drawing package with weld map
- S293400: BNL_UDF_Old Activity Name 181221: (Current Leads Warm Piping) General Arrangement Layout
- S293500: BNL_UDF_Old Activity Name 181221: (Current Leads Warm Piping) Detailed drawing package with weld map
- S293600: BNL_UDF_Old Activity Name 181221: (Warm Piping System Materials Procurement) Reliefs M&S
- S293700: BNL_UDF_Old Activity Name 181221: (Warm Piping System Materials Procurement) Reliefs Labor
- S293800: BNL_UDF_Old Activity Name 181221: (Warm Piping System Materials Procurement) Warm Valves M&S
- S293900: BNL_UDF_Old Activity Name 181221: (Warm Piping System Materials Procurement) Warm Valves
- S294000: BNL_UDF_Old Activity Name 181221: Procure Warm Piping and fittings - Provide Requirements to Procurement
- S294100: BNL_UDF_Old Activity Name 181221: Procure Warm Piping and fittings - Prepare and Send Solicitation
- S294200: BNL_UDF_Old Activity Name 181221: Procure Warm Piping and fittings - Vendor Response and Selection
- S294300: BNL_UDF_Old Activity Name 181221: Procure Warm Piping and fittings - Contract award
- S294400: BNL_UDF_Old Activity Name 181221: Procure Warm Piping and fittings - Leadtime
- S294600: BNL_UDF_Old Activity Name 181221: (Warm Piping System Materials Procurement) Piping supports M&S
- S294700: BNL_UDF_Old Activity Name 181221: (Warm Piping System Materials Procurement) Piping supports Labor
- OBLG294310: BNL_UDF_Old Activity Name 181221: Procure Warm Piping and fittings - Contract award
- S294500: BNL_UDF_Old Activity Name 181221: Procure Warm Piping and fittings - Delivery acceptance
- S294510: BNL_UDF_Old Activity Name 181221: Procure Warm Piping and fittings - Delivery acceptance

| ID | WBS | Activity | Type | Duration | Start | Finish | Predecessors | Complete | Remaining | Planned start | Planned finish | Total float | Free float | Constraint | Expected finish | Resources | Cost | BNL_UDF_Temp Text 01 | BNL_UDF_Percent Complete | BNL_UDF_OPC TEC (deprecated) | BNL_UDF_Old Activity ID 181221 | BNL_Cobra WP | RG Check | BNL_Activity Status | BNL_Fund Source | BNL_Estimator | BNL_Cost Basis | BNL_Location | BNL_EDIA | BNL_CAM | BNL_Institution | BNL_OPC TEC (deprecated) | BNL_WBS | BNL_EVT | BNL_Master Control Account | BNL_Account Number | BNL_Cobra Control Account | BNL_WBS_Hierarchical | Major SC Activity | Additional EVT documentation required | BNL_Milestone Level | Temp | Target Milestone Date | Variance | PMP Milestones | Indicator - Procurement | Indicator - Float | BNL_Proc Sig | BNL_UDF_Remaining Tot Cost | BNL_UDF_Percent_remaining |
| --- | --- | --- | --- | --- | --- | --- | --- | --- | --- | --- | --- | --- | --- | --- | --- | --- | --- | --- | --- | --- | --- | --- | --- | --- | --- | --- | --- | --- | --- | --- | --- | --- | --- | --- | --- | --- | --- | --- | --- | --- | --- | --- | --- | --- | --- | --- | --- | --- | --- | --- |
|  | 04 | **Installation: Warm Piping Systems** |  |  | 2021-07-09 | 2022-04-25 |  |  |  |  |  |  |  |  |  |  |  |  |  |  |  |  |  |  |  |  |  |  |  |  |  |  |  |  |  |  |  |  |  |  |  |  |  |  |  |  |  |  |  |  |
| S294840 |  | (Warm Piping System) Phase 2: Welding of piping, vent lines and install of piping supports, after coldbox/magnet install |  | 30d | 2021-07-09 | 2021-08-19 | S274310 |  |  |  |  | 163d |  |  |  | PROF3 AD [36 h]; TECH3 AD [180 h]; CRAFT3 [40 h] | 31,002.16 | S294900 | 0 | S260500 | S260500 | S294840 | CA | Not Started | C | Yip, Kin | L4 | BNL | Installation | Kin Yip | BNL | null | POM02.2.02.03.03.04 | C | 2.02 | 16718 | 2.02 | 04 | Yes |  |  |  |  |  |  |  |  |  |  |  |
| S294800 |  | (Warm Piping System) Phase 1: Welding of piping and install of piping supports |  | 90d | 2021-08-31 | 2022-01-12 | S293500, S294700, S294600, S293100, S293300, S293600 FS+15d, S293800 FS+15d, S293700 FS+15d, S293900 FS+15d, S292610, S292910, S294510 |  |  |  |  | 61d | 0d |  |  | PROF3 AD [144 h]; TECH3 AD [360 h]; CRAFT3 [240 h] | 94,083.3 | S294800 | 0 | S260400 | S260400 | S294800 | CA | Not Started | C | Yip, Kin | L4 | BNL | Installation | Kin Yip | BNL | null | POM02.2.02.03.03.04 | C | 2.02 | 16718 | 2.02 | 04 | Yes | Yes |  |  |  |  |  |  |  |  |  |  |
| S294860 |  | (Warm Piping System) Assembly hall work on Platform |  | 15d | 2021-12-30 | 2022-01-21 | S349410 |  |  |  |  | 50d | 0d |  |  | PROF3 AD [18 h]; TECH3 AD [90 h]; CRAFT3 [20 h] | 15,966.11 | S294900 | 0 | S260500 | S260500 | S294860 | CA | Not Started | C | Yip, Kin | L4 | BNL | Installation | Kin Yip | BNL | null | POM02.2.02.03.03.04 | C | 2.02 | 16718 | 2.02 | 04 |  |  |  |  |  |  |  |  |  |  |  |  |
| S294810 |  | Completed - (Warm Piping System) Phase 1: Welding of piping and install of piping supports | milestone | 0d | 2022-01-12 | 2022-01-12 | S294800 FF |  |  |  |  | 61d |  |  |  |  |  | S294800 | 0 | S260400 | S260400 |  | NOCA | Not Started | C | Yip, Kin |  | BNL | Installation | Kin Yip | BNL |  | POM02.2.02.03.03.04 |  |  |  |  | 04 | Yes |  | L5 |  |  |  |  |  |  |  |  |  |
| S295100 |  | (Warm Piping System) Install Instrumentation, reliefs and air supply to valves |  | 10d | 2022-01-24 | 2022-02-04 | S294860 |  |  |  |  | 50d |  |  |  | PROF3 AD [20 h]; TECH3 AD [64 h] | 10,432.9 | S295100 | 0 | S260700 | S260700 | S295100 | CA | Not Started | C | Yip, Kin | L4 | BNL | Installation | Kin Yip | BNL | null | POM02.2.02.03.03.04 | C | 2.02 | 16718 | 2.02 | 04 | Yes |  |  |  |  |  |  |  |  |  |  |  |
| S295300 |  | (Warm Piping System) Vacuum Pumping System installation |  | 5d | 2022-01-24 | 2022-01-28 | S294860 |  |  |  |  | 67d | 0d |  |  | PROF3 AD [8 h]; TECH3 AD [38 h] | 5,674.45 | S295300 | 0 | S260800 | S260820 | S295300 | CA | Not Started | C | Yip, Kin | L4 | BNL | Installation | Kin Yip | BNL | null | POM02.2.02.03.03.04 | C | 2.02 | 16718 | 2.02 | 04 | Yes |  |  |  |  |  |  |  |  |  |  |  |
| S295310 |  | Completed - (Warm Piping System) Vacuum Pumping System installation | milestone | 0d | 2022-01-28 | 2022-01-28 | S295300 FF |  |  |  |  | 67d |  |  |  |  |  | S295300 | 0 | S260800 | S260820 |  | NOCA | Not Started | C | Yip, Kin |  | BNL | Installation | Kin Yip | BNL |  | POM02.2.02.03.03.04 |  |  |  |  | 04 | Yes |  | L5 |  |  |  |  |  |  |  |  |  |
| S294880 |  | (Warm Piping System) IR Hall work Jumper work between Platform and West Wall |  | 15d | 2022-03-29 | 2022-04-18 | S370000 |  |  |  |  | 0d |  |  |  | PROF3 AD [18 h]; TECH3 AD [90 h]; CRAFT3 [20 h] | 15,966.11 | S294900 | 0 | S260500 | S260500 | S294880 | CA | Not Started | C | Yip, Kin | L4 | BNL | Installation | Kin Yip | BNL | null | POM02.2.02.03.03.04 | C | 2.02 | 16718 | 2.02 | 04 |  |  |  |  |  |  |  |  |  |  |  |  |
| S295000 |  | (Warm Piping System) Pressure and leak check |  | 5d | 2022-04-12 | 2022-04-18 | S294810, S294910 FF |  |  |  |  | 0d |  |  |  | PROF3 AD [32 h]; TECH3 AD [32 h] | 8,169.16 | S295000 | 0 | S260600 | S260600 | S295000 | CA | Not Started | C | Yip, Kin | L4 | BNL | Installation | Kin Yip | BNL | null | POM02.2.02.03.03.04 | C | 2.02 | 16718 | 2.02 | 04 | Yes |  |  |  |  |  |  |  |  |  |  |  |
| S294910 |  | Completed - (Warm Piping System) Phase 2: Welding of piping, vent lines & install of piping supports | milestone | 0d | 2022-04-18 | 2022-04-18 | S294840 FF, S294860, S294880 |  |  |  |  | 0d |  |  |  |  |  | S294900 | 0 | S260500 | S260500 |  | NOCA | Not Started | C | Yip, Kin |  | BNL | Installation | Kin Yip | BNL |  | POM02.2.02.03.03.04 |  |  |  |  | 04 | Yes |  | L5 |  |  |  |  |  |  |  |  |  |
| S295200 |  | (Warm Piping System) Final pressure. leak check and equipment shakedown |  | 5d | 2022-04-19 | 2022-04-25 | S295100, S295000 |  |  |  |  | 0d |  |  |  | PROF3 AD [32 h]; TECH3 AD [32 h] | 8,169.16 | S295200 | 0 | S260800 | S260800 | S295200 | CA | Not Started | C | Yip, Kin | L4 | BNL | Installation | Kin Yip | BNL | null | POM02.2.02.03.03.04 | C | 2.02 | 16718 | 2.02 | 04 | Yes |  |  |  |  |  |  |  |  |  |  |  |
|  | 04 | **Cryo Controls Hardware** |  |  | 2019-07-24 | 2022-04-18 |  |  |  |  |  |  |  |  |  |  |  |  |  |  |  |  |  |  |  |  |  |  |  |  |  |  |  |  |  |  |  |  |  |  |  |  |  |  |  |  |  |  |  |  |
|  | 01 | **Engineering and Design** |  |  | 2019-07-24 | 2021-10-27 |  |  |  |  |  |  |  |  |  |  |  |  |  |  |  |  |  |  |  |  |  |  |  |  |  |  |  |  |  |  |  |  |  |  |  |  |  |  |  |  |  |  |  |  |
| S295400 |  | (Controls Hardware) Cryo instrument and equipment specifications 30% |  | 48d | 2019-07-24 A | 2019-09-30 A | S101000 | 100% |  |  |  |  |  |  |  |  |  | S295400 | 0 | S260900 | S260900 |  | NOCA | Completed | C | Yip, Kin | L4 | BNL | Design | Kin Yip | BNL | null | POM02.2.02.03.04.01 | C | 2.02 | 16718 |  | 01 |  |  |  | 1 |  |  |  |  |  |  |  |  |
| S295401 |  | (Controls Hardware) Cryo instrument and equipment specifications 70% |  | 141d | 2019-10-01 A | 2021-07-28 | S295400 | 90% | 41d | 2019-11-01 | 2020-05-27 | 45d | 0d |  | 2021-07-28 | PROF3 AD [84 h]; PROF4 AD [84 h] | 22,997.06 | S295400 | 0 | S260900 | S260900 | S295401 | CA | In Progress | C | Yip, Kin | L4 | BNL | Design | Kin Yip | BNL | null | POM02.2.02.03.04.01 | C | 2.02 | 16718 | 2.02 | 01 |  |  |  | 1 |  |  |  |  |  |  |  |  |
| S295700 |  | (Controls Hardware) I/O list table |  | 37d | 2020-08-07 A | 2021-07-23 | S281800, S295401 FS-4d | 89% | 1d | 2020-08-07 | 2020-09-29 | 62d | 0d |  | 2021-06-14 | PROF3 AD [48 h]; TECH3 AD [48 h] | 11,550.32 | S295700 | 0 | S261200 | S261200 | S295700 | CA | Not Started | C | Yip, Kin | L4 | BNL | Design | Kin Yip | BNL | null | POM02.2.02.03.04.01 | C | 2.02 | 16718 | 2.02 | 01 |  |  |  |  |  |  |  |  |  |  |  |  |
| S295600 |  | (Controls Hardware) Power distribution drawings |  | 40d | 2021-02-15 A | 2021-10-27 | S295500 FS-20d | 20% | 40d | 2021-08-31 | 2021-10-27 | 45d | 0d |  | 2021-10-27 | TECH3 AD [40 h] | 4,765.31 | S295600 | 0 | S261100 | S261100 | S295600 | CA | Not Started | C | Yip, Kin | L4 | BNL | Design | Kin Yip | BNL | null | POM02.2.02.03.04.01 | C | 2.02 | 16718 | 2.02 | 01 |  |  |  |  |  |  |  |  |  |  |  |  |
| S295500 |  | (Controls Hardware) Wire diagram drawings |  | 43d | 2021-04-19 A | 2021-09-28 | S295401 | 20% | 43d | 2021-07-29 | 2021-09-28 | 45d | 0d |  | 2021-09-28 | TECH3 AD [128 h] | 15,045.86 | S295500 | 0 | S261000 | S261000 | S295500 | CA | Not Started | C | Yip, Kin | L4 | BNL | Design | Kin Yip | BNL | null | POM02.2.02.03.04.01 | C | 2.02 | 16718 | 2.02 | 01 |  |  |  |  |  |  |  |  |  |  |  |  |
| S295610 |  | Completed - (Controls Hardware) Power distribution drawings | milestone | 0d | 2021-10-27 | 2021-10-27 | S295600 |  |  |  |  | 45d | 0d |  |  |  |  | S295600 | 0 | S261100 | S261100 |  | NOCA | Not Started | C | Yip, Kin |  | BNL | Design | Kin Yip | BNL |  | POM02.2.02.03.04.01 |  |  |  |  | 01 |  |  | L5 |  | 2021-10-27 | -1 | PMP_2x |  |  |  |  |  |
|  | 02 | **Procurement** |  |  | 2020-04-01 | 2021-08-27 |  |  |  |  |  |  |  |  |  |  |  |  |  |  |  |  |  |  |  |  |  |  |  |  |  |  |  |  |  |  |  |  |  |  |  |  |  |  |  |  |  |  |  |  |
| S295800 |  | (Cryo Controls Hardware procurement) PLC I/O cards & expansion chassis Labor |  | 15d | 2020-04-01 A | 2020-04-30 A | S101000 | 100% |  | 2020-07-20 | 2020-08-07 |  |  |  |  | PROF3 AD [15 h] | 1,897.64 | S295800 | 0 | S261300 | S261300 | S295800 | CA | Not Started | C | Yip, Kin | L4 | BNL | Procurement | Kin Yip | BNL | null | POM02.2.02.03.04.02 | C | 2.02 | 16718 | 2.02 | 02 |  | Yes |  |  |  |  |  |  |  |  |  |  |
| S295900 |  | (Cryo Controls Hardware procurement) PLC I/O cards & expansion chassis M&S |  | 15d | 2020-04-01 A | 2020-04-30 A | S295700, S101000 | 100% |  | 2020-07-15 | 2020-08-04 |  |  |  |  | Material (Purchase (1st $2M) [7500 h] | 8,534.44 | S295900 | 0 | S261400 | S261400 | S295900 | CA | Not Started | C | Yip, Kin | M4 | BNL | Fab & Assy | Kin Yip | BNL | null | POM02.2.02.03.04.02 | E | 2.02 | 16718 | 2.02 | 02 |  | Yes |  |  |  |  |  | UDF_G3 | UDF_G3 | TBD |  |  |
| S296000 |  | (Cryo Controls Hardware procurement) Rack components Labor |  | 20d | 2020-04-01 A | 2020-04-30 A | S295700, S101000 | 100% |  | 2020-07-15 | 2020-08-11 |  |  |  |  | PROF3 AD [4 h] | 506.04 | S296000 | 0 | S261500 | S261500 | S296000 | CA | Not Started | C | Yip, Kin | L4 | BNL | Procurement | Kin Yip | BNL | null | POM02.2.02.03.04.02 | C | 2.02 | 16718 | 2.02 | 02 |  |  |  |  |  |  |  |  |  |  |  |  |
| S296100 |  | (Cryo Controls Hardware procurement) Rack components M&S |  | 20d | 2020-04-01 A | 2020-04-30 A | S101000, S296000 SS+1d | 100% |  | 2020-07-16 | 2020-08-12 |  |  |  |  | Material (Purchase (1st $2M) [6000 h] | 6,827.55 | S296100 | 0 | S261600 | S261600 | S296100 | CA | Not Started | C | Yip, Kin | M4 | BNL | Fab & Assy | Kin Yip | BNL | null | POM02.2.02.03.04.02 | E | 2.02 | 16718 | 2.02 | 02 |  |  |  |  |  |  |  | UDF_G3 | UDF_G3 | TBD |  |  |
| S295910 |  | Completed - (Cryo Controls Hardware procurement) PLC I/O cards & expansion chassis M&S | milestone | 0d | 2020-04-30 A | 2020-04-30 A | S295900 FF | 100% |  | 2020-08-04 | 2020-08-04 |  |  |  |  |  |  | S295900 | 0 | S261400 | S261400 |  | NOCA | Not Started | C | Yip, Kin |  | BNL | Fab & Assy | Kin Yip | BNL |  | POM02.2.02.03.04.02 |  |  |  |  | 02 |  |  | L5 |  |  |  |  |  |  |  |  |  |
| S297400 |  | (Cryo Controls Hardware procurement) 32 conductor cables, IP8 to 1008B racks M&S |  | 15d | 2020-06-02 A | 2020-06-05 A | S101000, S297300 SS+6d | 100% |  | 2020-07-15 | 2020-08-04 |  |  |  |  | Material (Purchase (1st $2M) [16000 h] | 18,206.81 | S297400 | 0 | S262900 | S262900 | S297400 | CA | Not Started | C | Yip, Kin | M4 | BNL | Fab & Assy | Kin Yip | BNL | null | POM02.2.02.03.04.02 | E | 2.02 | 16718 | 2.02 | 02 |  | Yes |  |  |  |  |  | UDF_G3 | UDF_G3 | TBD | 18206.81264 | 1 |
| S297500 |  | (Cryo Controls Hardware procurement) 32 conductor cables, IP8 to 1008B racks Labor |  | 15d | 2020-06-02 A | 2020-06-05 A | S101000, S297400 SS | 100% |  | 2020-07-15 | 2020-08-04 |  |  |  |  | PROF3 AD [12 h] | 1,518.11 | S297500 | 0 | S263000 | S263000 | S297500 | CA | Not Started | C | Yip, Kin | L4 | BNL | Procurement | Kin Yip | BNL | null | POM02.2.02.03.04.02 | C | 2.02 | 16718 | 2.02 | 02 |  | Yes |  |  |  |  |  |  |  |  |  |  |
| S296800 |  | (Cryo Controls Hardware procurement) Pressure transmitters Labor |  | 20d | 2020-06-12 A | 2020-06-15 A | S101000, S296700 SS | 100% |  | 2020-07-07 | 2020-08-03 |  |  |  |  | PROF3 AD [12 h] | 1,518.11 | S296800 | 0 | S262300 | S262300 | S296800 | CA | Not Started | C | Yip, Kin | L4 | BNL | Procurement | Kin Yip | BNL | null | POM02.2.02.03.04.02 | C | 2.02 | 16718 | 2.02 | 02 |  | Yes |  |  |  |  |  |  |  |  |  |  |
| S296900 |  | (Cryo Controls Hardware procurement) Pressure transmitters M&S |  | 20d | 2020-06-12 A | 2020-06-15 A | S101000, S296800 SS | 100% |  | 2020-07-07 | 2020-08-03 |  |  |  |  | Material (Purchase (1st $2M) [6400 h] | 7,282.73 | S296900 | 0 | S262400 | S262400 | S296900 | CA | Not Started | C | Yip, Kin | M4 | BNL | Fab & Assy | Kin Yip | BNL | null | POM02.2.02.03.04.02 | E | 2.02 | 16718 | 2.02 | 02 |  | Yes |  |  |  |  |  | UDF_G3 | UDF_G3 | TBD | 7282.725056 | 1 |
| S298000 |  | (Cryo Controls Hardware procurement) Heater UL listed Control Panel Labor |  | 84d | 2020-06-15 A | 2020-06-18 A | S101000, S297900 SS | 100% |  | 2020-11-13 | 2021-03-18 |  |  |  |  | PROF3 AD [14 h] | 1,824.27 | S298000 | 0 | S263500 | S263500 | S298000 | CA | Not Started | C | Yip, Kin | L4 | BNL | Procurement | Kin Yip | BNL | null | POM02.2.02.03.04.02 | C | 2.02 | 16718 | 2.02 | 02 |  | Yes |  |  |  |  |  |  |  |  |  |  |
| S298100 |  | (Cryo Controls Hardware procurement) Heater UL listed Control Panel M&S |  | 84d | 2020-06-15 A | 2020-06-18 A | S101000, S298000 SS | 100% |  | 2020-11-13 | 2021-03-18 |  |  |  |  | Material (Purchase (1st $2M) [18000 h] | 20,892.32 | S298100 | 0 | S263600 | S263600 | S298100 | CA | Not Started | C | Yip, Kin | M4 | BNL | Fab & Assy | Kin Yip | BNL | null | POM02.2.02.03.04.02 | E | 2.02 | 16718 | 2.02 | 02 |  | Yes |  |  |  |  |  | UDF_G1 | UDF_G3 | TBD | 20892.31758 | 1 |
| S296200 |  | (Cryo Controls Hardware procurement) Lakeshore Temperature Controller/conditioners Labor |  | 20d | 2020-07-07 A | 2020-07-31 A | S101000, S299400 SS | 100% |  | 2020-07-07 | 2020-08-03 |  |  |  |  | PROF3 AD [12 h] | 1,518.11 | S296200 | 0 | S261700 | S261700 | S296200 | CA | Not Started | C | Yip, Kin | L4 | BNL | Procurement | Kin Yip | BNL | null | POM02.2.02.03.04.02 | C | 2.02 | 16718 | 2.02 | 02 |  | Yes |  |  |  |  |  |  |  |  |  |  |
| S296300 |  | (Cryo Controls Hardware procurement) Lakeshore Temperature Controller/conditioners M&S |  | 20d | 2020-07-07 A | 2020-07-31 A | S101000, S296200 SS | 100% |  | 2020-07-07 | 2020-08-03 |  |  |  |  | Material (Purchase (1st $2M) [5000 h] | 5,689.63 | S296300 | 0 | S261800 | S261800 | S296300 | CA | Not Started | C | Yip, Kin | M4 | BNL | Fab & Assy | Kin Yip | BNL | null | POM02.2.02.03.04.02 | E | 2.02 | 16718 | 2.02 | 02 |  | Yes |  |  |  |  |  | UDF_G3 | UDF_G3 | TBD | 5689.62895 | 1 |
| S298800 |  | (Cryo Controls Hardware Procurement) 32 conductor cable LN2 |  | 30d | 2020-07-20 A | 2020-07-31 A | S298700 SS | 100% |  | 2020-07-20 | 2020-08-28 |  |  |  |  | Material (Purchase (1st $2M) [6500 h] | 7,396.52 | S298800 | 0 | S264200 | S277590044 | S298800 | CA | Not Started | C | Yip, Kin | M4 | BNL | Fab & Assy | Kin Yip | BNL | null | POM02.2.02.03.04.02 | E | 2.02 | 16718 | 2.02 | 02 |  |  |  |  |  |  |  | UDF_G2 | UDF_G3 | TBD | 7396.517635 | 1 |
| S299000 |  | (Cryo Controls Hardware Procurement) Acopian 24V power Supply |  | 17d | 2020-08-03 A | 2020-08-25 A |  | 100% |  |  |  |  |  | start on or after 2020-07-07 |  | Material (Purchase (1st $2M) [2000 h] | 2,275.85 | S299000 | 0 | S264200 | S277590124 | S299000 | CA | Not Started | C | Yip, Kin | M4 | BNL | Fab & Assy | Kin Yip | BNL | null | POM02.2.02.03.04.02 | E | 2.02 | 16718 | 2.02 | 02 |  |  |  |  |  |  |  | UDF_G3 | UDF_G3 | TBD | 2275.85158 | 1 |
| S299200 |  | (Cryo Controls Hardware Procurement) 72 inch enclosure |  | 17d | 2020-08-03 A | 2020-08-25 A | S299100 SS | 100% |  |  |  |  |  |  |  | Material (Purchase (1st $2M) [1500 h] | 1,706.89 | S299200 | 0 | S264200 | S277590204 | S299200 | CA | Not Started | C | Yip, Kin | M4 | BNL | Fab & Assy | Kin Yip | BNL | null | POM02.2.02.03.04.02 | E | 2.02 | 16718 | 2.02 | 02 |  |  |  |  |  |  |  | UDF_G3 | UDF_G3 | TBD | 1706.888685 | 1 |
| S297600 |  | (Cryo Controls Hardware procurement) 8 conductor cables, IP8 to 1008B racks Labor |  | 15d | 2020-09-22 A | 2020-09-30 A | S101000, S297500 SS | 100% |  | 2020-10-09 | 2020-10-30 |  |  |  |  | PROF3 AD [12 h] | 1,563.66 | S297600 | 0 | S263100 | S263100 | S297600 | CA | Not Started | C | Yip, Kin | L4 | BNL | Procurement | Kin Yip | BNL | null | POM02.2.02.03.04.02 | C | 2.02 | 16718 | 2.02 | 02 |  | Yes |  |  |  |  |  |  |  |  |  |  |
| S297700 |  | (Cryo Controls Hardware procurement) 8 conductor cables, IP8 to 1008B racks M&S |  | 15d | 2020-09-22 A | 2020-09-30 A | S101000, S297600 SS | 100% |  | 2020-10-09 | 2020-10-30 |  |  |  |  | Material (Purchase (1st $2M) [6200 h] | 7,196.24 | S297700 | 0 | S263200 | S263200 | S297700 | CA | Not Started | C | Yip, Kin | M4 | BNL | Fab & Assy | Kin Yip | BNL | null | POM02.2.02.03.04.02 | E | 2.02 | 16718 | 2.02 | 02 |  | Yes |  |  |  |  |  | UDF_G2 | UDF_G3 | TBD | 7055.139898 | 1 |
| S298600 |  | (Cryo Controls Hardware procurement) Cable tray and supports Labor |  | 30d | 2020-09-22 A | 2021-02-26 A | S101000, S298500 SS | 100% |  | 2020-10-01 | 2020-11-13 |  |  |  |  | PROF3 AD [46 h] | 5,994.02 | S298600 | 0 | S264100 | S264100 | S298600 | CA | Not Started | C | Yip, Kin | L4 | BNL | Procurement | Kin Yip | BNL | null | POM02.2.02.03.04.02 | C | 2.02 | 16718 | 2.02 | 02 |  |  |  |  |  |  |  |  |  |  |  |  |
| S298700 |  | (Cryo Controls Hardware procurement) Cable tray and supports M&S |  | 30d | 2020-09-22 A | 2021-02-26 A | S101000, S298600 SS | 100% |  | 2020-10-01 | 2020-11-13 |  |  |  |  | Material (Purchase (1st $2M) [4000 h] | 4,642.74 | S298700 | 0 | S264200 | S264200 | S298700 | CA | Not Started | C | Yip, Kin | M4 | BNL | Fab & Assy | Kin Yip | BNL | null | POM02.2.02.03.04.02 | E | 2.02 | 16718 | 2.02 | 02 |  |  |  |  |  |  |  | UDF_G1 | UDF_G3 | TBD | 4551.70316 | 1 |
| S296600 |  | (Cryo Controls Hardware procurement) SC level probes Labor |  | 20d | 2020-10-01 A | 2021-06-28 | S101000, S296500 SS | 50% | 20d | 2020-10-01 | 2020-10-29 | 80d | 0d |  | 2021-06-28 | PROF3 AD [12 h] | 1,563.66 | S296600 | 0 | S262100 | S262100 | S296600 | CA | Not Started | C | Yip, Kin | L4 | BNL | Procurement | Kin Yip | BNL | null | POM02.2.02.03.04.02 | C | 2.02 | 16718 | 2.02 | 02 |  | Yes |  |  |  |  |  |  |  |  |  |  |
| S296700 |  | (Cryo Controls Hardware procurement) SC level probes M&S |  | 20d | 2020-10-01 A | 2021-06-28 | S101000, S296600 SS | 50% | 20d | 2020-10-01 | 2020-10-29 | 80d | 0d |  | 2021-06-28 | Material (Purchase (1st $2M) [3000 h] | 3,482.05 | S296700 | 0 | S262200 | S262200 | S296700 | CA | Not Started | C | Yip, Kin | M4 | BNL | Fab & Assy | Kin Yip | BNL | null | POM02.2.02.03.04.02 | E | 2.02 | 16718 | 2.02 | 02 |  | Yes |  |  |  |  |  | UDF_G1 | UDF_G3 | TBD | 3413.77737 | 1 |
| S298900 |  | (Cryo Controls Hardware Procurement) Plastic general 32 conductor connectors (pairs) |  | 30d | 2020-10-01 A | 2020-10-30 A | S298800 SS | 100% |  | 2020-10-01 | 2020-11-13 |  |  |  |  | Material (Purchase (1st $2M) [300 h] | 348.21 | S298900 | 0 | S264200 | S277590084 | S298900 | CA | Not Started | C | Yip, Kin | M4 | BNL | Fab & Assy | Kin Yip | BNL | null | POM02.2.02.03.04.02 | E | 2.02 | 16718 | 2.02 | 02 |  |  |  |  |  |  |  | UDF_G1 | UDF_G3 | TBD | 341.377737 | 1 |
| S299100 |  | (Cryo Controls Hardware Procurement) +/- 15 volt Power Supply |  | 17d | 2020-10-01 A | 2020-10-26 A | S299000 SS | 100% |  |  |  |  |  |  |  | Material (Purchase (1st $2M) [500 h] | 580.34 | S299100 | 0 | S264200 | S277590164 | S299100 | CA | Not Started | C | Yip, Kin | M4 | BNL | Fab & Assy | Kin Yip | BNL | null | POM02.2.02.03.04.02 | E | 2.02 | 16718 | 2.02 | 02 |  |  |  |  |  |  |  | UDF_G2 | UDF_G3 | TBD | 568.962895 | 1 |
| S297000 |  | (Cryo Controls Hardware procurement) Flowmeters Labor |  | 20d | 2020-12-01 A | 2021-01-29 A | S101000, S296900 SS | 100% |  | 2020-12-01 | 2020-12-29 |  |  |  |  | PROF3 AD [12 h] | 1,563.66 | S297000 | 0 | S262500 | S262500 | S297000 | CA | Not Started | C | Yip, Kin | L4 | BNL | Procurement | Kin Yip | BNL | null | POM02.2.02.03.04.02 | C | 2.02 | 16718 | 2.02 | 02 |  | Yes |  |  |  |  |  |  |  |  |  |  |
| S297100 |  | (Cryo Controls Hardware procurement) Flowmeters M&S |  | 20d | 2020-12-01 A | 2021-01-29 A | S101000, S297000 SS | 100% |  | 2020-12-01 | 2020-12-29 |  |  |  |  | Material (Purchase (1st $2M) [4600 h] | 5,339.15 | S297100 | 0 | S262600 | S262600 | S297100 | CA | Not Started | C | Yip, Kin | M4 | BNL | Fab & Assy | Kin Yip | BNL | null | POM02.2.02.03.04.02 | E | 2.02 | 16718 | 2.02 | 02 |  | Yes |  |  |  |  |  | UDF_G1 | UDF_G3 | TBD | 5234.458634 | 1 |
| S299400 |  | (Cryo Controls Hardware Procurement) Turbo pump and Controller |  | 20d | 2020-12-01 A | 2021-01-28 A | S299300 SS | 100% |  | 2020-12-01 | 2020-12-29 |  |  |  |  | Material (Purchase (1st $2M) [25000 h] | 29,017.11 | S299400 | 0 | S264200 | S277590284 | S299400 | CA | Not Started | C | Yip, Kin | M4 | BNL | Fab & Assy | Kin Yip | BNL | null | POM02.2.02.03.04.02 | E | 2.02 | 16718 | 2.02 | 02 |  |  |  |  |  |  |  | UDF_G1 | UDF_G3 | TBD | 28448.14475 | 1 |
| S297200 |  | (Cryo Controls Hardware procurement) Vacuum gages and cables Labor |  | 20d | 2021-01-04 A | 2021-01-29 A | S101000, S297100 SS | 100% |  | 2021-01-04 | 2021-02-01 |  |  |  |  | PROF3 AD [12 h] | 1,563.66 | S297200 | 0 | S262700 | S262700 | S297200 | CA | Not Started | C | Yip, Kin | L4 | BNL | Procurement | Kin Yip | BNL | null | POM02.2.02.03.04.02 | C | 2.02 | 16718 | 2.02 | 02 |  | Yes |  |  |  |  |  |  |  |  |  |  |
| S297300 |  | (Cryo Controls Hardware procurement) Vacuum gages and cables M&S |  | 20d | 2021-01-04 A | 2021-01-29 A | S101000, S297200 SS | 100% |  | 2021-01-04 | 2021-02-01 |  |  |  |  | Material (Purchase (1st $2M) [6000 h] | 6,964.11 | S297300 | 0 | S262800 | S262800 | S297300 | CA | Not Started | C | Yip, Kin | M4 | BNL | Fab & Assy | Kin Yip | BNL | null | POM02.2.02.03.04.02 | E | 2.02 | 16718 | 2.02 | 02 |  | Yes |  |  |  |  |  | UDF_G1 | UDF_G3 | TBD | 6827.55474 | 1 |
| S296400 |  | (Cryo Controls Hardware procurement) Lakeshore Temperature sensors Labor |  | 20d | 2021-02-01 A | 2021-02-24 A | S101000, S296300 SS | 100% |  | 2021-02-01 | 2021-03-01 |  |  |  |  | PROF3 AD [12 h] | 1,563.66 | S296400 | 0 | S261900 | S261900 | S296400 | CA | Not Started | C | Yip, Kin | L4 | BNL | Procurement | Kin Yip | BNL | null | POM02.2.02.03.04.02 | C | 2.02 | 16718 | 2.02 | 02 |  | Yes |  |  |  |  |  |  |  |  |  |  |
| S296500 |  | (Cryo Controls Hardware procurement) Lakeshore Temperature sensors M&S |  | 20d | 2021-02-01 A | 2021-02-24 A | S101000, S296400 SS | 100% |  | 2021-02-01 | 2021-03-01 |  |  |  |  | Material (Purchase (1st $2M) [22000 h] | 25,535.05 | S296500 | 0 | S262000 | S262000 | S296500 | CA | Not Started | C | Yip, Kin | M4 | BNL | Fab & Assy | Kin Yip | BNL | null | POM02.2.02.03.04.02 | E | 2.02 | 16718 | 2.02 | 02 |  | Yes |  |  |  |  |  | UDF_G1 | UDF_G3 | TBD | 25034.36738 | 1 |
| S299300 |  | (Cryo Controls Hardware Procurement) LN2 Conduit/couplings |  | 17d | 2021-02-01 A | 2021-02-24 A | S299200 SS | 100% |  |  |  |  |  |  |  | Material (Purchase (1st $2M) [3400 h] | 3,946.33 | S299300 | 0 | S264200 | S277590244 | S299300 | CA | Not Started | C | Yip, Kin | M4 | BNL | Fab & Assy | Kin Yip | BNL | null | POM02.2.02.03.04.02 | E | 2.02 | 16718 | 2.02 | 02 |  |  |  |  |  |  |  | UDF_G1 | UDF_G3 | TBD | 3868.947686 | 1 |
| S297800 |  | (Cryo Controls Hardware procurement) Heaters 480VAC Labor |  | 84d | 2021-03-22 A | 2021-04-30 A | S101000, S295700 FS+60d | 100% |  | 2021-10-20 | 2022-02-23 |  |  |  |  | PROF3 AD [14 h] | 1,879 | S297800 | 0 | S263300 | S263300 | S297800 | CA | Not Started | C | Yip, Kin | L4 | BNL | Procurement | Kin Yip | BNL | null | POM02.2.02.03.04.02 | C | 2.02 | 16718 | 2.02 | 02 |  | Yes |  |  |  |  |  |  |  |  |  |  |
| S297900 |  | (Cryo Controls Hardware procurement) Heaters 480VAC M&S |  | 84d | 2021-03-22 A | 2021-04-30 A | S101000, S297800 SS | 100% |  | 2021-10-20 | 2022-02-23 |  |  |  |  | Material (Purchase (1st $2M) [17000 h] | 20,126.27 | S297900 | 0 | S263400 | S263400 | S297900 | CA | Not Started | C | Yip, Kin | M4 | BNL | Fab & Assy | Kin Yip | BNL | null | POM02.2.02.03.04.02 | E | 2.02 | 16718 | 2.02 | 02 |  | Yes |  |  |  |  |  | UDF_G1 | UDF_G1 | TBD | 19731.63327 | 1 |
| S298400 |  | (Cryo Controls Hardware procurement) Network switch and Ethernet fiber drop Labor |  | 20d | 2021-05-03 A | 2021-05-24 A | S101000 | 100% |  | 2021-06-01 | 2021-06-28 |  |  |  |  | PROF3 AD [5 h] | 651.52 | S298400 | 0 | S263900 | S263900 | S298400 | CA | Not Started | C | Yip, Kin | L4 | BNL | Procurement | Kin Yip | BNL | null | POM02.2.02.03.04.02 | C | 2.02 | 16718 | 2.02 | 02 |  |  |  |  |  |  |  |  |  |  |  |  |
| S298500 |  | (Cryo Controls Hardware procurement) Network switch and Ethernet fiber drop M&S |  | 20d | 2021-05-03 A | 2021-05-24 A | S101000, S298400 SS | 100% |  | 2021-06-01 | 2021-06-28 |  |  |  |  | Material (Purchase (1st $2M) [3500 h] | 4,062.4 | S298500 | 0 | S264000 | S264000 | S298500 | CA | Not Started | C | Yip, Kin | M4 | BNL | Fab & Assy | Kin Yip | BNL | null | POM02.2.02.03.04.02 | E | 2.02 | 16718 | 2.02 | 02 |  |  |  |  |  |  |  | UDF_G1 | UDF_G3 | TBD | 3982.740265 | 1 |
| S298200 |  | (Cryo Controls Hardware procurement) Switch, 480 VAC Labor |  | 25d | 2021-07-26 | 2021-08-27 | S101000, S296100 SS |  |  |  |  | 137d | 0d |  |  | PROF3 AD [5 h] | 651.52 | S298200 | 0 | S263700 | S263700 | S298200 | CA | Not Started | C | Yip, Kin | L4 | BNL | Procurement | Kin Yip | BNL | null | POM02.2.02.03.04.02 | C | 2.02 | 16718 | 2.02 | 02 |  |  |  |  |  |  |  |  |  |  |  |  |
| S298300 |  | (Cryo Controls Hardware procurement) Switch, 480 VAC M&S |  | 25d | 2021-07-26 | 2021-08-27 | S101000, S298200 SS |  |  |  |  | 137d | 112d |  |  | Material (Purchase (1st $2M) [1220 h] | 1,416.03 | S298300 | 0 | S263800 | S263800 | S298300 | CA | Not Started | C | Yip, Kin | M4 | BNL | Fab & Assy | Kin Yip | BNL | null | POM02.2.02.03.04.02 | E | 2.02 | 16718 | 2.02 | 02 |  |  |  |  |  |  |  | UDF_G1 | UDF_G3 | TBD | 1388.269464 | 1 |

Notes:
- S294840: BNL_UDF_Old Activity Name 181221: (Warm Piping System) Phase 2: Welding of piping,vent lines and install of piping supports, after coldbox/magnet install
- S294800: BNL_UDF_Old Activity Name 181221: (Warm Piping System) Phase 1: Welding of piping and install of piping supports
- S294860: BNL_UDF_Old Activity Name 181221: (Warm Piping System) Phase 2: Welding of piping,vent lines and install of piping supports, after coldbox/magnet install
- S294810: BNL_UDF_Old Activity Name 181221: (Warm Piping System) Phase 1: Welding of piping and install of piping supports
- S295100: BNL_UDF_Old Activity Name 181221: (Warm Piping System) Install Instrumentation, reliefs and air supply to valves
- S295300: BNL_UDF_Old Activity Name 181221: (Warm Piping System) Vacuum Pumping System installation
- S295310: BNL_UDF_Old Activity Name 181221: (Warm Piping System) Vacuum Pumping System installation
- S294880: BNL_UDF_Old Activity Name 181221: (Warm Piping System) Phase 2: Welding of piping,vent lines and install of piping supports, after coldbox/magnet install
- S295000: BNL_UDF_Old Activity Name 181221: (Warm Piping System) Pressure and leak check
- S294910: BNL_UDF_Old Activity Name 181221: (Warm Piping System) Phase 2: Welding of piping,vent lines and install of piping supports, after coldbox/magnet install
- S295200: BNL_UDF_Old Activity Name 181221: (Warm Piping System) Final pressure. leak check and equipment shakedown
- S295400: BNL_UDF_Old Activity Name 181221: (Controls Hardware) Cryo instrument and equipment specifications
- S295401: BNL_UDF_Old Activity Name 181221: (Controls Hardware) Cryo instrument and equipment specifications
- S295700: BNL_UDF_Old Activity Name 181221: (Controls Hardware) I/O list table
- S295600: BNL_UDF_Old Activity Name 181221: (Controls Hardware) Power distribution drawings
- S295500: BNL_UDF_Old Activity Name 181221: (Controls Hardware) Wire diagram drawings
- S295610: BNL_UDF_Old Activity Name 181221: (Controls Hardware) Power distribution drawings
- S295800: BNL_UDF_Old Activity Name 181221: (Cryo Controls Hardware procurement) PLC I/O cards & expansion chassis Labor
- S295900: BNL_UDF_Old Activity Name 181221: (Cryo Controls Hardware procurement) PLC I/O cards & expansion chassis M&S
- S296000: BNL_UDF_Old Activity Name 181221: (Cryo Controls Hardware procurement) Rack components Labor
- S296100: BNL_UDF_Old Activity Name 181221: (Cryo Controls Hardware procurement) Rack components M&S
- S295910: BNL_UDF_Old Activity Name 181221: (Cryo Controls Hardware procurement) PLC I/O cards & expansion chassis M&S
- S297400: BNL_UDF_Old Activity Name 181221: (Cryo Controls Hardware procurement) 32 conductor cables, IP8 to 1008B racks M&S
- S297500: BNL_UDF_Old Activity Name 181221: (Cryo Controls Hardware procurement) 32 conductor cables, IP8 to 1008B racks Labor
- S296800: BNL_UDF_Old Activity Name 181221: (Cryo Controls Hardware procurement) Pressure transmitters Labor
- S296900: BNL_UDF_Old Activity Name 181221: (Cryo Controls Hardware procurement) Pressure transmitters M&S
- S298000: BNL_UDF_Old Activity Name 181221: (Cryo Controls Hardware procurement) Heater UL listed Control Panel Labor
- S298100: BNL_UDF_Old Activity Name 181221: (Cryo Controls Hardware procurement) Heater UL listed Control Panel M&S
- S296200: BNL_UDF_Old Activity Name 181221: (Cryo Controls Hardware procurement) Lakeshore Temperature Controller/conditioners Labor
- S296300: BNL_UDF_Old Activity Name 181221: (Cryo Controls Hardware procurement) Lakeshore Temperature Controller/conditioners M&S
- S298800: BNL_UDF_Old Activity Name 181221: (Cryo Controls Hardware Procurement) 32 conductor cable LN2
- S299000: BNL_UDF_Old Activity Name 181221: (Cryo Controls Hardware Procurement) Acopian 24V power Supply
- S299200: BNL_UDF_Old Activity Name 181221: (Cryo Controls Hardware Procurement) 72 inch enclosure
- S297600: BNL_UDF_Old Activity Name 181221: (Cryo Controls Hardware procurement) 8 conductor cables, IP8 to 1008B racks Labor
- S297700: BNL_UDF_Old Activity Name 181221: (Cryo Controls Hardware procurement) 8 conductor cables, IP8 to 1008B racks M&S
- S298600: BNL_UDF_Old Activity Name 181221: (Cryo Controls Hardware procurement) Cable tray and supports Labor
- S298700: BNL_UDF_Old Activity Name 181221: (Cryo Controls Hardware procurement) Cable tray and supports M&S
- S296600: BNL_UDF_Old Activity Name 181221: (Cryo Controls Hardware procurement) SC level probes Labor
- S296700: BNL_UDF_Old Activity Name 181221: (Cryo Controls Hardware procurement) SC level probes M&S
- S298900: BNL_UDF_Old Activity Name 181221: (Cryo Controls Hardware Procurement) Plastic general 32 conductor connectors (pairs)
- S299100: BNL_UDF_Old Activity Name 181221: (Cryo Controls Hardware Procurement) +/- 15 volt Power Supply
- S297000: BNL_UDF_Old Activity Name 181221: (Cryo Controls Hardware procurement) Flowmeters Labor
- S297100: BNL_UDF_Old Activity Name 181221: (Cryo Controls Hardware procurement) Flowmeters M&S
- S299400: BNL_UDF_Old Activity Name 181221: (Cryo Controls Hardware Procurement) Turbo pump and Controller
- S297200: BNL_UDF_Old Activity Name 181221: (Cryo Controls Hardware procurement) Vacuum gages and cables Labor
- S297300: BNL_UDF_Old Activity Name 181221: (Cryo Controls Hardware procurement) Vacuum gages and cables M&S
- S296400: BNL_UDF_Old Activity Name 181221: (Cryo Controls Hardware procurement) Lakeshore Temperature sensors Labor
- S296500: BNL_UDF_Old Activity Name 181221: (Cryo Controls Hardware procurement) Lakeshore Temperature sensors M&S
- S299300: BNL_UDF_Old Activity Name 181221: (Cryo Controls Hardware Procurement) LN2 Conduit/couplings
- S297800: BNL_UDF_Old Activity Name 181221: (Cryo Controls Hardware procurement) Heaters 480VAC Labor
- S297900: BNL_UDF_Old Activity Name 181221: (Cryo Controls Hardware procurement) Heaters 480VAC M&S
- S298400: BNL_UDF_Old Activity Name 181221: (Cryo Controls Hardware procurement) Network switch and Ethernet fiber drop Labor
- S298500: BNL_UDF_Old Activity Name 181221: (Cryo Controls Hardware procurement) Network switch and Ethernet fiber drop M&S
- S298200: BNL_UDF_Old Activity Name 181221: (Cryo Controls Hardware procurement) Switch, 480 VAC Labor
- S298300: BNL_UDF_Old Activity Name 181221: (Cryo Controls Hardware procurement) Switch, 480 VAC M&S

| ID | WBS | Activity | Type | Duration | Start | Finish | Predecessors | Complete | Remaining | Planned start | Planned finish | Total float | Free float | Expected finish | Resources | Cost | BNL_UDF_Temp Text 01 | BNL_UDF_Percent Complete | BNL_UDF_OPC TEC (deprecated) | BNL_UDF_Old Activity ID 181221 | RG Check | BNL_Activity Status | BNL_Fund Source | BNL_Estimator | BNL_Location | BNL_EDIA | BNL_Milestone Level | BNL_CAM | BNL_Institution | BNL_WBS | BNL_WBS_Hierarchical | Major SC Activity | BNL_Cobra WP | BNL_Cost Basis | BNL_OPC TEC (deprecated) | BNL_EVT | BNL_Master Control Account | BNL_Account Number | BNL_Cobra Control Account | Target Milestone Date | Variance | PMP Milestones | Additional EVT documentation required | BNL_UDF_Temp Date 01 | BNL_UDF_Exclude | BNL_UDF_Status Comments | BNL_Actuals | BNL_FY | BNL_PCR ID | Completed | Indicator - Procurement |
| --- | --- | --- | --- | --- | --- | --- | --- | --- | --- | --- | --- | --- | --- | --- | --- | --- | --- | --- | --- | --- | --- | --- | --- | --- | --- | --- | --- | --- | --- | --- | --- | --- | --- | --- | --- | --- | --- | --- | --- | --- | --- | --- | --- | --- | --- | --- | --- | --- | --- | --- | --- |
|  | 03 | **Installation: Cryo Controls Hardware** |  |  | 2019-07-24 | 2022-04-18 |  |  |  |  |  |  |  |  |  |  |  |  |  |  |  |  |  |  |  |  |  |  |  |  |  |  |  |  |  |  |  |  |  |  |  |  |  |  |  |  |  |  |  |  |  |
| S299500 |  | (Cryo Controls Hardware) Rack available from 912 | milestone | 0d | 2019-07-24 A | 2019-07-24 A | S101000 | 100% |  |  |  |  |  |  |  |  | S299500 | 0 | S264300 | S264300 | NOCA | Completed | C | Yip, Kin | BNL | Installation | L5 | Kin Yip | BNL | POM02.2.02.03.04.03 | 03 | Yes |  |  |  |  |  |  |  |  |  |  |  |  |  |  |  |  |  |  |  |
| S299600 |  | (Cryo Controls Hardware) Rack built/rebuilt |  | 20d | 2021-07-26 | 2021-08-20 | S295800, S296000, S296200, S296400, S296100, S296300, S296500, S296600, S296700, S296800, S296900, S297000, S297100, S297200, S297300, S298400, S298500, S295910 |  |  |  |  | 62d | 0d |  | PROF3 AD [48 h]; TECH3 AD [280 h] | 39,167.46 | S299600 | 0 | S264400 | S264400 | CA | Not Started | C | Yip, Kin | BNL | Installation |  | Kin Yip | BNL | POM02.2.02.03.04.03 | 03 |  | S299600 | L4 | null | C | 2.02 | 16718 | 2.02 |  |  |  |  |  |  |  |  |  |  |  |  |
| S299700 |  | (Cryo Controls Hardware) Rack install |  | 5d | 2021-08-23 | 2021-08-27 | S299600 |  |  |  |  | 62d | 0d |  | PROF3 AD [4 h]; TECH3 AD [13 h] | 2,049.31 | S299700 | 0 | S264500 | S264500 | CA | Not Started | C | Yip, Kin | BNL | Installation |  | Kin Yip | BNL | POM02.2.02.03.04.03 | 03 | Yes | S299700 | L4 | null | C | 2.02 | 16718 | 2.02 |  |  |  |  |  |  |  |  |  |  |  |  |
| S299800 |  | (Cryo Controls Hardware) Cable pulling |  | 50d | 2021-08-30 | 2021-11-09 | S297500, S297600, S298600, S299700, S297400, S297700, S298700 |  |  |  |  | 62d | 0d |  | TECH3 AD [52 h]; CRAFT3 [150 h] | 25,847.96 | S299800 | 0 | S264600 | S264600 | CA | Not Started | C | Yip, Kin | BNL | Installation |  | Kin Yip | BNL | POM02.2.02.03.04.03 | 03 | Yes | S299800 | L4 | null | C | 2.02 | 16718 | 2.02 |  |  |  |  |  |  |  |  |  |  |  |  |
| S299810 |  | Completed - (Cryo Controls Hardware) Cable pulling | milestone | 0d | 2021-11-09 | 2021-11-09 | S299800 FF |  |  |  |  | 62d |  |  |  |  | S299800 | 0 | S264600 | S264600 | NOCA | Not Started |  | Yip, Kin | BNL | Installation | L5 | Kin Yip | BNL | POM02.2.02.03.04.03 | 03 | Yes |  |  |  |  |  |  |  |  |  |  |  |  |  |  |  |  |  |  |  |
| S300100 |  | (Cryo Controls Hardware) Heater Control Panel Install |  | 11d | 2021-12-29 | 2022-01-13 | S295610 FS+40d |  |  |  |  | 45d | 20d |  | CRAFT3 [32 h] | 4,246.02 | S300100 | 0 | S264900 | S264900 | CA | Not Started | C | Yip, Kin | BNL | Installation |  | Kin Yip | BNL | POM02.2.02.03.04.03 | 03 | Yes | S300100 | L4 | null | C | 2.02 | 16718 | 2.02 |  |  |  |  |  |  |  |  |  |  |  |  |
| S299900 |  | (Cryo Controls Hardware) Cable termination |  | 20d | 2022-02-14 | 2022-03-14 | S299700, S287410, S299810 |  |  |  |  | 0d |  |  | TECH3 AD [160 h] | 19,371.55 | S299900 | 0 | S264700 | S264700 | CA | Not Started | C | Yip, Kin | BNL | Installation |  | Kin Yip | BNL | POM02.2.02.03.04.03 | 03 | Yes | S299900 | L4 | null | C | 2.02 | 16718 | 2.02 |  |  |  |  |  |  |  |  |  |  |  |  |
| S300200 |  | (Cryo Controls Hardware) Heater 480VAC wiring |  | 5d | 2022-02-14 | 2022-02-18 | S297800, S298200, S300100, S297900, S298300, S287410, S295610, S299810 |  |  |  |  | 25d | 0d |  | CRAFT3 [480 h] | 63,690.31 | S300200 | 0 | S265000 | S265000 | CA | Not Started | C | Yip, Kin | BNL | Installation |  | Kin Yip | BNL | POM02.2.02.03.04.03 | 03 | Yes | S300200 | L4 | null | C | 2.02 | 16718 | 2.02 |  |  |  |  |  |  |  |  |  |  |  |  |
| S300300 |  | (Cryo Controls Hardware) Insulating vacuum roughing pumps 480VAC Breaker install and 480V wiring to roughing pumps |  | 5d | 2022-02-14 | 2022-02-18 | S299400, S287410, S300200 SS |  |  |  |  | 40d |  |  | CRAFT3 [8 h] | 1,061.51 | S300300 | 0 | S265000 | S265010 | CA | Not Started | C | Yip, Kin | BNL | Installation |  | Kin Yip | BNL | POM02.2.02.03.04.03 | 03 | Yes | S300300 | L4 | null | C | 2.02 | 16718 | 2.02 |  |  |  |  |  |  |  |  |  |  |  |  |
| S300400 |  | (Cryo Controls Hardware) Heater I/O wiring, temp sensors |  | 5d | 2022-03-03 | 2022-03-09 | S300200 |  |  |  |  | 18d |  |  | TECH3 AD [16 h] | 1,937.15 | S300400 | 0 | S265100 | S265100 | CA | Not Started | C | Yip, Kin | BNL | Installation |  | Kin Yip | BNL | POM02.2.02.03.04.03 | 03 | Yes | S300400 | L4 | null | C | 2.02 | 16718 | 2.02 |  |  |  |  |  |  |  |  |  |  |  |  |
| S300500 |  | (Cryo Controls Hardware) Wire up instruments and control valves |  | 15d | 2022-03-15 | 2022-04-04 | S299900 |  |  |  |  | 0d |  |  | TECH3 AD [96 h] | 11,622.93 | S300500 | 0 | S265200 | S265200 | CA | Not Started | C | Yip, Kin | BNL | Installation |  | Kin Yip | BNL | POM02.2.02.03.04.03 | 03 | Yes | S300500 | L4 | null | C | 2.02 | 16718 | 2.02 |  |  |  |  |  |  |  |  |  |  |  |  |
| S300000 |  | (Cryo Controls Hardware) Check out continuity |  | 10d | 2022-04-05 | 2022-04-18 | S299900, S300200, S300400, S300500 |  |  |  |  | 0d |  |  | TECH3 AD [40 h] | 4,842.89 | S300000 | 0 | S264800 | S264800 | CA | Not Started | C | Yip, Kin | BNL | Installation |  | Kin Yip | BNL | POM02.2.02.03.04.03 | 03 |  | S300000 | L4 | null | C | 2.02 | 16718 | 2.02 |  |  |  |  |  |  |  |  |  |  |  |  |
| S300600 |  | (Cryo Controls Hardware) Hardware Installed | milestone | 0d | 2022-04-18 | 2022-04-18 | S300000, S300500, S300300 FF |  |  |  |  | 0d |  |  |  |  | S300600 | 0 | S265300 | S265300 | NOCA | Not Started | C | Yip, Kin | BNL | Installation | L4 | Kin Yip | BNL | POM02.2.02.03.04.03 | 03 | Yes |  |  |  |  |  |  |  | 2022-06-30 | 51 | PMP_2x |  |  |  |  |  |  |  |  |  |
|  | 05 | **Cryo Controls Software** |  |  | 2020-07-13 | 2022-05-02 |  |  |  |  |  |  |  |  |  |  |  |  |  |  |  |  |  |  |  |  |  |  |  |  |  |  |  |  |  |  |  |  |  |  |  |  |  |  |  |  |  |  |  |  |  |
| S301000 |  | (Cryo Controls Hardware) PLC programming |  | 123d | 2020-07-13 A | 2021-08-27 | S300700 SS | 91% | 63d | 2020-07-13 | 2021-01-08 | 157d | 0d | 2021-08-27 | PROF3 AD [576 h]; PROF4 AD [72 h] | 84,816.28 | S301000 | 0 | S265700 | S265700 | CA | Not Started | C | Yip, Kin | BNL | Programming |  | Kin Yip | BNL | POM02.2.02.03.05 | 05 |  | S301000 | L4 | null | C | 2.02 | 16718 | 2.02 |  |  |  | Yes |  |  |  |  |  |  |  |  |
| S300700 |  | (Cryo Controls Hardware) Control Logic eng document revision by Cryo process engineering |  | 60d | 2020-08-03 A | 2020-09-30 A | S300800 SS | 100% |  | 2020-08-03 | 2020-10-27 |  |  |  | PROF3 AD [240 h]; PROF4 AD [240 h] | 66,297.24 | S300700 | 0 | S265400 | S265400 | CA | Not Started | C | Yip, Kin | BNL | Programming |  | Kin Yip | BNL | POM02.2.02.03.05 | 05 |  | S300700 | L4 | null | C | 2.02 | 16718 | 2.02 |  |  |  |  | 2019-06-18 |  |  |  |  |  |  |  |
| S300800 |  | (Cryo Controls Hardware) Interface document definition for variables to MCR and sPHENIX controls |  | 10d | 2020-08-03 A | 2021-06-28 | S288500 | 50% | 20d | 2020-08-03 | 2020-08-14 | 157d | 0d | 2021-06-28 | PROF3 AD [8 h]; PROF4 AD [8 h] | 2,190.2 | S300800 | 0 | S265500 | S265500 | CA | Not Started | C | Yip, Kin | BNL | Programming |  | Kin Yip | BNL | POM02.2.02.03.05 | 05 |  | S300800 | L4 | null | C | 2.02 | 16718 | 2.02 |  |  |  |  |  |  |  |  |  |  |  |  |
| S300900 |  | (Cryo Controls Hardware) Built HMI operator screens |  | 27d | 2021-03-08 A | 2021-08-02 | S300700, S101000 | 40% | 44d | 2021-04-01 | 2021-05-07 | 176d | 0d | 2021-08-02 | PROF3 AD [576 h]; PROF4 AD [72 h] | 85,976.75 | S300900 | 0 | S265600 | S265600 | CA | Not Started | C | Yip, Kin | BNL | Programming |  | Kin Yip | BNL | POM02.2.02.03.05 | 05 |  | S300900 | L4 | null | C | 2.02 | 16718 | 2.02 |  |  |  | Yes |  |  |  |  |  |  |  |  |
| S300910 |  | Completed - (Cryo Controls Hardware) Built HMI operator screens | milestone | 0d | 2021-08-02 | 2021-08-02 | S300900 FF |  |  |  |  | 176d |  |  |  |  | S300900 | 0 | S265600 | S265600 | NOCA | Not Started |  | Yip, Kin | BNL | Programming | L5 | Kin Yip | BNL | POM02.2.02.03.05 | 05 |  |  |  |  |  |  |  |  |  |  |  | Yes |  |  |  |  |  |  |  |  |
| S301100 |  | (Cryo Controls Hardware) Live I/O check out and control logic test |  | 10d | 2022-04-19 | 2022-05-02 | S300600, S301000, S300800, S300910 |  |  |  |  | 0d |  |  | PROF3 AD [120 h]; TECH3 AD [120 h]; PROF4 AD [24 h] | 34,383.94 | S301100 | 0 | S265800 | S265800 | CA | Not Started | C | Yip, Kin | BNL | Programming |  | Kin Yip | BNL | POM02.2.02.03.05 | 05 | Yes | S301100 | L4 | null | C | 2.02 | 16718 | 2.02 |  |  |  |  |  |  |  |  |  |  |  |  |
|  | 04 | **Magnet Power Supplies/Controls/Quench Protection** |  |  | 2017-02-01 | 2022-04-19 |  |  |  |  |  |  |  |  |  |  |  |  |  |  |  |  |  |  |  |  |  |  |  |  |  |  |  |  |  |  |  |  |  |  |  |  |  |  |  |  |  |  |  |  |  |
| S1000119 |  | Actuals - Labor - sPHENIX Magnet FY17 16719 |  | 169d | 2017-02-01 A | 2017-09-29 A | S100090 SS | 100% |  |  |  |  |  |  | Actual Labor [89.29 h] | 14,920.26 | S278400 | 100 |  | S338540 | CA | Completed | C | Yip, Kin |  | Design |  | Kin Yip |  | POM02.2.02.04 | 04 |  | S1000119 | L1 | null | A | 2.02 | 16719 | 2.02 |  |  |  |  |  | MP6LAEXCLUDE | 190315 DurType to align with EVT | Yes | 2017 | 003 | yes |  |
| S1000199 |  | Actuals - Labor - sPHENIX Magnet FY18 16719 |  | 249d | 2017-10-02 A | 2018-09-28 A | S278400, S1000039, S1000079, S1000119 | 100% |  |  |  |  |  |  | Actual Labor [40.5 h] | 6,767.26 | S278500 | 100 |  | S339340 | CA | Completed | C | Yip, Kin |  | Design |  | Kin Yip |  | POM02.2.02.04 | 04 |  | S1000199 | L1 | null | A | 2.02 | 16719 | 2.02 |  |  |  |  |  | MP6LAEXCLUDE | 190315 DurType to align with EVT | Yes | 2018 | 003 | yes |  |
| S1001399 |  | Actuals - Labor - sPHENIX Magnet FY19 M8 16719 |  | 166d | 2018-10-01 A | 2019-05-31 A |  | 100% |  |  |  |  |  |  | Actual Labor [69.39 h] | 11,594.58 | S278500 | 100 |  | S339340 | CA | Completed | C | Yip, Kin |  | Design |  | Kin Yip |  | POM02.2.02.04 | 04 |  | S1001399 | L1 | null | A | 2.02 | 16719 | 2.02 |  |  |  |  |  | MP6LAEXCLUDE | 190315 DurType to align with EVT | Yes | 2019 | 003 | yes |  |
| S1004520 |  | Actuals - Labor FY19 Jun-Sep 16719 |  | 84d | 2019-06-03 A | 2019-09-30 A |  | 100% |  |  |  |  |  |  | Actual Labor [109.17 h] | 18,241.53 | S278400 | 100 |  | S338540 | CA | Completed | C | Yip, Kin |  | Design |  | Kin Yip |  | POM02.2.02.04 | 04 |  | S1004520 | L1 | null | A | 2.02 | 16719 | 2.02 |  |  |  |  |  | MP6LAEXCLUDE | 190315 DurType to align with EVT | Yes | 2017 | 003 | yes |  |
| S1004560 |  | Actuals - NonLabor FY19 Jun-Sep 16719 |  | 84d | 2019-06-03 A | 2019-09-30 A |  | 100% |  |  |  |  |  |  | Actual Nonlabor [512.03 h] | 564.9 | S278400 | 100 |  | S338540 | CA | Completed | C | Yip, Kin |  | Design |  | Kin Yip |  | POM02.2.02.04 | 04 |  | S1004560 | L1 | null | A | 2.02 | 16719 | 2.02 |  |  |  |  |  | MP6LAEXCLUDE | 190315 DurType to align with EVT | Yes | 2017 | 003 | yes | UDF_G3 |

Notes:
- S299500: BNL_UDF_Old Activity Name 181221: (Cryo Controls Hardware) Rack available from 912
- S299600: BNL_UDF_Old Activity Name 181221: (Cryo Controls Hardware) Rack built/rebuilt
- S299700: BNL_UDF_Old Activity Name 181221: (Cryo Controls Hardware) Rack install
- S299800: BNL_UDF_Old Activity Name 181221: (Cryo Controls Hardware) Cable pulling
- S299810: BNL_UDF_Old Activity Name 181221: (Cryo Controls Hardware) Cable pulling
- S300100: BNL_UDF_Old Activity Name 181221: (Cryo Controls Hardware) Heater Control Panel Install
- S299900: BNL_UDF_Old Activity Name 181221: (Cryo Controls Hardware) Cable termination
- S300200: BNL_UDF_Old Activity Name 181221: (Cryo Controls Hardware) Heater 480VAC wiring
- S300300: BNL_UDF_Old Activity Name 181221: (Cryo Controls Hardware) Insulating vacuum roughing pumps 480VAC Breaker install and 480V wiring to roughing pumps
- S300400: BNL_UDF_Old Activity Name 181221: (Cryo Controls Hardware) Heater I/O wiring, temp sensors
- S300500: BNL_UDF_Old Activity Name 181221: (Cryo Controls Hardware) Wire up instruments and control valves
- S300000: BNL_UDF_Old Activity Name 181221: (Cryo Controls Hardware) Check out continuity
- S300600: BNL_UDF_Old Activity Name 181221: (Cryo Controls Hardware) Hardware Installed
- S301000: BNL_UDF_Old Activity Name 181221: (Cryo Controls Hardware) PLC programming
- S300700: BNL_UDF_Old Activity Name 181221: (Cryo Controls Hardware) Control Logic eng document revision by Cryo process engineering
- S300800: BNL_UDF_Old Activity Name 181221: (Cryo Controls Hardware) Interface document definition for variables to MCR and sPHENIX controls
- S300900: BNL_UDF_Old Activity Name 181221: (Cryo Controls Hardware) Built HMI operator screens
- S300910: BNL_UDF_Old Activity Name 181221: (Cryo Controls Hardware) Built HMI operator screens
- S301100: BNL_UDF_Old Activity Name 181221: (Cryo Controls Hardware) Live I/O check out and control logic test
- S1000119: BNL_UDF_Old Activity Name 181221: Actuals - Labor - sPHENIX Magnet FY17
- S1000199: BNL_UDF_Old Activity Name 181221: Actuals - Labor - sPHENIX Magnet FY18
- S1001399: BNL_UDF_Old Activity Name 181221: Actuals - Labor - sPHENIX Magnet FY18
- S1004520: BNL_UDF_Old Activity Name 181221: Actuals - Labor - sPHENIX Magnet FY17
- S1004560: BNL_UDF_Old Activity Name 181221: Actuals - Labor - sPHENIX Magnet FY17

| ID | WBS | Activity | Duration | Start | Finish | Predecessors | Complete | Planned start | Planned finish | Total float | Free float | Constraint | Expected finish | Resources | Cost | BNL_UDF_Temp Text 01 | BNL_UDF_Percent Complete | BNL_UDF_OPC TEC (deprecated) | BNL_UDF_Old Activity ID 181221 | RG Check | BNL_Activity Status | BNL_Fund Source | BNL_Estimator | BNL_Location | BNL_EDIA | BNL_CAM | BNL_Institution | BNL_WBS | BNL_EVT | BNL_WBS_Hierarchical | Completed | BNL_Cost Basis | BNL_Account Number | BNL_OPC TEC (deprecated) | BNL_Master Control Account | Temp | BNL_Cobra WP | BNL_Cobra Control Account | BNL_UDF_Status Comments | BNL_Proc Sig | BNL_PCR ID | BNL_UDF_Adhoc Comments | Indicator - Procurement | Indicator - Float | BNL_UDF_Remaining Tot Cost | BNL_UDF_Percent_remaining | BNL_UDF_Exclude |
| --- | --- | --- | --- | --- | --- | --- | --- | --- | --- | --- | --- | --- | --- | --- | --- | --- | --- | --- | --- | --- | --- | --- | --- | --- | --- | --- | --- | --- | --- | --- | --- | --- | --- | --- | --- | --- | --- | --- | --- | --- | --- | --- | --- | --- | --- | --- | --- |
|  | 01 | **AC/DC Power Distribution** |  | 2017-02-01 | 2022-01-13 |  |  |  |  |  |  |  |  |  |  |  |  |  |  |  |  |  |  |  |  |  |  |  |  |  |  |  |  |  |  |  |  |  |  |  |  |  |  |  |  |  |  |
|  | 01 | **Design AC/DC Power Distribution** |  | 2017-02-01 | 2021-06-25 |  |  |  |  |  |  |  |  |  |  |  |  |  |  |  |  |  |  |  |  |  |  |  |  |  |  |  |  |  |  |  |  |  |  |  |  |  |  |  |  |  |  |
| S301200 |  | Magnet: Design Power Supply AC and Quench Detector Power Distribution | 10d | 2017-02-01 A | 2017-02-14 A | S100090 SS | 100% |  |  |  |  |  |  |  |  | S301200 | 100 | S265900 | S265900 | NOCA | Completed | C | Yip, Kin | BNL | Design | Kin Yip | BNL | POM02.2.02.04.01.01 | C | 01 | yes |  |  |  |  |  |  |  |  |  |  |  |  |  |  |  |  |
| S301500 |  | Magnet: Design Power Supply, Magnet, Dump Resistor DC Cabling | 5d | 2017-02-01 A | 2017-02-07 A | S100090 SS | 100% |  |  |  |  |  |  |  |  | S301500 | 100 | S266200 | S266200 | NOCA | Completed | C | Yip, Kin | BNL | Design | Kin Yip | BNL | POM02.2.02.04.01.01 | C | 01 | yes |  |  |  |  |  |  |  |  |  |  |  |  |  |  |  |  |
| S301300 |  | Magnet: Design Power Supply AC Power Hook-up | 3d | 2017-02-15 A | 2017-02-17 A | S301200 | 100% |  |  |  |  |  |  |  |  | S301300 | 100 | S266000 | S266000 | NOCA | Completed | C | Yip, Kin | BNL | Design | Kin Yip | BNL | POM02.2.02.04.01.01 | C | 01 | yes |  |  |  |  |  |  |  |  |  |  |  |  |  |  |  |  |
| S301400 |  | Magnet: Design Quench Detector AC Power Hook-up | 2d | 2017-02-15 A | 2017-02-16 A | S301200 | 100% |  |  |  |  |  |  |  |  | S301400 | 100 | S266100 | S266100 | NOCA | Completed | C | Yip, Kin | BNL | Design | Kin Yip | BNL | POM02.2.02.04.01.01 | C | 01 | yes |  |  |  |  |  |  |  |  |  |  |  |  |  |  |  |  |
| S301600 |  | Magnet: 1008 IR Design Power Supply AC and Quench Detector Power Distribution | 39d | 2019-04-08 A | 2019-05-31 A | S101009 FS+105d | 100% |  |  |  |  |  |  |  |  | S301600 | 0 |  | S266240 | NOCA | Completed | C | Yip, Kin |  | Design | Kin Yip |  | POM02.2.02.04.01.01 | C | 01 | yes | L4 | 16719 |  |  |  |  |  |  |  |  |  |  |  |  |  |  |
| S301700 |  | Magnet: 1008 IR Design Power Supply AC Power Hook-up | 29d | 2019-04-22 A | 2019-05-31 A |  | 100% |  |  |  |  |  |  |  |  | S301700 | 0 |  | S266280 | NOCA | Completed | C | Yip, Kin |  | Design | Kin Yip |  | POM02.2.02.04.01.01 | C | 01 | yes | L4 | 16719 |  |  |  |  |  |  |  |  |  |  |  |  |  |  |
| S301900 |  | Magnet: 1008 IR Design Power Supply, Magnet, Dump Resistor DC Cabling | 24d | 2019-04-29 A | 2019-05-31 A | S301800 | 100% |  |  |  |  |  |  |  |  | S301900 | 0 |  | S266295 | NOCA | Completed | C | Yip, Kin |  | Design | Kin Yip |  | POM02.2.02.04.01.01 | C | 01 | yes | L4 | 16719 |  |  |  |  |  |  |  |  |  |  |  |  |  |  |
| S302000 |  | Magnet: Design Cable Tray and Supports for Power and Signal Distribution | 19d | 2019-05-06 A | 2019-05-31 A | S303700, S301800 | 100% |  |  |  |  |  |  |  |  | S302000 | 0 | S266300 | S266300 | NOCA | Completed | C | Yip, Kin | BNL | Design | Kin Yip | BNL | POM02.2.02.04.01.01 | C | 01 | yes | L4 | 16719 | null |  |  |  |  |  |  |  |  |  |  |  |  |  |
| S302100 |  | Magnet: Design DC Flags 50% | 44d | 2019-07-30 A | 2019-09-30 A | S302010 | 100% |  |  |  |  |  |  |  |  | S302100 | 0 | S266300 | S266350 | NOCA | Completed | C | Yip, Kin | BNL | Design | Kin Yip | BNL | POM02.2.02.04.01.01 | C | 01 |  | L4 | 16719 | null | 2.02 | 1 |  |  |  |  |  |  |  |  |  |  |  |
| S301610 |  | Magnet: 1008 IR Design Power Supply AC and Quench Detector Power Distribution Split | 39d | 2019-10-01 A | 2021-02-26 A | S301600 | 100% | 2019-11-01 | 2019-12-31 |  |  |  |  | PROF4 AD [30 h] | 4,417.95 | S301600 | 0 |  | S266240 | CA | In Progress | C | Yip, Kin |  | Design | Kin Yip |  | POM02.2.02.04.01.01 | C | 01 |  | L4 | 16719 |  | 2.02 |  | S301610 | 2.02 |  |  |  |  |  |  |  |  |  |
| S302010 |  | Magnet: Design Cable Tray and Supports for Power and Signal Distribution Split | 5d | 2020-11-23 A | 2021-02-26 A | S302000, S301910, S301710 | 100% | 2021-01-19 | 2021-01-25 |  |  |  |  | PROF4 AD [60 h] | 9,100.98 | S302000 | 0 | S266300 | S266300 | CA | Not Started | C | Yip, Kin | BNL | Design | Kin Yip | BNL | POM02.2.02.04.01.01 | C | 01 |  | L4 | 16719 | null | 2.02 |  | S302010 | 2.02 |  |  |  |  |  |  |  |  |  |
| S301710 |  | Magnet: 1008 IR Design Power Supply AC Power Hook-up Split | 5d | 2021-01-12 A | 2021-02-26 A | S301700, S301610 | 100% | 2021-05-03 | 2021-05-07 |  |  |  |  | PROF4 AD [18 h] | 2,730.29 | S301700 | 0 |  | S266280 | CA | Not Started | C | Yip, Kin |  | Procurement | Kin Yip |  | POM02.2.02.04.01.01 | C | 01 |  | L4 | 16719 |  | 2.02 |  | S301710 | 2.02 |  |  |  |  |  |  |  |  |  |
| S301800 |  | Magnet: 1008 IR Design Quench Detector AC Power Hook-up | 5d | 2021-01-12 A | 2021-02-26 A | S301610 | 100% | 2021-05-03 | 2021-05-07 |  |  |  |  | PROF4 AD [16 h] | 2,426.93 | S301800 | 0 |  | S266290 | CA | Not Started | C | Yip, Kin |  | Procurement | Kin Yip |  | POM02.2.02.04.01.01 | C | 01 |  | L4 | 16719 |  | 2.02 |  | S301800 | 2.02 |  |  |  |  |  |  |  |  |  |
| S301910 |  | Magnet: 1008 IR Design Power Supply, Magnet, Dump Resistor DC Cabling Split | 5d | 2021-01-12 A | 2021-02-26 A | S301900 | 100% | 2021-05-10 | 2021-05-14 |  |  |  |  | PROF4 AD [12 h] | 1,820.2 | S301900 | 0 |  | S266295 | CA | Not Started | C | Yip, Kin |  | Procurement | Kin Yip |  | POM02.2.02.04.01.01 | C | 01 |  | L4 | 16719 |  | 2.02 |  | S301910 | 2.02 |  |  |  |  |  |  |  |  |  |
| S302101 |  | Magnet: Design DC Flags 50% | 19d | 2021-06-01 | 2021-06-25 | S302010, S302100 |  |  |  | 220d | 0d | start on or after 2021-06-01 | 2021-04-27 | PROF4 AD [5 h] | 758.41 | S302100 | 0 | S266300 | S266350 | CA | Not Started | C | Yip, Kin | BNL | Design | Kin Yip | BNL | POM02.2.02.04.01.01 | C | 01 |  | L4 | 16719 | null | 2.02 | 1 | S302101 | 2.02 |  |  |  |  |  |  |  |  |  |
|  | 02 | **Procure PS System Connections** |  | 2019-07-24 | 2021-04-30 |  |  |  |  |  |  |  |  |  |  |  |  |  |  |  |  |  |  |  |  |  |  |  |  |  |  |  |  |  |  |  |  |  |  |  |  |  |  |  |  |  |  |
| S302200 |  | Magnet: Delivery AC Power Distribution Parts M&S_50% | 48d | 2019-07-24 A | 2019-09-30 A | S101000 | 100% |  |  |  |  |  |  |  |  | S302200 | 0 | S266400 | S266400 | NOCA | Completed | C | Yip, Kin | BNL | Fab & Assy | Kin Yip | BNL | POM02.2.02.04.01.02 | C | 02 |  | M3 | 16719 | null | 2.02 | 1 |  |  | 190607 IVS investigate big float | TBD | 005 |  |  |  |  |  |  |
| S302900 |  | Magnet: Order Cable Tray and Supports_15% | 44d | 2019-07-30 A | 2019-09-30 A | S101000 FF | 100% |  |  |  |  |  |  |  |  | S302900 | 0 | S267100 | S267100 | NOCA | Completed | C | Yip, Kin | BNL | Procurement | Kin Yip | BNL | POM02.2.02.04.01.02 | C | 02 |  | L4 | 16719 | null | 2.02 | 1 |  |  |  |  |  | 180219 ELM resource change from PROF3 AD to PROF4 AD per EOB |  |  |  |  |  |
| S302600 |  | Magnet: Order Power Supply and Quench Detector AC Power Cables and Interconnects Labor 5% | 33d | 2019-08-14 A | 2019-09-30 A | S301400, S101000 | 100% |  |  |  |  |  |  |  |  | S302600 | 0 | S266800 | S266800 | NOCA | Completed | C | Yip, Kin | BNL | Procurement | Kin Yip | BNL | POM02.2.02.04.01.02 | C | 02 |  | L4 | 16719 | null | 2.02 | 1 |  |  |  |  |  |  |  |  |  |  |  |
| S302601 |  | Magnet: Order Power Supply and Quench Detector AC Power Cables and Interconnects Labor 95% | 21d | 2019-11-01 A | 2021-02-26 A | S302600 | 100% | 2019-12-02 | 2019-12-31 |  |  |  |  | PROF4 AD [7.6 h] | 1,119.21 | S302600 | 0 | S266800 | S266800 | CA | In Progress | C | Yip, Kin | BNL | Procurement | Kin Yip | BNL | POM02.2.02.04.01.02 | C | 02 |  | L4 | 16719 | null | 2.02 | 1 | S302601 | 2.02 |  |  |  |  |  |  |  |  |  |
| S302201 |  | Magnet: Delivery AC Power Distribution Parts M&S_50% | 39d | 2019-12-02 A | 2021-02-26 A | S302200, S301610 FF | 100% | 2019-12-02 | 2020-01-28 |  |  |  |  | Material (Purchase (1st $2M) [10000 h] | 11,379.26 | S302200 | 0 | S266400 | S266400 | CA | Not Started | C | Yip, Kin | BNL | Fab & Assy | Kin Yip | BNL | POM02.2.02.04.01.02 | C | 02 |  | M3 | 16719 | null | 2.02 | 1 | S302201 | 2.02 | 190607 IVS investigate big float | TBD | 005 |  | UDF_G1 | UDF_G3 | 7965.48053 | 0.7 |  |
| S302901 |  | Magnet: Order Cable Tray and Supports_85% | 21d | 2020-03-24 A | 2020-03-31 A | S302900, S302010 FF | 100% | 2020-03-24 | 2020-04-21 |  |  |  |  | PROF4 AD [68 h] | 10,014.02 | S302900 | 0 | S267100 | S267100 | CA | Not Started | C | Yip, Kin | BNL | Procurement | Kin Yip | BNL | POM02.2.02.04.01.02 | C | 02 |  | L4 | 16719 | null | 2.02 | 1 | S302901 | 2.02 |  |  |  | 180219 ELM resource change from PROF3 AD to PROF4 AD per EOB |  |  |  |  |  |
| S303000 |  | Magnet: Order Cable Tray and Supports M&S | 60d | 2020-03-24 A | 2020-03-31 A | S302901 | 100% | 2020-04-22 | 2020-07-16 |  |  |  |  | Material (Purchase (1st $2M) [2000 h] | 2,275.85 | S303000 | 0 | S267200 | S267200 | CA | Not Started | C | Yip, Kin | BNL | Procurement | Kin Yip | BNL | POM02.2.02.04.01.02 | C | 02 |  | M3 | 16719 |  | 2.02 |  | S303000 | 2.02 |  | TBD |  |  | UDF_G1 | UDF_G3 |  |  |  |
| S302500 |  | Magnet: Order AC Power Distribution Parts Labor | 1d | 2020-05-20 A | 2021-02-26 A | S101000, S301800, S301710 | 100% | 2020-11-09 | 2020-11-09 |  |  |  |  | PROF4 AD [8 h] | 1,213.46 | S302500 | 0 | S266700 | S266700 | CA | Not Started | C | Yip, Kin | BNL | Procurement | Kin Yip | BNL | POM02.2.02.04.01.02 | C | 02 |  | L4 | 16719 | null | 2.02 |  | S302500 | 2.02 |  |  |  |  |  |  |  |  |  |
| S302800 |  | Magnet: Fabricate DC flags | 10d | 2020-10-22 A | 2020-10-28 A | S101000, S301910, S302101 | 100% | 2021-02-25 | 2021-03-10 |  |  |  |  | CRAFT3 [40 h] | 5,152.94 | S302800 | 0 | S267000 | S267000 | CA | Not Started | C | Yip, Kin | BNL | Fab & Assy | Kin Yip | BNL | POM02.2.02.04.01.02 | C | 02 |  | L4 | 16719 | null | 2.02 |  | S302800 | 2.02 |  |  |  |  |  |  |  |  |  |
| S302400 |  | Magnet: Delivery Power Supply, Magnet, Dump Resistor DC Cabling and Interconnects M&S | 60d | 2020-11-23 A | 2021-04-30 A | S301500, S101000, S303000 | 100% | 2021-01-26 | 2021-04-20 |  |  |  |  | Material (Purchase (1st $2M) [21000 h] | 24,374.37 | S302400 | 0 | S266600 | S266600 | CA | Not Started | C | Yip, Kin | BNL | Fab & Assy | Kin Yip | BNL | POM02.2.02.04.01.02 | C | 02 |  | M3 | 16719 | null | 2.02 |  | S302400 | 2.02 |  | TBD |  |  | UDF_G1 | UDF_G3 | 24374.37051 | 1 | MP6LAEXCLUDE |
| S302700 |  | Magnet: Order Power Supply, Magnet, Dump Resistor DC Cabling and Interconnects Labor | 2d | 2020-12-15 A | 2021-04-30 A | S101000, S301910 | 100% | 2021-05-17 | 2021-05-18 |  |  |  |  | PROF4 AD [16 h] | 2,426.93 | S302700 | 0 | S266900 | S266900 | CA | Not Started | C | Yip, Kin | BNL | Procurement | Kin Yip | BNL | POM02.2.02.04.01.02 | C | 02 |  | L4 | 16719 | null | 2.02 |  | S302700 | 2.02 |  |  |  |  |  |  |  |  |  |
| S302300 |  | Magnet: Delivery Power Supply and Quench Detector AC Power Cables and Interconnects M&S | 1d | 2021-01-25 A | 2021-02-26 A | S301300, S301400, S101000, S303000 | 100% | 2021-05-24 | 2021-05-24 |  |  |  |  | Material (Purchase (1st $2M) [4000 h] | 4,642.74 | S302300 | 0 | S266500 | S266500 | CA | Not Started | C | Yip, Kin | BNL | Fab & Assy | Kin Yip | BNL | POM02.2.02.04.01.02 | C | 02 |  | M3 | 16719 | null | 2.02 |  | S302300 | 2.02 |  | TBD |  |  | UDF_G1 | UDF_G3 | 4642.73724 | 1 |  |

Notes:
- S301200: BNL_UDF_Old Activity Name 181221: Magnet: Design Power Supply AC and Quench Detector Power Distribution
- S301500: BNL_UDF_Old Activity Name 181221: Magnet: Design Power Supply, Magnet, Dump Resistor DC Cabling
- S301300: BNL_UDF_Old Activity Name 181221: Magnet: Design Power Supply AC Power Hook-up
- S301400: BNL_UDF_Old Activity Name 181221: Magnet: Design Quench Detector AC Power Hook-up
- S301600: BNL_UDF_Old Activity Name 181221: Magnet: 1008 IR Design Power Supply AC and Quench Detector Power Distribution
- S301700: BNL_UDF_Old Activity Name 181221: Magnet: 1008 IR Design Power Supply AC Power Hook-up
- S301900: BNL_UDF_Old Activity Name 181221: Magnet: 1008 IR Design Power Supply, Magnet, Dump Resistor DC Cabling
- S302000: BNL_UDF_Old Activity Name 181221: Magnet: Design Cable Tray and Supports for Power and Signal Distribution
- S302100: BNL_UDF_Old Activity Name 181221: Magnet: Design DC Flags
- S301610: BNL_UDF_Old Activity Name 181221: Magnet: 1008 IR Design Power Supply AC and Quench Detector Power Distribution
- S302010: BNL_UDF_Old Activity Name 181221: Magnet: Design Cable Tray and Supports for Power and Signal Distribution
- S301710: BNL_UDF_Old Activity Name 181221: Magnet: 1008 IR Design Power Supply AC Power Hook-up
- S301800: BNL_UDF_Old Activity Name 181221: Magnet: 1008 IR Design Quench Detector AC Power Hook-up
- S301910: BNL_UDF_Old Activity Name 181221: Magnet: 1008 IR Design Power Supply, Magnet, Dump Resistor DC Cabling
- S302101: BNL_UDF_Old Activity Name 181221: Magnet: Design DC Flags
- S302200: BNL_UDF_Old Activity Name 181221: Magnet: Delivery AC Power Distribution Parts M&S
- S302900: BNL_UDF_Old Activity Name 181221: Magnet: Order Cable Tray and Supports
- S302600: BNL_UDF_Old Activity Name 181221: Magnet: Order Power Supply and Quench Detector AC Power Cables and Interconnects Labor
- S302601: BNL_UDF_Old Activity Name 181221: Magnet: Order Power Supply and Quench Detector AC Power Cables and Interconnects Labor
- S302201: BNL_UDF_Old Activity Name 181221: Magnet: Delivery AC Power Distribution Parts M&S
- S302901: BNL_UDF_Old Activity Name 181221: Magnet: Order Cable Tray and Supports
- S303000: BNL_UDF_Old Activity Name 181221: Magnet: Order Cable Tray and Supports M&S
- S302500: BNL_UDF_Old Activity Name 181221: Magnet: Order AC Power Distribution Parts Labor
- S302800: BNL_UDF_Old Activity Name 181221: Magnet: Fabricate DC flags
- S302400: BNL_UDF_Old Activity Name 181221: Magnet: Delivery Power Supply, Magnet, Dump Resistor DC Cabling and Interconnects M&S
- S302700: BNL_UDF_Old Activity Name 181221: Magnet: Order Power Supply, Magnet, Dump Resistor DC Cabling and Interconnects Labor
- S302300: BNL_UDF_Old Activity Name 181221: Magnet: Delivery Power Supply and Quench Detector AC Power Cables and Interconnects M&S

| ID | WBS | Activity | Type | Duration | Start | Finish | Predecessors | Complete | Remaining | Planned start | Planned finish | Total float | Free float | Constraint | Expected finish | Resources | Cost | BNL_UDF_Temp Text 01 | BNL_UDF_Percent Complete | BNL_UDF_OPC TEC (deprecated) | BNL_UDF_Old Activity ID 181221 | BNL_Cobra WP | RG Check | BNL_Activity Status | BNL_Fund Source | BNL_Estimator | BNL_Cost Basis | BNL_Location | BNL_EDIA | BNL_CAM | BNL_Institution | BNL_OPC TEC (deprecated) | BNL_WBS | BNL_EVT | BNL_Master Control Account | BNL_Account Number | BNL_Cobra Control Account | BNL_WBS_Hierarchical | Major SC Activity | BNL_Milestone Level | Completed | BNL_UDF_Temp Date 01 | Temp | Indicator - Procurement | Indicator - Float | BNL_UDF_Remaining Tot Cost | BNL_UDF_Percent_remaining |
| --- | --- | --- | --- | --- | --- | --- | --- | --- | --- | --- | --- | --- | --- | --- | --- | --- | --- | --- | --- | --- | --- | --- | --- | --- | --- | --- | --- | --- | --- | --- | --- | --- | --- | --- | --- | --- | --- | --- | --- | --- | --- | --- | --- | --- | --- | --- | --- |
|  | 03 | **Install PS AC/DC Cabling** |  |  | 2020-09-16 | 2022-01-13 |  |  |  |  |  |  |  |  |  |  |  |  |  |  |  |  |  |  |  |  |  |  |  |  |  |  |  |  |  |  |  |  |  |  |  |  |  |  |  |  |  |
| S303200 |  | Magnet: Install Cable Tray and Supports for Power and Signal Distribution in 1008B to 1008IR |  | 15d | 2020-09-16 A | 2021-09-08 | S302400 | 30% | 70d | 2021-02-24 | 2021-03-16 | 149d | 0d |  | 2021-09-08 | PROF4 AD [60 h]; CRAFT3 [240 h] | 40,018.6 | S303200 | 0 | S267300 | S267302 | S303200 | CA | Not Started | C | Yip, Kin | L4 | BNL | Installation | Kin Yip | BNL | null | POM02.2.02.04.01.03 | C | 2.02 | 16719 | 2.02 | 03 | Yes |  |  |  |  |  |  |  |  |
| S303100 |  | Magnet: Install Cable Tray and Supports for Power and Signal Distribution 1008B |  | 10d | 2020-09-22 A | 2021-03-29 A | S303000, S302201 | 100% |  | 2021-01-04 | 2021-01-15 |  |  |  |  | PROF4 AD [40 h]; CRAFT3 [160 h] | 26,679.07 | S303100 | 0 | S267300 | S267300 | S303100 | CA | Not Started | C | Yip, Kin | L4 | BNL | Installation | Kin Yip | BNL | null | POM02.2.02.04.01.03 | C | 2.02 | 16719 | 2.02 | 03 | Yes |  |  |  |  |  |  |  |  |
| S303400 |  | Magnet: Pull & Terminate AC/DC Power Cables and Signal Cables 1008B |  | 10d | 2020-09-22 A | 2021-03-29 A | S303100, S303700, S302300, S302500, S302700, S302601 | 100% |  | 2021-01-19 | 2021-02-01 |  |  |  |  | PROF4 AD [16 h]; TECH3 AD [160 h]; CRAFT3 [220 h] | 49,575.41 | S303400 | 0 | S267400 | S267400 | S303400 | CA | Not Started | C | Yip, Kin | L4 | BNL | Installation | Kin Yip | BNL | null | POM02.2.02.04.01.03 | C | 2.02 | 16719 | 2.02 | 03 | Yes |  |  |  |  |  |  |  |  |
| S303300 |  | Magnet: Install Cable Tray and Supports for Power and Signal Distribution 1008IR |  | 15d | 2021-09-09 | 2021-09-29 | S303200 |  |  |  |  | 149d | 0d |  |  | CRAFT3 [240 h]; PROF4 AD [60 h] | 40,018.6 | S303300 | 0 |  | S267342 | S303300 | CA | Not Started | C | Yip, Kin | L4 |  | Procurement | Kin Yip |  |  | POM02.2.02.04.01.03 | C | 2.02 | 16719 | 2.02 | 03 | Yes |  |  |  |  |  |  |  |  |
| S303500 |  | Magnet: Pull & Terminate AC/DC Power Cables and Signal Cables 1008B to 1008IR |  | 15d | 2021-09-09 | 2021-09-29 | S303200 |  |  |  |  | 149d | 120d |  |  | PROF4 AD [60 h]; TECH3 AD [240 h]; CRAFT3 [300 h] | 75,959 | S303500 | 0 | S267400 | S267402 | S303500 | CA | Not Started | C | Yip, Kin | L4 | BNL | Installation | Kin Yip | BNL | null | POM02.2.02.04.01.03 | C | 2.02 | 16719 | 2.02 | 03 | Yes |  |  |  |  |  |  |  |  |
| S303310 |  | Completed - Magnet: Install Cable Tray and Supports for Power and Signal Distribution 1008IR | milestone | 0d | 2021-09-29 | 2021-09-29 | S303300 FF |  |  |  |  | 149d | 120d |  |  |  |  | S303300 | 0 |  | S267342 |  | NOCA | Not Started | C | Yip, Kin |  |  | Procurement | Kin Yip |  |  | POM02.2.02.04.01.03 |  |  |  |  | 03 | Yes | L5 |  |  |  |  |  |  |  |
| S303600 |  | Magnet: Pull & Terminate AC/DC Power Cables and Signal Cables 1008IR |  | 10d | 2021-12-30 | 2022-01-13 | S303700, S101012, S349410, S302201 |  |  |  |  | 79d | 0d |  |  | PROF4 AD [40 h]; TECH3 AD [160 h]; CRAFT3 [220 h] | 54,812.28 | S303600 | 0 |  | S267442 | S303600 | CA | Not Started | C | Yip, Kin | L4 |  | Installation | Kin Yip |  |  | POM02.2.02.04.01.03 | C | 2.02 | 16719 | 2.02 | 03 | Yes |  |  |  |  |  |  |  |  |
| S303610 |  | Completed - Magnet: Pull & Terminate AC/DC Power Cables and Signal Cables 1008IR | milestone | 0d | 2022-01-13 | 2022-01-13 | S303600 FF |  |  |  |  | 79d | 50d |  |  |  |  | S303600 | 0 |  | S267442 |  | NOCA | Not Started | C | Yip, Kin |  |  | Installation | Kin Yip |  |  | POM02.2.02.04.01.03 |  |  |  |  | 03 | Yes | L5 |  |  |  |  |  |  |  |
|  | 02 | **Power Supply** |  |  | 2017-02-01 | 2022-04-18 |  |  |  |  |  |  |  |  |  |  |  |  |  |  |  |  |  |  |  |  |  |  |  |  |  |  |  |  |  |  |  |  |  |  |  |  |  |  |  |  |  |
|  | 01 | **Install Power Supply** |  |  | 2017-02-01 | 2022-04-18 |  |  |  |  |  |  |  |  |  |  |  |  |  |  |  |  |  |  |  |  |  |  |  |  |  |  |  |  |  |  |  |  |  |  |  |  |  |  |  |  |  |
| S303700 |  | Magnet Power Supply Installation: Design Signal Interconnects |  | 5d | 2017-02-01 A | 2017-02-07 A | S100090 SS | 100% |  |  |  |  |  |  |  |  |  | S303700 | 100 | S267500 | S267500 |  | NOCA | Completed | C | Yip, Kin |  | BNL | Design | Kin Yip | BNL |  | POM02.2.02.04.02.01 | C |  |  |  | 01 |  |  | yes |  |  |  |  |  |  |
| S304300 |  | Magnet Power Supply Installation: Cooling Water Design |  | 105d | 2019-01-02 A | 2019-05-31 A | S101009 | 100% |  |  |  |  |  |  |  |  |  | S304300 | 20 |  | S267940 |  | NOCA | Completed | C | Yip, Kin | L4 |  | Design | Kin Yip |  |  | POM02.2.02.04.02.01 | C |  | 16719 |  | 01 |  |  | yes | 2019-05-15 |  |  |  |  |  |
| S305100 |  | Magnet Power Supply Installation: Documentation |  | 95d | 2019-01-16 A | 2019-05-31 A | S303700 | 100% |  |  |  |  |  |  |  |  |  | S305100 | 10 |  | S268010 |  | NOCA | Completed | C | Yip, Kin | L4 |  | Design | Kin Yip |  |  | POM02.2.02.04.02.01 | C |  | 16719 |  | 01 |  |  | yes | 2019-05-30 |  |  |  |  |  |
| S303800 |  | Magnet Power Supply Installation: Disconnect Power Supply from Test System in 912 |  | 1d | 2019-07-24 A | 2019-07-24 A | S101000 | 100% |  |  |  |  |  |  |  |  |  | S303800 | 0 | S267600 | S267550 |  | NOCA | Completed | C | Yip, Kin | L4 | BNL | Installation | Kin Yip | BNL | null | POM02.2.02.04.02.01 | C | 2.02 | 16719 |  | 01 |  |  |  |  |  |  |  |  |  |
| S304900 |  | Magnet Power Supply Installation: Design and Test Control Interface update software_50% |  | 20d | 2019-09-03 A | 2019-09-30 A |  | 100% |  |  |  |  |  |  |  |  |  | S304900 | 0 |  | S267986 |  | NOCA | Completed | C | Yip, Kin | L4 |  | Installation | Kin Yip |  |  | POM02.2.02.04.02.01 | C | 2.02 | 16719 |  | 01 |  |  |  |  | 1 |  |  |  |  |
| S305110 |  | Magnet Power Supply Installation: Documentation Split |  | 290d | 2019-10-01 A | 2019-12-31 A | S305100 | 100% |  | 2019-11-01 | 2020-12-31 |  |  |  |  | TECH3 AD [216 h]; PROF5 AD [108 h] | 43,288.65 | S305100 | 10 |  | S268010 | S305110 | CA | In Progress | C | Yip, Kin | L4 |  | Design | Kin Yip |  |  | POM02.2.02.04.02.01 | C | 2.02 | 16719 | 2.02 | 01 |  |  |  | 2019-05-30 |  |  |  |  |  |
| S304310 |  | Magnet Power Supply Installation: Cooling Water Design Split |  | 21d | 2019-11-01 A | 2021-04-28 A | S304300 | 100% |  | 2019-12-02 | 2019-12-31 |  |  |  |  | PROF4 AD [64 h] | 9,424.96 | S304300 | 20 |  | S267940 | S304310 | CA | In Progress | C | Yip, Kin | L4 |  | Installation | Kin Yip |  |  | POM02.2.02.04.02.01 | C | 2.02 | 16719 | 2.02 | 01 |  |  |  | 2019-05-15 |  |  |  |  |  |
| S304901 |  | Magnet Power Supply Installation: Design and Test Control Interface update software_50% |  | 21d | 2019-11-13 A | 2019-11-29 A | S304900 | 100% |  | 2019-12-02 | 2019-12-31 |  |  |  |  | PROF4 AD [60 h]; PROF5 AD [30 h] | 13,937.79 | S304900 | 0 |  | S267986 | S304901 | CA | Completed | C | Yip, Kin | L4 |  | Installation | Kin Yip |  |  | POM02.2.02.04.02.01 | C | 2.02 | 16719 | 2.02 | 01 |  |  |  |  | 1 |  |  |  |  |
| S304400 |  | Magnet Power Supply Installation: Cooling Water Installation 1008B |  | 5d | 2020-08-03 A | 2021-05-24 A | S303900, S304310 | 100% |  | 2020-11-03 | 2020-11-09 |  |  |  |  | TECH3 AD [70 h] | 8,228.21 | S304400 | 0 |  | S267980 | S304400 | CA | Not Started | C | Yip, Kin | L4 |  | Installation | Kin Yip |  |  | POM02.2.02.04.02.01 | C | 2.02 | 16719 | 2.02 | 01 |  |  |  |  |  |  |  |  |  |
| S304500 |  | Magnet Power Supply Installation: Water Cooled Bus Termination 1008B L |  | 5d | 2020-08-03 A | 2021-03-23 A | S302800, S303100, S303400, S303900 | 100% |  | 2021-03-11 | 2021-03-17 |  |  |  |  | TECH3 AD [70 h] | 8,228.21 | S304500 | 0 |  | S267982 | S304500 | CA | Not Started | C | Yip, Kin | L4 |  | Installation | Kin Yip |  |  | POM02.2.02.04.02.01 | C | 2.02 | 16719 | 2.02 | 01 | Yes |  |  |  |  |  |  |  |  |
| S304600 |  | Magnet Power Supply Installation: Water Cooled Bus Termination 1008B M&S |  | 5d | 2020-08-03 A | 2021-05-24 A | S302800, S303100, S303400, S303900 | 100% |  | 2021-03-11 | 2021-03-17 |  |  |  |  | Material (Purchase (1st $2M) [8000 h] | 8,924.91 | S304600 | 0 |  | S267983 | S304600 | CA | Not Started | C | Yip, Kin | M3 |  | Installation | Kin Yip |  |  | POM02.2.02.04.02.01 | C | 2.02 | 16719 | 2.02 | 01 |  |  |  |  |  | UDF_G1 | UDF_G3 | 8924.90816 | 1 |
| S304100 |  | Magnet Power Supply Installation: Connect DC Cabling to Power Supply, Dump Resistor, Magnet |  | 5d | 2020-08-11 A | 2021-02-17 A | S302800, S303400, S303900 | 100% |  | 2021-03-11 | 2021-03-17 |  |  |  |  | PROF4 AD [8 h]; TECH3 AD [80 h] | 10,617.13 | S304100 | 0 | S267800 | S267800 | S304100 | CA | Not Started | C | Yip, Kin | L4 | BNL | Installation | Kin Yip | BNL | null | POM02.2.02.04.02.01 | C | 2.02 | 16719 | 2.02 | 01 | Yes |  |  |  |  |  |  |  |  |
| S303900 |  | Magnet Power Supply Installation: Move Power Supply to location |  | 1d | 2020-08-18 A | 2020-08-27 A | S306800, S303800 | 100% |  | 2020-10-01 | 2020-10-01 |  |  |  |  | CRAFT3 [16 h] | 2,061.18 | S303900 | 0 | S267600 | S267600 | S303900 | CA | Not Started | C | Yip, Kin | L4 | BNL | Installation | Kin Yip | BNL | null | POM02.2.02.04.02.01 | C | 2.02 | 16719 | 2.02 | 01 | Yes |  |  |  |  |  |  |  |  |
| S304110 |  | Completed - Magnet Power Supply Installation: Connect DC Cabling to Power Supply, Dump Resistor, Magnet | milestone | 0d | 2021-03-01 A | 2021-03-01 A | S304100 FF | 100% |  | 2021-05-18 | 2021-05-18 |  |  |  |  |  |  | S304100 | 0 | S267800 | S267800 |  | NOCA | Not Started | C | Yip, Kin |  | BNL | Installation | Kin Yip | BNL |  | POM02.2.02.04.02.01 |  |  | 16719 |  | 01 | Yes | L5 |  |  |  |  |  |  |  |
| S304000 |  | Magnet Power Supply Installation: Connect AC Power to Power Supply |  | 3d | 2021-03-22 A | 2021-03-31 A | S303400, S303900 | 100% |  | 2021-06-22 | 2021-06-24 |  |  |  |  | CRAFT3 [32 h]; PROF4 AD [5 h] | 4,880.76 | S304000 | 0 | S267700 | S267700 | S304000 | CA | Not Started | C | Yip, Kin | L4 | BNL | Installation | Kin Yip | BNL | null | POM02.2.02.04.02.01 | C | 2.02 | 16719 | 2.02 | 01 | Yes |  |  |  |  |  |  |  |  |
| S304510 |  | Completed - Magnet Power Supply Installation: Water Cooled Bus Termination 1008B L | milestone | 0d | 2021-05-17 A | 2021-05-17 A | S304500 FF | 100% |  | 2021-06-25 | 2021-06-25 |  |  |  |  |  |  | S304500 | 0 |  | S267982 |  | NOCA | Not Started | C | Yip, Kin |  |  | Installation | Kin Yip |  |  | POM02.2.02.04.02.01 |  |  |  |  | 01 | Yes | L5 |  |  |  |  |  |  |  |
| S304200 |  | Magnet Power Supply Installation: Connect Signal Interconnections 1008B |  | 4d | 2021-05-24 A | 2021-06-14 | S303400, S303900 | 10% | 10d | 2021-07-01 | 2021-07-07 | 229d | 0d | start on or after 2021-07-01 | 2021-06-14 | PROF4 AD [7 h]; TECH3 AD [32 h] | 4,823.25 | S304200 | 0 | S267900 | S267900 | S304200 | CA | Not Started | C | Yip, Kin | L4 | BNL | Installation | Kin Yip | BNL | null | POM02.2.02.04.02.01 | C | 2.02 | 16719 | 2.02 | 01 | Yes |  |  |  |  |  |  |  |  |
| S304700 |  | Magnet Power Supply Installation: Water Cooled Bus Termination 1008IR L |  | 5d | 2022-03-29 | 2022-04-04 | S370000, S101012, S303500, S303610, S303310, S349410, S370100, S1003919 |  |  |  |  | 29d | 0d |  |  | TECH3 AD [70 h] | 8,475.05 | S304700 | 0 |  | S267984 | S304700 | CA | Not Started | C | Yip, Kin | L4 |  | Installation | Kin Yip |  |  | POM02.2.02.04.02.01 | C | 2.02 | 16719 | 2.02 | 01 | Yes |  |  |  |  |  |  |  |  |
| S304800 |  | Magnet Power Supply Installation: Water Cooled Bus Termination 1008IR M&S |  | 5d | 2022-03-29 | 2022-04-04 | S370000, S101012, S303610, S349410, S370100, S1003919 |  |  |  |  | 29d | 0d |  |  | Material (Purchase (1st $2M) [3137 h] | 3,499.68 | S304800 | 0 |  | S267985 | S304800 | CA | Not Started | C | Yip, Kin | M3 |  | Installation | Kin Yip |  |  | POM02.2.02.04.02.01 | C | 2.02 | 16719 | 2.02 | 01 |  |  |  |  |  | UDF_G3 | UDF_G1 | 3499.679612 | 1 |
| S304710 |  | Completed - Magnet Power Supply Installation: Water Cooled Bus Termination 1008IR L | milestone | 0d | 2022-04-04 | 2022-04-04 | S304700 FF |  |  |  |  | 29d | 0d |  |  |  |  | S304700 | 0 |  | S267984 |  | NOCA | Not Started | C | Yip, Kin |  |  | Installation | Kin Yip |  |  | POM02.2.02.04.02.01 |  |  |  |  | 01 | Yes | L5 |  |  |  |  |  |  |  |
| S305000 |  | Magnet Power Supply Installation: Power Supply Testing |  | 10d | 2022-04-05 | 2022-04-18 | S304000, S304200, S304800, S304400, S304600, S304110, S304710, S304510, S304310, S304901 |  |  |  |  | 29d | 0d |  |  | PROF4 AD [80 h]; TECH3 AD [80 h] | 22,184.45 | S305000 | 0 | S268000 | S268000 | S305000 | CA | Not Started | C | Yip, Kin | L4 | BNL | Test_Components | Kin Yip | BNL | null | POM02.2.02.04.02.01 | C | 2.02 | 16719 | 2.02 | 01 | Yes |  |  |  |  |  |  |  |  |
| S305010 |  | Completed - Magnet Power Supply Installation: Power Supply Testing | milestone | 0d | 2022-04-18 | 2022-04-18 | S305000 FF, S304310 |  |  |  |  | 29d |  |  |  |  |  | S305000 | 0 | S268000 | S268000 |  | NOCA | Not Started | C | Yip, Kin |  | BNL | Test_Components | Kin Yip | BNL |  | POM02.2.02.04.02.01 |  |  |  |  | 01 | Yes | L5 |  |  |  |  |  |  |  |

Notes:
- S303200: BNL_UDF_Old Activity Name 181221: Magnet: Install Cable Tray and Supports for Power and Signal Distribution in 1008B to 1008IR
- S303100: BNL_UDF_Old Activity Name 181221: Magnet: Install Cable Tray and Supports for Power and Signal Distribution 1008B
- S303400: BNL_UDF_Old Activity Name 181221: Magnet: Pull & Terminate AC/DC Power Cables and Signal Cables 1008B
- S303300: BNL_UDF_Old Activity Name 181221: Magnet: Install Cable Tray and Supports for Power and Signal Distribution 1008IR
- S303500: BNL_UDF_Old Activity Name 181221: Magnet: Pull & Terminate AC/DC Power Cables and Signal Cables 1008B to 1008IR
- S303310: BNL_UDF_Old Activity Name 181221: Magnet: Install Cable Tray and Supports for Power and Signal Distribution 1008IR
- S303600: BNL_UDF_Old Activity Name 181221: Magnet: Pull & Terminate AC/DC Power Cables and Signal Cables 1008IR
- S303610: BNL_UDF_Old Activity Name 181221: Magnet: Pull & Terminate AC/DC Power Cables and Signal Cables 1008IR
- S303700: BNL_UDF_Old Activity Name 181221: Magnet Power Supply Installation: Design Signal Interconnects
- S304300: BNL_UDF_Old Activity Name 181221: Magnet Power Supply Installation: Cooling Water Design
- S305100: BNL_UDF_Old Activity Name 181221: Magnet Power Supply Installation: Documentation
- S303800: BNL_UDF_Old Activity Name 181221: Magnet Power Supply Installation: Disconnect Power Supply from Test System in 912
- S304900: BNL_UDF_Old Activity Name 181221: Magnet Power Supply Installation:Design and Test Control Interface update software
- S305110: BNL_UDF_Old Activity Name 181221: Magnet Power Supply Installation: Documentation
- S304310: BNL_UDF_Old Activity Name 181221: Magnet Power Supply Installation: Cooling Water Design
- S304901: BNL_UDF_Old Activity Name 181221: Magnet Power Supply Installation:Design and Test Control Interface update software
- S304400: BNL_UDF_Old Activity Name 181221: Magnet Power Supply Installation: Cooling Water Installation 1008B
- S304500: BNL_UDF_Old Activity Name 181221: Magnet Power Supply Installation: Water Cooled Bus Termination 1008B L
- S304600: BNL_UDF_Old Activity Name 181221: Magnet Power Supply Installation: Water Cooled Bus Termination 1008B M&S
- S304100: BNL_UDF_Old Activity Name 181221: Magnet Power Supply Installation: Connect DC Cabling to Power Supply, Dump Resistor, Magnet
- S303900: BNL_UDF_Old Activity Name 181221: Magnet Power Supply Installation: Move Power Supply to location
- S304110: BNL_UDF_Old Activity Name 181221: Magnet Power Supply Installation: Connect DC Cabling to Power Supply, Dump Resistor, Magnet
- S304000: BNL_UDF_Old Activity Name 181221: Magnet Power Supply Installation: Connect AC Power to Power Supply
- S304510: BNL_UDF_Old Activity Name 181221: Magnet Power Supply Installation: Water Cooled Bus Termination 1008B L
- S304200: BNL_UDF_Old Activity Name 181221: Magnet Power Supply Installation: Connect Signal Interconnections 1008B
- S304700: BNL_UDF_Old Activity Name 181221: Magnet Power Supply Installation: Water Cooled Bus Termination 1008IR L
- S304800: BNL_UDF_Old Activity Name 181221: Magnet Power Supply Installation: Water Cooled Bus Termination 1008IR M&S
- S304710: BNL_UDF_Old Activity Name 181221: Magnet Power Supply Installation: Water Cooled Bus Termination 1008IR L
- S305000: BNL_UDF_Old Activity Name 181221: Magnet Power Supply Installation: Power Supply Testing
- S305010: BNL_UDF_Old Activity Name 181221: Magnet Power Supply Installation: Power Supply Testing

| ID | WBS | Activity | Type | Duration | Start | Finish | Predecessors | Complete | Remaining | Planned start | Planned finish | Total float | Free float | Constraint | Expected finish | Resources | Cost | BNL_UDF_Temp Text 01 | BNL_UDF_Percent Complete | BNL_UDF_OPC TEC (deprecated) | BNL_UDF_Old Activity ID 181221 | RG Check | BNL_Activity Status | BNL_Fund Source | BNL_Estimator | BNL_Location | BNL_EDIA | BNL_CAM | BNL_Institution | BNL_WBS | BNL_WBS_Hierarchical | BNL_Cost Basis | BNL_EVT | BNL_Master Control Account | BNL_Account Number | Temp | Major SC Activity | BNL_Cobra WP | Indicator - Procurement | Indicator - Float | BNL_UDF_Remaining Tot Cost | BNL_UDF_Percent_remaining | BNL_Cobra Control Account | BNL_UDF_Temp Date 01 | Completed | BNL_OPC TEC (deprecated) | BNL_UDF_Exclude | BNL_UDF_Status Comments | BNL_Actuals | BNL_FY | BNL_PCR ID | Additional EVT documentation required | BNL_UDF_Temp Text 02 | BNL_Milestone Level | Variance |
| --- | --- | --- | --- | --- | --- | --- | --- | --- | --- | --- | --- | --- | --- | --- | --- | --- | --- | --- | --- | --- | --- | --- | --- | --- | --- | --- | --- | --- | --- | --- | --- | --- | --- | --- | --- | --- | --- | --- | --- | --- | --- | --- | --- | --- | --- | --- | --- | --- | --- | --- | --- | --- | --- | --- | --- |
|  | 03 | **Quench Detector** |  |  | 2019-01-09 | 2022-04-19 |  |  |  |  |  |  |  |  |  |  |  |  |  |  |  |  |  |  |  |  |  |  |  |  |  |  |  |  |  |  |  |  |  |  |  |  |  |  |  |  |  |  |  |  |  |  |  |  |  |
|  | 01 | **Design Quench Detector System Connections** |  |  |  |  |  |  |  |  |  |  |  |  |  |  |  |  |  |  |  |  |  |  |  |  |  |  |  |  |  |  |  |  |  |  |  |  |  |  |  |  |  |  |  |  |  |  |  |  |  |  |  |  |  |
|  | 02 | **Procure Quench Detector System Connections** |  |  | 2019-01-09 | 2022-04-19 |  |  |  |  |  |  |  |  |  |  |  |  |  |  |  |  |  |  |  |  |  |  |  |  |  |  |  |  |  |  |  |  |  |  |  |  |  |  |  |  |  |  |  |  |  |  |  |  |  |
| S306400 |  | Magnet: Order Quench Detector Signal Cables and Interconnects L |  | 5d | 2019-08-01 A | 2021-02-02 A |  | 100% |  | 2019-08-01 | 2019-08-07 |  |  |  |  |  |  | S306400 | 0 | S268200 | S268200 | NOCA | In Progress | C | Yip, Kin | BNL | Procurement | Kin Yip | BNL | POM02.2.02.04.03.02 | 02 |  |  |  |  |  |  |  |  |  |  |  |  |  |  |  |  |  |  |  |  |  |  |  |  |
| S306500 |  | Magnet: Order Quench Detector Signal Cables and Interconnects M&S_10% |  | 42d | 2019-08-01 A | 2019-09-30 A | S306400 SS | 100% |  |  |  |  |  |  |  |  |  | S306500 | 0 |  | S268240 | NOCA | Completed | C | Yip, Kin |  | Procurement | Kin Yip |  | POM02.2.02.04.03.02 | 02 | M3 | C | 2.02 | 16719 | 1 |  |  |  |  |  |  |  |  |  |  |  |  |  |  |  |  |  |  |  |
| S306600 |  | Magnet: Delivery of Quench Detector Signal Cables and Interconnects |  | 20d | 2019-08-08 A | 2021-02-03 A | S306400, S306501 FF | 100% |  | 2019-08-08 | 2019-09-05 |  |  |  |  |  |  | S306600 | 0 | S268300 | S268300 | NOCA | In Progress | C | Yip, Kin | BNL | Procurement | Kin Yip | BNL | POM02.2.02.04.03.02 | 02 |  |  |  |  |  | Yes |  |  |  |  |  |  |  |  |  |  |  |  |  |  |  |  |  |  |
| S306501 |  | Magnet: Order Quench Detector Signal Cables and Interconnects M&S_90% |  | 157d | 2019-11-20 A | 2021-02-02 A | S306500 | 100% |  | 2019-12-02 | 2020-07-15 |  |  |  |  | Material (Purchase (1st $2M) [1800 h] | 2,048.27 | S306500 | 0 |  | S268240 | CA | In Progress | C | Yip, Kin |  | Procurement | Kin Yip |  | POM02.2.02.04.03.02 | 02 | M3 | C | 2.02 | 16719 | 1 |  | S306501 | UDF_G1 | UDF_G3 | 1126.5465321 | 0.55 | 2.02 |  |  |  |  |  |  |  |  |  |  |  |  |
| S306700 |  | Magnet: Install Quench Detector Cabling |  | 5d | 2022-04-06 | 2022-04-12 | S306600 |  |  |  |  | 28d | 0d | start on or after 2022-04-06 |  |  |  | S306700 | 0 | S268400 | S268400 | NOCA | Not Started | C | Yip, Kin | BNL | Installation | Kin Yip | BNL | POM02.2.02.04.03.02 | 02 |  |  |  |  |  | Yes |  |  |  |  |  |  |  |  |  |  |  |  |  |  |  |  |  |  |
|  | 01 | **Install Quench Detector** |  |  | 2019-01-09 | 2022-04-19 |  |  |  |  |  |  |  |  |  |  |  |  |  |  |  |  |  |  |  |  |  |  |  |  |  |  |  |  |  |  |  |  |  |  |  |  |  |  |  |  |  |  |  |  |  |  |  |  |  |
| S307300 |  | Magnet: Quench Detector Documentation |  | 100d | 2019-01-09 A | 2019-05-31 A |  | 100% |  |  |  |  |  |  |  |  |  | S307300 | 20 |  | S268840 | NOCA | Completed | C | Yip, Kin |  | Design | Kin Yip |  | POM02.2.02.04.03.02.01 | 01 | L4 | C |  | 16719 |  |  |  |  |  |  |  |  | 2019-08-08 | yes |  |  |  |  |  |  |  |  |  |  |
| S307310 |  | Magnet: Quench Detector Documentation Split_15% |  | 84d | 2019-06-03 A | 2019-09-30 A | S307300 | 100% |  |  |  |  |  |  |  |  |  | S307300 | 20 |  | S268840 | NOCA | Completed | C | Yip, Kin |  | Design | Kin Yip |  | POM02.2.02.04.03.02.01 | 01 | L4 | C | 2.02 | 16719 | 1 |  |  |  |  |  |  |  | 2019-08-08 |  |  |  |  |  |  |  |  |  |  |  |
| S307311 |  | Magnet: Quench Detector Documentation Split_85% |  | 255d | 2019-10-01 A | 2021-10-29 | S307310 | 85% | 106d | 2019-11-01 | 2020-11-06 | 138d | 0d |  | 2021-10-29 | TECH3 AD [54.4 h]; PROF5 AD [27.2 h] | 10,867.1 | S307300 | 20 |  | S268840 | CA | In Progress | C | Yip, Kin |  | Design | Kin Yip |  | POM02.2.02.04.03.02.01 | 01 | L4 | C | 2.02 | 16719 | 1 |  | S307311 |  |  |  |  | 2.02 | 2019-08-08 |  |  |  |  |  |  |  |  |  |  |  |
| S306800 |  | Magnet: Disconnect Quench Detector from Test System in 912 |  | 1d | 2020-05-13 A | 2020-05-28 A | S306600 | 100% |  | 2020-08-13 | 2020-08-13 |  |  |  |  | TECH3 AD [8 h] | 912.98 | S306800 | 0 |  | S268450 | CA | Not Started | C | Yip, Kin |  | Installation | Kin Yip |  | POM02.2.02.04.03.02.01 | 01 | L4 | C | 2.02 | 16719 |  | Yes | S306800 |  |  |  |  | 2.02 |  |  |  |  |  |  |  |  |  |  |  |  |
| S306900 |  | Magnet: Move Quench Detector to location |  | 1d | 2020-05-14 A | 2020-10-30 A | S101000, S306800, S101012 | 100% |  | 2020-08-14 | 2020-08-14 |  |  |  |  | CRAFT3 [16 h] | 2,001.14 | S306900 | 0 | S268500 | S268500 | CA | Not Started | C | Yip, Kin | BNL | Installation | Kin Yip | BNL | POM02.2.02.04.03.02.01 | 01 | L4 | C | 2.02 | 16719 |  | Yes | S306900 |  |  |  |  | 2.02 |  |  | null |  |  |  |  |  |  |  |  |  |
| S307000 |  | Magnet: Connect AC Power to Quench Detector |  | 3d | 2021-01-12 A | 2021-02-05 A | S306900 | 100% |  | 2021-02-03 | 2021-02-05 |  |  |  |  | CRAFT3 [24 h] | 3,091.76 | S307000 | 0 | S268600 | S268600 | CA | Not Started | C | Yip, Kin | BNL | Installation | Kin Yip | BNL | POM02.2.02.04.03.02.01 | 01 | L4 | C | 2.02 | 16719 |  | Yes | S307000 |  |  |  |  | 2.02 |  |  | null |  |  |  |  |  |  |  |  |  |
| S307100 |  | Magnet: Connect Signal Interconnections |  | 10d | 2021-03-08 A | 2021-08-31 | S306900 | 25% | 65d | 2021-04-01 | 2021-04-14 | 179d | 0d |  | 2021-08-31 | TECH3 AD [80 h] | 9,403.66 | S307100 | 0 | S268700 | S268700 | CA | Not Started | C | Yip, Kin | BNL | Installation | Kin Yip | BNL | POM02.2.02.04.03.02.01 | 01 | L4 | C | 2.02 | 16719 |  | Yes | S307100 |  |  |  |  | 2.02 |  |  | null |  |  |  |  |  |  |  |  |  |
| S307200 |  | Magnet: Quench Detector Testing |  | 5d | 2022-04-13 | 2022-04-19 | S306700, S307000, S307100, S307311 |  |  |  |  | 28d |  |  |  | TECH3 AD [80 h]; PROF5 AD [80 h] | 24,119.37 | S307200 | 0 | S268800 | S268800 | CA | Not Started | C | Yip, Kin | BNL | Test_Components | Kin Yip | BNL | POM02.2.02.04.03.02.01 | 01 | L4 | C | 2.02 | 16719 |  | Yes | S307200 |  |  |  |  | 2.02 |  |  | null |  |  |  |  |  |  |  |  |  |
|  | 05 | **Magnet Field Measurements** |  |  | 2017-10-02 | 2022-08-04 |  |  |  |  |  |  |  |  |  |  |  |  |  |  |  |  |  |  |  |  |  |  |  |  |  |  |  |  |  |  |  |  |  |  |  |  |  |  |  |  |  |  |  |  |  |  |  |  |  |
| S1000239 |  | Actuals - Labor - sPHENIX Magnet FY18 16720 |  | 249d | 2017-10-02 A | 2018-09-28 A | S278400, S1000039, S1000079, S1000119 | 100% |  |  |  |  |  |  |  | Actual Labor [5.54 h] | 925.36 | S278500 | 100 |  | S339340 | CA | Completed | C | Yip, Kin |  | Design | Kin Yip |  | POM02.2.02.05 | 05 | L1 | A | 2.02 | 16720 |  |  | S1000239 |  |  |  |  | 2.02 |  | yes | null | MP6LAEXCLUDE | 190315 DurType to align with EVT | Yes | 2018 | 003 |  |  |  |  |
| S1001439 |  | Actuals - Labor - sPHENIX Magnet FY19 M8 16720 |  | 166d | 2018-10-01 A | 2019-05-31 A |  | 100% |  |  |  |  |  |  |  | Actual Labor [38.48 h] | 6,429.73 | S278500 | 100 |  | S339340 | CA | Completed | C | Yip, Kin |  | Design | Kin Yip |  | POM02.2.02.05 | 05 | L1 | A | 2.02 | 16720 |  |  | S1001439 |  |  |  |  | 2.02 |  | yes | null | MP6LAEXCLUDE | 190315 DurType to align with EVT | Yes | 2019 | 003 |  |  |  |  |
| S1001479 |  | Actuals - NonLabor - sPHENIX Magnet FY19 M8 16720 |  | 166d | 2018-10-01 A | 2019-05-30 A |  | 100% |  | 2018-10-01 | 2019-05-31 |  |  |  |  | Actual Nonlabor [1217.43 h] | 1,343.15 | S278500 | 100 |  | S339340 | CA | Completed | C | Yip, Kin |  | Design | Kin Yip |  | POM02.2.02.05 | 05 | L1 | A | 2.02 | 16720 |  |  | S1001479 | UDF_G3 |  |  |  | 2.02 |  | yes | null | MP6LAEXCLUDE | 190315 DurType to align with EVT | Yes | 2019 | 003 |  |  |  |  |
| S1004600 |  | Actuals - Labor FY19 Jun-Sep 16720 |  | 84d | 2019-06-03 A | 2019-09-30 A |  | 100% |  |  |  |  |  |  |  | Actual Labor [12.84 h] | 2,145.31 | S278500 | 100 |  | S339340 | CA | Completed | C | Yip, Kin |  | Design | Kin Yip |  | POM02.2.02.05 | 05 | L1 | A | 2.02 | 16720 |  |  | S1004600 |  |  |  |  | 2.02 |  | yes | null | MP6LAEXCLUDE | 190315 DurType to align with EVT | Yes | 2018 | 003 |  |  |  |  |
|  | 01 | **Magnet Field Measurements Engineering and Design, Field Studies and Stress Analysis** |  |  | 2018-02-13 | 2020-09-30 |  |  |  |  |  |  |  |  |  |  |  |  |  |  |  |  |  |  |  |  |  |  |  |  |  |  |  |  |  |  |  |  |  |  |  |  |  |  |  |  |  |  |  |  |  |  |  |  |  |
| S307400 |  | Magnet Field Measurements: Setup a detailed 3D model of the coil, return yoke and internal calorimeters FY18 |  | 160d | 2018-02-13 A | 2018-09-28 A | S100340 SS | 100% |  |  |  |  |  |  |  |  |  | S307400 | 100 | S268900 | S268900 | NOCA | Completed | C | Yip, Kin | BNL | Design | Kin Yip | BNL | POM02.2.02.05.01 | 01 | L3 | C |  |  |  |  |  |  |  |  |  |  | 2019-06-01 | yes | null |  |  |  |  |  |  |  |  |  |
| S307800 |  | Magnet Field Measurements: Perform Magnet Assembly Stress Analysis FY18 |  | 140d | 2018-03-14 A | 2018-09-28 A | S100340 SS | 100% |  |  |  |  |  |  |  |  |  | S307800 | 100 | S269200 | S269200 | NOCA | Completed | C | Yip, Kin | BNL | Test_Components | Kin Yip | BNL | POM02.2.02.05.01 | 01 | L3 | C |  |  |  |  |  |  |  |  |  |  | 2019-06-01 | yes | null |  |  |  |  |  |  |  |  |  |
| S307500 |  | Magnet Field Measurements: Setup a detailed 3D model of the coil, return yoke and internal calorimeters FY19 |  | 105d | 2019-01-02 A | 2019-05-31 A | S307400 | 100% |  |  |  |  |  |  |  |  |  | S307500 | 50 | S268900 | S268950 | NOCA | Completed | C | Yip, Kin | BNL | Design | Kin Yip | BNL | POM02.2.02.05.01 | 01 | L3 | C |  | 16720 |  |  |  |  |  |  |  |  | 2019-05-31 | yes | null |  |  |  |  |  | Yes |  |  |  |
| S307900 |  | Magnet Field Measurements: Perform Magnet Assembly Stress Analysis FY19 - Physics Resource(s) |  | 105d | 2019-01-02 A | 2019-05-31 A | S307800, S307511 SS | 100% |  |  |  |  |  |  |  |  |  | PO&AD | 50 | S269200 | S269250 | NOCA | Completed | C | Yip, Kin | BNL | Test_Components | Kin Yip | BNL | POM02.2.02.05.01 | 01 | L3 | C |  | 16720 | PO |  |  |  |  |  |  |  | 2019-05-31 | yes | null |  |  |  |  |  | Yes |  |  |  |
| S307910 |  | Magnet Field Measurements: Perform Magnet Assembly Stress Analysis FY19 - CA-D Resource(s) |  | 105d | 2019-01-02 A | 2019-05-31 A |  | 100% |  |  |  |  |  |  |  |  |  | PO&ADS307910 | 20 | S269200 | S269250 | NOCA | Completed | C | Yip, Kin | BNL | Test_Components | Kin Yip | BNL | POM02.2.02.05.01 | 01 | L3 | C |  | 16720 | C-AD |  |  |  |  |  |  |  | 2019-05-31 | yes | null |  |  |  |  |  | Yes | S307910 |  |  |
| S307510 |  | Magnet Field Measurements: Setup a detailed 3D model of the coil, return yoke and internal calorimeters FY19 Split_40% |  | 64d | 2019-07-01 A | 2019-09-30 A | S307500 | 100% |  |  |  |  |  |  |  |  |  | S307500 | 50 | S268900 | S268950 | NOCA | Completed | C | Yip, Kin | BNL | Design | Kin Yip | BNL | POM02.2.02.05.01 | 01 | L3 | C | 2.02 | 16720 | 1 |  |  |  |  |  |  |  | 2019-05-31 |  | null |  |  |  |  |  | Yes |  |  |  |
| S307920 |  | Magnet Field Measurements: Perform Magnet Assembly Stress Analysis FY19 - CA-D Resource(s) Split_30% |  | 64d | 2019-07-01 A | 2019-09-30 A | S307910 | 100% |  |  |  |  |  |  |  |  |  | PO&ADS307910 | 20 | S269200 | S269250 | NOCA | Completed | C | Yip, Kin | BNL | Test_Components | Kin Yip | BNL | POM02.2.02.05.01 | 01 | L3 | C | 2.02 | 16720 | C-AD |  |  |  |  |  |  |  | 2019-05-31 |  | null |  |  |  |  |  | Yes | S307910 |  |  |
| S307905 |  | Magnet Field Measurements: Perform Magnet Assembly Stress Analysis FY19 - Physics Resource(s) Split |  | 22d | 2019-08-01 A | 2019-08-30 A | S307900 | 100% |  |  |  |  |  |  |  |  |  | PO&AD | 50 | S269200 | S269250 | NOCA | Completed | C | Yip, Kin | BNL | Test_Components | Kin Yip | BNL | POM02.2.02.05.01 | 01 | L3 | C | 2.02 | 16720 | PO |  |  |  |  |  |  |  | 2019-05-31 |  | null |  |  |  |  |  | Yes |  |  |  |
| S307511 |  | Magnet Field Measurements: Setup a detailed 3D model of the coil, return yoke and internal calorimeters FY19 Split_60% |  | 39d | 2019-10-01 A | 2019-12-31 A | S307510 | 100% |  | 2019-11-01 | 2019-12-31 |  |  |  |  | SCI3 PO [19.2 h]; TECH3 PO D [6 h] | 3,989.16 | S307500 | 50 | S268900 | S268950 | CA | In Progress | C | Yip, Kin | BNL | Design | Kin Yip | BNL | POM02.2.02.05.01 | 01 | L3 | C | 2.02 | 16720 | 1 |  | S307511 |  |  |  |  | 2.02 | 2019-05-31 |  | null |  |  |  |  |  | Yes |  |  |  |
| S307921 |  | Magnet Field Measurements: Perform Magnet Assembly Stress Analysis FY19 - CA-D Resource(s) Split_70% |  | 39d | 2019-10-01 A | 2019-12-31 A | S307920 | 100% |  | 2019-11-01 | 2019-12-31 |  |  |  |  | PROF4 AD [47.6 h] | 7,009.81 | PO&ADS307910 | 20 | S269200 | S269250 | CA | In Progress | C | Yip, Kin | BNL | Test_Components | Kin Yip | BNL | POM02.2.02.05.01 | 01 | L3 | C | 2.02 | 16720 | C-AD |  | S307921 |  |  |  |  | 2.02 | 2019-05-31 |  | null |  |  |  |  |  | Yes | S307910 |  |  |
| S307600 |  | Magnet Field Measurements: Design mounts for probes to monitor field - Physics Resource(s) |  | 10d | 2020-02-03 A | 2020-02-14 A | S101010 | 100% |  |  |  |  |  |  |  | TECH3 PO D [40 h] | 4,564.89 | PO&AD | 0 | S269000 | S269000 | CA | Not Started | C | Yip, Kin | BNL | Design | Kin Yip | BNL | POM02.2.02.05.01 | 01 | L3 | C | 2.02 | 16720 | PO |  | S307600 |  |  |  |  | 2.02 |  |  | null |  |  |  |  |  |  |  |  |  |
| S307610 |  | Magnet Field Measurements: Design mounts for probes to monitor field - CA-D Resource(s) |  | 10d | 2020-02-03 A | 2020-02-14 A | S307600 SS | 100% |  |  |  |  |  |  |  | PROF4 AD [8 h] | 1,178.12 | PO&ADS307610 | 0 | S269000 | S269000 | CA | Not Started | C | Yip, Kin | BNL | Design | Kin Yip | BNL | POM02.2.02.05.01 | 01 | L3 | C | 2.02 | 16720 | C-AD |  | S307610 |  |  |  |  | 2.02 |  |  | null |  |  |  |  |  |  | S307610 |  |  |
| S308000 |  | Magnet Field Measurements: Magnet Engineering and Design Complete | milestone | 0d | 2020-02-03 A | 2020-02-03 A | S307700, S307710, S307905, S307921 | 100% |  |  |  |  |  |  |  |  |  | S308000 | 0 | S269300 | S269300 | NOCA | Not Started | C | Yip, Kin | BNL | Design | Kin Yip | BNL | POM02.2.02.05.01 | 01 |  |  |  |  |  | Yes |  |  |  |  |  |  |  |  |  |  |  |  |  |  |  |  | L3 |  |
| S307700 |  | Magnet Field Measurements: Design readout for probes to monitor field - Physics Resource(s) |  | 5d | 2020-02-18 A | 2020-02-24 A | S307600, S307610 | 100% |  |  |  |  |  |  |  | TECH3 PO D [40 h] | 4,564.89 | PO&AD | 0 | S269100 | S269100 | CA | Not Started | C | Yip, Kin | BNL | Design | Kin Yip | BNL | POM02.2.02.05.01 | 01 | L3 | C | 2.02 | 16720 | PO |  | S307700 |  |  |  |  | 2.02 |  |  | null |  |  |  |  |  |  |  |  |  |
| S307710 |  | Magnet Field Measurements: Design readout for probes to monitor field - CA-D Resource(s) |  | 5d | 2020-02-18 A | 2020-02-24 A | S307700 SS | 100% |  |  |  |  |  |  |  | PROF4 AD [4 h] | 589.06 | PO&ADS307710 | 0 | S269100 | S269100 | CA | Not Started | C | Yip, Kin | BNL | Design | Kin Yip | BNL | POM02.2.02.05.01 | 01 | L3 | C | 2.02 | 16720 | C-AD |  | S307710 |  |  |  |  | 2.02 |  |  | null |  |  |  |  |  |  | S307710 |  |  |
| S307922 |  | Final Field Calculations Pre-measurement - Phys |  | 200d | 2020-09-21 A | 2020-09-30 A |  | 100% |  | 2020-10-01 | 2021-07-21 |  |  | start on or after 2020-09-01 |  | SCI 4 PO [20 h] | 4,241.69 | PO&ADS307910 | 20 | S269200 | S269250 | CA | In Progress | C | Yip, Kin | BNL | Test_Components | Kin Yip | BNL | POM02.2.02.05.01 | 01 | L3 | C | 2.02 | 16720 | 1 |  | S307922 |  |  |  |  | 2.02 | 2019-05-31 |  | null |  |  |  |  | 012 |  | S307910 |  | 0 |
| S307923 |  | Final Field Calculations Pre-measurement - CAD |  | 200d | 2020-09-21 A | 2020-09-30 A |  | 100% |  | 2020-10-01 | 2021-07-21 |  |  | start on or after 2020-09-01 |  | PROF4 AD [60 h] | 9,100.98 | PO&ADS307910 | 20 | S269200 | S269250 | CA | In Progress | C | Yip, Kin | BNL | Test_Components | Kin Yip | BNL | POM02.2.02.05.01 | 01 | L3 | C | 2.02 | 16720 | 1 |  | S307923 |  |  |  |  | 2.02 | 2019-05-31 |  | null |  |  |  |  | 012 |  | S307910 |  | 0 |

Notes:
- 03: 180215 ELM WBS name per GRY
- S306400: BNL_UDF_Old Activity Name 181221: Magnet: Order Quench Detector Signal Cables and Interconnects L Actual
- S306500: BNL_UDF_Old Activity Name 181221: Magnet: Order Quench Detector Signal Cables and Interconnects M&S
- S306600: BNL_UDF_Old Activity Name 181221: Magnet: Delivery of Quench Detector Signal Cables and Interconnects
- S306501: BNL_UDF_Old Activity Name 181221: Magnet: Order Quench Detector Signal Cables and Interconnects M&S
- S306700: BNL_UDF_Old Activity Name 181221: Magnet: Install Quench Detector Cabling
- S307300: BNL_UDF_Old Activity Name 181221: Magnet: Quench Detector Documentation
- S307310: BNL_UDF_Old Activity Name 181221: Magnet: Quench Detector Documentation
- S307311: BNL_UDF_Old Activity Name 181221: Magnet: Quench Detector Documentation
- S306800: BNL_UDF_Old Activity Name 181221: Magnet: Disconnect Quench Detector from Test System in 912
- S306900: BNL_UDF_Old Activity Name 181221: Magnet: Move Quench Detector to location
- S307000: BNL_UDF_Old Activity Name 181221: Magnet: Connect AC Power to Quench Detector
- S307100: BNL_UDF_Old Activity Name 181221: Magnet: Connect Signal Interconnections
- S307200: BNL_UDF_Old Activity Name 181221: Magnet: Quench Detector Testing
- S1000239: BNL_UDF_Old Activity Name 181221: Actuals - Labor - sPHENIX Magnet FY18
- S1001439: BNL_UDF_Old Activity Name 181221: Actuals - Labor - sPHENIX Magnet FY18
- S1001479: BNL_UDF_Old Activity Name 181221: Actuals - Labor - sPHENIX Magnet FY18
- S1004600: BNL_UDF_Old Activity Name 181221: Actuals - Labor - sPHENIX Magnet FY18
- S307400: BNL_UDF_Old Activity Name 181221: Magnet Field Measurements: Setup a detailed 3D model of the coil, return yoke and internal calorimeters FY18
- S307800: BNL_UDF_Old Activity Name 181221: Magnet Field Measurements: Perform Magnet Assembly Stress Analysis FY18
- S307500: BNL_UDF_Old Activity Name 181221: Magnet Field Measurements: Setup a detailed 3D model of the coil, return yoke and internal calorimeters FY19
- S307900: BNL_UDF_Old Activity Name 181221: Magnet Field Measurements: Perform Magnet Assembly Stress Analysis FY19
- S307910: BNL_UDF_Old Activity Name 181221: Magnet Field Measurements: Perform Magnet Assembly Stress Analysis FY19
- S307510: BNL_UDF_Old Activity Name 181221: Magnet Field Measurements: Setup a detailed 3D model of the coil, return yoke and internal calorimeters FY19
- S307920: BNL_UDF_Old Activity Name 181221: Magnet Field Measurements: Perform Magnet Assembly Stress Analysis FY19
- S307905: BNL_UDF_Old Activity Name 181221: Magnet Field Measurements: Perform Magnet Assembly Stress Analysis FY19
- S307511: BNL_UDF_Old Activity Name 181221: Magnet Field Measurements: Setup a detailed 3D model of the coil, return yoke and internal calorimeters FY19
- S307921: BNL_UDF_Old Activity Name 181221: Magnet Field Measurements: Perform Magnet Assembly Stress Analysis FY19
- S307600: BNL_UDF_Adhoc Comments: 180219 ELM resource change from PROF3 AD to PROF4 AD per EOB / BNL_UDF_Old Activity Name 181221: Magnet Field Measurements: Design mounts for NMR probes to monitor field
- S307610: BNL_UDF_Adhoc Comments: 180219 ELM resource change from PROF3 AD to PROF4 AD per EOB / BNL_UDF_Old Activity Name 181221: Magnet Field Measurements: Design mounts for NMR probes to monitor field
- S308000: BNL_UDF_Old Activity Name 181221: Magnet Field Measurements: Magnet Engineering and Design Complete
- S307700: BNL_UDF_Adhoc Comments: 180220 ELM staff & workgroup change per EOB; 180219 ELM resource change from PROF3 AD to PROF4 AD per EOB / BNL_UDF_Old Activity Name 181221: Magnet Field Measurements: Design readout for NMR probes to monitor field
- S307710: BNL_UDF_Adhoc Comments: 180220 ELM staff & workgroup change per EOB; 180219 ELM resource change from PROF3 AD to PROF4 AD per EOB / BNL_UDF_Old Activity Name 181221: Magnet Field Measurements: Design readout for NMR probes to monitor field
- S307922: BNL_UDF_Old Activity Name 181221: Magnet Field Measurements: Perform Magnet Assembly Stress Analysis FY19
- S307923: BNL_UDF_Old Activity Name 181221: Magnet Field Measurements: Perform Magnet Assembly Stress Analysis FY19

| ID | WBS | Activity | Type | Duration | Start | Finish | Predecessors | Complete | Remaining | Planned start | Planned finish | Total float | Free float | Constraint | Expected finish | Resources | Cost | BNL_UDF_Temp Text 01 | BNL_UDF_Percent Complete | BNL_UDF_Sort Order | BNL_UDF_OPC TEC (deprecated) | BNL_UDF_Old Activity ID 181221 | BNL_Cobra WP | RG Check | BNL_UDF_PCR_Labor_Delta | BNL_UDF_PCR_Direct$_Delta | BNL_UDF_PCR_TotCost_Delta | BNL_Activity Status | BNL_Fund Source | BNL_Estimator | BNL_Cost Basis | BNL_Location | BNL_EDIA | BNL_CAM | BNL_Institution | BNL_OPC TEC (deprecated) | BNL_WBS | BNL_EVT | BNL_Master Control Account | BNL_Account Number | BNL_PCR ID | BNL_Cobra Control Account | BNL_WBS_Hierarchical | Indicator - Procurement | Indicator - Float | BNL_Milestone Level | BNL_UDF_Temp Text 02 | Variance | BNL_UDF_Remaining Tot Cost | BNL_UDF_Percent_remaining | Major SC Activity | Target Milestone Date | PMP Milestones | BNL_UDF_Status Comments |
| --- | --- | --- | --- | --- | --- | --- | --- | --- | --- | --- | --- | --- | --- | --- | --- | --- | --- | --- | --- | --- | --- | --- | --- | --- | --- | --- | --- | --- | --- | --- | --- | --- | --- | --- | --- | --- | --- | --- | --- | --- | --- | --- | --- | --- | --- | --- | --- | --- | --- | --- | --- | --- | --- | --- |
|  | 02 | **Magnet Field Measurements Equipment Purchase and Fabrication** |  |  | 2020-01-16 | 2022-02-14 |  |  |  |  |  |  |  |  |  |  |  |  |  |  |  |  |  |  |  |  |  |  |  |  |  |  |  |  |  |  |  |  |  |  |  |  |  |  |  |  |  |  |  |  |  |  |  |  |
| S308600 |  | Magnet Field Measurements: Fabricate NMR probe mounts - Physics Resource(s) |  | 20d | 2020-01-16 A | 2020-04-24 A |  | 100% |  | 2020-01-16 | 2020-02-13 |  |  | start on or after 2020-01-16 |  | TECH3 PO D [160 h]; SCI3 PO [16 h] | 21,013.23 | PO&AD | 0 | 1000 | S269900 | S269900 | S308600 | CA | 0 | 0 | 0 | Not Started | C | Yip, Kin | L3 | BNL | Fab & Assy | Kin Yip | BNL | null | POM02.2.02.05.02 | C | 2.02 | 16720 | 012 | 2.02 | 02 |  |  |  |  |  |  |  |  |  |  |  |
| S308100 |  | Magnet Field Measurements: Procure NMR probes Labor |  | 40d | 2020-01-24 A | 2020-03-20 A |  | 100% |  |  |  |  |  | start on or after 2020-01-24 |  | PROF4 PO M [10 h] | 1,472.65 | S308100 | 0 | 1000 | S269400 | S269400 | S308100 | CA | 0 | 0 | 0 | Not Started | C | Yip, Kin | L3 | BNL | Procurement | Kin Yip | BNL | null | POM02.2.02.05.02 | C | 2.02 | 16720 | 012 | 2.02 | 02 |  |  |  |  |  |  |  |  |  |  |  |
| S308200 |  | Magnet Field Measurements: Procure NMR probes M&S |  | 0d | 2020-01-24 A | 2020-04-24 A |  | 100% |  | 2020-01-24 | 2020-01-24 |  |  | start on or after 2020-01-24 |  | Material (Purchase (1st $2M) [6000 h] | 6,827.55 | S308200 | 0 | 1000 | S269500 | S269500 | S308200 | CA | 0 | 0 | 0 | Not Started | C | Yip, Kin | M3 | BNL | Fab & Assy | Kin Yip | BNL | null | POM02.2.02.05.02 | C | 2.02 | 16720 | 012 | 2.02 | 02 | UDF_G2 | UDF_G3 |  |  |  |  |  |  |  |  |  |
| S308300 |  | Magnet Field Measurements: Procure NMR probe readout parts Labor |  | 40d | 2020-01-24 A | 2020-04-24 A |  | 100% |  | 2020-01-24 | 2020-03-20 |  |  | start on or after 2020-01-24 |  | PROF4 PO M [10 h] | 1,472.65 | S308300 | 0 | 1000 | S269600 | S269600 | S308300 | CA | 0 | 0 | 0 | Not Started | C | Yip, Kin | L3 | BNL | Procurement | Kin Yip | BNL | null | POM02.2.02.05.02 | C | 2.02 | 16720 | 012 | 2.02 | 02 |  |  |  |  |  |  |  |  |  |  |  |
| S308400 |  | Magnet Field Measurements: Procure NMR probe readout parts M&S |  | 40d | 2020-01-24 A | 2020-04-24 A |  | 100% |  | 2020-01-24 | 2020-03-20 |  |  | start on or after 2020-01-24 |  | Material (Purchase (1st $2M) [1000 h] | 1,137.93 | S308400 | 0 | 1000 | S269700 | S269700 | S308400 | CA | 0 | 0 | 0 | Not Started | C | Yip, Kin | M3 | BNL | Fab & Assy | Kin Yip | BNL | null | POM02.2.02.05.02 | C | 2.02 | 16720 | 012 | 2.02 | 02 | UDF_G2 | UDF_G3 |  |  |  |  |  |  |  |  |  |
| S308510 |  | Completed - Magnet Field Measurements: Fabricate NMR probe readout parts | milestone | 0d | 2020-04-17 A | 2020-04-17 A |  | 100% |  | 2020-04-01 | 2020-04-01 |  |  |  |  |  |  | S308500 | 0 | 2000 | S269800 | S269800 | S308510 | NOCA |  |  |  | Not Started | C | Yip, Kin |  | BNL | Fab & Assy | Kin Yip | BNL |  | POM02.2.02.05.02 |  |  |  | 012 |  | 02 |  |  | L5 |  |  |  |  |  |  |  |  |
| S308500 |  | Magnet Field Measurements: Fabricate NMR probe readout parts |  | 20d | 2020-05-01 A | 2020-05-29 A |  | 100% |  |  |  |  |  | start on or after 2020-03-23 |  | SCI3 PO [16 h]; TECH3 PO D [160 h]; PROF4 PO M [16 h] | 23,369.47 | S308500 | 0 | 3000 | S269800 | S269800 | S308500 | CA | 0 | 0 | 0 | Not Started | C | Yip, Kin | L3 | BNL | Fab & Assy | Kin Yip | BNL | null | POM02.2.02.05.02 | C | 2.02 | 16720 | 012 | 2.02 | 02 |  |  |  |  |  |  |  |  |  |  |  |
| S308610 |  | Magnet Field Measurements: Fabricate NMR probe mounts - CA-D Resource(s) |  | 20d | 2020-05-01 A | 2020-05-29 A |  | 100% |  |  |  |  |  | start on or after 2020-01-16 |  | PROF4 AD [16 h] | 2,356.24 | PO&ADS308610 | 0 |  | S269900 | S269900 | S308610 | CA | 0 | 0 | 0 | Not Started | C | Yip, Kin | L3 | BNL | Fab & Assy | Kin Yip | BNL | null | POM02.2.02.05.02 | C | 2.02 | 16720 | 012 | 2.02 | 02 |  |  |  | S308610 |  |  |  |  |  |  |  |
| S308611 |  | Specify and test probes for field monitoring |  | 10d | 2020-10-01 A | 2020-12-31 A |  | 100% |  | 2020-10-01 | 2020-10-15 |  |  | start on or after 2020-10-01 |  | SCI 4 PO [16 h]; PROF4 PO E [16 h]; PROF4 PO M [16 h] | 8,247.21 | PO&AD | 0 |  | S269900 | S269900 | S308611 | CA |  |  |  | Not Started | C | Yip, Kin | L3 | BNL | Fab & Assy | Kin Yip | BNL | null | POM02.2.02.05.02 | C | 2.02 | 16720 | 012 | 2.02 | 02 |  |  |  |  | 0 |  |  |  |  |  |  |
| S308615 |  | Develop readout electronics |  | 30d | 2020-10-30 A | 2021-09-01 | S308613 | 85% | 66d | 2020-10-30 | 2020-12-15 | 113d | 0d |  | 2021-09-01 | PROF4 PO E [90 h] | 13,651.47 | PO&AD | 0 |  | S269900 | S269900 | S308615 | CA |  |  |  | Not Started | C | Yip, Kin | L3 | BNL | Fab & Assy | Kin Yip | BNL | null | POM02.2.02.05.02 | C | 2.02 | 16720 | 012 | 2.02 | 02 |  |  |  |  | 0 |  |  |  |  |  |  |
| S308613 |  | Purchase probes for Magnetic Field Measurements |  | 10d | 2020-11-04 A | 2020-12-31 A | S308611 | 100% |  | 2021-01-04 | 2021-01-15 |  |  |  |  | Material (Purchase (1st $2M) [7000 h] | 8,124.79 | PO&AD | 0 |  | S269900 | S269900 | S308613 | CA |  |  |  | Not Started | C | Yip, Kin | L3 | BNL | Fab & Assy | Kin Yip | BNL | null | POM02.2.02.05.02 | C | 2.02 | 16720 | 012 | 2.02 | 02 | UDF_G2 | UDF_G3 |  |  | 0 | 8124.79017 | 1 |  |  |  |  |
| S308617 |  | Calibrate probes |  | 60d | 2021-09-02 | 2021-12-01 | S308615 |  |  |  |  | 113d | 40d |  |  | SCI 4 PO [24 h]; PROF4 PO E [24 h]; TECH3 PO E [24 h] | 11,782.55 | PO&AD | 0 |  | S269900 | S269900 | S308617 | CA |  |  |  | Not Started | C | Yip, Kin | L3 | BNL | Fab & Assy | Kin Yip | BNL | null | POM02.2.02.05.02 | C | 2.02 | 16720 | 012 | 2.02 | 02 |  |  |  |  | 0 |  |  |  |  |  |  |
| S308619 |  | Install probes and readout on TPC |  | 10d | 2022-02-01 | 2022-02-14 | S308617, S121900 |  |  |  |  | 73d | 71d |  |  | TECH3 PO E [40 h] | 4,842.89 | PO&AD | 0 |  | S269900 | S269900 | S308619 | CA |  |  |  | Not Started | C | Yip, Kin | L3 | BNL | Fab & Assy | Kin Yip | BNL | null | POM02.2.02.05.02 | C | 2.02 | 16720 | 012 | 2.02 | 02 |  |  |  |  | 0 |  |  |  |  |  |  |
|  | 03 | **Magnet Field Measurements Installation and Test, Post-Test Field Studies and Stress Analysis** |  |  | 2020-01-24 | 2022-08-04 |  |  |  |  |  |  |  |  |  |  |  |  |  |  |  |  |  |  |  |  |  |  |  |  |  |  |  |  |  |  |  |  |  |  |  |  |  |  |  |  |  |  |  |  |  |  |  |  |
| S308700 |  | Magnet Field Measurements: Run 3D field simulations and construct field and force maps - Physics Resource(s) |  | 10d | 2020-01-24 A | 2020-02-24 A |  | 100% |  | 2020-01-24 | 2020-02-06 |  |  | start on or after 2020-01-24 |  | SCI3 PO [40 h] | 6,884.23 | PO&AD | 0 |  | S270000 | S270000 | S308700 | CA | 0 | 0 | 0 | Not Started | C | Yip, Kin | L3 | BNL | Test_Components | Kin Yip | BNL | null | POM02.2.02.05.03 | C | 2.02 | 16720 | 012 | 2.02 | 03 |  |  |  |  |  |  |  |  |  |  |  |
| S308710 |  | Magnet Field Measurements: Run 3D field simulations and construct field and force maps - CA-D Resource(s) |  | 10d | 2020-01-24 A | 2020-02-24 A | S308700 SS | 100% |  | 2020-01-24 | 2020-02-06 |  |  | start on or after 2020-01-24 |  | SCI3 AD [40 h] | 6,884.23 | PO&ADS308710 | 0 |  | S270000 | S270000 | S308710 | CA | 0 | 0 | 0 | Not Started | C | Yip, Kin | L3 | BNL | Test_Components | Kin Yip | BNL | null | POM02.2.02.05.03 | C | 2.02 | 16720 | 012 | 2.02 | 03 |  |  |  | S308710 |  |  |  |  |  |  |  |
| S308621 |  | Conceptual design of mapping campaign |  | 20d | 2020-10-01 A | 2021-09-29 |  | 60% | 85d | 2020-10-01 | 2020-10-29 | 229d | 0d | start on or after 2020-10-01 | 2021-09-29 | SCI 4 PO [32 h] | 6,786.71 | PO&AD | 0 |  | S269900 | S269900 | S308621 | CA |  |  |  | Not Started | C | Yip, Kin | L3 | BNL | Fab & Assy | Kin Yip | BNL | null | POM02.2.02.05.02 | C | 2.02 | 16720 | 012 | 2.02 | 03 |  |  |  |  | 0 |  |  |  |  |  |  |
| S308623 |  | Develop mapping plan with Vendor |  | 40d | 2020-10-30 A | 2021-11-30 | S308621 | 50% | 40d | 2020-10-30 | 2020-12-30 | 229d | 0d | start on or after 2020-06-01 | 2021-06-30 | SCI 4 PO [100 h] | 21,208.47 | PO&AD | 0 |  | S269900 | S269900 | S308623 | CA |  |  |  | Not Started | C | Yip, Kin | L3 | BNL | Fab & Assy | Kin Yip | BNL | null | POM02.2.02.05.02 | C | 2.02 | 16720 | 012 | 2.02 | 03 |  |  |  |  | 0 |  |  |  |  |  |  |
| S308629 |  | Complete mechanical and electrical design for mapping |  | 20d | 2020-11-23 A | 2021-10-01 | S308627 SS, S308625 SS | 35% | 2d | 2021-09-03 | 2021-10-01 | 314d | 0d | start on or after 2020-06-01 | 2021-10-01 | PROF4 PO M [60 h]; TECH3 PO D [30 h] | 12,646.29 | PO&AD | 0 |  | S269900 | S269900 | S308629 | CA |  |  |  | Not Started | C | Yip, Kin | L3 | BNL | Fab & Assy | Kin Yip | BNL | null | POM02.2.02.05.02 | C | 2.02 | 16720 | 012 | 2.02 | 03 |  |  |  |  | 0 |  |  |  |  |  |  |
| S308625 |  | Complete MOU with Vendor |  | 20d | 2021-02-22 A | 2021-10-05 | S308623 SS | 20% | 4d | 2022-01-03 | 2022-01-31 | 229d | 0d |  | 2021-07-22 | SCI 4 PO [8 h] | 1,747.58 | PO&AD | 0 |  | S269900 | S269900 | S308625 | CA |  |  |  | Not Started | C | Yip, Kin | L3 | BNL | Fab & Assy | Kin Yip | BNL | null | POM02.2.02.05.02 | C | 2.02 | 16720 | 012 | 2.02 | 03 |  |  |  |  | 0 |  |  |  |  |  |  |
| S308633 |  | Construct mapping support (mechanical and electrical) |  | 10d | 2021-03-08 A | 2021-10-21 | S308631 | 5% | 10d | 2021-10-07 | 2021-10-21 | 314d | 0d |  | 2021-10-21 | TECH3 PO M [32 h] | 3,874.31 | PO&AD | 0 |  | S269900 | S269900 | S308633 | CA |  |  |  | Not Started | C | Yip, Kin | L3 | BNL | Fab & Assy | Kin Yip | BNL | null | POM02.2.02.05.02 | C | 2.02 | 16720 | 012 | 2.02 | 03 |  |  |  |  | 0 |  |  |  |  |  |  |
| S308627 |  | Place contract with Vendor (Procurement string, $70K obligated at Contract award, paid when mapped?) |  | 100d | 2021-09-30 | 2022-02-28 | S308625 SS |  |  |  |  | 229d | 0d |  | 2022-02-28 | Material (Purchase (1st $2M) [63000 h] | 74,570.95 | PO&AD | 0 |  | S269900 | S269900 | S308627 | CA |  |  |  | Not Started | C | Yip, Kin | L3 | BNL | Fab & Assy | Kin Yip | BNL | null | POM02.2.02.05.02 | C | 2.02 | 16720 | 012 | 2.02 | 03 | UDF_G1 | UDF_G3 |  |  | 0 | 73123.11153 | 1 |  |  |  |  |
| S308631 |  | Review mapping plan |  | 5d | 2021-09-30 | 2021-10-06 | S308629 SS |  |  |  |  | 314d | 0d |  |  | PROF4 PO M [16 h]; TECH3 PO D [16 h]; SCI 4 PO [10 h] | 6,582.79 | PO&AD | 0 |  | S269900 | S269900 | S308631 | CA |  |  |  | Not Started | C | Yip, Kin | L3 | BNL | Fab & Assy | Kin Yip | BNL | null | POM02.2.02.05.02 | C | 2.02 | 16720 | 012 | 2.02 | 03 |  |  |  |  | 0 |  |  |  |  |  |  |
| S308900 |  | Magnet Field Measurements: Install Field Mapping Equipment |  | 10d | 2022-05-26 | 2022-06-09 | S279100, S308619 |  |  |  |  | 2d |  |  |  | TECH3 PO M [80 h]; TECH3 PO E [160 h]; PROF3 PO E [80 h]; SCI 4 PO [160 h] | 74,745.99 | S308900 | 0 |  | S270100 | S270200 | S308900 | CA |  |  |  | Not Started | C | Yip, Kin | L3 | BNL | Installation | Kin Yip | BNL | null | POM02.2.02.05.03 | C | 2.02 | 16720 |  | 2.02 | 03 |  |  |  |  |  |  |  | Yes |  |  |  |
| S309000 |  | Magnet Field Measurements: Map Magnetic Field of SC Magnet |  | 15d | 2022-06-14 | 2022-07-05 | S279500, S308900 |  |  |  |  | 0d |  |  |  | TECH3 PO M [80 h]; SCI 4 PO [160 h]; PROF3 PO E [80 h]; TECH3 PO E [160 h] | 74,745.99 | S309000 | 0 |  | S270100 | S270220 | S309000 | CA |  |  |  | Not Started | C | Yip, Kin | L3 | BNL | Installation | Kin Yip | BNL | null | POM02.2.02.05.03 | C | 2.02 | 16720 |  | 2.02 | 03 |  |  |  |  |  |  |  | Yes |  |  |  |
| S309005 |  | Magnet Field Measurements: Map Magnetic Field of SC Magnet |  | 15d | 2022-06-14 | 2022-07-05 | S279400 |  |  |  |  | 0d |  |  |  | TECH3 PO M [80 h]; SCI 4 PO [160 h]; PROF3 PO E [80 h]; TECH3 PO E [160 h] | 74,745.99 | S309000 | 0 |  | S270100 | S270220 | S309005 | CA |  |  |  | Not Started | C | Yip, Kin | L3 | BNL | Installation | Kin Yip | BNL | null | POM02.2.02.05.03 | C | 2.02 | 16720 | 008C | 2.02 | 03 |  |  |  |  |  |  |  | Yes |  |  |  |
| S309010 |  | Completed - Magnet Field Measurements: Map Magnetic Field of SC Magnet | milestone | 0d | 2022-07-05 | 2022-07-05 | S309000 FF, S309005 |  |  |  |  | 0d |  |  |  |  |  | S309000 | 0 |  | S270100 | S270220 |  | NOCA |  |  |  | Not Started | C | Yip, Kin |  | BNL | Installation | Kin Yip | BNL |  | POM02.2.02.05.03 |  |  |  |  |  | 03 |  |  | L5 |  | 40 |  |  | Yes | 2022-08-31 | PMP_2x |  |
| S309100 |  | Magnet Field Measurements: Remove Field Mapping Equipment |  | 2d | 2022-07-06 | 2022-07-07 | S309010 |  |  |  |  | 0d |  |  |  | TECH3 PO M [40 h]; TECH3 PO E [80 h] | 14,528.66 | S309100 | 0 |  | S270100 | S270240 | S309100 | CA |  |  |  | Not Started | C | Yip, Kin | L3 | BNL | Installation | Kin Yip | BNL | null | POM02.2.02.05.03 | C | 2.02 | 16720 | 003 | 2.02 | 03 |  |  |  |  |  |  |  |  |  |  | 190328 dur; logic per EOB |
| S309110 |  | Receive report from CERN, incorporate into analysis |  | 20d | 2022-07-08 | 2022-08-04 |  |  |  |  |  | 118d |  | start on or after 2022-07-08 |  | SCI 4 PO [16 h] | 3,495.16 | PO&AD | 0 |  | S269900 | S269900 | S309110 | CA |  |  |  | Not Started | C | Yip, Kin | L3 | BNL | Fab & Assy | Kin Yip | BNL | null | POM02.2.02.05.02 | C | 2.02 | 16720 | 012 | 2.02 | 03 |  |  |  |  | 0 |  |  |  |  |  |  |

Notes:
- S308600: BNL_UDF_Adhoc Comments: 180219 ELM resource change from PROF3 AD to PROF4 AD per EOB / BNL_UDF_Old Activity Name 181221: Magnet Field Measurements: Fabricate NMR probe mounts
- S308100: BNL_UDF_Adhoc Comments: 180220 ELM staff & workgroup change per EOB; 180219 ELM resource change from PROF3 AD to PROF4 AD per EOB / BNL_UDF_Old Activity Name 181221: Magnet Field Measurements: Procure NMR probes Labor
- S308200: BNL_UDF_Old Activity Name 181221: Magnet Field Measurements: Procure NMR probes M&S
- S308300: BNL_UDF_Adhoc Comments: 180220 ELM staff & workgroup change per EOB; 180219 ELM resource change from PROF3 AD to PROF4 AD per EOB / BNL_UDF_Old Activity Name 181221: Magnet Field Measurements: Procure NMR probe readout parts Labor
- S308400: BNL_UDF_Old Activity Name 181221: Magnet Field Measurements: Procure NMR probe readout parts M&S
- S308510: BNL_UDF_Adhoc Comments: 180220 ELM staff & workgroup change per EOB / BNL_UDF_Old Activity Name 181221: Magnet Field Measurements: Fabricate NMR probe readout parts
- S308500: BNL_UDF_Adhoc Comments: 180220 ELM staff & workgroup change per EOB / BNL_UDF_Old Activity Name 181221: Magnet Field Measurements: Fabricate NMR probe readout parts
- S308610: BNL_UDF_Adhoc Comments: 180219 ELM resource change from PROF3 AD to PROF4 AD per EOB / BNL_UDF_Old Activity Name 181221: Magnet Field Measurements: Fabricate NMR probe mounts
- S308611: BNL_UDF_Adhoc Comments: 180219 ELM resource change from PROF3 AD to PROF4 AD per EOB / BNL_UDF_Old Activity Name 181221: Magnet Field Measurements: Fabricate NMR probe mounts
- S308615: BNL_UDF_Adhoc Comments: 180219 ELM resource change from PROF3 AD to PROF4 AD per EOB / BNL_UDF_Old Activity Name 181221: Magnet Field Measurements: Fabricate NMR probe mounts
- S308613: BNL_UDF_Adhoc Comments: 180219 ELM resource change from PROF3 AD to PROF4 AD per EOB / BNL_UDF_Old Activity Name 181221: Magnet Field Measurements: Fabricate NMR probe mounts
- S308617: BNL_UDF_Adhoc Comments: 180219 ELM resource change from PROF3 AD to PROF4 AD per EOB / BNL_UDF_Old Activity Name 181221: Magnet Field Measurements: Fabricate NMR probe mounts
- S308619: BNL_UDF_Adhoc Comments: 180219 ELM resource change from PROF3 AD to PROF4 AD per EOB / BNL_UDF_Old Activity Name 181221: Magnet Field Measurements: Fabricate NMR probe mounts
- S308700: BNL_UDF_Adhoc Comments: 180219 ELM resource change from PROF3 AD to SCI3 AD per EOB / BNL_UDF_Old Activity Name 181221: Magnet Field Measurements: Run 3D field simulations and construct field and force maps
- S308710: BNL_UDF_Adhoc Comments: 180219 ELM resource change from PROF3 AD to SCI3 AD per EOB / BNL_UDF_Old Activity Name 181221: Magnet Field Measurements: Run 3D field simulations and construct field and force maps
- S308621: BNL_UDF_Adhoc Comments: 180219 ELM resource change from PROF3 AD to PROF4 AD per EOB / BNL_UDF_Old Activity Name 181221: Magnet Field Measurements: Fabricate NMR probe mounts
- S308623: BNL_UDF_Adhoc Comments: 180219 ELM resource change from PROF3 AD to PROF4 AD per EOB / BNL_UDF_Old Activity Name 181221: Magnet Field Measurements: Fabricate NMR probe mounts
- S308629: BNL_UDF_Adhoc Comments: 180219 ELM resource change from PROF3 AD to PROF4 AD per EOB / BNL_UDF_Old Activity Name 181221: Magnet Field Measurements: Fabricate NMR probe mounts
- S308625: BNL_UDF_Adhoc Comments: 180219 ELM resource change from PROF3 AD to PROF4 AD per EOB / BNL_UDF_Old Activity Name 181221: Magnet Field Measurements: Fabricate NMR probe mounts
- S308633: BNL_UDF_Adhoc Comments: 180219 ELM resource change from PROF3 AD to PROF4 AD per EOB / BNL_UDF_Old Activity Name 181221: Magnet Field Measurements: Fabricate NMR probe mounts
- S308627: BNL_UDF_Adhoc Comments: 180219 ELM resource change from PROF3 AD to PROF4 AD per EOB / BNL_UDF_Old Activity Name 181221: Magnet Field Measurements: Fabricate NMR probe mounts
- S308631: BNL_UDF_Adhoc Comments: 180219 ELM resource change from PROF3 AD to PROF4 AD per EOB / BNL_UDF_Old Activity Name 181221: Magnet Field Measurements: Fabricate NMR probe mounts
- S308900: BNL_UDF_Adhoc Comments: 180219 ELM resource change from PROF3 AD to SCI3 AD per EOB / BNL_UDF_Old Activity Name 181221: Magnet Field Measurements: Install Field Mapping Equipment
- S309000: BNL_UDF_Adhoc Comments: 180219 ELM resource change from PROF3 AD to SCI3 AD per EOB / BNL_UDF_Old Activity Name 181221: Magnet Field Measurements: Map Magnetic Field of SC Magnet
- S309005: BNL_UDF_Adhoc Comments: 180219 ELM resource change from PROF3 AD to SCI3 AD per EOB / BNL_UDF_Old Activity Name 181221: Magnet Field Measurements: Map Magnetic Field of SC Magnet
- S309010: BNL_UDF_Adhoc Comments: 180219 ELM resource change from PROF3 AD to SCI3 AD per EOB / BNL_UDF_Old Activity Name 181221: Magnet Field Measurements: Map Magnetic Field of SC Magnet
- S309100: BNL_UDF_Adhoc Comments: 180412 ELM pred/succ per GRY; 180219 ELM resource change from PROF3 AD to SCI3 AD per EOB / BNL_UDF_Old Activity Name 181221: Magnet Field Measurements: Remove Field Mapping Equipment
- S309110: BNL_UDF_Adhoc Comments: 180219 ELM resource change from PROF3 AD to PROF4 AD per EOB / BNL_UDF_Old Activity Name 181221: Magnet Field Measurements: Fabricate NMR probe mounts

| ID | WBS | Activity | Type | Duration | Start | Finish | Predecessors | Complete | Remaining | Planned start | Planned finish | Total float | Free float | Constraint | Expected finish | Resources | Cost | BNL_UDF_Exclude | BNL_UDF_Status Comments | BNL_UDF_Temp Text 01 | BNL_UDF_Percent Complete | BNL_UDF_Old Activity ID 181221 | RG Check | BNL_Activity Status | BNL_Fund Source | BNL_Estimator | BNL_Cost Basis | BNL_Location | BNL_EDIA | BNL_CAM | BNL_OPC TEC (deprecated) | BNL_WBS | BNL_Actuals | BNL_FY | BNL_EVT | BNL_PCR ID | BNL_WBS_Hierarchical | Completed | BNL_UDF_OPC TEC (deprecated) | BNL_UDF_Temp Date 01 | BNL_Institution | BNL_WBS Manager | BNL_Cobra WP | BNL_Master Control Account | BNL_Account Number | BNL_Cobra Control Account | Additional EVT documentation required | Temp | BNL_UDF_Temp Text 02 | BNL_Proc Sig Phase | BNL_Proc Sig | BNL_Obligation | BNL_Milestone Level | SPH Proc Register | Indicator - Procurement | Indicator - Float | BNL_UDF_Remaining Tot Cost | BNL_UDF_Percent_remaining |
| --- | --- | --- | --- | --- | --- | --- | --- | --- | --- | --- | --- | --- | --- | --- | --- | --- | --- | --- | --- | --- | --- | --- | --- | --- | --- | --- | --- | --- | --- | --- | --- | --- | --- | --- | --- | --- | --- | --- | --- | --- | --- | --- | --- | --- | --- | --- | --- | --- | --- | --- | --- | --- | --- | --- | --- | --- | --- | --- |
|  | 03 | **Carriage and Structural Components** |  |  | 2017-02-01 | 2022-07-26 |  |  |  |  |  |  |  |  |  |  |  |  |  |  |  |  |  |  |  |  |  |  |  |  |  |  |  |  |  |  |  |  |  |  |  |  |  |  |  |  |  |  |  |  |  |  |  |  |  |  |  |  |
| S309400 |  | Actuals - Nonlabor - sPHENIX Infrastructure FY17 |  | 169d | 2017-02-01 A | 2017-09-29 A | S100090 SS | 100% |  |  |  |  |  |  |  |  |  | MP6LAEXCLUDE | 190315 DurType to align with EVT | S309400 | 100 | S339382 | NOCA | Completed | C | Pisani, Rob | M1 | BNL | Design | Chris Pontieri | null | POM02.2.03 | Yes | 2017 | A | 003 | 03 | yes |  |  |  |  |  |  |  |  |  |  |  |  |  |  |  |  |  |  |  |  |
|  | 01 | **Cradle Carriage** |  |  | 2017-02-01 | 2022-07-26 |  |  |  |  |  |  |  |  |  |  |  |  |  |  |  |  |  |  |  |  |  |  |  |  |  |  |  |  |  |  |  |  |  |  |  |  |  |  |  |  |  |  |  |  |  |  |  |  |  |  |  |  |
| S309600 |  | Carriage Cradle - Create Overall Preliminary Layout |  | 354d | 2017-02-01 A | 2018-06-28 A | S100090 SS | 100% |  |  |  |  |  |  |  |  |  |  |  | S309600 | 100 | S270300 | NOCA | Completed | C | Mills, Jim | L4 | BNL | Design | Chris Pontieri | null | POM02.2.03.01 |  |  |  |  | 01 | yes | S270300 | 2018-09-01 | BNL | Hock, John |  |  |  |  |  |  |  |  |  |  |  |  |  |  |  |  |
| S309700 |  | Carriage Cradle - Perform Analyses, Design & System Integration (Initial) |  | 128d | 2018-03-30 A | 2018-09-28 A | S100090 SS | 100% |  |  |  |  |  |  |  |  |  |  |  | S309700 | 100 | S270398 | NOCA | Completed | C | Mills, Jim | L4 | BNL | Design | Chris Pontieri | null | POM02.2.03.01 |  |  |  |  | 01 | yes | S270400 | 2018-07-23 | BNL | Hock, John |  |  |  |  |  |  |  |  |  |  |  |  |  |  |  |  |
| S1001799 |  | Actuals - Labor - sPHENIX Infrastructure FY19 M8 16729 |  | 166d | 2018-10-01 A | 2019-05-31 A |  | 100% |  |  |  |  |  |  |  | Actual Labor [1141.78 h] | 190,783.32 | MP6LAEXCLUDE | 190315 DurType to align with EVT | S309300 | 100 | S339380 | CA | Completed | C | Pisani, Rob | L1 | BNL | Design | Chris Pontieri | null | POM02.2.03.01 | Yes | 2019 | A | 003 | 01 | yes |  |  |  |  | S1001799 | 2.03 | 16729 | 2.03 |  |  |  |  |  |  |  |  |  |  |  |  |
| S310000 |  | Carriage Cradle - Create Assembly & Detail Drawings - Physics Resource(s) |  | 115d | 2018-12-17 A | 2019-05-31 A | S309700 | 100% |  |  |  |  |  |  |  |  |  |  |  | PO&AD | 20 | S270700 | NOCA | Completed | C | Mills, Jim | L4 | BNL | Design | Chris Pontieri | null | POM02.2.03.01 |  |  | C |  | 01 | yes | S270700 | 2019-09-11 | BNL | Hock, John |  |  | 16729 |  | Yes | PO |  |  |  |  |  |  |  |  |  |  |
| S310010 |  | Carriage Cradle - Create Assembly & Detail Drawings - CA-D Resource(s) |  | 115d | 2018-12-17 A | 2019-05-31 A | S309700 | 100% |  |  |  |  |  |  |  |  |  |  |  | PO&ADS310010 | 20 | S270700 | NOCA | Completed | C | Mills, Jim | L4 | BNL | Design | Chris Pontieri | null | POM02.2.03.01 |  |  | C |  | 01 | yes | S270700 | 2019-09-11 | BNL | Hock, John |  |  | 16729 |  | Yes | C-AD | S310010 |  |  |  |  |  |  |  |  |  |
| S309800 |  | Carriage Cradle - Perform Analyses, Design & System Integration (Final) - Physics Resource(s) |  | 105d | 2019-01-02 A | 2019-05-31 A | S309700, S309600 | 100% |  |  |  |  |  |  |  |  |  |  |  | PO&AD | 80 | S270400 | NOCA | Completed | C | Mills, Jim | L4 | BNL | Design | Chris Pontieri | null | POM02.2.03.01 |  |  | C |  | 01 | yes | S270400 | 2019-04-17 | BNL | Hock, John |  |  | 16729 |  |  | PO |  |  |  |  |  |  |  |  |  |  |
| S309810 |  | Carriage Cradle - Perform Analyses, Design & System Integration (Final) - CA-D Resource(s) |  | 105d | 2019-01-02 A | 2019-05-31 A |  | 100% |  |  |  |  |  |  |  |  |  |  |  | PO&ADS309810 | 80 | S270400 | NOCA | Completed | C | Mills, Jim | L4 | BNL | Design | Chris Pontieri | null | POM02.2.03.01 |  |  | C |  | 01 | yes | S270400 | 2019-04-17 | BNL | Hock, John |  |  | 16729 |  |  | C-AD | S309810 |  |  |  |  |  |  |  |  |  |
| S314700 |  | Track Modifications - Structural Analysis of Existing Track System & Preliminary Design - Physics Resource(s) |  | 105d | 2019-01-02 A | 2019-05-31 A | S310000 SS, S310006 SS, S310016 SS | 100% |  |  |  |  |  |  |  |  |  |  |  | PO&AD | 5 | S2716530 | NOCA | Completed | C | Mills, Jim | L4 | BNL | Design | Chris Pontieri | null | POM02.2.03.01 |  |  | C |  | 01 | yes |  | 2019-06-28 | BNL | Hock, John |  |  | 16729 |  |  | PO |  |  |  |  |  |  |  |  |  |  |
| S314710 |  | Steel Track Modifications - Structural Analysis of Existing Steel Track System & Preliminary Design - CA-D Resource(s) |  | 105d | 2019-01-02 A | 2019-05-31 A |  | 100% |  |  |  |  |  |  |  |  |  |  |  | PO&ADS314710 | 5 | S2716530 | NOCA | Completed | C | Mills, Jim | L4 | BNL | Design | Chris Pontieri | null | POM02.2.03.01 |  |  | C |  | 01 | yes |  | 2019-06-28 | BNL | Hock, John |  |  | 16729 |  |  | C-AD | S314710 |  |  |  |  |  |  |  |  |  |
| S309900 |  | Carriage Cradle - Preliminary Design Review (Assembly, System Integration, Final Layout) - Physics Resource(s) |  | 13d | 2019-02-11 A | 2019-02-28 A | S309810 | 100% |  |  |  |  |  |  |  |  |  |  |  | PO&AD | 100 | S270404 | NOCA | Completed | C | Mills, Jim | L4 | BNL | Design | Chris Pontieri | null | POM02.2.03.01 |  |  | C |  | 01 | yes | S270400 | 2018-07-23 | BNL | Hock, John |  |  | 16729 |  |  | PO |  |  |  |  |  |  |  |  |  |  |
| S309910 |  | Carriage Cradle - Preliminary Design Review (Assembly, System Integration, Final Layout) - CA-D Resource(s) |  | 13d | 2019-02-11 A | 2019-02-28 A | S309900 SS | 100% |  |  |  |  |  |  |  |  |  |  |  | PO&ADS309910 | 100 | S270404 | NOCA | Completed | C | Mills, Jim | L4 | BNL | Design | Chris Pontieri | null | POM02.2.03.01 |  |  | C |  | 01 | yes | S270400 | 2018-07-23 | BNL | Hock, John |  |  | 16729 |  |  | C-AD | S309910 |  |  |  |  |  |  |  |  |  |
| S1004880 |  | Actuals - Labor FY19 Jun-Sep 16729 |  | 84d | 2019-06-03 A | 2019-09-30 A |  | 100% |  |  |  |  |  |  |  | Actual Labor [1358.29 h] | 226,959.94 | MP6LAEXCLUDE | 190315 DurType to align with EVT | S309300 | 100 | S339380 | CA | Completed | C | Pisani, Rob | L1 | BNL | Design | Chris Pontieri | null | POM02.2.03.01 | Yes | 2019 | A | 003 | 01 | yes |  |  |  |  | S1004880 | 2.03 | 16729 | 2.03 |  |  |  |  |  |  |  |  |  |  |  |  |
| S310005 |  | Carriage Cradle - Create Assembly & Detail Drawings - Physics Resource(s) Split_90% |  | 84d | 2019-06-03 A | 2019-09-30 A | S310000 | 100% |  |  |  |  |  |  |  |  |  |  |  | PO&AD | 20 | S270700 | NOCA | Completed | C | Mills, Jim | L4 | BNL | Design | Chris Pontieri | null | POM02.2.03.01 |  |  | C |  | 01 |  | S270700 | 2019-09-11 | BNL | Hock, John |  | 2.03 | 16729 |  | Yes | PO |  |  |  |  |  |  |  |  |  |  |
| S310015 |  | Carriage Cradle - Create Assembly & Detail Drawings - CA-D Resource(s) Split_90% |  | 84d | 2019-06-03 A | 2019-09-30 A | S310010 | 100% |  |  |  |  |  |  |  |  |  |  |  | PO&ADS310010 | 20 | S270700 | NOCA | Completed | C | Mills, Jim | L4 | BNL | Design | Chris Pontieri | null | POM02.2.03.01 |  |  | C |  | 01 |  | S270700 | 2019-09-11 | BNL | Hock, John |  | 2.03 | 16729 |  | Yes | C-AD | S310010 |  |  |  |  |  |  |  |  |  |
| S314705 |  | Track Modifications - Structural Analysis of Existing Track System & Preliminary Design - Physics Resource(s) Split |  | 84d | 2019-06-03 A | 2019-10-30 A | S314700 | 100% |  | 2019-06-03 | 2019-09-30 |  |  |  |  |  |  |  |  | PO&AD | 5 | S2716530 | NOCA | Completed | C | Mills, Jim | L4 | BNL | Design | Chris Pontieri | null | POM02.2.03.01 |  |  | C |  | 01 |  |  | 2019-06-28 | BNL | Hock, John |  | 2.03 | 16729 |  |  | PO |  |  |  |  |  |  |  |  |  |  |
| S314715 |  | Steel Track Modifications - Structural Analysis of Existing Steel Track System & Preliminary Design_15% |  | 84d | 2019-06-03 A | 2019-09-30 A | S314710 | 100% |  |  |  |  |  |  |  |  |  |  |  | PO&ADS314710 | 5 | S2716530 | NOCA | Completed | C | Mills, Jim | L4 | BNL | Design | Chris Pontieri | null | POM02.2.03.01 |  |  | C |  | 01 |  |  | 2019-06-28 | BNL | Hock, John |  | 2.03 | 16729 |  |  | C-AD | S314710 |  |  |  |  |  |  |  |  |  |
| S310100 |  | Carriage Cradle - Final Review (Design & Safety) - Physics Resource(s) |  | 2d | 2019-08-07 A | 2019-08-08 A | S309910, S309900 | 100% |  |  |  |  |  |  |  |  |  |  |  | PO&AD | 0 | S270900 | NOCA | Completed | C | Mills, Jim | L4 | BNL | Design | Chris Pontieri | null | POM02.2.03.01 |  |  | C |  | 01 |  | S270900 |  | BNL | Hock, John |  | 2.03 | 16729 |  |  | PO |  |  |  |  |  |  |  |  |  |  |
| S310110 |  | Carriage Cradle - Final Review (Design & Safety) - CA-D Resource(s) |  | 20d | 2019-09-03 A | 2019-09-30 A | S310100 SS, S310006 SS | 100% |  |  |  |  |  |  |  |  |  |  |  | PO&ADS310110 | 0 | S270900 | NOCA | Completed | C | Mills, Jim | L4 | BNL | Design | Chris Pontieri | null | POM02.2.03.01 |  |  | C |  | 01 |  | S270900 |  | BNL | Hock, John |  | 2.03 | 16729 |  |  | C-AD | S310110 |  |  |  |  |  |  |  |  |  |
| S310200 |  | Carriage Cradle - Address Action Items from Design & Safety Reviews - Physics Resource(s)_25% |  | 11d | 2019-09-16 A | 2019-09-30 A | S310100 | 100% |  |  |  |  |  |  |  |  |  |  |  | PO&AD | 0 | S271000 | NOCA | Completed | C | Mills, Jim | L4 | BNL | Management Tech Reviews | Chris Pontieri | null | POM02.2.03.01 |  |  | C |  | 01 |  | S271000 |  | BNL | Hock, John |  | 2.03 | 16729 |  |  | PO |  |  |  |  |  |  |  |  |  |  |
| S310210 |  | Carriage Cradle - Address Action Items from Design & Safety Reviews - CA-D Resource(s)_25% |  | 11d | 2019-09-16 A | 2019-09-30 A |  | 100% |  |  |  |  |  |  |  |  |  |  |  | PO&ADS310210 | 0 | S271000 | NOCA | Completed | C | Mills, Jim | L4 | BNL | Management Tech Reviews | Chris Pontieri | null | POM02.2.03.01 |  |  | C |  | 01 |  | S271000 |  | BNL | Hock, John |  | 2.03 | 16729 |  |  | C-AD | S310210 |  |  |  |  |  |  |  |  |  |
| S310201 |  | Carriage Cradle - Address Action Items from Design & Safety Reviews - Physics Resource(s)_75% |  | 12d | 2019-10-01 A | 2019-10-17 A | S310200 | 100% |  | 2019-11-01 | 2019-11-19 |  |  |  |  | TECH3 PO D [45 h]; SCI3 PO [6 h]; TECH3 PO M [6 h] | 6,852.86 |  |  | PO&AD | 0 | S271000 | CA | Completed | C | Mills, Jim | L4 | BNL | Management Tech Reviews | Chris Pontieri | null | POM02.2.03.01 |  |  | C |  | 01 |  | S271000 |  | BNL | Hock, John | S310201 | 2.03 | 16729 | 2.03 |  | PO |  |  |  |  |  |  |  |  |  |  |
| S310211 |  | Carriage Cradle - Address Action Items from Design & Safety Reviews - CA-D Resource(s)_75% |  | 12d | 2019-10-01 A | 2019-10-17 A | S310210 | 100% |  | 2019-11-01 | 2019-11-19 |  |  |  |  | PROF4 AD [60 h]; PROF5 AD [30 h]; TECH3 AD [45 h] | 19,073.29 |  |  | PO&ADS310210 | 0 | S271000 | CA | Completed | C | Mills, Jim | L4 | BNL | Management Tech Reviews | Chris Pontieri | null | POM02.2.03.01 |  |  | C |  | 01 |  | S271000 |  | BNL | Hock, John | S310211 | 2.03 | 16729 | 2.03 |  | C-AD | S310210 |  |  |  |  |  |  |  |  |  |
| S310400 |  | Carriage Cradle - Prepare Procurement Package(s) - Physics Resource(s) |  | 10d | 2019-10-01 A | 2019-11-15 A | S310300 | 100% |  | 2019-11-01 | 2019-11-15 |  |  |  |  | TECH3 PO D [24 h]; TECH3 PO M [24 h] | 5,477.86 |  | 190317 ELM remove proc nos. | PO&AD | 0 | S271200 | CA | Completed | C | Mills, Jim | L4 | BNL | Procurement | Chris Pontieri | null | POM02.2.03.01 |  |  | C | 003 | 01 |  | S271200 |  | BNL | Hock, John | S310400 | 2.03 | 16729 | 2.03 |  | PO |  |  |  |  |  |  |  |  |  |  |
| S310410 |  | Carriage Cradle - Prepare Procurement Package(s) - CA-D Resource(s) |  | 10d | 2019-10-01 A | 2019-11-15 A | S310400 SS | 100% |  | 2019-11-01 | 2019-11-15 |  |  |  |  | PROF4 AD [24 h]; PROF5 AD [20 h]; TECH3 AD [24 h] | 9,674.55 |  | 190317 ELM remove proc nos. | PO&ADS310410 | 0 | S271200 | CA | Completed | C | Mills, Jim | L4 | BNL | Procurement | Chris Pontieri | null | POM02.2.03.01 |  |  | C | 003 | 01 |  | S271200 |  | BNL | Hock, John | S310410 | 2.03 | 16729 | 2.03 |  | C-AD | S310410 |  |  |  |  |  |  |  |  |  |
| OBLG315810 |  | Track Modifications - Obligation |  | 1d | 2019-10-01 A | 2019-10-01 A |  | 100% |  |  |  |  |  |  |  | Obligation Resource [30439.5 h] | 30,439.52 |  |  | S315800 | 0 | S2716592 |  | Completed | C | Mills, Jim | L4 | BNL | Procurement | Chris Pontieri | null | POM02.2.03.01 |  |  |  |  | 01 |  |  |  | BNL | Hock, John |  |  |  |  |  |  |  | PP5 | MP209106 | OBLG |  |  |  |  |  |  |
| S310006 |  | Carriage Cradle - Create Assembly & Detail Drawings - Physics Resource(s) Split_10% |  | 11d | 2019-10-01 A | 2019-11-29 A | S310005 SS | 100% |  | 2019-10-01 | 2019-10-16 |  |  |  |  | TECH3 PO D [19.2 h]; TECH3 PO M [2.6 h] | 2,487.86 |  |  | PO&AD | 20 | S270700 | CA | Completed | C | Mills, Jim | L4 | BNL | Design | Chris Pontieri | null | POM02.2.03.01 |  |  | C |  | 01 |  | S270700 | 2019-09-11 | BNL | Hock, John | S310006 | 2.03 | 16729 | 2.03 | Yes | PO |  |  |  |  |  |  |  |  |  |  |
| S310016 |  | Carriage Cradle - Create Assembly & Detail Drawings - CA-D Resource(s) Split_10% |  | 11d | 2019-10-01 A | 2019-11-29 A | S310015 | 100% |  | 2019-10-01 | 2019-10-16 |  |  |  |  | PROF4 AD [9.6 h]; PROF5 AD [9.6 h]; TECH3 AD [19.2 h] | 5,237.49 |  |  | PO&ADS310010 | 20 | S270700 | CA | Completed | C | Mills, Jim | L4 | BNL | Design | Chris Pontieri | null | POM02.2.03.01 |  |  | C |  | 01 |  | S270700 | 2019-09-11 | BNL | Hock, John | S310016 | 2.03 | 16729 | 2.03 | Yes | C-AD | S310010 |  |  |  |  |  |  |  |  |  |
| S314716 |  | Steel Track Modifications - Structural Analysis of Existing Steel Track System & Preliminary Design_85% |  | 21d | 2019-10-01 A | 2019-10-30 A | S314715 | 100% |  |  |  |  |  |  |  | TECH3 PO D [34 h] | 3,880.15 |  |  | PO&ADS314710 | 5 | S2716530 | CA | Completed | C | Mills, Jim | L4 | BNL | Design | Chris Pontieri | null | POM02.2.03.01 |  |  | C |  | 01 |  |  | 2019-06-28 | BNL | Hock, John | S314716 | 2.03 | 16729 | 2.03 |  | C-AD | S314710 |  |  |  |  |  |  |  |  |  |
| S311800 |  | CC Drive & Alignment System - Engineering (re-engineer & use STAR controller?) - Physics Resource(s) |  | 60d | 2019-10-18 A | 2020-04-30 A | S310300 | 100% |  | 2019-10-18 | 2020-01-16 |  |  |  |  | TECH3 PO D [15 h] | 1,711.83 |  |  | PO&AD | 0 | S2716110 | CA | In Progress | C | Mills, Jim | L4 | BNL | Design | Chris Pontieri | null | POM02.2.03.01 |  |  | C |  | 01 |  |  |  | BNL | Hock, John | S311800 | 2.03 | 16729 | 2.03 |  | PO |  |  |  |  |  |  |  |  |  |  |
| S311810 |  | CC Drive & Alignment System - Engineering (re-engineer & use STAR controller?) - CA-D Resource(s) |  | 60d | 2019-10-18 A | 2020-04-30 A | S311800 SS | 100% |  | 2019-10-18 | 2020-01-16 |  |  |  |  | PROF4 AD [30 h]; PROF5 AD [64 h]; TECH3 AD [15 h] | 17,013.82 |  |  | PO&ADS311810 | 0 | S2716110 | CA | In Progress | C | Mills, Jim | L4 | BNL | Design | Chris Pontieri | null | POM02.2.03.01 |  |  | C |  | 01 |  |  |  | BNL | Hock, John | S311810 | 2.03 | 16729 | 2.03 |  | C-AD | S311810 |  |  |  |  |  |  |  |  |  |
| S313300 |  | CC Seismic Restraints - Engineer & Analysis |  | 30d | 2019-10-28 A | 2020-03-31 A | S314716 | 100% |  | 2019-10-31 | 2019-12-16 |  |  |  |  | PROF5 AD [120 h]; PROF4 AD [240 h] | 55,751.17 |  |  | S313300 | 0 | S2716230 | CA | In Progress | C | Mills, Jim | L4 | BNL | Design | Chris Pontieri | null | POM02.2.03.01 |  |  | C |  | 01 |  |  |  | BNL | Hock, John | S313300 | 2.03 | 16729 | 2.03 |  |  |  |  |  |  |  |  |  |  |  |  |
| S315010 |  | Steel Track Modifications - Final Design Reviews (Design & Safety) |  | 10d | 2019-10-30 A | 2019-10-31 A | S314716 | 100% |  | 2019-10-31 | 2019-11-14 |  |  |  |  | PROF4 AD [8 h] | 1,178.12 |  |  | PO&ADS315010 | 0 | S2716560 | CA | Completed | C | Mills, Jim | L4 | BNL | Design | Chris Pontieri | null | POM02.2.03.01 |  |  | C |  | 01 |  |  |  | BNL | Hock, John | S315010 | 2.03 | 16729 | 2.03 |  | C-AD | S315010 |  |  |  |  |  |  |  |  |  |
| S310300 |  | Carriage Cradle - Design & Safety Reviews Complete Released for Production | milestone | 0d | 2019-11-01 A | 2019-11-01 A | S310100, S310201 FF, S310211 FF | 100% |  |  |  |  |  |  |  |  |  |  |  | S310300 | 0 | S271100 | NOCA | Completed | C | Mills, Jim | L4 | BNL | Management Safety Reviews | Chris Pontieri | null | POM02.2.03.01 |  |  |  |  | 01 |  | S271100 |  | BNL | Hock, John |  |  |  |  |  |  |  |  |  |  | L4 |  |  |  |  |  |
| S315110 |  | Steel Track Modifications - Address Action Items from Design & Safety Reviews |  | 10d | 2019-11-01 A | 2019-11-15 A | S315010, S314716 | 100% |  |  |  |  |  |  |  | PROF3 AD [8 h] | 1,012.08 |  |  | PO&ADS315110 | 0 | S2716565 | CA | Completed | C | Mills, Jim | L4 | BNL | Management Tech Reviews | Chris Pontieri | null | POM02.2.03.01 |  |  | C |  | 01 |  |  |  | BNL | Hock, John | S315110 | 2.03 | 16729 | 2.03 |  | C-AD | S315110 |  |  |  |  |  |  |  |  |  |
| S310500 |  | Carriage Cradle - Procurement Readiness Review - Physics Resource(s) |  | 5d | 2019-11-18 A | 2019-11-22 A | S310400 | 100% |  |  |  |  |  |  |  | TECH3 PO D [12 h]; TECH3 PO M [24 h] | 4,108.4 |  | 190317 ELM remove proc nos. | PO&AD | 0 | S271204 | CA | Completed | C | Mills, Jim | L4 | BNL | Procurement | Chris Pontieri | null | POM02.2.03.01 |  |  | C | 003 | 01 |  | S271200 |  | BNL | Hock, John | S310500 | 2.03 | 16729 | 2.03 |  | PO |  |  |  |  |  |  |  |  |  |  |
| S310510 |  | Carriage Cradle - Procurement Readiness Review - CA-D Resource(s) |  | 5d | 2019-11-18 A | 2019-11-22 A | S310410 | 100% |  |  |  |  |  |  |  | PROF4 AD [24 h]; TECH3 AD [12 h] | 4,903.83 |  | 190317 ELM remove proc nos. | PO&ADS310510 | 0 | S271204 | CA | Completed | C | Mills, Jim | L4 | BNL | Procurement | Chris Pontieri | null | POM02.2.03.01 |  |  | C | 003 | 01 |  | S271200 |  | BNL | Hock, John | S310510 | 2.03 | 16729 | 2.03 |  | C-AD | S310510 |  |  |  |  |  |  |  |  |  |
| S315900 |  | Steel Track Modifications - BNL Oversight Construction - Physics Resource(s) |  | 60d | 2019-11-18 A | 2020-01-31 A | S315110 | 100% |  | 2019-11-18 | 2020-02-14 |  |  |  |  | TECH3 PO D [80 h] | 9,129.77 |  | 190317 ELM remove proc nos.; 19315 DurType to align with EVT | PO&AD | 0 | S2716594 | CA | In Progress | C | Mills, Jim | L4 | BNL | Procurement | Chris Pontieri | null | POM02.2.03.01 |  |  | A | 003 | 01 |  | S271400 |  | BNL | Hock, John | S315900 | 2.03 | 16729 | 2.03 |  | PO |  |  |  |  |  |  |  |  |  |  |
| S315910 |  | Steel Track Modifications - BNL Oversight Construction - CA-D Resource(s) |  | 60d | 2019-11-18 A | 2020-01-31 A | S315900 SS | 100% |  | 2019-11-18 | 2020-02-14 |  |  |  |  | PROF4 AD [120 h]; CRAFT3 [300 h] | 55,193.19 |  | 190317 ELM remove proc nos.; 19315 DurType to align with EVT | PO&ADS315910 | 0 | S2716594 | CA | In Progress | C | Mills, Jim | L4 | BNL | Procurement | Chris Pontieri | null | POM02.2.03.01 |  |  | A | 003 | 01 |  | S271400 |  | BNL | Hock, John | S315910 | 2.03 | 16729 | 2.03 |  | C-AD | S315910 |  |  |  |  |  |  |  |  |  |
| S310600 |  | Carriage Cradle - Provide Requirement to Procurement |  | 5d | 2019-11-25 A | 2019-12-31 A | S310500, S310510 | 100% |  | 2019-11-25 | 2019-12-03 |  |  |  |  | PROF5 AD [8 h] | 1,360.5 |  |  | S310600 | 0 | S27120402 | CA | In Progress | C | Mills, Jim | L4 | BNL | Procurement | Chris Pontieri | null | POM02.2.03.01 |  |  | C |  | 01 |  | S273400 | 2018-08-01 | BNL | Hock, John | S310600 | 2.03 | 16729 | 2.03 |  |  |  | PP1 | MP209100 |  |  |  |  |  |  |  |
| S311900 |  | CC Drive & Alignment System - Design Carriage Controls & Limits |  | 30d | 2019-12-02 A | 2020-09-01 A | S310500, S310300, S310510 | 100% |  | 2019-12-02 | 2020-01-14 |  |  |  |  | PROF4 PO E [120 h] | 17,671.8 |  |  | S311900 | 0 | S2716112 | CA | Not Started | C | Mills, Jim | L4 | BNL | Design | Chris Pontieri | null | POM02.2.03.01 |  |  | C |  | 01 |  |  |  | BNL | Hock, John | S311900 | 2.03 | 16729 | 2.03 |  |  |  |  |  |  |  |  |  |  |  |  |
| S310700 |  | Carriage Cradle - Prepare & Send Solicitation |  | 15d | 2019-12-16 A | 2020-01-31 A | S310600 | 100% |  | 2019-12-16 | 2020-01-07 |  |  |  |  |  |  |  |  | S310700 | 0 | S27120404 | NOCA | Not Started | C | Mills, Jim | L4 | BNL | Procurement | Chris Pontieri | null | POM02.2.03.01 |  |  |  |  | 01 |  |  | 2018-08-01 | BNL | Hock, John |  |  |  |  |  |  |  | PP2 | MP209100 |  |  |  |  |  |  |  |
| S313400 |  | CC Seismic Restraints - Assembly & Detail Drawings - Physics Resource(s) |  | 30d | 2019-12-17 A | 2021-06-17 | S313300 | 95% | 13d | 2019-12-17 | 2020-01-30 | 29d | 0d |  | 2021-06-17 | TECH3 PO D [120 h] | 13,694.66 |  |  | PO&AD | 0 | S2716240 | CA | Not Started | C | Mills, Jim | L4 | BNL | Design | Chris Pontieri | null | POM02.2.03.01 |  |  | C |  | 01 |  |  |  | BNL | Hock, John | S313400 | 2.03 | 16729 | 2.03 |  | PO |  |  |  |  |  |  |  |  |  |  |
| S313410 |  | CC Seismic Restraints - Assembly & Detail Drawings - CA-D Resource(s) |  | 30d | 2019-12-17 A | 2021-06-17 | S313400 SS | 95% | 13d | 2019-12-17 | 2020-01-30 | 29d | 0d |  | 2021-06-17 | PROF4 AD [80 h]; PROF5 AD [40 h]; TECH3 AD [120 h] | 32,278.38 |  |  | PO&ADS313410 | 0 | S2716240 | CA | Not Started | C | Mills, Jim | L4 | BNL | Design | Chris Pontieri | null | POM02.2.03.01 |  |  | C |  | 01 |  |  |  | BNL | Hock, John | S313410 | 2.03 | 16729 | 2.03 |  | C-AD | S313410 |  |  |  |  |  |  |  |  |  |
| S310800 |  | Carriage Cradle - Vendor Responses - Physics Resource(s) |  | 50d | 2020-01-08 A | 2020-03-19 A | S310700 | 100% |  |  |  |  |  |  |  | TECH3 PO D [36 h] | 4,108.4 |  |  | PO&AD | 0 | S27120406 | CA | Not Started | C | Mills, Jim | L4 | BNL | Procurement | Chris Pontieri | null | POM02.2.03.01 |  |  | C |  | 01 |  |  |  | BNL | Hock, John | S310800 | 2.03 | 16729 | 2.03 |  | PO |  | PP3 | MP209100 |  |  |  |  |  |  |  |
| S310810 |  | Carriage Cradle - Vendor Responses - CA-D Resource(s) |  | 50d | 2020-01-08 A | 2020-03-19 A | S310800 SS | 100% |  |  |  |  |  |  |  | PROF4 AD [36 h]; PROF5 AD [36 h]; TECH3 AD [36 h] | 15,532.21 |  |  | PO&ADS310810 | 0 | S27120406 | CA | Not Started | C | Mills, Jim | L4 | BNL | Procurement | Chris Pontieri | null | POM02.2.03.01 |  |  | C |  | 01 |  |  |  | BNL | Hock, John | S310810 | 2.03 | 16729 | 2.03 |  | C-AD | S310810 | PP3 | MP209100 |  |  |  |  |  |  |  |
| S315915 |  | Steel Track Modifications - Inspection As-Builts and Punchlists Phys |  | 5d | 2020-02-03 A | 2020-10-30 A | S315910 | 100% |  | 2020-02-03 | 2020-02-07 |  |  |  |  | TECH3 PO D [60 h] | 6,847.33 | MP6LAEXCLUDE |  | S316000 | 0 | S2716596 | CA | Not Started | C | Mills, Jim | L4 | BNL | Procurement | Chris Pontieri | null | POM02.2.03.01 |  |  | C |  | 01 |  | S270200 |  | BNL | Hock, John | S315915 | 2.03 | 16729 | 2.03 |  |  |  | PP6 | MP209106 |  |  |  |  |  |  |  |
| S315925 |  | Steel Track Modifications - Inspection As-Builts and Punchlists CA-D |  | 5d | 2020-02-03 A | 2020-10-30 A | S315910 | 100% |  | 2020-02-03 | 2020-02-07 |  |  |  |  | PROF4 AD [60 h] | 8,835.9 | MP6LAEXCLUDE |  | S316000 | 0 | S2716596 | CA | Not Started | C | Mills, Jim | L4 | BNL | Procurement | Chris Pontieri | null | POM02.2.03.01 |  |  | C |  | 01 |  | S270200 |  | BNL | Hock, John | S315925 | 2.03 | 16729 | 2.03 |  |  |  | PP6 | MP209106 |  |  |  |  |  |  |  |
| S310900 |  | Carriage Cradle - Vendor Selection - Physics Resource(s) |  | 40d | 2020-03-20 A | 2020-03-25 A | S310800, S310810 | 100% |  | 2020-03-20 | 2020-05-14 |  |  |  |  | TECH3 PO D [36 h]; TECH3 PO M [72 h] | 12,325.19 |  |  | PO&AD | 0 | S271300 | CA | Not Started | C | Mills, Jim | L4 | BNL | Procurement | Chris Pontieri | null | POM02.2.03.01 |  |  | C |  | 01 |  | S271300 |  | BNL | Hock, John | S310900 | 2.03 | 16729 | 2.03 |  | PO |  | PP4 | MP209100 |  |  |  |  |  |  |  |
| S310910 |  | Carriage Cradle - Vendor Selection - CA-D Resource(s) |  | 40d | 2020-03-20 A | 2020-03-25 A | S310900 SS | 100% |  | 2020-03-20 | 2020-05-14 |  |  |  |  | PROF4 AD [20 h]; PROF5 AD [20 h]; TECH3 AD [36 h] | 10,454.96 |  |  | PO&ADS310910 | 0 | S271300 | CA | Not Started | C | Mills, Jim | L4 | BNL | Procurement | Chris Pontieri | null | POM02.2.03.01 |  |  | C |  | 01 |  | S271300 |  | BNL | Hock, John | S310910 | 2.03 | 16729 | 2.03 |  | C-AD | S310910 | PP4 | MP209100 |  |  |  |  |  |  |  |
| S312000 |  | CC Drive & Alignment System - Assembly & Detail Drawings - Physics Resource(s) |  | 50d | 2020-04-01 A | 2020-09-01 A | S311800, S311900 SS, S311810 | 100% |  | 2020-05-01 | 2020-07-13 |  |  |  |  | TECH3 PO D [240 h] | 27,389.31 |  |  | PO&AD | 0 | S2716120 | CA | Not Started | C | Mills, Jim | L4 | BNL | Design | Chris Pontieri | null | POM02.2.03.01 |  |  | C |  | 01 |  |  |  | BNL | Hock, John | S312000 | 2.03 | 16729 | 2.03 |  | PO |  |  |  |  |  |  |  |  |  |  |
| S312010 |  | CC Drive & Alignment System - Assembly & Detail Drawings - CA-D Resource(s) |  | 50d | 2020-04-01 A | 2020-09-01 A | S312000 SS | 100% |  | 2020-05-01 | 2020-07-13 |  |  |  |  | PROF4 AD [120 h]; PROF5 AD [80 h]; TECH3 AD [240 h] | 58,666.16 |  |  | PO&ADS312010 | 0 | S2716120 | CA | Not Started | C | Mills, Jim | L4 | BNL | Design | Chris Pontieri | null | POM02.2.03.01 |  |  | C |  | 01 |  |  |  | BNL | Hock, John | S312010 | 2.03 | 16729 | 2.03 |  | C-AD | S312010 |  |  |  |  |  |  |  |  |  |
| S311000 |  | Carriage Cradle - Contract Award(s) |  | 1d | 2020-04-01 A | 2020-04-01 A | S310900, S310910 | 100% |  |  |  |  |  |  |  |  |  |  |  | S311000 | 0 | S27130002 | NOCA | Not Started | C | Mills, Jim | L4 | BNL | Procurement | Chris Pontieri | null | POM02.2.03.01 |  |  |  |  | 01 |  |  |  | BNL | Hock, John |  |  |  |  |  |  |  | PP5 | MP209100 |  | L5 | Contract Award |  |  |  |  |
| S312100 |  | CC Drive & Alignment System - Final Design Reviews (Design & Safety) - Physics Resource(s) |  | 5d | 2020-04-14 A | 2020-04-30 A | S312000, S312010 | 100% |  | 2020-07-14 | 2020-07-20 |  |  |  |  | TECH3 PO D [40 h] | 4,564.89 |  |  | PO&AD | 0 | S2716122 | CA | Not Started | C | Mills, Jim | L4 | BNL | Design | Chris Pontieri | null | POM02.2.03.01 |  |  | C |  | 01 |  |  |  | BNL | Hock, John | S312100 | 2.03 | 16729 | 2.03 |  | PO |  |  |  |  |  |  |  |  |  |  |
| S312110 |  | CC Drive & Alignment System - Final Design Reviews (Design & Safety) - CA-D Resource(s) |  | 5d | 2020-04-14 A | 2020-04-30 A | S312100 SS | 100% |  | 2020-07-14 | 2020-07-20 |  |  |  |  | PROF4 AD [80 h]; PROF5 AD [40 h]; TECH3 AD [40 h] | 23,148.61 |  |  | PO&ADS312110 | 0 | S2716122 | CA | Not Started | C | Mills, Jim | L4 | BNL | Design | Chris Pontieri | null | POM02.2.03.01 |  |  | C |  | 01 |  |  |  | BNL | Hock, John | S312110 | 2.03 | 16729 | 2.03 |  | C-AD | S312110 |  |  |  |  |  |  |  |  |  |
| S312200 |  | CC Drive & Alignment System - Address Action Items from Design & Safety Reviews - Physics Resource(s) |  | 5d | 2020-04-21 A | 2020-10-14 A | S312100, S312110 | 100% |  | 2020-07-21 | 2020-07-27 |  |  |  |  | TECH3 PO D [40 h] | 4,564.89 |  |  | PO&AD | 0 | S2716123 | CA | Not Started | C | Mills, Jim | L4 | BNL | Design | Chris Pontieri | null | POM02.2.03.01 |  |  | C |  | 01 |  |  |  | BNL | Hock, John | S312200 | 2.03 | 16729 | 2.03 |  | PO |  |  |  |  |  |  |  |  |  |  |
| S312210 |  | CC Drive & Alignment System - Address Action Items from Design & Safety Reviews - CA-D Resource(s) |  | 5d | 2020-04-21 A | 2020-10-14 A | S312200 SS | 100% |  | 2020-07-21 | 2020-07-27 |  |  |  |  | PROF4 AD [80 h]; PROF5 AD [40 h]; TECH3 AD [40 h] | 23,148.61 |  |  | PO&ADS312210 | 0 | S2716123 | CA | Not Started | C | Mills, Jim | L4 | BNL | Design | Chris Pontieri | null | POM02.2.03.01 |  |  | C |  | 01 |  |  |  | BNL | Hock, John | S312210 | 2.03 | 16729 | 2.03 |  | C-AD | S312210 |  |  |  |  |  |  |  |  |  |
| S311100 |  | Carriage Cradle - BNL Oversight - Physics Resource(s) |  | 180d | 2020-05-06 A | 2021-01-26 A | S311000, OBLG311010 | 100% |  |  |  |  |  | start on or after 2020-05-06 |  | TECH3 PO D [10 h]; TECH3 PO M [40 h] | 5,779.33 |  | 190317 ELM remove proc nos.; 19315 DurType to align with EVT | PO&AD | 0 | S271400 | CA | Not Started | C | Mills, Jim | L4 | BNL | Procurement | Chris Pontieri | null | POM02.2.03.01 |  |  | A | 012 | 01 |  | S271400 |  | BNL | Hock, John | S311100 | 2.03 | 16729 | 2.03 | Yes | PO |  |  |  |  |  |  |  |  |  |  |
| S311110 |  | Carriage Cradle - BNL Oversight - CA-D Resource(s) |  | 180d | 2020-05-06 A | 2021-01-26 A | S311100 SS | 100% |  |  |  |  |  |  |  | PROF4 AD [40 h]; PROF5 AD [40 h]; TECH3 AD [10 h] | 14,011.88 |  | 190317 ELM remove proc nos.; 19315 DurType to align with EVT | PO&ADS311110 | 0 | S271400 | CA | Not Started | C | Mills, Jim | L4 | BNL | Procurement | Chris Pontieri | null | POM02.2.03.01 |  |  | A | 012 | 01 |  | S271400 |  | BNL | Hock, John | S311110 | 2.03 | 16729 | 2.03 | Yes | C-AD | S311110 |  |  |  |  |  |  |  |  |  |
| S311200 |  | Carriage Cradle - Vendor Leadtime |  | 48d | 2020-05-06 A | 2020-09-01 A | S311100 SS, S311110 SS | 100% |  | 2020-05-06 | 2020-07-14 |  |  |  |  |  |  | MP6LAEXCLUDE | 190317 ELM remove proc nos. | S311200 | 0 | S271450 | NOCA | Not Started | C | Mills, Jim | L4 | BNL | Procurement | Chris Pontieri | null | POM02.2.03.01 |  |  | C | 012 | 01 |  | S270200 |  | BNL | Hock, John | S311200 |  |  |  |  |  |  |  |  |  |  |  |  |  |  |  |
| S311500 |  | Carriage Cradle - Assembly Fixtures & Survey Tooling Engineering - Physics Resource(s) |  | 20d | 2020-05-14 A | 2020-10-30 A | S310500, S312000, S310510, S312010 | 100% |  | 2020-07-14 | 2020-08-10 |  |  |  |  | TECH3 PO D [80 h] | 9,129.77 |  |  | PO&AD | 0 | S2716010 | CA | Not Started | C | Mills, Jim | L4 | BNL | Design | Chris Pontieri | null | POM02.2.03.01 |  |  | C |  | 01 |  |  |  | BNL | Hock, John | S311500 | 2.03 | 16729 | 2.03 |  | PO |  |  |  |  |  |  |  |  |  |  |
| S311510 |  | Carriage Cradle - Assembly Fixtures & Survey Tooling Engineering - CA-D Resource(s) |  | 20d | 2020-05-14 A | 2020-10-30 A | S311500 SS | 100% |  | 2020-07-14 | 2020-08-10 |  |  |  |  | PROF4 AD [160 h]; PROF5 AD [80 h]; TECH3 AD [80 h] | 46,297.22 |  |  | PO&ADS311510 | 0 | S2716010 | CA | Not Started | C | Mills, Jim | L4 | BNL | Design | Chris Pontieri | null | POM02.2.03.01 |  |  | C |  | 01 |  |  |  | BNL | Hock, John | S311510 | 2.03 | 16729 | 2.03 |  | C-AD | S311510 |  |  |  |  |  |  |  |  |  |
| OBLG311010 |  | Carriage Cradle - Obligation |  | 1d | 2020-07-01 A | 2020-07-01 A | S310900, S310910 | 100% |  | 2020-08-03 | 2020-08-03 |  |  |  |  | Obligation Resource [1250672 h] | 1,250,672.37 |  |  | S311000 | 0 | S27130002 |  | Not Started | C | Mills, Jim | L4 | BNL | Procurement | Chris Pontieri | null | POM02.2.03.01 |  |  |  |  | 01 |  |  |  | BNL | Hock, John |  |  |  |  |  |  |  | PP5 | MP209100 | OBLG |  |  |  |  |  |  |
| S311350 |  | Carriage Cradle - Delivery Acceptance - M&S |  | 5d | 2020-07-01 A | 2020-07-02 A | S311200 | 100% |  | 2020-08-04 | 2020-08-10 |  |  |  |  | Material (Purchase (1st $2M) [204848 h] | 233,101.82 |  |  |  | 0 | S271500 | CA | Not Started | C | Mills, Jim | M5 | BNL | Procurement | Chris Pontieri | null | POM02.2.03.01 |  |  | C | 012 | 01 |  | S271500 |  | BNL | Hock, John | S311350 | 2.03 | 16729 | 2.03 |  | PO |  | PP6 | MP209100 | FAB |  | Delivery | UDF_G2 | UDF_G1 | 233101.82223 | 1 |
| S312300 |  | CC Drive & Alignment System - Prepare Procurement Package - Physics Resource(s) |  | 5d | 2020-07-28 A | 2020-10-21 A | S312200, S312210 | 100% |  | 2020-07-28 | 2020-08-03 |  |  |  |  | TECH3 PO D [20 h] | 2,282.44 |  | 190317 ELM remove proc nos. | PO&AD | 0 | S2716124 | CA | Not Started | C | Mills, Jim | L4 | BNL | Procurement | Chris Pontieri | null | POM02.2.03.01 |  |  | C | 003 | 01 |  |  |  | BNL | Hock, John | S312300 | 2.03 | 16729 | 2.03 |  | PO |  |  |  |  |  |  |  |  |  |  |
| S312310 |  | CC Drive & Alignment System - Prepare Procurement Package - CA-D Resource(s) |  | 5d | 2020-07-28 A | 2020-10-21 A | S312300 SS | 100% |  | 2020-07-28 | 2020-08-03 |  |  |  |  | PROF4 AD [20 h]; PROF5 AD [8 h]; TECH3 AD [20 h] | 6,588.25 |  | 190317 ELM remove proc nos. | PO&ADS312310 | 0 | S2716124 | CA | Not Started | C | Mills, Jim | L4 | BNL | Procurement | Chris Pontieri | null | POM02.2.03.01 |  |  | C | 003 | 01 |  |  |  | BNL | Hock, John | S312310 | 2.03 | 16729 | 2.03 |  | C-AD | S312310 |  |  |  |  |  |  |  |  |  |
| S311300 |  | Carriage Cradle - Delivery Acceptance - Physics Resource(s) - Labor |  | 20d | 2020-09-02 A | 2020-12-30 A | S311200 | 100% |  | 2020-09-02 | 2020-09-30 |  |  |  |  | TECH3 PO D [16 h]; TECH3 PO M [80 h] | 10,955.73 |  | 190317 ELM remove proc nos. | PO&AD | 0 | S271500 | CA | Not Started | C | Mills, Jim | M5 | BNL | Procurement | Chris Pontieri | null | POM02.2.03.01 |  |  | C | 012 | 01 |  | S271500 |  | BNL | Hock, John | S311300 | 2.03 | 16729 | 2.03 |  | PO |  |  |  |  |  |  |  |  |  |  |
| S311310 |  | Carriage Cradle - Delivery Acceptance - CA-D Resource(s) - Labor |  | 20d | 2020-09-02 A | 2020-12-30 A | S311300 SS | 100% |  | 2020-09-02 | 2020-09-30 |  |  |  |  | PROF4 AD [32 h]; PROF5 AD [8 h]; TECH3 AD [16 h] | 7,898.94 |  | 190317 ELM remove proc nos. | PO&ADS311310 | 0 | S271500 | CA | Not Started | C | Mills, Jim | M5 | BNL | Procurement | Chris Pontieri | null | POM02.2.03.01 |  |  | C | 012 | 01 |  | S271500 |  | BNL | Hock, John | S311310 | 2.03 | 16729 | 2.03 |  | C-AD | S311310 |  |  |  |  |  |  |  |  |  |

Notes:
- S309400: BNL_UDF_Old Activity Name 181221: Actuals - Nonlabor - sPHENIX Infrastructure FY17
- S309600: BNL_UDF_Old Activity Name 181221: Carriage Cradle - Create Overall Preliminary Layout
- S309700: BNL_UDF_Old Activity Name 181221: Carriage Cradle - Perform Analyses, Design & System Integration (Initial)
- S1001799: BNL_UDF_Old Activity Name 181221: Actuals - Labor - sPHENIX Infrastructure FY18
- S310000: BNL_UDF_Old Activity Name 181221: Carriage Cradle - Create Assembly & Detail Drawings
- S310010: BNL_UDF_Old Activity Name 181221: Carriage Cradle - Create Assembly & Detail Drawings
- S309800: BNL_UDF_Old Activity Name 181221: Carriage Cradle - Perform Analyses, Design & System Integration (Final)
- S309810: BNL_UDF_Old Activity Name 181221: Carriage Cradle - Perform Analyses, Design & System Integration (Final)
- S314700: BNL_UDF_Old Activity Name 181221: Track Modifications - Structural Analysis of Existing Track System & Preliminary Design
- S314710: BNL_UDF_Old Activity Name 181221: Track Modifications - Structural Analysis of Existing Track System & Preliminary Design
- S309900: BNL_UDF_Old Activity Name 181221: Carriage Cradle - Preliminary Design Review (Assembly, System Integration, Final Layout)
- S309910: BNL_UDF_Old Activity Name 181221: Carriage Cradle - Preliminary Design Review (Assembly, System Integration, Final Layout)
- S1004880: BNL_UDF_Old Activity Name 181221: Actuals - Labor - sPHENIX Infrastructure FY18
- S310005: BNL_UDF_Old Activity Name 181221: Carriage Cradle - Create Assembly & Detail Drawings
- S310015: BNL_UDF_Old Activity Name 181221: Carriage Cradle - Create Assembly & Detail Drawings
- S314705: BNL_UDF_Old Activity Name 181221: Track Modifications - Structural Analysis of Existing Track System & Preliminary Design
- S314715: BNL_UDF_Old Activity Name 181221: Track Modifications - Structural Analysis of Existing Track System & Preliminary Design
- S310100: BNL_UDF_Old Activity Name 181221: Carriage Cradle - Final Review (Design & Safety)
- S310110: BNL_UDF_Old Activity Name 181221: Carriage Cradle - Final Review (Design & Safety)
- S310200: BNL_UDF_Old Activity Name 181221: Carriage Cradle - Address Action Items from Design & Safety Reviews
- S310210: BNL_UDF_Old Activity Name 181221: Carriage Cradle - Address Action Items from Design & Safety Reviews
- S310201: BNL_UDF_Old Activity Name 181221: Carriage Cradle - Address Action Items from Design & Safety Reviews
- S310211: BNL_UDF_Old Activity Name 181221: Carriage Cradle - Address Action Items from Design & Safety Reviews
- S310400: BNL_UDF_Old Activity Name 181221: Carriage Cradle - Prepare Procurement Package(s)
- S310410: BNL_UDF_Old Activity Name 181221: Carriage Cradle - Prepare Procurement Package(s)
- OBLG315810: BNL_UDF_Old Activity Name 181221: Track Modifications - Contract Award(s)
- S310006: BNL_UDF_Old Activity Name 181221: Carriage Cradle - Create Assembly & Detail Drawings
- S310016: BNL_UDF_Old Activity Name 181221: Carriage Cradle - Create Assembly & Detail Drawings
- S314716: BNL_UDF_Old Activity Name 181221: Track Modifications - Structural Analysis of Existing Track System & Preliminary Design
- S311800: BNL_UDF_Old Activity Name 181221: CC Drive & Alignment System - Engineering (re-engineer & use STAR controller?)
- S311810: BNL_UDF_Old Activity Name 181221: CC Drive & Alignment System - Engineering (re-engineer & use STAR controller?)
- S313300: BNL_UDF_Old Activity Name 181221: CC Seismic Restraints - Engineer & Analysis
- S315010: BNL_UDF_Old Activity Name 181221: Track Modifications - Final Design Reviews (Design & Safety)
- S310300: BNL_UDF_Old Activity Name 181221: Carriage Cradle - Design & Safety Reviews Complete Released for Production
- S315110: BNL_UDF_Old Activity Name 181221: Track Modifications - Address Action Items from Design & Safety Reviews
- S310500: BNL_UDF_Old Activity Name 181221: Carriage Cradle - Procurement Readiness Review
- S310510: BNL_UDF_Old Activity Name 181221: Carriage Cradle - Procurement Readiness Review
- S315900: BNL_UDF_Old Activity Name 181221: Track Modifications - BNL Oversight
- S315910: BNL_UDF_Old Activity Name 181221: Track Modifications - BNL Oversight
- S310600: BNL_UDF_Old Activity Name 181221: Carriage Cradle - Provide Requirement to Procurement
- S311900: BNL_UDF_Old Activity Name 181221: CC Drive & Alignment System - Design Carriage Controls & Limits
- S310700: BNL_UDF_Old Activity Name 181221: Carriage Cradle - Prepare & Send Solicitation
- S313400: BNL_UDF_Old Activity Name 181221: CC Seismic Restraints - Assembly & Detail Drawings
- S313410: BNL_UDF_Old Activity Name 181221: CC Seismic Restraints - Assembly & Detail Drawings
- S310800: BNL_UDF_Old Activity Name 181221: Carriage Cradle - Vendor Responses
- S310810: BNL_UDF_Old Activity Name 181221: Carriage Cradle - Vendor Responses
- S315915: BNL_UDF_Old Activity Name 181221: Track Modifications - Vendor Leadtime
- S315925: BNL_UDF_Old Activity Name 181221: Track Modifications - Vendor Leadtime
- S310900: BNL_UDF_Old Activity Name 181221: Carriage Cradle - Vendor Selection
- S310910: BNL_UDF_Old Activity Name 181221: Carriage Cradle - Vendor Selection
- S312000: BNL_UDF_Old Activity Name 181221: CC Drive & Alignment System - Assembly & Detail Drawings
- S312010: BNL_UDF_Old Activity Name 181221: CC Drive & Alignment System - Assembly & Detail Drawings
- S311000: BNL_UDF_Old Activity Name 181221: Carriage Cradle - Contract Award(s)
- S312100: BNL_UDF_Old Activity Name 181221: CC Drive & Alignment System - Final Design Reviews (Design & Safety)
- S312110: BNL_UDF_Old Activity Name 181221: CC Drive & Alignment System - Final Design Reviews (Design & Safety)
- S312200: BNL_UDF_Old Activity Name 181221: CC Drive & Alignment System - Address Action Items from Design & Safety Reviews
- S312210: BNL_UDF_Old Activity Name 181221: CC Drive & Alignment System - Address Action Items from Design & Safety Reviews
- S311100: BNL_UDF_Old Activity Name 181221: Carriage Cradle - BNL Oversight
- S311110: BNL_UDF_Old Activity Name 181221: Carriage Cradle - BNL Oversight
- S311200: BNL_UDF_Old Activity Name 181221: Carriage Cradle - Vendor Leadtime
- S311500: BNL_UDF_Old Activity Name 181221: Carriage Cradle - Assembly Fixtures & Survey Tooling Engineering
- S311510: BNL_UDF_Old Activity Name 181221: Carriage Cradle - Assembly Fixtures & Survey Tooling Engineering
- OBLG311010: BNL_UDF_Old Activity Name 181221: Carriage Cradle - Contract Award(s)
- S311350: BNL_UDF_Old Activity Name 181221: Carriage Cradle - Delivery Acceptance
- S312300: BNL_UDF_Old Activity Name 181221: CC Drive & Alignment System - Prepare Procurment Package
- S312310: BNL_UDF_Old Activity Name 181221: CC Drive & Alignment System - Prepare Procurment Package
- S311300: BNL_UDF_Old Activity Name 181221: Carriage Cradle - Delivery Acceptance
- S311310: BNL_UDF_Old Activity Name 181221: Carriage Cradle - Delivery Acceptance

| ID | Activity | Type | Duration | Start | Finish | Predecessors | Complete | Remaining | Planned start | Planned finish | Total float | Free float | Constraint | Expected finish | Resources | Cost | BNL_UDF_Status Comments | BNL_UDF_Temp Text 01 | BNL_UDF_Percent Complete | BNL_UDF_Old Activity ID 181221 | BNL_Cobra WP | RG Check | BNL_Activity Status | BNL_Fund Source | BNL_Estimator | BNL_Cost Basis | BNL_Location | BNL_EDIA | BNL_CAM | BNL_Institution | BNL_OPC TEC (deprecated) | BNL_WBS | BNL_WBS Manager | BNL_EVT | BNL_Master Control Account | BNL_Account Number | BNL_PCR ID | BNL_Cobra Control Account | BNL_WBS_Hierarchical | Temp | BNL_UDF_Temp Text 02 | BNL_UDF_OPC TEC (deprecated) | BNL_UDF_Temp Date 01 | BNL_Proc Sig Phase | BNL_Proc Sig | BNL_UDF_Exclude | Indicator - Procurement | Indicator - Float | BNL_UDF_Remaining Tot Cost | BNL_UDF_Percent_remaining | BNL_Obligation | Additional EVT documentation required | BNL_Milestone Level | SPH Proc Register | Variance | Target Milestone Date | PMP Milestones |
| --- | --- | --- | --- | --- | --- | --- | --- | --- | --- | --- | --- | --- | --- | --- | --- | --- | --- | --- | --- | --- | --- | --- | --- | --- | --- | --- | --- | --- | --- | --- | --- | --- | --- | --- | --- | --- | --- | --- | --- | --- | --- | --- | --- | --- | --- | --- | --- | --- | --- | --- | --- | --- | --- | --- | --- | --- | --- |
| S312400 | CC Drive & Alignment System - Procurement Readiness Review - Physics Resource(s) |  | 5d | 2020-10-01 A | 2020-10-07 A | S312300, S312310 | 100% |  |  |  |  |  |  |  | TECH3 PO D [20 h] | 2,350.92 | 190317 ELM remove proc nos. | PO&AD | 0 | S2716126 | S312400 | CA | Not Started | C | Mills, Jim | L4 | BNL | Procurement | Chris Pontieri | BNL | null | POM02.2.03.01 | Hock, John | C | 2.03 | 16729 | 003 | 2.03 | 01 | PO |  |  |  |  |  |  |  |  |  |  |  |  |  |  |  |  |  |
| S312410 | CC Drive & Alignment System - Procurement Readiness Review - CA-D Resource(s) |  | 5d | 2020-10-01 A | 2020-10-07 A | S312400 SS | 100% |  |  |  |  |  |  |  | PROF4 AD [20 h]; PROF5 AD [8 h]; TECH3 AD [20 h] | 6,785.9 | 190317 ELM remove proc nos. | PO&ADS312410 | 0 | S2716126 | S312410 | CA | Not Started | C | Mills, Jim | L4 | BNL | Procurement | Chris Pontieri | BNL | null | POM02.2.03.01 | Hock, John | C | 2.03 | 16729 | 003 | 2.03 | 01 | C-AD | S312410 |  |  |  |  |  |  |  |  |  |  |  |  |  |  |  |  |
| S312500 | CC Drive & Alignment System - Provide Requirement to Procurement |  | 5d | 2020-10-08 A | 2020-10-15 A | S312400, S312410 | 100% |  |  |  |  |  |  |  | PROF5 AD [8 h] | 1,401.32 |  | S312500 | 0 | S2716128 | S312500 | CA | Not Started | C | Mills, Jim | L4 | BNL | Procurement | Chris Pontieri | BNL | null | POM02.2.03.01 | Hock, John | C | 2.03 | 16729 |  | 2.03 | 01 |  |  | S273400 | 2018-08-01 | PP1 | MP209104 |  |  |  |  |  |  |  |  |  |  |  |  |
| S311600 | Carriage Cradle - Assembly Fixtures & Survey Tooling Design - Physics Resource(s) |  | 20d | 2020-10-14 A | 2020-10-30 A | S311500, S311510 | 100% |  | 2020-11-23 | 2020-12-22 |  |  |  |  | TECH3 PO D [80 h] | 9,403.66 |  | PO&AD | 0 | S2716020 | S311600 | CA | Not Started | C | Mills, Jim | L4 | BNL | Design | Chris Pontieri | BNL | null | POM02.2.03.01 | Hock, John | C | 2.03 | 16729 |  | 2.03 | 01 | PO |  |  |  |  |  |  |  |  |  |  |  |  |  |  |  |  |  |
| S311610 | Carriage Cradle - Assembly Fixtures & Survey Tooling Design - CA-D Resource(s) |  | 20d | 2020-10-14 A | 2020-10-30 A | S311600 SS | 100% |  | 2020-11-23 | 2020-12-22 |  |  |  |  | PROF4 AD [160 h]; PROF5 AD [80 h]; TECH3 AD [80 h] | 47,686.13 |  | PO&ADS311610 | 0 | S2716020 | S311610 | CA | Not Started | C | Mills, Jim | L4 | BNL | Design | Chris Pontieri | BNL | null | POM02.2.03.01 | Hock, John | C | 2.03 | 16729 |  | 2.03 | 01 | C-AD | S311610 |  |  |  |  |  |  |  |  |  |  |  |  |  |  |  |  |
| S311700 | Carriage Cradle - Fabricate Fixtures & Tooling |  | 40d | 2020-10-14 A | 2020-10-30 A | S311600, S311610 | 100% |  | 2020-12-23 | 2021-02-22 |  |  |  |  |  |  |  | S311700 | 0 | S2716030 |  | NOCA | Not Started | C | Mills, Jim | L4 | BNL | Fab & Assy | Chris Pontieri | BNL | null | POM02.2.03.01 | Hock, John |  |  |  | 008C |  | 01 |  |  |  |  |  |  |  |  |  |  |  |  |  |  |  |  |  |  |
| S316000 | Steel Track Modifications - Finish Track Work M&S |  | 60d | 2020-10-15 A | 2021-08-30 | S315910, S274300 | 95% | 64d | 2020-10-15 | 2021-01-13 | 101d | 0d | start on or after 2020-10-15 | 2021-08-30 | Material (Purchase (1st $2M) [20000 h] | 23,213.69 |  | S316000 | 0 | S2716596 | S316000 | CA | Not Started | C | Mills, Jim | L4 | BNL | Procurement | Chris Pontieri | BNL | null | POM02.2.03.01 | Hock, John | C | 2.03 | 16729 | 016 | 2.03 | 01 |  |  | S270200 |  | PP6 | MP209106 | MP6LAEXCLUDE | UDF_G1 | UDF_G3 | 23213.6862 | 1 | FAB |  |  |  |  |  |  |
| S316005 | Steel Track Modifications - Finish Track Work Labor |  | 5d | 2020-10-15 A | 2021-08-30 | S316000 FF, S274300 | 95% | 64d | 2021-01-07 | 2021-01-13 | 101d | 0d | start on or after 2020-07-15 | 2021-08-30 | PROF3 AD [24 h]; CRAFT3 [40 h] | 8,280.25 |  | S316000 | 0 | S2716596 | S316005 | CA | Not Started | C | Mills, Jim | L4 | BNL | Procurement | Chris Pontieri | BNL | null | POM02.2.03.01 | Hock, John | C | 2.03 | 16729 |  | 2.03 | 01 |  |  | S270200 |  | PP6 | MP209106 | MP6LAEXCLUDE |  |  |  |  |  |  |  |  |  |  |  |
| S312600 | CC Drive & Alignment System - Prepare & Send Solicitation |  | 5d | 2020-10-16 A | 2020-10-28 A | S312500 | 100% |  | 2020-10-16 | 2020-10-22 |  |  |  |  |  |  |  | S312600 | 0 | S2716130 |  | NOCA | Not Started |  | Mills, Jim | L4 | BNL | Procurement | Chris Pontieri | BNL | null | POM02.2.03.01 | Hock, John |  |  |  |  |  | 01 |  |  |  | 2018-08-01 | PP2 | MP209104 |  |  |  |  |  |  |  |  |  |  |  |  |
| S312700 | CC Drive & Alignment System - Vendor Responses - Physics Resource(s) |  | 10d | 2020-10-23 A | 2020-10-28 A | S312600 | 100% |  | 2020-10-23 | 2020-11-05 |  |  |  |  | TECH3 PO D [18 h] | 2,115.82 |  | PO&AD | 0 | S2716132 | S312700 | CA | Not Started | C | Mills, Jim | L4 | BNL | Procurement | Chris Pontieri | BNL | null | POM02.2.03.01 | Hock, John | C | 2.03 | 16729 |  | 2.03 | 01 | PO |  |  |  | PP3 | MP209104 |  |  |  |  |  |  |  |  |  |  |  |  |
| S312710 | CC Drive & Alignment System - Vendor Responses - CA-D Resource(s) |  | 10d | 2020-10-23 A | 2020-10-28 A | S312700 SS | 100% |  | 2020-10-23 | 2020-11-05 |  |  |  |  | PROF4 AD [18 h]; PROF5 AD [8 h]; TECH3 AD [18 h] | 6,247.44 |  | PO&ADS312710 | 0 | S2716132 | S312710 | CA | Not Started | C | Mills, Jim | L4 | BNL | Procurement | Chris Pontieri | BNL | null | POM02.2.03.01 | Hock, John | C | 2.03 | 16729 |  | 2.03 | 01 | C-AD | S312710 |  |  | PP3 | MP209104 |  |  |  |  |  |  |  |  |  |  |  |  |
| S312800 | CC Drive & Alignment System - Vendor Selection - Physics Resource(s) |  | 10d | 2020-10-23 A | 2020-10-28 A | S312700, S312710 | 100% |  | 2020-11-06 | 2020-11-20 |  |  |  |  | TECH3 PO D [18 h]; TECH3 PO M [36 h] | 6,347.47 |  | PO&AD | 0 | S2716134 | S312800 | CA | Not Started | C | Mills, Jim | L4 | BNL | Procurement | Chris Pontieri | BNL | null | POM02.2.03.01 | Hock, John | C | 2.03 | 16729 |  | 2.03 | 01 | PO |  | S271300 |  | PP4 | MP209104 |  |  |  |  |  |  |  |  |  |  |  |  |
| S312810 | CC Drive & Alignment System - Vendor Selection - CA-D Resource(s) |  | 10d | 2020-10-23 A | 2020-10-28 A | S312800 SS | 100% |  | 2020-11-06 | 2020-11-20 |  |  |  |  | PROF4 AD [18 h]; PROF5 AD [8 h]; TECH3 AD [18 h] | 6,247.44 |  | PO&ADS312810 | 0 | S2716134 | S312810 | CA | Not Started | C | Mills, Jim | L4 | BNL | Procurement | Chris Pontieri | BNL | null | POM02.2.03.01 | Hock, John | C | 2.03 | 16729 |  | 2.03 | 01 | C-AD | S312810 | S271300 |  | PP4 | MP209104 |  |  |  |  |  |  |  |  |  |  |  |  |
| S313000 | CC Drive & Alignment System - BNL Oversight - Physics Resource(s) |  | 40d | 2020-11-03 A | 2021-04-15 A | S312900, OBLG312910 | 100% |  | 2020-11-03 | 2021-01-04 |  |  |  |  | TECH3 PO D [10 h]; TECH3 PO M [40 h] | 5,877.29 | 190317 ELM remove proc nos.; 19315 DurType to align with EVT | PO&AD | 0 | S2716138 | S313000 | CA | Not Started | C | Mills, Jim | L4 | BNL | Procurement | Chris Pontieri | BNL | null | POM02.2.03.01 | Hock, John | A | 2.03 | 16729 | 003 | 2.03 | 01 | PO |  | S271400 |  |  |  |  |  |  |  |  |  | Yes |  |  |  |  |  |
| S313010 | CC Drive & Alignment System - BNL Oversight - CA-D Resource(s) |  | 40d | 2020-11-03 A | 2021-04-15 A | S313000 SS | 100% |  | 2020-11-03 | 2021-01-04 |  |  |  |  | PROF4 AD [20 h]; PROF5 AD [20 h]; TECH3 AD [10 h] | 7,712.42 | 190317 ELM remove proc nos.; 19315 DurType to align with EVT | PO&ADS313010 | 0 | S2716138 | S313010 | CA | Not Started | C | Mills, Jim | L4 | BNL | Procurement | Chris Pontieri | BNL | null | POM02.2.03.01 | Hock, John | A | 2.03 | 16729 | 003 | 2.03 | 01 | C-AD | S313010 | S271400 |  |  |  |  |  |  |  |  |  | Yes |  |  |  |  |  |
| S313100 | CC Drive & Alignment System - Vendor Leadtime |  | 40d | 2020-11-03 A | 2021-04-15 A | S313000 SS, S313010 SS | 100% |  | 2020-11-03 | 2021-01-04 |  |  |  |  |  |  | 190317 ELM remove proc nos. | S313100 | 0 | S2716140 |  | NOCA | Not Started | C | Mills, Jim | L4 | BNL | Procurement | Chris Pontieri | BNL | null | POM02.2.03.01 | Hock, John | C |  |  | 003 |  | 01 |  |  | S270200 |  |  |  | MP6LAEXCLUDE |  |  |  |  |  |  |  |  |  |  |  |
| S312900 | CC Drive & Alignment System - Contract Award(s) | milestone | 0d | 2020-11-30 A | 2020-11-30 A | S312800, S312810 | 100% |  | 2020-11-02 | 2020-11-02 |  |  |  |  |  |  |  | S312900 | 0 | S2716136 |  | NOCA | Not Started | C | Mills, Jim | L4 | BNL | Procurement | Chris Pontieri | BNL | null | POM02.2.03.01 | Hock, John |  |  |  |  |  | 01 |  |  |  |  | PP5 | MP209104 |  |  |  |  |  |  |  | L5 | Contract Award |  |  |  |
| OBLG312910 | CC Drive & Alignment System - Obligation |  | 1d | 2020-12-01 A | 2020-12-01 A | S312800, S312810 | 100% |  |  |  |  |  |  |  | Obligation Resource [65671.5 h] | 65,671.53 |  | S312900 | 0 | S2716136 |  |  | Not Started | C | Mills, Jim | L4 | BNL | Procurement | Chris Pontieri | BNL | null | POM02.2.03.01 | Hock, John |  |  |  |  |  | 01 |  |  |  |  | PP5 | MP209104 |  |  |  |  |  | OBLG |  |  |  |  |  |  |
| S311355 | Carriage Cradle - Delivery Acceptance Two - M&S |  | 5d | 2020-12-21 A | 2020-12-31 A | S311350 FS+122d | 100% |  | 2020-12-30 | 2021-01-06 |  |  |  |  | Material (Purchase (1st $2M) [1101666 h] | 1,278,686.44 |  |  | 0 | S271500 | S311355 | CA | Not Started | C | Mills, Jim | M5 | BNL | Procurement | Chris Pontieri | BNL | null | POM02.2.03.01 | Hock, John | C | 2.03 | 16729 | 012 | 2.03 | 01 |  |  | S271500 |  | PP6 | MP209100 |  | UDF_G3 | UDF_G1 | 1278686.44106 | 1 | FAB |  |  |  | 0 |  |  |
| S313200 | CC Drive & Alignment System - Delivery Acceptance - Physics Resource(s) - Labor |  | 5d | 2021-04-12 A | 2021-04-15 A | S313000, S313100, S313010 | 100% |  | 2021-05-18 | 2021-05-24 |  |  |  |  | TECH3 PO D [16 h]; TECH3 PO M [80 h] | 11,284.4 | 190317 ELM remove proc nos. | PO&AD | 0 | S2716150 | S313200 | CA | Not Started | C | Mills, Jim | M5 | BNL | Procurement | Chris Pontieri | BNL | null | POM02.2.03.01 | Hock, John | C | 2.03 | 16729 | 012 | 2.03 | 01 | PO |  | S271500 |  |  |  |  |  |  |  |  |  |  |  |  |  |  |  |
| S313210 | CC Drive & Alignment System - Delivery Acceptance - CA-D Resource(s) - Labor |  | 5d | 2021-04-12 A | 2021-04-15 A | S313200 SS | 100% |  | 2021-05-18 | 2021-05-24 |  |  |  |  | PROF4 AD [32 h]; PROF5 AD [4 h]; TECH3 AD [16 h] | 7,435.25 | 190317 ELM remove proc nos. | PO&ADS313210 | 0 | S2716150 | S313210 | CA | Not Started | C | Mills, Jim | M5 | BNL | Procurement | Chris Pontieri | BNL | null | POM02.2.03.01 | Hock, John | C | 2.03 | 16729 | 012 | 2.03 | 01 | C-AD | S313210 | S271500 |  |  |  |  |  |  |  |  |  |  |  |  |  |  |  |
| S313250 | CC Drive & Alignment System - Delivery Acceptance - M&S |  | 5d | 2021-04-12 A | 2021-04-15 A | S313000, S313100, S313010 | 100% |  | 2021-05-18 | 2021-05-24 |  |  |  |  | Material (Purchase (1st $2M) [56580 h] | 65,671.52 |  |  | 0 | S2716150 | S313250 | CA | Not Started | C | Mills, Jim | M5 | BNL | Procurement | Chris Pontieri | BNL | null | POM02.2.03.01 | Hock, John | C | 2.03 | 16729 | 012 | 2.03 | 01 | PO |  | S271500 |  | PP6 | MP209104 |  | UDF_G1 | UDF_G1 | 65671.51826 | 1 | FAB |  |  | Contract Award |  |  |  |
| S311400 | Carriage Cradle - Components Ready for Installation | milestone | 0d | 2021-04-15 A | 2021-04-15 A | S311300 FF, S311700, S313200, S311350 FF, S311310 FF, S313210, S313255, S311355 | 100% |  | 2021-05-24 | 2021-05-24 |  |  |  |  |  |  |  | S311400 | 0 | S271600 | S311400 | NOCA | Not Started | C | Mills, Jim | L4 | BNL | Procurement | Chris Pontieri | BNL | null | POM02.2.03.01 | Hock, John |  |  |  | 012 |  | 01 |  |  | S271600 |  |  |  |  |  |  |  |  |  |  | L3 |  | 32 | 2021-05-31 | PMP_2x |
| S313255 | Completed - CC Drive & Alignment System - Delivery Acceptance - M&S | milestone | 0d | 2021-04-15 A | 2021-04-15 A | S313250 FF | 100% |  | 2021-05-24 | 2021-05-24 |  |  |  |  |  |  |  |  | 0 | S2716150 |  | NOCA | Not Started | C | Mills, Jim |  | BNL | Procurement | Chris Pontieri | BNL |  | POM02.2.03.01 | Hock, John |  |  |  |  |  | 01 | PO |  | S271500 |  |  |  |  |  |  |  |  |  |  | L5 |  |  |  |  |
| S313500 | CC Seismic Restraints - Final Design Reviews (Design & Safety) - Physics Resource(s) |  | 5d | 2021-06-18 | 2021-06-24 | S313400, S313410 |  |  |  |  | 29d | 0d |  |  | TECH3 PO D [20 h] | 2,350.92 |  | PO&AD | 0 | S2716250 | S313500 | CA | Not Started | C | Mills, Jim | L4 | BNL | Design | Chris Pontieri | BNL | null | POM02.2.03.01 | Hock, John | C | 2.03 | 16729 |  | 2.03 | 01 | PO |  |  |  |  |  |  |  |  |  |  |  |  |  |  |  |  |  |
| S313510 | CC Seismic Restraints - Final Design Reviews (Design & Safety) - CA-D Resource(s) |  | 5d | 2021-06-18 | 2021-06-24 | S313500 SS |  |  |  |  | 29d | 0d |  |  | PROF4 AD [40 h]; TECH3 AD [20 h] | 8,418.23 |  | PO&ADS313510 | 0 | S2716250 | S313510 | CA | Not Started | C | Mills, Jim | L4 | BNL | Design | Chris Pontieri | BNL | null | POM02.2.03.01 | Hock, John | C | 2.03 | 16729 |  | 2.03 | 01 | C-AD | S313510 |  |  |  |  |  |  |  |  |  |  |  |  |  |  |  |  |
| S313600 | CC Seismic Restraints - Address Action Items from Design & Safety Reviews - Physics Resource(s) |  | 5d | 2021-06-25 | 2021-07-01 | S313500, S313510 |  |  |  |  | 29d | 0d |  |  | TECH3 PO D [20 h] | 2,350.92 |  | PO&AD | 0 | S2716260 | S313600 | CA | Not Started | C | Mills, Jim | L4 | BNL | Management Tech Reviews | Chris Pontieri | BNL | null | POM02.2.03.01 | Hock, John | C | 2.03 | 16729 |  | 2.03 | 01 | PO |  |  |  |  |  |  |  |  |  |  |  |  |  |  |  |  |  |
| S313610 | CC Seismic Restraints - Address Action Items from Design & Safety Reviews - CA-D Resource(s) |  | 5d | 2021-06-25 | 2021-07-01 | S313600 SS |  |  |  |  | 29d | 0d |  |  | PROF4 AD [40 h]; PROF5 AD [20 h]; TECH3 AD [20 h] | 11,921.53 |  | PO&ADS313610 | 0 | S2716260 | S313610 | CA | Not Started | C | Mills, Jim | L4 | BNL | Management Tech Reviews | Chris Pontieri | BNL | null | POM02.2.03.01 | Hock, John | C | 2.03 | 16729 |  | 2.03 | 01 | C-AD | S313610 |  |  |  |  |  |  |  |  |  |  |  |  |  |  |  |  |
| S313700 | CC Seismic Restraints - Prepare Procurement Package - Physics Resource(s) |  | 5d | 2021-07-02 | 2021-07-09 | S313600, S313610 |  |  |  |  | 29d | 0d |  |  | TECH3 PO D [20 h] | 2,350.92 | 190317 ELM remove proc nos. | PO&AD | 0 | S2716270 | S313700 | CA | Not Started | C | Mills, Jim | L4 | BNL | Procurement | Chris Pontieri | BNL | null | POM02.2.03.01 | Hock, John | C | 2.03 | 16729 | 003 | 2.03 | 01 | PO |  |  |  |  |  |  |  |  |  |  |  |  |  |  |  |  |  |
| S313710 | CC Seismic Restraints - Prepare Procurement Package - CA-D Resource(s) |  | 5d | 2021-07-02 | 2021-07-09 | S313700 SS |  |  |  |  | 29d | 0d |  |  | PROF4 AD [20 h]; PROF5 AD [8 h]; TECH3 AD [20 h] | 6,785.9 | 190317 ELM remove proc nos. | PO&ADS313710 | 0 | S2716270 | S313710 | CA | Not Started | C | Mills, Jim | L4 | BNL | Procurement | Chris Pontieri | BNL | null | POM02.2.03.01 | Hock, John | C | 2.03 | 16729 | 003 | 2.03 | 01 | C-AD | S313710 |  |  |  |  |  |  |  |  |  |  |  |  |  |  |  |  |
| S313800 | CC Seismic Restraints - Procurement Readiness Review - Physics Resource(s) |  | 5d | 2021-07-12 | 2021-07-16 | S313700, S313710 |  |  |  |  | 29d | 0d |  |  | TECH3 PO D [20 h] | 2,350.92 | 190317 ELM remove proc nos. | PO&AD | 0 | S2716280 | S313800 | CA | Not Started | C | Mills, Jim | L4 | BNL | Procurement | Chris Pontieri | BNL | null | POM02.2.03.01 | Hock, John | C | 2.03 | 16729 | 003 | 2.03 | 01 | PO |  |  |  |  |  |  |  |  |  |  |  |  |  |  |  |  |  |
| S313810 | CC Seismic Restraints - Procurement Readiness Review - CA-D Resource(s) |  | 5d | 2021-07-12 | 2021-07-16 | S313800 SS |  |  |  |  | 29d | 0d |  |  | PROF4 AD [20 h]; PROF5 AD [8 h]; TECH3 AD [20 h] | 6,785.9 | 190317 ELM remove proc nos. | PO&ADS313810 | 0 | S2716280 | S313810 | CA | Not Started | C | Mills, Jim | L4 | BNL | Procurement | Chris Pontieri | BNL | null | POM02.2.03.01 | Hock, John | C | 2.03 | 16729 | 003 | 2.03 | 01 | C-AD | S313810 |  |  |  |  |  |  |  |  |  |  |  |  |  |  |  |  |
| S313900 | CC Seismic Restraints - Provide Requirement to Procurement |  | 5d | 2021-07-19 | 2021-07-23 | S313800, S313810 |  |  |  |  | 29d | 0d |  |  | PROF5 AD [8 h] | 1,401.32 |  | S313900 | 0 | S2716284 | S313900 | CA | Not Started | C | Mills, Jim | L4 | BNL | Procurement | Chris Pontieri | BNL | null | POM02.2.03.01 | Hock, John | C | 2.03 | 16729 |  | 2.03 | 01 |  |  | S273400 | 2018-08-01 | PP1 | MP209108 |  |  |  |  |  |  |  |  |  |  |  |  |
| S314000 | CC Seismic Restraints - Prepare & Send Solicitation |  | 5d | 2021-07-26 | 2021-07-30 | S313900 |  |  |  |  | 29d | 0d |  |  |  |  |  | S314000 | 0 | S2716286 |  | NOCA | Not Started | C | Mills, Jim | L4 | BNL | Procurement | Chris Pontieri | BNL | null | POM02.2.03.01 | Hock, John |  |  |  |  |  | 01 |  |  |  | 2018-08-01 | PP2 | MP209108 |  |  |  |  |  |  |  |  |  |  |  |  |
| S314100 | CC Seismic Restraints - Vendor Responses - Physics Resource(s) |  | 30d | 2021-08-02 | 2021-09-13 | S314000 |  |  |  |  | 29d | 0d |  |  | TECH3 PO D [18 h] | 2,115.82 |  | PO&AD | 0 | S2716288 | S314100 | CA | Not Started | C | Mills, Jim | L4 | BNL | Procurement | Chris Pontieri | BNL | null | POM02.2.03.01 | Hock, John | C | 2.03 | 16729 |  | 2.03 | 01 | PO |  |  |  | PP3 | MP209108 |  |  |  |  |  |  |  |  |  |  |  |  |
| S314110 | CC Seismic Restraints - Vendor Responses - CA-D Resource(s) |  | 30d | 2021-08-02 | 2021-09-13 | S314100 SS |  |  |  |  | 29d | 0d |  |  | PROF4 AD [18 h]; PROF5 AD [8 h]; TECH3 AD [18 h] | 6,247.44 |  | PO&ADS314110 | 0 | S2716288 | S314110 | CA | Not Started | C | Mills, Jim | L4 | BNL | Procurement | Chris Pontieri | BNL | null | POM02.2.03.01 | Hock, John | C | 2.03 | 16729 |  | 2.03 | 01 | C-AD | S314110 |  |  | PP3 | MP209108 |  |  |  |  |  |  |  |  |  |  |  |  |
| S316010 | Completed - Steel Track Modifications | milestone | 0d | 2021-08-30 | 2021-08-30 | S316000 FF, S315915, S315925, S316005 |  |  |  |  | 101d | 0d |  |  |  |  |  | S316000 | 0 | S2716596 |  | NOCA | Not Started | C | Mills, Jim |  | BNL | Procurement | Chris Pontieri | BNL |  | POM02.2.03.01 | Hock, John |  |  | 16729 |  |  | 01 |  |  | S270200 |  |  |  | MP6LAEXCLUDE |  |  |  |  |  |  | L5 |  | -107 | 2021-03-31 | PMP_2x |
| S314200 | CC Seismic Restraints - Vendor Selection - Physics Resource(s) |  | 30d | 2021-09-14 | 2021-10-26 | S314100, S314000, S314110 |  |  |  |  | 29d | 0d |  |  | TECH3 PO D [18 h]; TECH3 PO M [36 h] | 6,455.38 |  | PO&AD | 0 | S2716290 | S314200 | CA | Not Started | C | Mills, Jim | L4 | BNL | Procurement | Chris Pontieri | BNL | null | POM02.2.03.01 | Hock, John | C | 2.03 | 16729 |  | 2.03 | 01 | PO |  | S271300 |  | PP4 | MP209108 |  |  |  |  |  |  |  |  |  |  |  |  |
| S314210 | CC Seismic Restraints - Vendor Selection - CA-D Resource(s) |  | 30d | 2021-09-14 | 2021-10-26 | S314200 SS |  |  |  |  | 29d | 0d |  |  | PROF4 AD [18 h]; PROF5 AD [8 h]; TECH3 AD [18 h] | 6,353.64 |  | PO&ADS314210 | 0 | S2716290 | S314210 | CA | Not Started | C | Mills, Jim | L4 | BNL | Procurement | Chris Pontieri | BNL | null | POM02.2.03.01 | Hock, John | C | 2.03 | 16729 |  | 2.03 | 01 | C-AD | S314210 | S271300 |  | PP4 | MP209108 |  |  |  |  |  |  |  |  |  |  |  |  |
| OBLG314310 | CC Seismic Restraints - Obligation |  | 1d | 2021-10-27 | 2021-10-27 | S314200, S314210 |  |  |  |  | 29d | 0d |  |  | Obligation Resource [143379 h] | 143,378.65 |  | S314300 | 0 | S2716292 |  |  | Not Started | C | Mills, Jim | L4 | BNL | Procurement | Chris Pontieri | BNL | null | POM02.2.03.01 | Hock, John |  |  |  |  |  | 01 |  |  |  |  | PP5 | MP209108 |  |  |  |  |  | OBLG |  |  |  |  |  |  |
| S314300 | CC Seismic Restraints - Contract Award(s) | milestone | 0d | 2021-10-27 | 2021-10-27 | S314200, S314210 |  |  |  |  | 30d | 1d |  |  |  |  |  | S314300 | 0 | S2716292 |  | NOCA | Not Started | C | Mills, Jim | L4 | BNL | Procurement | Chris Pontieri | BNL | null | POM02.2.03.01 | Hock, John |  |  |  |  |  | 01 |  |  |  |  | PP5 | MP209108 |  |  |  |  |  |  |  | L5 | Contract Award |  |  |  |
| S314400 | CC Seismic Restraints - BNL Oversight - Physics Resource(s) |  | 180d | 2021-10-28 | 2022-07-19 | S314300, OBLG314310 |  |  |  |  | 29d | 0d |  |  | TECH3 PO D [10 h]; TECH3 PO M [40 h] | 6,053.61 | 190317 ELM remove proc nos.; 19315 DurType to align with EVT | PO&AD | 0 | S2716294 | S314400 | CA | Not Started | C | Mills, Jim | L4 | BNL | Procurement | Chris Pontieri | BNL | null | POM02.2.03.01 | Hock, John | A | 2.03 | 16729 | 012 | 2.03 | 01 | PO |  | S271400 |  |  |  |  |  |  |  |  |  |  |  |  |  |  |  |
| S314410 | CC Seismic Restraints - BNL Oversight - CA-D Resource(s) |  | 180d | 2021-10-28 | 2022-07-19 | S314400 SS |  |  |  |  | 29d | 0d |  |  | PROF4 AD [24 h]; PROF5 AD [24 h]; TECH3 AD [10 h] | 9,290.4 | 190317 ELM remove proc nos.; 19315 DurType to align with EVT | PO&ADS314410 | 0 | S2716294 | S314410 | CA | Not Started | C | Mills, Jim | L4 | BNL | Procurement | Chris Pontieri | BNL | null | POM02.2.03.01 | Hock, John | A | 2.03 | 16729 | 012 | 2.03 | 01 | C-AD | S314410 | S271400 |  |  |  |  |  |  |  |  |  |  |  |  |  |  |  |
| S314500 | CC Seismic Restraints - Vendor Leadtime |  | 180d | 2021-10-28 | 2022-07-19 | S314400 SS, S314410 SS |  |  |  |  | 29d | 0d |  |  |  |  | 190317 ELM remove proc nos. | S314500 | 0 | S2716296 | S314500 | NOCA | Not Started | C | Mills, Jim | L4 | BNL | Procurement | Chris Pontieri | BNL | null | POM02.2.03.01 | Hock, John | C |  |  | 012 |  | 01 |  |  | S270200 |  |  |  | MP6LAEXCLUDE |  |  |  |  |  |  |  |  |  |  |  |
| S314600 | CC Seismic Restraints - Delivery Acceptance - Physics Resource(s) - Labor |  | 5d | 2022-07-20 | 2022-07-26 | S314400, S314500, S314410 |  |  |  |  | 29d | 0d |  |  | TECH3 PO D [4 h]; TECH3 PO M [20 h] | 2,905.73 | 190317 ELM remove proc nos. | PO&AD | 0 | S2716298 | S314600 | CA | Not Started | C | Mills, Jim | M5 | BNL | Procurement | Chris Pontieri | BNL | null | POM02.2.03.01 | Hock, John | C | 2.03 | 16729 | 003 | 2.03 | 01 | PO |  | S271500 |  |  |  |  |  |  |  |  |  |  |  |  |  |  |  |
| S314610 | CC Seismic Restraints - Delivery Acceptance - CA-D Resource(s) - Labor |  | 5d | 2022-07-20 | 2022-07-26 | S314600 SS |  |  |  |  | 29d | 0d |  |  | PROF4 AD [2 h]; PROF5 AD [4 h]; TECH3 AD [4 h] | 1,518.44 | 190317 ELM remove proc nos. | PO&ADS314610 | 0 | S2716298 | S314610 | CA | Not Started | C | Mills, Jim | M5 | BNL | Procurement | Chris Pontieri | BNL | null | POM02.2.03.01 | Hock, John | C | 2.03 | 16729 | 003 | 2.03 | 01 | C-AD | S314610 | S271500 |  |  |  |  |  |  |  |  |  |  |  |  |  |  |  |
| S314650 | CC Seismic Restraints - Delivery Acceptance - M&S |  | 5d | 2022-07-20 | 2022-07-26 | S314400, S314500, S314410 |  |  |  |  | 29d | 0d |  |  | Material (Purchase (1st $2M) [126000 h] | 149,171.15 |  |  | 0 | S2716298 | S314650 | CA | Not Started | C | Mills, Jim | M5 | BNL | Procurement | Chris Pontieri | BNL | null | POM02.2.03.01 | Hock, John | C | 2.03 | 16729 |  | 2.03 | 01 | PO |  | S271500 |  | PP6 | MP209108 |  | UDF_G1 | UDF_G1 | 146246.22306 | 1 | FAB |  |  | Delivery |  |  |  |
| S314655 | Completed - CC Seismic Restraints - Delivery Acceptance - M&S | milestone | 0d | 2022-07-26 | 2022-07-26 | S314650 FF |  |  |  |  | 29d | 0d |  |  |  |  |  |  | 0 | S2716298 |  | NOCA | Not Started | C | Mills, Jim |  | BNL | Procurement | Chris Pontieri | BNL |  | POM02.2.03.01 | Hock, John |  |  |  |  |  | 01 | PO |  | S271500 |  |  |  |  |  |  |  |  |  |  | L5 |  |  |  |  |

Notes:
- S312400: BNL_UDF_Old Activity Name 181221: CC Drive & Alignment System - Procurement Readiness Review
- S312410: BNL_UDF_Old Activity Name 181221: CC Drive & Alignment System - Procurement Readiness Review
- S312500: BNL_UDF_Old Activity Name 181221: CC Drive & Alignment System - Provide Requirement to Procurement
- S311600: BNL_UDF_Old Activity Name 181221: Carriage Cradle - Assembly Fixtures & Survey Tooling Design
- S311610: BNL_UDF_Old Activity Name 181221: Carriage Cradle - Assembly Fixtures & Survey Tooling Design
- S311700: BNL_UDF_Old Activity Name 181221: Carriage Cradle - Fabricate Fixtures & Tooling
- S316000: BNL_UDF_Old Activity Name 181221: Track Modifications - Vendor Leadtime
- S316005: BNL_UDF_Old Activity Name 181221: Track Modifications - Vendor Leadtime
- S312600: BNL_UDF_Old Activity Name 181221: CC Drive & Alignment System - Prepare & Send Solicitation
- S312700: BNL_UDF_Old Activity Name 181221: CC Drive & Alignment System - Vendor Responses
- S312710: BNL_UDF_Old Activity Name 181221: CC Drive & Alignment System - Vendor Responses
- S312800: BNL_UDF_Old Activity Name 181221: CC Drive & Alignment System - Vendor Selection
- S312810: BNL_UDF_Old Activity Name 181221: CC Drive & Alignment System - Vendor Selection
- S313000: BNL_UDF_Old Activity Name 181221: CC Drive & Alignment System - BNL Oversite
- S313010: BNL_UDF_Old Activity Name 181221: CC Drive & Alignment System - BNL Oversite
- S313100: BNL_UDF_Old Activity Name 181221: CC Drive & Alignment System - Vendor Leadtime
- S312900: BNL_UDF_Old Activity Name 181221: CC Drive & Alignment System - Contract Award(s)
- OBLG312910: BNL_UDF_Old Activity Name 181221: CC Drive & Alignment System - Contract Award(s)
- S311355: BNL_UDF_Old Activity Name 181221: Carriage Cradle - Delivery Acceptance
- S313200: BNL_UDF_Old Activity Name 181221: CC Drive & Alignment System - Delivery Acceptance
- S313210: BNL_UDF_Old Activity Name 181221: CC Drive & Alignment System - Delivery Acceptance
- S313250: BNL_UDF_Old Activity Name 181221: CC Drive & Alignment System - Delivery Acceptance
- S311400: BNL_UDF_Old Activity Name 181221: Carriage Cradle - Components Ready for Installation
- S313255: BNL_UDF_Old Activity Name 181221: CC Drive & Alignment System - Delivery Acceptance
- S313500: BNL_UDF_Old Activity Name 181221: CC Seismic Restraints - Final Design Reviews (Design & Safety)
- S313510: BNL_UDF_Old Activity Name 181221: CC Seismic Restraints - Final Design Reviews (Design & Safety)
- S313600: BNL_UDF_Old Activity Name 181221: CC Seismic Restraints - Address Action Items from Design & Safety Reviews
- S313610: BNL_UDF_Old Activity Name 181221: CC Seismic Restraints - Address Action Items from Design & Safety Reviews
- S313700: BNL_UDF_Old Activity Name 181221: CC Seismic Restraints - Prepare Procurement Package
- S313710: BNL_UDF_Old Activity Name 181221: CC Seismic Restraints - Prepare Procurement Package
- S313800: BNL_UDF_Old Activity Name 181221: CC Seismic Restraints - Procurement Readiness Review
- S313810: BNL_UDF_Old Activity Name 181221: CC Seismic Restraints - Procurement Readiness Review
- S313900: BNL_UDF_Old Activity Name 181221: CC Seismic Restraints - Provide Requirement to Procurement
- S314000: BNL_UDF_Old Activity Name 181221: CC Seismic Restraints - Prepare & Send Solicitation
- S314100: BNL_UDF_Old Activity Name 181221: CC Seismic Restraints - Vendor Responses
- S314110: BNL_UDF_Old Activity Name 181221: CC Seismic Restraints - Vendor Responses
- S316010: BNL_UDF_Old Activity Name 181221: Track Modifications - Vendor Leadtime
- S314200: BNL_UDF_Old Activity Name 181221: CC Seismic Restraints - Vendor Selection
- S314210: BNL_UDF_Old Activity Name 181221: CC Seismic Restraints - Vendor Selection
- OBLG314310: BNL_UDF_Old Activity Name 181221: CC Seismic Restraints - Contract Award(s)
- S314300: BNL_UDF_Old Activity Name 181221: CC Seismic Restraints - Contract Award(s)
- S314400: BNL_UDF_Old Activity Name 181221: CC Seismic Restraints - BNL Oversight
- S314410: BNL_UDF_Old Activity Name 181221: CC Seismic Restraints - BNL Oversight
- S314500: BNL_UDF_Old Activity Name 181221: CC Seismic Restraints - Vendor Leadtime
- S314600: BNL_UDF_Old Activity Name 181221: CC Seismic Restraints - Delivery Acceptance
- S314610: BNL_UDF_Old Activity Name 181221: CC Seismic Restraints - Delivery Acceptance
- S314650: BNL_UDF_Old Activity Name 181221: CC Seismic Restraints - Delivery Acceptance
- S314655: BNL_UDF_Old Activity Name 181221: CC Seismic Restraints - Delivery Acceptance

| ID | WBS | Activity | Type | Duration | Start | Finish | Predecessors | Complete | Remaining | Planned start | Planned finish | Total float | Free float | Constraint | Expected finish | Resources | Cost | BNL_UDF_Temp Text 01 | BNL_UDF_Percent Complete | BNL_UDF_OPC TEC (deprecated) | BNL_UDF_Temp Date 01 | BNL_UDF_Old Activity ID 181221 | RG Check | BNL_Activity Status | BNL_Fund Source | BNL_Estimator | BNL_Cost Basis | BNL_Location | BNL_EDIA | BNL_CAM | BNL_Institution | BNL_OPC TEC (deprecated) | BNL_WBS | BNL_WBS_Hierarchical | Completed | BNL_UDF_Exclude | BNL_UDF_Status Comments | BNL_Cobra WP | Indicator - Procurement | BNL_Actuals | BNL_FY | BNL_EVT | BNL_Master Control Account | BNL_Account Number | BNL_PCR ID | BNL_Cobra Control Account | Temp | BNL_UDF_Temp Text 02 | Additional EVT documentation required | BNL_Milestone Level | Indicator - Float | BNL_UDF_Remaining Tot Cost | BNL_UDF_Percent_remaining | BNL_Proc Sig Phase | BNL_Proc Sig | SPH Proc Register | Target Milestone Date | Variance | PMP Milestones | BNL_Obligation |
| --- | --- | --- | --- | --- | --- | --- | --- | --- | --- | --- | --- | --- | --- | --- | --- | --- | --- | --- | --- | --- | --- | --- | --- | --- | --- | --- | --- | --- | --- | --- | --- | --- | --- | --- | --- | --- | --- | --- | --- | --- | --- | --- | --- | --- | --- | --- | --- | --- | --- | --- | --- | --- | --- | --- | --- | --- | --- | --- | --- | --- |
|  | 02 | **Inner Detector Rings and Interface to Mechanical Structural Supports** |  |  | 2017-02-01 | 2021-12-10 |  |  |  |  |  |  |  |  |  |  |  |  |  |  |  |  |  |  |  |  |  |  |  |  |  |  |  |  |  |  |  |  |  |  |  |  |  |  |  |  |  |  |  |  |  |  |  |  |  |  |  |  |  |  |
| S316300 |  | Analyze and Evaluate Structural Support for Internal Detectors FY18 |  | 289d | 2017-02-01 A | 2018-03-28 A | S100090 SS | 100% |  |  |  |  |  |  |  |  |  | S316300 | 100 | S271800 | 2019-01-16 | S271800 | NOCA | Completed | C | Pisani, Rob | L4 | BNL | Design | Chris Pontieri | BNL | null | POM02.2.03.02 | 02 | yes |  |  |  |  |  |  |  |  |  |  |  |  |  |  |  |  |  |  |  |  |  |  |  |  |  |
| S1001759 |  | Actuals - NonLabor - sPHENIX Infrastructure FY19 M8 16731 |  | 166d | 2018-10-01 A | 2019-05-31 A |  | 100% |  |  |  |  |  |  |  | Actual Nonlabor [5225 h] | 5,764.56 | S309300 | 100 |  |  | S339380 | CA | Completed | C | Pisani, Rob | L1 | BNL | Design | Chris Pontieri |  | null | POM02.2.03.02 | 02 | yes | MP6LAEXCLUDE | 190315 DurType to align with EVT | S1001759 | UDF_G3 | Yes | 2019 | A | 2.03 | 16731 | 003 | 2.03 |  |  |  |  |  |  |  |  |  |  |  |  |  |  |
| S316400 |  | Analyze and Evaluate Structural Support for Internal Detectors FY19 - Physics Resource(s) |  | 65d | 2019-03-01 A | 2019-05-31 A | S316300 | 100% |  |  |  |  |  |  |  |  |  | PO&AD | 0 | S271800 | 2019-01-16 | S271802 | NOCA | Completed | C | Feder, Russ | L4 | BNL | Design | Chris Pontieri | BNL | null | POM02.2.03.02 | 02 | yes |  | 90506 IVS add Russ at 120h |  |  |  |  | C |  | 16731 | 005 |  | PO |  |  |  |  |  |  |  |  |  |  |  |  |  |
| S316500 |  | Create Internal Detector Structural Support Assembly Drawings - Physics Resource(s) |  | 21d | 2019-05-02 A | 2019-05-31 A | S316410, S316406 | 100% |  |  |  |  |  |  |  |  |  | PO&AD | 0 | S271900 |  | S271900 | NOCA | Completed | C | Feder, Russ | L4 | BNL | Design | Chris Pontieri | BNL | null | POM02.2.03.02 | 02 | yes |  | 90506 IVS add Russ at 120h |  |  |  |  | C |  | 16731 | 005 |  | PO |  |  |  |  |  |  |  |  |  |  |  |  |  |
| S1004920 |  | Actuals - Labor FY19 Jun-Sep 16731 |  | 84d | 2019-06-03 A | 2019-09-30 A |  | 100% |  |  |  |  |  |  |  | Actual Labor [125.65 h] | 20,994.72 | S309300 | 100 |  |  | S339380 | CA | Completed | C | Pisani, Rob | L1 | BNL | Design | Chris Pontieri |  | null | POM02.2.03.02 | 02 | yes | MP6LAEXCLUDE | 190315 DurType to align with EVT | S1004920 |  | Yes | 2019 | A | 2.03 | 16731 | 003 | 2.03 |  |  |  |  |  |  |  |  |  |  |  |  |  |  |
| S316405 |  | Analyze and Evaluate Structural Support for Internal Detectors FY19 - Physics Resource(s) Split_25% |  | 84d | 2019-06-03 A | 2019-09-30 A | S316400 | 100% |  |  |  |  |  |  |  |  |  | PO&AD | 0 | S271800 | 2019-01-16 | S271802 | NOCA | Completed | C | Feder, Russ | L4 | BNL | Design | Chris Pontieri | BNL | null | POM02.2.03.02 | 02 |  |  | 90506 IVS add Russ at 120h |  |  |  |  | C | 2.03 | 16731 | 005 |  | PO |  |  |  |  |  |  |  |  |  |  |  |  |  |
| S316410 |  | Analyze and Evaluate Structural Support for Internal Detectors FY19 - CA-D Resource(s) |  | 19d | 2019-06-03 A | 2019-06-27 A | S316406 SS | 100% |  |  |  |  |  |  |  |  |  | PO&ADS316410 | 0 | S271800 | 2019-01-16 | S271802 | NOCA | Completed | C | Feder, Russ | L4 | BNL | Design | Chris Pontieri | BNL | null | POM02.2.03.02 | 02 |  |  | 190605 IVS remove activ. |  |  |  |  | C | 2.03 | 16731 | 005 |  | C-AD | S316410 |  |  |  |  |  |  |  |  |  |  |  |  |
| S317300 |  | Procure & Deliver Internal Detector Structural Support (leadtime and fabrication included) - Labor - Physics Resource(s) |  | 120d | 2019-11-01 A | 2019-11-27 A |  | 100% |  | 2019-12-02 | 2020-05-21 |  |  |  |  |  |  | PO&AD | 0 | S272700 |  | S272700 | NOCA | Completed | C | Pisani, Rob | L4 | BNL | Fab & Assy | Chris Pontieri | BNL | null | POM02.2.03.02 | 02 |  |  |  |  |  |  |  | C | 2.03 | 16731 | 008C |  | PO |  | Yes |  |  |  |  |  |  |  |  |  |  |  |
| S317310 |  | Procure & Deliver Internal Detector Structural Support (leadtime and fabrication included) - Labor - CA-D Resource(s) |  | 120d | 2019-11-01 A | 2019-11-29 A |  | 100% |  | 2019-12-02 | 2020-05-21 |  |  |  |  |  |  | PO&ADS317310 | 0 | S272700 |  | S272700 | NOCA | Completed | C | Pisani, Rob | L4 | BNL | Fab & Assy | Chris Pontieri | BNL | null | POM02.2.03.02 | 02 |  |  |  |  |  |  |  | C | 2.03 | 16731 |  |  | C-AD | S317310 | Yes |  |  |  |  |  |  |  |  |  |  |  |
| S316406 |  | Analyze and Evaluate Structural Support for Internal Detectors FY19 - Physics Resource(s) Split_75% |  | 8d | 2019-11-01 A | 2020-07-31 A | S316405 | 100% |  | 2019-11-01 | 2019-11-13 |  |  |  |  | TECH3 PO D [19.5 h]; TECH3 PO M [14.25 h] | 3,851.62 | PO&AD | 0 | S271800 | 2019-01-16 | S271802 | CA | In Progress | C | Feder, Russ | L4 | BNL | Design | Chris Pontieri | BNL | null | POM02.2.03.02 | 02 |  |  | 90506 IVS add Russ at 120h | S316406 |  |  |  | C | 2.03 | 16731 | 005 | 2.03 | PO |  |  |  |  |  |  |  |  |  |  |  |  |  |
| S317090 |  | Create Beampipe Supports and Beampipe Detailed Design Drawings |  | 20d | 2020-03-12 A | 2021-06-28 | S317080 | 90% | 20d | 2020-10-05 | 2020-11-02 | 146d | 0d |  | 2021-06-28 | PROF3 PO E [240 h]; PROF3 PO M [300 h] | 70,364.6 | S317000 | 0 | S272400 |  | S272400 | CA | Not Started | C | Pisani, Rob |  | BNL | Management Tech Reviews | Chris Pontieri | BNL |  | POM02.2.03.02 | 02 |  |  |  | S317090 |  |  |  | C |  | 16731 | 010 | 2.03 |  |  |  | L4 |  |  |  |  |  |  |  |  |  |  |
| S316505 |  | Create Internal Detector Structural Support Assembly Drawings - Physics Resource(s) Split |  | 30d | 2020-05-13 A | 2021-01-29 A | S316500, S316406 | 100% |  | 2020-06-01 | 2020-07-13 |  |  |  |  | TECH3 PO D [48 h] | 5,477.86 | PO&AD | 0 | S271900 |  | S271900 | CA | Not Started | C | Feder, Russ | L4 | BNL | Design | Chris Pontieri | BNL | null | POM02.2.03.02 | 02 |  |  | 90506 IVS add Russ at 120h | S316505 |  |  |  | C | 2.03 | 16731 | 005 | 2.03 | PO |  |  |  |  |  |  |  |  |  |  |  |  |  |
| S316510 |  | Create Internal Detector Structural Support Assembly Drawings - CA-D Resource(s) |  | 30d | 2020-05-13 A | 2021-01-29 A | S316505 SS | 100% |  | 2020-06-01 | 2020-07-13 |  |  |  |  | PROF4 AD [64 h] | 9,424.96 | PO&ADS316510 | 0 | S271900 |  | S271900 | CA | Not Started | C | Feder, Russ | L4 | BNL | Design | Chris Pontieri | BNL | null | POM02.2.03.02 | 02 |  |  | 190605 IVS remove activ. | S316510 |  |  |  | C | 2.03 | 16731 | 005 | 2.03 | C-AD | S316510 |  |  |  |  |  |  |  |  |  |  |  |  |
| S317050 |  | Create INTT Supports Detailed Design Drawings |  | 20d | 2020-05-13 A | 2021-07-14 | S317040 | 65% | 4d | 2021-03-22 | 2021-04-16 | 177d | 0d |  | 2021-06-28 | PROF3 PO E [40 h]; PROF3 PO M [160 h] | 26,060.96 | S317000 | 0 | S272400 |  | S272400 | CA | Not Started | C | Pisani, Rob |  | BNL | Management Tech Reviews | Chris Pontieri | BNL |  | POM02.2.03.02 | 02 |  |  |  | S317050 |  |  |  | C |  | 16731 | 010 | 2.03 |  |  |  | L4 |  |  |  |  |  |  |  |  |  |  |
| S317080 |  | Create Large Support Rings Supports Detailed Design Drawings |  | 60d | 2020-05-13 A | 2020-11-09 A |  | 100% |  | 2020-09-23 | 2020-12-21 |  |  |  |  | PROF3 PO E [100 h]; PROF3 PO M [350 h] | 58,466.38 | S317000 | 0 | S272400 |  | S272400 | CA | Not Started | C | Pisani, Rob |  | BNL | Management Tech Reviews | Chris Pontieri | BNL |  | POM02.2.03.02 | 02 |  |  |  | S317080 |  |  |  | C |  | 16731 | 010 | 2.03 |  |  |  | L4 |  |  |  |  |  |  |  |  |  |  |
| S317070 |  | Create MBD Supports Detailed Design Drawings |  | 10d | 2020-05-18 A | 2021-07-28 | S317060 | 70% | 10d | 2021-05-17 | 2021-05-28 | 194d | 0d |  | 2021-06-28 | PROF3 PO E [60 h]; PROF3 PO M [80 h] | 18,242.68 | S317000 | 0 | S272400 |  | S272400 | CA | Not Started | C | Pisani, Rob |  | BNL | Management Tech Reviews | Chris Pontieri | BNL |  | POM02.2.03.02 | 02 |  |  |  | S317070 |  |  |  | C |  | 16731 | 010 | 2.03 |  |  |  | L4 |  |  |  |  |  |  |  |  |  |  |
| S317060 |  | Create MVTX Supports Detailed Design Drawings |  | 20d | 2020-05-19 A | 2021-05-28 A | S317050 | 100% |  | 2021-04-19 | 2021-05-14 |  |  |  |  | PROF3 PO E [40 h]; PROF3 PO M [160 h] | 26,060.96 | S317000 | 0 | S272400 |  | S272400 | CA | Not Started | C | Pisani, Rob |  | BNL | Management Tech Reviews | Chris Pontieri | BNL |  | POM02.2.03.02 | 02 |  |  |  | S317060 |  |  |  | C |  | 16731 | 010 | 2.03 |  |  |  | L4 |  |  |  |  |  |  |  |  |  |  |
| S317020 |  | Create Magnet Supports Detailed Design Drawings |  | 10d | 2020-09-15 A | 2020-12-30 A | S317090 | 100% |  | 2020-12-29 | 2021-01-12 |  |  |  |  | PROF3 PO E [220 h]; PROF3 PO M [300 h] | 67,758.51 | S317000 | 0 | S272400 |  | S272400 | CA | Not Started | C | Pisani, Rob |  | BNL | Management Tech Reviews | Chris Pontieri | BNL |  | POM02.2.03.02 | 02 |  |  |  | S317020 |  |  |  | C |  | 16731 | 010 | 2.03 |  |  |  | L4 |  |  |  |  |  |  |  |  |  |  |
| S317030 |  | Create EMCal Supports Detailed Design Drawings |  | 10d | 2020-10-08 A | 2020-10-28 A | S317020 | 100% |  | 2021-03-16 | 2021-03-29 |  |  |  |  | PROF3 PO E [100 h]; PROF3 PO M [120 h] | 28,667.06 | S317000 | 0 | S272400 |  | S272400 | CA | Not Started | C | Pisani, Rob |  | BNL | Management Tech Reviews | Chris Pontieri | BNL |  | POM02.2.03.02 | 02 |  |  |  | S317030 |  |  |  | C |  | 16731 | 010 | 2.03 |  |  |  | L4 |  |  |  |  |  |  |  |  |  |  |
| S317031 |  | Review Design and Safety EMCal Supports |  | 2d | 2020-10-08 A | 2020-10-28 A | S317030 | 100% |  | 2021-03-30 | 2021-03-31 |  |  |  |  | PROF3 PO E [0.4 h]; PROF3 PO M [0.4 h] | 104.24 | S317000 | 0 | S272400 |  | S272400 | CA | Not Started | C | Pisani, Rob |  | BNL | Management Tech Reviews | Chris Pontieri | BNL |  | POM02.2.03.02 | 02 |  |  |  | S317031 |  |  |  | C |  | 16731 | 008C | 2.03 |  |  |  | L4 |  |  |  |  |  |  |  |  |  |  |
| S317032 |  | Address Action Items for EMCal Supports |  | 2d | 2020-10-08 A | 2020-10-28 A | S317031 | 100% |  | 2021-04-01 | 2021-04-02 |  |  |  |  | PROF3 PO E [0.4 h]; PROF3 PO M [0.4 h] | 104.24 | S317000 | 0 | S272400 |  | S272400 | CA | Not Started | C | Pisani, Rob |  | BNL | Management Tech Reviews | Chris Pontieri | BNL |  | POM02.2.03.02 | 02 |  |  |  | S317032 |  |  |  | C |  | 16731 | 008C | 2.03 |  |  |  | L4 |  |  |  |  |  |  |  |  |  |  |
| S317033 |  | EMCal Supports Released for Production (Milestone) | milestone | 0d | 2020-10-28 A | 2020-10-28 A | S317032 | 100% |  | 2021-04-02 | 2021-04-02 |  |  |  |  |  |  | S317000 | 0 | S272400 |  | S272400 | NOCA | Not Started | C | Pisani, Rob |  | BNL | Management Tech Reviews | Chris Pontieri | BNL |  | POM02.2.03.02 | 02 |  |  |  |  |  |  |  |  |  |  | 008C |  |  |  |  | L4 |  |  |  |  |  |  |  |  |  |  |
| S317081 |  | Review Design and Safety Large Support Rings Supports |  | 10d | 2020-11-10 A | 2020-11-24 A | S317080 | 100% |  |  |  |  |  |  |  | PROF3 PO E [24 h]; PROF3 PO M [24 h] | 6,254.63 | S317000 | 0 | S272400 |  | S272400 | CA | Not Started | C | Pisani, Rob |  | BNL | Management Tech Reviews | Chris Pontieri | BNL |  | POM02.2.03.02 | 02 |  |  |  | S317081 |  |  |  | C |  | 16731 | 010 | 2.03 |  |  |  | L4 |  |  |  |  |  |  |  |  |  |  |
| S317040 |  | Create TPC Supports Detailed Design Drawings |  | 20d | 2020-11-17 A | 2021-07-08 | S317030 | 95% | 7d | 2020-12-24 | 2021-01-25 | 146d | 0d |  | 2021-06-28 | PROF3 PO E [80 h]; PROF3 PO M [160 h] | 31,273.16 | S317000 | 0 | S272400 |  | S272400 | CA | Not Started | C | Pisani, Rob |  | BNL | Management Tech Reviews | Chris Pontieri | BNL |  | POM02.2.03.02 | 02 |  |  |  | S317040 |  |  |  | C |  | 16731 | 010 | 2.03 |  |  |  | L4 |  |  |  |  |  |  |  |  |  |  |
| S317082 |  | Address Action Items for Large Support Rings Supports |  | 5d | 2020-11-25 A | 2021-02-01 A | S317081 | 100% |  | 2020-11-25 | 2020-12-03 |  |  |  |  | PROF3 PO E [10 h]; PROF3 PO M [10 h] | 2,606.1 | S317000 | 0 | S272400 |  | S272400 | CA | Not Started | C | Pisani, Rob |  | BNL | Management Tech Reviews | Chris Pontieri | BNL |  | POM02.2.03.02 | 02 |  |  |  | S317082 |  |  |  | C |  | 16731 | 008C | 2.03 |  |  |  | L4 |  |  |  |  |  |  |  |  |  |  |
| S317021 |  | Review Design and Safety Magnet Supports |  | 2d | 2020-12-01 A | 2020-12-02 A |  | 100% |  |  |  |  |  | start on or after 2020-12-01 |  | PROF3 PO E [4 h]; PROF3 PO M [4 h] | 1,042.44 | S317000 | 0 | S272400 |  | S272400 | CA | Not Started | C | Pisani, Rob |  | BNL | Management Tech Reviews | Chris Pontieri | BNL |  | POM02.2.03.02 | 02 |  |  |  | S317021 |  |  |  | C |  | 16731 | 008C | 2.03 |  |  |  | L4 |  |  |  |  |  |  |  |  |  |  |
| S317022 |  | Address Action Items for Magnet Supports |  | 2d | 2020-12-03 A | 2021-02-26 A | S317021 | 100% |  | 2020-12-03 | 2020-12-04 |  |  |  |  | PROF3 PO E [4 h]; PROF3 PO M [4 h] | 1,042.44 | S317000 | 0 | S272400 |  | S272400 | CA | Not Started | C | Pisani, Rob |  | BNL | Management Tech Reviews | Chris Pontieri | BNL |  | POM02.2.03.02 | 02 |  |  |  | S317022 |  |  |  | C |  | 16731 | 008C | 2.03 |  |  |  | L4 |  |  |  |  |  |  |  |  |  |  |
| S317061 |  | Review Design and Safety MVTX Supports |  | 5d | 2020-12-21 A | 2020-12-31 A | S317060 | 100% |  | 2021-03-02 | 2021-03-08 |  |  |  |  | PROF3 PO E [8 h]; PROF3 PO M [8 h] | 2,084.88 | S317000 | 0 | S272400 |  | S272400 | CA | Not Started | C | Pisani, Rob |  | BNL | Management Tech Reviews | Chris Pontieri | BNL |  | POM02.2.03.02 | 02 |  |  |  | S317061 |  |  |  | C |  | 16731 | 008C | 2.03 |  |  |  | L4 |  |  |  |  |  |  |  |  |  |  |
| S316600 |  | Create Internal Detector Structural Support Detail Drawings - Physics Resource(s) |  | 25d | 2021-01-11 A | 2021-01-18 A | S316510, S316505 | 100% |  | 2021-02-01 | 2021-03-08 |  |  |  |  | TECH3 PO D [50 h] | 5,877.29 | PO&AD | 0 | S272000 |  | S272000 | CA | Not Started | C | Pisani, Rob | L4 | BNL | Design | Chris Pontieri | BNL | null | POM02.2.03.02 | 02 |  |  |  | S316600 |  |  |  | C | 2.03 | 16731 |  | 2.03 | PO |  |  |  |  |  |  |  |  |  |  |  |  |  |
| S316610 |  | Create Internal Detector Structural Support Detail Drawings - CA-D Resource(s) |  | 25d | 2021-01-11 A | 2021-01-18 A | S316600 SS | 100% |  | 2021-02-01 | 2021-03-08 |  |  |  |  | PROF4 AD [48 h] | 7,280.78 | PO&ADS316610 | 0 | S272000 |  | S272000 | CA | Not Started | C | Pisani, Rob | L4 | BNL | Design | Chris Pontieri | BNL | null | POM02.2.03.02 | 02 |  |  |  | S316610 |  |  |  | C | 2.03 | 16731 |  | 2.03 | C-AD | S316610 |  |  |  |  |  |  |  |  |  |  |  |  |
| S316700 |  | Review Internal Detector Structural Support Safety - Physics Resource(s) |  | 5d | 2021-01-19 A | 2021-01-28 A | S316600, S316610 | 100% |  | 2021-03-09 | 2021-03-15 |  |  |  |  | TECH3 PO D [4 h]; TECH3 PO M [4 h] | 940.37 | PO&AD | 0 | S272100 |  | S272100 | CA | Not Started | C | Pisani, Rob | L4 | BNL | Management Safety Reviews | Chris Pontieri | BNL | null | POM02.2.03.02 | 02 |  |  |  | S316700 |  |  |  | C | 2.03 | 16731 |  | 2.03 | PO |  |  |  |  |  |  |  |  |  |  |  |  |  |
| S316710 |  | Review Internal Detector Structural Support Safety - CA-D Resource(s) |  | 5d | 2021-01-19 A | 2021-01-28 A | S316700 SS | 100% |  | 2021-03-09 | 2021-03-15 |  |  |  |  | PROF4 AD [8 h] | 1,213.46 | PO&ADS316710 | 0 | S272100 |  | S272100 | CA | Not Started | C | Pisani, Rob | L4 | BNL | Management Safety Reviews | Chris Pontieri | BNL | null | POM02.2.03.02 | 02 |  |  |  | S316710 |  |  |  | C | 2.03 | 16731 |  | 2.03 | C-AD | S316710 |  |  |  |  |  |  |  |  |  |  |  |  |
| S316800 |  | Review Internal Detector Structural Support Design - Physics Resource(s) |  | 10d | 2021-01-19 A | 2021-01-28 A | S316700, S316710 | 100% |  | 2021-03-16 | 2021-03-29 |  |  |  |  | TECH3 PO D [8 h]; TECH3 PO M [4 h] | 1,410.55 | PO&AD | 0 | S272200 |  | S272200 | CA | Not Started | C | Pisani, Rob | L4 | BNL | Management Tech Reviews | Chris Pontieri | BNL | null | POM02.2.03.02 | 02 |  |  |  | S316800 |  |  |  | C | 2.03 | 16731 |  | 2.03 | PO |  |  |  |  |  |  |  |  |  |  |  |  |  |
| S316810 |  | Review Internal Detector Structural Support Design - CA-D Resource(s) |  | 10d | 2021-01-19 A | 2021-01-28 A | S316800 SS | 100% |  | 2021-03-16 | 2021-03-29 |  |  |  |  | PROF4 AD [16 h] | 2,426.93 | PO&ADS316810 | 0 | S272200 |  | S272200 | CA | Not Started | C | Pisani, Rob | L4 | BNL | Management Tech Reviews | Chris Pontieri | BNL | null | POM02.2.03.02 | 02 |  |  |  | S316810 |  |  |  | C | 2.03 | 16731 |  | 2.03 | C-AD | S316810 |  |  |  |  |  |  |  |  |  |  |  |  |
| S316900 |  | Address Action Items from Internal Detector Structural Support Design & Safety Reviews - Physics Resource(s) |  | 10d | 2021-01-29 A | 2021-02-26 A | S316800, S316810 | 100% |  | 2021-03-30 | 2021-04-12 |  |  |  |  | TECH3 PO D [20 h] | 2,350.92 | PO&AD | 0 | S272300 |  | S272300 | CA | Not Started | C | Pisani, Rob | L4 | BNL | Management Tech Reviews | Chris Pontieri | BNL | null | POM02.2.03.02 | 02 |  |  |  | S316900 |  |  |  | C | 2.03 | 16731 |  | 2.03 | PO |  |  |  |  |  |  |  |  |  |  |  |  |  |
| S316910 |  | Address Action Items from Internal Detector Structural Support Design & Safety Reviews - CA-D Resource(s) |  | 10d | 2021-01-29 A | 2021-02-26 A | S316900 SS | 100% |  | 2021-03-30 | 2021-04-12 |  |  |  |  | PROF4 AD [40 h] | 6,067.32 | PO&ADS316910 | 0 | S272300 |  | S272300 | CA | Not Started | C | Pisani, Rob | L4 | BNL | Management Tech Reviews | Chris Pontieri | BNL | null | POM02.2.03.02 | 02 |  |  |  | S316910 |  |  |  | C | 2.03 | 16731 |  | 2.03 | C-AD | S316910 |  |  |  |  |  |  |  |  |  |  |  |  |
| S317083 |  | Large Support Rings Supports Released for Production (Milestone) | milestone | 0d | 2021-02-01 A | 2021-02-01 A | S317082 | 100% |  |  |  |  |  |  |  |  |  | S317000 | 0 | S272400 |  | S272400 | NOCA | Not Started | C | Pisani, Rob |  | BNL | Management Tech Reviews | Chris Pontieri | BNL |  | POM02.2.03.02 | 02 |  |  |  |  |  |  |  |  |  |  | 008C |  |  |  |  | L4 |  |  |  |  |  |  |  |  |  |  |
| S317180 |  | Prepare Procurement Package for Large Support Rings |  | 20d | 2021-02-02 A | 2021-03-31 A | S317083 | 100% |  | 2021-02-02 | 2021-03-02 |  |  |  |  | TECH3 PO M [80 h]; PROF3 PO M [80 h]; PROF3 PO E [80 h] | 30,252.44 | PO&AD | 0 | S272600 |  | S272600 | CA | Not Started | C | Pontieri, Chris | L4 | BNL | Procurement | Chris Pontieri | BNL | null | POM02.2.03.02 | 02 |  |  |  | S317180 |  |  |  | C | 2.03 | 16731 | 008C | 2.03 |  |  |  |  |  |  |  |  |  |  |  |  |  |  |
| S317230 |  | Evaluate and Process Bid for EMCal Supports |  | 20d | 2021-02-16 A | 2021-02-25 A | S317130 | 100% |  | 2021-03-04 | 2021-03-31 |  |  |  |  | PROF3 PO M [10 h]; PROF3 PO E [10 h] | 2,606.1 | PO&AD | 0 | S272600 |  | S272600 | CA | Not Started | C | Pontieri, Chris | L4 | BNL | Procurement | Chris Pontieri | BNL | null | POM02.2.03.02 | 02 |  |  |  | S317230 |  |  |  | C | 2.03 | 16731 | 008C | 2.03 |  |  |  |  |  |  |  |  |  |  |  |  |  |  |
| S317130 |  | Prepare Procurement Package for EMCal Supports |  | 10d | 2021-02-18 A | 2021-02-26 A | S317033 | 100% |  | 2021-02-18 | 2021-03-03 |  |  |  |  | TECH3 PO M [10 h]; PROF3 PO M [10 h]; PROF3 PO E [10 h] | 3,781.55 | PO&AD | 0 | S272600 |  | S272600 | CA | Not Started | C | Pontieri, Chris | L4 | BNL | Procurement | Chris Pontieri | BNL | null | POM02.2.03.02 | 02 |  |  |  | S317130 |  |  |  | C | 2.03 | 16731 | 008C | 2.03 |  |  |  |  |  |  |  |  |  |  |  |  |  |  |
| S317930 |  | Procure EMCal Supports - M&S |  | 40d | 2021-02-22 A | 2021-02-26 A | S317230 | 100% |  | 2021-04-01 | 2021-05-26 |  |  |  |  | Material (Purchase (1st $2M) [18040 h] | 20,938.74 | S317900 | 0 | S271700 |  | S271710 | CA | Not Started | C | Pontieri, Chris | M5 | BNL | Fab & Assy | Chris Pontieri | BNL | null | POM02.2.03.02 | 02 |  | MP6LAEXCLUDE |  | S317930 | UDF_G2 |  |  | C | 2.03 | 16731 | 008C | 2.03 |  |  |  |  | UDF_G3 | 20938.744952 | 1 | PP6 | TBD | Combined |  |  |  |  |
| S318130 |  | Perform EMCal Supports Acceptance |  | 10d | 2021-02-23 A | 2021-02-26 A | S317930 | 100% |  | 2021-05-27 | 2021-06-10 |  |  |  |  | TECH3 PO M [10 h]; PROF3 PO E [10 h] | 2,478.51 | PO&AD | 0 | S272800 |  | S272800 | CA | Not Started | C | Pontieri, Chris | L4 | BNL | Procurement | Chris Pontieri | BNL | null | POM02.2.03.02 | 02 |  |  |  | S318130 |  |  |  | C | 2.03 | 16731 | 008C | 2.03 |  |  |  |  |  |  |  |  |  |  |  |  |  |  |
| S317000 |  | Design/Safety Reviews Complete, Internal Detector Structural Support Released for Production | milestone | 0d | 2021-02-26 A | 2021-02-26 A | S316900 FF, S316910 FF | 100% |  | 2021-04-12 | 2021-04-12 |  |  |  |  |  |  | S317000 | 0 | S272400 |  | S272400 | NOCA | Not Started | C | Pisani, Rob |  | BNL | Management Tech Reviews | Chris Pontieri | BNL |  | POM02.2.03.02 | 02 |  |  |  |  |  |  |  |  |  |  |  |  |  |  |  | L4 |  |  |  |  |  |  |  |  |  |  |
| S317023 |  | Magnet Supports Released for Production (Milestone) | milestone | 0d | 2021-02-26 A | 2021-02-26 A | S317022 | 100% |  |  |  |  |  |  |  |  |  | S317000 | 0 | S272400 |  | S272400 | NOCA | Not Started | C | Pisani, Rob |  | BNL | Management Tech Reviews | Chris Pontieri | BNL |  | POM02.2.03.02 | 02 |  |  |  |  |  |  |  |  |  |  | 008C |  |  |  |  | L4 |  |  |  |  |  |  | 2021-01-31 | -19 | PMP_2x |  |
| S317120 |  | Prepare Procurement Package for Magnet Supports |  | 10d | 2021-03-16 A | 2021-03-25 A | S317023 | 100% |  | 2021-04-01 | 2021-04-14 |  |  |  |  | TECH3 PO M [40 h]; PROF3 PO M [40 h]; PROF3 PO E [40 h] | 15,126.22 | PO&AD | 0 | S272600 |  | S272600 | CA | Not Started | C | Pontieri, Chris | L4 | BNL | Procurement | Chris Pontieri | BNL | null | POM02.2.03.02 | 02 |  |  |  | S317120 |  |  |  | C | 2.03 | 16731 | 008C | 2.03 |  |  |  |  |  |  |  |  |  |  |  |  |  |  |
| S317280 |  | Evaluate and Process Bid for Large Support Rings |  | 20d | 2021-03-22 A | 2021-03-31 A | S317180 | 100% |  | 2021-04-13 | 2021-05-10 |  |  |  |  | PROF3 PO M [20 h]; PROF3 PO E [20 h] | 5,212.19 | PO&AD | 0 | S272600 |  | S272600 | CA | Not Started | C | Pontieri, Chris | L4 | BNL | Procurement | Chris Pontieri | BNL | null | POM02.2.03.02 | 02 |  |  |  | S317280 |  |  |  | C | 2.03 | 16731 | 008C | 2.03 |  |  |  |  |  |  |  |  |  |  |  |  |  |  |
| S317100 |  | Prepare Procurement Package(s) for Inner HCal Support Tabs - Physics Resource(s) |  | 30d | 2021-04-15 A | 2021-06-28 | S317000, S101000 | 50% | 20d | 2021-05-03 | 2021-06-14 | 1d | 0d |  | 2021-06-28 | TECH3 PO D [24 h]; TECH3 PO M [24 h] | 5,642.2 | PO&AD | 0 | S272500 |  | S272500 | CA | Not Started | C | Pisani, Rob | L4 | BNL | Design | Chris Pontieri | BNL | null | POM02.2.03.02 | 02 |  |  |  | S317100 |  |  |  | C | 2.03 | 16731 | 010 | 2.03 | PO |  |  |  |  |  |  |  |  |  |  |  |  |  |
| S317110 |  | Prepare Procurement Package(s) for Inner HCal Support Tabs - CA-D Resource(s) |  | 30d | 2021-04-15 A | 2021-06-28 | S317100 SS | 50% | 20d | 2021-05-03 | 2021-06-14 | 1d | 0d |  | 2021-06-28 | PROF4 AD [120 h] | 18,201.95 | PO&ADS317110 | 0 | S272500 |  | S272500 | CA | Not Started | C | Pisani, Rob | L4 | BNL | Design | Chris Pontieri | BNL | null | POM02.2.03.02 | 02 |  |  |  | S317110 |  |  |  | C | 2.03 | 16731 | 010 | 2.03 | C-AD | S317110 |  |  |  |  |  |  |  |  |  |  |  |  |
| S317980 |  | Procure Large Support Rings - M&S |  | 80d | 2021-04-15 A | 2021-08-25 | S317280, OBLG317770 | 25% | 60d | 2021-05-04 | 2021-08-25 | 9d | 0d |  | 2021-08-25 | Material (Purchase (1st $2M) [300000 h] | 348,205.29 | S317900 | 0 | S271700 |  | S271710 | CA | Not Started | C | Pontieri, Chris | M5 | BNL | Fab & Assy | Chris Pontieri | BNL | null | POM02.2.03.02 | 02 |  | MP6LAEXCLUDE |  | S317980 | UDF_G1 |  |  | C | 2.03 | 16731 | 008C | 2.03 |  |  |  |  | UDF_G1 | 348205.293 | 1 | PP6 | MP300050 | Combined |  |  |  | FAB |
| S317220 |  | Evaluate and Process Bid for Magnet Supports |  | 20d | 2021-05-03 A | 2021-05-17 A | S317120 | 100% |  | 2021-06-01 | 2021-06-28 |  |  |  |  | PROF3 PO M [20 h]; PROF3 PO E [20 h] | 5,212.19 | PO&AD | 0 | S272600 |  | S272600 | CA | Not Started | C | Pontieri, Chris | L4 | BNL | Procurement | Chris Pontieri | BNL | null | POM02.2.03.02 | 02 |  |  |  | S317220 |  |  |  | C | 2.03 | 16731 | 008C | 2.03 |  |  |  |  |  |  |  |  |  |  |  |  |  |  |
| S317920 |  | Procure Magnet Supports - M&S |  | 40d | 2021-05-10 A | 2021-08-05 | S317220, OBLG317720 | 50% | 46d | 2021-06-30 | 2021-08-25 | 14d | 0d |  | 2021-08-05 | Material (Purchase (1st $2M) [50000 h] | 58,034.22 | S317900 | 0 | S271700 |  | S271710 | CA | Not Started | C | Pontieri, Chris | M5 | BNL | Fab & Assy | Chris Pontieri | BNL | null | POM02.2.03.02 | 02 |  | MP6LAEXCLUDE |  | S317920 | UDF_G1 |  |  | C | 2.03 | 16731 | 008C | 2.03 |  |  |  |  | UDF_G1 | 58034.2155 | 1 | PP6 | MP300010 | Combined |  |  |  | FAB |
| OBLG317710 |  | Procure Internal Detector Structural Support - Obligation |  | 1d | 2021-05-18 A | 2021-05-19 A | S317600 | 100% |  | 2021-08-18 | 2021-08-18 |  |  |  |  | Obligation Resource [311666 h] | 311,666.5 | S317700 | 0 | S271700 |  | S271706 |  | Not Started | C | Pisani, Rob | M5 | BNL | Fab & Assy | Chris Pontieri | BNL | null | POM02.2.03.02 | 02 |  | MP6LAEXCLUDE |  |  |  |  |  | K |  |  |  |  |  |  |  |  |  |  |  | PP5 | MP210060 |  |  |  |  | OBLG |
| OBLG317770 |  | Procure Large Support Rings - Obligation |  | 1d | 2021-05-27 A | 2021-05-28 A | S317280 | 100% |  | 2021-06-01 | 2021-06-01 |  |  |  |  | Obligation Resource [348205 h] | 348,205 | S317700 | 0 | S271700 |  | S271706 |  | Not Started | C | Pisani, Rob | M5 | BNL | Fab & Assy | Chris Pontieri | BNL | null | POM02.2.03.02 | 02 |  | MP6LAEXCLUDE |  |  |  |  |  | K |  |  | 008C |  |  |  |  |  |  |  |  | PP5 | MP210060 |  |  |  |  | OBLG |
| OBLG317720 |  | Procure Magnet Support - Obligation |  | 1d | 2021-06-01 | 2021-06-01 | S317220 |  |  |  |  | 14d | 0d |  |  | Obligation Resource [56896 h] | 56,896 | S317700 | 0 | S271700 |  | S271706 |  | Not Started | C | Pisani, Rob | M5 | BNL | Fab & Assy | Chris Pontieri | BNL | null | POM02.2.03.02 | 02 |  | MP6LAEXCLUDE |  |  |  |  |  | K |  |  | 008C |  |  |  |  |  |  |  |  | PP5 | MP210060 |  |  |  |  | OBLG |
| S317091 |  | Review Design and Safety Beampipe Supports |  | 5d | 2021-06-29 | 2021-07-06 | S317090 |  |  |  |  | 205d | 0d |  |  | PROF3 PO E [20 h]; PROF3 PO M [20 h] | 5,212.19 | S317000 | 0 | S272400 |  | S272400 | CA | Not Started | C | Pisani, Rob |  | BNL | Management Tech Reviews | Chris Pontieri | BNL |  | POM02.2.03.02 | 02 |  |  |  | S317091 |  |  |  | C |  | 16731 | 010 | 2.03 |  |  |  | L4 |  |  |  |  |  |  |  |  |  |  |
| S317200 |  | Evaluate & Process Bid for Inner HCal Support Tabs - Physics Resource(s) |  | 20d | 2021-06-29 | 2021-07-27 | S317100, S317110 |  |  |  |  | 1d | 0d |  |  | TECH3 PO D [16 h]; TECH3 PO M [16 h] | 3,761.47 | PO&AD | 0 | S272600 |  | S272600 | CA | Not Started | C | Pisani, Rob | L4 | BNL | Procurement | Chris Pontieri | BNL | null | POM02.2.03.02 | 02 |  |  |  | S317200 |  |  |  | C | 2.03 | 16731 | 010 | 2.03 | PO |  |  |  |  |  |  |  |  |  |  |  |  |  |
| S317210 |  | Evaluate & Process Bid for IHCal Structural Support - CA-D Resource(s) |  | 20d | 2021-06-29 | 2021-07-27 | S317200 SS |  |  |  |  | 1d | 0d |  |  | PROF4 AD [32 h] | 4,853.85 | PO&ADS317210 | 0 | S272600 |  | S272600 | CA | Not Started | C | Pisani, Rob | L4 | BNL | Procurement | Chris Pontieri | BNL | null | POM02.2.03.02 | 02 |  |  |  | S317210 |  |  |  | C | 2.03 | 16731 | 010 | 2.03 | C-AD | S317210 |  |  |  |  |  |  |  |  |  |  |  |  |
| S317092 |  | Address Action Items for Beampipe Supports |  | 2d | 2021-07-07 | 2021-07-08 | S317091 |  |  |  |  | 205d | 0d |  |  | PROF3 PO E [4 h]; PROF3 PO M [4 h] | 1,042.44 | S317000 | 0 | S272400 |  | S272400 | CA | Not Started | C | Pisani, Rob |  | BNL | Management Tech Reviews | Chris Pontieri | BNL |  | POM02.2.03.02 | 02 |  |  |  | S317092 |  |  |  | C |  | 16731 | 008C | 2.03 |  |  |  | L4 |  |  |  |  |  |  |  |  |  |  |
| S317093 |  | Beampipe Supports Released for Production (Milestone) | milestone | 0d | 2021-07-08 | 2021-07-08 | S317092 |  |  |  |  | 205d | 0d |  |  |  |  | S317000 | 0 | S272400 |  | S272400 | NOCA | Not Started | C | Pisani, Rob |  | BNL | Management Tech Reviews | Chris Pontieri | BNL |  | POM02.2.03.02 | 02 |  |  |  |  |  |  |  |  |  |  | 008C |  |  |  |  | L4 |  |  |  |  |  |  |  |  |  |  |
| S317041 |  | Review Design and Safety TPC Supports |  | 5d | 2021-07-09 | 2021-07-15 | S317040 |  |  |  |  | 146d | 0d |  |  | PROF3 PO E [8 h]; PROF3 PO M [8 h] | 2,084.88 | S317000 | 0 | S272400 |  | S272400 | CA | Not Started | C | Pisani, Rob |  | BNL | Management Tech Reviews | Chris Pontieri | BNL |  | POM02.2.03.02 | 02 |  |  |  | S317041 |  |  |  | C |  | 16731 | 008C | 2.03 |  |  |  | L4 |  |  |  |  |  |  |  |  |  |  |
| S317190 |  | Prepare Procurement Package for Beampipe Supports |  | 10d | 2021-07-09 | 2021-07-22 | S317093 |  |  |  |  | 205d | 0d |  |  | TECH3 PO M [40 h]; PROF3 PO M [40 h]; PROF3 PO E [40 h] | 15,126.22 | PO&AD | 0 | S272600 |  | S272600 | CA | Not Started | C | Pontieri, Chris | L4 | BNL | Procurement | Chris Pontieri | BNL | null | POM02.2.03.02 | 02 |  |  |  | S317190 |  |  |  | C | 2.03 | 16731 | 008C | 2.03 |  |  |  |  |  |  |  |  |  |  |  |  |  |  |
| S317051 |  | Review Design and Safety INTT Supports |  | 5d | 2021-07-15 | 2021-07-21 | S317050 |  |  |  |  | 181d | 0d |  |  | PROF3 PO E [8 h]; PROF3 PO M [40 h] | 6,254.63 | S317000 | 0 | S272400 |  | S272400 | CA | Not Started | C | Pisani, Rob |  | BNL | Management Tech Reviews | Chris Pontieri | BNL |  | POM02.2.03.02 | 02 |  |  |  | S317051 |  |  |  | C |  | 16731 | 008C | 2.03 |  |  |  | L4 |  |  |  |  |  |  |  |  |  |  |
| S317062 |  | Address Action Items for MVTX Supports |  | 2d | 2021-07-15 | 2021-07-16 | S317061 |  |  |  |  | 177d | 0d |  |  | PROF3 PO E [8 h]; PROF3 PO M [8 h] | 2,084.88 | S317000 | 0 | S272400 |  | S272400 | CA | Not Started | C | Pisani, Rob |  | BNL | Management Tech Reviews | Chris Pontieri | BNL |  | POM02.2.03.02 | 02 |  |  |  | S317062 |  |  |  | C |  | 16731 | 008C | 2.03 |  |  |  | L4 |  |  |  |  |  |  |  |  |  |  |
| S317042 |  | Address Action Items for TPC Supports |  | 2d | 2021-07-16 | 2021-07-19 | S317041 |  |  |  |  | 146d | 0d |  |  | PROF3 PO E [8 h]; PROF3 PO M [8 h] | 2,084.88 | S317000 | 0 | S272400 |  | S272400 | CA | Not Started | C | Pisani, Rob |  | BNL | Management Tech Reviews | Chris Pontieri | BNL |  | POM02.2.03.02 | 02 |  |  |  | S317042 |  |  |  | C |  | 16731 | 008C | 2.03 |  |  |  | L4 |  |  |  |  |  |  |  |  |  |  |
| S317063 |  | MVTX Supports Released for Production (Milestone) | milestone | 0d | 2021-07-16 | 2021-07-16 | S317062 |  |  |  |  | 177d | 0d |  |  |  |  | S317000 | 0 | S272400 |  | S272400 | NOCA | Not Started | C | Pisani, Rob |  | BNL | Management Tech Reviews | Chris Pontieri | BNL |  | POM02.2.03.02 | 02 |  |  |  |  |  |  |  |  |  |  | 008C |  |  |  |  | L4 |  |  |  |  |  |  |  |  |  |  |
| S317160 |  | Prepare Procurement Package for MVTX Supports |  | 10d | 2021-07-19 | 2021-07-30 | S317063 |  |  |  |  | 177d | 0d |  |  | TECH3 PO M [20 h]; PROF3 PO M [20 h]; PROF3 PO E [20 h] | 7,563.11 | PO&AD | 0 | S272600 |  | S272600 | CA | Not Started | C | Pontieri, Chris | L4 | BNL | Procurement | Chris Pontieri | BNL | null | POM02.2.03.02 | 02 |  |  |  | S317160 |  |  |  | C | 2.03 | 16731 | 008C | 2.03 |  |  |  |  |  |  |  |  |  |  |  |  |  |  |
| S317043 |  | TPC Supports Released for Production (Milestone) | milestone | 0d | 2021-07-19 | 2021-07-19 | S317042 |  |  |  |  | 146d | 0d |  |  |  |  | S317000 | 0 | S272400 |  | S272400 | NOCA | Not Started | C | Pisani, Rob |  | BNL | Management Tech Reviews | Chris Pontieri | BNL |  | POM02.2.03.02 | 02 |  |  |  |  |  |  |  |  |  |  | 008C |  |  |  |  | L4 |  |  |  |  |  |  |  |  |  |  |
| S317140 |  | Prepare Procurement Package for TPC Supports |  | 20d | 2021-07-20 | 2021-08-16 | S317043 |  |  |  |  | 146d | 0d |  |  | TECH3 PO M [40 h]; PROF3 PO M [40 h]; PROF3 PO E [40 h] | 15,126.22 | PO&AD | 0 | S272600 |  | S272600 | CA | Not Started | C | Pontieri, Chris | L4 | BNL | Procurement | Chris Pontieri | BNL | null | POM02.2.03.02 | 02 |  |  |  | S317140 |  |  |  | C | 2.03 | 16731 | 008C | 2.03 |  |  |  |  |  |  |  |  |  |  |  |  |  |  |
| S317052 |  | Address Action Items for INTT Supports |  | 2d | 2021-07-22 | 2021-07-23 | S317051 |  |  |  |  | 181d | 0d |  |  | PROF3 PO E [8 h]; PROF3 PO M [8 h] | 2,084.88 | S317000 | 0 | S272400 |  | S272400 | CA | Not Started | C | Pisani, Rob |  | BNL | Management Tech Reviews | Chris Pontieri | BNL |  | POM02.2.03.02 | 02 |  |  |  | S317052 |  |  |  | C |  | 16731 | 008C | 2.03 |  |  |  | L4 |  |  |  |  |  |  |  |  |  |  |

Notes:
- 02: 180814 RFG changed WBS desc
- S316300: BNL_UDF_Old Activity Name 181221: Analyze and Evaluate Structural Support for Internal Detectors FY18
- S1001759: BNL_UDF_Old Activity Name 181221: Actuals - Labor - sPHENIX Infrastructure FY18
- S316400: BNL_UDF_Old Activity Name 181221: Analyze and Evaluate Structural Support for Internal Detectors FY19
- S316500: BNL_UDF_Old Activity Name 181221: Create Internal Detector Structural Support Assembly Drawings
- S1004920: BNL_UDF_Old Activity Name 181221: Actuals - Labor - sPHENIX Infrastructure FY18
- S316405: BNL_UDF_Old Activity Name 181221: Analyze and Evaluate Structural Support for Internal Detectors FY19
- S316410: BNL_UDF_Old Activity Name 181221: Analyze and Evaluate Structural Support for Internal Detectors FY19
- S317300: BNL_UDF_Old Activity Name 181221: Procure & Deliver Internal Detector Structural Support (leadtime and fabrication included) - Labor
- S317310: BNL_UDF_Old Activity Name 181221: Procure & Deliver Internal Detector Structural Support (leadtime and fabrication included) - Labor
- S316406: BNL_UDF_Old Activity Name 181221: Analyze and Evaluate Structural Support for Internal Detectors FY19
- S317090: BNL_UDF_Old Activity Name 181221: Design/Safety Reviews Complete, Internal Detector Structural Support Released for Production
- S316505: BNL_UDF_Old Activity Name 181221: Create Internal Detector Structural Support Assembly Drawings
- S316510: BNL_UDF_Old Activity Name 181221: Create Internal Detector Structural Support Assembly Drawings
- S317050: BNL_UDF_Old Activity Name 181221: Design/Safety Reviews Complete, Internal Detector Structural Support Released for Production
- S317080: BNL_UDF_Old Activity Name 181221: Design/Safety Reviews Complete, Internal Detector Structural Support Released for Production
- S317070: BNL_UDF_Old Activity Name 181221: Design/Safety Reviews Complete, Internal Detector Structural Support Released for Production
- S317060: BNL_UDF_Old Activity Name 181221: Design/Safety Reviews Complete, Internal Detector Structural Support Released for Production
- S317020: BNL_UDF_Old Activity Name 181221: Design/Safety Reviews Complete, Internal Detector Structural Support Released for Production
- S317030: BNL_UDF_Old Activity Name 181221: Design/Safety Reviews Complete, Internal Detector Structural Support Released for Production
- S317031: BNL_UDF_Old Activity Name 181221: Design/Safety Reviews Complete, Internal Detector Structural Support Released for Production
- S317032: BNL_UDF_Old Activity Name 181221: Design/Safety Reviews Complete, Internal Detector Structural Support Released for Production
- S317033: BNL_UDF_Old Activity Name 181221: Design/Safety Reviews Complete, Internal Detector Structural Support Released for Production
- S317081: BNL_UDF_Old Activity Name 181221: Design/Safety Reviews Complete, Internal Detector Structural Support Released for Production
- S317040: BNL_UDF_Old Activity Name 181221: Design/Safety Reviews Complete, Internal Detector Structural Support Released for Production
- S317082: BNL_UDF_Old Activity Name 181221: Design/Safety Reviews Complete, Internal Detector Structural Support Released for Production
- S317021: BNL_UDF_Old Activity Name 181221: Design/Safety Reviews Complete, Internal Detector Structural Support Released for Production
- S317022: BNL_UDF_Old Activity Name 181221: Design/Safety Reviews Complete, Internal Detector Structural Support Released for Production
- S317061: BNL_UDF_Old Activity Name 181221: Design/Safety Reviews Complete, Internal Detector Structural Support Released for Production
- S316600: BNL_UDF_Old Activity Name 181221: Create Internal Detector Structural Support Detail Drawings
- S316610: BNL_UDF_Old Activity Name 181221: Create Internal Detector Structural Support Detail Drawings
- S316700: BNL_UDF_Old Activity Name 181221: Review Internal Detector Structural Support Safety
- S316710: BNL_UDF_Old Activity Name 181221: Review Internal Detector Structural Support Safety
- S316800: BNL_UDF_Old Activity Name 181221: Review Internal Detector Structural Support Design
- S316810: BNL_UDF_Old Activity Name 181221: Review Internal Detector Structural Support Design
- S316900: BNL_UDF_Old Activity Name 181221: Address Action Items from Internal Detector Structural Support Design & Safety Reviews
- S316910: BNL_UDF_Old Activity Name 181221: Address Action Items from Internal Detector Structural Support Design & Safety Reviews
- S317083: BNL_UDF_Old Activity Name 181221: Design/Safety Reviews Complete, Internal Detector Structural Support Released for Production
- S317180: BNL_UDF_Old Activity Name 181221: Evaluate & Process Bid for Internal Detector Structural Support
- S317230: BNL_UDF_Old Activity Name 181221: Evaluate & Process Bid for Internal Detector Structural Support
- S317130: BNL_UDF_Old Activity Name 181221: Evaluate & Process Bid for Internal Detector Structural Support
- S317930: BNL_UDF_Old Activity Name 181221: Procure Internal Detector Structural Support - Delivery Acceptance
- S318130: BNL_UDF_Old Activity Name 181221: Perform Internal Detector Structural Support Acceptance
- S317000: BNL_UDF_Old Activity Name 181221: Design/Safety Reviews Complete, Internal Detector Structural Support Released for Production
- S317023: BNL_UDF_Old Activity Name 181221: Design/Safety Reviews Complete, Internal Detector Structural Support Released for Production
- S317120: BNL_UDF_Old Activity Name 181221: Evaluate & Process Bid for Internal Detector Structural Support
- S317280: BNL_UDF_Old Activity Name 181221: Evaluate & Process Bid for Internal Detector Structural Support
- S317100: BNL_UDF_Old Activity Name 181221: Prepare Procurement Package(s) for Internal Detector Structural Support
- S317110: BNL_UDF_Old Activity Name 181221: Prepare Procurement Package(s) for Internal Detector Structural Support
- S317980: BNL_UDF_Old Activity Name 181221: Procure Internal Detector Structural Support - Delivery Acceptance
- S317220: BNL_UDF_Old Activity Name 181221: Evaluate & Process Bid for Internal Detector Structural Support
- S317920: BNL_UDF_Old Activity Name 181221: Procure Internal Detector Structural Support - Delivery Acceptance
- OBLG317710: BNL_UDF_Old Activity Name 181221: Procure Internal Detector Structural Support - Cotract Award
- OBLG317770: BNL_UDF_Old Activity Name 181221: Procure Internal Detector Structural Support - Cotract Award
- OBLG317720: BNL_UDF_Old Activity Name 181221: Procure Internal Detector Structural Support - Cotract Award
- S317091: BNL_UDF_Old Activity Name 181221: Design/Safety Reviews Complete, Internal Detector Structural Support Released for Production
- S317200: BNL_UDF_Old Activity Name 181221: Evaluate & Process Bid for Internal Detector Structural Support
- S317210: BNL_UDF_Old Activity Name 181221: Evaluate & Process Bid for Internal Detector Structural Support
- S317092: BNL_UDF_Old Activity Name 181221: Design/Safety Reviews Complete, Internal Detector Structural Support Released for Production
- S317093: BNL_UDF_Old Activity Name 181221: Design/Safety Reviews Complete, Internal Detector Structural Support Released for Production
- S317041: BNL_UDF_Old Activity Name 181221: Design/Safety Reviews Complete, Internal Detector Structural Support Released for Production
- S317190: BNL_UDF_Old Activity Name 181221: Evaluate & Process Bid for Internal Detector Structural Support
- S317051: BNL_UDF_Old Activity Name 181221: Design/Safety Reviews Complete, Internal Detector Structural Support Released for Production
- S317062: BNL_UDF_Old Activity Name 181221: Design/Safety Reviews Complete, Internal Detector Structural Support Released for Production
- S317042: BNL_UDF_Old Activity Name 181221: Design/Safety Reviews Complete, Internal Detector Structural Support Released for Production
- S317063: BNL_UDF_Old Activity Name 181221: Design/Safety Reviews Complete, Internal Detector Structural Support Released for Production
- S317160: BNL_UDF_Old Activity Name 181221: Evaluate & Process Bid for Internal Detector Structural Support
- S317043: BNL_UDF_Old Activity Name 181221: Design/Safety Reviews Complete, Internal Detector Structural Support Released for Production
- S317140: BNL_UDF_Old Activity Name 181221: Evaluate & Process Bid for Internal Detector Structural Support
- S317052: BNL_UDF_Old Activity Name 181221: Design/Safety Reviews Complete, Internal Detector Structural Support Released for Production

| ID | Activity | Type | Duration | Start | Finish | Predecessors | Total float | Free float | Resources | Cost | BNL_UDF_Temp Text 01 | BNL_UDF_Percent Complete | BNL_UDF_OPC TEC (deprecated) | BNL_UDF_Old Activity ID 181221 | BNL_Cobra WP | RG Check | BNL_Activity Status | BNL_Fund Source | BNL_Estimator | BNL_Cost Basis | BNL_Location | BNL_EDIA | BNL_CAM | BNL_Institution | BNL_OPC TEC (deprecated) | BNL_WBS | BNL_EVT | BNL_Master Control Account | BNL_Account Number | BNL_PCR ID | BNL_Cobra Control Account | BNL_WBS_Hierarchical | BNL_Milestone Level | BNL_UDF_Exclude | BNL_Proc Sig Phase | BNL_Proc Sig | SPH Proc Register | Indicator - Procurement | Indicator - Float | BNL_UDF_Remaining Tot Cost | BNL_UDF_Percent_remaining | BNL_Obligation | Temp | BNL_UDF_Temp Text 02 | Target Milestone Date | Variance | PMP Milestones |
| --- | --- | --- | --- | --- | --- | --- | --- | --- | --- | --- | --- | --- | --- | --- | --- | --- | --- | --- | --- | --- | --- | --- | --- | --- | --- | --- | --- | --- | --- | --- | --- | --- | --- | --- | --- | --- | --- | --- | --- | --- | --- | --- | --- | --- | --- | --- | --- |
| S317290 | Evaluate and Process Bid for Beampipe Supports |  | 20d | 2021-07-23 | 2021-08-19 | S317190 | 205d | 0d | PROF3 PO M [20 h]; PROF3 PO E [20 h] | 5,212.19 | PO&AD | 0 | S272600 | S272600 | S317290 | CA | Not Started | C | Pontieri, Chris | L4 | BNL | Procurement | Chris Pontieri | BNL | null | POM02.2.03.02 | C | 2.03 | 16731 | 008C | 2.03 | 02 |  |  |  |  |  |  |  |  |  |  |  |  |  |  |  |
| S317053 | INTT Supports Released for Production (Milestone) | milestone | 0d | 2021-07-23 | 2021-07-23 | S317052 | 181d | 0d |  |  | S317000 | 0 | S272400 | S272400 |  | NOCA | Not Started | C | Pisani, Rob |  | BNL | Management Tech Reviews | Chris Pontieri | BNL |  | POM02.2.03.02 |  |  |  | 008C |  | 02 | L4 |  |  |  |  |  |  |  |  |  |  |  |  |  |  |
| S317150 | Prepare Procurement Package for INTT Supports |  | 10d | 2021-07-26 | 2021-08-06 | S317053 | 181d | 0d | TECH3 PO M [20 h]; PROF3 PO M [20 h]; PROF3 PO E [20 h] | 7,563.11 | PO&AD | 0 | S272600 | S272600 | S317150 | CA | Not Started | C | Pontieri, Chris | L4 | BNL | Procurement | Chris Pontieri | BNL | null | POM02.2.03.02 | C | 2.03 | 16731 | 008C | 2.03 | 02 |  |  |  |  |  |  |  |  |  |  |  |  |  |  |  |
| S317400 | Procure IHCal Support Tabs - Provide Requirements to Procurement |  | 5d | 2021-07-28 | 2021-08-03 | S317200, S317210 | 1d | 0d | PROF3 PO M [32 h] | 4,169.75 | S317400 | 0 | S271700 | S271700 | S317400 | CA | Not Started | C | Pisani, Rob | M5 | BNL | Fab & Assy | Chris Pontieri | BNL | null | POM02.2.03.02 | C |  |  |  | 2.03 | 02 |  | MP6LAEXCLUDE | PP1 | MP210060 |  |  |  |  |  |  |  |  |  |  |  |
| S317071 | Review Design and Safety MBD Supports |  | 2d | 2021-07-29 | 2021-07-30 | S317070 | 194d | 0d | PROF3 PO E [4 h]; PROF3 PO M [4 h] | 1,042.44 | S317000 | 0 | S272400 | S272400 | S317071 | CA | Not Started | C | Pisani, Rob |  | BNL | Management Tech Reviews | Chris Pontieri | BNL |  | POM02.2.03.02 | C |  | 16731 | 008C | 2.03 | 02 | L4 |  |  |  |  |  |  |  |  |  |  |  |  |  |  |
| S317072 | Address Action Items for MBD Supports |  | 2d | 2021-08-02 | 2021-08-03 | S317071 | 194d | 0d | PROF3 PO E [4 h]; PROF3 PO M [4 h] | 1,042.44 | S317000 | 0 | S272400 | S272400 | S317072 | CA | Not Started | C | Pisani, Rob |  | BNL | Management Tech Reviews | Chris Pontieri | BNL |  | POM02.2.03.02 | C |  | 16731 | 008C | 2.03 | 02 | L4 |  |  |  |  |  |  |  |  |  |  |  |  |  |  |
| S317260 | Evaluate and Process Bid for MVTX Supports |  | 20d | 2021-08-02 | 2021-08-27 | S317160 | 177d | 0d | PROF3 PO M [20 h]; PROF3 PO E [20 h] | 5,212.19 | PO&AD | 0 | S272600 | S272600 | S317260 | CA | Not Started | C | Pontieri, Chris | L4 | BNL | Procurement | Chris Pontieri | BNL | null | POM02.2.03.02 | C | 2.03 | 16731 | 008C | 2.03 | 02 |  |  |  |  |  |  |  |  |  |  |  |  |  |  |  |
| S317073 | MBD Supports Released for Production (Milestone) | milestone | 0d | 2021-08-03 | 2021-08-03 | S317072 | 194d | 0d |  |  | S317000 | 0 | S272400 | S272400 |  | NOCA | Not Started | C | Pisani, Rob |  | BNL | Management Tech Reviews | Chris Pontieri | BNL |  | POM02.2.03.02 |  |  |  | 008C |  | 02 | L4 |  |  |  |  |  |  |  |  |  |  |  |  |  |  |
| S317170 | Prepare Procurement Package for MBD Supports |  | 10d | 2021-08-04 | 2021-08-17 | S317073 | 194d | 0d | TECH3 PO M [10 h]; PROF3 PO M [10 h]; PROF3 PO E [10 h] | 3,781.55 | PO&AD | 0 | S272600 | S272600 | S317170 | CA | Not Started | C | Pontieri, Chris | L4 | BNL | Procurement | Chris Pontieri | BNL | null | POM02.2.03.02 | C | 2.03 | 16731 | 008C | 2.03 | 02 |  |  |  |  |  |  |  |  |  |  |  |  |  |  |  |
| S317500 | Procure IHCal Support Tabs - Prepare and Send Solicitation |  | 5d | 2021-08-04 | 2021-08-10 | S317400 | 1d | 0d |  |  | S317500 | 0 | S271700 | S271702 |  | NOCA | Not Started | C | Pisani, Rob | M5 | BNL | Fab & Assy | Chris Pontieri | BNL | null | POM02.2.03.02 | C |  |  | 008C |  | 02 |  | MP6LAEXCLUDE | PP2 | MP210060 |  |  |  |  |  |  |  |  |  |  |  |
| S318120 | Perform Magnet Supports Acceptance |  | 10d | 2021-08-06 | 2021-08-19 | S317920 | 14d |  | TECH3 PO M [20 h]; PROF3 PO E [20 h] | 4,957.01 | PO&AD | 0 | S272800 | S272800 | S318120 | CA | Not Started | C | Pontieri, Chris | L4 | BNL | Procurement | Chris Pontieri | BNL | null | POM02.2.03.02 | C | 2.03 | 16731 | 008C | 2.03 | 02 |  |  |  |  |  |  |  |  |  |  |  |  |  |  |  |
| S317250 | Evaluate and Process Bid for INTT Supports |  | 20d | 2021-08-09 | 2021-09-03 | S317150 | 181d | 0d | PROF3 PO M [20 h]; PROF3 PO E [20 h] | 5,212.19 | PO&AD | 0 | S272600 | S272600 | S317250 | CA | Not Started | C | Pontieri, Chris | L4 | BNL | Procurement | Chris Pontieri | BNL | null | POM02.2.03.02 | C | 2.03 | 16731 | 008C | 2.03 | 02 |  |  |  |  |  |  |  |  |  |  |  |  |  |  |  |
| S317600 | Procure IHCal Support Tabs - Vendor Response and Selection |  | 5d | 2021-08-11 | 2021-08-17 | S317500 | 1d | 0d | PROF3 PO M [32 h] | 4,169.75 | S317600 | 0 | S271700 | S271704 | S317600 | CA | Not Started | C | Pisani, Rob | M5 | BNL | Fab & Assy | Chris Pontieri | BNL | null | POM02.2.03.02 | C |  |  |  | 2.03 | 02 |  | MP6LAEXCLUDE | PP4 | MP210060 |  |  |  |  |  |  |  |  |  |  |  |
| S317240 | Evaluate and Process Bid for TPC Supports |  | 20d | 2021-08-17 | 2021-09-14 | S317140 | 146d | 0d | PROF3 PO M [20 h]; PROF3 PO E [20 h] | 5,212.19 | PO&AD | 0 | S272600 | S272600 | S317240 | CA | Not Started | C | Pontieri, Chris | L4 | BNL | Procurement | Chris Pontieri | BNL | null | POM02.2.03.02 | C | 2.03 | 16731 | 008C | 2.03 | 02 |  |  |  |  |  |  |  |  |  |  |  |  |  |  |  |
| S317270 | Evaluate and Process Bid for MBD Supports |  | 20d | 2021-08-18 | 2021-09-15 | S317170 | 194d | 0d | PROF3 PO M [10 h]; PROF3 PO E [10 h] | 2,606.1 | PO&AD | 0 | S272600 | S272600 | S317270 | CA | Not Started | C | Pontieri, Chris | L4 | BNL | Procurement | Chris Pontieri | BNL | null | POM02.2.03.02 | C | 2.03 | 16731 | 008C | 2.03 | 02 |  |  |  |  |  |  |  |  |  |  |  |  |  |  |  |
| S317700 | Procure IHCal Structural Support - Contract Award | milestone | 0d | 2021-08-18 | 2021-08-18 | S317600 | 1d | 0d |  |  | S317700 | 0 | S271700 | S271706 |  | NOCA | Not Started | C | Pisani, Rob | M5 | BNL | Fab & Assy | Chris Pontieri | BNL | null | POM02.2.03.02 | K |  |  |  |  | 02 | L5 | MP6LAEXCLUDE | PP5 | MP210060 | Contract Award |  |  |  |  |  |  |  |  |  |  |
| S317800 | Procure IHCal Support Tabs - Leadtime |  | 48d | 2021-08-18 | 2021-10-26 | S317700, OBLG317710 | 1d | 0d |  |  | S317800 | 0 | S271700 | S271708 |  | NOCA | Not Started | C | Pisani, Rob | M5 | BNL | Fab & Assy | Chris Pontieri | BNL | null | POM02.2.03.02 | C |  |  |  |  | 02 |  | MP6LAEXCLUDE | PP6 | MP210060 |  |  |  |  |  |  |  |  |  |  |  |
| S317990 | Procure Beampipe Supports - M&S |  | 20d | 2021-08-20 | 2021-09-17 | S317290 | 205d | 0d | Material (Purchase (1st $2M) [25000 h] | 29,017.11 | S317900 | 0 | S271700 | S271710 | S317990 | CA | Not Started | C | Pontieri, Chris | M5 | BNL | Fab & Assy | Chris Pontieri | BNL | null | POM02.2.03.02 | C | 2.03 | 16731 | 008C | 2.03 | 02 |  | MP6LAEXCLUDE | PP6 | TBD | Combined | UDF_G1 | UDF_G3 | 29017.10775 | 1 |  |  |  |  |  |  |
| S318180 | Perform Large Support Rings Acceptance |  | 10d | 2021-08-26 | 2021-09-09 | S317980 | 9d | 0d | TECH3 PO M [80 h]; PROF3 PO E [40 h] | 14,615.86 | PO&AD | 0 | S272800 | S272800 | S318180 | CA | Not Started | C | Pontieri, Chris | L4 | BNL | Procurement | Chris Pontieri | BNL | null | POM02.2.03.02 | C | 2.03 | 16731 | 008C | 2.03 | 02 |  |  |  |  |  |  |  |  |  |  |  |  |  |  |  |
| OBLG317760 | Procure MVTX Support - Obligation |  | 1d | 2021-08-30 | 2021-08-30 | S317260 | 177d | 0d | Obligation Resource [56896 h] | 56,896 | S317700 | 0 | S271700 | S271706 |  |  | Not Started | C | Pisani, Rob | M5 | BNL | Fab & Assy | Chris Pontieri | BNL | null | POM02.2.03.02 | K |  |  | 008C |  | 02 |  | MP6LAEXCLUDE | PP5 | MP210060 |  |  |  |  |  | OBLG |  |  |  |  |  |
| S317960 | Procure MVTX Supports - M&S |  | 40d | 2021-08-31 | 2021-10-27 | S317260, OBLG317760 | 177d | 0d | Material (Purchase (1st $2M) [50000 h] | 58,556.52 | S317900 | 0 | S271700 | S271710 | S317960 | CA | Not Started | C | Pontieri, Chris | M5 | BNL | Fab & Assy | Chris Pontieri | BNL | null | POM02.2.03.02 | C | 2.03 | 16731 | 008C | 2.03 | 02 |  | MP6LAEXCLUDE | PP6 | MP300040 | Combined | UDF_G1 | UDF_G3 | 58034.2155 | 1 | FAB |  |  |  |  |  |
| OBLG317750 | Procure INTT Support - Obligation |  | 1d | 2021-09-07 | 2021-09-07 | S317250 | 181d | 0d | Obligation Resource [56896 h] | 56,896 | S317700 | 0 | S271700 | S271706 |  |  | Not Started | C | Pisani, Rob | M5 | BNL | Fab & Assy | Chris Pontieri | BNL | null | POM02.2.03.02 | K |  |  | 008C |  | 02 |  | MP6LAEXCLUDE | PP5 | MP210060 |  |  |  |  |  | OBLG |  |  |  |  |  |
| S317950 | Procure INTT Supports - M&S |  | 40d | 2021-09-08 | 2021-11-03 | S317250, OBLG317750 | 181d | 0d | Material (Purchase (1st $2M) [50000 h] | 58,701.61 | S317900 | 0 | S271700 | S271710 | S317950 | CA | Not Started | C | Pontieri, Chris | M5 | BNL | Fab & Assy | Chris Pontieri | BNL | null | POM02.2.03.02 | C | 2.03 | 16731 | 008C | 2.03 | 02 |  | MP6LAEXCLUDE | PP6 | MP300030 | Combined | UDF_G1 | UDF_G3 | 58034.2155 | 1 | FAB |  |  |  |  |  |
| S318182 | Assemble Large Support Rings |  | 15d | 2021-09-10 | 2021-09-30 | S318180 | 9d |  | TECH3 PO M [80 h]; PROF3 PO E [40 h]; PROF4 PO M [40 h] | 20,683.18 | PO&AD | 0 | S272800 | S272800 | S318182 | CA | Not Started | C | Pontieri, Chris | L4 | BNL | Procurement | Chris Pontieri | BNL | null | POM02.2.03.02 | C | 2.03 | 16731 | 008C | 2.03 | 02 |  |  |  |  |  |  |  |  |  |  |  |  |  |  |  |
| OBLG317740 | Procure TPC Support - Obligation |  | 1d | 2021-09-15 | 2021-09-15 | S317240 | 146d | 0d | Obligation Resource [56896 h] | 56,896 | S317700 | 0 | S271700 | S271706 |  |  | Not Started | C | Pisani, Rob | M5 | BNL | Fab & Assy | Chris Pontieri | BNL | null | POM02.2.03.02 | K |  |  | 008C |  | 02 |  | MP6LAEXCLUDE | PP5 | MP210060 |  |  |  |  |  | OBLG |  |  |  |  |  |
| S317940 | Procure TPC Supports - M&S |  | 40d | 2021-09-16 | 2021-11-12 | S317240, OBLG317740 | 146d | 0d | Material (Purchase (1st $2M) [50000 h] | 58,875.71 | S317900 | 0 | S271700 | S271710 | S317940 | CA | Not Started | C | Pontieri, Chris | M5 | BNL | Fab & Assy | Chris Pontieri | BNL | null | POM02.2.03.02 | C | 2.03 | 16731 | 008C | 2.03 | 02 |  | MP6LAEXCLUDE | PP6 | MP300020 | Combined | UDF_G1 | UDF_G3 | 58034.2155 | 1 | FAB |  |  |  |  |  |
| S317970 | Procure MBD Supports - M&S |  | 20d | 2021-09-16 | 2021-10-14 | S317270 | 194d | 0d | Material (Purchase (1st $2M) [10000 h] | 11,711.3 | S317900 | 0 | S271700 | S271710 | S317970 | CA | Not Started | C | Pontieri, Chris | M5 | BNL | Fab & Assy | Chris Pontieri | BNL | null | POM02.2.03.02 | C | 2.03 | 16731 | 008C | 2.03 | 02 |  | MP6LAEXCLUDE | PP6 | TBD | Combined | UDF_G1 | UDF_G3 | 11606.8431 | 1 |  |  |  |  |  |  |
| S318190 | Perform Beampipe Supports Acceptance |  | 10d | 2021-09-20 | 2021-10-01 | S317990 | 205d |  | TECH3 PO M [40 h]; PROF3 PO E [40 h] | 9,943.77 | PO&AD | 0 | S272800 | S272800 | S318190 | CA | Not Started | C | Pontieri, Chris | L4 | BNL | Procurement | Chris Pontieri | BNL | null | POM02.2.03.02 | C | 2.03 | 16731 | 008C | 2.03 | 02 |  |  |  |  |  |  |  |  |  |  |  |  |  |  |  |
| S318170 | Perform MBD Supports Acceptance |  | 10d | 2021-10-15 | 2021-10-28 | S317970 | 194d | 35d | TECH3 PO M [10 h]; PROF3 PO E [10 h] | 2,552.86 | PO&AD | 0 | S272800 | S272800 | S318170 | CA | Not Started | C | Pontieri, Chris | L4 | BNL | Procurement | Chris Pontieri | BNL | null | POM02.2.03.02 | C | 2.03 | 16731 | 008C | 2.03 | 02 |  |  |  |  |  |  |  |  |  |  |  |  |  |  |  |
| S317900 | Procure IHCal Support Tabs - Delivery Acceptance |  | 5d | 2021-10-27 | 2021-11-02 | S317800 | 1d | 0d | Material (Purchase (1st $2M) [45850 h] | 54,281.72 | S317900 | 0 | S271700 | S271710 | S317900 | CA | Not Started | C | Pisani, Rob | M5 | BNL | Fab & Assy | Chris Pontieri | BNL | null | POM02.2.03.02 | C | 2.03 | 16731 |  | 2.03 | 02 |  | MP6LAEXCLUDE | PP6 | MP210060 | Delivery | UDF_G1 | UDF_G1 | 53217.375614 | 1 | FAB |  |  |  |  |  |
| S318160 | Perform MVTX Supports Acceptance |  | 10d | 2021-10-28 | 2021-11-10 | S317960 | 177d | 84d | TECH3 PO M [20 h]; PROF3 PO E [20 h] | 5,105.72 | PO&AD | 0 | S272800 | S272800 | S318160 | CA | Not Started | C | Pontieri, Chris | L4 | BNL | Procurement | Chris Pontieri | BNL | null | POM02.2.03.02 | C | 2.03 | 16731 | 008C | 2.03 | 02 |  |  |  |  |  |  |  |  |  |  |  |  |  |  |  |
| S317910 | Completed - Procure IHCal Structural Support - Delivery Acceptance | milestone | 0d | 2021-11-02 | 2021-11-02 | S317900 FF | 1d | 0d |  |  | S317900 | 0 | S271700 | S271710 |  | NOCA | Not Started | C | Pisani, Rob |  | BNL | Fab & Assy | Chris Pontieri | BNL |  | POM02.2.03.02 |  |  |  |  |  | 02 | L5 | MP6LAEXCLUDE |  |  |  |  |  |  |  |  |  |  |  |  |  |
| S318000 | Perform Inner HCal Support Tabs Acceptance - Physics Resource(s) |  | 25d | 2021-11-03 | 2021-12-10 | S317910 | 1d | 0d | TECH3 PO D [20 h]; TECH3 PO M [8 h] | 3,390.02 | PO&AD | 0 | S272800 | S272800 | S318000 | CA | Not Started | C | Pisani, Rob | L4 | BNL | Procurement | Chris Pontieri | BNL | null | POM02.2.03.02 | C | 2.03 | 16731 | 010 | 2.03 | 02 |  |  |  |  |  |  |  |  |  |  | PO |  |  |  |  |
| S318010 | Perform Inner HCal Support Tabs Acceptance - CA-D Resource(s) |  | 25d | 2021-11-03 | 2021-12-10 | S318000 SS | 1d | 0d | PROF4 AD [16 h] | 2,499.74 | PO&ADS318010 | 0 | S272800 | S272800 | S318010 | CA | Not Started | C | Pisani, Rob | L4 | BNL | Procurement | Chris Pontieri | BNL | null | POM02.2.03.02 | C | 2.03 | 16731 | 010 | 2.03 | 02 |  |  |  |  |  |  |  |  |  |  | C-AD | S318010 |  |  |  |
| S318150 | Perform INTT Supports Acceptance |  | 10d | 2021-11-04 | 2021-11-18 | S317950 | 181d | 127d | TECH3 PO M [20 h]; PROF3 PO E [20 h] | 5,105.72 | PO&AD | 0 | S272800 | S272800 | S318150 | CA | Not Started | C | Pontieri, Chris | L4 | BNL | Procurement | Chris Pontieri | BNL | null | POM02.2.03.02 | C | 2.03 | 16731 | 008C | 2.03 | 02 |  |  |  |  |  |  |  |  |  |  |  |  |  |  |  |
| S318140 | Perform TPC Supports Acceptance |  | 10d | 2021-11-15 | 2021-11-30 | S317940 | 146d | 41d | TECH3 PO M [40 h]; PROF3 PO E [40 h] | 10,211.45 | PO&AD | 0 | S272800 | S272800 | S318140 | CA | Not Started | C | Pontieri, Chris | L4 | BNL | Procurement | Chris Pontieri | BNL | null | POM02.2.03.02 | C | 2.03 | 16731 | 008C | 2.03 | 02 |  |  |  |  |  |  |  |  |  |  |  |  |  |  |  |
| S318100 | Inner HCal Support Tabs Components Ready for Installation | milestone | 0d | 2021-12-10 | 2021-12-10 | S318000 FF, S318010 FF | 1d | 0d |  |  | S318100 | 0 | S272900 | S272900 |  | NOCA | Not Started | C | Pisani, Rob |  | BNL | Fab & Assy | Chris Pontieri | BNL |  | POM02.2.03.02 |  |  |  | 010 |  | 02 | L3 |  |  |  |  |  |  |  |  |  |  |  | 2021-10-05 | -45 | PMP_2x |

Notes:
- S317290: BNL_UDF_Old Activity Name 181221: Evaluate & Process Bid for Internal Detector Structural Support
- S317053: BNL_UDF_Old Activity Name 181221: Design/Safety Reviews Complete, Internal Detector Structural Support Released for Production
- S317150: BNL_UDF_Old Activity Name 181221: Evaluate & Process Bid for Internal Detector Structural Support
- S317400: BNL_UDF_Old Activity Name 181221: Procure Internal Detector Structural Support - Provide Requirements to Procurement
- S317071: BNL_UDF_Old Activity Name 181221: Design/Safety Reviews Complete, Internal Detector Structural Support Released for Production
- S317072: BNL_UDF_Old Activity Name 181221: Design/Safety Reviews Complete, Internal Detector Structural Support Released for Production
- S317260: BNL_UDF_Old Activity Name 181221: Evaluate & Process Bid for Internal Detector Structural Support
- S317073: BNL_UDF_Old Activity Name 181221: Design/Safety Reviews Complete, Internal Detector Structural Support Released for Production
- S317170: BNL_UDF_Old Activity Name 181221: Evaluate & Process Bid for Internal Detector Structural Support
- S317500: BNL_UDF_Old Activity Name 181221: Procure Internal Detector Structural Support - Prepare and Send Solicitation
- S318120: BNL_UDF_Old Activity Name 181221: Perform Internal Detector Structural Support Acceptance
- S317250: BNL_UDF_Old Activity Name 181221: Evaluate & Process Bid for Internal Detector Structural Support
- S317600: BNL_UDF_Old Activity Name 181221: Procure Internal Detector Structural Support - Vendor Response and Selection
- S317240: BNL_UDF_Old Activity Name 181221: Evaluate & Process Bid for Internal Detector Structural Support
- S317270: BNL_UDF_Old Activity Name 181221: Evaluate & Process Bid for Internal Detector Structural Support
- S317700: BNL_UDF_Old Activity Name 181221: Procure Internal Detector Structural Support - Cotract Award
- S317800: BNL_UDF_Old Activity Name 181221: Procure Internal Detector Structural Support - Leadtime
- S317990: BNL_UDF_Old Activity Name 181221: Procure Internal Detector Structural Support - Delivery Acceptance
- S318180: BNL_UDF_Old Activity Name 181221: Perform Internal Detector Structural Support Acceptance
- OBLG317760: BNL_UDF_Old Activity Name 181221: Procure Internal Detector Structural Support - Cotract Award
- S317960: BNL_UDF_Old Activity Name 181221: Procure Internal Detector Structural Support - Delivery Acceptance
- OBLG317750: BNL_UDF_Old Activity Name 181221: Procure Internal Detector Structural Support - Cotract Award
- S317950: BNL_UDF_Old Activity Name 181221: Procure Internal Detector Structural Support - Delivery Acceptance
- S318182: BNL_UDF_Old Activity Name 181221: Perform Internal Detector Structural Support Acceptance
- OBLG317740: BNL_UDF_Old Activity Name 181221: Procure Internal Detector Structural Support - Cotract Award
- S317940: BNL_UDF_Old Activity Name 181221: Procure Internal Detector Structural Support - Delivery Acceptance
- S317970: BNL_UDF_Old Activity Name 181221: Procure Internal Detector Structural Support - Delivery Acceptance
- S318190: BNL_UDF_Old Activity Name 181221: Perform Internal Detector Structural Support Acceptance
- S318170: BNL_UDF_Old Activity Name 181221: Perform Internal Detector Structural Support Acceptance
- S317900: BNL_UDF_Old Activity Name 181221: Procure Internal Detector Structural Support - Delivery Acceptance
- S318160: BNL_UDF_Old Activity Name 181221: Perform Internal Detector Structural Support Acceptance
- S317910: BNL_UDF_Old Activity Name 181221: Procure Internal Detector Structural Support - Delivery Acceptance
- S318000: BNL_UDF_Old Activity Name 181221: Perform Internal Detector Structural Support Acceptance
- S318010: BNL_UDF_Old Activity Name 181221: Perform Internal Detector Structural Support Acceptance
- S318150: BNL_UDF_Old Activity Name 181221: Perform Internal Detector Structural Support Acceptance
- S318140: BNL_UDF_Old Activity Name 181221: Perform Internal Detector Structural Support Acceptance
- S318100: BNL_UDF_Old Activity Name 181221: Internal Detector Structural Support Components Ready for Installation

| ID | WBS | Activity | Type | Duration | Start | Finish | Predecessors | Complete | Planned start | Planned finish | Resources | Cost | BNL_UDF_Exclude | BNL_UDF_Status Comments | BNL_UDF_Temp Text 01 | BNL_UDF_Percent Complete | BNL_UDF_Old Activity ID 181221 | BNL_Cobra WP | RG Check | BNL_Activity Status | BNL_Fund Source | BNL_Estimator | BNL_Cost Basis | BNL_Location | BNL_EDIA | BNL_CAM | BNL_OPC TEC (deprecated) | BNL_WBS | BNL_Actuals | BNL_FY | BNL_EVT | BNL_Master Control Account | BNL_Account Number | BNL_PCR ID | BNL_Cobra Control Account | BNL_WBS_Hierarchical | Completed | BNL_UDF_OPC TEC (deprecated) | BNL_UDF_Temp Text 02 | BNL_Proc Sig Phase | BNL_Proc Sig | BNL_Institution | Cost = Awarded Proc or Mgmt | BNL_UDF_Temp Date 01 | BNL_Milestone Level | SPH Proc Register | Indicator - Procurement | Barrel Steel Major Procurement | BNL_Obligation | BNL_UDF_Adhoc Comments | Additional EVT documentation required | Target Milestone Date | Variance | PMP Milestones |
| --- | --- | --- | --- | --- | --- | --- | --- | --- | --- | --- | --- | --- | --- | --- | --- | --- | --- | --- | --- | --- | --- | --- | --- | --- | --- | --- | --- | --- | --- | --- | --- | --- | --- | --- | --- | --- | --- | --- | --- | --- | --- | --- | --- | --- | --- | --- | --- | --- | --- | --- | --- | --- | --- | --- |
|  | 03 | **Barrel Steel** |  |  | 2017-02-01 | 2019-09-30 |  |  |  |  |  |  |  |  |  |  |  |  |  |  |  |  |  |  |  |  |  |  |  |  |  |  |  |  |  |  |  |  |  |  |  |  |  |  |  |  |  |  |  |  |  |  |  |  |
| S1000439 |  | Actuals - Labor - sPHENIX Infrastructure FY17 16722 |  | 169d | 2017-02-01 A | 2017-09-29 A | S100090 SS | 100% |  |  | Actual Labor [93.65 h] | 15,648.25 | MP6LAEXCLUDE | 190315 DurType to align with EVT | S309200 | 100 | S338500 | S1000439 | CA | Completed | C | Pisani, Rob | L1 | BNL | Design | Chris Pontieri | null | POM02.2.03.03 | Yes | 2017 | A | 2.03 | 16722 | 003 | 2.03 | 03 | yes |  |  |  |  |  |  |  |  |  |  |  |  |  |  |  |  |  |
| S318200 |  | Outer HCAL Sector Mechanical Structure production and assembly - Provide Requirements to Procurement |  | 0d | 2017-02-01 A | 2017-02-01 A | S200400 SS | 100% |  |  |  |  |  |  | S318200 | 100 | S273010 |  | NOCA | Completed | C | Pontieri, Chris |  | BNL | Procurement | Chris Pontieri |  | POM02.2.03.03 |  |  |  |  |  |  |  | 03 | yes | S273800 | 0 | PP1 | MP104701-01 | ISU | Yes |  |  |  |  |  |  |  |  |  |  |  |
| S319200 |  | Procure Outer HCAL Mechanical Structure Components - Prepare & Send Solicitation |  | 30d | 2017-02-02 A | 2017-03-16 A | S318200 | 100% |  |  |  |  |  |  | S319200 | 100 | S273900 |  | NOCA | Completed | C | Pontieri, Chris | L3 | BNL | Procurement | Chris Pontieri | null | POM02.2.03.03 |  |  | C |  |  |  |  | 03 | yes | S273900 | 0 | PP2 | MP104701-01 | ISU | Yes | 2018-10-01 |  |  |  |  |  |  |  |  |  |  |
| S319300 |  | Procure Outer HCAL Mechanical Structure Components - Vendor Responses |  | 10d | 2017-03-17 A | 2017-03-30 A | S319200 | 100% |  |  |  |  |  |  | S319300 | 100 | S274000 |  | NOCA | Completed | C | Pontieri, Chris |  | BNL | Procurement | Chris Pontieri |  | POM02.2.03.03 |  |  |  |  |  |  |  | 03 | yes | S274000 | 0 | PP3 | MP104701-01 | ISU | Yes |  |  |  |  |  |  |  |  |  |  |  |
| S319400 |  | Procure Outer HCAL Mechanical Structure Components - Vendor Selection |  | 14d | 2017-03-31 A | 2017-04-19 A | S319300 | 100% |  |  |  |  |  |  | S319400 | 100 | S274100 |  | NOCA | Completed | C | Pontieri, Chris |  | BNL | Procurement | Chris Pontieri |  | POM02.2.03.03 |  |  |  |  |  |  |  | 03 | yes | S274100 | 0 | PP4 | MP104701-01 | ISU | Yes |  |  |  |  |  |  |  |  |  |  |  |
| OBLG319501 |  | Procure Outer HCAL Mechanical Structure Components - Obligation (Raw Mat'l & Sector Assemblies) |  | 1d | 2017-04-21 A | 2017-04-21 A | S319400 | 100% |  |  | Obligation Resource |  |  |  | S319500 | 100 | S274200 |  | NOCA | Completed | C | Lajoie, John |  | BNL | Procurement | Chris Pontieri |  | POM02.2.03.03 |  |  |  |  |  |  |  | 03 | yes | S274200 | 0 | PP5 | MP104701-00 | ISU | Yes |  | L5 |  |  |  |  |  |  |  |  |  |
| S319500 |  | Procure Outer HCAL Mechanical Structure Components - Contract Award (Raw Mat'l & Sector Assemblies) | milestone | 0d | 2017-04-21 A | 2017-04-21 A | S319400 | 100% |  |  |  |  |  |  | S319500 | 100 | S274200 |  | NOCA | Completed | C | Pontieri, Chris |  | BNL | Procurement | Chris Pontieri |  | POM02.2.03.03 |  |  |  |  |  |  |  | 03 | yes | S274200 | 0 | PP5 | MP104701-00 | ISU | Yes |  | L5 | Contract Award |  |  |  |  |  |  |  |  |
| S319600 |  | Procure Outer HCAL Mechanical Structure Components - Contract Award (First Article) | milestone | 0d | 2017-08-03 A | 2017-08-03 A | S319500 SS, OBLG319501 SS | 100% |  |  |  |  |  |  | S319600 | 100 | S274300 |  | NOCA | Completed | C | Pontieri, Chris |  | BNL | Procurement | Chris Pontieri |  | POM02.2.03.03 |  |  |  |  |  |  |  | 03 | yes | S274200 | 0 | PP5 | MP104700 | ISU | Yes |  | L5 |  |  |  |  |  |  |  |  |  |
| S319700 |  | Procure Outer HCal Mechanical Structure Components - Lead Time (First Article) |  | 26d | 2017-08-03 A | 2017-09-09 A | S319600 SS | 100% | 2017-08-03 | 2017-09-08 |  |  |  |  | S319700 | 100 | S274301 |  | NOCA | Completed | C | Pontieri, Chris |  | BNL | Procurement | Chris Pontieri |  | POM02.2.03.03 |  |  |  |  |  |  |  | 03 | yes | S274300 | 0 | PP6 | MP104700 | ISU | Yes | 2018-10-01 |  |  |  |  |  |  |  |  |  |  |
| S318300 |  | Final Mechanical Design of Outer HCAL Sector |  | 99d | 2017-09-05 A | 2018-01-30 A | S200700 | 100% |  |  |  |  |  |  | S318300 | 100 | S273020 |  | NOCA | Completed | C | Pontieri, Chris |  | BNL | Design | Chris Pontieri |  | POM02.2.03.03 |  |  |  |  |  |  |  | 03 | yes | S275900 | 0 |  |  | BNL |  |  |  |  |  |  |  |  |  |  |  |  |
| S320100 |  | Procure Outer HCal Mechanical Structure Components - Del. Accept. (First Article) |  | 41d | 2017-09-10 A | 2017-11-07 A | S319700, S320000 SS, S200801 | 100% | 2017-09-11 | 2017-11-07 |  |  |  |  | S320100 | 100 | S274307 |  | NOCA | Completed | C | Pontieri, Chris |  | BNL | Procurement | Chris Pontieri |  | POM02.2.03.03 |  |  |  |  |  |  |  | 03 | yes | S274300 | 0 | PP6 | MP104700 | ISU | Yes | 2018-10-01 |  |  |  |  |  |  |  |  |  |  |
| S1000599 |  | Actuals - Labor - sPHENIX Infrastructure FY18 16722 |  | 249d | 2017-10-01 A | 2018-09-28 A | S309200, S1000439, S1000479, S1000519, S1000559 | 100% | 2017-10-02 | 2018-09-28 | Actual Labor [1008.97 h] | 168,591.72 | MP6LAEXCLUDE | 190315 DurType to align with EVT | S309300 | 100 | S339380 | S1000599 | CA | Completed | C | Pisani, Rob | L1 | BNL | Design | Chris Pontieri | null | POM02.2.03.03 | Yes | 2018 | A | 2.03 | 16722 | 003 | 2.03 | 03 | yes |  |  |  |  |  |  |  |  |  |  |  |  |  |  |  |  |  |
| S309500 |  | Actuals - Nonlabor - sPHENIX Infrastructure FY18 16722 |  | 249d | 2017-10-01 A | 2018-09-28 A | S309400 | 100% | 2017-10-02 | 2018-09-28 | Actual Nonlabor [966502 h] | 1,078,242.93 | MP6LAEXCLUDE | 190315 DurType to align with EVT | S309500 | 100 | S339385 | S309500 | CA | Completed | C | Pisani, Rob | M1 | BNL | Design | Chris Pontieri | null | POM02.2.03.03 | Yes | 2018 | A | 2.03 | 16722 | 003 | 2.03 | 03 | yes |  |  |  |  |  |  |  |  |  | UDF_G3 |  |  |  |  |  |  |  |
| S318400 |  | Internal Review of Outer HCAL Sector Mechanical Design |  | 2d | 2018-01-31 A | 2018-02-01 A | S318300 | 100% |  |  |  |  |  |  | S318400 | 100 | S273030 |  | NOCA | Completed | C | Pontieri, Chris |  | BNL | Design | Chris Pontieri |  | POM02.2.03.03 |  |  |  |  |  |  |  | 03 | yes | S275900 | 0 |  |  | BNL |  |  |  |  |  |  |  |  |  |  |  |  |
| S318700 |  | Internal Review of Outer HCAL Lifting Fixture and Supports |  | 10d | 2018-01-31 A | 2018-02-13 A | S100300 FS+28d | 100% |  |  |  |  |  |  | S318700 | 100 | S273100 |  | NOCA | Completed | C | Pontieri, Chris |  | BNL | Test_System | Chris Pontieri |  | POM02.2.03.03 |  |  |  |  |  |  |  | 03 | yes | S273100 | 0 |  |  | ISU |  |  |  |  |  |  |  |  |  |  |  |  |
| S318500 |  | Address Issues from Internal Review of Outer HCAL Sector Mechanical Design |  | 20d | 2018-02-02 A | 2018-03-03 A | S318400 | 100% | 2018-02-02 | 2018-03-02 |  |  |  |  | S318500 | 100 | S273040 |  | NOCA | Completed | C | Pontieri, Chris |  | BNL | Design | Chris Pontieri |  | POM02.2.03.03 |  |  |  |  |  |  |  | 03 | yes | S275900 | 0 |  |  | BNL |  |  |  |  |  |  |  |  |  |  |  |  |
| S318800 |  | Address Issues from Internal Review of Outer HCAL Lifting Fixture and Supports |  | 30d | 2018-02-14 A | 2018-03-28 A | S318700 | 100% |  |  |  |  |  |  | S318800 | 100 | S273200 |  | NOCA | Completed | C | Pontieri, Chris | L3 | BNL | Test_System | Chris Pontieri | null | POM02.2.03.03 |  |  | C |  |  |  |  | 03 | yes | S273200 | 0 |  |  | ISU |  |  |  |  |  |  |  |  |  |  |  |  |
| S318900 |  | Outer HCAL Lifting Fixture and Supports Design Complete | milestone | 0d | 2018-03-28 A | 2018-03-28 A | S318800 FF | 100% |  |  |  |  |  |  | S318900 | 100 | S273300 |  | NOCA | Completed | C | Pontieri, Chris |  | BNL | Design | Chris Pontieri |  | POM02.2.03.03 |  |  |  |  |  |  |  | 03 | yes | S273300 | 0 |  |  | ISU |  |  | L3 |  |  |  |  |  |  |  |  |  |
| S319000 |  | Procure Outer HCAL Lifting Fixture and Supports - Provide BNL Central Shops |  | 67d | 2018-03-29 A | 2018-07-02 A | S318900 | 100% |  |  |  |  |  |  | S319000 | 100 | S273400 |  | NOCA | Completed | C | Pontieri, Chris | L3 | BNL | Procurement | Chris Pontieri | null | POM02.2.03.03 |  |  | C |  |  |  |  | 03 | yes | S273400 | 0 |  |  | ISU |  | 2018-08-01 |  |  |  |  |  |  |  |  |  |  |
| S318600 |  | Outer HCAL Sector Mechanical Design Complete | milestone | 0d | 2018-03-30 A | 2018-03-30 A | S318500 FF | 100% |  |  |  |  |  |  | S318600 | 100 | S273050 |  | NOCA | Completed | C | Pontieri, Chris |  | BNL | Design | Chris Pontieri |  | POM02.2.03.03 |  |  |  |  |  |  |  | 03 | yes | S275900 | 0 |  |  | BNL |  |  | L3 |  |  |  |  |  |  |  |  |  |
| S320200 |  | Procure Outer HCAL Mechanical Structure Components - Vendor purchases raw material |  | 15d | 2018-04-19 A | 2018-05-09 A | S319500 SS, OBLG319501 SS | 100% |  |  |  |  |  |  | S320200 | 100 | S274400 |  | NOCA | Completed | C | Pontieri, Chris |  | BNL | Fab & Assy | Chris Pontieri | null | POM02.2.03.03 |  |  |  |  |  |  |  | 03 | yes | S274400 | 0 | PP6 | MP104701-00 | ISU | Yes |  |  |  |  |  |  |  |  |  |  |  |
| S319800 |  | Design and procure Outer HCAL acceptance testing tooling Labor |  | 87d | 2018-05-01 A | 2018-08-31 A | S318600, S319200 | 100% |  |  |  |  |  |  | S319800 | 100 | S274302 |  | NOCA | Completed | C | Pontieri, Chris | L4 | BNL | Procurement | Chris Pontieri | null | POM02.2.03.03 |  |  | C |  |  |  |  | 03 | yes | S275900 | 0 |  |  | ISU |  |  |  |  |  |  |  |  |  |  |  |  |
| S319900 |  | Design and procure Outer HCAL acceptance testing tooling - M&S |  | 87d | 2018-05-01 A | 2018-08-31 A | S319200, S318600 | 100% |  |  |  |  |  |  | S319900 | 100 | S274303 |  | NOCA | Completed | C | Pontieri, Chris | M4 | BNL | Fab & Assy | Chris Pontieri | null | POM02.2.03.03 |  |  | C |  |  |  |  | 03 | yes | S275800 | x |  |  | ISU |  |  |  |  |  |  |  |  |  |  |  |  |
| S320300 |  | Procure Outer HCAL Mechanical Structure Components - Payment for purchases raw material |  | 0d | 2018-05-10 A | 2018-05-10 A | S320200 | 100% |  |  |  |  |  |  | S320300 | 100 | S274405 |  | NOCA | Completed | C | Pontieri, Chris |  | BNL | Fab & Assy | Chris Pontieri | null | POM02.2.03.03 |  |  | C |  |  |  |  | 03 | yes | S274400 | 0 | PP6 | MP104701-00 | ISU | Yes |  |  |  |  | Yes |  |  |  |  |  |  |
| S320400 |  | Procure Outer HCAL Mechanical Structure Components - Lead Time |  | 87d | 2018-05-14 A | 2018-09-14 A | S320200 | 100% |  |  |  |  |  |  | S320400 | 100 | S274410 |  | NOCA | Completed | C | Pontieri, Chris |  | BNL | Fab & Assy | Chris Pontieri | null | POM02.2.03.03 |  |  |  |  |  |  |  | 03 | yes | S274400 | 0 | PP6 | MP104701-00 | ISU | Yes |  |  |  |  |  |  |  |  |  |  |  |
| S319100 |  | Procure Outer HCAL Lifting Fixture and Supports - Delivery Acceptance |  | 52d | 2018-07-03 A | 2018-09-14 A | S319000 | 100% |  |  |  |  | MP6LA |  | S319100 | 100 | S273500 |  | NOCA | Completed | C | Pontieri, Chris | M5 | BNL | Fab & Assy | Chris Pontieri | null | POM02.2.03.03 |  |  | C |  | 16722 |  |  | 03 | yes | S273500 | x |  |  | ISU |  |  |  |  |  |  |  |  |  |  |  |  |
| S320000 |  | Outer HCAL Sector Mechanical Structure First Article Acceptance Testing |  | 20d | 2018-09-10 A | 2018-10-08 A | S319900, S319800 | 100% | 2018-09-10 | 2018-10-05 |  |  | MP6LAEXCLUDE |  | S320000 | 100 | S274306 |  | NOCA | Completed | C | Pontieri, Chris | L4 | BNL | Test_System | Chris Pontieri | null | POM02.2.03.03 |  |  | C |  |  |  |  | 03 | yes | S274700 | x |  |  | ISU |  |  |  |  |  |  |  |  |  |  |  |  |
| S320500 |  | Procure Outer HCAL Mechanical Structure Components - Del. Accept. (Sector Structural Assembly 1) |  | 6d | 2018-09-21 A | 2018-09-28 A | S320000, S320400 SS+60d, S320300, S320100 | 100% |  |  |  |  | MP6LA |  | S320500 | 100 | S274801 |  | NOCA | Completed | C | Pontieri, Chris | M1 | BNL | Fab & Assy | Chris Pontieri | null | POM02.2.03.03 |  |  | C |  |  |  |  | 03 | yes | S274800 | x | PP6 | MP104701-01 | ISU | Yes |  |  | Delivery |  | Yes | FAB |  |  |  |  |  |
| S1001559 |  | Actuals - Labor - sPHENIX Infrastructure FY19 M8 16722 |  | 166d | 2018-10-01 A | 2019-05-31 A |  | 100% |  |  | Actual Labor [690.56 h] | 115,387.67 | MP6LAEXCLUDE | 190315 DurType to align with EVT | S309300 | 100 | S339380 | S1001559 | CA | Completed | C | Pisani, Rob | L1 | BNL | Design | Chris Pontieri | null | POM02.2.03.03 | Yes | 2019 | A | 2.03 | 16722 | 003 | 2.03 | 03 | yes |  |  |  |  |  |  |  |  |  |  |  |  |  |  |  |  |  |
| S1001599 |  | Actuals - NonLabor - sPHENIX Infrastructure FY19 M8 16722 |  | 166d | 2018-10-01 A | 2019-05-31 A |  | 100% |  |  | Actual Nonlabor [3505619 h] | 3,867,626.92 | MP6LAEXCLUDE | 190315 DurType to align with EVT | S309300 | 100 | S339380 | S1001599 | CA | Completed | C | Pisani, Rob | L1 | BNL | Design | Chris Pontieri | null | POM02.2.03.03 | Yes | 2019 | A | 2.03 | 16722 | 003 | 2.03 | 03 | yes |  |  |  |  |  |  |  |  |  | UDF_G3 |  |  |  |  |  |  |  |
| S320600 |  | Procure Outer HCAL Mechanical Structure Components - Del. Accept. (Sector Structural Assembly 2) |  | 6d | 2018-10-26 A | 2018-11-02 A | S320500 | 100% |  |  |  |  | MP6LA |  | S320600 | 100 | S274802 |  | NOCA | Completed | C | Pontieri, Chris | M1 | BNL | Fab & Assy | Chris Pontieri | null | POM02.2.03.03 |  |  | C |  | 16722 |  |  | 03 | yes | S274900 | x | PP6 | MP104701-02 | ISU | Yes |  |  |  |  | Yes | FAB | 180227 ELM pred per GRY |  |  |  |  |
| S323700 |  | Outer HCAL Sector Mechanical Structure Acceptance Testing FY18 |  | 4d | 2018-10-26 A | 2018-10-31 A | S320500 SS | 100% |  |  |  |  |  |  | S323700 | 100 | S276100 |  | NOCA | Completed | C | Pontieri, Chris | L4 | BNL | Test_System | Chris Pontieri | null | POM02.2.03.03 |  |  |  |  |  |  |  | 03 | yes | S276100 | x |  |  | ISU |  |  |  |  |  |  |  |  |  |  |  |  |
| S320700 |  | Procure Outer HCAL Mechanical Structure Components - Del. Accept. (Sector Structural Assembly 3) |  | 29d | 2018-11-02 A | 2018-12-17 A | S320600 | 100% |  |  |  |  | MP6LA | 190315 ELM chg % to align with EVT 40>0, remove AS, use EF | S320700 | 100 | S274803 |  | NOCA | Completed | C | Pontieri, Chris | M1 | BNL | Fab & Assy | Chris Pontieri | null | POM02.2.03.03 |  |  | C |  | 16722 | 003 |  | 03 | yes | S275000 | x | PP6 | MP104701-03 | ISU | Yes |  |  |  |  | Yes | FAB |  |  |  |  |  |
| S320800 |  | Procure Outer HCAL Mechanical Structure Components - Del. Accept. (Sector Structural Assembly 4) |  | 5d | 2018-11-09 A | 2018-11-16 A | S319600 SS | 100% |  |  |  |  | MP6LA | 190317 ELM logic | S320800 | 100 | S274804 |  | NOCA | Completed | C | Pontieri, Chris | M1 | BNL | Fab & Assy | Chris Pontieri | null | POM02.2.03.03 |  |  | C |  | 16722 | 003 |  | 03 | yes | S274800 | x | PP6 | MP104701-04 | ISU | Yes |  |  |  |  | Yes | FAB |  |  |  |  |  |
| S320900 |  | Procure Outer HCAL Mechanical Structure Components - Del. Accept. (Sector Structural Assembly 5) |  | 4d | 2018-11-16 A | 2018-11-23 A | S320800 SS | 100% | 2018-11-16 | 2018-11-21 |  |  | MP6LA |  | S320900 | 100 | S274805 |  | NOCA | Completed | C | Pontieri, Chris | M1 | BNL | Fab & Assy | Chris Pontieri | null | POM02.2.03.03 |  |  | C |  | 16722 |  |  | 03 | yes | S274800 | x | PP6 | MP104701-05 | ISU | Yes |  |  |  |  | Yes | FAB |  |  |  |  |  |
| S321000 |  | Procure Outer HCAL Mechanical Structure Components - Del. Accept. (Sector Structural Assembly 6) |  | 1d | 2018-11-30 A | 2018-11-30 A | S320900, S320800 SS, S320700 SS | 100% |  |  |  |  | MP6LA | 190315 ELM chg % to align with EVT 25>0, remove AS, use EF | S321000 | 100 | S274806 |  | NOCA | Completed | C | Pontieri, Chris | M1 | BNL | Fab & Assy | Chris Pontieri | null | POM02.2.03.03 |  |  | C |  | 16722 | 003 |  | 03 | yes | S274800 | x | PP6 | MP104701-06 | ISU | Yes |  |  |  |  | Yes | FAB |  |  |  |  |  |
| S321100 |  | Procure Outer HCAL Mechanical Structure Components - Del. Accept. (Sector Structural Assembly 7) |  | 6d | 2019-01-02 A | 2019-01-09 A | S321000 SS+5d | 100% |  |  |  |  | MP6LA |  | S321100 | 100 | S274807 |  | NOCA | Completed | C | Pontieri, Chris | M1 | BNL | Fab & Assy | Chris Pontieri | null | POM02.2.03.03 |  |  | C |  | 16722 |  |  | 03 | yes | S274900 | x | PP6 | MP104701-07 | ISU | Yes |  |  |  |  | Yes | FAB | 180227 ELM pred per GRY |  |  |  |  |
| S321200 |  | Procure Outer HCAL Mechanical Structure Components - Del. Accept. (Sector Structural Assembly 8) |  | 6d | 2019-01-09 A | 2019-01-16 A | S321100 SS+5d | 100% |  |  |  |  | MP6LA |  | S321200 | 100 | S274808 |  | NOCA | Completed | C | Pontieri, Chris | M1 | BNL | Fab & Assy | Chris Pontieri | null | POM02.2.03.03 |  |  | C |  | 16722 |  |  | 03 | yes | S275000 | x | PP6 | MP104701-08 | ISU | Yes |  |  |  |  | Yes | FAB |  |  |  |  |  |
| S321300 |  | Procure Outer HCAL Mechanical Structure Components - Del. Accept. (Sector Structural Assembly 9) |  | 5d | 2019-01-16 A | 2019-01-23 A | S321200 SS+5d | 100% |  |  |  |  | MP6LA |  | S321300 | 100 | S274809 |  | NOCA | Completed | C | Pontieri, Chris | M1 | BNL | Fab & Assy | Chris Pontieri | null | POM02.2.03.03 |  |  | C |  | 16722 |  |  | 03 | yes | S274800 | x | PP6 | MP104701-09 | ISU | Yes |  |  |  |  | Yes | FAB |  |  |  |  |  |
| S321400 |  | Procure Outer HCAL Mechanical Structure Components - Del. Accept. (Sector Structural Assembly 10) |  | 6d | 2019-02-05 A | 2019-02-12 A | S321300 SS+13d | 100% |  |  |  |  | MP6LA |  | S321400 | 100 | S274810 |  | NOCA | Completed | C | Pontieri, Chris | M1 | BNL | Fab & Assy | Chris Pontieri | null | POM02.2.03.03 |  |  | C |  | 16722 |  |  | 03 | yes | S274800 | x | PP6 | MP104701-10 | ISU | Yes |  |  |  |  | Yes | FAB |  |  |  |  |  |
| S321700 |  | Procure Outer HCAL Mechanical Structure Components - Del. Accept. (Sector Structural Assembly 13) |  | 6d | 2019-02-08 A | 2019-02-15 A | S321600 SS+5d | 100% |  |  |  |  | MP6LA |  | S321700 | 100 | S274813 |  | NOCA | Completed | C | Pontieri, Chris | M1 | BNL | Fab & Assy | Chris Pontieri | null | POM02.2.03.03 |  |  | C |  | 16722 |  |  | 03 | yes | S275000 | x | PP6 | MP104701-13 | ISU | Yes |  |  |  |  | Yes | FAB |  |  |  |  |  |
| S321500 |  | Procure Outer HCAL Mechanical Structure Components - Del. Accept. (Sector Structural Assembly 11) |  | 5d | 2019-02-12 A | 2019-02-19 A | S321400 SS+5d | 100% |  |  |  |  | MP6LA |  | S321500 | 100 | S274811 |  | NOCA | Completed | C | Pontieri, Chris | M1 | BNL | Fab & Assy | Chris Pontieri | null | POM02.2.03.03 |  |  | C |  | 16722 |  |  | 03 | yes | S274800 | x | PP6 | MP104701-11 | ISU | Yes |  |  |  |  | Yes | FAB |  |  |  |  |  |
| S321800 |  | Procure Outer HCAL Mechanical Structure Components - Del. Accept. (Sector Structural Assembly 14) |  | 8d | 2019-02-15 A | 2019-02-27 A | S321700 SS+5d | 100% |  |  |  |  | MP6LA |  | S321800 | 100 | S274814 |  | NOCA | Completed | C | Pontieri, Chris | M1 | BNL | Fab & Assy | Chris Pontieri | null | POM02.2.03.03 |  |  | C |  | 16722 |  |  | 03 | yes | S274800 | x | PP6 | MP104701-14 | ISU | Yes |  |  |  |  | Yes | FAB |  |  |  |  |  |
| S321900 |  | Procure Outer HCAL Mechanical Structure Components - Del. Accept. (Sector Structural Assembly 15) |  | 12d | 2019-02-15 A | 2019-03-05 A | S321800 SS+5d | 100% |  |  |  |  | MP6LA |  | S321900 | 0 | S274815 |  | NOCA | Completed | C | Pontieri, Chris | M1 | BNL | Fab & Assy | Chris Pontieri | null | POM02.2.03.03 |  |  | C |  | 16722 |  |  | 03 | yes | S274800 | x | PP6 | MP104701-15 | ISU | Yes |  |  |  |  | Yes | FAB |  |  |  |  |  |
| S321600 |  | Procure Outer HCAL Mechanical Structure Components - Del. Accept. (Sector Structural Assembly 12) |  | 6d | 2019-02-19 A | 2019-02-26 A | S321500 SS+4d | 100% |  |  |  |  | MP6LA |  | S321600 | 100 | S274812 |  | NOCA | Completed | C | Pontieri, Chris | M1 | BNL | Fab & Assy | Chris Pontieri | null | POM02.2.03.03 |  |  | C |  | 16722 |  |  | 03 | yes | S274900 | x | PP6 | MP104701-12 | ISU | Yes |  |  |  |  | Yes | FAB | 180227 ELM pred per GRY |  |  |  |  |
| S322000 |  | Procure Outer HCAL Mechanical Structure Components - Del. Accept. (Sector Structural Assembly 16) |  | 11d | 2019-03-01 A | 2019-03-15 A | S321900 SS+9d | 100% |  |  |  |  | MP6LA |  | S322000 | 0 | S274816 |  | NOCA | Completed | C | Pontieri, Chris | M1 | BNL | Fab & Assy | Chris Pontieri | null | POM02.2.03.03 |  |  | C |  | 16722 |  |  | 03 | yes | S274800 | x | PP6 | MP104701-16 | ISU | Yes |  |  |  |  | Yes | FAB |  |  |  |  |  |
| S322100 |  | Procure Outer HCAL Mechanical Structure Components - Del. Accept. (Sector Structural Assembly 17) |  | 6d | 2019-03-08 A | 2019-03-15 A | S322000 SS+5d | 100% |  |  |  |  | MP6LA |  | S322100 | 0 | S274817 |  | NOCA | Completed | C | Pontieri, Chris | M1 | BNL | Fab & Assy | Chris Pontieri | null | POM02.2.03.03 |  |  | C |  | 16722 |  |  | 03 | yes | S274900 | x | PP6 | MP104701-17 | ISU | Yes |  |  |  |  | Yes | FAB | 180227 ELM pred per GRY |  |  |  |  |
| S322200 |  | Procure Outer HCAL Mechanical Structure Components - Del. Accept. (Sector Structural Assembly 18) |  | 13d | 2019-03-15 A | 2019-04-02 A | S322100 SS+5d | 100% |  |  |  |  | MP6LA |  | S322200 | 0 | S274818 |  | NOCA | Completed | C | Pontieri, Chris | M1 | BNL | Fab & Assy | Chris Pontieri | null | POM02.2.03.03 |  |  | C |  | 16722 |  |  | 03 | yes | S275000 | x | PP6 | MP104701-18 | ISU | Yes |  |  |  |  | Yes | FAB |  |  |  |  |  |
| S322300 |  | Procure Outer HCAL Mechanical Structure Components - Del. Accept. (Sector Structural Assembly 19) |  | 9d | 2019-03-21 A | 2019-04-02 A | S322200 SS+5d | 100% |  |  |  |  | MP6LA |  | S322300 | 0 | S274819 |  | NOCA | Completed | C | Pontieri, Chris | M1 | BNL | Fab & Assy | Chris Pontieri | null | POM02.2.03.03 |  |  | C |  | 16722 |  |  | 03 | yes | S274800 | x | PP6 | MP104701-19 | ISU | Yes |  |  |  |  | Yes | FAB |  |  |  |  |  |
| S322400 |  | Procure Outer HCAL Mechanical Structure Components - Del. Accept. (Sector Structural Assembly 20) |  | 13d | 2019-03-29 A | 2019-04-16 A | S322300 SS+5d | 100% |  |  |  |  | MP6LA |  | S322400 | 0 | S274820 |  | NOCA | Completed | C | Pontieri, Chris | M1 | BNL | Fab & Assy | Chris Pontieri | null | POM02.2.03.03 |  |  | C |  | 16722 |  |  | 03 | yes | S274800 | x | PP6 | MP104701-20 | ISU | Yes |  |  |  |  | Yes | FAB |  |  |  |  |  |
| S322500 |  | Procure Outer HCAL Mechanical Structure Components - Del. Accept. (Sector Structural Assembly 21) |  | 11d | 2019-04-05 A | 2019-04-19 A | S322400 SS+5d | 100% |  |  |  |  | MP6LA |  | S322500 | 0 | S274821 |  | NOCA | Completed | C | Pontieri, Chris | M1 | BNL | Fab & Assy | Chris Pontieri | null | POM02.2.03.03 |  |  | C |  | 16722 |  |  | 03 | yes | S274800 | x | PP6 | MP104701-21 | ISU | Yes |  |  |  |  | Yes | FAB |  |  |  |  |  |
| S322600 |  | Procure Outer HCAL Mechanical Structure Components - Del. Accept. (Sector Structural Assembly 22) |  | 27d | 2019-04-12 A | 2019-05-20 A | S322500 SS+5d | 100% |  |  |  |  | MP6LA |  | S322600 | 0 | S274822 |  | NOCA | Completed | C | Pontieri, Chris | M1 | BNL | Fab & Assy | Chris Pontieri | null | POM02.2.03.03 |  |  | C |  | 16722 |  |  | 03 | yes | S274900 | x | PP6 | MP104701-22 | ISU | Yes |  |  |  |  | Yes | FAB | 180227 ELM pred per GRY |  |  |  |  |
| S322700 |  | Procure Outer HCAL Mechanical Structure Components - Del. Accept. (Sector Structural Assembly 23) |  | 14d | 2019-04-19 A | 2019-05-08 A | S322600 SS+5d | 100% |  |  |  |  | MP6LA |  | S322700 | 0 | S274823 |  | NOCA | Completed | C | Pontieri, Chris | M1 | BNL | Fab & Assy | Chris Pontieri | null | POM02.2.03.03 |  |  | C |  | 16722 |  |  | 03 | yes | S275000 | x | PP6 | MP104701-23 | ISU | Yes |  |  |  |  | Yes | FAB |  |  |  |  |  |
| S322800 |  | Procure Outer HCAL Mechanical Structure Components - Del. Accept. (Sector Structural Assembly 24) |  | 10d | 2019-05-03 A | 2019-05-16 A | S322700 SS+10d | 100% |  |  |  |  | MP6LA |  | S322800 | 0 | S274824 |  | NOCA | Completed | C | Pontieri, Chris | M1 | BNL | Fab & Assy | Chris Pontieri | null | POM02.2.03.03 |  |  | C |  | 16722 |  |  | 03 | yes | S274800 | x | PP6 | MP104701-24 | ISU | Yes |  |  |  |  | Yes | FAB |  |  |  |  |  |
| S322900 |  | Procure Outer HCAL Mechanical Structure Components - Del. Accept. (Sector Structural Assembly 25) |  | 5d | 2019-05-10 A | 2019-05-16 A | S322800 SS+5d | 100% |  |  |  |  | MP6LA |  | S322900 | 0 | S274825 |  | NOCA | Completed | C | Pontieri, Chris | M1 | BNL | Fab & Assy | Chris Pontieri | null | POM02.2.03.03 |  |  | C |  | 16722 |  |  | 03 | yes | S274800 | x | PP6 | MP104701-25 | ISU | Yes |  |  |  |  | Yes | FAB |  |  |  |  |  |
| S323000 |  | Procure Outer HCAL Mechanical Structure Components - Del. Accept. (Sector Structural Assembly 26) |  | 6d | 2019-05-17 A | 2019-05-24 A | S322900 SS+5d | 100% |  |  |  |  | MP6LA |  | S323000 | 0 | S274826 |  | NOCA | Completed | C | Pontieri, Chris | M1 | BNL | Fab & Assy | Chris Pontieri | null | POM02.2.03.03 |  |  | C |  | 16722 |  |  | 03 | yes | S274800 | x | PP6 | MP104701-26 | ISU | Yes |  |  |  |  | Yes | FAB |  |  |  |  |  |
| S1004840 |  | Actuals - NonLabor FY19 Jun-Sep 16722 |  | 84d | 2019-06-03 A | 2019-09-30 A |  | 100% |  |  | Actual Nonlabor [952324 h] | 1,050,666.17 | MP6LAEXCLUDE | 190315 DurType to align with EVT | S309300 | 100 | S339380 | S1004840 | CA | Completed | C | Pisani, Rob | L1 | BNL | Design | Chris Pontieri | null | POM02.2.03.03 | Yes | 2019 | A | 2.03 | 16722 | 003 | 2.03 | 03 | yes |  |  |  |  |  |  |  |  |  | UDF_G2 |  |  |  |  |  |  |  |
| S323100 |  | Procure Outer HCAL Mechanical Structure Components - Del. Accept. (Sector Structural Assembly 27) |  | 2d | 2019-06-03 A | 2019-06-04 A | S323000 SS+5d | 100% |  |  |  |  | MP6LA |  | S323100 | 0 | S274827 |  | NOCA | Completed | C | Pontieri, Chris | M1 | BNL | Fab & Assy | Chris Pontieri | null | POM02.2.03.03 |  |  | C | 2.03 | 16722 |  |  | 03 |  | S274900 | x | PP6 | MP104701-27 | ISU | Yes |  |  | Delivery |  | Yes |  | 180227 ELM pred per GRY |  |  |  |  |
| S323200 |  | Procure Outer HCAL Mechanical Structure Components - Del. Accept. (Sector Structural Assembly 28) |  | 6d | 2019-06-14 A | 2019-06-21 A | S323100 SS+9d | 100% |  |  |  |  | MP6LA |  | S323200 | 0 | S274828 |  | NOCA | Completed | C | Pontieri, Chris | M1 | BNL | Fab & Assy | Chris Pontieri | null | POM02.2.03.03 |  |  | C | 2.03 | 16722 |  |  | 03 |  | S275000 | x | PP6 | MP104701-28 | ISU | Yes |  |  | Delivery |  | Yes |  |  |  |  |  |  |
| S323300 |  | Procure Outer HCAL Mechanical Structure Components - Del. Accept. (Sector Structural Assembly 29) |  | 6d | 2019-06-21 A | 2019-06-28 A | S323200 SS+5d | 100% |  |  |  |  | MP6LA |  | S323300 | 0 | S274829 |  | NOCA | Completed | C | Pontieri, Chris | M1 | BNL | Fab & Assy | Chris Pontieri | null | POM02.2.03.03 |  |  | C | 2.03 | 16722 |  |  | 03 |  | S274800 | x | PP6 | MP104701-29 | ISU | Yes |  |  | Delivery |  | Yes |  |  |  |  |  |  |
| S323400 |  | Procure Outer HCAL Mechanical Structure Components - Del. Accept. (Chimney Sector Assembly 1) |  | 6d | 2019-07-01 A | 2019-07-09 A | S323300 SS+5d | 100% |  |  |  |  | MP6LA |  | S323400 | 0 | S274830 |  | NOCA | Completed | C | Pontieri, Chris | M1 | BNL | Fab & Assy | Chris Pontieri | null | POM02.2.03.03 |  |  | C | 2.03 | 16722 |  |  | 03 |  | S274800 | x | PP6 | MP104701-30 | ISU | Yes |  |  | Delivery |  | Yes |  |  |  |  |  |  |
| S323800 |  | Outer HCAL Sector Mechanical Structure Acceptance Testing FY19 |  | 22d | 2019-07-01 A | 2019-07-31 A | S323600 FF, S323700 | 100% |  |  |  |  |  |  | S323800 | 0 | S276150 |  | NOCA | Completed | C | Pontieri, Chris | L4 | BNL | Test_System | Chris Pontieri | null | POM02.2.03.03 |  |  | A | 2.03 | 16722 |  |  | 03 |  | S276100 | x |  |  | ISU |  |  |  |  |  |  |  |  | Yes |  |  |  |
| S323500 |  | Procure Outer HCAL Mechanical Structure Components - Del. Accept. (Chimney Sector Assembly 2) |  | 5d | 2019-07-09 A | 2019-07-15 A | S323400 SS+5d | 100% |  |  |  |  | MP6LA |  | S323500 | 0 | S274831 |  | NOCA | Completed | C | Pontieri, Chris | M1 | BNL | Fab & Assy | Chris Pontieri | null | POM02.2.03.03 |  |  | C | 2.03 | 16722 |  |  | 03 |  | S274800 | x | PP6 | MP104701-31 | ISU | Yes |  |  | Delivery |  | Yes |  |  |  |  |  |  |
| S323600 |  | Procure Outer HCAL Mechanical Structure Components - Del. Accept. (Chimney Sector Assembly 3) |  | 6d | 2019-07-22 A | 2019-07-29 A | S323500 SS+9d | 100% |  |  |  |  | MP6LA |  | S323600 | 0 | S274832 |  | NOCA | Completed | C | Pontieri, Chris | M1 | BNL | Fab & Assy | Chris Pontieri | null | POM02.2.03.03 |  |  | C | 2.03 | 16722 |  |  | 03 |  | S274900 | x | PP6 | MP104701-32 | ISU | Yes |  |  | Delivery |  | Yes |  | 180227 ELM pred per GRY |  |  |  |  |
| S323900 |  | Completion of Outer HCAL Sector Mechanical Structure Procurement | milestone | 0d | 2019-09-03 A | 2019-09-03 A | S323800 FF | 100% | 2019-10-01 | 2019-10-01 |  |  |  |  | S323900 | 0 | S276200 |  | NOCA | Completed | C | Pontieri, Chris |  | BNL | Procurement | Chris Pontieri |  | POM02.2.03.03 |  |  |  |  |  |  |  | 03 |  | S276200 | x |  |  | ISU |  |  | L4 |  |  |  |  |  |  | 2019-09-30 | 19 | PMP_2x |

Notes:
- S1000439: BNL_UDF_Old Activity Name 181221: Actuals - Labor - sPHENIX Infrastructure FY17
- S318200: BNL_UDF_Old Activity Name 181221: Outer HCAL Sector Mechanical Structure production and assembly - Provide Requirements to Procurement
- S319200: BNL_UDF_Old Activity Name 181221: Procure Outer HCAL Mechanical Structure Components - Prepare & Send Solicitation
- S319300: BNL_UDF_Old Activity Name 181221: Procure Outer HCAL Mechanical Structure Components - Vendor Responses
- S319400: BNL_UDF_Old Activity Name 181221: Procure Outer HCAL Mechanical Structure Components - Vendor Selection
- OBLG319501: BNL_UDF_Old Activity Name 181221: Procure Outer HCAL Mechanical Structure Components - Contract Award (Raw Mat'l & Sector Assemblies)
- S319500: BNL_UDF_Old Activity Name 181221: Procure Outer HCAL Mechanical Structure Components - Contract Award (Raw Mat'l & Sector Assemblies)
- S319600: BNL_UDF_Old Activity Name 181221: Procure Outer HCAL Mechanical Structure Components - Contract Award (First Article)
- S319700: BNL_UDF_Old Activity Name 181221: Procure Outer HCal Mechanical Structure Components - Lead Time (First Article)
- S318300: BNL_UDF_Old Activity Name 181221: Final Mechanical Design of Outer HCAL Sector
- S320100: BNL_UDF_Old Activity Name 181221: Procure Outer HCal Mechanical Structure Components - Del. Accept. (First Article)
- S1000599: BNL_UDF_Old Activity Name 181221: Actuals - Labor - sPHENIX Infrastructure FY18
- S309500: BNL_UDF_Old Activity Name 181221: Actuals - Nonlabor - sPHENIX Infrastructure FY18
- S318400: BNL_UDF_Old Activity Name 181221: Internal Review of Outer HCAL Sector Mechanical Design
- S318700: BNL_UDF_Old Activity Name 181221: Internal Review of Outer HCAL Lifting Fixture and Supports
- S318500: BNL_UDF_Old Activity Name 181221: Address Issues from Internal Review of Outer HCAL Sector Mechanical Design
- S318800: BNL_UDF_Old Activity Name 181221: Address Issues from Internal Review of Outer HCAL Lifting Fixture and Supports
- S318900: BNL_UDF_Old Activity Name 181221: Outer HCAL Lifting Fixture and Supports Design Complete
- S319000: BNL_UDF_Old Activity Name 181221: Procure Outer HCAL Lifting Fixture and Supports - Provide BNL Central Shops
- S318600: BNL_UDF_Old Activity Name 181221: Outer HCAL Sector Mechanical Design Complete
- S320200: BNL_UDF_Old Activity Name 181221: Procure Outer HCAL Mechanical Structure Components - Vendor purchases raw material
- S319800: BNL_UDF_Old Activity Name 181221: Design and procure Outer HCAL acceptance testing tooling Labor
- S319900: BNL_UDF_Old Activity Name 181221: Design and procure Outer HCAL acceptance testing tooling - M&S
- S320300: BNL_UDF_Old Activity Name 181221: Procure Outer HCAL Mechanical Structure Components - Payment for purchases raw material
- S320400: BNL_UDF_Old Activity Name 181221: Procure Outer HCAL Mechanical Structure Components - Lead Time
- S319100: BNL_UDF_Old Activity Name 181221: Procure Outer HCAL Lifting Fixture and Supports - Delivery Acceptance
- S320000: BNL_UDF_Old Activity Name 181221: Outer HCAL Sector Mechanical Structure First Article Acceptance Testing
- S320500: BNL_UDF_Old Activity Name 181221: Procure Outer HCAL Mechanical Structure Components - Del. Accept. (Sector Structural Assembly 1)
- S1001559: BNL_UDF_Old Activity Name 181221: Actuals - Labor - sPHENIX Infrastructure FY18
- S1001599: BNL_UDF_Old Activity Name 181221: Actuals - Labor - sPHENIX Infrastructure FY18
- S320600: BNL_UDF_Old Activity Name 181221: Procure Outer HCAL Mechanical Structure Components - Del. Accept. (Sector Structural Assembly 2)
- S323700: BNL_UDF_Old Activity Name 181221: Outer HCAL Sector Mechanical Structure Acceptance Testing FY18
- S320700: BNL_UDF_Old Activity Name 181221: Procure Outer HCAL Mechanical Structure Components - Del. Accept. (Sector Structural Assembly 3)
- S320800: BNL_UDF_Old Activity Name 181221: Procure Outer HCAL Mechanical Structure Components - Del. Accept. (Sector Structural Assembly 4)
- S320900: BNL_UDF_Old Activity Name 181221: Procure Outer HCAL Mechanical Structure Components - Del. Accept. (Sector Structural Assembly 5)
- S321000: BNL_UDF_Old Activity Name 181221: Procure Outer HCAL Mechanical Structure Components - Del. Accept. (Sector Structural Assembly 6)
- S321100: BNL_UDF_Old Activity Name 181221: Procure Outer HCAL Mechanical Structure Components - Del. Accept. (Sector Structural Assembly 7)
- S321200: BNL_UDF_Old Activity Name 181221: Procure Outer HCAL Mechanical Structure Components - Del. Accept. (Sector Structural Assembly 8)
- S321300: BNL_UDF_Old Activity Name 181221: Procure Outer HCAL Mechanical Structure Components - Del. Accept. (Sector Structural Assembly 9)
- S321400: BNL_UDF_Old Activity Name 181221: Procure Outer HCAL Mechanical Structure Components - Del. Accept. (Sector Structural Assembly 10)
- S321700: BNL_UDF_Old Activity Name 181221: Procure Outer HCAL Mechanical Structure Components - Del. Accept. (Sector Structural Assembly 13)
- S321500: BNL_UDF_Old Activity Name 181221: Procure Outer HCAL Mechanical Structure Components - Del. Accept. (Sector Structural Assembly 11)
- S321800: BNL_UDF_Old Activity Name 181221: Procure Outer HCAL Mechanical Structure Components - Del. Accept. (Sector Structural Assembly 14)
- S321900: BNL_UDF_Old Activity Name 181221: Procure Outer HCAL Mechanical Structure Components - Del. Accept. (Sector Structural Assembly 15)
- S321600: BNL_UDF_Old Activity Name 181221: Procure Outer HCAL Mechanical Structure Components - Del. Accept. (Sector Structural Assembly 12)
- S322000: BNL_UDF_Old Activity Name 181221: Procure Outer HCAL Mechanical Structure Components - Del. Accept. (Sector Structural Assembly 16)
- S322100: BNL_UDF_Old Activity Name 181221: Procure Outer HCAL Mechanical Structure Components - Del. Accept. (Sector Structural Assembly 17)
- S322200: BNL_UDF_Old Activity Name 181221: Procure Outer HCAL Mechanical Structure Components - Del. Accept. (Sector Structural Assembly 18)
- S322300: BNL_UDF_Old Activity Name 181221: Procure Outer HCAL Mechanical Structure Components - Del. Accept. (Sector Structural Assembly 19)
- S322400: BNL_UDF_Old Activity Name 181221: Procure Outer HCAL Mechanical Structure Components - Del. Accept. (Sector Structural Assembly 20)
- S322500: BNL_UDF_Old Activity Name 181221: Procure Outer HCAL Mechanical Structure Components - Del. Accept. (Sector Structural Assembly 21)
- S322600: BNL_UDF_Old Activity Name 181221: Procure Outer HCAL Mechanical Structure Components - Del. Accept. (Sector Structural Assembly 22)
- S322700: BNL_UDF_Old Activity Name 181221: Procure Outer HCAL Mechanical Structure Components - Del. Accept. (Sector Structural Assembly 23)
- S322800: BNL_UDF_Old Activity Name 181221: Procure Outer HCAL Mechanical Structure Components - Del. Accept. (Sector Structural Assembly 24)
- S322900: BNL_UDF_Old Activity Name 181221: Procure Outer HCAL Mechanical Structure Components - Del. Accept. (Sector Structural Assembly 25)
- S323000: BNL_UDF_Old Activity Name 181221: Procure Outer HCAL Mechanical Structure Components - Del. Accept. (Sector Structural Assembly 26)
- S1004840: BNL_UDF_Old Activity Name 181221: Actuals - Labor - sPHENIX Infrastructure FY18
- S323100: BNL_UDF_Old Activity Name 181221: Procure Outer HCAL Mechanical Structure Components - Del. Accept. (Sector Structural Assembly 27)
- S323200: BNL_UDF_Old Activity Name 181221: Procure Outer HCAL Mechanical Structure Components - Del. Accept. (Sector Structural Assembly 28)
- S323300: BNL_UDF_Old Activity Name 181221: Procure Outer HCAL Mechanical Structure Components - Del. Accept. (Sector Structural Assembly 29)
- S323400: BNL_UDF_Old Activity Name 181221: Procure Outer HCAL Mechanical Structure Components - Del. Accept. (Chimney Sector Assembly 1)
- S323800: BNL_UDF_Old Activity Name 181221: Outer HCAL Sector Mechanical Structure Acceptance Testing FY19
- S323500: BNL_UDF_Old Activity Name 181221: Procure Outer HCAL Mechanical Structure Components - Del. Accept. (Chimney Sector Assembly 2)
- S323600: BNL_UDF_Old Activity Name 181221: Procure Outer HCAL Mechanical Structure Components - Del. Accept. (Chimney Sector Assembly 3)
- S323900: BNL_UDF_Old Activity Name 181221: Completion of Outer HCAL Sector Mechanical Structure Procurement

| ID | WBS | Activity | Type | Duration | Start | Finish | Predecessors | Complete | Remaining | Planned start | Planned finish | Total float | Free float | Expected finish | Resources | Cost | BNL_UDF_Temp Text 01 | BNL_UDF_Percent Complete | BNL_UDF_Old Activity ID 181221 | BNL_Cobra WP | RG Check | BNL_Activity Status | BNL_Fund Source | BNL_Estimator | BNL_Cost Basis | BNL_Location | BNL_EDIA | BNL_CAM | BNL_Institution | BNL_OPC TEC (deprecated) | BNL_WBS | BNL_WBS Manager | BNL_EVT | BNL_Master Control Account | BNL_Account Number | BNL_Cobra Control Account | BNL_WBS_Hierarchical | Temp | BNL_UDF_Temp Text 02 | BNL_UDF_OPC TEC (deprecated) | BNL_UDF_Status Comments | BNL_PCR ID | BNL_Milestone Level | BNL_UDF_Temp Date 01 | BNL_Proc Sig Phase | BNL_Proc Sig | SPH Proc Register | BNL_Obligation | Indicator - Procurement | Indicator - Float | BNL_UDF_Remaining Tot Cost | BNL_UDF_Percent_remaining |
| --- | --- | --- | --- | --- | --- | --- | --- | --- | --- | --- | --- | --- | --- | --- | --- | --- | --- | --- | --- | --- | --- | --- | --- | --- | --- | --- | --- | --- | --- | --- | --- | --- | --- | --- | --- | --- | --- | --- | --- | --- | --- | --- | --- | --- | --- | --- | --- | --- | --- | --- | --- | --- |
|  | 04 | **End Caps/ Pole Tips** |  |  | 2019-11-01 | 2021-09-09 |  |  |  |  |  |  |  |  |  |  |  |  |  |  |  |  |  |  |  |  |  |  |  |  |  |  |  |  |  |  |  |  |  |  |  |  |  |  |  |  |  |  |  |  |  |  |
| S324000 |  | End Caps/ Pole Tips - Engineering & Analysis (includes drive system) - Physics Resource(s) |  | 35d | 2019-11-01 A | 2020-03-31 A | S315010, S314716 | 100% |  | 2019-12-02 | 2020-01-22 |  |  |  | TECH3 PO D [70 h] | 7,988.55 | PO&AD | 0 | S2716330 | S324000 | CA | In Progress | C | Mills, Jim | L4 | BNL | Design | Chris Pontieri | BNL | null | POM02.2.03.04 | Hock, John | C | 2.03 | 16732 | 2.03 | 04 | PO |  |  |  |  |  |  |  |  |  |  |  |  |  |  |
| S324010 |  | End Caps/ Pole Tips - Engineering & Analysis (includes drive system) - CA-D Resource(s) |  | 35d | 2019-11-01 A | 2020-03-31 A | S324000 SS | 100% |  | 2019-12-02 | 2020-01-22 |  |  |  | PROF5 AD [140 h]; TECH3 AD [70 h]; PROF4 AD [240 h] | 67,140.98 | PO&ADS324010 | 0 | S2716330 | S324010 | CA | In Progress | C | Mills, Jim | L4 | BNL | Design | Chris Pontieri | BNL | null | POM02.2.03.04 | Hock, John | C | 2.03 | 16732 | 2.03 | 04 | C-AD | S324010 |  |  |  |  |  |  |  |  |  |  |  |  |  |
| S324100 |  | End Caps/ Pole Tips - Design Controls for Drive System - Physics Resource(s) |  | 15d | 2020-04-01 A | 2020-12-30 A | S324000, S324010 | 100% |  | 2020-04-01 | 2020-04-21 |  |  |  | PROF3 PO E [120 h]; TECH3 PO D [60 h] | 22,028.47 | S324100 | 0 | S2716370 | S324100 | CA | Not Started | C | Mills, Jim | L4 | BNL | Design | Chris Pontieri | BNL | null | POM02.2.03.04 | Hock, John | C | 2.03 | 16732 | 2.03 | 04 |  |  |  |  |  |  |  |  |  |  |  |  |  |  |  |
| S324110 |  | End Caps/ Pole Tips - Design Controls for Drive System - CA-D Resource(s) |  | 15d | 2020-04-01 A | 2020-12-30 A | S324000, S324010 | 100% |  | 2020-04-01 | 2020-04-21 |  |  |  | TECH3 AD [60 h] | 6,847.33 | S324100 | 0 | S2716370 | S324110 | CA | Not Started | C | Mills, Jim | L4 | BNL | Design | Chris Pontieri | BNL | null | POM02.2.03.04 | Hock, John | C | 2.03 | 16732 | 2.03 | 04 |  |  |  |  |  |  |  |  |  |  |  |  |  |  |  |
| S324200 |  | End Caps/ Pole Tips - Assembly & Detail Drawing - Physics Resource(s) |  | 65d | 2020-04-01 A | 2020-10-14 A | S324000, S324010 | 100% |  | 2020-04-01 | 2020-07-01 |  |  |  | PROF4 PO M [24 h]; SCI3 PO [24 h]; TECH3 PO M [24 h]; TECH3 PO D [240 h] | 37,793.14 | PO&AD | 0 | S276400 | S324200 | CA | Not Started | C | Mills, Jim | L4 | BNL | Design | Chris Pontieri | BNL | null | POM02.2.03.04 | Hock, John | C | 2.03 | 16732 | 2.03 | 04 | PO |  | S276400 |  |  |  |  |  |  |  |  |  |  |  |  |
| S324210 |  | End Caps/ Pole Tips - Assembly & Detail Drawing - CA-D Resource(s) |  | 65d | 2020-04-01 A | 2020-10-14 A | S324200 SS | 100% |  | 2020-04-01 | 2020-07-01 |  |  |  | PROF5 AD [125 h]; TECH3 AD [240 h]; PROF4 AD [245 h] | 84,727.13 | PO&ADS324210 | 0 | S276400 | S324210 | CA | Not Started | C | Mills, Jim | L4 | BNL | Design | Chris Pontieri | BNL | null | POM02.2.03.04 | Hock, John | C | 2.03 | 16732 | 2.03 | 04 | C-AD | S324210 | S276400 |  |  |  |  |  |  |  |  |  |  |  |  |
| S324300 |  | End Caps/ Pole Tips - Final Design Reviews (Design & Safety) - Physics Resource(s) |  | 5d | 2020-04-01 A | 2020-04-21 A | S324200, S324210, S324100, S324110 | 100% |  | 2020-07-02 | 2020-07-09 |  |  |  | TECH3 PO D [20 h]; SCI3 PO [4 h] | 2,970.87 | PO&AD | 0 | S276600 | S324300 | CA | Not Started | C | Mills, Jim | L4 | BNL | Management Safety Reviews | Chris Pontieri | BNL | null | POM02.2.03.04 | Hock, John | C | 2.03 | 16732 | 2.03 | 04 | PO |  | S276600 |  |  |  |  |  |  |  |  |  |  |  |  |
| S324310 |  | End Caps/ Pole Tips - Final Design Reviews (Design & Safety) - CA-D Resource(s) |  | 5d | 2020-04-01 A | 2020-04-21 A | S324300 SS, S324100, S324110 | 100% |  | 2020-07-02 | 2020-07-09 |  |  |  | PROF5 AD [20 h]; TECH3 AD [20 h]; PROF4 AD [40 h] | 11,574.3 | PO&ADS324310 | 0 | S276600 | S324310 | CA | Not Started | C | Mills, Jim | L4 | BNL | Management Safety Reviews | Chris Pontieri | BNL | null | POM02.2.03.04 | Hock, John | C | 2.03 | 16732 | 2.03 | 04 | C-AD | S324310 | S276600 |  |  |  |  |  |  |  |  |  |  |  |  |
| S324400 |  | End Caps/ Pole Tips - Address Action Items from Design & Safety Reviews - Physics Resource(s) |  | 10d | 2020-04-01 A | 2020-10-28 A | S324300, S324310 | 100% |  | 2020-07-10 | 2020-07-23 |  |  |  | TECH3 PO D [40 h]; TECH3 PO M [8 h] | 5,477.86 | PO&AD | 0 | S276800 | S324400 | CA | Not Started | C | Mills, Jim | L4 | BNL | Management Tech Reviews | Chris Pontieri | BNL | null | POM02.2.03.04 | Hock, John | C | 2.03 | 16732 | 2.03 | 04 | PO |  | S276800 |  |  |  |  |  |  |  |  |  |  |  |  |
| S324410 |  | End Caps/ Pole Tips - Address Action Items from Design & Safety Reviews - CA-D Resource(s) |  | 10d | 2020-04-01 A | 2020-10-28 A | S324400 SS | 100% |  | 2020-07-10 | 2020-07-23 |  |  |  | PROF5 AD [20 h]; TECH3 AD [40 h]; PROF4 AD [40 h] | 13,856.75 | PO&ADS324410 | 0 | S276800 | S324410 | CA | Not Started | C | Mills, Jim | L4 | BNL | Management Tech Reviews | Chris Pontieri | BNL | null | POM02.2.03.04 | Hock, John | C | 2.03 | 16732 | 2.03 | 04 | C-AD | S324410 | S276800 |  |  |  |  |  |  |  |  |  |  |  |  |
| S324600 |  | End Caps/ Pole Tips - Prepare Procurement Package(s) - Physics Resource(s) |  | 21d | 2020-04-01 A | 2020-11-30 A | S324500 | 100% |  | 2020-07-24 | 2020-08-21 |  |  |  | TECH3 PO D [120 h] | 13,694.66 | PO&AD | 0 | S277000 | S324600 | CA | Not Started | C | Mills, Jim | L4 | BNL | Procurement | Chris Pontieri | BNL | null | POM02.2.03.04 | Hock, John | C | 2.03 | 16732 | 2.03 | 04 | PO |  | S277000 | 190317 ELM remove proc nos. | 003 |  |  |  |  |  |  |  |  |  |  |
| S324610 |  | End Caps/ Pole Tips - Prepare Procurement Package(s) - CA-D Resource(s) |  | 21d | 2020-04-01 A | 2020-11-30 A | S324600 SS | 100% |  | 2020-07-24 | 2020-08-21 |  |  |  | PROF5 AD [16 h]; TECH3 AD [120 h]; PROF4 AD [40 h] | 22,306.27 | PO&ADS324610 | 0 | S277000 | S324610 | CA | Not Started | C | Mills, Jim | L4 | BNL | Procurement | Chris Pontieri | BNL | null | POM02.2.03.04 | Hock, John | C | 2.03 | 16732 | 2.03 | 04 | C-AD | S324610 | S277000 | 190317 ELM remove proc nos. | 003 |  |  |  |  |  |  |  |  |  |  |
| S324500 |  | End Caps/ Pole Tips - Design & Safety Reviews Complete Released for Production | milestone | 0d | 2020-10-30 A | 2020-10-30 A | S324400 FF, S324410 FF | 100% |  | 2020-11-20 | 2020-11-20 |  |  |  |  |  | S324500 | 0 | S276900 |  | NOCA | Not Started | C | Mills, Jim | L4 | BNL | Management Tech Reviews | Chris Pontieri | BNL | null | POM02.2.03.04 | Hock, John |  |  |  |  | 04 |  |  | S276900 |  |  | L5 |  |  |  |  |  |  |  |  |  |
| S324800 |  | End Caps/ Pole Tips - Provide Requirement to Procurement |  | 5d | 2020-12-15 A | 2020-12-22 A | S324700, S324710 | 100% |  | 2021-01-08 | 2021-01-14 |  |  |  | PROF5 AD [16 h] | 2,802.64 | S324800 | 0 | S27700004 | S324800 | CA | Not Started | C | Mills, Jim | L4 | BNL | Procurement | Chris Pontieri | BNL | null | POM02.2.03.04 | Hock, John | C | 2.03 | 16732 | 2.03 | 04 |  |  | S273400 |  |  |  | 2018-08-01 | PP1 | MP209120 |  |  |  |  |  |  |
| S324700 |  | End Caps/ Pole Tips - Procurement Readiness Review - Physics Resource(s) |  | 5d | 2020-12-21 A | 2020-12-23 A | S324600, S324610 | 100% |  | 2020-12-31 | 2021-01-07 |  |  |  | TECH3 PO M [24 h]; TECH3 PO D [20 h] | 5,172.02 | PO&AD | 0 | S27700002 | S324700 | CA | Not Started | C | Mills, Jim | L4 | BNL | Procurement | Chris Pontieri | BNL | null | POM02.2.03.04 | Hock, John | C | 2.03 | 16732 | 2.03 | 04 | PO |  | S271200 | 190317 ELM remove proc nos. | 003 |  |  |  |  |  |  |  |  |  |  |
| S324710 |  | End Caps/ Pole Tips - Procurement Readiness Review - CA-D Resource(s) |  | 5d | 2020-12-21 A | 2020-12-23 A | S324700 SS | 100% |  | 2020-12-31 | 2021-01-07 |  |  |  | PROF5 AD [16 h]; TECH3 AD [20 h]; PROF4 AD [24 h] | 8,793.95 | PO&ADS324710 | 0 | S27700002 | S324710 | CA | Not Started | C | Mills, Jim | L4 | BNL | Procurement | Chris Pontieri | BNL | null | POM02.2.03.04 | Hock, John | C | 2.03 | 16732 | 2.03 | 04 | C-AD | S324710 | S271200 | 190317 ELM remove proc nos. | 003 |  |  |  |  |  |  |  |  |  |  |
| S324900 |  | End Caps/ Pole Tips - Prepare & Send Solicitation |  | 5d | 2021-01-04 A | 2021-01-08 A | S324800 | 100% |  |  |  |  |  |  |  |  | S324900 | 0 | S27700006 |  | NOCA | Not Started | C | Mills, Jim | L4 | BNL | Procurement | Chris Pontieri | BNL | null | POM02.2.03.04 | Hock, John |  |  |  |  | 04 |  |  |  |  |  |  | 2018-08-01 | PP2 | MP209120 |  |  |  |  |  |  |
| S325000 |  | End Caps/ Pole Tips - Vendor Responses - Physics Resource(s) |  | 30d | 2021-01-11 A | 2021-01-28 A | S324900 | 100% |  | 2021-01-11 | 2021-02-23 |  |  |  | TECH3 PO D [10 h] | 1,175.46 | PO&AD | 0 | S27700020 | S325000 | CA | Not Started | C | Mills, Jim | L4 | BNL | Procurement | Chris Pontieri | BNL | null | POM02.2.03.04 | Hock, John | C | 2.03 | 16732 | 2.03 | 04 | PO |  |  |  |  |  |  | PP3 | MP209120 |  |  |  |  |  |  |
| S325010 |  | End Caps/ Pole Tips - Vendor Responses - CA-D Resource(s) |  | 30d | 2021-01-11 A | 2021-01-28 A | S325000 SS | 100% |  | 2021-01-11 | 2021-02-23 |  |  |  | PROF5 AD [16 h]; TECH3 AD [10 h]; PROF4 AD [16 h] | 6,405.02 | PO&ADS325010 | 0 | S27700020 | S325010 | CA | Not Started | C | Mills, Jim | L4 | BNL | Procurement | Chris Pontieri | BNL | null | POM02.2.03.04 | Hock, John | C | 2.03 | 16732 | 2.03 | 04 | C-AD | S325010 |  |  |  |  |  | PP3 | MP209120 |  |  |  |  |  |  |
| S325100 |  | End Caps/ Pole Tips - Vendor Selection - Physics Resource(s) |  | 30d | 2021-01-29 A | 2021-02-26 A | S325000, S325010 | 100% |  | 2021-02-24 | 2021-04-06 |  |  |  | TECH3 PO D [10 h] | 1,175.46 | PO&AD | 0 | S277100 | S325100 | CA | Not Started | C | Mills, Jim | L4 | BNL | Procurement | Chris Pontieri | BNL | null | POM02.2.03.04 | Hock, John | C | 2.03 | 16732 | 2.03 | 04 | PO |  | S277100 |  |  |  |  | PP4 | MP209120 |  |  |  |  |  |  |
| S325110 |  | End Caps/ Pole Tips - Vendor Selection - CA-D Resource(s) |  | 30d | 2021-01-29 A | 2021-02-26 A | S325100 SS | 100% |  | 2021-02-24 | 2021-04-06 |  |  |  | PROF5 AD [16 h]; TECH3 AD [10 h]; PROF4 AD [16 h] | 6,405.02 | PO&ADS325110 | 0 | S277100 | S325110 | CA | Not Started | C | Mills, Jim | L4 | BNL | Procurement | Chris Pontieri | BNL | null | POM02.2.03.04 | Hock, John | C | 2.03 | 16732 | 2.03 | 04 | C-AD | S325110 | S277100 |  |  |  |  | PP4 | MP209120 |  |  |  |  |  |  |
| S325200 |  | End Caps/ Pole Tips - Contract Award(s) | milestone | 0d | 2021-02-26 A | 2021-02-26 A | S325100, S325110 | 100% |  | 2021-03-01 | 2021-03-01 |  |  |  |  |  | S325200 | 0 | S27710002 |  | NOCA | Not Started | C | Mills, Jim | L4 | BNL | Procurement | Chris Pontieri | BNL | null | POM02.2.03.04 | Hock, John |  |  |  |  | 04 |  |  |  |  |  | L4 |  | PP5 | MP209120 | Contract Award |  |  |  |  |  |
| S325300 |  | End Caps/ Pole Tips - Contract lead Time |  | 180d | 2021-02-26 A | 2021-08-25 | S325200, OBLG325210 | 11% | 60d | 2021-03-02 | 2021-11-15 | 119d | 0d | 2021-08-25 |  |  | S325300 | 0 | S277200 | S325300 | NOCA | Not Started | C | Mills, Jim | L4 | BNL | Procurement | Chris Pontieri | BNL | null | POM02.2.03.04 | Hock, John | C |  |  |  | 04 |  |  | S277200 |  | 012 |  |  | PP6 | MP209120 |  |  |  |  |  |  |
| OBLG325210 |  | End Caps/ Pole Tips - Obligation |  | 1d | 2021-06-01 | 2021-06-01 | S325100, S325110 |  |  |  |  | 119d | 0d |  | Obligation Resource [715692 h] | 715,691.99 | S325200 | 0 | S27710002 |  |  | Not Started | C | Mills, Jim | L4 | BNL | Procurement | Chris Pontieri | BNL | null | POM02.2.03.04 | Hock, John |  |  |  |  | 04 |  |  |  |  |  | L4 |  | PP5 | MP209120 |  | OBLG |  |  |  |  |
| S325400 |  | End Caps/ Pole Tips - Delivery Acceptance |  | 0d | 2021-08-26 | 2021-08-26 | S325300 |  |  |  |  | 129d | 0d |  | Material (Purchase (1st $2M) [890262 h] | 993,188.32 | S325400 | 0 | S277300 | S325400 | CA | Not Started | C | Mills, Jim | M4 | BNL | Procurement | Chris Pontieri | BNL | null | POM02.2.03.04 | Hock, John | C | 2.03 | 16732 | 2.03 | 04 |  |  | S277300 |  | 023 |  |  | PP6 | MP209120 | Delivery | FAB | UDF_G3 | UDF_G3 | 715691.873758 | 1 |
| S325410 |  | Completed - End Caps/ Pole Tips - Delivery Acceptance | milestone | 0d | 2021-08-26 | 2021-08-26 | S325400 FF |  |  |  |  | 129d | 10d |  |  |  | S325400 | 0 | S277300 |  | NOCA | Not Started | C | Mills, Jim |  | BNL | Procurement | Chris Pontieri | BNL |  | POM02.2.03.04 | Hock, John |  |  |  |  | 04 |  |  | S277300 |  |  | L5 |  |  |  |  |  |  |  |  |  |
| S325500 |  | End Caps/ Pole Tips - Delivery Acceptance Support Labor - Physics Resource(s) |  | 10d | 2021-08-26 | 2021-09-09 | S325300 |  |  |  |  | 119d | 0d |  | TECH3 PO M [40 h]; TECH3 PO D [44 h] | 9,873.85 | PO&AD | 0 | S277350 | S325500 | CA | Not Started | C | Mills, Jim | L4 | BNL | Procurement | Chris Pontieri | BNL | null | POM02.2.03.04 | Hock, John | C | 2.03 | 16732 | 2.03 | 04 | PO |  | S277300 | 190317 ELM remove proc nos. | 003 |  |  |  |  |  |  |  |  |  |  |
| S325510 |  | End Caps/ Pole Tips - Delivery Acceptance Support Labor - CA-D Resource(s) |  | 10d | 2021-08-26 | 2021-09-09 | S325500 SS |  |  |  |  | 119d | 0d |  | PROF5 AD [36 h]; TECH3 AD [44 h]; PROF4 AD [52 h] | 19,365.47 | PO&ADS325510 | 0 | S277350 | S325510 | CA | Not Started | C | Mills, Jim | L4 | BNL | Procurement | Chris Pontieri | BNL | null | POM02.2.03.04 | Hock, John | C | 2.03 | 16732 | 2.03 | 04 | C-AD | S325510 | S277300 | 190317 ELM remove proc nos. | 003 |  |  |  |  |  |  |  |  |  |  |
| S325600 |  | End Caps/ Pole Tips - Ready for Installation | milestone | 0d | 2021-09-09 | 2021-09-09 | S325500 FF, S325510 FF, S325410 FF |  |  |  |  | 119d |  |  |  |  | S325600 | 0 | S277400 |  | NOCA | Not Started | C | Mills, Jim | L4 | BNL | Procurement | Chris Pontieri | BNL | null | POM02.2.03.04 | Hock, John |  |  |  |  | 04 |  |  | S277400 |  |  | L3 |  |  |  |  |  |  |  |  |  |

Notes:
- S324000: BNL_UDF_Old Activity Name 181221: End Caps/ Pole Tips - Engineering & Analysis (includes drive system)
- S324010: BNL_UDF_Old Activity Name 181221: End Caps/ Pole Tips - Engineering & Analysis (includes drive system)
- S324100: BNL_UDF_Old Activity Name 181221: End Caps/ Pole Tips - Design Controls for Drive System
- S324110: BNL_UDF_Old Activity Name 181221: End Caps/ Pole Tips - Design Controls for Drive System
- S324200: BNL_UDF_Old Activity Name 181221: End Caps/ Pole Tips - Assembly & Detail Drawing
- S324210: BNL_UDF_Old Activity Name 181221: End Caps/ Pole Tips - Assembly & Detail Drawing
- S324300: BNL_UDF_Old Activity Name 181221: End Caps/ Pole Tips - Final Design Reviews (Design & Safety)
- S324310: BNL_UDF_Old Activity Name 181221: End Caps/ Pole Tips - Final Design Reviews (Design & Safety)
- S324400: BNL_UDF_Old Activity Name 181221: End Caps/ Pole Tips - Address Action Items from Design & Safety Reviews
- S324410: BNL_UDF_Old Activity Name 181221: End Caps/ Pole Tips - Address Action Items from Design & Safety Reviews
- S324600: BNL_UDF_Old Activity Name 181221: End Caps/ Pole Tips - Prepare Procurement Package(s)
- S324610: BNL_UDF_Old Activity Name 181221: End Caps/ Pole Tips - Prepare Procurement Package(s)
- S324500: BNL_UDF_Old Activity Name 181221: End Caps/ Pole Tips - Design & Safety Reviews Complete Released for Production
- S324800: BNL_UDF_Old Activity Name 181221: End Caps/ Pole Tips - Provide Requirement to Procurement
- S324700: BNL_UDF_Old Activity Name 181221: End Caps/ Pole Tips - Procurement Readiness Review
- S324710: BNL_UDF_Old Activity Name 181221: End Caps/ Pole Tips - Procurement Readiness Review
- S324900: BNL_UDF_Old Activity Name 181221: End Caps/ Pole Tips - Prepare & Send Solicitation
- S325000: BNL_UDF_Old Activity Name 181221: End Caps/ Pole Tips - Vendor Responses
- S325010: BNL_UDF_Old Activity Name 181221: End Caps/ Pole Tips - Vendor Responses
- S325100: BNL_UDF_Old Activity Name 181221: End Caps/ Pole Tips - Vendor Selection
- S325110: BNL_UDF_Old Activity Name 181221: End Caps/ Pole Tips - Vendor Selection
- S325200: BNL_UDF_Old Activity Name 181221: End Caps/ Pole Tips - Contract Award(s)
- S325300: BNL_UDF_Old Activity Name 181221: End Caps/ Pole Tips - Contract lead Time
- OBLG325210: BNL_UDF_Old Activity Name 181221: End Caps/ Pole Tips - Contract Award(s)
- S325400: BNL_UDF_Old Activity Name 181221: End Caps/ Pole Tips - Delivery Acceptance
- S325410: BNL_UDF_Old Activity Name 181221: End Caps/ Pole Tips - Delivery Acceptance
- S325500: BNL_UDF_Old Activity Name 181221: End Caps/ Pole Tips - Delivery Acceptance Support Labor
- S325510: BNL_UDF_Old Activity Name 181221: End Caps/ Pole Tips - Delivery Acceptance Support Labor
- S325600: BNL_UDF_Old Activity Name 181221: End Caps/ Pole Tips - Ready for Installation

| ID | WBS | Activity | Type | Duration | Start | Finish | Predecessors | Complete | Planned start | Planned finish | Total float | Free float | Constraint | Resources | Cost | BNL_UDF_Temp Text 01 | BNL_UDF_Percent Complete | BNL_UDF_Old Activity ID 181221 | BNL_Cobra WP | RG Check | BNL_Activity Status | BNL_Fund Source | BNL_Estimator | BNL_Cost Basis | BNL_Location | BNL_EDIA | BNL_CAM | BNL_Institution | BNL_OPC TEC (deprecated) | BNL_WBS | BNL_WBS Manager | BNL_EVT | BNL_Master Control Account | BNL_Account Number | BNL_Cobra Control Account | BNL_WBS_Hierarchical | Temp | BNL_UDF_Temp Text 02 | BNL_UDF_Status Comments | BNL_UDF_OPC TEC (deprecated) | BNL_PCR ID | Additional EVT documentation required | BNL_Milestone Level | BNL_UDF_Temp Date 01 | BNL_Proc Sig Phase | BNL_Proc Sig | BNL_Obligation | Indicator - Procurement | Indicator - Float | BNL_UDF_Remaining Tot Cost | BNL_UDF_Percent_remaining | SPH Proc Register | BNL_UDF_Exclude | Target Milestone Date | Variance | PMP Milestones |
| --- | --- | --- | --- | --- | --- | --- | --- | --- | --- | --- | --- | --- | --- | --- | --- | --- | --- | --- | --- | --- | --- | --- | --- | --- | --- | --- | --- | --- | --- | --- | --- | --- | --- | --- | --- | --- | --- | --- | --- | --- | --- | --- | --- | --- | --- | --- | --- | --- | --- | --- | --- | --- | --- | --- | --- | --- |
|  | 05 | **CC Bridge, Mid Platforms and Access** |  |  | 2019-11-01 | 2022-01-31 |  |  |  |  |  |  |  |  |  |  |  |  |  |  |  |  |  |  |  |  |  |  |  |  |  |  |  |  |  |  |  |  |  |  |  |  |  |  |  |  |  |  |  |  |  |  |  |  |  |  |
| S325700 |  | CC Bridge, Mid Platforms & Access - Engineering Analysis - Physics Resource(s) |  | 40d | 2019-11-01 A | 2020-03-31 A |  | 100% | 2020-05-15 | 2020-07-13 |  |  |  | TECH3 PO D [160 h] | 18,259.54 | PO&AD | 0 | S277598 | S325700 | CA | In Progress | C | Mills, Jim | L4 | BNL | Design | Chris Pontieri | BNL | null | POM02.2.03.05 | Hock, John | C | 2.03 | 16733 | 2.03 | 05 | PO |  |  |  |  |  |  |  |  |  |  |  |  |  |  |  |  |  |  |  |
| S325710 |  | CC Bridge, Mid Platforms & Access - Engineering Analysis - CA-D Resource(s) |  | 40d | 2019-11-01 A | 2020-03-31 A | S325700 SS | 100% | 2020-05-15 | 2020-07-13 |  |  |  | PROF4 AD [320 h]; PROF5 AD [160 h]; TECH3 AD [160 h] | 92,594.44 | PO&ADS325710 | 0 | S277598 | S325710 | CA | In Progress | C | Mills, Jim | L4 | BNL | Design | Chris Pontieri | BNL | null | POM02.2.03.05 | Hock, John | C | 2.03 | 16733 | 2.03 | 05 | C-AD | S325710 |  |  |  |  |  |  |  |  |  |  |  |  |  |  |  |  |  |  |
| S325800 |  | CC Bridge, Mid Platforms & Access - Assembly & Detail Drawings - Physics Resource(s) |  | 80d | 2020-04-01 A | 2021-01-29 A | S325700, S325710 | 100% | 2020-04-01 | 2020-07-23 |  |  |  | TECH3 PO M [32 h]; TECH3 PO D [320 h] | 40,170.99 | PO&AD | 0 | S277600 | S325800 | CA | Not Started | C | Mills, Jim | L4 | BNL | Design | Chris Pontieri | BNL | null | POM02.2.03.05 | Hock, John | C | 2.03 | 16733 | 2.03 | 05 | PO |  | 190606 IVS restructure | S277600 | 005 | Yes |  |  |  |  |  |  |  |  |  |  |  |  |  |  |
| S325810 |  | CC Bridge, Mid Platforms & Access - Assembly & Detail Drawings - CA-D Resource(s) |  | 80d | 2020-04-01 A | 2021-01-29 A | S325800 SS | 100% | 2020-04-01 | 2020-07-23 |  |  |  | PROF4 AD [320 h]; PROF5 AD [160 h]; TECH3 AD [320 h] | 110,853.98 | PO&ADS325810 | 0 | S277600 | S325810 | CA | Not Started | C | Mills, Jim | L4 | BNL | Design | Chris Pontieri | BNL | null | POM02.2.03.05 | Hock, John | C | 2.03 | 16733 | 2.03 | 05 | C-AD | S325810 |  | S277600 |  | Yes |  |  |  |  |  |  |  |  |  |  |  |  |  |  |
| S325900 |  | CC Bridge, Mid Platforms & Access - Final Design Reviews (Design & Safety) - Physics Resource(s) |  | 10d | 2020-04-01 A | 2020-10-28 A | S325800, S325810 | 100% | 2020-07-24 | 2020-08-06 |  |  |  | TECH3 PO D [40 h]; TECH3 PO M [8 h] | 5,477.86 | PO&AD | 0 | S277800 | S325900 | CA | Not Started | C | Mills, Jim | L4 | BNL | Management Tech Reviews | Chris Pontieri | BNL | null | POM02.2.03.05 | Hock, John | C | 2.03 | 16733 | 2.03 | 05 | PO |  |  | S277800 |  |  |  |  |  |  |  |  |  |  |  |  |  |  |  |  |
| S325910 |  | CC Bridge, Mid Platforms & Access - Final Design Reviews (Design & Safety) - CA-D Resource(s) |  | 10d | 2020-04-01 A | 2020-10-28 A | S325900 SS | 100% | 2020-07-24 | 2020-08-06 |  |  |  | PROF4 AD [40 h]; PROF5 AD [20 h]; TECH3 AD [40 h] | 13,856.75 | PO&ADS325910 | 0 | S277800 | S325910 | CA | Not Started | C | Mills, Jim | L4 | BNL | Management Tech Reviews | Chris Pontieri | BNL | null | POM02.2.03.05 | Hock, John | C | 2.03 | 16733 | 2.03 | 05 | C-AD | S325910 |  | S277800 |  |  |  |  |  |  |  |  |  |  |  |  |  |  |  |  |
| S326000 |  | CC Bridge, Mid Platforms & Access - Address Action Items from Design & Safety Reviews - Physics Resource(s) |  | 10d | 2020-04-01 A | 2020-10-29 A | S325900, S325910 | 100% | 2020-08-07 | 2020-08-20 |  |  |  | TECH3 PO M [8 h]; TECH3 PO D [40 h] | 5,477.86 | PO&AD | 0 | S277900 | S326000 | CA | Not Started | C | Mills, Jim | L4 | BNL | Management Tech Reviews | Chris Pontieri | BNL | null | POM02.2.03.05 | Hock, John | C | 2.03 | 16733 | 2.03 | 05 | PO |  |  | S277900 |  |  |  |  |  |  |  |  |  |  |  |  |  |  |  |  |
| S326010 |  | CC Bridge, Mid Platforms & Access - Address Action Items from Design & Safety Reviews - CA-D Resource(s) |  | 10d | 2020-04-01 A | 2020-10-29 A | S326000 SS | 100% | 2020-08-07 | 2020-08-20 |  |  |  | PROF4 AD [40 h]; PROF5 AD [20 h]; TECH3 AD [40 h] | 13,856.75 | PO&ADS326010 | 0 | S277900 | S326010 | CA | Not Started | C | Mills, Jim | L4 | BNL | Management Tech Reviews | Chris Pontieri | BNL | null | POM02.2.03.05 | Hock, John | C | 2.03 | 16733 | 2.03 | 05 | C-AD | S326010 |  | S277900 |  |  |  |  |  |  |  |  |  |  |  |  |  |  |  |  |
| S326100 |  | CC Bridge, Mid Platforms & Access - Design & Safety Reviews Complete Released for Production | milestone | 0d | 2020-10-30 A | 2020-10-30 A | S326000 FF, S326010 FF | 100% | 2020-11-20 | 2020-11-20 |  |  |  |  |  | S326100 | 0 | S278000 |  | NOCA | Not Started | C | Mills, Jim | L4 | BNL | Management Tech Reviews | Chris Pontieri | BNL | null | POM02.2.03.05 | Hock, John |  |  |  |  | 05 |  |  |  | S278000 |  |  | L4 |  |  |  |  |  |  |  |  |  |  |  |  |  |
| S326200 |  | CC Bridge, Mid Platforms & Access - Prepare Procurement Package(s) - Physics Resource(s) |  | 10d | 2021-01-29 A | 2021-02-12 A | S326100 | 100% | 2021-02-01 | 2021-02-12 |  |  |  | TECH3 PO M [24 h]; TECH3 PO D [80 h] | 12,224.76 | PO&AD | 0 | S278100 | S326200 | CA | Not Started | C | Mills, Jim | L4 | BNL | Procurement | Chris Pontieri | BNL | null | POM02.2.03.05 | Hock, John | C | 2.03 | 16733 | 2.03 | 05 | PO |  | 190317 ELM remove proc nos. | S278100 | 003 |  |  |  |  |  |  |  |  |  |  |  |  |  |  |  |
| S326210 |  | CC Bridge, Mid Platforms & Access - Prepare Procurement Package(s) - CA-D Resource(s) |  | 10d | 2021-01-29 A | 2021-02-12 A | S326200 SS | 100% | 2021-02-01 | 2021-02-12 |  |  |  | PROF4 AD [40 h]; PROF5 AD [16 h]; TECH3 AD [80 h] | 18,273.62 | PO&ADS326210 | 0 | S278100 | S326210 | CA | Not Started | C | Mills, Jim | L4 | BNL | Procurement | Chris Pontieri | BNL | null | POM02.2.03.05 | Hock, John | C | 2.03 | 16733 | 2.03 | 05 | C-AD | S326210 | 190317 ELM remove proc nos. | S278100 | 003 |  |  |  |  |  |  |  |  |  |  |  |  |  |  |  |
| S326300 |  | CC Bridge, Mid Platforms & Access - Procurement Readiness Review - Physics Resource(s) |  | 5d | 2021-02-16 A | 2021-02-22 A | S326200, S326210 | 100% |  |  |  |  |  | TECH3 PO M [24 h]; TECH3 PO D [20 h] | 5,172.02 | PO&AD | 0 | S278104 | S326300 | CA | Not Started | C | Mills, Jim | L4 | BNL | Procurement | Chris Pontieri | BNL | null | POM02.2.03.05 | Hock, John | C | 2.03 | 16733 | 2.03 | 05 | PO |  | 190317 ELM remove proc nos. | S271200 | 003 |  |  |  |  |  |  |  |  |  |  |  |  |  |  |  |
| S326310 |  | CC Bridge, Mid Platforms & Access - Procurement Readiness Review - CA-D Resource(s) |  | 5d | 2021-02-16 A | 2021-02-22 A | S326300 SS | 100% |  |  |  |  |  | PROF4 AD [24 h]; PROF5 AD [16 h]; TECH3 AD [20 h] | 8,793.95 | PO&ADS326310 | 0 | S278104 | S326310 | CA | Not Started | C | Mills, Jim | L4 | BNL | Procurement | Chris Pontieri | BNL | null | POM02.2.03.05 | Hock, John | C | 2.03 | 16733 | 2.03 | 05 | C-AD | S326310 | 190317 ELM remove proc nos. | S271200 | 003 |  |  |  |  |  |  |  |  |  |  |  |  |  |  |  |
| F317050 |  | CC Bridge, Mid Platforms & Access - Prepare & Send Solicitation |  | 5d | 2021-02-22 A | 2021-02-25 A | S326400 | 100% | 2021-03-02 | 2021-03-08 |  |  |  |  |  | S326500 | 0 | S278108 |  | NOCA | Not Started | C | Mills, Jim | L4 | BNL | Procurement | Chris Pontieri | BNL | null | POM02.2.03.05 | Hock, John |  |  |  |  | 05 |  |  |  |  |  |  |  | 2018-08-01 | PP2 | MP209110 |  |  |  |  |  |  |  |  |  |  |
| S326400 |  | CC Bridge, Mid Platforms & Access - Provide Requirement to Procurement |  | 5d | 2021-02-23 A | 2021-02-26 A | S326300, S326310 | 100% | 2021-02-23 | 2021-03-01 |  |  |  | PROF5 AD [16 h] | 2,802.64 | S326400 | 0 | S278106 | S326400 | CA | Not Started | C | Mills, Jim | L4 | BNL | Procurement | Chris Pontieri | BNL | null | POM02.2.03.05 | Hock, John | C | 2.03 | 16733 | 2.03 | 05 |  |  |  | S273400 |  |  |  | 2018-08-01 | PP1 | MP209110 |  |  |  |  |  |  |  |  |  |  |
| S326600 |  | CC Bridge, Mid Platforms & Access - Vendor Responses - Physics Resource(s) |  | 30d | 2021-03-15 A | 2021-04-21 A | F317050 | 100% | 2021-04-01 | 2021-05-12 |  |  |  | TECH3 PO D [60 h] | 7,052.75 | PO&AD | 0 | S278110 | S326600 | CA | Not Started | C | Mills, Jim | L4 | BNL | Procurement | Chris Pontieri | BNL | null | POM02.2.03.05 | Hock, John | C | 2.03 | 16733 | 2.03 | 05 | PO |  |  |  |  |  |  |  | PP3 | MP209110 |  |  |  |  |  |  |  |  |  |  |
| S326610 |  | CC Bridge, Mid Platforms & Access - Vendor Responses - CA-D Resource(s) |  | 30d | 2021-03-15 A | 2021-04-21 A | S326600 SS | 100% | 2021-04-01 | 2021-05-12 |  |  |  | PROF4 AD [16 h]; PROF5 AD [8 h]; TECH3 AD [60 h] | 10,881 | PO&ADS326610 | 0 | S278110 | S326610 | CA | Not Started | C | Mills, Jim | L4 | BNL | Procurement | Chris Pontieri | BNL | null | POM02.2.03.05 | Hock, John | C | 2.03 | 16733 | 2.03 | 05 | C-AD | S326610 |  |  |  |  |  |  | PP3 | MP209110 |  |  |  |  |  |  |  |  |  |  |
| OBLG326810 |  | CC Bridge, Mid Platforms & Access - Obligation |  | 1d | 2021-05-17 A | 2021-05-26 A | S326700, S326710 | 100% | 2021-07-14 | 2021-07-14 |  |  |  | Obligation Resource [379627 h] | 379,627.45 | S326800 | 0 | S278204 |  |  | Not Started | C | Mills, Jim | L4 | BNL | Procurement | Chris Pontieri | BNL | null | POM02.2.03.05 | Hock, John |  |  |  |  | 05 |  |  |  |  |  |  | L4 |  | PP5 | MP209110 | OBLG |  |  |  |  |  |  |  |  |  |
| S326700 |  | CC Bridge, Mid Platforms & Access - Vendor Selection - Physics Resource(s) |  | 30d | 2021-06-01 | 2021-07-13 | S326600, S326610 |  |  |  | 0d |  |  | TECH3 PO M [24 h]; TECH3 PO D [60 h] | 9,873.85 | PO&AD | 0 | S278200 | S326700 | CA | Not Started | C | Mills, Jim | L4 | BNL | Procurement | Chris Pontieri | BNL | null | POM02.2.03.05 | Hock, John | C | 2.03 | 16733 | 2.03 | 05 | PO |  |  | S278200 |  |  |  |  | PP4 | MP209110 |  |  |  |  |  |  |  |  |  |  |
| S326710 |  | CC Bridge, Mid Platforms & Access - Vendor Selection - CA-D Resource(s) |  | 30d | 2021-06-01 | 2021-07-13 | S326700 SS |  |  |  | 0d |  |  | PROF4 AD [16 h]; PROF5 AD [16 h]; TECH3 AD [60 h] | 12,282.32 | PO&ADS326710 | 0 | S278200 | S326710 | CA | Not Started | C | Mills, Jim | L4 | BNL | Procurement | Chris Pontieri | BNL | null | POM02.2.03.05 | Hock, John | C | 2.03 | 16733 | 2.03 | 05 | C-AD | S326710 |  | S278200 |  |  |  |  | PP4 | MP209110 |  |  |  |  |  |  |  |  |  |  |
| S327150 |  | Access stairs for upper platforms |  | 166d | 2021-06-01 | 2022-01-31 |  |  |  |  | 34d |  | start on or after 2021-06-01 | Material (Purchase (1st $2M) [45000 h] | 50,202.61 | S327100 | 0 | S278400 | S327150 | CA | Not Started | C | Mills, Jim | M4 | BNL | Procurement | Chris Pontieri | BNL | null | POM02.2.03.05 | Hock, John | F | 2.03 | 16733 | 2.03 | 05 |  |  |  | S278400 | 024 |  |  |  | PP6 | MP209110 | FAB | UDF_G3 | UDF_G1 | 372183.87016 | 1 | Delivery |  |  |  |  |
| S326800 |  | CC Bridge, Mid Platforms & Access - Contract Award(s) | milestone | 0d | 2021-07-14 | 2021-07-14 | S326700, S326710 |  |  |  | 0d |  |  |  |  | S326800 | 0 | S278204 |  | NOCA | Not Started | C | Mills, Jim | L4 | BNL | Procurement | Chris Pontieri | BNL | null | POM02.2.03.05 | Hock, John |  |  |  |  | 05 |  |  |  |  |  |  | L4 |  | PP5 | MP209110 |  |  |  |  |  | Contract Award |  |  |  |  |
| S326900 |  | CC Bridge, Mid Platforms & Access - BNL Oversight - Physics Resource(s) |  | 85d | 2021-07-14 | 2021-11-12 | S326800, OBLG326810 |  |  |  | 0d |  |  | TECH3 PO D [36 h]; TECH3 PO M [72 h] | 12,824.88 | PO&AD | 0 | S278300 | S326900 | CA | Not Started | C | Mills, Jim | L4 | BNL | Procurement | Chris Pontieri | BNL | null | POM02.2.03.05 | Hock, John | C | 2.03 | 16733 | 2.03 | 05 | PO |  | 190317 ELM remove proc nos. | S278300 | 003 | Yes |  |  |  |  |  |  |  |  |  |  |  |  |  |  |
| S326910 |  | CC Bridge, Mid Platforms & Access - BNL Oversight - CA-D Resource(s) |  | 85d | 2021-07-14 | 2021-11-12 | S326900 SS |  |  |  | 0d |  |  | PROF4 AD [60 h]; PROF5 AD [30 h]; TECH3 AD [36 h] | 18,777.82 | PO&ADS326910 | 0 | S278300 | S326910 | CA | Not Started | C | Mills, Jim | L4 | BNL | Procurement | Chris Pontieri | BNL | null | POM02.2.03.05 | Hock, John | C | 2.03 | 16733 | 2.03 | 05 | C-AD | S326910 | 190317 ELM remove proc nos. | S278300 | 003 | Yes |  |  |  |  |  |  |  |  |  |  |  |  |  |  |
| S327000 |  | CC Bridge, Mid Platforms & Access - Vendor Leadtime |  | 85d | 2021-07-14 | 2021-11-12 | S326900 SS, S326910 SS |  |  |  | 0d |  |  |  |  | S327000 | 0 | S278350 |  | NOCA | Not Started | C | Mills, Jim | L4 | BNL | Procurement | Chris Pontieri | BNL | null | POM02.2.03.05 | Hock, John | C |  |  |  | 05 |  |  |  | S277500 |  |  |  |  | PP6 | MP209110 |  |  |  |  |  |  | MP6LAEXCLUDE |  |  |  |
| S327100 |  | CC Bridge, Mid Platforms & Access - Delivery Acceptance |  | 5d | 2021-11-15 | 2021-11-19 | S326900, S327000, S326910 |  |  |  | 5d | 0d |  | Material (Purchase (1st $2M) [320659 h] | 379,627.55 | S327100 | 0 | S278400 | S327100 | CA | Not Started | C | Mills, Jim | M4 | BNL | Procurement | Chris Pontieri | BNL | null | POM02.2.03.05 | Hock, John | C | 2.03 | 16733 | 2.03 | 05 |  |  |  | S278400 |  |  |  |  | PP6 | MP209110 | FAB | UDF_G1 | UDF_G1 | 372183.87016 | 1 | Delivery |  |  |  |  |
| S327200 |  | CC Bridge, Mid Platforms & Access - Delivery Acceptance Support Labor - Physics Resource(s) |  | 10d | 2021-11-15 | 2021-11-30 | S326900, S327000, S326910 |  |  |  | 0d |  |  | TECH3 PO D [4 h]; TECH3 PO M [8 h] | 1,452.87 | PO&AD | 0 | S278410 | S327200 | CA | Not Started | C | Mills, Jim | L4 | BNL | Procurement | Chris Pontieri | BNL | null | POM02.2.03.05 | Hock, John | C | 2.03 | 16733 | 2.03 | 05 | PO |  | 190317 ELM remove proc nos. | S278400 | 003 |  |  |  |  |  |  |  |  |  |  |  |  |  |  |  |
| S327210 |  | CC Bridge, Mid Platforms & Access - Delivery Acceptance Support Labor - CA-D Resource(s) |  | 10d | 2021-11-15 | 2021-11-30 | S327200 SS |  |  |  | 0d |  |  | CRAFT3 [8 h]; PROF4 AD [16 h]; PROF5 AD [16 h]; TECH3 AD [4 h] | 6,932.25 | PO&ADS327210 | 0 | S278410 | S327210 | CA | Not Started | C | Mills, Jim | L4 | BNL | Procurement | Chris Pontieri | BNL | null | POM02.2.03.05 | Hock, John | C | 2.03 | 16733 | 2.03 | 05 | C-AD | S327210 | 190317 ELM remove proc nos. | S278400 | 003 |  |  |  |  |  |  |  |  |  |  |  |  |  |  |  |
| S327110 |  | Completed - CC Bridge, Mid Platforms & Access - Delivery Acceptance | milestone | 0d | 2021-11-19 | 2021-11-19 | S327100 FF |  |  |  | 5d |  |  |  |  | S327100 | 0 | S278400 |  | NOCA | Not Started | C | Mills, Jim |  | BNL | Procurement | Chris Pontieri | BNL |  | POM02.2.03.05 | Hock, John |  |  | 16733 |  | 05 |  |  |  | S278400 |  |  | L5 |  |  |  |  |  |  |  |  |  |  |  |  |  |
| S327300 |  | CC Bridge, Mid Platforms & Access - Ready for Installation | milestone | 0d | 2021-11-30 | 2021-11-30 | S327200 FF, S327210 FF, S327110 FF |  |  |  | 0d |  |  |  |  | S327300 | 0 | S278500 |  | NOCA | Not Started | C | Mills, Jim | L4 | BNL | Procurement | Chris Pontieri | BNL | null | POM02.2.03.05 | Hock, John |  |  |  |  | 05 |  |  |  | S278500 |  |  | L4 |  |  |  |  |  |  |  |  |  |  | 2021-10-31 | -19 | PMP_2x |

Notes:
- S325700: BNL_UDF_Old Activity Name 181221: CC Bridge, Mid Platforms & Access - Engineering Analysis
- S325710: BNL_UDF_Old Activity Name 181221: CC Bridge, Mid Platforms & Access - Engineering Analysis
- S325800: BNL_UDF_Old Activity Name 181221: CC Bridge, Mid Platforms & Access - Assembly & Detail Drawings
- S325810: BNL_UDF_Old Activity Name 181221: CC Bridge, Mid Platforms & Access - Assembly & Detail Drawings
- S325900: BNL_UDF_Old Activity Name 181221: CC Bridge, Mid Platforms & Access - Final Design Reviews (Design & Safety)
- S325910: BNL_UDF_Old Activity Name 181221: CC Bridge, Mid Platforms & Access - Final Design Reviews (Design & Safety)
- S326000: BNL_UDF_Old Activity Name 181221: CC Bridge, Mid Platforms & Access - Address Action Items from Design & Safety Reviews
- S326010: BNL_UDF_Old Activity Name 181221: CC Bridge, Mid Platforms & Access - Address Action Items from Design & Safety Reviews
- S326100: BNL_UDF_Old Activity Name 181221: CC Bridge, Mid Platforms & Access - Design & Safety Reviews Complete Released for Production
- S326200: BNL_UDF_Old Activity Name 181221: CC Bridge, Mid Platforms & Access - Prepare Procurement Package(s)
- S326210: BNL_UDF_Old Activity Name 181221: CC Bridge, Mid Platforms & Access - Prepare Procurement Package(s)
- S326300: BNL_UDF_Old Activity Name 181221: CC Bridge, Mid Platforms & Access - Procurement Readiness Review
- S326310: BNL_UDF_Old Activity Name 181221: CC Bridge, Mid Platforms & Access - Procurement Readiness Review
- F317050: BNL_UDF_Old Activity Name 181221: CC Bridge, Mid Platforms & Access - Prepare & Send Solicitation
- S326400: BNL_UDF_Old Activity Name 181221: CC Bridge, Mid Platforms & Access - Provide Requirement to Procurement
- S326600: BNL_UDF_Old Activity Name 181221: CC Bridge, Mid Platforms & Access - Vendor Responses
- S326610: BNL_UDF_Old Activity Name 181221: CC Bridge, Mid Platforms & Access - Vendor Responses
- OBLG326810: BNL_UDF_Old Activity Name 181221: CC Bridge, Mid Platforms & Access - Contract Award(s)
- S326700: BNL_UDF_Old Activity Name 181221: CC Bridge, Mid Platforms & Access - Vendor Selection
- S326710: BNL_UDF_Old Activity Name 181221: CC Bridge, Mid Platforms & Access - Vendor Selection
- S327150: BNL_UDF_Old Activity Name 181221: CC Bridge, Mid Platforms & Access - Delivery Acceptance
- S326800: BNL_UDF_Old Activity Name 181221: CC Bridge, Mid Platforms & Access - Contract Award(s)
- S326900: BNL_UDF_Old Activity Name 181221: CC Bridge, Mid Platforms & Access - BNL Oversite
- S326910: BNL_UDF_Old Activity Name 181221: CC Bridge, Mid Platforms & Access - BNL Oversite
- S327000: BNL_UDF_Old Activity Name 181221: CC Bridge, Mid Platforms & Access - Vendor Leadtime
- S327100: BNL_UDF_Old Activity Name 181221: CC Bridge, Mid Platforms & Access - Delivery Acceptance
- S327200: BNL_UDF_Old Activity Name 181221: CC Bridge, Mid Platforms & Access - Delivery Acceptance Support Labor
- S327210: BNL_UDF_Old Activity Name 181221: CC Bridge, Mid Platforms & Access - Delivery Acceptance Support Labor
- S327110: BNL_UDF_Old Activity Name 181221: CC Bridge, Mid Platforms & Access - Delivery Acceptance
- S327300: BNL_UDF_Old Activity Name 181221: CC Bridge, Mid Platforms & Access - Ready for Installation

| ID | WBS | Activity | Type | Duration | Start | Finish | Predecessors | Complete | Remaining | Planned start | Planned finish | Total float | Free float | Constraint | Expected finish | Resources | Cost | BNL_UDF_Exclude | BNL_UDF_Temp Text 01 | BNL_UDF_Percent Complete | BNL_UDF_Old Activity ID 181221 | BNL_Cobra WP | RG Check | BNL_Activity Status | BNL_Fund Source | BNL_Estimator | BNL_Cost Basis | BNL_Location | BNL_EDIA | BNL_CAM | BNL_OPC TEC (deprecated) | BNL_WBS | BNL_Actuals | BNL_FY | BNL_EVT | BNL_Master Control Account | BNL_Account Number | BNL_PCR ID | BNL_Cobra Control Account | BNL_WBS_Hierarchical | Completed | BNL_UDF_OPC TEC (deprecated) | BNL_UDF_Temp Date 01 | BNL_Institution | BNL_Milestone Level | BNL_Proc Sig Phase | BNL_Proc Sig | BNL_Obligation | SPH Proc Register | BNL_Management or Mgmt Travel | Cost = Awarded Proc or Mgmt | Indicator - Procurement | Indicator - Float | BNL_UDF_Remaining Tot Cost | BNL_UDF_Percent_remaining |
| --- | --- | --- | --- | --- | --- | --- | --- | --- | --- | --- | --- | --- | --- | --- | --- | --- | --- | --- | --- | --- | --- | --- | --- | --- | --- | --- | --- | --- | --- | --- | --- | --- | --- | --- | --- | --- | --- | --- | --- | --- | --- | --- | --- | --- | --- | --- | --- | --- | --- | --- | --- | --- | --- | --- | --- |
|  | 04 | **Infrastructure** |  |  | 2017-02-01 | 2022-11-28 |  |  |  |  |  |  |  |  |  |  |  |  |  |  |  |  |  |  |  |  |  |  |  |  |  |  |  |  |  |  |  |  |  |  |  |  |  |  |  |  |  |  |  |  |  |  |  |  |  |
|  | 01 | **Infrastructure Detector Support Systems** |  |  | 2017-02-01 | 2022-11-28 |  |  |  |  |  |  |  |  |  |  |  |  |  |  |  |  |  |  |  |  |  |  |  |  |  |  |  |  |  |  |  |  |  |  |  |  |  |  |  |  |  |  |  |  |  |  |  |  |  |
| S1000479 |  | Actuals - Labor - sPHENIX Infrastructure FY17 16723 |  | 169d | 2017-02-01 A | 2017-09-29 A | S100090 SS | 100% |  |  |  |  |  |  |  | Actual Labor [102.68 h] | 17,157.1 | MP6LAEXCLUDE | S309200 | 100 | S338500 | S1000479 | CA | Completed | C | Pisani, Rob | L1 | BNL | Design | Joel Vasquez | null | POM02.2.04.01 | Yes | 2017 | A | 2.04 | 16723 | 003 | 2.04 | 01 | yes |  |  |  |  |  |  |  |  |  |  |  |  |  |  |
| S1000639 |  | Actuals - Labor - sPHENIX Infrastructure FY18 16723 |  | 249d | 2017-10-01 A | 2018-09-28 A | S309200, S1000439, S1000479, S1000519, S1000559 | 100% |  | 2017-10-02 | 2018-09-28 |  |  |  |  | Actual Labor [123.98 h] | 20,716.18 | MP6LAEXCLUDE | S309300 | 100 | S339380 | S1000639 | CA | Completed | C | Pisani, Rob | L1 | BNL | Design | Joel Vasquez | null | POM02.2.04.01 | Yes | 2018 | A | 2.04 | 16723 | 003 | 2.04 | 01 | yes |  |  |  |  |  |  |  |  |  |  |  |  |  |  |
| S1001639 |  | Actuals - Labor - sPHENIX Infrastructure FY19 M8 16723 |  | 166d | 2018-10-01 A | 2019-05-31 A |  | 100% |  |  |  |  |  |  |  | Actual Labor [313.39 h] | 52,365.24 | MP6LAEXCLUDE | S309300 | 100 | S339380 | S1001639 | CA | Completed | C | Pisani, Rob | L1 | BNL | Design | Joel Vasquez | null | POM02.2.04.01 | Yes | 2019 | A | 2.04 | 16723 | 003 | 2.04 | 01 | yes |  |  |  |  |  |  |  |  |  |  |  |  |  |  |
| S1004960 |  | Actuals - Labor FY19 Jun-Sep 16723 |  | 84d | 2019-06-03 A | 2019-09-30 A |  | 100% |  |  |  |  |  |  |  | Actual Labor [126.42 h] | 21,123.22 | MP6LAEXCLUDE | S309300 | 100 | S339380 | S1004960 | CA | Completed | C | Pisani, Rob | L1 | BNL | Design | Joel Vasquez | null | POM02.2.04.01 | Yes | 2018 | A | 2.04 | 16723 | 003 | 2.04 | 01 | yes |  |  |  |  |  |  |  |  |  |  |  |  |  |  |
|  | 01 | **Line Electric Power Distribution** |  |  | 2018-03-01 | 2022-09-30 |  |  |  |  |  |  |  |  |  |  |  |  |  |  |  |  |  |  |  |  |  |  |  |  |  |  |  |  |  |  |  |  |  |  |  |  |  |  |  |  |  |  |  |  |  |  |  |  |  |
| S327400 |  | Evaluate Existing Power Distribution System for Line Electric Power |  | 65d | 2018-03-01 A | 2018-05-31 A | S100090 SS | 100% |  |  |  |  |  |  |  |  |  |  | S327400 | 100 | S278700 |  | NOCA | Completed | C | Pisani, Rob | L4 | BNL | Design | Joel Vasquez | null | POM02.2.04.01.01 |  |  | C |  | 16723 |  |  | 01 | yes | S278700 | 2019-01-01 | BNL |  |  |  |  |  |  |  |  |  |  |  |
| S327500 |  | Gather Design Requirements for All sPHENIX Subsystems for Line Electric Power |  | 105d | 2019-01-02 A | 2019-05-31 A | S327400 | 100% |  |  |  |  |  |  |  |  |  |  | S327500 | 10 | S278800 |  | NOCA | Completed | C | Pisani, Rob | L4 | BNL | Design | Joel Vasquez | null | POM02.2.04.01.01 |  |  | C |  | 16723 | 003,005 |  | 01 | yes | S278800 | 2019-07-31 | BNL |  |  |  |  |  |  |  |  |  |  |  |
| S327502 |  | Gather Design Requirements for All sPHENIX Subsystems for Line Electric Power Split |  | 42d | 2019-11-01 A | 2019-12-18 A | S327500 | 100% |  | 2019-11-01 | 2020-01-06 |  |  |  |  | PROF3 PO E [40 h] | 5,060.38 |  | S327500 | 10 | S278800 | S327502 | CA | In Progress | C | Pisani, Rob | L4 | BNL | Design | Joel Vasquez | null | POM02.2.04.01.01 |  |  | C | 2.04 | 16723 | 003,005 | 2.04 | 01 |  | S278800 | 2019-07-31 | BNL |  |  |  |  |  |  |  |  |  |  |  |
| S327600 |  | Evaluate Normal, Emergency and UPS Load Requirements for Line Electric Power |  | 5d | 2020-01-02 A | 2020-01-08 A | S327502 | 100% |  |  |  |  |  |  |  | PROF3 PO E [20 h] | 2,530.19 |  | S327600 | 0 | S278900 | S327600 | CA | Not Started | C | Pisani, Rob | L4 | BNL | Design | Joel Vasquez | null | POM02.2.04.01.01 |  |  | C | 2.04 | 16723 |  | 2.04 | 01 |  | S278900 |  | BNL |  |  |  |  |  |  |  |  |  |  |  |
| S1001999 |  | Calculate Power Transformer Requirements for Line Electric Power - Physics Resource(s) |  | 23d | 2020-01-09 A | 2020-01-30 A | S327600 | 100% |  | 2020-01-09 | 2020-02-11 |  |  |  |  | PROF4 PO E [40 h]; TECH3 PO D [40 h] | 10,455.49 |  | S327700 | 0 | S279000 | S1001999 | CA | Not Started | C | Pisani, Rob | L4 | BNL | Design | Joel Vasquez | null | POM02.2.04.01.01 |  |  | C | 2.04 | 16723 |  | 2.04 | 01 |  | S279000 | 2019-03-01 | BNL |  |  |  |  |  |  |  |  |  |  |  |
| S327700 |  | Calculate Power Transformer Requirements for Line Electric Power - CA-D Resource(s) |  | 23d | 2020-01-09 A | 2020-01-30 A | S327600 | 100% |  | 2020-01-09 | 2020-02-11 |  |  |  |  | PROF4 AD [16 h]; TECH3 AD [16 h] | 4,182.19 |  | S327700 | 0 | S279000 | S327700 | CA | Not Started | C | Pisani, Rob | L4 | BNL | Design | Joel Vasquez | null | POM02.2.04.01.01 |  |  | C | 2.04 | 16723 |  | 2.04 | 01 |  | S279000 | 2019-03-01 | BNL |  |  |  |  |  |  |  |  |  |  |  |
| S327501 |  | Gather Power Reqs for CRYO, Cooling and Lighting |  | 40d | 2020-03-30 A | 2020-03-31 A |  | 100% |  | 2020-04-01 | 2020-05-27 |  |  | start on or after 2020-04-01 |  | PROF3 PO E [40 h]; TECH3 PO D [20 h] | 7,342.82 |  | S327500 | 10 | S278800 | S327501 | NOCA | Completed | C | Pisani, Rob | L4 | BNL | Design | Joel Vasquez | null | POM02.2.04.01.01 |  |  | C | 2.04 | 16723 | 010 | 2.04 | 01 | yes | S278800 | 2019-07-31 | BNL |  |  |  |  |  |  |  |  |  |  |  |
| S1002039 |  | Size Conductors for Line Electric Power - Physics Resource(s) |  | 4d | 2020-08-17 A | 2020-09-30 A | S327700, S1001999, S327800 SS | 100% |  | 2020-08-17 | 2020-08-20 |  |  |  |  | PROF4 PO E [32 h]; TECH3 PO D [32 h] | 8,364.39 |  | S327800 | 0 | S279100 | S1002039 | CA | Not Started | C | Pisani, Rob | L4 | BNL | Design | Joel Vasquez | null | POM02.2.04.01.01 |  |  | C | 2.04 | 16723 |  | 2.04 | 01 |  | S279100 | 2019-04-01 | BNL |  |  |  |  |  |  |  |  |  |  |  |
| S327800 |  | Size Conductors for Line Electric Power - CA-D Resource(s) |  | 8d | 2020-08-17 A | 2020-09-30 A | S327700, S1001999 | 100% |  | 2020-08-17 | 2020-08-26 |  |  | start on or after 2020-08-17 |  | PROF4 AD [16 h]; TECH3 AD [16 h] | 4,182.19 |  | S327800 | 0 | S279100 | S327800 | CA | Not Started | C | Pisani, Rob | L4 | BNL | Design | Joel Vasquez | null | POM02.2.04.01.01 |  |  | C | 2.04 | 16723 | 010 | 2.04 | 01 |  | S279100 | 2019-04-01 | BNL |  |  |  |  |  |  |  |  |  |  |  |
| S1002079 |  | Create Line Electric Distribution Design/Schematic Drawings for Line Electric Power - Physics Resource(s) |  | 4d | 2020-08-27 A | 2021-03-31 A | S327800, S1002039 | 100% |  | 2020-08-27 | 2020-09-01 |  |  |  |  | TECH3 PO D [32 h]; PROF4 PO E [32 h] | 8,364.39 |  | S327900 | 0 | S279200 | S1002079 | CA | Not Started | C | Pisani, Rob | L4 | BNL | Design | Joel Vasquez | null | POM02.2.04.01.01 |  |  | C | 2.04 | 16723 |  | 2.04 | 01 |  | S279200 | 2019-05-01 | BNL |  |  |  |  |  |  |  |  |  |  |  |
| S327900 |  | Create Line Electric Distribution Design/Schematic Drawings for Line Electric Power - CA-D Resource(s) |  | 8d | 2020-08-27 A | 2021-03-31 A | S327800, S1002039 | 100% |  | 2020-08-27 | 2020-09-08 |  |  |  |  | PROF4 AD [32 h]; TECH3 AD [32 h] | 8,364.39 |  | S327900 | 0 | S279200 | S327900 | CA | Not Started | C | Pisani, Rob | L4 | BNL | Design | Joel Vasquez | null | POM02.2.04.01.01 |  |  | C | 2.04 | 16723 | 010 | 2.04 | 01 |  | S279200 | 2019-05-01 | BNL |  |  |  |  |  |  |  |  |  |  |  |
| S1002119 |  | Review Line Electric Distribution Design/Safety - Physics Resource(s) |  | 5d | 2020-11-17 A | 2020-11-27 A | S327900, S1002079 | 100% |  | 2020-12-01 | 2020-12-07 |  |  |  |  | PROF4 PO E [20 h] | 3,033.66 |  | S328000 | 0 | S279300 | S1002119 | CA | Not Started | C | Pisani, Rob | L4 | BNL | Design | Joel Vasquez | null | POM02.2.04.01.01 |  |  | C | 2.04 | 16723 |  | 2.04 | 01 |  | S279300 |  | BNL |  |  |  |  |  |  |  |  |  |  |  |
| S328000 |  | Review Line Electric Distribution Design/Safety - CA-D Resource(s) |  | 10d | 2020-11-17 A | 2020-11-27 A | S327900, S1002079 | 100% |  | 2020-12-01 | 2020-12-14 |  |  |  |  | PROF4 AD [24 h] | 3,640.39 |  | S328000 | 0 | S279300 | S328000 | CA | Not Started | C | Pisani, Rob | L4 | BNL | Design | Joel Vasquez | null | POM02.2.04.01.01 |  |  | C | 2.04 | 16723 | 010 | 2.04 | 01 |  | S279300 |  | BNL |  |  |  |  |  |  |  |  |  |  |  |
| S328100 |  | Address Action Items from Line Electric Distribution Design & Safety Reviews |  | 20d | 2020-11-17 A | 2020-11-27 A | S328000, S1002119 | 100% |  | 2020-12-15 | 2021-01-13 |  |  |  |  | TECH3 PO D [80 h]; PROF3 PO E [20 h] | 12,009.76 |  | S328100 | 0 | S279400 | S328100 | CA | Not Started | C | Pisani, Rob | L4 | BNL | Management Tech Reviews | Joel Vasquez | null | POM02.2.04.01.01 |  |  | C | 2.04 | 16723 | 010 | 2.04 | 01 |  | S279400 |  | BNL |  |  |  |  |  |  |  |  |  |  |  |
| S328200 |  | Design/Safety Reviews Complete, Line Electric Power Distribution Released for Production | milestone | 0d | 2021-04-01 A | 2021-04-01 A | S328100 FF | 100% |  |  |  |  |  |  |  |  |  |  | S328200 | 0 | S279500 |  | NOCA | Not Started | C | Pisani, Rob |  | BNL | Management Safety Reviews | Joel Vasquez |  | POM02.2.04.01.01 |  |  |  |  | 16723 | 010 |  | 01 |  | S279500 |  | BNL | L4 |  |  |  |  |  |  |  |  |  |  |
| S328500 |  | Procure Line Electric Power Distribution Components - Provide Requirements to Procurement |  | 60d | 2021-04-01 A | 2021-04-30 A | S328200 | 100% |  | 2021-04-01 | 2021-06-24 |  |  |  |  | PROF3 PO E [48 h] | 6,254.63 |  | S328500 | 0 | S279800 | S328500 | CA | Not Started | C | Pisani, Rob | L4 | BNL | Fab & Assy | Joel Vasquez | null | POM02.2.04.01.01 |  |  | C | 2.04 | 16723 | 010 | 2.04 | 01 |  | S279800 |  | BNL |  | PP1 | MP210070 |  |  |  |  |  |  |  |  |
| S328550 |  | Prepare Line Electric Power Distribution Components Procurement Package(s) |  | 60d | 2021-04-01 A | 2021-04-30 A | S328500 SS, S328200 | 100% |  | 2021-04-01 | 2021-06-24 |  |  |  |  | PROF3 PO E [60 h] | 7,818.29 |  | S328300 | 0 | S279600 | S328550 | CA | Not Started | C | Pisani, Rob | L4 | BNL | Procurement | Joel Vasquez | null | POM02.2.04.01.01 |  |  | C | 2.04 | 16723 | 010 | 2.04 | 01 |  | S279600 |  | BNL |  |  |  |  |  |  |  |  |  |  |  |
| S328700 |  | Procure Line Electric Power Distribution Components - Prepare and Send Solicitation |  | 20d | 2021-05-10 A | 2021-06-28 | S328550 | 80% | 20d | 2021-06-01 | 2021-06-28 | 123d | 0d |  | 2021-06-28 |  |  |  | S328700 | 0 | S279855 |  | NOCA | Not Started | C | Pisani, Rob | M4 | BNL | Fab & Assy | Joel Vasquez | null | POM02.2.04.01.01 |  |  |  |  | 16723 | 010 |  | 01 |  | S278600 |  | BNL |  | PP2 | MP210070 |  |  |  |  |  |  |  |  |
| S328800 |  | Procure Line Electric Power Distribution Components - Vendor Responses and Selection |  | 60d | 2021-06-29 | 2021-09-22 | S328700 |  |  |  |  | 123d | 0d |  |  |  |  |  | S328800 | 0 | S279860 |  | NOCA | Not Started | C | Pisani, Rob | M4 | BNL | Fab & Assy | Joel Vasquez | null | POM02.2.04.01.01 |  |  |  |  | 16723 | 010 |  | 01 |  | S278600 |  | BNL |  | PP4 | MP210070 |  |  |  |  |  |  |  |  |
| S328850 |  | Evaluate & Process Line Electric Power Distribution Components Bid |  | 60d | 2021-06-29 | 2021-09-22 | S328700 |  |  |  |  | 123d | 0d |  |  | PROF3 PO E [40 h] | 5,212.19 |  | S328400 | 0 | S279700 | S328850 | CA | Not Started | C | Pisani, Rob | L4 | BNL | Procurement | Joel Vasquez | null | POM02.2.04.01.01 |  |  | C | 2.04 | 16723 | 010 | 2.04 | 01 |  | S279700 |  | BNL |  |  |  |  |  |  |  |  |  |  |  |
| OBLG328910 |  | Procure Line Electric Power Distribution Components - Obligation |  | 1d | 2021-09-23 | 2021-09-23 | S328800 |  |  |  |  | 123d | 0d |  |  | Obligation Resource [58034.2 h] | 58,034.23 |  | S328900 | 0 | S279865 |  |  | Not Started | C | Pisani, Rob | M4 | BNL | Fab & Assy | Joel Vasquez | null | POM02.2.04.01.01 |  |  | K |  |  |  |  | 01 |  | S278600 |  | BNL |  | PP5 | MP210070 | OBLG |  |  |  |  |  |  |  |
| S328900 |  | Procure Line Electric Power Distribution Components - Contract Award | milestone | 0d | 2021-09-23 | 2021-09-23 | S328800, S328850 |  |  |  |  | 123d | 0d |  |  |  |  |  | S328900 | 0 | S279865 |  | NOCA | Not Started | C | Pisani, Rob | M4 | BNL | Fab & Assy | Joel Vasquez | null | POM02.2.04.01.01 |  |  |  |  | 16723 | 010 |  | 01 |  | S278600 |  | BNL | L5 | PP5 | MP210070 |  | Contract Award |  |  |  |  |  |  |
| S329000 |  | Procure Line Electric Power Distribution Components - Leadtime |  | 60d | 2021-09-23 | 2021-12-21 | S328900 SS, OBLG328910 SS |  |  |  |  | 123d | 0d |  |  |  |  |  | S329000 | 0 | S279870 |  | NOCA | Not Started | C | Pisani, Rob | M4 | BNL | Fab & Assy | Joel Vasquez | null | POM02.2.04.01.01 |  |  |  |  | 16723 | 010 |  | 01 |  | S278600 |  | BNL |  | PP6 | MP210070 |  |  |  |  |  |  |  |  |
| S277600 |  | 2022 Detector Support Systems L3 Project Management |  | 250d | 2021-10-01 | 2022-09-30 | S277500 |  |  |  |  | 0d |  | start on or after 2021-10-01 |  | PROF5 PO M [352 h] | 63,507.81 |  | S277600 | 0 | S337150 | S277600 | CA | Not Started | C | Yip, Kin | L2 | BNL | Management | Irina Sourikova | null | POM02.2.01.03 |  |  | A | 2.01 | 16721 | 025 | 2.04 | 04 |  | S248100 |  | BNL |  |  |  |  |  | Yes | Yes |  |  |  |  |
| S329100 |  | Procure Line Electric Power Distribution Components - Delivery Acceptance |  | 20d | 2021-12-22 | 2022-01-21 | S329000 |  |  |  |  | 123d | 0d |  |  | Material (Purchase (1st $2M) [50000 h] | 59,194.9 |  | S329100 | 0 | S279875 | S329100 | CA | Not Started | C | Pisani, Rob | M4 | BNL | Fab & Assy | Joel Vasquez | null | POM02.2.04.01.01 |  |  | C | 2.04 | 16723 | 010 | 2.04 | 01 |  | S278600 |  | BNL |  | PP6 | MP210070 | FAB | Delivery |  |  | UDF_G1 | UDF_G3 | 58034.2155 | 1 |
| S329200 |  | Perform Line Electric Power Distribution Components Acceptance |  | 20d | 2021-12-22 | 2022-01-21 | S329100 SS |  |  |  |  | 123d | 0d |  |  | PROF3 PO E [40 h]; TECH3 PO D [80 h] | 15,054.33 |  | S329200 | 0 | S279900 | S329200 | CA | Not Started | C | Pisani, Rob | L4 | BNL | Procurement | Joel Vasquez | null | POM02.2.04.01.01 |  |  | C | 2.04 | 16723 | 010 | 2.04 | 01 |  | S279900 |  | BNL |  |  |  |  |  |  |  |  |  |  |  |
| S329300 |  | Line Electric Power Distribution Components Ready for Installation | milestone | 0d | 2022-01-21 | 2022-01-21 | S329200 FF, S329100 FF |  |  |  |  | 123d | 0d |  |  |  |  |  | S329300 | 0 | S280000 |  | NOCA | Not Started | C | Pisani, Rob |  | BNL | Procurement | Joel Vasquez |  | POM02.2.04.01.01 |  |  |  |  | 16723 | 010 |  | 01 |  | S280000 |  | BNL | L3 |  |  |  |  |  |  |  |  |  |  |

Notes:
- S1000479: BNL_UDF_Status Comments: 190315 DurType to align with EVT / BNL_UDF_Old Activity Name 181221: Actuals - Labor - sPHENIX Infrastructure FY17
- S1000639: BNL_UDF_Status Comments: 190315 DurType to align with EVT / BNL_UDF_Old Activity Name 181221: Actuals - Labor - sPHENIX Infrastructure FY18
- S1001639: BNL_UDF_Status Comments: 190315 DurType to align with EVT / BNL_UDF_Old Activity Name 181221: Actuals - Labor - sPHENIX Infrastructure FY18
- S1004960: BNL_UDF_Status Comments: 190315 DurType to align with EVT / BNL_UDF_Old Activity Name 181221: Actuals - Labor - sPHENIX Infrastructure FY18
- S327400: BNL_UDF_Old Activity Name 181221: Evaluate Existing Power Distribution System for Line Electric Power
- S327500: BNL_UDF_Status Comments: 190606 IVS need new act. with start in future; 190318 ELM logic per GRY / BNL_UDF_Old Activity Name 181221: Gather Design Requirements for All sPHENIX Subsystems for Line Electric Power
- S327502: BNL_UDF_Status Comments: 190606 IVS need new act. with start in future; 190318 ELM logic per GRY / BNL_UDF_Old Activity Name 181221: Gather Design Requirements for All sPHENIX Subsystems for Line Electric Power
- S327600: BNL_UDF_Old Activity Name 181221: Evaluate Normal, Emergency and UPS Load Requirements for Line Electric Power
- S1001999: BNL_UDF_Old Activity Name 181221: Calculate Power Transformer Requirements for Line Electric Power
- S327700: BNL_UDF_Old Activity Name 181221: Calculate Power Transformer Requirements for Line Electric Power
- S327501: BNL_UDF_Status Comments: 190606 IVS need new act. with start in future; 190318 ELM logic per GRY / BNL_UDF_Old Activity Name 181221: Gather Design Requirements for All sPHENIX Subsystems for Line Electric Power
- S1002039: BNL_UDF_Old Activity Name 181221: Size Conductors for Line Electric Power
- S327800: BNL_UDF_Old Activity Name 181221: Size Conductors for Line Electric Power
- S1002079: BNL_UDF_Old Activity Name 181221: Create Line Electric Distribution Design/Schematic Drawings for Line Electric Power
- S327900: BNL_UDF_Old Activity Name 181221: Create Line Electric Distribution Design/Schematic Drawings for Line Electric Power
- S1002119: BNL_UDF_Old Activity Name 181221: Review Line Electric Distribution Design/Safety
- S328000: BNL_UDF_Old Activity Name 181221: Review Line Electric Distribution Design/Safety
- S328100: BNL_UDF_Old Activity Name 181221: Address Action Items from Line Electric Distribution Design & Safety Reviews
- S328200: BNL_UDF_Old Activity Name 181221: Design/Safety Reviews Complete, Line Electric Power Distribution Released for Production
- S328500: BNL_UDF_Old Activity Name 181221: Procure & Deliver Line Electric Power Distribution Components (leadtime and fabrication included) - Labor
- S328550: BNL_UDF_Old Activity Name 181221: Prepare Line Electric Power Distribution Components Procurement Package(s)
- S328700: BNL_UDF_Old Activity Name 181221: Procure Line Electric Power Distribution Components - Prepare and Send Solicitation
- S328800: BNL_UDF_Old Activity Name 181221: Procure Line Electric Power Distribution Components - Vendor Responses and Selection
- S328850: BNL_UDF_Old Activity Name 181221: Evaluate & Process Line Electric Power Distribution Components Bid
- OBLG328910: BNL_UDF_Old Activity Name 181221: Procure Line Electric Power Distribution Components - Contract Award
- S328900: BNL_UDF_Old Activity Name 181221: Procure Line Electric Power Distribution Components - Contract Award
- S329000: BNL_UDF_Old Activity Name 181221: Procure Line Electric Power Distribution Components - Leadtime
- S277600: BNL_UDF_Old Activity Name 181221: 2022 Detector Support Systems L3 Project Management
- S329100: BNL_UDF_Old Activity Name 181221: Procure Line Electric Power Distribution Components - Delivery Acceptance
- S329200: BNL_UDF_Old Activity Name 181221: Perform Line Electric Power Distribution Components Acceptance
- S329300: BNL_UDF_Old Activity Name 181221: Line Electric Power Distribution Components Ready for Installation

| ID | WBS | Activity | Type | Duration | Start | Finish | Predecessors | Complete | Remaining | Planned start | Planned finish | Total float | Free float | Constraint | Expected finish | Resources | Cost | BNL_UDF_Status Comments | BNL_UDF_Temp Text 01 | BNL_UDF_Percent Complete | BNL_UDF_Sort Order | BNL_UDF_OPC TEC (deprecated) | BNL_UDF_Temp Date 01 | BNL_UDF_Old Activity ID 181221 | RG Check | BNL_Activity Status | BNL_Fund Source | BNL_Estimator | BNL_Cost Basis | BNL_Location | BNL_EDIA | BNL_CAM | BNL_Institution | BNL_OPC TEC (deprecated) | BNL_WBS | BNL_EVT | BNL_Account Number | BNL_PCR ID | BNL_WBS_Hierarchical | Completed | BNL_Cobra WP | BNL_Master Control Account | BNL_Cobra Control Account | Variance | BNL_Milestone Level | BNL_UDF_Exclude | Indicator - Procurement | Indicator - Float | BNL_UDF_Remaining Tot Cost | BNL_UDF_Percent_remaining | BNL_Proc Sig | SPH Proc Register |
| --- | --- | --- | --- | --- | --- | --- | --- | --- | --- | --- | --- | --- | --- | --- | --- | --- | --- | --- | --- | --- | --- | --- | --- | --- | --- | --- | --- | --- | --- | --- | --- | --- | --- | --- | --- | --- | --- | --- | --- | --- | --- | --- | --- | --- | --- | --- | --- | --- | --- | --- | --- | --- |
|  | 02 | **Detector Support Services Systems (including Cables, Fibers, Cable Trays)** |  |  | 2019-01-02 | 2022-07-28 |  |  |  |  |  |  |  |  |  |  |  |  |  |  |  |  |  |  |  |  |  |  |  |  |  |  |  |  |  |  |  |  |  |  |  |  |  |  |  |  |  |  |  |  |  |  |
| S329400 |  | Analyze Detector Support Services Systems Requirements |  | 105d | 2019-01-02 A | 2019-05-31 A | S100500, S101010 | 100% |  |  |  |  |  |  |  |  |  | 190318 ELM logic per GRY | S329400 | 20 | 1000 | S280200 | 2019-08-30 | S280200 | NOCA | Completed | C | Pisani, Rob | L4 | BNL | Design | Joel Vasquez | BNL | null | POM02.2.04.01.02 | C | 16723 | 003 | 02 | yes |  |  |  |  |  |  |  |  |  |  |  |  |
| S1002199 |  | Analyze Detector Support Services Systems Requirements Split - Physics Resource(s) |  | 84d | 2019-10-01 A | 2020-07-31 A | S329400 | 100% |  | 2019-10-01 | 2020-02-04 |  |  |  |  | PROF4 PO M [32 h]; TECH3 PO M [26 h]; TECH3 PO D [26 h]; SCI3 PO [26 h] | 15,121.58 | 190318 ELM logic per GRY | S329400 | 20 | 1500 | S280200 | 2019-08-30 | S280200 | CA | In Progress | C | Pisani, Rob | L4 | BNL | Design | Joel Vasquez | BNL | null | POM02.2.04.01.02 | C | 16723 | 003 | 02 |  | S1002199 | 2.04 | 2.04 |  |  |  |  |  |  |  |  |  |
| S329405 |  | Analyze Detector Support Services Systems Requirements Split - CA-D Resource(s) |  | 84d | 2019-10-01 A | 2020-07-31 A | S329400 | 100% |  | 2019-10-01 | 2020-02-04 |  |  |  |  | PROF4 AD [16 h] | 2,356.24 | 190318 ELM logic per GRY | S329400 | 20 | 1500 | S280200 | 2019-08-30 | S280200 | CA | In Progress | C | Pisani, Rob | L4 | BNL | Design | Joel Vasquez | BNL | null | POM02.2.04.01.02 | C | 16723 | 003 | 02 |  | S329405 | 2.04 | 2.04 |  |  |  |  |  |  |  |  |  |
| S1002319 |  | Create Layout/Schematic Drawings & Design, Specification Control Documents, Assembly & Detail Drawings - Detector Supp P |  | 40d | 2020-03-02 A | 2020-05-29 A |  | 100% |  | 2020-03-02 | 2020-04-24 |  |  | start on 2020-02-05 |  | PROF4 PO M [32 h]; TECH3 PO D [32 h] | 8,364.39 |  | S329500 | 0 | 3020 | S280300 |  | S280300 | CA | Not Started | C | Pisani, Rob | L4 | BNL | Design | Joel Vasquez | BNL | null | POM02.2.04.01.02 | C | 16723 |  | 02 |  | S1002319 | 2.04 | 2.04 |  |  |  |  |  |  |  |  |  |
| S329475 |  | Create Layout/Schematic Drawings & Design, Specification Control Documents, Assembly & Detail Drawings - Detector Supp P |  | 40d | 2020-03-02 A | 2020-05-29 A | S329470 | 100% |  | 2021-10-01 | 2021-12-01 |  |  |  |  | TECH3 PO D [200 h]; PROF3 PO E [80 h] | 34,951.55 |  | S329500 | 0 | 3020 | S280300 |  | S280300 | CA | Not Started | C | Pisani, Rob | L4 | BNL | Design | Joel Vasquez | BNL | null | POM02.2.04.01.02 | C | 16723 | 010 | 02 |  | S329475 | 2.04 | 2.04 | 0 |  |  |  |  |  |  |  |  |
| S329478 |  | Create Layout/Schematic Drawings & Design, Specification Control Documents, Assembly & Detail Drawings - Detector Supp C |  | 40d | 2020-03-02 A | 2020-05-29 A | S329470 | 100% |  | 2021-10-01 | 2021-12-01 |  |  |  |  | PROF4 AD [4 h] | 624.93 |  | S329500 | 0 | 3020 | S280300 |  | S280300 | CA | Not Started | C | Pisani, Rob | L4 | BNL | Design | Joel Vasquez | BNL | null | POM02.2.04.01.02 | C | 16723 | 010 | 02 |  | S329478 | 2.04 | 2.04 | 0 |  |  |  |  |  |  |  |  |
| S329500 |  | Create Layout/Schematic Drawings & Design, Specification Control Documents, Assembly & Detail Drawings - Detector Supp C |  | 40d | 2020-03-02 A | 2020-05-29 A |  | 100% |  | 2020-03-02 | 2020-04-24 |  |  | start on 2020-02-05 |  | PROF4 AD [4 h] | 589.06 |  | S329500 | 0 | 3020 | S280300 |  | S280300 | CA | Not Started | C | Pisani, Rob | L4 | BNL | Design | Joel Vasquez | BNL | null | POM02.2.04.01.02 | C | 16723 |  | 02 |  | S329500 | 2.04 | 2.04 |  |  |  |  |  |  |  |  |  |
| S329407 |  | Conceptual Design for Cable Routing from Detector to Rack (HCal, EMCal) |  | 30d | 2020-03-11 A | 2020-10-30 A | S329406 | 100% |  | 2020-05-13 | 2020-06-24 |  |  |  |  | TECH3 PO D [136 h]; PROF3 PO E [16 h] | 17,544.76 | 190318 ELM logic per GRY | S329400 | 20 | 3000 | S280200 | 2019-08-30 | S280200 | CA | In Progress | C | Pisani, Rob | L4 | BNL | Design | Joel Vasquez | BNL | null | POM02.2.04.01.02 | C | 16723 | 010 | 02 |  | S329407 | 2.04 | 2.04 | 0 |  |  |  |  |  |  |  |  |
| S329406 |  | Send proposal packages for approvals (cable types, rack locations, and support components) |  | 30d | 2020-04-01 A | 2020-04-30 A |  | 100% |  | 2020-04-01 | 2020-05-12 |  |  | start on or after 2020-04-01 |  | TECH3 PO D [15 h]; PROF3 PO E [8 h] | 2,723.91 | 190318 ELM logic per GRY | S329400 | 20 | 3000 | S280200 | 2019-08-30 | S280200 | CA | In Progress | C | Pisani, Rob | L4 | BNL | Design | Joel Vasquez | BNL | null | POM02.2.04.01.02 | C | 16723 | 010 | 02 |  | S329406 | 2.04 | 2.04 | 0 |  |  |  |  |  |  |  |  |
| S329408 |  | Conceptual Design for Cable Routing from Detector to Rack (TPC) |  | 20d | 2020-07-01 A | 2021-06-14 | S329407 | 90% | 10d | 2020-06-25 | 2020-07-23 | 12d | 0d |  | 2021-06-14 | TECH3 PO D [120 h]; PROF3 PO E [8 h] | 14,706.73 | 190318 ELM logic per GRY | S329400 | 20 | 3000 | S280200 | 2019-08-30 | S280200 | CA | In Progress | C | Pisani, Rob | L4 | BNL | Design | Joel Vasquez | BNL | null | POM02.2.04.01.02 | C | 16723 | 010 | 02 |  | S329408 | 2.04 | 2.04 | 0 |  |  |  |  |  |  |  |  |
| S329450 |  | Conceptual Design for Routing Detector Cooling System |  | 25d | 2020-07-15 A | 2021-09-27 | S329440 | 35% | 1.5d | 2021-01-29 | 2021-03-05 | 12d | 0d |  | 2021-06-14 | PROF3 PO E [100 h]; TECH3 PO D [200 h] | 36,539.64 |  |  |  | 3000 |  |  |  |  |  | C |  |  |  | Design | Joel Vasquez | BNL |  | POM02.2.04.01.02 | C | 16723 | 010 | 02 |  | S329450 | 2.04 | 2.04 |  |  |  |  |  |  |  |  |  |
| S329420 |  | Conceptual Design for Cable Routing from Detector to Rack (MBD) |  | 20d | 2020-10-23 A | 2021-07-29 | S329410 | 95% | 2d | 2021-02-03 | 2021-03-03 | 12d | 0d |  | 2021-06-14 | PROF3 PO E [8 h]; TECH3 PO D [88 h] | 11,386.47 |  |  |  | 3000 |  |  |  |  |  | C |  |  |  | Design | Joel Vasquez | BNL |  | POM02.2.04.01.02 | C | 16723 | 010 | 02 |  | S329420 | 2.04 | 2.04 |  |  |  |  |  |  |  |  |  |
| S329440 |  | Conceptual Design for Routing Rack Cooling System |  | 20d | 2020-10-23 A | 2021-09-24 | S329430 | 30% | 20d | 2021-04-01 | 2021-04-28 | 12d | 0d |  | 2021-06-14 | PROF3 PO E [104 h]; TECH3 PO D [104 h] | 25,776.47 |  |  |  | 3000 |  |  |  |  |  | C |  |  |  | Design | Joel Vasquez | BNL |  | POM02.2.04.01.02 | C | 16723 | 010 | 02 |  | S329440 | 2.04 | 2.04 |  |  |  |  |  |  |  |  |  |
| S329410 |  | Conceptual Design for Cable Routing from Detector to Rack (MVTX) |  | 20d | 2020-11-09 A | 2021-07-27 | S329409 | 95% | 20d | 2020-12-30 | 2021-01-28 | 12d | 0d |  | 2021-06-14 | PROF3 PO E [8 h]; TECH3 PO D [80 h] | 10,446.1 |  |  |  | 3000 |  |  |  |  |  | C |  |  |  | Design | Joel Vasquez | BNL |  | POM02.2.04.01.02 | C | 16723 | 010 | 02 |  | S329410 | 2.04 | 2.04 |  |  |  |  |  |  |  |  |  |
| S329409 |  | Conceptual Design for Cable Routing from Detector to Rack (INTT) |  | 20d | 2020-12-22 A | 2021-06-28 | S329408 | 95% | 10d | 2021-02-03 | 2021-03-03 | 12d | 0d |  | 2021-06-14 | TECH3 PO D [88 h]; PROF3 PO E [8 h] | 11,386.47 | 190318 ELM logic per GRY | S329400 | 20 | 3000 | S280200 | 2019-08-30 | S280200 | CA | In Progress | C | Pisani, Rob | L4 | BNL | Design | Joel Vasquez | BNL | null | POM02.2.04.01.02 | C | 16723 | 010 | 02 |  | S329409 | 2.04 | 2.04 | 0 |  |  |  |  |  |  |  |  |
| S329430 |  | Conceptual Design for Routing Fiber Optic Cables from Rack to Patch Panel |  | 20d | 2020-12-22 A | 2021-08-26 | S329420 | 95% | 20d | 2021-04-05 | 2021-04-30 | 12d | 0d |  | 2021-06-14 | PROF3 PO E [8 h]; TECH3 PO D [96 h] | 12,326.84 |  |  |  | 3000 |  |  |  |  |  | C |  |  |  | Design | Joel Vasquez | BNL |  | POM02.2.04.01.02 | C | 16723 | 010 | 02 |  | S329430 | 2.04 | 2.04 |  |  |  |  |  |  |  |  |  |
| S329470 |  | Conceptual Design for Power Distribution / Controls Cable Routing |  | 17d | 2021-03-22 A | 2021-03-31 A | S329460 | 100% |  | 2021-09-08 | 2021-09-30 |  |  |  |  | PROF3 PO E [68 h]; TECH3 PO D [136 h] | 24,846.96 |  |  |  | 3000 |  |  |  |  |  | C |  |  |  | Design | Joel Vasquez | BNL |  | POM02.2.04.01.02 | C | 16723 | 010 | 02 |  | S329470 | 2.04 | 2.04 |  |  |  |  |  |  |  |  |  |
| S329460 |  | Design Package for Detector Cooling System |  | 30d | 2021-09-27 | 2021-11-08 | S329450 |  |  |  |  | 12d | 0d |  |  | PROF3 PO E [120 h]; TECH3 PO D [240 h] | 44,987.61 |  |  |  | 3000 |  |  |  |  |  | C |  |  |  | Design | Joel Vasquez | BNL |  | POM02.2.04.01.02 | C | 16723 | 010 | 02 |  | S329460 | 2.04 | 2.04 |  |  |  |  |  |  |  |  |  |
| S1002399 |  | Review Detector Support Services Systems Design/Safety - Physics Resource(s) |  | 12d | 2021-11-09 | 2021-11-29 | S329478 |  |  |  |  | 12d | 0d |  |  | PROF4 PO M [8 h]; TECH3 PO D [8 h] | 2,218.45 |  | S329600 | 0 | 3030 | S280400 |  | S280400 | CA | Not Started | C | Pisani, Rob | L4 | BNL | Management Safety Reviews | Joel Vasquez | BNL | null | POM02.2.04.01.02 | C | 16723 |  | 02 |  | S1002399 | 2.04 | 2.04 |  |  |  |  |  |  |  |  |  |
| S329600 |  | Review Detector Support Services Systems Design/Safety - CA-D Resource(s) |  | 12d | 2021-11-09 | 2021-11-29 | S329500, S329478, S1002319 |  |  |  |  | 12d | 0d |  |  | PROF4 AD [20 h] | 3,124.67 |  | S329600 | 0 | 3030 | S280400 |  | S280400 | CA | Not Started | C | Pisani, Rob | L4 | BNL | Management Safety Reviews | Joel Vasquez | BNL | null | POM02.2.04.01.02 | C | 16723 |  | 02 |  | S329600 | 2.04 | 2.04 |  |  |  |  |  |  |  |  |  |
| S329700 |  | Address Action Items from Detector Support Services Systems Design & Safety Reviews |  | 12d | 2021-11-30 | 2021-12-15 | S329600, S1002399 |  |  |  |  | 12d | 0d |  |  | PROF4 PO M [40 h]; TECH3 PO D [80 h] | 15,935.11 |  | S329700 | 0 | 3040 | S280500 |  | S280500 | CA | Not Started | C | Pisani, Rob | L4 | BNL | Management Safety Reviews | Joel Vasquez | BNL | null | POM02.2.04.01.02 | C | 16723 |  | 02 |  | S329700 | 2.04 | 2.04 |  |  |  |  |  |  |  |  |  |
| S329800 |  | Design/Safety Reviews Complete, Detector Support Services Systems Components Released for Production | milestone | 0d | 2021-12-15 | 2021-12-15 | S329700 FF |  |  |  |  | 12d | 0d |  |  |  |  |  | S329800 | 0 | 3050 | S280600 |  | S280600 | NOCA | Not Started | C | Pisani, Rob |  | BNL | Management Safety Reviews | Joel Vasquez | BNL |  | POM02.2.04.01.02 |  |  |  | 02 |  |  |  |  |  | L4 |  |  |  |  |  |  |  |
| S1002479 |  | Prepare Detector Support Services Systems Components Procurement Package(s) - Physics Resource(s) |  | 20d | 2021-12-16 | 2022-01-14 | S329800 |  |  |  |  | 12d | 0d |  |  | TECH3 PO D [80 h]; PROF3 PO E [80 h] | 20,422.89 |  | S329900 | 0 | 3060 | S280700 |  | S280700 | CA | Not Started | C | Pisani, Rob | L4 | BNL | Procurement | Joel Vasquez | BNL | null | POM02.2.04.01.02 | C | 16723 | 010 | 02 |  | S1002479 | 2.04 | 2.04 |  |  |  |  |  |  |  |  |  |
| S329900 |  | Prepare Detector Support Services Systems Components Procurement Package(s) - CA-D Resource(s) |  | 20d | 2021-12-16 | 2022-01-14 | S329800 |  |  |  |  | 12d | 0d |  |  | PROF4 AD [20 h] | 3,124.67 |  | S329900 | 0 | 3060 | S280700 |  | S280700 | CA | Not Started | C | Pisani, Rob | L4 | BNL | Procurement | Joel Vasquez | BNL | null | POM02.2.04.01.02 | C | 16723 |  | 02 |  | S329900 | 2.04 | 2.04 |  |  |  |  |  |  |  |  |  |
| S1002559 |  | Evaluate & Process Detector Support Services Systems Components Bids - Physics Resource(s) |  | 20d | 2022-01-18 | 2022-02-14 | S329900, S1002479 |  |  |  |  | 12d | 0d |  |  | TECH3 PO D [16 h]; PROF3 PO E [16 h] | 4,084.58 |  | S330000 | 0 | 3070 | S280800 |  | S280800 | CA | Not Started | C | Pisani, Rob | L4 | BNL | Procurement | Joel Vasquez | BNL | null | POM02.2.04.01.02 | C | 16723 | 010 | 02 |  | S1002559 | 2.04 | 2.04 |  |  |  |  |  |  |  |  |  |
| S330000 |  | Evaluate & Process Detector Support Services Systems Components Bids - CA-D Resource(s) |  | 20d | 2022-01-18 | 2022-02-14 | S329900, S1002479 |  |  |  |  | 12d | 0d |  |  | PROF4 AD [10 h] | 1,562.33 |  | S330000 | 0 | 3070 | S280800 |  | S280800 | CA | Not Started | C | Pisani, Rob | L4 | BNL | Procurement | Joel Vasquez | BNL | null | POM02.2.04.01.02 | C | 16723 |  | 02 |  | S330000 | 2.04 | 2.04 |  |  |  |  |  |  |  |  |  |
| S1002639 |  | Procure & Deliver Detector Support Services Systems Components (leadtime and fabrication included) - Labor P |  | 50d | 2022-02-15 | 2022-04-26 | S330000, S1002559 |  |  |  |  | 12d | 0d |  |  | PROF4 PO M [40 h]; TECH3 PO D [40 h] | 11,092.23 |  | S330100 | 0 | 3080 | S280900 |  | S280900 | CA | Not Started | C | Pisani, Rob | L4 | BNL | Fab & Assy | Joel Vasquez | BNL | null | POM02.2.04.01.02 | C | 16723 | 010 | 02 |  | S1002639 | 2.04 | 2.04 |  |  |  |  |  |  |  |  |  |
| S330100 |  | Procure & Deliver Detector Support Services Systems Components (leadtime and fabrication included) - Labor C |  | 50d | 2022-02-15 | 2022-04-26 | S330000, S1002559 |  |  |  |  | 12d | 0d |  |  | PROF4 AD [2 h] | 312.47 |  | S330100 | 0 | 3080 | S280900 |  | S280900 | CA | Not Started | C | Pisani, Rob | L4 | BNL | Fab & Assy | Joel Vasquez | BNL | null | POM02.2.04.01.02 | C | 16723 |  | 02 |  | S330100 | 2.04 | 2.04 |  |  |  |  |  |  |  |  |  |
| S330200 |  | Procure & Deliver Detector Support Services Systems Components (leadtime and fabrication included) M&S |  | 50d | 2022-02-15 | 2022-04-26 | S330100 SS, S1002639 SS |  |  |  |  | 12d | 0d |  |  | Material (Purchase (1st $2M) [32000 h] | 37,884.74 |  | S330200 | 0 | 3080 | S280100 |  | S280950 | CA | Not Started | C | Pisani, Rob | M5 | BNL | Fab & Assy | Joel Vasquez | BNL | null | POM02.2.04.01.02 | C | 16723 |  | 02 |  | S330200 | 2.04 | 2.04 |  |  | MP6LAEXCLUDE | UDF_G1 | UDF_G1 | 37557.887066 | 1 | TBD | Combined |
| S1002719 |  | Perform Detector Support Services Systems Components Acceptance - Physics Resource(s) |  | 5d | 2022-04-27 | 2022-05-03 | S330100, S330200, S1002639 |  |  |  |  | 12d | 0d |  |  | PROF4 PO M [4 h]; TECH3 PO M [20 h]; TECH3 PO D [4 h] | 3,530.67 |  | S330300 | 0 | 4000 | S281000 |  | S281000 | CA | Not Started | C | Pisani, Rob | L4 | BNL | Procurement | Joel Vasquez | BNL | null | POM02.2.04.01.02 | C | 16723 | 010 | 02 |  | S1002719 | 2.04 | 2.04 |  |  |  |  |  |  |  |  |  |
| S330300 |  | Perform Detector Support Services Systems Components Acceptance - CA-D Resource(s) |  | 5d | 2022-04-27 | 2022-05-03 | S330100, S330200, S1002639 |  |  |  |  | 12d | 0d |  |  | PROF4 AD [4 h] | 624.93 |  | S330300 | 0 | 4000 | S281000 |  | S281000 | CA | Not Started | C | Pisani, Rob | L4 | BNL | Procurement | Joel Vasquez | BNL | null | POM02.2.04.01.02 | C | 16723 |  | 02 |  | S330300 | 2.04 | 2.04 |  |  |  |  |  |  |  |  |  |
| S1002759 |  | Procure Fiber Optics Trunk Cables and Accessories - Labor - Physics Resource(s) |  | 60d | 2022-05-04 | 2022-07-28 | S330300, S1002719 |  |  |  |  | 12d | 0d |  |  | SCI3 PO [80 h]; PROF3 PO E [80 h] | 25,344.07 | 190322 ELM add per GRY/EM | S330300 | 0 | 4010 | S281000 |  | S281000 | CA | Not Started | C | Pisani, Rob | L4 | BNL | Procurement | Joel Vasquez | BNL | null | POM02.2.04.01.02 | C | 16723 | 003 | 02 |  | S1002759 | 2.04 | 2.04 |  |  |  |  |  |  |  |  |  |
| S330350 |  | Procure Fiber Optics Trunk Cables and Accessories - Labor - CA-D Resource(s) |  | 60d | 2022-05-04 | 2022-07-28 | S330300, S1002719 |  |  |  |  | 12d | 0d |  |  | PROF4 AD [4 h] | 624.93 | 190322 ELM add per GRY/EM | S330300 | 0 | 4010 | S281000 |  | S281000 | CA | Not Started | C | Pisani, Rob | L4 | BNL | Procurement | Joel Vasquez | BNL | null | POM02.2.04.01.02 | C | 16723 | 003 | 02 |  | S330350 | 2.04 | 2.04 |  |  |  |  |  |  |  |  |  |
| S330355 |  | Procure Fiber Optics Trunk Cables and Accessories - M&S |  | 60d | 2022-05-04 | 2022-07-28 | S330300, S1002719 |  |  |  |  | 12d | 0d |  |  | Material (Purchase (1st $2M) [22000 h] | 26,045.76 | 190322 ELM add per GRY/EM | S330200 | 0 | 4010 | S280100 |  | S280950 | CA | Not Started | C | Pisani, Rob | M5 | BNL | Fab & Assy | Joel Vasquez | BNL | null | POM02.2.04.01.02 | C | 16723 | 003 | 02 |  | S330355 | 2.04 | 2.04 |  |  | MP6LAEXCLUDE | UDF_G1 | UDF_G1 | 26045.75578 | 1 | TBD | Combined |
| S330400 |  | Detector Support Services Systems Components Ready for Installation | milestone | 0d | 2022-07-28 | 2022-07-28 | S330350 FF, S330355 FF, S1002759 FF |  |  |  |  | 12d | 0d |  |  |  |  |  | S330400 | 0 |  | S281100 |  | S281100 | NOCA | Not Started | C | Pisani, Rob |  | BNL | Procurement | Joel Vasquez | BNL |  | POM02.2.04.01.02 |  |  |  | 02 |  |  |  |  |  | L3 |  |  |  |  |  |  |  |

Notes:
- S329400: BNL_UDF_Old Activity Name 181221: Analyze Detector Support Services Systems Requirements
- S1002199: BNL_UDF_Old Activity Name 181221: Analyze Detector Support Services Systems Requirements
- S329405: BNL_UDF_Old Activity Name 181221: Analyze Detector Support Services Systems Requirements
- S1002319: BNL_UDF_Old Activity Name 181221: Create Layout/Schematic Drawings & Design, Specification Control Documents, Assembly & Detail Drawings for Detector Supp
- S329475: BNL_UDF_Old Activity Name 181221: Create Layout/Schematic Drawings & Design, Specification Control Documents, Assembly & Detail Drawings for Detector Supp
- S329478: BNL_UDF_Old Activity Name 181221: Create Layout/Schematic Drawings & Design, Specification Control Documents, Assembly & Detail Drawings for Detector Supp
- S329500: BNL_UDF_Old Activity Name 181221: Create Layout/Schematic Drawings & Design, Specification Control Documents, Assembly & Detail Drawings for Detector Supp
- S329407: BNL_UDF_Old Activity Name 181221: Analyze Detector Support Services Systems Requirements
- S329406: BNL_UDF_Old Activity Name 181221: Analyze Detector Support Services Systems Requirements
- S329408: BNL_UDF_Old Activity Name 181221: Analyze Detector Support Services Systems Requirements
- S329409: BNL_UDF_Old Activity Name 181221: Analyze Detector Support Services Systems Requirements
- S1002399: BNL_UDF_Old Activity Name 181221: Review Detector Support Services Systems Design/Safety
- S329600: BNL_UDF_Old Activity Name 181221: Review Detector Support Services Systems Design/Safety
- S329700: BNL_UDF_Old Activity Name 181221: Address Action Items from Detector Support Services Systems Design & Safety Reviews
- S329800: BNL_UDF_Old Activity Name 181221: Design/Safety Reviews Complete, Detector Support Services Systems Components Released for Production
- S1002479: BNL_UDF_Old Activity Name 181221: Prepare Detector Support Services Systems Components Procurement Package(s)
- S329900: BNL_UDF_Old Activity Name 181221: Prepare Detector Support Services Systems Components Procurement Package(s)
- S1002559: BNL_UDF_Old Activity Name 181221: Evaluate & Process Detector Support Services Systems Components Bids
- S330000: BNL_UDF_Old Activity Name 181221: Evaluate & Process Detector Support Services Systems Components Bids
- S1002639: BNL_UDF_Old Activity Name 181221: Procure & Deliver Detector Support Services Systems Components (leadtime and fabrication included) - Labor
- S330100: BNL_UDF_Old Activity Name 181221: Procure & Deliver Detector Support Services Systems Components (leadtime and fabrication included) - Labor
- S330200: BNL_UDF_Old Activity Name 181221: Procure & Deliver Detector Support Services Systems Components (leadtime and fabrication included) M&S
- S1002719: BNL_UDF_Old Activity Name 181221: Perform Detector Support Services Systems Components Acceptance
- S330300: BNL_UDF_Old Activity Name 181221: Perform Detector Support Services Systems Components Acceptance
- S1002759: BNL_UDF_Old Activity Name 181221: Perform Detector Support Services Systems Components Acceptance
- S330350: BNL_UDF_Old Activity Name 181221: Perform Detector Support Services Systems Components Acceptance
- S330355: BNL_UDF_Old Activity Name 181221: Procure & Deliver Detector Support Services Systems Components (leadtime and fabrication included) M&S
- S330400: BNL_UDF_Old Activity Name 181221: Detector Support Services Systems Components Ready for Installation

| ID | WBS | Activity | Type | Duration | Start | Finish | Predecessors | Complete | Remaining | Planned start | Planned finish | Total float | Free float | Constraint | Expected finish | Resources | Cost | BNL_UDF_Temp Text 01 | BNL_UDF_Percent Complete | BNL_UDF_Sort Order | BNL_UDF_OPC TEC (deprecated) | BNL_UDF_Temp Date 01 | BNL_UDF_Old Activity ID 181221 | RG Check | BNL_Activity Status | BNL_Fund Source | BNL_Estimator | BNL_Cost Basis | BNL_Location | BNL_EDIA | BNL_CAM | BNL_Institution | BNL_OPC TEC (deprecated) | BNL_WBS | BNL_EVT | BNL_WBS_Hierarchical | Completed | BNL_UDF_Status Comments | BNL_Cobra WP | BNL_Master Control Account | BNL_Account Number | BNL_PCR ID | BNL_Cobra Control Account | Indicator - Procurement | Indicator - Float | BNL_UDF_Remaining Tot Cost | BNL_UDF_Percent_remaining | Variance | BNL_Milestone Level | BNL_UDF_Exclude | BNL_Proc Sig | SPH Proc Register | Target Milestone Date | PMP Milestones |
| --- | --- | --- | --- | --- | --- | --- | --- | --- | --- | --- | --- | --- | --- | --- | --- | --- | --- | --- | --- | --- | --- | --- | --- | --- | --- | --- | --- | --- | --- | --- | --- | --- | --- | --- | --- | --- | --- | --- | --- | --- | --- | --- | --- | --- | --- | --- | --- | --- | --- | --- | --- | --- | --- | --- |
|  | 03 | **Detector Electronics Racks and Rack generic support systems** |  |  | 2018-05-01 | 2022-03-23 |  |  |  |  |  |  |  |  |  |  |  |  |  |  |  |  |  |  |  |  |  |  |  |  |  |  |  |  |  |  |  |  |  |  |  |  |  |  |  |  |  |  |  |  |  |  |  |  |
| S330500 |  | Analyze Detector Electronics Racks and Rack generic support systems Requirements FY18 |  | 106d | 2018-05-01 A | 2018-09-28 A | S100090 SS | 100% |  |  |  |  |  |  |  |  |  | S330500 | 100 | 1000 | S281300 | 2019-05-01 | S281300 | NOCA | Completed | C | Pisani, Rob | L4 | BNL | Procurement | Joel Vasquez | BNL | null | POM02.2.04.01.03 | C | 03 | yes |  |  |  |  |  |  |  |  |  |  |  |  |  |  |  |  |  |
| S330600 |  | Analyze Detector Electronics Racks and Rack generic support systems Requirements FY19 |  | 23d | 2020-02-03 A | 2020-02-28 A | S330500, S101015 SS | 100% |  | 2020-10-01 | 2020-11-03 |  |  |  |  | PROF4 PO E [13 h]; PROF4 PO M [13 h]; SCI3 PO [13 h]; TECH3 PO D [54 h] | 12,595.73 | S330600 | 0 | 1000 | S281300 | 2020-01-03 | S281350 | CA | Not Started | C | Pisani, Rob | L4 | BNL | Procurement | Joel Vasquez | BNL | null | POM02.2.04.01.03 | C | 03 |  | 190318 ELM logic per GRY | S330600 | 2.04 | 16723 | 012 | 2.04 |  |  |  |  |  |  |  |  |  |  |  |
| S330606 |  | Gather Rack Interlock Reqs and Specify Interlock Equipment |  | 20d | 2020-03-11 A | 2020-03-31 A | S330602 SS, S330604 | 100% |  | 2020-06-26 | 2020-07-24 |  |  |  |  | TECH3 PO D [80 h]; PROF3 PO E [80 h] | 19,250.53 |  |  | 2000 |  |  |  |  |  | C |  |  |  | Design | Joel Vasquez |  |  | POM02.2.04.01.03 | C | 03 |  |  | S330606 | 2.04 | 16723 | 010 | 2.04 |  |  |  |  |  |  |  |  |  |  |  |
| S330612 |  | Rack Interlock Conceptual Design |  | 45d | 2020-03-13 A | 2020-07-31 A | S330610, S330608 FF | 100% |  | 2020-07-13 | 2020-09-14 |  |  |  |  | TECH3 PO D [240 h]; PROF3 PO E [240 h] | 57,751.6 |  |  | 2000 |  |  |  |  |  | C |  |  |  | Design | Joel Vasquez |  |  | POM02.2.04.01.03 | C | 03 |  |  | S330612 | 2.04 | 16723 | 010 | 2.04 |  |  |  |  |  |  |  |  |  |  |  |
| S330640 |  | Prototype System Development Labor |  | 90d | 2020-03-16 A | 2021-06-14 | S330616 | 90% | 10d | 2020-09-15 | 2021-01-27 | 1d | 0d |  | 2021-06-14 | TECH3 PO D [180 h]; PROF3 PO E [180 h] | 44,439.86 |  |  | 2000 |  |  |  |  |  | C |  |  |  | Design | Joel Vasquez |  |  | POM02.2.04.01.03 | C | 03 |  |  | S330640 | 2.04 | 16723 | 010 | 2.04 |  |  |  |  |  |  |  |  |  |  |  |
| S330642 |  | Prototype System Development M&S |  | 90d | 2020-03-16 A | 2021-06-14 | S330616 | 90% | 10d | 2020-09-15 | 2021-01-27 | 1d | 0d |  | 2021-06-14 | Material (Purchase (1st $2M) [35000 h] | 40,517.74 |  |  | 2000 |  |  |  |  |  | C |  |  |  | Design | Joel Vasquez |  |  | POM02.2.04.01.03 | C | 03 |  |  | S330642 | 2.04 | 16723 | 010 | 2.04 | UDF_G1 | UDF_G1 | 23095.11432111 | 0.57 |  |  |  |  |  |  |  |
| S330610 |  | Radiation Test for Water Leak Detection System |  | 10d | 2020-04-08 A | 2020-04-29 A | S330608 SS | 100% |  | 2020-06-29 | 2020-07-13 |  |  |  |  | TECH3 PO D [40 h]; PROF3 PO E [40 h] | 9,625.27 |  |  | 2000 |  |  |  |  |  | C |  |  |  | Design | Joel Vasquez |  |  | POM02.2.04.01.03 | C | 03 |  |  | S330610 | 2.04 | 16723 | 010 | 2.04 |  |  |  |  |  |  |  |  |  |  |  |
| S330601 |  | Analyze Detector Electronics Racks and Rack generic support systems Reqs |  | 10d | 2020-05-01 A | 2020-05-14 A | S330500 | 100% |  |  |  |  |  | start on or after 2020-05-01 |  |  |  | S330600 | 0 | 1000 | S281300 | 2020-01-03 | S281350 | CA | Not Started | C | Pisani, Rob | L4 | BNL | Procurement | Joel Vasquez | BNL | null | POM02.2.04.01.03 | C | 03 |  | 190318 ELM logic per GRY | S330601 | 2.04 | 16723 | 012 | 2.04 |  |  |  |  | 0 |  |  |  |  |  |  |
| S330602 |  | Gather Power Reqs for Subsystem Racks on Detector |  | 15d | 2020-05-15 A | 2020-05-29 A | S330601 | 100% |  | 2020-05-15 | 2020-06-05 |  |  | start on or after 2020-05-14 |  | TECH3 PO D [120 h]; PROF3 PO E [120 h] | 28,875.8 |  |  | 2000 |  |  |  |  |  | C |  |  |  | Design | Joel Vasquez |  |  | POM02.2.04.01.03 | C | 03 |  |  | S330602 | 2.04 | 16723 | 012 | 2.04 |  |  |  |  |  |  |  |  |  |  |  |
| S330604 |  | Power Distribution Conceptual Gesign for Subsystem Racks on Detector |  | 15d | 2020-06-01 A | 2020-06-19 A | S330602 | 100% |  |  |  |  |  | start on or after 2020-04-01 |  | TECH3 PO D [120 h]; PROF3 PO E [120 h] | 28,875.8 |  |  | 2000 |  |  |  |  |  | C |  |  |  | Design | Joel Vasquez |  |  | POM02.2.04.01.03 | C | 03 |  |  | S330604 | 2.04 | 16723 | 010 | 2.04 |  |  |  |  |  |  |  |  |  |  |  |
| S330608 |  | Specify Power Controls Distribution Equipment |  | 30d | 2020-06-22 A | 2020-11-30 A | S330606 SS | 100% |  | 2020-06-22 | 2020-08-03 |  |  |  |  | TECH3 PO D [120 h]; PROF3 PO E [120 h] | 28,875.8 |  |  | 2000 |  |  |  |  |  | C |  |  |  | Design | Joel Vasquez |  |  | POM02.2.04.01.03 | C | 03 |  |  | S330608 | 2.04 | 16723 | 010 | 2.04 |  |  |  |  |  |  |  |  |  |  |  |
| S330700 |  | Create Layout/Schematic Drawings & Design, Specification Control Documents, Assembly & Detail Drawings for Detector Elec |  | 30d | 2020-10-23 A | 2021-06-30 | S330600, S330642, S330640 | 30% | 12d | 2021-01-22 | 2021-03-05 | 1d | 0d |  | 2021-06-14 | PROF4 PO M [24 h]; TECH3 PO D [96 h]; PROF3 PO E [24 h] | 18,052.1 | S330700 | 0 | 2000 | S281400 |  | S281400 | CA | Not Started | C | Pisani, Rob | L4 | BNL | Design | Joel Vasquez | BNL | null | POM02.2.04.01.03 | C | 03 |  |  | S330700 | 2.04 | 16723 |  | 2.04 |  |  |  |  |  |  |  |  |  |  |  |
| S330616 |  | Prelim Design/Safety Reviews Complete for Det El Racks and Rack generic support systems | milestone | 0d | 2021-04-01 A | 2021-04-01 A | S330612 | 100% |  |  |  |  |  |  |  |  |  |  |  | 2000 |  |  |  |  |  | C |  |  |  | Design | Joel Vasquez |  |  | POM02.2.04.01.03 |  | 03 |  |  | S330616 | 2.04 |  | 010 |  |  |  |  |  |  |  |  |  |  |  |  |
| S1002799 |  | Review Detector Electronics Racks and Rack generic support systems Design/Safety - Physics Resource(s) |  | 10d | 2021-04-30 A | 2021-07-15 | S330700 | 75% | 10d | 2021-05-04 | 2021-05-17 | 1d | 0d |  | 2021-06-16 | PROF4 PO M [8 h]; TECH3 PO D [32 h]; PROF3 PO E [8 h] | 6,017.37 | S330800 | 0 | 3000 | S281500 |  | S281500 | CA | Not Started | C | Pisani, Rob | L4 | BNL | Design | Joel Vasquez | BNL | null | POM02.2.04.01.03 | C | 03 |  |  | S1002799 | 2.04 | 16723 |  | 2.04 |  |  |  |  |  |  |  |  |  |  |  |
| S330800 |  | Review Detector Electronics Racks and Rack generic support systems Design/Safety - CA-D Resource(s) |  | 10d | 2021-04-30 A | 2021-07-15 | S330700 | 50% | 10d | 2021-05-04 | 2021-05-17 | 1d | 0d |  | 2021-06-16 | PROF4 AD [8 h] | 1,213.46 | S330800 | 0 |  | S281500 |  | S281500 | CA | Not Started | C | Pisani, Rob | L4 | BNL | Design | Joel Vasquez | BNL | null | POM02.2.04.01.03 | C | 03 |  |  | S330800 | 2.04 | 16723 |  | 2.04 |  |  |  |  |  |  |  |  |  |  |  |
| S330900 |  | Address Action Items from Detector Electronics Racks and Rack generic support systems Design & Safety Reviews |  | 10d | 2021-07-16 | 2021-07-29 | S330800, S1002799 |  |  |  |  | 1d | 0d |  |  | PROF4 PO M [8 h]; TECH3 PO D [32 h]; PROF3 PO E [8 h] | 6,017.37 | S330900 | 0 |  | S281600 |  | S281600 | CA | Not Started | C | Pisani, Rob | L4 | BNL | Management Safety Reviews | Joel Vasquez | BNL | null | POM02.2.04.01.03 | C | 03 |  |  | S330900 | 2.04 | 16723 |  | 2.04 |  |  |  |  |  |  |  |  |  |  |  |
| S331000 |  | Design/Safety Reviews Complete, Detector Electronics Racks and Rack generic support systems Components Released for Prod | milestone | 0d | 2021-07-29 | 2021-07-29 | S330900 FF |  |  |  |  | 1d | 0d |  |  |  |  | S331000 | 0 |  | S281700 |  | S281700 | NOCA | Not Started | C | Pisani, Rob |  | BNL | Management Safety Reviews | Joel Vasquez | BNL |  | POM02.2.04.01.03 |  | 03 |  |  |  |  |  |  |  |  |  |  |  |  | L4 |  |  |  |  |  |
| S331100 |  | Prepare Detector Electronics Racks and Rack generic support systems Components Procurement Package(s) |  | 50d | 2021-07-30 | 2021-10-08 | S331000 |  |  |  |  | 1d | 0d |  |  | PROF4 PO M [16 h]; TECH3 PO D [72 h]; PROF3 PO E [16 h] | 13,021.81 | S331100 | 0 |  | S281800 |  | S281800 | CA | Not Started | C | Pisani, Rob | L4 | BNL | Design | Joel Vasquez | BNL | null | POM02.2.04.01.03 | C | 03 |  |  | S331100 | 2.04 | 16723 |  | 2.04 |  |  |  |  |  |  |  |  |  |  |  |
| S331200 |  | Evaluate & Process Detector Electronics Racks and Rack generic support systems Components Bids |  | 50d | 2021-10-12 | 2021-12-23 | S331100 |  |  |  |  | 1d | 0d |  |  | PROF4 PO M [48 h]; TECH3 PO D [144 h]; PROF3 PO E [48 h] | 31,375.87 | S331200 | 0 |  | S281900 |  | S281900 | CA | Not Started | C | Pisani, Rob | L4 | BNL | Procurement | Joel Vasquez | BNL | null | POM02.2.04.01.03 | C | 03 |  |  | S331200 | 2.04 | 16723 |  | 2.04 |  |  |  |  |  |  |  |  |  |  |  |
| S331300 |  | Procure & Deliver Detector Elec. Racks & Rack generic support systems Components (leadtime and fab incl.) - Labor |  | 50d | 2021-12-27 | 2022-03-09 | S331200 |  |  |  |  | 1d | 0d |  |  | PROF4 PO M [48 h]; TECH3 PO D [144 h]; PROF3 PO E [48 h] | 31,375.87 | S331300 | 0 |  | S282000 |  | S282000 | CA | Not Started | C | Pisani, Rob | L4 | BNL | Fab & Assy | Joel Vasquez | BNL | null | POM02.2.04.01.03 | C | 03 |  |  | S331300 | 2.04 | 16723 |  | 2.04 |  |  |  |  |  |  |  |  |  |  |  |
| S331400 |  | Procure & Deliver Detector Elec. Racks & Rack generic support systems Components (leadtime and fab incl.) - M&S |  | 50d | 2021-12-27 | 2022-03-09 | S331300 SS |  |  |  |  | 1d | 0d |  |  | Material (Purchase (1st $2M) [92000 h] | 108,918.62 | S331400 | 0 |  | S281200 |  | S282050 | CA | Not Started | C | Pisani, Rob | M5 | BNL | Fab & Assy | Joel Vasquez | BNL | null | POM02.2.04.01.03 | C | 03 |  |  | S331400 | 2.04 | 16723 |  | 2.04 | UDF_G2 | UDF_G1 | 108705.049224 | 1 |  |  | MP6LAEXCLUDE | TBD | Combined |  |  |
| S331500 |  | Perform Detector Electronics Racks and Rack generic support systems Components Acceptance |  | 10d | 2022-03-10 | 2022-03-23 | S331300, S331400 |  |  |  |  | 1d | 0d |  |  | PROF4 PO M [8 h]; TECH3 PO M [40 h]; TECH3 PO D [16 h]; PROF3 PO E [8 h] | 9,103.62 | S331500 | 0 |  | S282100 |  | S282100 | CA | Not Started | C | Pisani, Rob | L4 | BNL | Procurement | Joel Vasquez | BNL | null | POM02.2.04.01.03 | C | 03 |  |  | S331500 | 2.04 | 16723 |  | 2.04 |  |  |  |  |  |  |  |  |  |  |  |
| S331600 |  | Detector Electronics Racks and Rack generic support systems Components Ready for Installation | milestone | 0d | 2022-03-23 | 2022-03-23 | S331500 |  |  |  |  | 1d | 0d |  |  |  |  | S331600 | 0 |  | S282200 |  | S282200 | NOCA | Not Started | C | Pisani, Rob |  | BNL | Procurement | Joel Vasquez | BNL |  | POM02.2.04.01.03 |  | 03 |  |  |  |  |  |  |  |  |  |  |  | -35 | L3 |  |  |  | 2022-02-02 | PMP_2x |

Notes:
- S330500: BNL_UDF_Old Activity Name 181221: Analyze Detector Electronics Racks and Rack generic support systems Requirements FY18
- S330600: BNL_UDF_Old Activity Name 181221: Analyze Detector Electronics Racks and Rack generic support systems Requirements FY19
- S330601: BNL_UDF_Old Activity Name 181221: Analyze Detector Electronics Racks and Rack generic support systems Requirements FY19
- S330700: BNL_UDF_Old Activity Name 181221: Create Layout/Schematic Drawings & Design, Specification Control Documents, Assembly & Detail Drawings for Detector Elec
- S1002799: BNL_UDF_Old Activity Name 181221: Review Detector Electronics Racks and Rack generic support systems Design/Safety
- S330800: BNL_UDF_Old Activity Name 181221: Review Detector Electronics Racks and Rack generic support systems Design/Safety
- S330900: BNL_UDF_Old Activity Name 181221: Address Action Items from Detector Electronics Racks and Rack generic support systems Design & Safety Reviews
- S331000: BNL_UDF_Old Activity Name 181221: Design/Safety Reviews Complete, Detector Electronics Racks and Rack generic support systems Components Released for Prod
- S331100: BNL_UDF_Old Activity Name 181221: Prepare Detector Electronics Racks and Rack generic support systems Components Procurement Package(s)
- S331200: BNL_UDF_Old Activity Name 181221: Evaluate & Process Detector Electronics Racks and Rack generic support systems Components Bids
- S331300: BNL_UDF_Old Activity Name 181221: Procure & Deliver Detector Elec. Racks & Rack generic support systems Components (leadtime and fab incll) - Labor
- S331400: BNL_UDF_Old Activity Name 181221: Procure & Deliver Detector Elec. Racks & Rack generic support systems Components (leadtime and fab incll) - M&S
- S331500: BNL_UDF_Old Activity Name 181221: Perform Detector Electronics Racks and Rack generic support systems Components Acceptance
- S331600: BNL_UDF_Old Activity Name 181221: Detector Electronics Racks and Rack generic support systems Components Ready for Installation

| ID | WBS | Activity | Type | Duration | Start | Finish | Predecessors | Complete | Remaining | Planned start | Planned finish | Total float | Free float | Constraint | Expected finish | Resources | Cost | BNL_UDF_Status Comments | BNL_UDF_Temp Text 01 | BNL_UDF_Percent Complete | BNL_UDF_OPC TEC (deprecated) | BNL_UDF_Temp Date 01 | BNL_UDF_Old Activity ID 181221 | RG Check | BNL_Activity Status | BNL_Fund Source | BNL_Estimator | BNL_Cost Basis | BNL_Location | BNL_EDIA | BNL_CAM | BNL_Institution | BNL_OPC TEC (deprecated) | BNL_WBS | BNL_EVT | BNL_Account Number | BNL_PCR ID | BNL_WBS_Hierarchical | Completed | Additional EVT documentation required | BNL_Cobra WP | BNL_Master Control Account | BNL_Cobra Control Account | Variance | BNL_Milestone Level | BNL_UDF_Exclude | BNL_Proc Sig | BNL_Obligation | Indicator - Procurement | Indicator - Float | BNL_UDF_Remaining Tot Cost | BNL_UDF_Percent_remaining | SPH Proc Register |
| --- | --- | --- | --- | --- | --- | --- | --- | --- | --- | --- | --- | --- | --- | --- | --- | --- | --- | --- | --- | --- | --- | --- | --- | --- | --- | --- | --- | --- | --- | --- | --- | --- | --- | --- | --- | --- | --- | --- | --- | --- | --- | --- | --- | --- | --- | --- | --- | --- | --- | --- | --- | --- | --- |
|  | 04 | **Detector Gas and Cooling Services Systems** |  |  | 2019-01-02 | 2022-11-28 |  |  |  |  |  |  |  |  |  |  |  |  |  |  |  |  |  |  |  |  |  |  |  |  |  |  |  |  |  |  |  |  |  |  |  |  |  |  |  |  |  |  |  |  |  |  |  |
| S331700 |  | Analyze Detector Gas and Cooling Services Systems Requirements |  | 105d | 2019-01-02 A | 2019-05-31 A | S100500, S101010 | 100% |  |  |  |  |  |  |  |  |  | 190318 ELM logic per GRY | S331700 | 5 | S282400 | 2019-08-30 | S282400 | NOCA | Completed | C | Pisani, Rob | L4 | BNL | Design | Joel Vasquez | BNL | null | POM02.2.04.01.04 | C | 16723 | 003 | 04 | yes | Yes |  |  |  |  |  |  |  |  |  |  |  |  |  |
| S1002839 |  | Analyze Detector Gas and Cooling Services Systems Requirements Split - Physics Resource(s) |  | 61d | 2019-10-01 A | 2020-07-31 A | S331700 | 100% |  | 2019-10-01 | 2019-12-31 |  |  |  |  | PROF4 PO M [168 h]; TECH3 PO M [66 h]; TECH3 PO D [66 h]; SCI3 PO [66 h] | 51,163.62 | 190318 ELM logic per GRY | S331700 | 5 | S282400 | 2019-08-30 | S282400 | CA | In Progress | C | Pisani, Rob | L4 | BNL | Design | Joel Vasquez | BNL | null | POM02.2.04.01.04 | C | 16723 | 003 | 04 |  | Yes | S1002839 | 2.04 | 2.04 |  |  |  |  |  |  |  |  |  |  |
| S331705 |  | Analyze Detector Gas and Cooling Services Systems Requirements Split - CA-D Resource(s) |  | 61d | 2019-10-01 A | 2020-07-31 A | S331700 | 100% |  | 2019-10-01 | 2019-12-31 |  |  |  |  | PROF4 AD [16 h] | 2,356.24 | 190318 ELM logic per GRY | S331700 | 5 | S282400 | 2019-08-30 | S282400 | CA | In Progress | C | Pisani, Rob | L4 | BNL | Design | Joel Vasquez | BNL | null | POM02.2.04.01.04 | C | 16723 | 003 | 04 |  | Yes | S331705 | 2.04 | 2.04 |  |  |  |  |  |  |  |  |  |  |
| S331720 |  | Design Cooling Manifolds for TPC |  | 5d | 2020-03-17 A | 2021-04-16 A | S331710 | 100% |  | 2020-08-17 | 2020-08-21 |  |  |  |  | PROF4 PO E [8 h]; TECH3 PO D [24 h] | 3,917.05 | 190318 ELM logic per GRY | S331700 | 5 | S282400 | 2019-08-30 | S282400 | CA | In Progress | C | Pisani, Rob | L4 | BNL | Design | Joel Vasquez | BNL | null | POM02.2.04.01.04 | C | 16723 | 010 | 04 |  |  | S331720 | 2.04 | 2.04 | 0 |  |  |  |  |  |  |  |  |  |
| S331710 |  | Design Cooling Manifolds for EMCal |  | 10d | 2020-03-18 A | 2021-06-15 |  | 40% | 11d | 2020-08-03 | 2020-08-14 | 8d | 0d | start on or after 2020-08-03 | 2021-06-15 | PROF4 PO E [8 h]; TECH3 PO D [24 h] | 3,917.05 | 190318 ELM logic per GRY | S331700 | 5 | S282400 | 2019-08-30 | S282400 | CA | In Progress | C | Pisani, Rob | L4 | BNL | Design | Joel Vasquez | BNL | null | POM02.2.04.01.04 | C | 16723 | 010 | 04 |  |  | S331710 | 2.04 | 2.04 | 0 |  |  |  |  |  |  |  |  |  |
| S331730 |  | Design Coolin Manifolds for INTT |  | 5d | 2020-12-08 A | 2021-06-16 | S331720 | 75% | 2.96d | 2021-01-08 | 2021-01-14 | 8d | 0d |  | 2021-06-15 | PROF4 PO E [8 h]; TECH3 PO D [24 h] | 4,034.56 | 190318 ELM logic per GRY | S331700 | 5 | S282400 | 2019-08-30 | S282400 | CA | In Progress | C | Pisani, Rob | L4 | BNL | Design | Joel Vasquez | BNL | null | POM02.2.04.01.04 | C | 16723 | 010 | 04 |  |  | S331730 | 2.04 | 2.04 | 0 |  |  |  |  |  |  |  |  |  |
| S331770 |  | Conceptual Design for Cooling Tube Routing from Detector to EMCal manifold |  | 5d | 2020-12-08 A | 2021-07-21 | S331760 | 20% | 5d | 2021-02-16 | 2021-02-22 | 8d | 0d |  | 2021-06-15 | PROF4 PO E [8 h]; TECH3 PO D [24 h] | 4,034.56 | 190318 ELM logic per GRY | S331700 | 5 | S282400 | 2019-08-30 | S282400 | CA | In Progress | C | Pisani, Rob | L4 | BNL | Design | Joel Vasquez | BNL | null | POM02.2.04.01.04 | C | 16723 | 010 | 04 |  |  | S331770 | 2.04 | 2.04 | 0 |  |  |  |  |  |  |  |  |  |
| S331780 |  | Conceptual Design for Cooling Tube Routing from Detector to TPC manifold |  | 5d | 2020-12-08 A | 2021-07-28 | S331770 | 50% | 5d | 2021-02-23 | 2021-03-01 | 8d | 0d |  | 2021-06-15 | PROF4 PO E [8 h]; TECH3 PO D [24 h] | 4,034.56 | 190318 ELM logic per GRY | S331700 | 5 | S282400 | 2019-08-30 | S282400 | CA | In Progress | C | Pisani, Rob | L4 | BNL | Design | Joel Vasquez | BNL | null | POM02.2.04.01.04 | C | 16723 | 010 | 04 |  |  | S331780 | 2.04 | 2.04 | 0 |  |  |  |  |  |  |  |  |  |
| S331790 |  | Conceptual Design for Cooling Tube Routing from Detector to INTT, MVTX manifold |  | 10d | 2020-12-14 A | 2021-08-10 | S331780 | 5% | 9d | 2021-03-02 | 2021-03-15 | 8d | 0d |  | 2021-06-15 | PROF4 PO E [16 h]; TECH3 PO D [48 h] | 8,069.13 | 190318 ELM logic per GRY | S331700 | 5 | S282400 | 2019-08-30 | S282400 | CA | In Progress | C | Pisani, Rob | L4 | BNL | Design | Joel Vasquez | BNL | null | POM02.2.04.01.04 | C | 16723 | 010 | 04 |  |  | S331790 | 2.04 | 2.04 | 0 |  |  |  |  |  |  |  |  |  |
| S332710 |  | Conceptual Design for Routing N2 Line from Gas House to N2/Air Manifolds |  | 2d | 2020-12-18 A | 2021-08-12 | S332705 | 80% | 2d | 2021-03-18 | 2021-03-19 | 41d | 0d |  | 2021-06-18 | PROF4 PO M [8 h]; TECH3 PO D [16 h] | 3,094.2 |  | S332600 | 0 | S283200 |  | S283200 | CA | Not Started | C | Pisani, Rob | L4 | BNL | Procurement | Joel Vasquez | BNL | null | POM02.2.04.01.04 | C | 16723 | 010 | 04 |  |  | S332710 | 2.04 | 2.04 | 0 |  |  |  |  |  |  |  |  |  |
| S332720 |  | Conceptual Design for Gas Tube Routing from Det to N2/Air Manifolds (INTT, MVTX) |  | 10d | 2020-12-18 A | 2021-09-10 | S332715 | 30% | 10d | 2021-04-05 | 2021-04-16 | 41d | 0d |  | 2021-06-18 | PROF4 PO M [8 h]; TECH3 PO D [16 h] | 3,094.2 |  | S332600 | 0 | S283200 |  | S283200 | CA | Not Started | C | Pisani, Rob | L4 | BNL | Procurement | Joel Vasquez | BNL | null | POM02.2.04.01.04 | C | 16723 | 010 | 04 |  |  | S332720 | 2.04 | 2.04 | 0 |  |  |  |  |  |  |  |  |  |
| S332725 |  | Conceptual Design for Gas Tube Routing from Det to N2/Air Manifolds (EMCal) |  | 5d | 2020-12-18 A | 2021-09-17 | S332720 | 30% | 5d | 2021-04-19 | 2021-04-23 | 41d | 0d |  | 2021-06-18 | PROF4 PO M [8 h]; TECH3 PO D [16 h] | 3,094.2 |  | S332600 | 0 | S283200 |  | S283200 | CA | Not Started | C | Pisani, Rob | L4 | BNL | Procurement | Joel Vasquez | BNL | null | POM02.2.04.01.04 | C | 16723 | 010 | 04 |  |  | S332725 | 2.04 | 2.04 | 0 |  |  |  |  |  |  |  |  |  |
| S332730 |  | Conceptual Design for Gas Tube Routing from Det to Operating Gas Manifolds (TPC) |  | 5d | 2020-12-22 A | 2021-09-24 | S332725 | 30% | 5d | 2021-04-26 | 2021-04-30 | 41d | 0d |  | 2021-06-18 | PROF4 PO M [8 h]; TECH3 PO D [16 h] | 3,094.2 |  | S332600 | 0 | S283200 |  | S283200 | CA | Not Started | C | Pisani, Rob | L4 | BNL | Procurement | Joel Vasquez | BNL | null | POM02.2.04.01.04 | C | 16723 | 010 | 04 |  |  | S332730 | 2.04 | 2.04 | 0 |  |  |  |  |  |  |  |  |  |
| S332705 |  | Conceptual Design for Routing Operating gas Line from Gas House to TPC Manifold |  | 2d | 2021-01-13 A | 2021-01-20 A | S331790 | 100% |  | 2021-04-13 | 2021-04-14 |  |  |  |  | PROF4 PO M [8 h]; TECH3 PO D [16 h] | 3,094.2 |  | S332600 | 0 | S283200 |  | S283200 | CA | Not Started | C | Pisani, Rob | L4 | BNL | Procurement | Joel Vasquez | BNL | null | POM02.2.04.01.04 | C | 16723 | 010 | 04 |  |  | S332705 | 2.04 | 2.04 | 0 |  |  |  |  |  |  |  |  |  |
| S331740 |  | Design Coolin Manifolds for MVTX |  | 5d | 2021-02-08 A | 2021-02-22 A | S331730 | 100% |  | 2021-03-23 | 2021-03-29 |  |  |  |  | PROF4 PO E [8 h]; TECH3 PO D [24 h] | 4,034.56 | 190318 ELM logic per GRY | S331700 | 5 | S282400 | 2019-08-30 | S282400 | CA | In Progress | C | Pisani, Rob | L4 | BNL | Design | Joel Vasquez | BNL | null | POM02.2.04.01.04 | C | 16723 | 010 | 04 |  |  | S331740 | 2.04 | 2.04 | 0 |  |  |  |  |  |  |  |  |  |
| S332712 |  | Conceptual Design for Gas Tube Routing from Det to N2/Air Manifolds (IHCal) |  | 5d | 2021-02-15 A | 2021-08-19 | S332710 | 30% | 5d | 2021-05-19 | 2021-05-25 | 41d | 0d |  | 2021-06-18 | PROF4 PO M [8 h]; TECH3 PO D [16 h] | 3,094.2 |  | S332600 | 0 | S283200 |  | S283200 | CA | Not Started | C | Pisani, Rob | L4 | BNL | Procurement | Joel Vasquez | BNL | null | POM02.2.04.01.04 | C | 16723 | 010 | 04 |  |  | S332712 | 2.04 | 2.04 | 0 |  |  |  |  |  |  |  |  |  |
| S332715 |  | Conceptual Design for Gas Tube Routing from Det to N2/Air Manifolds (MBD) |  | 5d | 2021-02-15 A | 2021-08-26 | S332712 | 60% | 5d | 2021-05-26 | 2021-06-02 | 41d | 0d |  | 2021-06-02 | PROF4 PO M [8 h]; TECH3 PO D [16 h] | 3,094.2 |  | S332600 | 0 | S283200 |  | S283200 | CA | Not Started | C | Pisani, Rob | L4 | BNL | Procurement | Joel Vasquez | BNL | null | POM02.2.04.01.04 | C | 16723 | 010 | 04 |  |  | S332715 | 2.04 | 2.04 | 0 |  |  |  |  |  |  |  |  |  |
| S332735 |  | Create Layout/Schematic Drawings & Design, Specs Control Docs, Assem. & Detail Drawings for Det Gas |  | 60d | 2021-02-15 A | 2021-10-12 | S332730 | 30% | 11d | 2021-07-01 | 2021-09-24 | 41d | 0d |  | 2021-09-24 | PROF4 PO M [96 h]; TECH3 PO D [48 h]; TECH3 PO M [48 h] | 25,845.96 |  | S332600 | 0 | S283200 |  | S283200 | CA | Not Started | C | Pisani, Rob | L4 | BNL | Procurement | Joel Vasquez | BNL | null | POM02.2.04.01.04 | C | 16723 | 010 | 04 |  |  | S332735 | 2.04 | 2.04 | 0 |  |  |  |  |  |  |  |  |  |
| S331800 |  | Create Layout/Schematic Drawings & Design, Specification Control Documents, Assembly & Detail Drawings for Detector Gas |  | 57d | 2021-02-22 A | 2021-08-24 | S331705, S1002839, S331790 | 33% | 10d | 2021-04-13 | 2021-07-01 | 8d | 0d |  | 2021-06-15 | PROF4 PO M [96 h]; TECH3 PO D [48 h]; TECH3 PO M [48 h] | 25,845.96 |  | S331800 | 0 | S282500 |  | S282500 | CA | Not Started | C | Pisani, Rob | L4 | BNL | Design | Joel Vasquez | BNL | null | POM02.2.04.01.04 | C | 16723 |  | 04 |  |  | S331800 | 2.04 | 2.04 |  |  |  |  |  |  |  |  |  |  |
| S331750 |  | Conceptual Design for Routing Detector Cooling Chiller Systems to Det Manifolds |  | 10d | 2021-02-23 A | 2021-07-07 | S331740 | 50% | 15d | 2021-03-30 | 2021-04-12 | 8d | 0d |  | 2021-06-15 | PROF4 PO E [8 h]; TECH3 PO D [24 h] | 4,034.56 | 190318 ELM logic per GRY | S331700 | 5 | S282400 | 2019-08-30 | S282400 | CA | In Progress | C | Pisani, Rob | L4 | BNL | Design | Joel Vasquez | BNL | null | POM02.2.04.01.04 | C | 16723 | 010 | 04 |  |  | S331750 | 2.04 | 2.04 | 0 |  |  |  |  |  |  |  |  |  |
| S331905 |  | Review Detector Cooling Services Systems Design/Safety |  | 10d | 2021-06-01 | 2021-06-14 |  |  |  |  |  | 68d | 60d | start on or after 2021-01-28 |  | PROF4 PO E [16 h] | 2,426.93 |  | S331900 | 0 | S282600 |  | S282600 | CA | Not Started | C | Pisani, Rob | L4 | BNL | Design | Joel Vasquez | BNL | null | POM02.2.04.01.04 | C | 16723 | 010 | 04 |  |  | S331905 | 2.04 | 2.04 | 0 |  |  |  |  |  |  |  |  |  |
| S331760 |  | Conceptual Design for Cooling Tube Routing from Detector to IHCal manifold |  | 5d | 2021-07-08 | 2021-07-14 | S331750 |  |  |  |  | 8d | 0d |  |  | PROF4 PO E [8 h]; TECH3 PO D [24 h] | 4,034.56 | 190318 ELM logic per GRY | S331700 | 5 | S282400 | 2019-08-30 | S282400 | CA | In Progress | C | Pisani, Rob | L4 | BNL | Design | Joel Vasquez | BNL | null | POM02.2.04.01.04 | C | 16723 | 010 | 04 |  |  | S331760 | 2.04 | 2.04 | 0 |  |  |  |  |  |  |  |  |  |
| S1002879 |  | Review Detector Gas and Cooling Services Systems Design/Safety - Physics Resource(s) |  | 10d | 2021-08-25 | 2021-09-08 | S331800 |  |  |  |  | 8d | 0d |  |  | PROF4 PO M [16 h]; TECH3 PO D [20 h]; TECH3 PO M [8 h] | 5,718.21 |  | S331900 | 0 | S282600 |  | S282600 | CA | Not Started | C | Pisani, Rob | L4 | BNL | Design | Joel Vasquez | BNL | null | POM02.2.04.01.04 | C | 16723 |  | 04 |  |  | S1002879 | 2.04 | 2.04 |  |  |  |  |  |  |  |  |  |  |
| S331900 |  | Review Detector Gas and Cooling Services Systems Design/Safety - CA-D Resource(s) |  | 10d | 2021-08-25 | 2021-09-08 | S331800 |  |  |  |  | 8d | 0d |  |  | PROF4 AD [16 h] | 2,426.93 |  | S331900 | 0 | S282600 |  | S282600 | CA | Not Started | C | Pisani, Rob | L4 | BNL | Design | Joel Vasquez | BNL | null | POM02.2.04.01.04 | C | 16723 |  | 04 |  |  | S331900 | 2.04 | 2.04 |  |  |  |  |  |  |  |  |  |  |
| S332000 |  | Address Action Items from Detector Gas and Cooling Services Systems Design & Safety Reviews |  | 10d | 2021-09-09 | 2021-09-22 | S331900, S1002879, S331905 |  |  |  |  | 8d | 0d |  |  | PROF4 PO M [20 h]; TECH3 PO D [16 h]; TECH3 PO M [16 h] | 6,795.12 |  | S332000 | 0 | S282700 |  | S282700 | CA | Not Started | C | Pisani, Rob | L4 | BNL | Management Safety Reviews | Joel Vasquez | BNL | null | POM02.2.04.01.04 | C | 16723 |  | 04 |  |  | S332000 | 2.04 | 2.04 |  |  |  |  |  |  |  |  |  |  |
| S332100 |  | Design/Safety Reviews Complete, Detector Gas and Cooling Services Systems Components Released for Production | milestone | 0d | 2021-09-22 | 2021-09-22 | S332000 FF |  |  |  |  | 8d | 0d |  |  |  |  |  | S332100 | 0 | S282800 |  | S282800 | NOCA | Not Started | C | Pisani, Rob |  | BNL | Management Safety Reviews | Joel Vasquez | BNL |  | POM02.2.04.01.04 |  |  |  | 04 |  |  |  |  |  |  | L4 |  |  |  |  |  |  |  |  |
| S332200 |  | Prepare Detector Gas and Cooling Services Systems Components Procurement Package(s) |  | 50d | 2021-09-23 | 2021-12-07 | S332100 |  |  |  |  | 13d | 0d |  |  | PROF4 PO M [32 h]; TECH3 PO D [72 h] | 13,668.73 |  | S332200 | 0 | S282900 |  | S282900 | CA | Not Started | C | Pisani, Rob | L4 | BNL | Procurement | Joel Vasquez | BNL | null | POM02.2.04.01.04 | C | 16723 |  | 04 |  | Yes | S332200 | 2.04 | 2.04 |  |  |  |  |  |  |  |  |  |  |
| S332740 |  | Review Detector Gas Service Systems Design/Safety |  | 10d | 2021-10-13 | 2021-10-26 | S332735 |  |  |  |  | 41d | 0d |  |  | PROF4 PO M [8 h]; TECH3 PO D [16 h] | 3,187.02 |  | S332600 | 0 | S283200 |  | S283200 | CA | Not Started | C | Pisani, Rob | L4 | BNL | Procurement | Joel Vasquez | BNL | null | POM02.2.04.01.04 | C | 16723 | 010 | 04 |  |  | S332740 | 2.04 | 2.04 | 0 |  |  |  |  |  |  |  |  |  |
| S332745 |  | Address Action items from Detector Gas Services Systems Design & Safety Reviews |  | 10d | 2021-10-27 | 2021-11-09 | S332740 |  |  |  |  | 41d | 0d |  |  | PROF4 PO M [20 h]; TECH3 PO D [8 h]; TECH3 PO M [8 h] | 5,061.82 |  | S332600 | 0 | S283200 |  | S283200 | CA | Not Started | C | Pisani, Rob | L4 | BNL | Procurement | Joel Vasquez | BNL | null | POM02.2.04.01.04 | C | 16723 | 010 | 04 |  |  | S332745 | 2.04 | 2.04 | 0 |  |  |  |  |  |  |  |  |  |
| S332750 |  | Design/Safety Reviews complete (MS) for Detector Gas Service Systems | milestone | 0d | 2021-11-09 | 2021-11-09 | S332745 |  |  |  |  | 41d | 0d |  |  |  |  |  | S332600 | 0 | S283200 |  | S283200 | CA | Not Started | C | Pisani, Rob | L4 | BNL | Procurement | Joel Vasquez | BNL | null | POM02.2.04.01.04 | F | 16723 | 010 | 04 |  |  |  | 2.04 |  | 0 |  |  |  |  |  |  |  |  |  |
| S332755 |  | Prepare Detector Gas Services Systems Components Procurement Packages |  | 90d | 2021-11-10 | 2022-03-24 | S332750 |  |  |  |  | 41d | 0d |  |  | PROF4 PO M [32 h]; TECH3 PO D [72 h] | 13,716.67 |  | S332600 | 0 | S283200 |  | S283200 | CA | Not Started | C | Pisani, Rob | L4 | BNL | Procurement | Joel Vasquez | BNL | null | POM02.2.04.01.04 | C | 16723 | 010 | 04 |  |  | S332755 | 2.04 | 2.04 | 0 |  |  |  |  |  |  |  |  |  |
| S332300 |  | Evaluate & Process Detector Gas and Cooling Services Systems Components Bids |  | 30d | 2021-12-08 | 2022-01-21 | S332200 |  |  |  |  | 13d | 0d |  |  | PROF4 PO M [24 h]; TECH3 PO D [24 h] | 6,655.34 |  | S332300 | 0 | S283000 |  | S283000 | CA | Not Started | C | Pisani, Rob | L4 | BNL | Procurement | Joel Vasquez | BNL | null | POM02.2.04.01.04 | C | 16723 |  | 04 |  |  | S332300 | 2.04 | 2.04 |  |  |  |  |  |  |  |  |  |  |
| OBLG329000 |  | Procure & Deliver Detector Gas and Cooling Services Systems Components (leadtime and fabrication included) M&S |  | 1d | 2022-01-24 | 2022-01-24 | S332400 SS |  |  |  |  | 13d | 0d |  |  | Obligation Resource [124193 h] | 124,193 |  | S332500 | 0 | S282300 |  | S283185 |  | Not Started | C | Pisani, Rob | M5 | BNL | Fab & Assy | Joel Vasquez | BNL | null | POM02.2.04.01.04 | K | 16723 | 008C | 04 |  |  | S332500 | 2.04 |  |  |  | MP6LAEXCLUDE | TBD | OBLG |  |  |  |  |  |
| S332400 |  | Procure & Deliver Detector Gas and Cooling Services Systems Components (leadtime and fabrication included) L |  | 90d | 2022-01-24 | 2022-05-31 | S332300 |  |  |  |  | 13d | 0d |  |  | PROF4 PO M [96 h]; TECH3 PO D [96 h] | 26,621.34 |  | S332400 | 0 | S283100 |  | S283100 | CA | Not Started | C | Pisani, Rob | L4 | BNL | Fab & Assy | Joel Vasquez | BNL | null | POM02.2.04.01.04 | C | 16723 |  | 04 |  | Yes | S332400 | 2.04 | 2.04 |  |  |  |  |  |  |  |  |  |  |
| S332500 |  | Procure & Deliver Detector Gas and Cooling Services Systems Components (leadtime and fabrication included) M&S |  | 90d | 2022-01-24 | 2022-05-31 | S332400 SS, OBLG329000 SS |  |  |  |  | 13d | 0d |  |  | Material (Purchase (1st $2M) [53000 h] | 62,746.59 |  | S332500 | 0 | S282300 |  | S283185 | CA | Not Started | C | Pisani, Rob | M5 | BNL | Fab & Assy | Joel Vasquez | BNL | null | POM02.2.04.01.04 | C | 16723 |  | 04 |  | Yes | S332500 | 2.04 | 2.04 |  |  | MP6LAEXCLUDE | TBD |  | UDF_G1 | UDF_G1 | 62418.506793 | 1 | Combined |
| S332760 |  | Evaluate & Process Bids Detector Gas Services Systems Components |  | 30d | 2022-03-25 | 2022-05-05 | S332755 |  |  |  |  | 41d | 0d |  |  | PROF4 PO M [24 h]; TECH3 PO D [24 h] | 6,655.34 |  | S332600 | 0 | S283200 |  | S283200 | CA | Not Started | C | Pisani, Rob | L4 | BNL | Procurement | Joel Vasquez | BNL | null | POM02.2.04.01.04 | C | 16723 | 010 | 04 |  |  | S332760 | 2.04 | 2.04 | 0 |  |  |  |  |  |  |  |  |  |
| S332765 |  | Procure & Deliver Detector Gas Services Systems Components - Labor |  | 120d | 2022-05-06 | 2022-10-26 | S332760 |  |  |  |  | 41d | 0d |  |  | PROF4 PO M [96 h]; TECH3 PO D [96 h] | 26,734.48 |  | S332600 | 0 | S283200 |  | S283200 | CA | Not Started | C | Pisani, Rob | L4 | BNL | Procurement | Joel Vasquez | BNL | null | POM02.2.04.01.04 | C | 16723 | 010 | 04 |  |  | S332765 | 2.04 | 2.04 | 0 |  |  |  |  |  |  |  |  |  |
| S332770 |  | Procure & Deliver Detector Gas Services Systems Components - M&S |  | 120d | 2022-05-06 | 2022-10-26 | S332760 |  |  |  |  | 41d | 0d |  |  | Material (Purchase (1st $2M) [54000 h] | 64,111.63 |  | S332600 | 0 | S283200 |  | S283200 | CA | Not Started | C | Pisani, Rob | L4 | BNL | Procurement | Joel Vasquez | BNL | null | POM02.2.04.01.04 | C | 16723 | 010 | 04 |  |  | S332770 | 2.04 | 2.04 | 0 |  |  |  |  | UDF_G1 | UDF_G1 | 63930.49146 | 1 |  |
| S332600 |  | Perform Detector Gas and Cooling Services Systems Components Acceptance |  | 20d | 2022-06-01 | 2022-06-28 | S332400, S332500 |  |  |  |  | 13d | 0d |  |  | PROF4 PO M [16 h]; TECH3 PO D [16 h]; TECH3 PO M [8 h] | 5,405.47 |  | S332600 | 0 | S283200 |  | S283200 | CA | Not Started | C | Pisani, Rob | L4 | BNL | Procurement | Joel Vasquez | BNL | null | POM02.2.04.01.04 | C | 16723 |  | 04 |  |  | S332600 | 2.04 | 2.04 |  |  |  |  |  |  |  |  |  |  |
| S332700 |  | Detector Gas and Cooling Services Systems Components Ready for Installation | milestone | 0d | 2022-06-28 | 2022-06-28 | S332600 FF |  |  |  |  | 13d | 0d |  |  |  |  |  | S332700 | 0 | S283300 |  | S283300 | NOCA | Not Started | C | Pisani, Rob |  | BNL | Test_System | Joel Vasquez | BNL |  | POM02.2.04.01.04 |  |  |  | 04 |  |  |  |  |  |  | L3 |  |  |  |  |  |  |  |  |
| S332775 |  | Perform Components Acceptance Detector Gas Services Systems Components |  | 20d | 2022-10-27 | 2022-11-28 | S332770, S332765 |  |  |  |  | 41d | 0d |  |  | PROF4 PO M [16 h]; TECH3 PO D [16 h]; TECH3 PO M [8 h] | 5,567.63 |  | S332600 | 0 | S283200 |  | S283200 | CA | Not Started | C | Pisani, Rob | L4 | BNL | Procurement | Joel Vasquez | BNL | null | POM02.2.04.01.04 | C | 16723 | 010 | 04 |  |  | S332775 | 2.04 | 2.04 | 0 |  |  |  |  |  |  |  |  |  |
| S332780 |  | Detector Gas Services Systems Components Ready for Installation | milestone | 0d | 2022-11-28 | 2022-11-28 | S332775 |  |  |  |  | 41d |  |  |  |  |  |  | S332600 | 0 | S283200 |  | S283200 | CA | Not Started | C | Pisani, Rob | L4 | BNL | Procurement | Joel Vasquez | BNL | null | POM02.2.04.01.04 | K | 16723 | 010 | 04 |  |  |  | 2.04 |  | 0 |  |  |  |  |  |  |  |  |  |

Notes:
- S331700: BNL_UDF_Old Activity Name 181221: Analyze Detector Gas and Cooling Services Systems Requirements
- S1002839: BNL_UDF_Old Activity Name 181221: Analyze Detector Gas and Cooling Services Systems Requirements
- S331705: BNL_UDF_Old Activity Name 181221: Analyze Detector Gas and Cooling Services Systems Requirements
- S331720: BNL_UDF_Old Activity Name 181221: Analyze Detector Gas and Cooling Services Systems Requirements
- S331710: BNL_UDF_Old Activity Name 181221: Analyze Detector Gas and Cooling Services Systems Requirements
- S331730: BNL_UDF_Old Activity Name 181221: Analyze Detector Gas and Cooling Services Systems Requirements
- S331770: BNL_UDF_Old Activity Name 181221: Analyze Detector Gas and Cooling Services Systems Requirements
- S331780: BNL_UDF_Old Activity Name 181221: Analyze Detector Gas and Cooling Services Systems Requirements
- S331790: BNL_UDF_Old Activity Name 181221: Analyze Detector Gas and Cooling Services Systems Requirements
- S332710: BNL_UDF_Old Activity Name 181221: Perform Detector Gas and Cooling Services Systems Components Acceptance
- S332720: BNL_UDF_Old Activity Name 181221: Perform Detector Gas and Cooling Services Systems Components Acceptance
- S332725: BNL_UDF_Old Activity Name 181221: Perform Detector Gas and Cooling Services Systems Components Acceptance
- S332730: BNL_UDF_Old Activity Name 181221: Perform Detector Gas and Cooling Services Systems Components Acceptance
- S332705: BNL_UDF_Old Activity Name 181221: Perform Detector Gas and Cooling Services Systems Components Acceptance
- S331740: BNL_UDF_Old Activity Name 181221: Analyze Detector Gas and Cooling Services Systems Requirements
- S332712: BNL_UDF_Old Activity Name 181221: Perform Detector Gas and Cooling Services Systems Components Acceptance
- S332715: BNL_UDF_Old Activity Name 181221: Perform Detector Gas and Cooling Services Systems Components Acceptance
- S332735: BNL_UDF_Old Activity Name 181221: Perform Detector Gas and Cooling Services Systems Components Acceptance
- S331800: BNL_UDF_Old Activity Name 181221: Create Layout/Schematic Drawings & Design, Specification Control Documents, Assembly & Detail Drawings for Detector Gas
- S331750: BNL_UDF_Old Activity Name 181221: Analyze Detector Gas and Cooling Services Systems Requirements
- S331905: BNL_UDF_Old Activity Name 181221: Review Detector Gas and Cooling Services Systems Design/Safety
- S331760: BNL_UDF_Old Activity Name 181221: Analyze Detector Gas and Cooling Services Systems Requirements
- S1002879: BNL_UDF_Old Activity Name 181221: Review Detector Gas and Cooling Services Systems Design/Safety
- S331900: BNL_UDF_Old Activity Name 181221: Review Detector Gas and Cooling Services Systems Design/Safety
- S332000: BNL_UDF_Old Activity Name 181221: Address Action Items from Detector Gas and Cooling Services Systems Design & Safety Reviews
- S332100: BNL_UDF_Old Activity Name 181221: Design/Safety Reviews Complete, Detector Gas and Cooling Services Systems Components Released for Production
- S332200: BNL_UDF_Old Activity Name 181221: Prepare Detector Gas and Cooling Services Systems Components Procurement Package(s)
- S332740: BNL_UDF_Old Activity Name 181221: Perform Detector Gas and Cooling Services Systems Components Acceptance
- S332745: BNL_UDF_Old Activity Name 181221: Perform Detector Gas and Cooling Services Systems Components Acceptance
- S332750: BNL_UDF_Old Activity Name 181221: Perform Detector Gas and Cooling Services Systems Components Acceptance
- S332755: BNL_UDF_Old Activity Name 181221: Perform Detector Gas and Cooling Services Systems Components Acceptance
- S332300: BNL_UDF_Old Activity Name 181221: Evaluate & Process Detector Gas and Cooling Srvices Systems Components Bids
- OBLG329000: BNL_UDF_Old Activity Name 181221: Procure & Deliver Detector Gas and Cooling Srvices Systems Components (leadtime and fabrication included) M&S
- S332400: BNL_UDF_Old Activity Name 181221: Procure & Deliver Detector Gas and Cooling Srvices Systems Components (leadtime and fabrication included) L
- S332500: BNL_UDF_Old Activity Name 181221: Procure & Deliver Detector Gas and Cooling Srvices Systems Components (leadtime and fabrication included) M&S
- S332760: BNL_UDF_Old Activity Name 181221: Perform Detector Gas and Cooling Services Systems Components Acceptance
- S332765: BNL_UDF_Old Activity Name 181221: Perform Detector Gas and Cooling Services Systems Components Acceptance
- S332770: BNL_UDF_Old Activity Name 181221: Perform Detector Gas and Cooling Services Systems Components Acceptance
- S332600: BNL_UDF_Old Activity Name 181221: Perform Detector Gas and Cooling Services Systems Components Acceptance
- S332700: BNL_UDF_Old Activity Name 181221: Detector Gas and Cooling Services Systems Components Ready for Installation
- S332775: BNL_UDF_Old Activity Name 181221: Perform Detector Gas and Cooling Services Systems Components Acceptance
- S332780: BNL_UDF_Old Activity Name 181221: Perform Detector Gas and Cooling Services Systems Components Acceptance

| ID | WBS | Activity | Type | Duration | Start | Finish | Predecessors | Complete | Remaining | Planned start | Planned finish | Total float | Free float | Expected finish | Resources | Cost | BNL_UDF_Temp Text 01 | BNL_UDF_Percent Complete | BNL_UDF_OPC TEC (deprecated) | BNL_UDF_Old Activity ID 181221 | BNL_Cobra WP | RG Check | BNL_Activity Status | BNL_Fund Source | BNL_Estimator | BNL_Cost Basis | BNL_Location | BNL_EDIA | BNL_CAM | BNL_Institution | BNL_OPC TEC (deprecated) | BNL_WBS | BNL_EVT | BNL_Master Control Account | BNL_Account Number | BNL_PCR ID | BNL_Cobra Control Account | BNL_WBS_Hierarchical | BNL_Milestone Level | Indicator - Procurement | Indicator - Float | BNL_UDF_Remaining Tot Cost | BNL_UDF_Percent_remaining | BNL_Proc Sig | SPH Proc Register | Target Milestone Date | Variance | PMP Milestones | BNL_UDF_Status Comments | Additional EVT documentation required |
| --- | --- | --- | --- | --- | --- | --- | --- | --- | --- | --- | --- | --- | --- | --- | --- | --- | --- | --- | --- | --- | --- | --- | --- | --- | --- | --- | --- | --- | --- | --- | --- | --- | --- | --- | --- | --- | --- | --- | --- | --- | --- | --- | --- | --- | --- | --- | --- | --- | --- | --- |
|  | 05 | **Detector Safety Subsystems** |  |  | 2021-04-26 | 2022-04-20 |  |  |  |  |  |  |  |  |  |  |  |  |  |  |  |  |  |  |  |  |  |  |  |  |  |  |  |  |  |  |  |  |  |  |  |  |  |  |  |  |  |  |  |  |
| S1002919 |  | Analyze Detector Safety Subsystems Requirements - Physics Resource(s) |  | 25d | 2021-04-26 A | 2021-09-02 | S331000 | 60% | 25d | 2021-07-01 | 2021-08-05 | 81d | 0d | 2021-06-30 | PROF4 PO E [48 h]; SCI3 PO [24 h]; TECH3 PO E [24 h]; TECH3 PO M [24 h]; TECH3 PO D [24 h] | 19,998.53 | S332800 | 0 | S283500 | S283500 | S1002919 | CA | Not Started | C | Pisani, Rob | L4 | BNL | Design | Joel Vasquez | BNL | null | POM02.2.04.01.05 | C | 2.04 | 16723 | 012 | 2.04 | 05 |  |  |  |  |  |  |  |  |  |  |  |  |
| S332800 |  | Analyze Detector Safety Subsystems Requirements - CA-D Resource(s) |  | 25d | 2021-04-26 A | 2021-09-02 | S331000 | 60% | 25d | 2021-07-01 | 2021-08-05 | 81d | 0d | 2021-06-30 | PROF4 AD [8 h] | 1,213.46 | S332800 | 0 | S283500 | S283500 | S332800 | CA | Not Started | C | Pisani, Rob | L4 | BNL | Design | Joel Vasquez | BNL | null | POM02.2.04.01.05 | C | 2.04 | 16723 | 012 | 2.04 | 05 |  |  |  |  |  |  |  |  |  |  |  |  |
| S1002959 |  | Create Schematic Design and Specification Control Documents for Detector Safety Subsystems - Physics Resource(s) |  | 25d | 2021-09-03 | 2021-10-08 | S1002919, S332800 |  |  |  |  | 81d | 0d |  | TECH3 PO D [24 h]; PROF4 PO E [48 h] | 10,174.61 | S332900 | 0 | S283600 | S283600 | S1002959 | CA | Not Started | C | Pisani, Rob | L4 | BNL | Design | Joel Vasquez | BNL | null | POM02.2.04.01.05 | C | 2.04 | 16723 | 012 | 2.04 | 05 |  |  |  |  |  |  |  |  |  |  |  |  |
| S332900 |  | Create Schematic Design and Specification Control Documents for Detector Safety Subsystems - CA-D Resource(s) |  | 25d | 2021-09-03 | 2021-10-08 | S1002919, S332800 |  |  |  |  | 81d | 0d |  | PROF4 AD [12 h] | 1,833.3 | S332900 | 0 | S283600 | S283600 | S332900 | CA | Not Started | C | Pisani, Rob | L4 | BNL | Design | Joel Vasquez | BNL | null | POM02.2.04.01.05 | C | 2.04 | 16723 | 012 | 2.04 | 05 |  |  |  |  |  |  |  |  |  |  |  |  |
| S1002999 |  | Review Detector Safety Subsystems Design/Safety - Physics Resource(s) |  | 10d | 2021-10-12 | 2021-10-25 | S332900, S1002959 |  |  |  |  | 81d | 0d |  | TECH3 PO D [8 h]; PROF4 PO E [16 h] | 3,468.31 | S333000 | 0 | S283700 | S283700 | S1002999 | CA | Not Started | C | Pisani, Rob | L4 | BNL | Design | Joel Vasquez | BNL | null | POM02.2.04.01.05 | C | 2.04 | 16723 |  | 2.04 | 05 |  |  |  |  |  |  |  |  |  |  |  |  |
| S333000 |  | Review Detector Safety Subsystems Design/Safety - CA-D Resource(s) |  | 10d | 2021-10-12 | 2021-10-25 | S332900, S1002959 |  |  |  |  | 81d | 0d |  | PROF4 AD [8 h] | 1,249.87 | S333000 | 0 | S283700 | S283700 | S333000 | CA | Not Started | C | Pisani, Rob | L4 | BNL | Design | Joel Vasquez | BNL | null | POM02.2.04.01.05 | C | 2.04 | 16723 |  | 2.04 | 05 |  |  |  |  |  |  |  |  |  |  |  |  |
| S333100 |  | Address Action Items from Detector Safety Subsystems Design & Safety Reviews |  | 10d | 2021-10-26 | 2021-11-08 | S333000, S1002999 |  |  |  |  | 81d | 0d |  | TECH3 PO D [8 h]; PROF4 PO E [16 h] | 3,468.31 | S333100 | 0 | S283800 | S283800 | S333100 | CA | Not Started | C | Pisani, Rob | L4 | BNL | Design | Joel Vasquez | BNL | null | POM02.2.04.01.05 | C | 2.04 | 16723 |  | 2.04 | 05 |  |  |  |  |  |  |  |  |  |  |  |  |
| S333200 |  | Design/Safety Reviews Complete, Detector Safety Subsystems Components Released for Production | milestone | 0d | 2021-11-08 | 2021-11-08 | S333100 FF |  |  |  |  | 81d | 0d |  |  |  | S333200 | 0 | S283900 | S283900 |  | NOCA | Not Started | C | Pisani, Rob |  | BNL | Management Safety Reviews | Joel Vasquez | BNL |  | POM02.2.04.01.05 |  |  |  |  |  | 05 | L4 |  |  |  |  |  |  |  |  |  |  |  |
| S333300 |  | Prepare Detector Safety Subsystems Components Procurement Package(s) |  | 10d | 2021-11-09 | 2021-11-23 | S333200 |  |  |  |  | 81d | 0d |  | TECH3 PO D [8 h]; PROF4 PO E [8 h] | 2,218.45 | S333300 | 0 | S284000 | S284000 | S333300 | CA | Not Started | C | Pisani, Rob | L4 | BNL | Design | Joel Vasquez | BNL | null | POM02.2.04.01.05 | C | 2.04 | 16723 |  | 2.04 | 05 |  |  |  |  |  |  |  |  |  |  |  |  |
| S333400 |  | Evaluate & Process Detector Safety Subsystems Components Bids |  | 30d | 2021-11-24 | 2022-01-10 | S333300 |  |  |  |  | 81d | 0d |  | TECH3 PO D [24 h]; PROF4 PO E [24 h] | 6,655.34 | S333400 | 0 | S284100 | S284100 | S333400 | CA | Not Started | C | Pisani, Rob | L4 | BNL | Procurement | Joel Vasquez | BNL | null | POM02.2.04.01.05 | C | 2.04 | 16723 |  | 2.04 | 05 |  |  |  |  |  |  |  |  |  |  |  |  |
| S333500 |  | Procure & Deliver Detector Safety Subsystems Components (leadtime and fabrication included) |  | 60d | 2022-01-11 | 2022-04-06 | S333400 |  |  |  |  | 81d | 0d |  | TECH3 PO D [48 h]; PROF4 PO E [48 h] | 13,310.67 | S333500 | 0 | S284200 | S284200 | S333500 | CA | Not Started | C | Pisani, Rob | L4 | BNL | Procurement | Joel Vasquez | BNL | null | POM02.2.04.01.05 | C | 2.04 | 16723 |  | 2.04 | 05 |  |  |  |  |  |  |  |  |  |  |  |  |
| S333600 |  | Procure & Deliver Detector Safety Subsystems Components (leadtime and fabrication included) - M&S |  | 60d | 2022-01-11 | 2022-04-06 | S333500 SS |  |  |  |  | 81d | 0d |  | Material (Purchase (1st $2M) [12000 h] | 14,206.78 | S333600 | 0 | S283400 | S284250 | S333600 | CA | Not Started | C | Pisani, Rob | M5 | BNL | Fab & Assy | Joel Vasquez | BNL | null | POM02.2.04.01.05 | C | 2.04 | 16723 |  | 2.04 | 05 |  | UDF_G1 | UDF_G3 | 14132.492104 | 1 | TBD | Combined |  |  |  |  |  |
| S333700 |  | Perform Detector Safety Subsystems Components Acceptance |  | 10d | 2022-04-07 | 2022-04-20 | S333500, S333600 |  |  |  |  | 81d | 0d |  | TECH3 PO D [4 h]; TECH3 PO M [4 h]; PROF4 PO E [8 h]; TECH3 PO E [4 h] | 2,702.73 | S333700 | 0 | S284300 | S284300 | S333700 | CA | Not Started | C | Pisani, Rob | L4 | BNL | Procurement | Joel Vasquez | BNL | null | POM02.2.04.01.05 | C | 2.04 | 16723 |  | 2.04 | 05 |  |  |  |  |  |  |  |  |  |  |  |  |
| S333800 |  | Detector Safety Subsystems Components Ready for Installation | milestone | 0d | 2022-04-20 | 2022-04-20 | S333700 FF |  |  |  |  | 81d | 0d |  |  |  | S333800 | 0 | S284400 | S284400 |  | NOCA | Not Started | C | Pisani, Rob |  | BNL | Procurement | Joel Vasquez | BNL |  | POM02.2.04.01.05 |  |  |  |  |  | 05 | L3 |  |  |  |  |  |  | 2022-01-19 | -65 | PMP_2x |  |  |
|  | 06 | **Gas Mixing House & Gas Pad Components** |  |  | 2021-04-01 | 2022-07-13 |  |  |  |  |  |  |  |  |  |  |  |  |  |  |  |  |  |  |  |  |  |  |  |  |  |  |  |  |  |  |  |  |  |  |  |  |  |  |  |  |  |  |  |  |
| S1003039 |  | Analyze Gas Mixing House & Gas Pad Components Requirements - Physics Resource(s) |  | 30d | 2021-04-01 A | 2021-11-04 | S332100, S101015 SS | 75% | 30d | 2021-09-08 | 2021-10-20 | 8d | 0d | 2021-06-30 | PROF4 PO M [60 h]; TECH3 PO D [24 h]; TECH3 PO M [24 h]; TECH3 PO E [24 h] | 17,792.61 | S333900 | 0 | S284600 | S284600 | S1003039 | CA | Not Started | C | Pisani, Rob | L4 | BNL | Design | Joel Vasquez | BNL | null | POM02.2.04.01.06 | C | 2.04 | 16723 | 003 | 2.04 | 06 |  |  |  |  |  |  |  |  |  |  | 190318 ELM logic per GRY |  |
| S1003079 |  | Create Gas Mixing House & Gas Pad Components Schematic Design and Specification Control Documents P |  | 30d | 2021-04-01 A | 2021-12-21 | S333900, S1003039 | 60% | 30d | 2021-10-21 | 2021-12-06 | 8d | 0d | 2021-07-06 | PROF4 PO M [24 h]; TECH3 PO D [60 h]; TECH3 PO M [24 h]; TECH3 PO E [24 h] | 16,825.4 | S334000 | 0 | S284700 | S284700 | S1003079 | CA | Not Started | C | Pisani, Rob | L4 | BNL | Design | Joel Vasquez | BNL | null | POM02.2.04.01.06 | C | 2.04 | 16723 |  | 2.04 | 06 |  |  |  |  |  |  |  |  |  |  |  |  |
| S333900 |  | Analyze Gas Mixing House & Gas Pad Components Requirements - CA-D Resource(s) |  | 30d | 2021-04-01 A | 2021-11-04 | S332100, S101015 SS | 75% | 30d | 2021-09-08 | 2021-10-20 | 8d | 0d | 2021-06-30 | PROF4 AD [16 h] | 2,458.48 | S333900 | 0 | S284600 | S284600 | S333900 | CA | Not Started | C | Pisani, Rob | L4 | BNL | Design | Joel Vasquez | BNL | null | POM02.2.04.01.06 | C | 2.04 | 16723 | 003 | 2.04 | 06 |  |  |  |  |  |  |  |  |  |  | 190318 ELM logic per GRY |  |
| S334000 |  | Create Gas Mixing House & Gas Pad Components Schematic Design and Specification Control Documents C |  | 30d | 2021-04-01 A | 2021-12-21 | S333900, S1003039 | 60% | 30d | 2021-10-21 | 2021-12-06 | 8d | 0d | 2021-07-06 | PROF4 AD [8 h] | 1,249.87 | S334000 | 0 | S284700 | S284700 | S334000 | CA | Not Started | C | Pisani, Rob | L4 | BNL | Design | Joel Vasquez | BNL | null | POM02.2.04.01.06 | C | 2.04 | 16723 |  | 2.04 | 06 |  |  |  |  |  |  |  |  |  |  |  |  |
| S1003119 |  | Review Gas Mixing House & Gas Pad Components Design/Safety - Physics Resource(s) |  | 10d | 2021-12-22 | 2022-01-06 | S334000, S1003079 |  |  |  |  | 8d | 0d |  | PROF4 PO M [8 h]; TECH3 PO D [8 h] | 2,218.45 | S334100 | 0 | S284800 | S284800 | S1003119 | CA | Not Started | C | Pisani, Rob | L4 | BNL | Design | Joel Vasquez | BNL | null | POM02.2.04.01.06 | C | 2.04 | 16723 |  | 2.04 | 06 |  |  |  |  |  |  |  |  |  |  |  |  |
| S334100 |  | Review Gas Mixing House & Gas Pad Components Design/Safety - CA-D Resource(s) |  | 10d | 2021-12-22 | 2022-01-06 | S334000, S1003079 |  |  |  |  | 8d | 0d |  | PROF4 AD [8 h] | 1,249.87 | S334100 | 0 | S284800 | S284800 | S334100 | CA | Not Started | C | Pisani, Rob | L4 | BNL | Design | Joel Vasquez | BNL | null | POM02.2.04.01.06 | C | 2.04 | 16723 |  | 2.04 | 06 |  |  |  |  |  |  |  |  |  |  |  |  |
| S334200 |  | Address Action Items from Gas Mixing House & Gas Pad Components Design & Safety Reviews |  | 10d | 2022-01-07 | 2022-01-21 | S334100, S1003119 |  |  |  |  | 8d | 0d |  | PROF4 PO M [8 h]; TECH3 PO D [8 h] | 2,218.45 | S334200 | 0 | S284900 | S284900 | S334200 | CA | Not Started | C | Pisani, Rob | L4 | BNL | Management Safety Reviews | Joel Vasquez | BNL | null | POM02.2.04.01.06 | C | 2.04 | 16723 |  | 2.04 | 06 |  |  |  |  |  |  |  |  |  |  |  |  |
| S334300 |  | Design/Safety Reviews Complete, Gas Mixing House & Gas Pad Components Released for Production | milestone | 0d | 2022-01-21 | 2022-01-21 | S334200 FF |  |  |  |  | 8d | 0d |  |  |  | S334300 | 0 | S285000 | S285000 |  | NOCA | Not Started | C | Pisani, Rob |  | BNL | Management Safety Reviews | Joel Vasquez | BNL |  | POM02.2.04.01.06 |  |  |  |  |  | 06 | L4 |  |  |  |  |  |  |  |  |  |  |  |
| S1003159 |  | Prepare Gas Mixing House & Gas Pad Components Procurement Package(s) - Physics Resource(s) |  | 30d | 2022-01-24 | 2022-03-07 | S334300 |  |  |  |  | 8d | 0d |  | PROF4 PO M [24 h]; TECH3 PO D [24 h]; TECH3 PO M [24 h]; TECH3 PO E [24 h] | 12,466.8 | S334400 | 0 | S285100 | S285100 | S1003159 | CA | Not Started | C | Pisani, Rob | L4 | BNL | Design | Joel Vasquez | BNL | null | POM02.2.04.01.06 | C | 2.04 | 16723 |  | 2.04 | 06 |  |  |  |  |  |  |  |  |  |  |  |  |
| S334400 |  | Prepare Gas Mixing House & Gas Pad Components Procurement Package(s) - CA-D Resource(s) |  | 30d | 2022-01-24 | 2022-03-07 | S334300 |  |  |  |  | 8d | 0d |  | PROF4 AD [2 h] | 312.47 | S334400 | 0 | S285100 | S285100 | S334400 | CA | Not Started | C | Pisani, Rob | L4 | BNL | Design | Joel Vasquez | BNL | null | POM02.2.04.01.06 | C | 2.04 | 16723 |  | 2.04 | 06 |  |  |  |  |  |  |  |  |  |  |  |  |
| S1003199 |  | Evaluate & Process Gas Mixing House & Gas Pad Components Bids - Physics Resource(s) |  | 30d | 2022-03-08 | 2022-04-18 | S334400, S1003159 |  |  |  |  | 8d | 0d |  | PROF4 PO M [24 h]; TECH3 PO D [24 h]; TECH3 PO M [24 h]; TECH3 PO E [24 h] | 12,466.8 | S334500 | 0 | S285200 | S285200 | S1003199 | CA | Not Started | C | Pisani, Rob | L4 | BNL | Procurement | Joel Vasquez | BNL | null | POM02.2.04.01.06 | C | 2.04 | 16723 |  | 2.04 | 06 |  |  |  |  |  |  |  |  |  |  |  |  |
| S334500 |  | Evaluate & Process Gas Mixing House & Gas Pad Components Bids - CA-D Resource(s) |  | 30d | 2022-03-08 | 2022-04-18 | S334400, S1003159 |  |  |  |  | 8d | 0d |  | PROF4 AD [2 h] | 312.47 | S334500 | 0 | S285200 | S285200 | S334500 | CA | Not Started | C | Pisani, Rob | L4 | BNL | Procurement | Joel Vasquez | BNL | null | POM02.2.04.01.06 | C | 2.04 | 16723 |  | 2.04 | 06 |  |  |  |  |  |  |  |  |  |  |  |  |
| S334600 |  | Procure & Deliver Gas Mixing House & Gas Pad Components (leadtime and fabrication included) - Labor |  | 50d | 2022-04-19 | 2022-06-28 | S334500, S1003199 |  |  |  |  | 8d | 0d |  | PROF4 PO M [72 h]; TECH3 PO D [72 h]; TECH3 PO M [72 h]; TECH3 PO E [72 h] | 37,400.4 | S334600 | 0 | S285300 | S285300 | S334600 | CA | Not Started | C | Pisani, Rob | L4 | BNL | Fab & Assy | Joel Vasquez | BNL | null | POM02.2.04.01.06 | C | 2.04 | 16723 |  | 2.04 | 06 |  |  |  |  |  |  |  |  |  |  |  | Yes |
| S334700 |  | Procure & Deliver Gas Mixing House & Gas Pad Components (leadtime and fabrication included) - M&S |  | 50d | 2022-04-19 | 2022-06-28 | S334600 SS |  |  |  |  | 8d | 0d |  | Material (Purchase (1st $2M) [10000 h] | 11,838.98 | S334700 | 0 | S284500 | S285350 | S334700 | CA | Not Started | C | Pisani, Rob | M5 | BNL | Fab & Assy | Joel Vasquez | BNL | null | POM02.2.04.01.06 | C | 2.04 | 16723 |  | 2.04 | 06 |  | UDF_G1 | UDF_G1 | 11808.028327 | 1 | TBD | Combined |  |  |  |  | Yes |
| S1003239 |  | Perform Gas Mixing House & Gas Pad Components Acceptance - Physics Resource(s) |  | 10d | 2022-06-29 | 2022-07-13 | S334600, S334700 |  |  |  |  | 8d | 0d |  | PROF4 PO M [8 h]; TECH3 PO D [8 h]; TECH3 PO M [8 h]; TECH3 PO E [8 h] | 4,155.6 | S334800 | 0 | S285400 | S285400 | S1003239 | CA | Not Started | C | Pisani, Rob | L4 | BNL | Procurement | Joel Vasquez | BNL | null | POM02.2.04.01.06 | C | 2.04 | 16723 |  | 2.04 | 06 |  |  |  |  |  |  |  |  |  |  |  |  |
| S334800 |  | Perform Gas Mixing House & Gas Pad Components Acceptance - CA-D Resource(s) |  | 10d | 2022-06-29 | 2022-07-13 | S334600, S334700 |  |  |  |  | 8d | 0d |  | PROF4 AD [2 h] | 312.47 | S334800 | 0 | S285400 | S285400 | S334800 | CA | Not Started | C | Pisani, Rob | L4 | BNL | Procurement | Joel Vasquez | BNL | null | POM02.2.04.01.06 | C | 2.04 | 16723 |  | 2.04 | 06 |  |  |  |  |  |  |  |  |  |  |  |  |
| S334900 |  | Gas Mixing House & Gas Pad Components Ready for Installation | milestone | 0d | 2022-07-13 | 2022-07-13 | S334800 FF, S1003239 FF |  |  |  |  | 8d | 0d |  |  |  | S334900 | 0 | S285500 | S285500 |  | NOCA | Not Started | C | Pisani, Rob |  | BNL | Test_System | Joel Vasquez | BNL |  | POM02.2.04.01.06 |  |  |  |  |  | 06 | L3 |  |  |  |  |  |  |  |  |  |  |  |

Notes:
- S1002919: BNL_UDF_Old Activity Name 181221: Analyze Detector Safety Subsystems Requirements
- S332800: BNL_UDF_Old Activity Name 181221: Analyze Detector Safety Subsystems Requirements
- S1002959: BNL_UDF_Old Activity Name 181221: Create Schematic Design and Specification Control Documents for Detector Safety Subsystems
- S332900: BNL_UDF_Old Activity Name 181221: Create Schematic Design and Specification Control Documents for Detector Safety Subsystems
- S1002999: BNL_UDF_Old Activity Name 181221: Review Detector Safety Subsystems Design/Safety
- S333000: BNL_UDF_Old Activity Name 181221: Review Detector Safety Subsystems Design/Safety
- S333100: BNL_UDF_Old Activity Name 181221: Address Action Items from Detector Safety Subsystems Design & Safety Reviews
- S333200: BNL_UDF_Old Activity Name 181221: Design/Safety Reviews Complete, Detector Safety Subsystems Components Released for Production
- S333300: BNL_UDF_Old Activity Name 181221: Prepare Detector Safety Subsystems Components Procurement Package(s)
- S333400: BNL_UDF_Old Activity Name 181221: Evaluate & Process Detector Safety Subsystems Components Bids
- S333500: BNL_UDF_Old Activity Name 181221: Procure & Deliver Detector Safety Subsystems Components (leadtime and fabrication included)
- S333600: BNL_UDF_Old Activity Name 181221: Procure & Deliver Detector Safety Subsystems Components (leadtime and fabrication included) - M&S
- S333700: BNL_UDF_Old Activity Name 181221: Perform Detector Safety Subsystems Components Acceptance
- S333800: BNL_UDF_Old Activity Name 181221: Detector Safety Subsystems Components Ready for Installation
- S1003039: BNL_UDF_Old Activity Name 181221: Analyze Gas Mixing House & Gas Pad Components Requirements
- S1003079: BNL_UDF_Old Activity Name 181221: Create Gas Mixing House & Gas Pad Components Schematic Design and Specification Control Documents
- S333900: BNL_UDF_Old Activity Name 181221: Analyze Gas Mixing House & Gas Pad Components Requirements
- S334000: BNL_UDF_Old Activity Name 181221: Create Gas Mixing House & Gas Pad Components Schematic Design and Specification Control Documents
- S1003119: BNL_UDF_Old Activity Name 181221: Review Gas Mixing House & Gas Pad Components Design/Safety
- S334100: BNL_UDF_Old Activity Name 181221: Review Gas Mixing House & Gas Pad Components Design/Safety
- S334200: BNL_UDF_Old Activity Name 181221: Address Action Items from Gas Mixing House & Gas Pad Components Design & Safety Reviews
- S334300: BNL_UDF_Old Activity Name 181221: Design/Safety Reviews Complete, Gas Mixing House & Gas Pad Components Released for Production
- S1003159: BNL_UDF_Old Activity Name 181221: Prepare Gas Mixing House & Gas Pad Components Procurement Package(s)
- S334400: BNL_UDF_Old Activity Name 181221: Prepare Gas Mixing House & Gas Pad Components Procurement Package(s)
- S1003199: BNL_UDF_Old Activity Name 181221: Evaluate & Process Gas Mixing House & Gas Pad Components Bids
- S334500: BNL_UDF_Old Activity Name 181221: Evaluate & Process Gas Mixing House & Gas Pad Components Bids
- S334600: BNL_UDF_Old Activity Name 181221: Procure & Deliver Gas Mixing House & Gas Pad Components (leadtime and fabrication included) - Labor
- S334700: BNL_UDF_Old Activity Name 181221: Procure & Deliver Gas Mixing House & Gas Pad Components (leadtime and fabrication included) - M&S
- S1003239: BNL_UDF_Old Activity Name 181221: Perform Gas Mixing House & Gas Pad Components Acceptance
- S334800: BNL_UDF_Old Activity Name 181221: Perform Gas Mixing House & Gas Pad Components Acceptance
- S334900: BNL_UDF_Old Activity Name 181221: Gas Mixing House & Gas Pad Components Ready for Installation

| ID | WBS | Activity | Type | Duration | Start | Finish | Predecessors | Complete | Planned start | Planned finish | Total float | Free float | Resources | Cost | BNL_UDF_Temp Text 01 | BNL_UDF_Percent Complete | BNL_UDF_OPC TEC (deprecated) | BNL_UDF_Old Activity ID 181221 | BNL_Cobra WP | RG Check | BNL_Activity Status | BNL_Fund Source | BNL_Estimator | BNL_Cost Basis | BNL_Location | BNL_EDIA | BNL_CAM | BNL_Institution | BNL_OPC TEC (deprecated) | BNL_WBS | BNL_EVT | BNL_Master Control Account | BNL_Account Number | BNL_PCR ID | BNL_Cobra Control Account | BNL_WBS_Hierarchical | BNL_Milestone Level | Indicator - Procurement | Indicator - Float | BNL_UDF_Remaining Tot Cost | BNL_UDF_Percent_remaining | BNL_Proc Sig | SPH Proc Register | BNL_UDF_Status Comments | BNL_UDF_Exclude | BNL_Obligation |
| --- | --- | --- | --- | --- | --- | --- | --- | --- | --- | --- | --- | --- | --- | --- | --- | --- | --- | --- | --- | --- | --- | --- | --- | --- | --- | --- | --- | --- | --- | --- | --- | --- | --- | --- | --- | --- | --- | --- | --- | --- | --- | --- | --- | --- | --- | --- |
|  | 07 | **Rack Room Modifications** |  |  | 2020-09-14 | 2022-04-18 |  |  |  |  |  |  |  |  |  |  |  |  |  |  |  |  |  |  |  |  |  |  |  |  |  |  |  |  |  |  |  |  |  |  |  |  |  |  |  |  |
| S1003279 |  | Analyze Rack Room Modifications Requirements - Physics Resource(s) |  | 40d | 2020-09-14 A | 2021-02-26 A |  | 100% | 2021-07-14 | 2021-09-08 |  |  | PROF4 PO E [32 h]; SCI3 PO [32 h]; TECH3 PO E [32 h]; TECH3 PO M [32 h]; TECH3 PO D [32 h] | 21,810.86 | S335000 | 0 | S285700 | S285700 | S1003279 | CA | Not Started | C | Pisani, Rob | L4 | BNL | Design | Joel Vasquez | BNL | null | POM02.2.04.01.07 | C | 2.04 | 16723 | 012 | 2.04 | 07 |  |  |  |  |  |  |  |  |  |  |
| S335000 |  | Analyze Rack Room Modifications Requirements - CA-D Resource(s) |  | 40d | 2020-09-14 A | 2021-02-26 A |  | 100% | 2021-07-14 | 2021-09-08 |  |  | PROF4 AD [2 h] | 303.37 | S335000 | 0 | S285700 | S285700 | S335000 | CA | Not Started | C | Pisani, Rob | L4 | BNL | Design | Joel Vasquez | BNL | null | POM02.2.04.01.07 | C | 2.04 | 16723 | 012 | 2.04 | 07 |  |  |  |  |  |  |  |  |  |  |
| S335100 |  | Create Rack Room Modifications Schematic Design and Specification Control Documents |  | 40d | 2021-06-01 | 2021-07-27 | S335000, S1003279 |  |  |  | 108d | 0d | TECH3 PO D [8 h]; PROF4 PO E [32 h] | 5,794.22 | S335100 | 0 | S285800 | S285800 | S335100 | CA | Not Started | C | Pisani, Rob | L4 | BNL | Design | Joel Vasquez | BNL | null | POM02.2.04.01.07 | C | 2.04 | 16723 |  | 2.04 | 07 |  |  |  |  |  |  |  |  |  |  |
| S335200 |  | Review Rack Room Modifications Components Design/Safety |  | 10d | 2021-07-28 | 2021-08-10 | S335100 |  |  |  | 108d | 0d | SCI3 PO [8 h]; PROF4 PO E [8 h] | 2,631.61 | S335200 | 0 | S285900 | S285900 | S335200 | CA | Not Started | C | Pisani, Rob | L4 | BNL | Design | Joel Vasquez | BNL | null | POM02.2.04.01.07 | C | 2.04 | 16723 |  | 2.04 | 07 |  |  |  |  |  |  |  |  |  |  |
| S335300 |  | Address Action Items from Rack Room Modifications Design & Safety Reviews |  | 10d | 2021-08-11 | 2021-08-24 | S335200 |  |  |  | 108d | 0d | SCI3 PO [8 h]; TECH3 PO D [16 h]; TECH3 PO M [8 h]; PROF4 PO E [8 h]; TECH3 PO E [8 h] | 6,393.08 | S335300 | 0 | S286000 | S286000 | S335300 | CA | Not Started | C | Pisani, Rob | L4 | BNL | Design | Joel Vasquez | BNL | null | POM02.2.04.01.07 | C | 2.04 | 16723 |  | 2.04 | 07 |  |  |  |  |  |  |  |  |  |  |
| S335400 |  | Design/Safety Reviews Complete, Rack Room Modifications Components Released for Production | milestone | 0d | 2021-08-24 | 2021-08-24 | S335300 FF |  |  |  | 108d | 0d |  |  | S335400 | 0 | S286100 | S286100 |  | NOCA | Not Started | C | Pisani, Rob |  | BNL | Management Safety Reviews | Joel Vasquez | BNL |  | POM02.2.04.01.07 |  |  |  |  |  | 07 | L4 |  |  |  |  |  |  |  |  |  |
| S1003319 |  | Prepare Rack Room Modifications Components Procurement Package(s) - Physics Resource(s) |  | 30d | 2021-08-25 | 2021-10-06 | S335400 |  |  |  | 108d | 0d | TECH3 PO M [24 h]; PROF4 PO E [24 h]; TECH3 PO E [24 h] | 9,319.72 | S335500 | 0 | S286200 | S286200 | S1003319 | CA | Not Started | C | Pisani, Rob | L4 | BNL | Procurement | Joel Vasquez | BNL | null | POM02.2.04.01.07 | C | 2.04 | 16723 |  | 2.04 | 07 |  |  |  |  |  |  |  |  |  |  |
| S335500 |  | Prepare Rack Room Modifications Components Procurement Package(s) - CA-D Resource(s) |  | 30d | 2021-08-25 | 2021-10-06 | S335400 |  |  |  | 108d | 0d | PROF4 AD [2 h] | 304.58 | S335500 | 0 | S286200 | S286200 | S335500 | CA | Not Started | C | Pisani, Rob | L4 | BNL | Procurement | Joel Vasquez | BNL | null | POM02.2.04.01.07 | C | 2.04 | 16723 |  | 2.04 | 07 |  |  |  |  |  |  |  |  |  |  |
| S335600 |  | Evaluate & Process Rack Room Modifications Components Bids |  | 20d | 2021-10-07 | 2021-11-04 | S335500, S1003319 |  |  |  | 108d | 0d | TECH3 PO D [8 h]; TECH3 PO M [16 h]; PROF4 PO E [16 h]; TECH3 PO E [16 h] | 7,342.62 | S335600 | 0 | S286300 | S286300 | S335600 | CA | Not Started | C | Pisani, Rob | L4 | BNL | Procurement | Joel Vasquez | BNL | null | POM02.2.04.01.07 | C | 2.04 | 16723 |  | 2.04 | 07 |  |  |  |  |  |  |  |  |  |  |
| S335700 |  | Procure & Deliver Rack Room Modifications Components (leadtime and fabrication included) - Labor |  | 60d | 2021-11-05 | 2022-02-04 | S335600 |  |  |  | 108d | 0d | TECH3 PO D [24 h]; TECH3 PO M [48 h]; PROF4 PO E [48 h]; TECH3 PO E [48 h] | 22,027.87 | S335700 | 0 | S286400 | S286400 | S335700 | CA | Not Started | C | Pisani, Rob | L4 | BNL | Fab & Assy | Joel Vasquez | BNL | null | POM02.2.04.01.07 | C | 2.04 | 16723 |  | 2.04 | 07 |  |  |  |  |  |  |  |  |  |  |
| S335800 |  | Procure & Deliver Rack Room Modifications Components (leadtime and fabrication included) - M&S |  | 60d | 2021-11-05 | 2022-02-04 | S335700 SS |  |  |  | 108d | 40d | Material (Purchase (1st $2M) [20000 h] | 23,677.96 | S335800 | 0 | S285600 | S286450 | S335800 | CA | Not Started | C | Pisani, Rob | M5 | BNL | Fab & Assy | Joel Vasquez | BNL | null | POM02.2.04.01.07 | C | 2.04 | 16723 |  | 2.04 | 07 |  | UDF_G3 | UDF_G3 | 23677.9598 | 1 | TBD | Combined |  |  |  |
| S335900 |  | Perform Rack Room Modifications Components Acceptance |  | 10d | 2022-04-05 | 2022-04-18 | S335700, S343700, S335800 |  |  |  | 68d | 0d | SCI3 PO [8 h]; TECH3 PO D [4 h]; TECH3 PO M [8 h]; PROF4 PO E [8 h]; TECH3 PO E [8 h] | 5,132.01 | S335900 | 0 | S286500 | S286500 | S335900 | CA | Not Started | C | Pisani, Rob | L4 | BNL | Test_System | Joel Vasquez | BNL | null | POM02.2.04.01.07 | C | 2.04 | 16723 |  | 2.04 | 07 |  |  |  |  |  |  |  |  |  |  |
| S336000 |  | Rack Room Modifications Components Ready for Installation | milestone | 0d | 2022-04-18 | 2022-04-18 | S335900 FF |  |  |  | 68d | 60d |  |  | S336000 | 0 | S286600 | S286600 |  | NOCA | Not Started |  | Pisani, Rob |  | BNL | Fab & Assy | Joel Vasquez | BNL |  | POM02.2.04.01.07 |  |  |  | 003 |  | 07 | L3 |  |  |  |  |  |  | 190318 ELM logic per GRY |  |  |
|  | 08 | **Control Room and Offices Modifications** |  |  | 2021-08-25 | 2022-02-07 |  |  |  |  |  |  |  |  |  |  |  |  |  |  |  |  |  |  |  |  |  |  |  |  |  |  |  |  |  |  |  |  |  |  |  |  |  |  |  |  |
| S1003359 |  | Analyze Control Room and Offices Modifications Requirements - Physics Resource(s) |  | 10d | 2021-08-25 | 2021-09-08 | S335400 |  |  |  | 117d | 0d | SCI3 PO [8 h]; TECH3 PO E [8 h]; TECH3 PO M [8 h]; TECH3 PO D [8 h]; PROF4 PO E [8 h] | 5,452.71 | S336100 | 0 | S286800 | S286800 | S1003359 | CA | Not Started | C | Pisani, Rob | L4 | BNL | Design | Joel Vasquez | BNL | null | POM02.2.04.01.08 | C | 2.04 | 16723 |  | 2.04 | 08 |  |  |  |  |  |  |  |  |  |  |
| S336100 |  | Analyze Control Room and Offices Modifications Requirements - CA-D Resource(s) |  | 10d | 2021-08-25 | 2021-09-08 | S335400 |  |  |  | 117d | 0d | PROF4 AD [4 h] | 606.73 | S336100 | 0 | S286800 | S286800 | S336100 | CA | Not Started | C | Pisani, Rob | L4 | BNL | Design | Joel Vasquez | BNL | null | POM02.2.04.01.08 | C | 2.04 | 16723 |  | 2.04 | 08 |  |  |  |  |  |  |  |  |  |  |
| S1003439 |  | Create Control Room and Offices Modifications Schematic Design and Specification Control Documents P |  | 5d | 2021-09-09 | 2021-09-15 | S336100, S1003359 |  |  |  | 117d | 0d | TECH3 PO D [8 h]; PROF4 PO E [4 h] | 1,547.1 | S336200 | 0 | S286900 | S286900 | S1003439 | CA | Not Started | C | Pisani, Rob | L4 | BNL | Design | Joel Vasquez | BNL | null | POM02.2.04.01.08 | C | 2.04 | 16723 |  | 2.04 | 08 |  |  |  |  |  |  |  |  |  |  |
| S336200 |  | Create Control Room and Offices Modifications Schematic Design and Specification Control Documents C |  | 5d | 2021-09-09 | 2021-09-15 | S336100, S1003359 |  |  |  | 117d | 0d | PROF4 AD [2 h] | 303.37 | S336200 | 0 | S286900 | S286900 | S336200 | CA | Not Started | C | Pisani, Rob | L4 | BNL | Design | Joel Vasquez | BNL | null | POM02.2.04.01.08 | C | 2.04 | 16723 |  | 2.04 | 08 |  |  |  |  |  |  |  |  |  |  |
| S336300 |  | Review Control Room and Offices Modifications Design/Safety |  | 5d | 2021-09-16 | 2021-09-22 | S336200, S1003439 |  |  |  | 117d | 0d | SCI3 PO [4 h]; PROF4 PO E [4 h] | 1,315.81 | S336300 | 0 | S287000 | S287000 | S336300 | CA | Not Started | C | Pisani, Rob | L4 | BNL | Management Safety Reviews | Joel Vasquez | BNL | null | POM02.2.04.01.08 | C | 2.04 | 16723 |  | 2.04 | 08 |  |  |  |  |  |  |  |  |  |  |
| S336400 |  | Address Action Items from Control Room and Offices Modifications Design & Safety Reviews |  | 10d | 2021-09-23 | 2021-10-06 | S336300 |  |  |  | 117d | 0d | SCI3 PO [8 h]; TECH3 PO D [8 h]; TECH3 PO M [8 h]; PROF4 PO E [8 h]; TECH3 PO E [8 h] | 5,518.15 | S336400 | 0 | S287100 | S287100 | S336400 | CA | Not Started | C | Pisani, Rob | L4 | BNL | Design | Joel Vasquez | BNL | null | POM02.2.04.01.08 | C | 2.04 | 16723 |  | 2.04 | 08 |  |  |  |  |  |  |  |  |  |  |
| S336500 |  | Design/Safety Reviews Complete, Control Room and Offices Modifications Components Released for Production | milestone | 0d | 2021-10-06 | 2021-10-06 | S336400 FF |  |  |  | 117d | 0d |  |  | S336500 | 0 | S287200 | S287200 |  | NOCA | Not Started |  | Pisani, Rob |  | BNL | Management Safety Reviews | Joel Vasquez | BNL |  | POM02.2.04.01.08 |  |  |  |  |  | 08 | L4 |  |  |  |  |  |  |  |  |  |
| S1003519 |  | Prepare Control Room and Offices Modifications Components Procurement Package(s) - Physics Resource(s) |  | 30d | 2021-10-07 | 2021-11-19 | S336500 |  |  |  | 117d | 0d | TECH3 PO M [24 h]; PROF4 PO E [24 h]; TECH3 PO E [24 h] | 9,561.07 | S336600 | 0 | S287300 | S287300 | S1003519 | CA | Not Started | C | Pisani, Rob | L4 | BNL | Design | Joel Vasquez | BNL | null | POM02.2.04.01.08 | C | 2.04 | 16723 |  | 2.04 | 08 |  |  |  |  |  |  |  |  |  |  |
| S336600 |  | Prepare Control Room and Offices Modifications Components Procurement Package(s) - CA-D Resource(s) |  | 30d | 2021-10-07 | 2021-11-19 | S336500 |  |  |  | 117d | 0d | PROF4 AD [2 h] | 312.47 | S336600 | 0 | S287300 | S287300 | S336600 | CA | Not Started | C | Pisani, Rob | L4 | BNL | Design | Joel Vasquez | BNL | null | POM02.2.04.01.08 | C | 2.04 | 16723 |  | 2.04 | 08 |  |  |  |  |  |  |  |  |  |  |
| S336700 |  | Evaluate & Process Control Room and Offices Modifications Components Bids |  | 10d | 2021-11-22 | 2021-12-07 | S336600, S1003519 |  |  |  | 117d | 0d | TECH3 PO D [8 h]; TECH3 PO M [8 h]; PROF4 PO E [8 h]; TECH3 PO E [8 h] | 4,155.6 | S336700 | 0 | S287400 | S287400 | S336700 | CA | Not Started | C | Pisani, Rob | L4 | BNL | Procurement | Joel Vasquez | BNL | null | POM02.2.04.01.08 | C | 2.04 | 16723 |  | 2.04 | 08 |  |  |  |  |  |  |  |  |  |  |
| OBLG329500 |  | Procure & Deliver Control Room and Offices Modifications Components (leadtime and fabrication included) - M&S |  | 1d | 2021-12-08 | 2021-12-08 | S336700 |  |  |  | 117d | 0d | Obligation Resource [59195 h] | 59,195 | S336900 | 0 | S286700 | S287550 | S336900 |  | Not Started | C | Pisani, Rob | M5 | BNL | Fab & Assy | Joel Vasquez | BNL | null | POM02.2.04.01.08 | K | 2.04 | 16723 | 008C |  | 08 |  |  |  |  |  | TBD |  |  | MP6LAEXCLUDE | OBLG |
| S336800 |  | Procure & Deliver Control Room and Offices Modifications Components (leadtime and fabrication included) - Labor |  | 30d | 2021-12-08 | 2022-01-21 | S336700 |  |  |  | 118d | 1d | TECH3 PO D [48 h]; TECH3 PO M [24 h]; PROF4 PO E [24 h]; TECH3 PO E [24 h] | 15,372.53 | S336800 | 0 | S287500 | S287500 | S336800 | CA | Not Started | C | Pisani, Rob | L4 | BNL | Fab & Assy | Joel Vasquez | BNL | null | POM02.2.04.01.08 | C | 2.04 | 16723 |  | 2.04 | 08 |  |  |  |  |  |  |  |  |  |  |
| S336900 |  | Procure & Deliver Control Room and Offices Modifications Components (leadtime and fabrication included) - M&S |  | 30d | 2021-12-09 | 2022-01-24 | S336700, OBLG329500 |  |  |  | 117d | 0d | Material (Purchase (1st $2M) [50000 h] | 59,194.9 | S336900 | 0 | S286700 | S287550 | S336900 | CA | Not Started | C | Pisani, Rob | M5 | BNL | Fab & Assy | Joel Vasquez | BNL | null | POM02.2.04.01.08 | C | 2.04 | 16723 |  | 2.04 | 08 |  | UDF_G3 | UDF_G3 | 59194.8995 | 1 | TBD | Combined |  | MP6LAEXCLUDE |  |
| S1003599 |  | Perform Control Room and Offices Modifications Components Acceptance - Physics Resource(s) |  | 10d | 2022-01-25 | 2022-02-07 | S336800, S336900 |  |  |  | 117d | 0d | SCI3 PO [8 h]; TECH3 PO D [4 h]; TECH3 PO M [8 h]; PROF4 PO E [8 h]; TECH3 PO E [8 h] | 5,132.01 | S337000 | 0 | S287600 | S287600 | S1003599 | CA | Not Started | C | Pisani, Rob | L4 | BNL | Test_System | Joel Vasquez | BNL | null | POM02.2.04.01.08 | C | 2.04 | 16723 |  | 2.04 | 08 |  |  |  |  |  |  |  |  |  |  |
| S337000 |  | Perform Control Room and Offices Modifications Components Acceptance - CA-D Resource(s) |  | 10d | 2022-01-25 | 2022-02-07 | S336800, S336900 |  |  |  | 117d | 0d | PROF4 AD [2 h] | 312.47 | S337000 | 0 | S287600 | S287600 | S337000 | CA | Not Started | C | Pisani, Rob | L4 | BNL | Test_System | Joel Vasquez | BNL | null | POM02.2.04.01.08 | C | 2.04 | 16723 |  | 2.04 | 08 |  |  |  |  |  |  |  |  |  |  |
| S337100 |  | Control Room and Offices Modifications Components Ready for Installation | milestone | 0d | 2022-02-07 | 2022-02-07 | S337000 FF, S1003599 FF |  |  |  | 117d | 109d |  |  | S337100 | 0 | S287700 | S287700 |  | NOCA | Not Started |  | Pisani, Rob |  | BNL | Test_System | Joel Vasquez | BNL |  | POM02.2.04.01.08 |  |  |  | 003 |  | 08 | L3 |  |  |  |  |  |  | 190318 ELM logic per GRY |  |  |

Notes:
- S1003279: BNL_UDF_Old Activity Name 181221: Analyze Rack Room Modifications Requirements
- S335000: BNL_UDF_Old Activity Name 181221: Analyze Rack Room Modifications Requirements
- S335100: BNL_UDF_Old Activity Name 181221: Create Rack Room Modifications Schematic Design and Specification Control Documents
- S335200: BNL_UDF_Old Activity Name 181221: Review Rack Room Modifications Components Design/Safety
- S335300: BNL_UDF_Old Activity Name 181221: Address Action Items from Rack Room Modifications Design & Safety Reviews
- S335400: BNL_UDF_Old Activity Name 181221: Design/Safety Reviews Complete, Rack Room Modifications Components Released for Production
- S1003319: BNL_UDF_Old Activity Name 181221: Prepare Rack Room Modifications Components Procurement Package(s)
- S335500: BNL_UDF_Old Activity Name 181221: Prepare Rack Room Modifications Components Procurement Package(s)
- S335600: BNL_UDF_Old Activity Name 181221: Evaluate & Process Rack Room Modifications Components Bids
- S335700: BNL_UDF_Old Activity Name 181221: Procure & Deliver Rack Room Modifications Components (leadtime and fabrication included) - Labor
- S335800: BNL_UDF_Old Activity Name 181221: Procure & Deliver Rack Room Modifications Components (leadtime and fabrication included) - M&S
- S335900: BNL_UDF_Old Activity Name 181221: Perform Rack Room Modifications Components Acceptance
- S336000: BNL_UDF_Old Activity Name 181221: Rack Room Modifications Components Ready for Installation
- S1003359: BNL_UDF_Old Activity Name 181221: Analyze Control Room and Offices Modifications Requirements
- S336100: BNL_UDF_Old Activity Name 181221: Analyze Control Room and Offices Modifications Requirements
- S1003439: BNL_UDF_Old Activity Name 181221: Create Control Room and Offices Modifications Schematic Design and Specification Control Documents
- S336200: BNL_UDF_Old Activity Name 181221: Create Control Room and Offices Modifications Schematic Design and Specification Control Documents
- S336300: BNL_UDF_Old Activity Name 181221: Review Control Room and Offices Modifications Design/Safety
- S336400: BNL_UDF_Old Activity Name 181221: Address Action Items from Control Room and Offices Modifications Design & Safety Reviews
- S336500: BNL_UDF_Old Activity Name 181221: Design/Safety Reviews Complete, Control Room and Offices Modifications Components Released for Production
- S1003519: BNL_UDF_Old Activity Name 181221: Prepare Control Room and Offices Modifications Components Procurement Package(s)
- S336600: BNL_UDF_Old Activity Name 181221: Prepare Control Room and Offices Modifications Components Procurement Package(s)
- S336700: BNL_UDF_Old Activity Name 181221: Evaluate & Process Control Room and Offices Modifications Components Bids
- OBLG329500: BNL_UDF_Old Activity Name 181221: Procure & Deliver Control Room and Offices Modifications Components (leadtime and fabrication included) - M&S
- S336800: BNL_UDF_Old Activity Name 181221: Procure & Deliver Control Room and Offices Modifications Components (leadtime and fabrication included) - Labor
- S336900: BNL_UDF_Old Activity Name 181221: Procure & Deliver Control Room and Offices Modifications Components (leadtime and fabrication included) - M&S
- S1003599: BNL_UDF_Old Activity Name 181221: Perform Control Room and Offices Modifications Components Acceptance
- S337000: BNL_UDF_Old Activity Name 181221: Perform Control Room and Offices Modifications Components Acceptance
- S337100: BNL_UDF_Old Activity Name 181221: Control Room and Offices Modifications Components Ready for Installation

| ID | WBS | Activity | Type | Duration | Start | Finish | Predecessors | Complete | Planned start | Planned finish | Total float | Free float | Constraint | Resources | Cost | BNL_UDF_Exclude | BNL_UDF_Temp Text 01 | BNL_UDF_Percent Complete | BNL_UDF_Old Activity ID 181221 | BNL_Cobra WP | RG Check | BNL_Activity Status | BNL_Fund Source | BNL_Estimator | BNL_Cost Basis | BNL_Location | BNL_EDIA | BNL_CAM | BNL_OPC TEC (deprecated) | BNL_WBS | BNL_Actuals | BNL_FY | BNL_EVT | BNL_Master Control Account | BNL_Account Number | BNL_PCR ID | BNL_Cobra Control Account | BNL_WBS_Hierarchical | Completed | Indicator - Procurement | BNL_UDF_Sort Order | BNL_UDF_OPC TEC (deprecated) | BNL_Institution | Temp | BNL_UDF_Temp Text 02 | Indicator - Float | BNL_UDF_Remaining Tot Cost | BNL_UDF_Percent_remaining | BNL_Proc Sig | SPH Proc Register | Additional EVT documentation required | BNL_Milestone Level | Target Milestone Date | Variance | PMP Milestones | BNL_Obligation | BNL_Management or Mgmt Travel | Cost = Awarded Proc or Mgmt |
| --- | --- | --- | --- | --- | --- | --- | --- | --- | --- | --- | --- | --- | --- | --- | --- | --- | --- | --- | --- | --- | --- | --- | --- | --- | --- | --- | --- | --- | --- | --- | --- | --- | --- | --- | --- | --- | --- | --- | --- | --- | --- | --- | --- | --- | --- | --- | --- | --- | --- | --- | --- | --- | --- | --- | --- | --- | --- | --- |
|  | 02 | **Infrastructure Facility Support Systems** |  |  | 2017-02-01 | 2022-10-04 |  |  |  |  |  |  |  |  |  |  |  |  |  |  |  |  |  |  |  |  |  |  |  |  |  |  |  |  |  |  |  |  |  |  |  |  |  |  |  |  |  |  |  |  |  |  |  |  |  |  |  |  |
| S1000519 |  | Actuals - Labor - sPHENIX Infrastructure FY17 16724 |  | 169d | 2017-02-01 A | 2017-09-29 A | S100090 SS | 100% |  |  |  |  |  | Actual Labor [36 h] | 6,015.34 | MP6LAEXCLUDE | S309200 | 100 | S338500 | S1000519 | CA | Completed | C | Pisani, Rob | L1 | BNL | Design | Joel Vasquez | null | POM02.2.04.02 | Yes | 2017 | A | 2.04 | 16724 | 003 | 2.04 | 02 | yes |  |  |  |  |  |  |  |  |  |  |  |  |  |  |  |  |  |  |  |
| S1000679 |  | Actuals - Labor - sPHENIX Infrastructure FY18 16724 |  | 249d | 2017-10-01 A | 2018-09-28 A | S309200, S1000439, S1000479, S1000519, S1000559 | 100% | 2017-10-02 | 2018-09-28 |  |  |  | Actual Labor [36 h] | 6,015.34 | MP6LAEXCLUDE | S309300 | 100 | S339380 | S1000679 | CA | Completed | C | Pisani, Rob | L1 | BNL | Design | Joel Vasquez | null | POM02.2.04.02 | Yes | 2018 | A | 2.04 | 16724 | 003 | 2.04 | 02 | yes |  |  |  |  |  |  |  |  |  |  |  |  |  |  |  |  |  |  |  |
| S1001679 |  | Actuals - Labor - sPHENIX Infrastructure FY19 M8 16724 |  | 166d | 2018-10-01 A | 2019-05-31 A |  | 100% |  |  |  |  |  | Actual Labor [36 h] | 6,015.34 | MP6LAEXCLUDE | S309300 | 100 | S339380 | S1001679 | CA | Completed | C | Pisani, Rob | L1 | BNL | Design | Joel Vasquez | null | POM02.2.04.02 | Yes | 2019 | A | 2.04 | 16724 | 003 | 2.04 | 02 | yes |  |  |  |  |  |  |  |  |  |  |  |  |  |  |  |  |  |  |  |
| S1005000 |  | Actuals - Labor FY19 Jun-Sep 16724 |  | 84d | 2019-06-03 A | 2019-09-30 A |  | 100% |  |  |  |  |  | Actual Labor [36 h] | 6,015.34 | MP6LAEXCLUDE | S309300 | 100 | S339380 | S1005000 | CA | Completed | C | Pisani, Rob | L1 | BNL | Design | Joel Vasquez | null | POM02.2.04.02 | Yes | 2019 | A | 2.04 | 16724 | 003 | 2.04 | 02 | yes |  |  |  |  |  |  |  |  |  |  |  |  |  |  |  |  |  |  |  |
| S1005040 |  | Actuals - NonLabor FY19 Jun-Sep 16724 |  | 84d | 2019-06-03 A | 2019-09-30 A |  | 100% |  |  |  |  |  | Actual Nonlabor [61592.6 h] | 67,952.97 | MP6LAEXCLUDE | S309300 | 100 | S339380 | S1005040 | CA | Completed | C | Pisani, Rob | L1 | BNL | Design | Joel Vasquez | null | POM02.2.04.02 | Yes | 2019 | A | 2.04 | 16724 | 003 | 2.04 | 02 | yes | UDF_G2 |  |  |  |  |  |  |  |  |  |  |  |  |  |  |  |  |  |  |
|  | 01 | **Magnet Cryo, Electrical & Control Structural Support in IR** |  |  | 2019-10-01 | 2022-10-04 |  |  |  |  |  |  |  |  |  |  |  |  |  |  |  |  |  |  |  |  |  |  |  |  |  |  |  |  |  |  |  |  |  |  |  |  |  |  |  |  |  |  |  |  |  |  |  |  |  |  |  |  |
| S337300 |  | Create Cryo Routing in IR Layout Drawings - Physics Resource(s) |  | 20d | 2019-10-01 A | 2020-08-31 A | S101000 | 100% | 2019-10-01 | 2019-10-29 |  |  |  | PROF4 PO M [24 h] | 3,534.36 |  | PO&AD | 0 | S287900 | S337300 | CA | In Progress | C | Pisani, Rob | L4 | BNL | Design | Joel Vasquez | null | POM02.2.04.02.01 |  |  | C | 2.04 | 16724 | 003 | 2.04 | 01 |  |  | 1000 | S287900 | BNL | PO |  |  |  |  |  |  |  |  |  |  |  |  |  |  |
| S337310 |  | Create Cryo Routing in IR Layout Drawings - CA-D Resource(s) |  | 20d | 2019-10-01 A | 2020-08-31 A | S337300 SS | 100% | 2019-10-01 | 2019-10-29 |  |  |  | TECH4 AD [16 h]; PROF2 AD [80 h]; TECH4 AD [24 h] | 13,241.33 |  | PO&ADS337310 | 0 | S287900 | S337310 | CA | In Progress | C | Pisani, Rob | L4 | BNL | Design | Joel Vasquez | null | POM02.2.04.02.01 |  |  | C | 2.04 | 16724 | 003 | 2.04 | 01 |  |  | 1000 | S287900 | BNL | C-AD | S337310 |  |  |  |  |  |  |  |  |  |  |  |  |  |
| S337400 |  | Create Cryo Structural Support in IR Detail & Assembly Drawings |  | 30d | 2019-10-30 A | 2020-08-31 A | S337300, S337310 | 100% | 2019-10-30 | 2019-12-13 |  |  |  | TECH3 AD [7.2 h]; TECH4 AD [7.2 h]; PROF2 AD [14.4 h] | 4,026.8 |  | S337400 | 0 | S288000 | S337400 | CA | In Progress | C | Pisani, Rob | L4 | BNL | Design | Joel Vasquez | null | POM02.2.04.02.01 |  |  | C | 2.04 | 16724 | 003 | 2.04 | 01 |  |  | 1000 | S288000 | BNL |  |  |  |  |  |  |  |  |  |  |  |  |  |  |  |
| S337500 |  | Review Magnet Cryo, Electrical & Control Structural Support in IR Design/Safety |  | 5d | 2020-06-17 A | 2020-10-30 A | S337400 | 100% | 2020-08-17 | 2020-08-21 |  |  |  | TECH4 AD [12 h]; PROF2 AD [24 h] | 3,972.4 |  | S337500 | 0 | S288100 | S337500 | CA | Not Started | C | Pisani, Rob | L4 | BNL | Design | Joel Vasquez | null | POM02.2.04.02.01 |  |  | C | 2.04 | 16724 | 003 | 2.04 | 01 |  |  | 1000 | S288100 | BNL |  |  |  |  |  |  |  |  |  |  |  |  |  |  |  |
| S337600 |  | Address Action Items from Cryo Structural Support in IR Detail Design & Safety Reviews |  | 5d | 2020-10-06 A | 2020-10-13 A | S337500 | 100% | 2020-11-02 | 2020-11-06 |  |  |  | TECH4 AD [7.2 h]; PROF2 AD [28.8 h] | 3,941.4 |  | S337600 | 0 | S288200 | S337600 | CA | Not Started | C | Pisani, Rob | L4 | BNL | Design | Joel Vasquez | null | POM02.2.04.02.01 |  |  | C | 2.04 | 16724 | 003 | 2.04 | 01 |  |  | 1000 | S288200 | BNL |  |  |  |  |  |  |  |  |  |  |  |  |  |  |  |
| S337200 |  | Procure & Deliver Magnet Cryo, Electrical & Control Structural Support in IR Components (leadtime and fab incl) - M&S |  | 80d | 2020-10-14 A | 2021-01-26 A | S338000 SS, OBLG356580 | 100% | 2021-02-10 | 2021-06-03 |  |  |  | Material (Purchase (1st $2M) [50000 h] | 58,034.22 | MP6LAEXCLUDE | S337200 | 0 | S287800 | S337200 | CA | Not Started | C | Pisani, Rob | M4 | BNL | Fab & Assy | Joel Vasquez | null | POM02.2.04.02.01 |  |  | C | 2.04 | 16724 | 003 | 2.04 | 01 |  | UDF_G1 | 2000 | S287800 | BNL |  |  | UDF_G3 | 57963.095125 | 1 | TBD | Combined | Yes |  |  |  |  |  |  |  |
| S337900 |  | Evaluate & Process Magnet Cryo, Electrical & Control Structural Support in IR Components Bids |  | 30d | 2020-10-14 A | 2021-01-29 A | S337800 | 100% | 2020-12-24 | 2021-02-08 |  |  |  | TECH4 AD [24 h]; PROF2 AD [48 h] | 8,183.14 |  | S337900 | 0 | S288500 | S337900 | CA | Not Started | C | Pisani, Rob | L4 | BNL | Procurement | Joel Vasquez | null | POM02.2.04.02.01 |  |  | C | 2.04 | 16724 | 003 | 2.04 | 01 |  |  | 1000 | S288500 | BNL |  |  |  |  |  |  |  |  |  |  |  |  |  |  |  |
| S338000 |  | Procure & Deliver Magnet Cryo, Electrical & Control Structural Support in IR Components (leadtime and fab incl) - Labor |  | 80d | 2020-10-14 A | 2021-01-29 A | S337900 | 100% | 2021-02-09 | 2021-06-02 |  |  |  | TECH4 AD [64 h]; PROF2 AD [128 h] | 21,821.71 |  | S338000 | 0 | S288600 | S338000 | CA | Not Started | C | Pisani, Rob | L4 | BNL | Fab & Assy | Joel Vasquez | null | POM02.2.04.02.01 |  |  | C | 2.04 | 16724 | 003 | 2.04 | 01 |  |  | 2000 | S288600 | BNL |  |  |  |  |  |  |  | Yes |  |  |  |  |  |  |  |
| S337800 |  | Prepare Magnet Cryo, Electrical & Control Structural Support in IR Components Procurement Package(s) |  | 30d | 2020-10-15 A | 2021-01-29 A | S337700 | 100% | 2020-11-09 | 2020-12-23 |  |  |  | TECH4 AD [24 h]; PROF2 AD [88 h]; TECH4 AD [20 h] | 15,002.43 |  | S337800 | 0 | S288400 | S337800 | CA | Not Started | C | Pisani, Rob | L4 | BNL | Procurement | Joel Vasquez | null | POM02.2.04.02.01 |  |  | C | 2.04 | 16724 | 003 | 2.04 | 01 |  |  | 1000 | S288400 | BNL |  |  |  |  |  |  |  |  |  |  |  |  |  |  |  |
| S337700 |  | Design/Safety Reviews Complete, Magnet Cryo, Electrical & Control Structural Support in IR Components Released for Produ | milestone | 0d | 2020-10-30 A | 2020-10-30 A | S337600 FF | 100% | 2020-11-06 | 2020-11-06 |  |  |  |  |  |  | S337700 | 0 | S288300 |  | NOCA | Not Started |  | Pisani, Rob |  | BNL | Management Safety Reviews | Joel Vasquez |  | POM02.2.04.02.01 |  |  |  |  |  | 003 |  | 01 |  |  | 1000 | S288300 | BNL |  |  |  |  |  |  |  |  | L4 |  |  |  |  |  |  |
| S338100 |  | Perform Magnet Cryo, Electrical & Control Structural Support in IR Components Acceptance |  | 10d | 2021-01-19 A | 2021-01-29 A | S338000, S337200 | 100% | 2021-06-04 | 2021-06-17 |  |  |  | TECH3 AD [8 h]; PROF2 AD [16 h] | 2,591.98 |  | S338100 | 0 | S288700 | S338100 | CA | Not Started | C | Pisani, Rob | L4 | BNL | Test_System | Joel Vasquez | null | POM02.2.04.02.01 |  |  | C | 2.04 | 16724 | 003 | 2.04 | 01 |  |  | 3000 | S288700 | BNL |  |  |  |  |  |  |  |  |  |  |  |  |  |  |  |
| S338200 |  | Magnet cryo, electrical and control structural support components Ready for Installation | milestone | 0d | 2021-01-29 A | 2021-01-29 A | S338100 FF | 100% | 2021-06-17 | 2021-06-17 |  |  |  |  |  |  | S338200 | 0 | S288800 |  | NOCA | Not Started |  | Pisani, Rob |  | BNL | Test_System | Joel Vasquez |  | POM02.2.04.02.01 |  |  |  |  |  | 003 |  | 01 |  |  | 3000 | S288800 | BNL |  |  |  |  |  |  |  |  | L3 | 2021-03-31 | 42 | PMP_2x |  |  |  |
| OBLG356580 |  | Procure & Deliver Magnet Cryo, Electrical & Control Structural Support in IR Components (leadtime and fab incl) - M&S |  | 1d | 2021-02-24 A | 2021-02-25 A | S338000 SS | 100% | 2021-03-01 | 2021-03-01 |  |  |  | Obligation Resource [56896 h] | 56,896 | MP6LAEXCLUDE | S337200 | 0 | S287800 | S337200 |  | Not Started | C | Pisani, Rob | M4 | BNL | Fab & Assy | Joel Vasquez | null | POM02.2.04.02.01 |  |  | C | 2.04 | 16724 | 008C |  | 01 |  |  | 2000 | S287800 | BNL |  |  |  |  |  | TBD |  |  |  |  |  |  | OBLG |  |  |
| S277700 |  | 2023 Detector Support Systems L3 Project Management |  | 2d | 2022-10-03 | 2022-10-04 | S277600 |  |  |  | 0d | 5d | start on 2022-10-01 | PROF5 PO M [113 h] | 20,999.07 |  | S277700 | 0 | S337155 | S277700 | CA | Not Started | C | Yip, Kin | L2 | BNL | Management | Irina Sourikova | null | POM02.2.01.03 |  |  | A | 2.01 | 16721 | 025 | 2.04 | 04 |  |  |  | S248100 | BNL |  |  |  |  |  |  |  |  |  |  |  |  |  | Yes | Yes |
|  | 02 | **Beampipe/Vacuum** |  |  | 2020-03-02 | 2022-06-30 |  |  |  |  |  |  |  |  |  |  |  |  |  |  |  |  |  |  |  |  |  |  |  |  |  |  |  |  |  |  |  |  |  |  |  |  |  |  |  |  |  |  |  |  |  |  |  |  |  |  |  |  |
| S338400 |  | Create Beampipe/Vacuum Layout - Physics Resource(s) |  | 20d | 2020-03-02 A | 2020-03-31 A | S101000, S101015 SS | 100% | 2020-10-01 | 2020-10-29 |  |  |  | PROF4 PO M [9 h]; TECH3 PO D [18 h]; SCI3 PO [9 h] | 5,076.39 |  | PO&AD | 0 | S289000 | S338400 | CA | Not Started | C | Pisani, Rob | L4 | BNL | Design | Joel Vasquez | null | POM02.2.04.02.02 |  |  | C | 2.04 | 16724 | 003,005 | 2.04 | 02 |  |  | 1000 | S289000 | BNL | PO |  |  |  |  |  |  |  |  |  |  |  |  |  |  |
| S338410 |  | Create Beampipe/Vacuum Layout - CA-D Resource(s) |  | 20d | 2020-03-02 A | 2020-03-31 A | S338400 SS | 100% | 2020-10-01 | 2020-10-29 |  |  |  | PROF4 AD [36 h] | 5,460.59 |  | PO&ADS338410 | 0 | S289000 | S338410 | CA | Not Started | C | Pisani, Rob | L4 | BNL | Design | Joel Vasquez | null | POM02.2.04.02.02 |  |  | C | 2.04 | 16724 | 003 | 2.04 | 02 |  |  | 1000 | S289000 | BNL | C-AD | S338410 |  |  |  |  |  |  |  |  |  |  |  |  |  |
| S338500 |  | Create Beampipe/Vacuum Envelope Drawing |  | 10d | 2020-03-02 A | 2020-03-31 A | S338400, S338410 | 100% | 2020-10-30 | 2020-11-13 |  |  |  | TECH3 PO D [36 h] | 4,231.65 |  | S338500 | 0 | S289100 | S338500 | CA | Not Started | C | Pisani, Rob | L4 | BNL | Design | Joel Vasquez | null | POM02.2.04.02.02 |  |  | C | 2.04 | 16724 | 003 | 2.04 | 02 |  |  | 1000 | S289100 | BNL |  |  |  |  |  |  |  |  |  |  |  |  |  |  |  |
| S338600 |  | Create Beampipe/Vacuum subassembly and detail Drawings |  | 20d | 2020-03-02 A | 2020-03-31 A | S338500 | 100% | 2020-11-16 | 2020-12-15 |  |  |  | TECH3 PO D [36 h] | 4,231.65 |  | S338600 | 0 | S289200 | S338600 | CA | Not Started | C | Pisani, Rob | L4 | BNL | Design | Joel Vasquez | null | POM02.2.04.02.02 |  |  | C | 2.04 | 16724 | 003 | 2.04 | 02 |  |  | 1000 | S289200 | BNL |  |  |  |  |  |  |  |  |  |  |  |  |  |  |  |
| S338700 |  | Review Beampipe/Vacuum Design/Safety - Physics Resource(s) |  | 5d | 2020-03-02 A | 2020-03-31 A | S338600 | 100% | 2020-12-16 | 2020-12-22 |  |  |  | SCI3 PO [18 h]; TECH3 PO D [18 h] | 5,306.66 |  | PO&AD | 0 | S289300 | S338700 | CA | Not Started | C | Pisani, Rob | L4 | BNL | Design | Joel Vasquez | null | POM02.2.04.02.02 |  |  | C | 2.04 | 16724 | 003 | 2.04 | 02 |  |  | 1000 | S289300 | BNL | PO |  |  |  |  |  |  |  |  |  |  |  |  |  |  |
| S338710 |  | Review Beampipe/Vacuum Design/Safety - CA-D Resource(s) |  | 5d | 2020-03-02 A | 2020-03-31 A | S338700 SS | 100% | 2020-12-16 | 2020-12-22 |  |  |  | PROF4 AD [30 h]; TECH4 AD [20 h] | 7,240.74 |  | PO&ADS338710 | 0 | S289300 | S338710 | CA | Not Started | C | Pisani, Rob | L4 | BNL | Design | Joel Vasquez | null | POM02.2.04.02.02 |  |  | C | 2.04 | 16724 | 003 | 2.04 | 02 |  |  | 1000 | S289300 | BNL | C-AD | S338710 |  |  |  |  |  |  |  |  |  |  |  |  |  |
| S338800 |  | Address Action Items from Beampipe/Vacuum Design & Safety Reviews - Physics Resource(s) |  | 10d | 2020-03-02 A | 2020-03-31 A | S338700, S338710 | 100% | 2020-12-23 | 2021-01-07 |  |  |  | TECH3 PO D [36 h] | 4,231.65 |  | PO&AD | 0 | S289400 | S338800 | CA | Not Started | C | Pisani, Rob | L4 | BNL | Design | Joel Vasquez | null | POM02.2.04.02.02 |  |  | C | 2.04 | 16724 | 003 | 2.04 | 02 |  |  | 1000 | S289400 | BNL | PO |  |  |  |  |  |  |  |  |  |  |  |  |  |  |
| S338810 |  | Address Action Items from Beampipe/Vacuum Design & Safety Reviews - CA-D Resource(s) |  | 10d | 2020-03-02 A | 2020-03-31 A | S338800 SS | 100% | 2020-12-23 | 2021-01-07 |  |  |  | PROF4 AD [36 h] | 5,460.59 |  | PO&ADS338810 | 0 | S289400 | S338810 | CA | Not Started | C | Pisani, Rob | L4 | BNL | Design | Joel Vasquez | null | POM02.2.04.02.02 |  |  | C | 2.04 | 16724 | 003 | 2.04 | 02 |  |  | 1000 | S289400 | BNL | C-AD | S338810 |  |  |  |  |  |  |  |  |  |  |  |  |  |
| S338900 |  | Design/Safety Reviews Complete, Beampipe/Vacuum components Released for Production | milestone | 0d | 2020-03-31 A | 2020-03-31 A | S338800 FF, S338810 FF | 100% | 2021-01-07 | 2021-01-07 |  |  |  |  |  |  | S338900 | 0 | S289500 |  | NOCA | Not Started |  | Pisani, Rob |  | BNL | Management Safety Reviews | Joel Vasquez |  | POM02.2.04.02.02 |  |  |  |  |  | 003 |  | 02 |  |  | 1000 | S289500 | BNL |  |  |  |  |  |  |  |  | L4 |  |  |  |  |  |  |
| S339000 |  | Prepare Beampipe/Vacuum Components Procurement Package(s) Preparation - Physics Resource(s) |  | 20d | 2020-07-01 A | 2020-07-15 A | S338900 | 100% | 2020-10-01 | 2020-10-29 |  |  |  | TECH3 PO D [36 h] | 4,231.65 |  | PO&AD | 0 | S289600 | S339000 | CA | Not Started | C | Pisani, Rob | L4 | BNL | Procurement | Joel Vasquez | null | POM02.2.04.02.02 |  |  | C | 2.04 | 16724 | 003 | 2.04 | 02 |  |  | 1000 | S289600 | BNL | PO |  |  |  |  |  |  |  |  |  |  |  |  |  |  |
| S339100 |  | Evaluate & Process Beampipe/Vacuum Components Bids - Physics Resource(s) |  | 20d | 2020-07-15 A | 2020-10-30 A | S339000, S339010 | 100% | 2020-10-30 | 2020-12-01 |  |  |  | TECH3 PO D [36 h] | 4,231.65 |  | PO&AD | 0 | S289700 | S339100 | CA | Not Started | C | Pisani, Rob | L4 | BNL | Procurement | Joel Vasquez | null | POM02.2.04.02.02 |  |  | C | 2.04 | 16724 | 003 | 2.04 | 02 |  |  | 1000 | S289700 | BNL | PO |  |  |  |  |  |  |  |  |  |  |  |  |  |  |
| S339010 |  | Prepare Beampipe/Vacuum Components Procurement Package(s) Preparation - CA-D Resource(s) |  | 20d | 2020-07-16 A | 2020-07-31 A | S339000 SS | 100% | 2020-10-01 | 2020-10-29 |  |  |  | PROF4 AD [36 h] | 5,460.59 |  | PO&ADS339010 | 0 | S289600 | S339010 | CA | Not Started | C | Pisani, Rob | L4 | BNL | Procurement | Joel Vasquez | null | POM02.2.04.02.02 |  |  | C | 2.04 | 16724 | 003 | 2.04 | 02 |  |  | 1000 | S289600 | BNL | C-AD | S339010 |  |  |  |  |  |  |  |  |  |  |  |  |  |
| S339110 |  | Evaluate & Process Beampipe/Vacuum Components Bids - CA-D Resource(s) |  | 20d | 2020-07-16 A | 2020-10-30 A | S339100 SS | 100% | 2020-10-30 | 2020-12-01 |  |  |  | PROF4 AD [36 h] | 5,460.59 |  | PO&ADS339110 | 0 | S289700 | S339110 | CA | Not Started | C | Pisani, Rob | L4 | BNL | Procurement | Joel Vasquez | null | POM02.2.04.02.02 |  |  | C | 2.04 | 16724 | 003 | 2.04 | 02 |  |  | 1000 | S289700 | BNL | C-AD | S339110 |  |  |  |  |  |  |  |  |  |  |  |  |  |
| S339200 |  | Procure & Deliver Beampipe/Vacuum Components (leadtime and fabrication included) - Physics Resource(s) |  | 120d | 2021-01-04 A | 2021-05-31 A | S339100, S339110 | 100% | 2021-01-04 | 2021-06-23 |  |  |  | TECH3 PO D [36 h] | 4,231.65 |  | PO&AD | 0 | S289800 | S339200 | CA | Not Started | C | Pisani, Rob | L4 | BNL | Procurement | Joel Vasquez | null | POM02.2.04.02.02 |  |  | C | 2.04 | 16724 | 003 | 2.04 | 02 |  |  | 2000 | S289800 | BNL | PO |  |  |  |  |  |  | Yes |  |  |  |  |  |  |  |
| S339210 |  | Procure & Deliver Beampipe/Vacuum Components (leadtime and fabrication included) - CA-D Resource(s) |  | 120d | 2021-01-04 A | 2021-05-31 A | S339200 SS | 100% | 2021-01-04 | 2021-06-23 |  |  |  | PROF4 AD [36 h] | 5,460.59 |  | PO&ADS339210 | 0 | S289800 | S339210 | CA | Not Started | C | Pisani, Rob | L4 | BNL | Procurement | Joel Vasquez | null | POM02.2.04.02.02 |  |  | C | 2.04 | 16724 | 003 | 2.04 | 02 |  |  | 2000 | S289800 | BNL | C-AD | S339210 |  |  |  |  |  | Yes |  |  |  |  |  |  |  |
| S338300 |  | Procure & Deliver Beampipe/Vacuum Components (leadtime and fabrication included) - M&S |  | 120d | 2021-01-05 A | 2021-05-31 A | S339100, S339110, OBLG356680 | 100% | 2021-01-05 | 2021-06-24 |  |  |  | Material (Purchase (1st $2M) [50000 h] | 58,034.22 | MP6LAEXCLUDE | S338300 | 0 | S288900 | S338300 | CA | Not Started | C | Pisani, Rob | M4 | BNL | Fab & Assy | Joel Vasquez | null | POM02.2.04.02.02 |  |  | C | 2.04 | 16724 | 003 | 2.04 | 02 |  | UDF_G1 | 2001 | S288900 | BNL |  |  | UDF_G3 | 58034.2155 | 1 | TBD | Combined | Yes |  |  |  |  |  |  |  |
| OBLG356680 |  | Procure & Deliver Beampipe/Vacuum Components (leadtime and fabrication included) - M&S |  | 1d | 2021-06-01 | 2021-06-01 | S339110 |  |  |  | 78d | 0d |  | Obligation Resource [58034 h] | 58,034 | MP6LAEXCLUDE | S338300 | 0 | S288900 | S338300 |  | Not Started | C | Pisani, Rob | M4 | BNL | Fab & Assy | Joel Vasquez | null | POM02.2.04.02.02 |  |  | K | 2.04 | 16724 | 008C |  | 02 |  |  | 2001 | S288900 | BNL |  |  |  |  |  | TBD |  |  |  |  |  |  | OBLG |  |  |
| S339350 |  | NEG Re-coating of beryllium beampipe |  | 272d | 2021-06-01 | 2022-06-30 |  |  |  |  | 20d |  | start on or after 2021-06-01 | Material (Purchase (1st $2M) [100000 h] | 111,561.35 |  | PO&ADS339310 | 0 | S289900 | S339350 | CA | Not Started | C | Pisani, Rob | L4 | BNL | Procurement | Joel Vasquez | null | POM02.2.04.02.02 |  |  | F | 2.04 | 16724 | 024 | 2.04 | 02 |  | UDF_G3 | 3000 | S289900 | BNL | C-AD | S339310 | UDF_G1 |  |  |  |  |  |  |  |  |  |  |  |  |
| S339300 |  | Perform Beampipe/vacuum Acceptance - Physics Resource(s) NEG coating |  | 213d | 2021-06-02 | 2022-04-08 | S339200, S338300, S339210 |  |  |  | 78d | 0d |  | TECH3 PO D [36 h] | 4,307.94 |  | PO&AD | 0 | S289900 | S339300 | CA | Not Started | C | Pisani, Rob | L4 | BNL | Procurement | Joel Vasquez | null | POM02.2.04.02.02 |  |  | C | 2.04 | 16724 | 024 | 2.04 | 02 |  |  | 3000 | S289900 | BNL | PO |  |  |  |  |  |  |  |  |  |  |  |  |  |  |
| S339310 |  | Perform Beampipe/vacuum Acceptance - CA-D Resource(s) NEG coating |  | 213d | 2021-06-02 | 2022-04-08 | S339300 SS |  |  |  | 78d | 0d |  | TECH3 AD [25.71 h]; PROF4 AD [10.29 h] | 4,665.39 |  | PO&ADS339310 | 0 | S289900 | S339310 | CA | Not Started | C | Pisani, Rob | L4 | BNL | Procurement | Joel Vasquez | null | POM02.2.04.02.02 |  |  | C | 2.04 | 16724 | 024 | 2.04 | 02 |  |  | 3000 | S289900 | BNL | C-AD | S339310 |  |  |  |  |  |  |  |  |  |  |  |  |  |
| S339400 |  | Beampipe/Vacuum components Ready for Installation | milestone | 0d | 2022-04-08 | 2022-04-08 | S339300 FF, S339310 FF |  |  |  | 78d |  |  |  |  |  | S339400 | 0 | S290000 |  | NOCA | Not Started |  | Pisani, Rob |  | BNL | Test_System | Joel Vasquez |  | POM02.2.04.02.02 |  |  |  |  |  | 003 |  | 02 |  |  | 3000 | S290000 | BNL |  |  |  |  |  |  |  |  | L3 |  |  |  |  |  |  |

Notes:
- S1000519: BNL_UDF_Status Comments: 190315 DurType to align with EVT / BNL_UDF_Old Activity Name 181221: Actuals - Labor - sPHENIX Infrastructure FY17
- S1000679: BNL_UDF_Status Comments: 190315 DurType to align with EVT / BNL_UDF_Old Activity Name 181221: Actuals - Labor - sPHENIX Infrastructure FY18
- S1001679: BNL_UDF_Status Comments: 190315 DurType to align with EVT / BNL_UDF_Old Activity Name 181221: Actuals - Labor - sPHENIX Infrastructure FY18
- S1005000: BNL_UDF_Status Comments: 190315 DurType to align with EVT / BNL_UDF_Old Activity Name 181221: Actuals - Labor - sPHENIX Infrastructure FY18
- S1005040: BNL_UDF_Status Comments: 190315 DurType to align with EVT / BNL_UDF_Old Activity Name 181221: Actuals - Labor - sPHENIX Infrastructure FY18
- S337300: BNL_UDF_Status Comments: 190318 ELM sort order per GRY / BNL_UDF_Old Activity Name 181221: Create Cryo Routing in IR Layout Drawings
- S337310: BNL_UDF_Status Comments: 190318 ELM sort order per GRY / BNL_UDF_Old Activity Name 181221: Create Cryo Routing in IR Layout Drawings
- S337400: BNL_UDF_Status Comments: 190318 ELM sort order per GRY / BNL_UDF_Old Activity Name 181221: Create Cryo Structural Support in IR Detail & Assembly Drawings
- S337500: BNL_UDF_Status Comments: 190318 ELM sort order per GRY / BNL_UDF_Old Activity Name 181221: Review Magnet Cryo, Electrical & Control Structural Support in IR Design/Safety
- S337600: BNL_UDF_Status Comments: 190318 ELM sort order per GRY / BNL_UDF_Old Activity Name 181221: Address Action Items from Cryo Structural Support in IR Detail Design & Safety Reviews
- S337200: BNL_UDF_Status Comments: 190318 ELM sort order per GRY / BNL_UDF_Old Activity Name 181221: Procure & Deliver Magnet Cryo, Electrical & Control Structural Support in IR Components (leadtime and fab incl) - M&S
- S337900: BNL_UDF_Status Comments: 190318 ELM sort order per GRY / BNL_UDF_Old Activity Name 181221: Evaluate & Process Magnet Cryo, Electrical & Control Structural Support in IR Components Bids
- S338000: BNL_UDF_Status Comments: 190318 ELM sort order per GRY / BNL_UDF_Old Activity Name 181221: Procure & Deliver Magnet Cryo, Electrical & Control Structural Support in IR Components (leadtime and fab incl) - Labor
- S337800: BNL_UDF_Status Comments: 190318 ELM sort order per GRY / BNL_UDF_Old Activity Name 181221: Prepare Magnet Cryo, Electrical & Control Structural Support in IR Components Procurement Package(s)
- S337700: BNL_UDF_Status Comments: 190318 ELM sort order per GRY / BNL_UDF_Old Activity Name 181221: Design/Safety Reviews Complete, Magnet Cryo, Electrical & Control Structural Support in IR Components Released for Produ
- S338100: BNL_UDF_Status Comments: 190318 ELM sort order per GRY / BNL_UDF_Old Activity Name 181221: Perform Magnet Cryo, Electrical & Control Structural Support in IR Components Acceptance
- S338200: BNL_UDF_Status Comments: 190318 ELM sort order per GRY / BNL_UDF_Old Activity Name 181221: Magnet cryo, electrical and control structural support components Ready for Installation
- OBLG356580: BNL_UDF_Status Comments: 190318 ELM sort order per GRY / BNL_UDF_Old Activity Name 181221: Procure & Deliver Magnet Cryo, Electrical & Control Structural Support in IR Components (leadtime and fab incl) - M&S
- S277700: BNL_UDF_Old Activity Name 181221: 2023 Detector Support Systems L3 Project Management
- S338400: BNL_UDF_Status Comments: 190606 IVS change dates?; 190318 ELM logic, sort order per GRY / BNL_UDF_Old Activity Name 181221: Create Beampipe/Vacuum Layout
- S338410: BNL_UDF_Status Comments: 190318 ELM sort order per GRY / BNL_UDF_Old Activity Name 181221: Create Beampipe/Vacuum Layout
- S338500: BNL_UDF_Status Comments: 190318 ELM sort order per GRY / BNL_UDF_Old Activity Name 181221: Create Beampipe/Vacuum Envelope Drawing
- S338600: BNL_UDF_Status Comments: 190318 ELM sort order per GRY / BNL_UDF_Old Activity Name 181221: Create Beampipe/Vacuum subassembly and detail Drawings
- S338700: BNL_UDF_Status Comments: 190318 ELM sort order per GRY / BNL_UDF_Old Activity Name 181221: Review Beampipe/Vacuum Design/Safety
- S338710: BNL_UDF_Status Comments: 190318 ELM sort order per GRY / BNL_UDF_Old Activity Name 181221: Review Beampipe/Vacuum Design/Safety
- S338800: BNL_UDF_Status Comments: 190318 ELM sort order per GRY / BNL_UDF_Old Activity Name 181221: Address Action Items from Beampipe/Vacuum Design & Safety Reviews
- S338810: BNL_UDF_Status Comments: 190318 ELM sort order per GRY / BNL_UDF_Old Activity Name 181221: Address Action Items from Beampipe/Vacuum Design & Safety Reviews
- S338900: BNL_UDF_Status Comments: 190318 ELM sort order per GRY / BNL_UDF_Old Activity Name 181221: Design/Safety Reviews Complete, Beampipe/Vacuum components Released for Production
- S339000: BNL_UDF_Status Comments: 190318 ELM sort order per GRY / BNL_UDF_Old Activity Name 181221: Prepare Beampipe/Vacuum Components Procurement Package(s) Preparation
- S339100: BNL_UDF_Status Comments: 190318 ELM sort order per GRY / BNL_UDF_Old Activity Name 181221: Evaluate & Process Beampipe/Vacuum Components Bids
- S339010: BNL_UDF_Status Comments: 190318 ELM sort order per GRY / BNL_UDF_Old Activity Name 181221: Prepare Beampipe/Vacuum Components Procurement Package(s) Preparation
- S339110: BNL_UDF_Status Comments: 190318 ELM sort order per GRY / BNL_UDF_Old Activity Name 181221: Evaluate & Process Beampipe/Vacuum Components Bids
- S339200: BNL_UDF_Status Comments: 190318 ELM dur, sort order per GRY / BNL_UDF_Old Activity Name 181221: Procure & Deliver Beampipe/Vacuum Components (leadtime and fabrication included)
- S339210: BNL_UDF_Status Comments: 190318 ELM dur, sort order per GRY / BNL_UDF_Old Activity Name 181221: Procure & Deliver Beampipe/Vacuum Components (leadtime and fabrication included)
- S338300: BNL_UDF_Status Comments: 190318 ELM dur, sort order per GRY / BNL_UDF_Old Activity Name 181221: Procure & Deliver Beampipe/Vacuum Components (leadtime and fabrication included) M&S
- OBLG356680: BNL_UDF_Status Comments: 190318 ELM dur, sort order per GRY / BNL_UDF_Old Activity Name 181221: Procure & Deliver Beampipe/Vacuum Components (leadtime and fabrication included) M&S
- S339350: BNL_UDF_Status Comments: 190318 ELM sort order per GRY / BNL_UDF_Old Activity Name 181221: Perform Beampipe/vacuum Acceptance
- S339300: BNL_UDF_Status Comments: 190318 ELM sort order per GRY / BNL_UDF_Old Activity Name 181221: Perform Beampipe/vacuum Acceptance
- S339310: BNL_UDF_Status Comments: 190318 ELM sort order per GRY / BNL_UDF_Old Activity Name 181221: Perform Beampipe/vacuum Acceptance
- S339400: BNL_UDF_Status Comments: 190318 ELM sort order per GRY / BNL_UDF_Old Activity Name 181221: Beampipe/Vacuum components Ready for Installation

| ID | WBS | Activity | Type | Duration | Start | Finish | Predecessors | Complete | Remaining | Planned start | Planned finish | Total float | Free float | Expected finish | Resources | Cost | BNL_UDF_Temp Text 01 | BNL_UDF_Percent Complete | BNL_UDF_Sort Order | BNL_UDF_OPC TEC (deprecated) | BNL_UDF_Old Activity ID 181221 | BNL_Cobra WP | RG Check | BNL_Activity Status | BNL_Fund Source | BNL_Estimator | BNL_Cost Basis | BNL_Location | BNL_EDIA | BNL_CAM | BNL_Institution | BNL_OPC TEC (deprecated) | BNL_WBS | BNL_EVT | BNL_Master Control Account | BNL_Account Number | BNL_PCR ID | BNL_Cobra Control Account | BNL_WBS_Hierarchical | BNL_Milestone Level | Indicator - Procurement | Indicator - Float | BNL_UDF_Remaining Tot Cost | BNL_UDF_Percent_remaining | BNL_Proc Sig | SPH Proc Register | BNL_UDF_Temp Date 01 | Completed | Temp | BNL_UDF_Temp Text 02 | BNL_UDF_Exclude | BNL_Obligation |
| --- | --- | --- | --- | --- | --- | --- | --- | --- | --- | --- | --- | --- | --- | --- | --- | --- | --- | --- | --- | --- | --- | --- | --- | --- | --- | --- | --- | --- | --- | --- | --- | --- | --- | --- | --- | --- | --- | --- | --- | --- | --- | --- | --- | --- | --- | --- | --- | --- | --- | --- | --- | --- |
|  | 03 | **IR HVAC** |  |  | 2020-10-01 | 2021-12-20 |  |  |  |  |  |  |  |  |  |  |  |  |  |  |  |  |  |  |  |  |  |  |  |  |  |  |  |  |  |  |  |  |  |  |  |  |  |  |  |  |  |  |  |  |  |  |
| S339600 |  | Model IR HVAC Thermal Requirements |  | 30d | 2020-10-01 A | 2021-01-29 A | S100090 SS, S101015 SS | 100% |  | 2020-10-01 | 2020-11-13 |  |  |  | TECH4 AD [6.65 h]; PROF2 AD [13.29 h]; CRAFT3 [2.22 h]; PROF4 AD [11.08 h]; PROF6 AD [2.77 h] | 4,782.15 | S339600 | 0 | 1000 | S290200 | S290200 | S339600 | CA | Not Started | C | Pisani, Rob | L4 | BNL | Design | Joel Vasquez | BNL | null | POM02.2.04.02.03 | C | 2.04 | 16724 | 003 | 2.04 | 03 |  |  |  |  |  |  |  |  |  |  |  |  |  |
| S339700 |  | Create IR HVAC Layout/schematic drawings & Design specification control documents |  | 20d | 2020-12-21 A | 2021-06-18 | S339600 | 50% | 14d | 2021-01-21 | 2021-02-18 | 174d | 0d | 2021-06-18 | TECH4 AD [6 h]; PROF2 AD [24 h]; PROF4 AD [6 h] | 4,194.59 | S339700 | 0 | 1000 | S290300 | S290300 | S339700 | CA | Not Started | C | Pisani, Rob | L4 | BNL | Design | Joel Vasquez | BNL | null | POM02.2.04.02.03 | C | 2.04 | 16724 | 003 | 2.04 | 03 |  |  |  |  |  |  |  |  |  |  |  |  |  |
| S339800 |  | Review IR HVAC Design/Safety |  | 5d | 2021-06-21 | 2021-06-25 | S339700 |  |  |  |  | 174d | 0d |  | TECH4 AD [9 h]; PROF2 AD [18 h]; PROF4 AD [9 h] | 4,433.83 | S339800 | 0 | 1000 | S290400 | S290400 | S339800 | CA | Not Started | C | Pisani, Rob | L4 | BNL | Design | Joel Vasquez | BNL | null | POM02.2.04.02.03 | C | 2.04 | 16724 | 003 | 2.04 | 03 |  |  |  |  |  |  |  |  |  |  |  |  |  |
| S339900 |  | Address Action Items from IR HVAC Design & Safety Reviews |  | 10d | 2021-06-28 | 2021-07-12 | S339800 |  |  |  |  | 174d | 0d |  | TECH4 AD [8 h]; PROF2 AD [16 h]; PROF4 AD [8 h] | 3,941.18 | S339900 | 0 | 1000 | S290500 | S290500 | S339900 | CA | Not Started | C | Pisani, Rob | L4 | BNL | Design | Joel Vasquez | BNL | null | POM02.2.04.02.03 | C | 2.04 | 16724 | 003 | 2.04 | 03 |  |  |  |  |  |  |  |  |  |  |  |  |  |
| S340000 |  | Design/Safety Reviews Complete, IR HVAC Components Released for Production | milestone | 0d | 2021-07-12 | 2021-07-12 | S339900 FF |  |  |  |  | 174d | 0d |  |  |  | S340000 | 0 | 1000 | S290600 | S290600 |  | NOCA | Not Started | C | Pisani, Rob |  | BNL | Management Safety Reviews | Joel Vasquez | BNL |  | POM02.2.04.02.03 |  |  |  | 003 |  | 03 | L4 |  |  |  |  |  |  |  |  |  |  |  |  |
| S340100 |  | Prepare IR HVAC Components Procurement Package(s) |  | 20d | 2021-07-13 | 2021-08-09 | S340000 |  |  |  |  | 174d | 0d |  | TECH4 AD [16 h]; PROF2 AD [32 h]; PROF4 AD [4 h] | 6,062.16 | S340100 | 0 | 1000 | S290700 | S290700 | S340100 | CA | Not Started | C | Pisani, Rob | L4 | BNL | Procurement | Joel Vasquez | BNL | null | POM02.2.04.02.03 | C | 2.04 | 16724 | 003 | 2.04 | 03 |  |  |  |  |  |  |  |  |  |  |  |  |  |
| S340200 |  | Evaluate & Process IR HVAC Components Bids |  | 20d | 2021-08-10 | 2021-09-07 | S340100 |  |  |  |  | 174d | 0d |  | TECH4 AD [16 h]; PROF2 AD [32 h]; PROF4 AD [4 h] | 6,062.16 | S340200 | 0 | 1000 | S290800 | S290800 | S340200 | CA | Not Started | C | Pisani, Rob | L4 | BNL | Procurement | Joel Vasquez | BNL | null | POM02.2.04.02.03 | C | 2.04 | 16724 | 003 | 2.04 | 03 |  |  |  |  |  |  |  |  |  |  |  |  |  |
| S339500 |  | Procure & Deliver IR HVAC Components (leadtime and fabrication included) - M&S |  | 60d | 2021-09-08 | 2021-12-06 | S340300 SS |  |  |  |  | 174d | 0d |  | Material (Purchase (1st $2M) [35000 h] | 41,206.23 | S339500 | 0 | 2001 | S290100 | S290100 | S339500 | CA | Not Started | C | Pisani, Rob | M4 | BNL | Fab & Assy | Joel Vasquez | BNL | null | POM02.2.04.02.03 | C | 2.04 | 16724 | 003 | 2.04 | 03 |  | UDF_G1 | UDF_G3 | 40623.95085 | 1 | TBD | Combined |  |  |  |  |  |  |
| S340300 |  | Procure & Deliver IR HVAC Components (leadtime and fabrication included) - Labor |  | 60d | 2021-09-08 | 2021-12-06 | S340200 |  |  |  |  | 174d | 0d |  | TECH4 AD [48 h]; PROF2 AD [96 h] | 16,718.16 | S340300 | 0 | 2000 | S290900 | S290900 | S340300 | CA | Not Started | C | Pisani, Rob | L4 | BNL | Fab & Assy | Joel Vasquez | BNL | null | POM02.2.04.02.03 | C | 2.04 | 16724 | 003 | 2.04 | 03 |  |  |  |  |  |  |  |  |  |  |  |  |  |
| S340400 |  | Perform IR HVAC Components Acceptance |  | 10d | 2021-12-07 | 2021-12-20 | S340300, S339500 |  |  |  |  | 174d | 0d |  | TECH3 AD [40 h]; TECH4 AD [8 h]; PROF2 AD [16 h]; PROF4 AD [2 h] | 7,964.9 | S340400 | 0 | 2001 | S291000 | S291000 | S340400 | CA | Not Started | C | Pisani, Rob | L4 | BNL | Procurement | Joel Vasquez | BNL | null | POM02.2.04.02.03 | C | 2.04 | 16724 | 003 | 2.04 | 03 |  |  |  |  |  |  |  |  |  |  |  |  |  |
| S340500 |  | IR HVAC components Ready for Installation | milestone | 0d | 2021-12-20 | 2021-12-20 | S340400 FF |  |  |  |  | 174d | 0d |  |  |  | S340500 | 0 | 2001 | S291100 | S291100 |  | NOCA | Not Started | C | Pisani, Rob |  | BNL | Procurement | Joel Vasquez | BNL |  | POM02.2.04.02.03 |  |  |  | 003 |  | 03 | L3 |  |  |  |  |  |  |  |  |  |  |  |  |
|  | 04 | **IR Electronics Cooling Water Distribution System** |  |  | 2019-01-02 | 2022-01-20 |  |  |  |  |  |  |  |  |  |  |  |  |  |  |  |  |  |  |  |  |  |  |  |  |  |  |  |  |  |  |  |  |  |  |  |  |  |  |  |  |  |  |  |  |  |  |
| S340700 |  | Model IR Electronics Cooling Water Distribution Thermal Requirements - Physics Resource(s) |  | 105d | 2019-01-02 A | 2019-05-31 A | S100500 | 100% |  |  |  |  |  |  |  |  | PO&AD | 5 | 1000 | S291300 | S291300 |  | NOCA | Completed | C | Pisani, Rob | L4 | BNL | Design | Joel Vasquez | BNL | null | POM02.2.04.02.04 | C |  | 16724 | 003 |  | 04 |  |  |  |  |  |  |  | 2019-07-31 | yes | PO |  |  |  |
| S340702 |  | Model IR Electronics Cooling Water Distribution Thermal Requirements - Physics Resource(s) Split |  | 39d | 2019-11-01 A | 2019-11-25 A | S340700 | 100% |  | 2019-11-01 | 2019-12-31 |  |  |  | SCI3 PO [30 h] | 5,163.17 | PO&AD | 5 | 1000 | S291300 | S291300 | S340702 | CA | Completed | C | Pisani, Rob | L4 | BNL | Design | Joel Vasquez | BNL | null | POM02.2.04.02.04 | C | 2.04 | 16724 | 003 | 2.04 | 04 |  |  |  |  |  |  |  | 2019-07-31 |  | PO |  |  |  |
| S340710 |  | Model IR Electronics Cooling Water Distribution Thermal Requirements - CA-D Resource(s) |  | 40d | 2019-11-01 A | 2019-11-25 A | S340702 SS | 100% |  | 2019-11-01 | 2020-01-02 |  |  |  | TECH3 AD [32 h]; TECH4 AD [32 h]; PROF2 AD [160 h]; PROF4 AD [20 h] | 26,811.32 | PO&ADS340710 | 0 | 1000 | S291300 | S291300 | S340710 | CA | Completed | C | Pisani, Rob | L4 | BNL | Design | Joel Vasquez | BNL | null | POM02.2.04.02.04 | C | 2.04 | 16724 | 003,005 | 2.04 | 04 |  |  |  |  |  |  |  |  |  | C-AD | S340710 |  |  |
| S340800 |  | Create IR Electronics Cooling Water Distribution Layout/Schematic Drawings & Design Specification Control Documents |  | 40d | 2020-12-21 A | 2021-06-18 | S340710, S340702 | 80% | 14d | 2021-01-04 | 2021-03-02 | 144d | 0d | 2021-06-18 | TECH4 AD [32 h]; PROF2 AD [64 h]; PROF4 AD [4 h] | 11,517.59 | S340800 | 0 | 1000 | S291400 | S291400 | S340800 | CA | Not Started | C | Pisani, Rob | L4 | BNL | Design | Joel Vasquez | BNL | null | POM02.2.04.02.04 | C | 2.04 | 16724 | 003 | 2.04 | 04 |  |  |  |  |  |  |  |  |  |  |  |  |  |
| S340600 |  | Procure & Deliver IR Electronics Cooling Water Distribution Components (leadtime and fabrication included) - M&S |  | 50d | 2021-04-26 A | 2022-01-12 | S341400 SS, OBLG356780 | 50% | 50d | 2021-10-28 | 2022-01-12 | 144d | 0d | 2022-01-12 | Material (Purchase (1st $2M) [65000 h] | 76,953.37 | S340600 | 0 | 2001 | S291200 | S291200 | S340600 | CA | Not Started | C | Pisani, Rob | M5 | BNL | Fab & Assy | Joel Vasquez | BNL | null | POM02.2.04.02.04 | C | 2.04 | 16724 | 003 | 2.04 | 04 |  | UDF_G3 | UDF_G3 | 75444.48015 | 1 | TBD | Combined |  |  |  |  | MP6LAEXCLUDE |  |
| S341400 |  | Procure & Deliver IR Electronics Cooling Water Distribution Components (leadtime and fabrication included) - Labor |  | 50d | 2021-04-26 A | 2021-10-26 | S341300 | 50% | 29d | 2021-08-16 | 2021-10-26 | 144d | 0d | 2021-10-26 | TECH4 AD [40 h]; PROF2 AD [80 h]; PROF4 AD [2 h] | 14,084.14 | S341400 | 0 | 2000 | S292000 | S292000 | S341400 | CA | Not Started | C | Pisani, Rob | L4 | BNL | Fab & Assy | Joel Vasquez | BNL | null | POM02.2.04.02.04 | C | 2.04 | 16724 | 003 | 2.04 | 04 |  |  |  |  |  |  |  |  |  |  |  |  |  |
| S340900 |  | Review IR Electronics cooling water System Design/Safety |  | 10d | 2021-06-21 | 2021-07-02 | S340800 |  |  |  |  | 144d | 0d |  | TECH4 AD [8 h]; PROF2 AD [16 h]; PROF4 AD [4 h] | 3,334.45 | S340900 | 0 | 1000 | S291500 | S291500 | S340900 | CA | Not Started | C | Pisani, Rob | L4 | BNL | Design | Joel Vasquez | BNL | null | POM02.2.04.02.04 | C | 2.04 | 16724 | 003 | 2.04 | 04 |  |  |  |  |  |  |  |  |  |  |  |  |  |
| S341000 |  | Address Action Items from IR Electronics Cooling Water Distribution Design & Safety Reviews |  | 10d | 2021-07-06 | 2021-07-19 | S340900 |  |  |  |  | 144d | 0d |  | TECH4 AD [8 h]; PROF2 AD [16 h]; PROF4 AD [2 h] | 3,031.08 | S341000 | 0 | 1000 | S291600 | S291600 | S341000 | CA | Not Started | C | Pisani, Rob | L4 | BNL | Design | Joel Vasquez | BNL | null | POM02.2.04.02.04 | C | 2.04 | 16724 | 003 | 2.04 | 04 |  |  |  |  |  |  |  |  |  |  |  |  |  |
| S341100 |  | Design/Safety Reviews Complete, IR Electronics Cooling Water Distribution System Components Released for Production | milestone | 0d | 2021-07-19 | 2021-07-19 | S341000 FF |  |  |  |  | 144d | 0d |  |  |  | S341100 | 0 | 1000 | S291700 | S291700 |  | NOCA | Not Started | C | Pisani, Rob |  | BNL | Management Safety Reviews | Joel Vasquez | BNL |  | POM02.2.04.02.04 |  |  |  | 003 |  | 04 | L4 |  |  |  |  |  |  |  |  |  |  |  |  |
| S341200 |  | Prepare IR Electronics Cooling Water Distribution System Components Procurement Package(s) |  | 20d | 2021-07-20 | 2021-08-16 | S341100 |  |  |  |  | 144d | 0d |  | TECH4 AD [16 h]; PROF2 AD [32 h]; PROF4 AD [4 h] | 6,062.16 | S341200 | 0 | 1000 | S291800 | S291800 | S341200 | CA | Not Started | C | Pisani, Rob | L4 | BNL | Procurement | Joel Vasquez | BNL | null | POM02.2.04.02.04 | C | 2.04 | 16724 | 003 | 2.04 | 04 |  |  |  |  |  |  |  |  |  |  |  |  |  |
| S341300 |  | Evaluate & Process IR Electronics Cooling Water Distribution System Components Bids |  | 20d | 2021-08-17 | 2021-09-14 | S341200 |  |  |  |  | 144d | 0d |  | TECH4 AD [16 h]; PROF2 AD [32 h]; PROF4 AD [4 h] | 6,062.16 | S341300 | 0 | 1000 | S291900 | S291900 | S341300 | CA | Not Started | C | Pisani, Rob | L4 | BNL | Procurement | Joel Vasquez | BNL | null | POM02.2.04.02.04 | C | 2.04 | 16724 | 003 | 2.04 | 04 |  |  |  |  |  |  |  |  |  |  |  |  |  |
| OBLG356780 |  | Procure & Deliver IR Electronics Cooling Water Distribution Components (leadtime and fabrication included) - M&S |  | 1d | 2021-10-27 | 2021-10-27 | S341400 |  |  |  |  | 144d | 0d |  | Obligation Resource [76953 h] | 76,953 | S340600 | 0 | 2001 | S291200 | S291200 | S340600 |  | Not Started | C | Pisani, Rob | M5 | BNL | Fab & Assy | Joel Vasquez | BNL | null | POM02.2.04.02.04 | K | 2.04 | 16724 | 008C |  | 04 |  |  |  |  |  | TBD |  |  |  |  |  | MP6LAEXCLUDE | OBLG |
| S341500 |  | Perform IR Electronics Cooling Water Distribution System Components Acceptance |  | 5d | 2022-01-13 | 2022-01-20 | S341400, S340600 |  |  |  |  | 144d | 0d |  | TECH3 AD [20 h]; TECH4 AD [4 h]; PROF2 AD [8 h]; PROF4 AD [4 h] | 4,451.15 | S341500 | 0 | 2001 | S292100 | S292100 | S341500 | CA | Not Started | C | Pisani, Rob | L4 | BNL | Procurement | Joel Vasquez | BNL | null | POM02.2.04.02.04 | C | 2.04 | 16724 | 003 | 2.04 | 04 |  |  |  |  |  |  |  |  |  |  |  |  |  |
| S341600 |  | IR Electronics Cooling Water Distribution System Components Ready for Installation | milestone | 0d | 2022-01-20 | 2022-01-20 | S341500 FF |  |  |  |  | 144d | 0d |  |  |  | S341600 | 0 | 2001 | S292200 | S292200 |  | NOCA | Not Started | C | Pisani, Rob |  | BNL | Procurement | Joel Vasquez | BNL |  | POM02.2.04.02.04 |  |  |  | 003 |  | 04 | L3 |  |  |  |  |  |  |  |  |  |  |  |  |

Notes:
- S339600: BNL_UDF_Status Comments: 190318 ELM logic, sort order per GRY / BNL_UDF_Old Activity Name 181221: Model IR HVAC Thermal Requirements
- S339700: BNL_UDF_Status Comments: 190318 ELM sort order per GRY / BNL_UDF_Old Activity Name 181221: Create IR HVAC Layout/schematic drawings & Design specification control documents
- S339800: BNL_UDF_Status Comments: 190318 ELM sort order per GRY / BNL_UDF_Old Activity Name 181221: Review IR HVAC Design/Safety
- S339900: BNL_UDF_Status Comments: 190318 ELM sort order per GRY / BNL_UDF_Old Activity Name 181221: Address Action Items from IR HVAC Design & Safety Reviews
- S340000: BNL_UDF_Status Comments: 190318 ELM sort order per GRY / BNL_UDF_Old Activity Name 181221: Design/Safety Reviews Complete, IR HVAC Components Released for Production
- S340100: BNL_UDF_Status Comments: 190318 ELM sort order per GRY / BNL_UDF_Old Activity Name 181221: Prepare IR HVAC Components Procurement Package(s)
- S340200: BNL_UDF_Status Comments: 190318 ELM sort order per GRY / BNL_UDF_Old Activity Name 181221: Evaluate & Process IR HVACComponents Bids
- S339500: BNL_UDF_Status Comments: 190318 ELM sort order per GRY / BNL_UDF_Old Activity Name 181221: Procure & Deliver IR HVAC Components (leadtime and fabrication included) - M&S
- S340300: BNL_UDF_Status Comments: 190318 ELM sort order per GRY / BNL_UDF_Old Activity Name 181221: Procure & Deliver IR HVAC Components (leadtime and fabrication included) - Labor
- S340400: BNL_UDF_Status Comments: 190318 ELM sort order per GRY / BNL_UDF_Old Activity Name 181221: Perform IR HVAC Components Acceptance
- S340500: BNL_UDF_Status Comments: 190318 ELM sort order per GRY / BNL_UDF_Old Activity Name 181221: IR HVAC components Ready for Installation
- S340700: BNL_UDF_Status Comments: 190318 ELM logic, sort order per GRY / BNL_UDF_Old Activity Name 181221: Model IR Electronics Cooling Water Distribution Thermal Requirements
- S340702: BNL_UDF_Status Comments: 190318 ELM logic, sort order per GRY / BNL_UDF_Old Activity Name 181221: Model IR Electronics Cooling Water Distribution Thermal Requirements
- S340710: BNL_UDF_Status Comments: 190606 IVS change dates accord. to MOU; 190318 ELM sort order per GRY / BNL_UDF_Old Activity Name 181221: Model IR Electronics Cooling Water Distribution Thermal Requirements
- S340800: BNL_UDF_Status Comments: 190318 ELM sort order per GRY / BNL_UDF_Old Activity Name 181221: Create IR Electronics Cooling Water Distribution Layout/Schematic Drawings & Design Specification Control Documents
- S340600: BNL_UDF_Status Comments: 190318 ELM sort order per GRY / BNL_UDF_Old Activity Name 181221: Procure & Deliver IR Electronics Cooling Water Distribution Components (leadtime and fabrication included) - M&S
- S341400: BNL_UDF_Status Comments: 190318 ELM sort order per GRY / BNL_UDF_Old Activity Name 181221: Procure & Deliver IR Electronics Cooling Water Distribution Components (leadtime and fabrication included) - Labor
- S340900: BNL_UDF_Status Comments: 190318 ELM sort order per GRY / BNL_UDF_Old Activity Name 181221: Review IR Electronics cooling water System Design/Safety
- S341000: BNL_UDF_Status Comments: 190318 ELM sort order per GRY / BNL_UDF_Old Activity Name 181221: Address Action Items from IR Electronics Cooling Water Distribution Design & Safety Reviews
- S341100: BNL_UDF_Status Comments: 190318 ELM sort order per GRY / BNL_UDF_Old Activity Name 181221: Design/Safety Reviews Complete, IR Electronics Cooling Water Distribution System Components Released for Production
- S341200: BNL_UDF_Status Comments: 190318 ELM sort order per GRY / BNL_UDF_Old Activity Name 181221: Prepare IR Electronics Cooling Water Distribution System Components Procurement Package(s)
- S341300: BNL_UDF_Status Comments: 190318 ELM sort order per GRY / BNL_UDF_Old Activity Name 181221: Evaluate & Process IR Electronics Cooling Water Distribution System Components Bids
- OBLG356780: BNL_UDF_Status Comments: 190318 ELM sort order per GRY / BNL_UDF_Old Activity Name 181221: Procure & Deliver IR Electronics Cooling Water Distribution Components (leadtime and fabrication included) - M&S
- S341500: BNL_UDF_Status Comments: 190318 ELM sort order per GRY / BNL_UDF_Old Activity Name 181221: Perform IR Electronics Cooling Water Distribution System Components Acceptance
- S341600: BNL_UDF_Status Comments: 190318 ELM sort order per GRY / BNL_UDF_Old Activity Name 181221: IR Electronics Cooling Water Distribution System Components Ready for Installation
