# POM02 sPHENIX WBS 1.x, 2.x May 2021

Schedule from Primavera P6, 2016-09-27 to 2023-01-30, data date 2021-06-01, costs in USD, A marks actual dates.
RG 06.20.19 made copy to swap resources to new set. Also / fixed the Activity Duration vs Res Assgn duration to be in sync. / EMenter 190531 / Copied from ID POM02P004_Other / and changed ID to POM02. / Created BL POM02B as a copy of the current / project. / EMenter 190422 / PCR004 is in this project / EMenter 190330 / Fixed fiscal / boundary issues and calculation errors; reissued iterations of this P6 / Project for the below uses / EMenter 190329 / Project frozen / for the purpose of productions of reports for the 2019 Director's Review and the / generation of P6 Project copies for use in Primavera Risk and / Cobra / EMenter 190326 / This project is the approved preliminary / baseline as of this date; cumulative changes from PCRs 001, 002 and 003 are / included. / EMenter 190211 / This project is for PCR data / entry / EMenter 181118 / This project has FY19EPR / rates / 180924 RFG - Changed Project Name to POM02 sPHENIX / Schedule Prep Prelim BL October 1 2018 Rev 0 from POM01 sPHENIX Schedule Rev K / Draft / 180909 RFG - Changed Project ID to POM02 from / POM02B_K. / 180325 ELM - relabeled as version K, after creating a / baseline as a copy of itself (changed naming convention for this / baseline- name is "POM02 after CD-1 Review 180525") / 180308 ELM - relabeled as version J, after creating a baseline as a copy of / itself (BL is labeled H, since this was version H as used for director's / review) / 180228 ELM copy as BL prior to moving Milestone CD1/3a to / 28-Sep-18 / 180227 IVS made a copy before importing estimate / uncertainty data. / 180214 RFG at the end of the day copied POM02_H Rev / H. Replaced the Nonlabor resources (except Actual budget resources) with / the _sEPR resources. Copy this afterward and replaced as new Rev H. / 180213 RFG copied to PM02B180213 prior to adding new / material resources to resource table / 180211 RFG copied Rev G to G4c for final Sunday Night data / pull for cost review / 180131 ELM copied Rev F to get rid of deleted / activities / 180112 IVS copied Rev E to get rid of deleted / activities / 171206 RFG copied Rev E. This copy has / procurement strings loaded / 171015 RFG Rev D to split M&S, merge milestones, and / fix rate source / 170823 IS changed to Rev C – made copy PO00101B1708 / 170823 RFG rev B was using in the Aug 2017 sPHENIX / Director's Review / 170808 RFG made copy of Rev B, PO00101x001, to / add coding for CEB intgration / 170716 RFG changed to rev B updated with resources, logic / to match 10 July MPP files / 170610 RFG updated with resources and matched up to June / 4 MPP files / 170604 RFG creating copy prior to adding materials to the / working copy / 170507 RFG Created SPHENIX P6 schedule in the restore / database / 180822 ELM values for Resource Assignment UDF / BNL_RAU_Institution / Value / Description / BNL / Brookhaven National Laboratory / GSU / Georgia State University / LANL / Los Alamos National Laboratory / LBNL / Lawrence Berkeley National Laboratory / Lehigh / Lehigh University / MIT / Massachusetts Institute of Technology / POOL / Resource Pool / SBU / Stony Brook University / Temple / Temple University / UCol / University of Colorado / UIUC / University of Illinois Urbana-Champagne / UTAustin / University of Texas Austin / Vanderbilt / Vanderbilt University / Wayne / Wayne University / WIS / University of / Wisconsin

| ID | WBS | Activity | Type | Duration | Start | Finish | Predecessors | Complete | Remaining | Planned start | Planned finish | Total float | Free float | Constraint | Expected finish | Resources | Cost | BNL_UDF_Status Comments | BNL_UDF_Temp Text 01 | BNL_UDF_Percent Complete | BNL_UDF_Sort Order | BNL_UDF_OPC TEC (deprecated) | BNL_UDF_Old Activity ID 181221 | BNL_Cobra WP | RG Check | BNL_Activity Status | BNL_Fund Source | BNL_Estimator | BNL_Cost Basis | BNL_Location | BNL_EDIA | BNL_CAM | BNL_Institution | BNL_OPC TEC (deprecated) | BNL_WBS | BNL_EVT | BNL_Master Control Account | BNL_Account Number | BNL_PCR ID | BNL_Cobra Control Account | BNL_WBS_Hierarchical | Temp | BNL_UDF_Temp Text 02 | BNL_Milestone Level | BNL_UDF_Exclude | Indicator - Procurement | Indicator - Float | BNL_UDF_Remaining Tot Cost | BNL_UDF_Percent_remaining | BNL_Proc Sig | SPH Proc Register | BNL_Obligation | Additional EVT documentation required | Target Milestone Date | Variance | PMP Milestones |
| --- | --- | --- | --- | --- | --- | --- | --- | --- | --- | --- | --- | --- | --- | --- | --- | --- | --- | --- | --- | --- | --- | --- | --- | --- | --- | --- | --- | --- | --- | --- | --- | --- | --- | --- | --- | --- | --- | --- | --- | --- | --- | --- | --- | --- | --- | --- | --- | --- | --- | --- | --- | --- | --- | --- | --- | --- |
|  | 05 | **IR/AH Safety Subsystems** |  |  | 2020-12-14 | 2022-02-23 |  |  |  |  |  |  |  |  |  |  |  |  |  |  |  |  |  |  |  |  |  |  |  |  |  |  |  |  |  |  |  |  |  |  |  |  |  |  |  |  |  |  |  |  |  |  |  |  |  |  |
| S341800 |  | Analyze IR/AH Safety Subsystems Requirements - Physics Resource(s) |  | 30d | 2020-12-14 A | 2021-06-30 | S100500, S101015 SS | 25% | 22d | 2021-01-04 | 2021-02-16 | 121d | 0d |  | 2021-06-30 | SCI3 PO [3 h] | 531.81 | 190318 ELM logic, sort order per GRY | PO&AD | 0 | 1000 | S292400 | S292400 | S341800 | CA | Not Started | C | Pisani, Rob | L4 | BNL | Design | Joel Vasquez | BNL | null | POM02.2.04.02.05 | C | 2.04 | 16724 | 003 | 2.04 | 05 | PO |  |  |  |  |  |  |  |  |  |  |  |  |  |  |
| S341810 |  | Analyze IR/AH Safety Subsystems Requirements - CA-D Resource(s) |  | 30d | 2020-12-14 A | 2021-06-30 | S341800 SS | 25% | 22d | 2021-01-04 | 2021-02-16 | 121d | 0d |  | 2021-06-30 | TECH4 AD [72 h]; PROF2 AD [96 h]; PROF4 AD [10 h] | 21,111.42 | 190318 ELM sort order per GRY | PO&ADS341810 | 0 | 1000 | S292400 | S292400 | S341810 | CA | Not Started | C | Pisani, Rob | L4 | BNL | Design | Joel Vasquez | BNL | null | POM02.2.04.02.05 | C | 2.04 | 16724 | 003 | 2.04 | 05 | C-AD | S341810 |  |  |  |  |  |  |  |  |  |  |  |  |  |
| S341900 |  | Create Schematic Design and Specification Control Documents for IR/AH Safety Subsystems |  | 30d | 2021-07-01 | 2021-08-12 | S341800, S341810 |  |  |  |  | 121d | 0d |  |  | TECH4 AD [60 h]; PROF2 AD [96 h]; PROF4 AD [8 h] | 19,193.9 | 190318 ELM sort order per GRY | S341900 | 0 | 1000 | S292500 | S292500 | S341900 | CA | Not Started | C | Pisani, Rob | L4 | BNL | Design | Joel Vasquez | BNL | null | POM02.2.04.02.05 | C | 2.04 | 16724 | 003 | 2.04 | 05 |  |  |  |  |  |  |  |  |  |  |  |  |  |  |  |
| S342000 |  | Review IR/AH Safety Subsystems Design/Safety |  | 10d | 2021-08-13 | 2021-08-26 | S341900 |  |  |  |  | 121d | 0d |  |  | TECH4 AD [8 h]; PROF2 AD [32 h]; PROF4 AD [8 h] | 5,592.79 | 190318 ELM sort order per GRY | S342000 | 0 | 1000 | S292600 | S292600 | S342000 | CA | Not Started | C | Pisani, Rob | L4 | BNL | Design | Joel Vasquez | BNL | null | POM02.2.04.02.05 | C | 2.04 | 16724 | 003 | 2.04 | 05 |  |  |  |  |  |  |  |  |  |  |  |  |  |  |  |
| S342100 |  | Address Action Items from IR/AH Safety Subsystems Design & Safety Reviews |  | 10d | 2021-08-27 | 2021-09-10 | S342000 |  |  |  |  | 121d | 0d |  |  | TECH4 AD [8 h]; PROF2 AD [32 h]; PROF4 AD [4 h] | 4,986.06 | 190318 ELM sort order per GRY | S342100 | 0 | 1000 | S292700 | S292700 | S342100 | CA | Not Started | C | Pisani, Rob | L4 | BNL | Design | Joel Vasquez | BNL | null | POM02.2.04.02.05 | C | 2.04 | 16724 | 003 | 2.04 | 05 |  |  |  |  |  |  |  |  |  |  |  |  |  |  |  |
| S342200 |  | Design/Safety Reviews Complete, IR/AH Safety Subsystems Components Released for Production | milestone | 0d | 2021-09-10 | 2021-09-10 | S342100 FF, S338200 |  |  |  |  | 121d | 0d |  |  |  |  | 190318 ELM sort order per GRY | S342200 | 0 | 1000 | S292800 | S292800 |  | NOCA | Not Started | C | Pisani, Rob |  | BNL | Management Safety Reviews | Joel Vasquez | BNL |  | POM02.2.04.02.05 |  |  |  | 003 |  | 05 |  |  | L4 |  |  |  |  |  |  |  |  |  |  |  |  |
| S342300 |  | Prepare IR/AH Safety Subsystems Components Procurement Package(s) |  | 10d | 2021-09-13 | 2021-09-24 | S342200 |  |  |  |  | 121d | 0d |  |  | TECH4 AD [8 h]; PROF2 AD [16 h]; PROF4 AD [4 h] | 3,334.45 | 190318 ELM sort order per GRY | S342300 | 0 | 1000 | S292900 | S292900 | S342300 | CA | Not Started | C | Pisani, Rob | L4 | BNL | Procurement | Joel Vasquez | BNL | null | POM02.2.04.02.05 | C | 2.04 | 16724 | 003 | 2.04 | 05 |  |  |  |  |  |  |  |  |  |  |  |  |  |  |  |
| S342400 |  | Evaluate & Process IR/AH Safety Subsystems Components Bids |  | 30d | 2021-09-27 | 2021-11-08 | S342300 |  |  |  |  | 121d | 0d |  |  | TECH4 AD [24 h]; PROF2 AD [48 h]; PROF4 AD [4 h] | 9,018.41 | 190318 ELM sort order per GRY | S342400 | 0 | 1000 | S293000 | S293000 | S342400 | CA | Not Started | C | Pisani, Rob | L4 | BNL | Procurement | Joel Vasquez | BNL | null | POM02.2.04.02.05 | C | 2.04 | 16724 | 003 | 2.04 | 05 |  |  |  |  |  |  |  |  |  |  |  |  |  |  |  |
| S341700 |  | Procure & Deliver IR/AH Safety Subsystems Components (leadtime and fabrication included) - M&S |  | 60d | 2021-11-09 | 2022-02-08 | S342500 SS |  |  |  |  | 121d | 0d |  |  | Material (Purchase (1st $2M) [32000 h] | 37,884.74 | 190318 ELM sort order per GRY | S341700 | 0 | 2001 | S292300 | S292300 | S341700 | CA | Not Started | C | Pisani, Rob | M5 | BNL | Fab & Assy | Joel Vasquez | BNL | null | POM02.2.04.02.05 | C | 2.04 | 16724 | 003 | 2.04 | 05 |  |  |  | MP6LAEXCLUDE | UDF_G1 | UDF_G3 | 37141.89792 | 1 | TBD | Combined |  |  |  |  |  |
| S342500 |  | Procure & Deliver IR/AH Safety Subsystems Components (leadtime and fabrication included) - Labor |  | 60d | 2021-11-09 | 2022-02-08 | S342400 |  |  |  |  | 121d | 0d |  |  | TECH4 AD [48 h]; PROF2 AD [96 h]; PROF4 AD [2 h] | 17,169.74 | 190318 ELM sort order per GRY | S342500 | 0 | 2000 | S293100 | S293100 | S342500 | CA | Not Started | C | Pisani, Rob | L4 | BNL | Procurement | Joel Vasquez | BNL | null | POM02.2.04.02.05 | C | 2.04 | 16724 | 003 | 2.04 | 05 |  |  |  |  |  |  |  |  |  |  |  |  |  |  |  |
| S342600 |  | Perform IR/AH Safety Subsystems Components Acceptance |  | 10d | 2022-02-09 | 2022-02-23 | S342500, S341700 |  |  |  |  | 121d | 0d |  |  | TECH4 AD [88 h]; PROF2 AD [16 h]; PROF4 AD [4 h] | 14,518.32 | 190318 ELM sort order per GRY | S342600 | 0 | 2001 | S293200 | S293200 | S342600 | CA | Not Started | C | Pisani, Rob | L4 | BNL | Procurement | Joel Vasquez | BNL | null | POM02.2.04.02.05 | C | 2.04 | 16724 | 003 | 2.04 | 05 |  |  |  |  |  |  |  |  |  |  |  |  |  |  |  |
| S342700 |  | IR/AH Safety Subsystems Components Ready for Installation | milestone | 0d | 2022-02-23 | 2022-02-23 | S342600 |  |  |  |  | 121d | 0d |  |  |  |  | 190318 ELM sort order per GRY | S342700 | 0 | 2001 | S293300 | S293300 |  | NOCA | Not Started | C | Pisani, Rob |  | BNL | Procurement | Joel Vasquez | BNL |  | POM02.2.04.02.05 |  |  |  | 003 |  | 05 |  |  | L3 |  |  |  |  |  |  |  |  |  |  |  |  |
|  | 06 | **Assembly Hall and Interaction Region Modifications** |  |  | 2019-10-18 | 2022-04-04 |  |  |  |  |  |  |  |  |  |  |  |  |  |  |  |  |  |  |  |  |  |  |  |  |  |  |  |  |  |  |  |  |  |  |  |  |  |  |  |  |  |  |  |  |  |  |  |  |  |  |
| S343809 |  | Start Track Modification - IR | milestone | 0d | 2019-10-18 A | 2019-10-18 A |  | 100% |  |  |  |  |  | start on or after 2019-10-18 |  |  |  |  |  |  |  |  |  |  | NOCA | Completed | C |  |  |  | Design | Joel Vasquez |  |  |  |  |  |  | 008C |  | 06 |  |  |  |  |  |  |  |  |  |  |  |  |  |  |  |
| S343810 |  | Start Track Modification - IR Structural Analysis of Existing Track System and Prelim Design |  | 30d | 2019-10-18 A | 2020-08-31 A | S343809 | 100% |  | 2019-10-18 | 2019-12-03 |  |  |  |  | PROF3 AD [120 h]; PROF4 AD [40 h] | 21,071.74 |  |  |  |  |  |  | S343810 | CA | In Progress | C |  |  |  | Design | Joel Vasquez |  |  |  | C |  | 16724 | 008C | 2.04 | 06 |  |  |  |  |  |  |  |  |  |  |  |  |  |  |  |
| S343848 |  | Start Track Modification - AH Structural Analysis of Existing Track System and Prelim. Design |  | 30d | 2019-10-18 A | 2020-09-30 A | S343809 | 100% |  | 2019-10-18 | 2019-12-03 |  |  |  |  | PROF3 AD [100 h]; PROF4 AD [80 h] | 24,432.15 |  |  |  |  |  |  | S343848 | CA | In Progress | C |  |  |  | Design | Joel Vasquez |  |  |  | C |  | 16724 | 008C | 2.04 | 06 |  |  |  |  |  |  |  |  |  |  |  |  |  |  |  |
| S343812 |  | Start Track Modification - IR Prelim Design and Safety Review |  | 4d | 2020-08-03 A | 2020-09-30 A | S343810 | 100% |  | 2020-09-01 | 2020-09-04 |  |  |  |  | PROF3 AD [16 h]; PROF4 AD [6.4 h] | 2,966.65 |  |  |  |  |  |  | S343812 | CA | Not Started | C |  |  |  | Design | Joel Vasquez |  |  |  | C |  | 16724 | 008C | 2.04 | 06 |  |  |  |  |  |  |  |  |  |  |  |  |  |  |  |
| S343814 |  | Start Track Modification - IR Assembly and Detail Drawings |  | 30d | 2020-08-03 A | 2020-09-30 A | S343812 | 100% |  | 2020-09-08 | 2020-10-20 |  |  |  |  | PROF3 AD [40 h]; PROF4 AD [16 h]; TECH3 AD [100 h] | 19,073.61 |  |  |  |  |  |  | S343814 | CA | Not Started | C |  |  |  | Design | Joel Vasquez |  |  |  | C |  | 16724 | 008C | 2.04 | 06 |  |  |  |  |  |  |  |  |  |  |  |  |  |  |  |
| S343816 |  | Start Track Modification - IR Final Design and Safety Review |  | 5d | 2020-08-03 A | 2020-09-30 A | S343814 | 100% |  | 2020-10-21 | 2020-10-27 |  |  |  |  | TECH3 AD [16 h]; PROF3 AD [16 h]; PROF4 AD [8 h] | 5,179.07 |  |  |  |  |  |  | S343816 | CA | Not Started | C |  |  |  | Design | Joel Vasquez |  |  |  | C |  | 16724 | 008C | 2.04 | 06 |  |  |  |  |  |  |  |  |  |  |  |  |  |  |  |
| S343818 |  | Start Track Modification - IR Address Action Items from D&S Review |  | 10d | 2020-08-03 A | 2020-09-30 A | S343816 | 100% |  | 2020-10-28 | 2020-11-10 |  |  |  |  | PROF3 AD [16 h]; TECH3 AD [16 h] | 3,965.61 |  |  |  |  |  |  | S343818 | CA | Not Started | C |  |  |  | Design | Joel Vasquez |  |  |  | C |  | 16724 | 008C | 2.04 | 06 |  |  |  |  |  |  |  |  |  |  |  |  |  |  |  |
| S343850 |  | Start Track Modification - AH Prelim Design and Safety Review |  | 5d | 2020-09-08 A | 2020-09-30 A | S343848 | 100% |  | 2020-10-01 | 2020-10-07 |  |  |  |  | PROF3 AD [20 h]; PROF4 AD [16 h] | 5,033.02 |  |  |  |  |  |  | S343850 | CA | Not Started | C |  |  |  | Design | Joel Vasquez |  |  |  | C |  | 16724 | 008C | 2.04 | 06 |  |  |  |  |  |  |  |  |  |  |  |  |  |  |  |
| S343852 |  | Start Track Modification - AH Assembly and Detail Drawings |  | 15d | 2020-09-08 A | 2020-09-30 A | S343850 | 100% |  | 2020-10-08 | 2020-10-29 |  |  |  |  | PROF3 AD [30 h]; PROF4 AD [12 h]; TECH3 AD [40 h] | 10,431.17 |  |  |  |  |  |  | S343852 | CA | Not Started | C |  |  |  | Design | Joel Vasquez |  |  |  | C |  | 16724 | 008C | 2.04 | 06 |  |  |  |  |  |  |  |  |  |  |  |  |  |  |  |
| S343854 |  | Start Track Modification - AH Final Design and Safety Review |  | 5d | 2020-09-08 A | 2020-09-30 A | S343852 | 100% |  | 2020-10-30 | 2020-11-05 |  |  |  |  | TECH3 AD [16 h]; PROF4 AD [16 h]; PROF3 AD [16 h] | 6,392.54 |  |  |  |  |  |  | S343854 | CA | Not Started | C |  |  |  | Design | Joel Vasquez |  |  |  | C |  | 16724 | 008C | 2.04 | 06 |  |  |  |  |  |  |  |  |  |  |  |  |  |  |  |
| S343856 |  | Start Track Modification - AH Address Action Items from D&S Review |  | 5d | 2020-09-08 A | 2020-09-30 A | S343854 | 100% |  | 2020-11-06 | 2020-11-13 |  |  |  |  | PROF3 AD [8 h]; PROF4 AD [8 h]; TECH3 AD [8 h] | 3,196.27 |  |  |  |  |  |  | S343856 | CA | Not Started | C |  |  |  | Design | Joel Vasquez |  |  |  | C |  | 16724 | 008C | 2.04 | 06 |  |  |  |  |  |  |  |  |  |  |  |  |  |  |  |
| S343820 |  | Start Track Modification - IR Design Complete | milestone | 0d | 2020-09-30 A | 2020-09-30 A | S343818 | 100% |  | 2020-11-10 | 2020-11-10 |  |  |  |  |  |  |  |  |  |  |  |  |  | NOCA | Not Started | C |  |  |  | Design | Joel Vasquez |  |  |  |  |  |  | 008C |  | 06 |  |  |  |  |  |  |  |  |  |  |  |  |  |  |  |
| S343822 |  | Start Track Modification - IR Prepare Procur. Package |  | 10d | 2020-10-01 A | 2020-10-15 A | S343820 | 100% |  |  |  |  |  |  |  | TECH3 AD [32 h]; PROF3 AD [16 h] | 5,846.34 |  |  |  |  |  |  | S343822 | CA | Not Started | C |  |  |  | Procurement | Joel Vasquez |  |  |  | C |  | 16724 | 008C | 2.04 | 06 |  |  |  |  |  |  |  |  |  |  |  |  |  |  |  |
| S343858 |  | Start Track Modification - AH Design Complete | milestone | 0d | 2020-10-13 A | 2020-10-13 A | S343856 | 100% |  | 2020-11-13 | 2020-11-13 |  |  |  |  |  |  |  |  |  |  |  |  |  | NOCA | Not Started | C |  |  |  | Design | Joel Vasquez |  |  |  |  |  |  | 008C |  | 06 |  |  |  |  |  |  |  |  |  |  |  |  |  |  |  |
| S343824 |  | Start Track Modification - IR Procur. Readiness Review |  | 5d | 2020-10-16 A | 2020-10-22 A | S343822 | 100% |  |  |  |  |  |  |  | PROF3 AD [16 h]; PROF4 AD [8 h]; TECH3 AD [16 h] | 5,179.07 |  |  |  |  |  |  | S343824 | CA | Not Started | C |  |  |  | Procurement | Joel Vasquez |  |  |  | C |  | 16724 | 008C | 2.04 | 06 |  |  |  |  |  |  |  |  |  |  |  |  |  |  |  |
| S343826 |  | Start Track Modification - IR Provide Requirements to Procurements |  | 5d | 2020-10-23 A | 2020-10-29 A | S343824 | 100% |  |  |  |  |  |  |  | PROF3 AD [16 h] | 2,084.88 |  |  |  |  |  |  | S343826 | CA | Not Started | C |  |  |  | Procurement | Joel Vasquez |  |  |  | C |  | 16724 | 008C | 2.04 | 06 |  |  |  |  |  |  |  |  |  |  |  |  |  |  |  |
| S343828 |  | Start Track Modification - IR Prepare and Send Solicitations |  | 10d | 2020-11-02 A | 2020-11-16 A | S343826 | 100% |  |  |  |  |  |  |  | PROF3 AD [8 h] | 1,042.44 |  |  |  |  |  |  | S343828 | CA | Not Started | C |  |  |  | Procurement | Joel Vasquez |  |  |  | C |  | 16724 | 008C | 2.04 | 06 |  |  |  |  |  |  |  |  |  |  |  |  |  |  |  |
| S343830 |  | Start Track Modification - IR Vendor Responses |  | 10d | 2020-11-17 A | 2021-01-29 A | S343828 | 100% |  | 2020-11-17 | 2020-12-02 |  |  |  |  | PROF3 AD [8 h] | 1,042.44 |  |  |  |  |  |  | S343830 | CA | Not Started | C |  |  |  | Procurement | Joel Vasquez |  |  |  | C |  | 16724 | 008C | 2.04 | 06 |  |  |  |  |  |  |  |  |  |  |  |  |  |  |  |
| S342900 |  | Analyze Assembly Hall Modification Requirements |  | 30d | 2021-01-04 A | 2021-05-25 A | S100500, S101015 SS | 100% |  | 2021-01-04 | 2021-02-16 |  |  |  |  | TECH4 AD [72 h]; PROF2 AD [120 h]; PROF4 AD [20 h] | 25,105.67 | 190318 ELM logic, sort order per GRY | S342900 | 0 | 1000 | S293500 | S293500 | S342900 | CA | Not Started | C | Pisani, Rob | L4 | BNL | Design | Joel Vasquez | BNL | null | POM02.2.04.02.06 | C | 2.04 | 16724 | 003 | 2.04 | 06 |  |  |  |  |  |  |  |  |  |  |  |  |  |  |  |
| S343832 |  | Start Track Modification - IR Vendor Selection |  | 5d | 2021-01-11 A | 2021-01-29 A | S343830 | 100% |  | 2021-02-01 | 2021-02-05 |  |  |  |  | PROF3 AD [8 h] | 1,042.44 |  |  |  |  |  |  | S343832 | CA | Not Started | C |  |  |  | Procurement | Joel Vasquez |  |  |  | C |  | 16724 | 008C | 2.04 | 06 |  |  |  |  |  |  |  |  |  |  |  |  |  |  |  |
| S343834 |  | Start Track Modification - IR Contract Award |  | 10d | 2021-01-11 A | 2021-01-29 A | S343832 | 100% |  | 2021-02-08 | 2021-02-22 |  |  |  |  |  |  |  |  |  |  |  |  |  | NOCA | Not Started | C |  |  |  | Procurement | Joel Vasquez |  |  |  |  |  |  | 008C |  | 06 |  |  |  |  |  |  |  |  |  | Contract Award |  |  |  |  |  |
| S343836 |  | Start Track Modification - IR Develop and Submit Safety Plan |  | 20d | 2021-01-11 A | 2021-02-16 A | S343834 | 100% |  | 2021-02-23 | 2021-03-22 |  |  |  |  | PROF3 AD [24 h] | 3,127.32 |  |  |  |  |  |  | S343836 | CA | Not Started | C |  |  |  | Procurement | Joel Vasquez |  |  |  | C |  | 16724 | 008C | 2.04 | 06 |  |  |  |  |  |  |  |  |  |  |  |  |  |  |  |
| S343860 |  | Start Track Modification - AH Fabricate Track Plates Labor - Internal |  | 45d | 2021-02-01 A | 2021-03-29 A | S343858 | 100% |  | 2021-02-01 | 2021-04-05 |  |  |  |  | PROF3 AD [22.5 h]; PROF4 AD [9 h] | 4,297.01 |  |  |  |  |  |  | S343860 | CA | Not Started | C |  |  |  | Procurement | Joel Vasquez |  |  |  | C |  | 16724 | 008C | 2.04 | 06 |  |  |  |  |  |  |  |  |  |  |  |  |  |  |  |
| S343861 |  | Start Track Modification - AH Fabricate Track Plates M&S - Internal |  | 5d | 2021-02-01 A | 2021-03-31 A | S343858 | 100% |  | 2021-02-01 | 2021-02-05 |  |  |  |  | Material (Purchase (1st $2M) [50000 h] | 58,034.22 |  |  |  |  |  |  | S343861 | CA | Not Started | C |  |  |  | Procurement | Joel Vasquez |  |  |  | C |  | 16724 | 008C | 2.04 | 06 |  |  |  |  | UDF_G1 | UDF_G1 | 56896.2895 | 1 | TBD | Combined |  |  |  |  |  |
| S343862 |  | Start Track Modification - AH Install Track Plates and Blocks - Internal |  | 13d | 2021-02-01 A | 2021-03-31 A | S343860, S343861 | 100% |  | 2021-04-06 | 2021-04-22 |  |  |  |  | PROF3 AD [26 h]; PROF4 AD [5.2 h]; TECH3 AD [5.2 h]; CRAFT3 [78 h] | 14,836.14 |  |  |  |  |  |  | S343862 | CA | Not Started | C |  |  |  | Installation | Joel Vasquez |  |  |  | C |  | 16724 | 008C | 2.04 | 06 |  |  |  |  |  |  |  |  |  |  |  |  |  |  |  |
| S343864 |  | Start Track Modification - AH Survey and Grout Plates Labor - External |  | 10d | 2021-02-01 A | 2021-04-30 A | S343862 | 100% |  | 2021-04-23 | 2021-05-06 |  |  |  |  | PROF3 AD [20 h]; PROF4 AD [16 h]; TECH3 AD [180 h]; CRAFT3 [144 h] | 44,741.85 |  |  |  |  |  |  | S343864 | CA | Not Started | C |  |  |  | Installation | Joel Vasquez |  |  |  | C |  | 16724 | 008C | 2.04 | 06 |  |  |  |  |  |  |  |  |  |  |  |  |  |  |  |
| S343865 |  | Start Track Modification - AH Survey and Grout Plates M&S - External |  | 0d | 2021-02-01 A | 2021-04-30 A | S343862 | 100% |  | 2021-04-23 | 2021-04-23 |  |  |  |  | Material (Purchase (1st $2M) [10000 h] | 11,606.84 |  |  |  |  |  |  | S343865 | CA | Not Started | C |  |  |  | Installation | Joel Vasquez |  |  |  | C |  | 16724 | 008C | 2.04 | 06 |  |  |  |  | UDF_G1 | UDF_G1 | 11606.8431 | 1 | TBD |  |  |  |  |  |  |
| S343838 |  | Start Track Modification - IR Notice to Proceed | milestone | 0d | 2021-02-25 A | 2021-02-25 A | S343836, S316010 | 100% |  | 2021-03-22 | 2021-03-22 |  |  |  |  |  |  |  |  |  |  |  |  |  | NOCA | Not Started | C |  |  |  | Procurement | Joel Vasquez |  |  |  |  |  |  | 008C |  | 06 |  |  |  |  |  |  |  |  |  |  |  |  |  |  |  |
| S343840 |  | Start Track Modification - IR Leadtime |  | 1d | 2021-02-26 A | 2021-08-31 | S343838 | 10% | 0d | 2021-04-01 | 2021-04-01 | 101d | 0d |  | 2021-07-15 |  |  |  |  |  |  |  |  |  | NOCA | Not Started | C |  |  |  | Procurement | Joel Vasquez |  |  |  |  |  |  | 008C |  | 06 |  |  |  |  |  |  |  |  |  |  |  |  |  |  |  |
| S343866 |  | Start Track Modification - AH Finish AH Installation | milestone | 0d | 2021-04-30 A | 2021-04-30 A | S343864, S343865 | 100% |  | 2021-06-02 | 2021-06-02 |  |  |  |  |  |  |  |  |  |  |  |  |  | NOCA | Not Started | C |  |  |  | Installation | Joel Vasquez |  |  |  |  |  |  | 008C |  | 06 |  |  |  |  |  |  |  |  |  |  |  |  |  |  |  |
| S343000 |  | Create Assembly Hall Modifications Schematic Design and Specification Control Documents |  | 30d | 2021-06-01 | 2021-07-13 | S342900 |  |  |  |  | 68d | 0d |  |  | TECH4 AD [24 h]; PROF2 AD [48 h]; PROF4 AD [20 h] | 11,216.8 | 190318 ELM sort order per GRY | S343000 | 0 | 1000 | S293600 | S293600 | S343000 | CA | Not Started | C | Pisani, Rob | L4 | BNL | Design | Joel Vasquez | BNL | null | POM02.2.04.02.06 | C | 2.04 | 16724 | 003 | 2.04 | 06 |  |  |  |  |  |  |  |  |  |  |  |  |  |  |  |
| S343100 |  | Review Assembly Hall Modifications Design/Safety |  | 10d | 2021-07-14 | 2021-07-27 | S343000 |  |  |  |  | 68d | 0d |  |  | TECH4 AD [8 h]; PROF2 AD [16 h]; PROF4 AD [5 h] | 3,486.13 | 190318 ELM sort order per GRY | S343100 | 0 | 1000 | S293700 | S293700 | S343100 | CA | Not Started | C | Pisani, Rob | L4 | BNL | Design | Joel Vasquez | BNL | null | POM02.2.04.02.06 | C | 2.04 | 16724 | 003 | 2.04 | 06 |  |  |  |  |  |  |  |  |  |  |  |  |  |  |  |
| S343200 |  | Address Action Items from Assembly Hall Modifications Design & Safety Reviews |  | 10d | 2021-07-28 | 2021-08-10 | S343100 |  |  |  |  | 68d | 0d |  |  | TECH4 AD [8 h]; PROF2 AD [16 h]; PROF4 AD [5 h] | 3,486.13 | 190318 ELM sort order per GRY | S343200 | 0 | 1000 | S293800 | S293800 | S343200 | CA | Not Started | C | Pisani, Rob | L4 | BNL | Management Safety Reviews | Joel Vasquez | BNL | null | POM02.2.04.02.06 | C | 2.04 | 16724 | 003 | 2.04 | 06 |  |  |  |  |  |  |  |  |  |  |  |  |  |  |  |
| S343847 |  | Addition of ReBar plus Concrete Forming and Placement for IR Tracks - Leadtime |  | 96d | 2021-08-02 | 2021-12-20 |  |  |  |  |  | 275d | 0d | start on or after 2021-08-02 |  |  |  |  |  |  |  |  |  | S343847 | CA | Not Started | C |  |  |  | Procurement | Joel Vasquez |  |  |  | C |  | 16724 | 026 | 2.04 | 06 |  |  |  |  | UDF_G1 | UDF_G3 | 162495.8034 | 1 | TBD | Delivery | FAB |  |  |  |  |
| S343300 |  | Design/Safety Reviews Complete, Assembly Hall Modifications Components Released for Production | milestone | 0d | 2021-08-10 | 2021-08-10 | S343200 FF |  |  |  |  | 68d | 0d |  |  |  |  | 190318 ELM sort order per GRY | S343300 | 0 | 1000 | S293900 | S293900 |  | NOCA | Not Started | C | Pisani, Rob |  | BNL | Management Safety Reviews | Joel Vasquez | BNL |  | POM02.2.04.02.06 |  |  |  | 003 |  | 06 |  |  | L4 |  |  |  |  |  |  |  |  |  |  |  |  |
| S343400 |  | Prepare Assembly Hall Modifications Components Procurement Package(s) |  | 30d | 2021-08-11 | 2021-09-22 | S343300 |  |  |  |  | 68d | 0d |  |  | TECH4 AD [72 h]; PROF2 AD [48 h]; PROF4 AD [4 h] | 15,246.48 | 190318 ELM sort order per GRY | S343400 | 0 | 1000 | S294000 | S294000 | S343400 | CA | Not Started | C | Pisani, Rob | L4 | BNL | Procurement | Joel Vasquez | BNL | null | POM02.2.04.02.06 | C | 2.04 | 16724 | 003 | 2.04 | 06 |  |  |  |  |  |  |  |  |  |  |  |  |  |  |  |
| S343842 |  | Start Track Modification - IR BNL Oversight of Construction |  | 29d | 2021-08-31 | 2021-10-12 | S343838, S343840, S274300 |  |  |  |  | 101d | 0d |  |  | PROF3 AD [104.4 h]; PROF4 AD [23.2 h] | 17,246.86 |  |  |  |  |  |  | S343842 | CA | Not Started | C |  |  |  | Procurement | Joel Vasquez |  |  |  | C |  | 16724 | 008C | 2.04 | 06 |  |  |  |  |  |  |  |  |  |  |  |  |  |  |  |
| S343500 |  | Evaluate & Process Assembly Hall Modifications Components Bids |  | 30d | 2021-09-23 | 2021-11-04 | S343400 |  |  |  |  | 68d | 0d |  |  | TECH4 AD [72 h]; PROF2 AD [48 h]; PROF4 AD [2 h] | 15,301.75 | 190318 ELM sort order per GRY | S343500 | 0 | 1000 | S294100 | S294100 | S343500 | CA | Not Started | C | Pisani, Rob | L4 | BNL | Procurement | Joel Vasquez | BNL | null | POM02.2.04.02.06 | C | 2.04 | 16724 | 003 | 2.04 | 06 |  |  |  |  |  |  |  |  |  |  |  |  |  |  |  |
| OBLG356880 |  | Start Track Modification - IR Delivery Acceptance M&S |  | 1d | 2021-10-13 | 2021-10-13 | S343842 |  |  |  |  | 101d | 0d |  |  | Obligation Resource [159310 h] | 159,310 |  |  |  |  |  |  |  |  | Not Started | C |  |  |  |  | Joel Vasquez |  |  |  |  |  | 16724 | 008C |  |  |  |  |  |  |  |  |  |  | TBD |  | OBLG |  |  |  |  |
| S343844 |  | Start Track Modification - IR Delivery Acceptance Labor |  | 5d | 2021-10-13 | 2021-10-19 | S343842 |  |  |  |  | 102d | 1d |  |  | PROF3 AD [16 h]; PROF4 AD [8 h] | 3,397.29 |  |  |  |  |  |  | S343844 | CA | Not Started | C |  |  |  | Procurement | Joel Vasquez |  |  |  | C |  | 16724 | 008C | 2.04 | 06 |  |  |  |  |  |  |  |  |  |  |  |  |  |  |  |
| S343845 |  | Start Track Modification - IR Delivery Acceptance M&S Outside BOA contractor |  | 5d | 2021-10-14 | 2021-10-20 | S343842, OBLG356880 |  |  |  |  | 101d | 0d |  |  | Material (Purchase (1st $2M) [140000 h] | 165,745.72 |  |  |  |  |  |  | S343845 | CA | Not Started | C |  |  |  | Procurement | Joel Vasquez |  |  |  | C |  | 16724 | 016 | 2.04 | 06 |  |  |  |  | UDF_G1 | UDF_G3 | 162495.8034 | 1 | TBD | Delivery | FAB |  |  |  |  |
| S343846 |  | Start Track Modification - IR Complete | milestone | 0d | 2021-10-20 | 2021-10-20 | S343844, S343845 |  |  |  |  | 101d |  |  |  |  |  |  |  |  |  |  |  |  | NOCA | Not Started | C |  |  |  | Procurement | Joel Vasquez |  |  |  |  |  |  | 008C |  | 06 |  |  |  |  |  |  |  |  |  |  |  |  |  |  |  |
| S342800 |  | Procure & Deliver Assembly Hall Modifications Components (leadtime and fabrication included) - M&S |  | 90d | 2021-11-05 | 2022-03-21 | S343600 SS |  |  |  |  | 68d | 0d |  |  | Material (Purchase (1st $2M) [10000 h] | 11,838.98 | 190318 ELM sort order per GRY | S342800 | 0 | 2001 | S293400 | S293400 | S342800 | CA | Not Started | C | Pisani, Rob | M5 | BNL | Fab & Assy | Joel Vasquez | BNL | null | POM02.2.04.02.06 | C | 2.04 | 16724 | 003 | 2.04 | 06 |  |  |  |  | UDF_G1 | UDF_G3 | 11606.8431 | 1 | TBD |  |  | Yes |  |  |  |
| S343600 |  | Procure & Deliver Assembly Hall Modifications Components (leadtime and fabrication included) - Labor |  | 90d | 2021-11-05 | 2022-03-21 | S343500 |  |  |  |  | 68d | 0d |  |  | TECH4 AD [72 h]; PROF2 AD [144 h]; PROF4 AD [8 h] | 26,535.78 | 190318 ELM sort order per GRY | S343600 | 0 | 2000 | S294200 | S294200 | S343600 | CA | Not Started | C | Pisani, Rob | L4 | BNL | Fab & Assy | Joel Vasquez | BNL | null | POM02.2.04.02.06 | C | 2.04 | 16724 | 003 | 2.04 | 06 |  |  |  |  |  |  |  |  |  |  |  | Yes |  |  |  |
| S343849 |  | Addition of ReBar plus Concrete Forming and Placement for IR Tracks - Acceptance |  | 0d | 2021-12-21 | 2021-12-21 | S343847 |  |  |  |  | 275d |  |  |  | Material (Purchase (1st $2M) [550000 h] | 613,587.44 |  |  |  |  |  |  | S343849 | CA | Not Started | C |  |  |  | Procurement | Joel Vasquez |  |  |  | C |  | 16724 | 026 | 2.04 | 06 |  |  |  |  | UDF_G3 | UDF_G3 | 162495.8034 | 1 | TBD | Delivery | FAB |  |  |  |  |
| S343700 |  | Perform Assembly Hall Modifications Components Acceptance |  | 10d | 2022-03-22 | 2022-04-04 | S343600, S342800 |  |  |  |  | 68d | 0d |  |  | TECH4 AD [24 h]; PROF2 AD [16 h] | 5,026.31 | 190318 ELM sort order per GRY | S343700 | 0 | 2001 | S294300 | S294300 | S343700 | CA | Not Started | C | Pisani, Rob | L4 | BNL | Procurement | Joel Vasquez | BNL | null | POM02.2.04.02.06 | C | 2.04 | 16724 | 003 | 2.04 | 06 |  |  |  |  |  |  |  |  |  |  |  |  |  |  |  |
| S343800 |  | Assembly Hall Components Ready for Installation | milestone | 0d | 2022-04-04 | 2022-04-04 | S343700 FF |  |  |  |  | 78d | 70d |  |  |  |  | 190318 ELM sort order per GRY | S343800 | 0 | 2001 | S294400 | S294400 |  | NOCA | Not Started | C | Pisani, Rob |  | BNL | Test_System | Joel Vasquez | BNL |  | POM02.2.04.02.06 |  |  |  | 003 |  | 06 |  |  | L3 |  |  |  |  |  |  |  |  |  | 2022-02-02 | -43 | PMP_2x |

Notes:
- S341800: BNL_UDF_Old Activity Name 181221: Analyze IR/AH Safety Subsystems Requirements
- S341810: BNL_UDF_Old Activity Name 181221: Analyze IR/AH Safety Subsystems Requirements
- S341900: BNL_UDF_Old Activity Name 181221: Create Schematic Design and Specification Control Documents for IR/AH Safety Subsystems
- S342000: BNL_UDF_Old Activity Name 181221: Review IR/AH Safety Subsystems Design/Safety
- S342100: BNL_UDF_Old Activity Name 181221: Address Action Items from IR/AH Safety Subsystems Design & Safety Reviews
- S342200: BNL_UDF_Old Activity Name 181221: Design/Safety Reviews Complete, IR/AH Safety Subsystems Components Released for Production
- S342300: BNL_UDF_Old Activity Name 181221: Prepare IR/AH Safety Subsystems Components Procurement Package(s)
- S342400: BNL_UDF_Old Activity Name 181221: Evaluate & Process IR/AH Safety Subsystems Components Bids
- S341700: BNL_UDF_Old Activity Name 181221: Procure & Deliver IR/AH Safety Subsystems Components (leadtime and fabrication included) - M&S
- S342500: BNL_UDF_Old Activity Name 181221: Procure & Deliver IR/AH Safety Subsystems Components (leadtime and fabrication included)
- S342600: BNL_UDF_Old Activity Name 181221: Perform IR/AH Safety Subsystems Components Acceptance
- S342700: BNL_UDF_Old Activity Name 181221: IR/AH Safety Subsystems Components Ready for Installation
- S342900: BNL_UDF_Old Activity Name 181221: Analyze Assembly Hall Modification Requirements
- S343000: BNL_UDF_Old Activity Name 181221: Create Assembly Hall Modifications Schematic Design and Specification Control Documents
- S343100: BNL_UDF_Old Activity Name 181221: Review Assembly Hall Modifications Design/Safety
- S343200: BNL_UDF_Old Activity Name 181221: Address Action Items from Assembly Hall Modifications Design & Safety Reviews
- S343300: BNL_UDF_Old Activity Name 181221: Design/Safety Reviews Complete, Assembly Hall Modifications Components Released for Production
- S343400: BNL_UDF_Old Activity Name 181221: Prepare Assembly Hall Modifications Components Procurement Package(s)
- S343500: BNL_UDF_Old Activity Name 181221: Evaluate & Process Assembly Hall Modifications Components Bids
- S342800: BNL_UDF_Old Activity Name 181221: Procure & Deliver Assembly Hall Modifications Components (leadtime and fabrication included) - M&S
- S343600: BNL_UDF_Old Activity Name 181221: Procure & Deliver Assembly Hall Modifications Components (leadtime and fabrication included) - Labor
- S343700: BNL_UDF_Old Activity Name 181221: Perform Assembly Hall Modifications Components Acceptance
- S343800: BNL_UDF_Old Activity Name 181221: Assembly Hall Components Ready for Installation

| ID | WBS | Activity | Type | Duration | Start | Finish | Predecessors | Complete | Planned start | Planned finish | Resources | Cost | BNL_UDF_Exclude | BNL_UDF_Status Comments | BNL_UDF_Temp Text 01 | BNL_UDF_Percent Complete | BNL_UDF_Old Activity ID 181221 | BNL_Cobra WP | RG Check | BNL_Activity Status | BNL_Fund Source | BNL_Estimator | BNL_Cost Basis | BNL_Location | BNL_EDIA | BNL_CAM | BNL_OPC TEC (deprecated) | BNL_WBS | BNL_Actuals | BNL_FY | BNL_EVT | BNL_Master Control Account | BNL_Account Number | BNL_PCR ID | BNL_Cobra Control Account | BNL_WBS_Hierarchical | Completed | BNL_UDF_OPC TEC (deprecated) | BNL_UDF_Temp Date 01 | BNL_Institution | BNL_UDF_Adhoc Comments | BNL_Milestone Level |
| --- | --- | --- | --- | --- | --- | --- | --- | --- | --- | --- | --- | --- | --- | --- | --- | --- | --- | --- | --- | --- | --- | --- | --- | --- | --- | --- | --- | --- | --- | --- | --- | --- | --- | --- | --- | --- | --- | --- | --- | --- | --- | --- |
|  | 05 | **Integration and Installation** |  |  | 2017-02-01 | 2023-01-30 |  |  |  |  |  |  |  |  |  |  |  |  |  |  |  |  |  |  |  |  |  |  |  |  |  |  |  |  |  |  |  |  |  |  |  |  |
| S1000279 |  | Actuals - Labor - sPHENIX Integration and Installation FY17 16727 |  | 169d | 2017-02-01 A | 2017-09-29 A | S100090 SS | 100% |  |  | Actual Labor [109.11 h] | 18,231.51 | MP6LAEXCLUDE | 190315 DurType to align with EVT | S343900 | 100 | S338460 | S1000279 | CA | Completed | C | Feder, Russ | L1 | BNL | Design | Russ Feder | null | POM02.2.05 | Yes | 2017 | A | 2.05 | 16727 | 003 | 2.05 | 05 | yes |  |  |  |  |  |
| S1000319 |  | Actuals - Labor - sPHENIX Integration and Installation FY17 16728 |  | 169d | 2017-02-01 A | 2017-09-29 A | S100090 SS | 100% |  |  | Actual Labor [0.85 h] | 142.03 | MP6LAEXCLUDE | 190315 DurType to align with EVT | S343900 | 100 | S338460 | S1000319 | CA | Completed | C | Feder, Russ | L1 | BNL | Design | Russ Feder | null | POM02.2.05 | Yes | 2017 | A | 2.05 | 16728 | 003 | 2.05 | 05 | yes |  |  |  |  |  |
| S344100 |  | Actuals - Nonlabor - sPHENIX Integration and Installation FY17 |  | 169d | 2017-02-01 A | 2017-09-29 A | S100090 SS | 100% |  |  |  |  | MP6LAEXCLUDE | 190315 DurType to align with EVT | S344100 | 100 | S339422 |  | NOCA | Completed | C | Feder, Russ | M1 | BNL | Design | Russ Feder | null | POM02.2.05 | Yes | 2017 | A |  |  | 003 |  | 05 | yes |  |  |  |  |  |
| S1000359 |  | Actuals - Labor - sPHENIX Integration and Installation FY18 16727 |  | 249d | 2017-10-01 A | 2018-09-28 A | S343900, S1000279, S1000319 | 100% | 2017-10-02 | 2018-09-28 | Actual Labor [460.12 h] | 76,882.78 | MP6LAEXCLUDE | 190315 DurType to align with EVT | S344000 | 100 | S339420 | S1000359 | CA | Completed | C | Feder, Russ | L1 | BNL | Design | Russ Feder | null | POM02.2.05 | Yes | 2018 | A | 2.05 | 16727 | 003 | 2.05 | 05 | yes |  |  |  |  |  |
| S1000399 |  | Actuals - Labor - sPHENIX Integration and Installation FY18 16728 |  | 249d | 2017-10-01 A | 2018-09-28 A | S343900, S1000279, S1000319 | 100% | 2017-10-02 | 2018-09-28 | Actual Labor [3.13 h] | 523 | MP6LAEXCLUDE | 190315 DurType to align with EVT | S344000 | 100 | S339420 | S1000399 | CA | Completed | C | Feder, Russ | L1 | BNL | Design | Russ Feder | null | POM02.2.05 | Yes | 2018 | A | 2.05 | 16728 | 003 | 2.05 | 05 | yes |  |  |  |  |  |
| S1001119 |  | Actuals - Labor - sPHENIX Integration and Installation FY19 M8 16727 |  | 166d | 2018-10-01 A | 2019-05-31 A |  | 100% |  |  | Actual Labor [386.32 h] | 64,551.33 | MP6LAEXCLUDE | 190315 DurType to align with EVT | S344000 | 100 | S339420 | S1001119 | CA | Completed | C | Feder, Russ | L1 | BNL | Design | Russ Feder | null | POM02.2.05 | Yes | 2019 | A | 2.05 | 16727 | 003 | 2.05 | 05 | yes |  |  |  |  |  |
| S1001159 |  | Actuals - Labor - sPHENIX Integration and Installation FY19 M8 16728 |  | 166d | 2018-10-01 A | 2019-05-31 A |  | 100% |  |  | Actual Labor [13.65 h] | 2,280.82 | MP6LAEXCLUDE | 190315 DurType to align with EVT | S344000 | 100 | S339420 | S1001159 | CA | Completed | C | Feder, Russ | L1 | BNL | Design | Russ Feder | null | POM02.2.05 | Yes | 2019 | A | 2.05 | 16728 | 003 | 2.05 | 05 | yes |  |  |  |  |  |
| S1005080 |  | Actuals - Labor FY19 Jun-Sep 16727 |  | 84d | 2019-06-03 A | 2019-09-30 A |  | 100% |  |  | Actual Labor [230.4 h] | 38,498.2 | MP6LAEXCLUDE | 190315 DurType to align with EVT | S344000 | 100 | S339420 | S1005080 | CA | Completed | C | Feder, Russ | L1 | BNL | Design | Russ Feder | null | POM02.2.05 | Yes | 2019 | A | 2.05 | 16727 | 003 | 2.05 | 05 | yes |  |  |  |  |  |
| S1005120 |  | Actuals - Labor FY19 Jun-Sep 16728 |  | 84d | 2019-06-03 A | 2019-09-30 A |  | 100% |  |  | Actual Labor [17.91 h] | 2,991.8 | MP6LAEXCLUDE | 190315 DurType to align with EVT | S344000 | 100 | S339420 | S1005120 | CA | Completed | C | Feder, Russ | L1 | BNL | Design | Russ Feder | null | POM02.2.05 | Yes | 2019 | A | 2.05 | 16728 | 003 | 2.05 | 05 | yes |  |  |  |  |  |
|  | 01 | **Subsystem Interface & Integration Plan** |  |  | 2017-02-01 | 2021-01-27 |  |  |  |  |  |  |  |  |  |  |  |  |  |  |  |  |  |  |  |  |  |  |  |  |  |  |  |  |  |  |  |  |  |  |  |  |
| S344300 |  | Create Subsystem Interface & Integration Plan |  | 399d | 2017-02-01 A | 2018-08-31 A | S100090 SS | 100% |  |  |  |  |  |  | S344300 | 100 | S294600 |  | NOCA | Completed | C | Feder, Russ | L4 | BNL | Installation | Russ Feder | null | POM02.2.05.01 |  |  | C |  |  |  |  | 01 | yes | S294600 | 2018-08-31 | BNL |  |  |
| S344400 |  | Create Subsystem Initial Envelope Drawings |  | 40d | 2018-03-30 A | 2018-05-24 A | S344300 | 100% |  |  |  |  |  |  | S344400 | 100 | S294700 |  | NOCA | Completed | C | Feder, Russ | L4 | BNL | Design | Russ Feder | null | POM02.2.05.01 |  |  | C |  |  |  |  | 01 | yes | S294700 |  | BNL |  |  |
| S344500 |  | Create Subsystem Outline/Interface Drawings |  | 84d | 2018-06-01 A | 2018-09-28 A | S344400 | 100% |  |  |  |  |  |  | S344500 | 100 | S294800 |  | NOCA | Completed | C | Feder, Russ | L4 | BNL | Design | Russ Feder | null | POM02.2.05.01 |  |  | C |  |  |  |  | 01 | yes | S294800 | 2018-09-01 | BNL |  |  |
| S344600 |  | Create Cable Management Plan |  | 105d | 2019-01-02 A | 2019-05-31 A | S344500, S101009 SS+185d | 100% |  |  |  |  |  | 190318 ELM logic per GRY | S344600 | 5 | S294900 |  | NOCA | Completed | C | Feder, Russ | L4 | BNL | Installation | Russ Feder | null | POM02.2.05.01 |  |  | C |  | 16727 | 003 |  | 01 | yes | S294900 | 2019-08-14 | BNL |  |  |
| S344602 |  | Create Cable Management Plan Split |  | 32d | 2019-07-01 A | 2019-11-29 A | S344600 | 100% | 2019-07-01 | 2019-08-14 |  |  |  | 190318 ELM logic per GRY | S344600 | 5 | S294900 |  | NOCA | Completed | C | Feder, Russ | L4 | BNL | Installation | Russ Feder | null | POM02.2.05.01 |  |  | C | 2.05 | 16727 | 003 |  | 01 |  | S294900 | 2019-08-14 | BNL |  |  |
| S344700 |  | Create Services Management Plan |  | 20d | 2019-12-02 A | 2021-01-27 A | S344602 | 100% | 2019-12-02 | 2019-12-30 | PROF4 PO M [80 h]; TECH3 PO M [32 h]; TECH3 PO D [40 h] | 19,997.99 |  |  | S344700 | 0 | S295000 | S344700 | CA | Not Started | C | Feder, Russ | L4 | BNL | Installation | Russ Feder | null | POM02.2.05.01 |  |  | C | 2.05 | 16727 |  | 2.05 | 01 |  | S295000 | 2018-09-30 | BNL |  |  |
| S344800 |  | Create Survey Plan |  | 20d | 2020-09-15 A | 2021-01-27 A |  | 100% | 2020-10-30 | 2020-12-01 | PROF4 PO M [40 h]; TECH3 PO M [32 h]; TECH3 PO D [40 h] | 14,530.62 |  |  | S344800 | 0 | S295100 | S344800 | CA | Not Started | C | Feder, Russ | L4 | BNL | Installation | Russ Feder | null | POM02.2.05.01 |  |  | C | 2.05 | 16727 |  | 2.05 | 01 |  | S295100 | 2018-10-15 | BNL | 180220 ELM staff change per EOB |  |
| S344900 |  | Create Installation Plan |  | 20d | 2021-01-12 A | 2021-01-27 A | S344800 | 100% | 2020-03-03 | 2020-03-30 | PROF4 PO M [80 h]; TECH3 PO D [160 h] | 30,040.74 |  |  | S344900 | 0 | S295150 | S344900 | CA | Not Started | C | Feder, Russ | L4 | BNL | Installation | Russ Feder | null | POM02.2.05.01 |  |  | C | 2.05 | 16727 |  | 2.05 | 01 |  | S295200 |  | BNL |  |  |
| S345000 |  | Review Integration and Installation Plan Design/Safety |  | 2d | 2021-01-12 A | 2021-01-27 A | S344800, S344900, S344700 | 100% | 2021-03-10 | 2021-03-11 | PROF4 PO M [20 h]; TECH3 PO D [20 h]; SCI3 PO [20 h] | 8,929.95 |  |  | S345000 | 0 | S295200 | S345000 | CA | Not Started | C | Feder, Russ | L4 | BNL | Installation | Russ Feder | null | POM02.2.05.01 |  |  | C | 2.05 | 16727 |  | 2.05 | 01 |  | S295200 |  | BNL |  |  |
| S345100 |  | Review Cable Management Plan |  | 2d | 2021-01-12 A | 2021-01-27 A | S345000 | 100% | 2021-03-12 | 2021-03-15 | PROF4 PO M [20 h]; TECH3 PO D [10 h]; PROF4 PO E [10 h] | 5,725.95 |  |  | S345100 | 0 | S295300 | S345100 | CA | Not Started | C | Feder, Russ | L4 | BNL | Design | Russ Feder | null | POM02.2.05.01 |  |  | C | 2.05 | 16727 |  | 2.05 | 01 |  | S295300 |  | BNL |  |  |
| S345200 |  | Review Survey Plan |  | 2d | 2021-01-12 A | 2021-01-27 A | S345100 | 100% | 2021-03-16 | 2021-03-17 | PROF4 PO M [10 h]; TECH3 PO M [10 h]; TECH3 PO D [10 h] | 3,867.75 |  |  | S345200 | 0 | S295400 | S345200 | CA | Not Started | C | Feder, Russ | L4 | BNL | Installation | Russ Feder | null | POM02.2.05.01 |  |  | C | 2.05 | 16727 |  | 2.05 | 01 |  | S295400 |  | BNL | 180220 ELM staff change per EOB |  |
| S345300 |  | Address Action Items from Subsystem Interface & Integration Plans (Interface, Integration, Cable Management and Survey P |  | 2d | 2021-01-12 A | 2021-01-27 A | S345200 | 100% | 2021-03-18 | 2021-03-19 | PROF4 PO M [10 h]; TECH3 PO M [10 h]; TECH3 PO D [10 h] | 3,867.75 |  |  | S345300 | 0 | S295500 | S345300 | CA | Not Started | C | Feder, Russ | L4 | BNL | Installation | Russ Feder | null | POM02.2.05.01 |  |  | C | 2.05 | 16727 |  | 2.05 | 01 |  | S295500 |  | BNL |  |  |
| S345400 |  | Design/Safety Reviews Complete, Ready to Begin Installation | milestone | 0d | 2021-01-27 A | 2021-01-27 A | S345300 | 100% | 2021-03-19 | 2021-03-19 |  |  |  |  | S345400 | 0 | S295600 |  | NOCA | Not Started | C | Feder, Russ |  | BNL | Management Safety Reviews | Russ Feder |  | POM02.2.05.01 |  |  |  |  |  |  |  | 01 |  | S295600 |  | BNL |  | L3 |

Notes:
- S1000279: BNL_UDF_Old Activity Name 181221: Actuals - Labor - sPHENIX Integration and Installation FY17
- S1000319: BNL_UDF_Old Activity Name 181221: Actuals - Labor - sPHENIX Integration and Installation FY17
- S344100: BNL_UDF_Old Activity Name 181221: Actuals - Nonlabor - sPHENIX Integration and Installation FY17
- S1000359: BNL_UDF_Old Activity Name 181221: Actuals - Labor - sPHENIX Integration and Installation FY18
- S1000399: BNL_UDF_Old Activity Name 181221: Actuals - Labor - sPHENIX Integration and Installation FY18
- S1001119: BNL_UDF_Old Activity Name 181221: Actuals - Labor - sPHENIX Integration and Installation FY18
- S1001159: BNL_UDF_Old Activity Name 181221: Actuals - Labor - sPHENIX Integration and Installation FY18
- S1005080: BNL_UDF_Old Activity Name 181221: Actuals - Labor - sPHENIX Integration and Installation FY18
- S1005120: BNL_UDF_Old Activity Name 181221: Actuals - Labor - sPHENIX Integration and Installation FY18
- S344300: BNL_UDF_Old Activity Name 181221: Create Subsystem Interface & Integration Plan
- S344400: BNL_UDF_Old Activity Name 181221: Create Subsystem Initial Envelope Drawings
- S344500: BNL_UDF_Old Activity Name 181221: Create Subsystem Outline/Interface Drawings
- S344600: BNL_UDF_Old Activity Name 181221: Create Cable Management Plan
- S344602: BNL_UDF_Old Activity Name 181221: Create Cable Management Plan
- S344700: BNL_UDF_Old Activity Name 181221: Create Services Management Plan
- S344800: BNL_UDF_Old Activity Name 181221: Create Survey Plan
- S344900: BNL_UDF_Old Activity Name 181221: Create Installation Plan
- S345000: BNL_UDF_Old Activity Name 181221: Review Integration and Installation Plan Design/Safety
- S345100: BNL_UDF_Old Activity Name 181221: Review Cable Management Plan
- S345200: BNL_UDF_Old Activity Name 181221: Review Survey Plan
- S345300: BNL_UDF_Old Activity Name 181221: Address Action Items from Subsystem Interface & Integration Plans (Interface, Integration, Cable Management and Survey P
- S345400: BNL_UDF_Old Activity Name 181221: Design/Safety Reviews Complete, Ready to Begin Installation

| ID | WBS | Activity | Type | Duration | Start | Finish | Predecessors | Complete | Planned start | Planned finish | Total float | Free float | Resources | Cost | BNL_UDF_Temp Text 01 | BNL_UDF_Adhoc Comments | BNL_UDF_Percent Complete | BNL_UDF_Sort Order | BNL_UDF_OPC TEC (deprecated) | BNL_UDF_Old Activity ID 181221 | BNL_Cobra WP | RG Check | BNL_Activity Status | BNL_Fund Source | BNL_Estimator | BNL_Cost Basis | BNL_Location | BNL_EDIA | BNL_CAM | BNL_Institution | BNL_OPC TEC (deprecated) | BNL_WBS | BNL_EVT | BNL_Master Control Account | BNL_Account Number | BNL_Cobra Control Account | BNL_WBS_Hierarchical | Temp | BNL_UDF_Temp Text 02 | Indicator - Procurement | Indicator - Float | BNL_UDF_Remaining Tot Cost | BNL_UDF_Percent_remaining | BNL_UDF_Status Comments | BNL_PCR ID | BNL_Milestone Level |
| --- | --- | --- | --- | --- | --- | --- | --- | --- | --- | --- | --- | --- | --- | --- | --- | --- | --- | --- | --- | --- | --- | --- | --- | --- | --- | --- | --- | --- | --- | --- | --- | --- | --- | --- | --- | --- | --- | --- | --- | --- | --- | --- | --- | --- | --- | --- |
|  | 02 | **Infrastructure Installation** |  |  | 2021-02-22 | 2022-09-12 |  |  |  |  |  |  |  |  |  |  |  |  |  |  |  |  |  |  |  |  |  |  |  |  |  |  |  |  |  |  |  |  |  |  |  |  |  |  |  |  |
| S346500 |  | Install Cryogenics Supply Structural Support - Labor - Physics Resource(s) |  | 20d | 2021-02-22 A | 2021-02-26 A | S338200 | 100% | 2021-03-02 | 2021-03-29 |  |  | PROF4 PO M [80 h]; TECH3 PO M [80 h]; TECH3 PO D [16 h] | 23,419.03 | PO&AD | 180227 ELM rsrc assign per DLynch | 0 | 1030 | S296500 | S296500 | S346500 | CA | Not Started | C | Feder, Russ | L4 | BNL | Installation | Russ Feder | BNL | null | POM02.2.05.02 | C | 2.05 | 16727 | 2.05 | 02 | PO |  |  |  |  |  |  |  |  |
| S346510 |  | Install Cryogenics Supply Structural Support - Labor - CA-D Resource(s) |  | 20d | 2021-02-22 A | 2021-02-26 A | S346500 SS | 100% | 2021-03-02 | 2021-03-29 |  |  | TECH3 AD [80 h]; CRAFT3 [160 h]; PROF2 AD [80 h]; PROF4 AD [32 h]; PROF6 AD [8 h] | 44,717.6 | PO&ADS346510 | 180227 ELM rsrc assign per DLynch | 0 | 1030 | S296500 | S296500 | S346510 | CA | Not Started | C | Feder, Russ | L4 | BNL | Installation | Russ Feder | BNL | null | POM02.2.05.02 | C | 2.05 | 16728 | 2.05 | 02 | C-AD | S346510 |  |  |  |  |  |  |  |
| S346600 |  | Install Cryogenics Supply Structural Support - M&S |  | 20d | 2021-02-22 A | 2021-02-26 A | S346500 SS, S346510 SS | 100% | 2021-03-02 | 2021-03-29 |  |  | Material (Purchase (1st $2M) [500 h] | 580.34 | S346600 |  | 0 | 1030 | S296600 | S296600 | S346600 | CA | Not Started | C | Feder, Russ | M4 | BNL | Fab & Assy | Russ Feder | BNL | null | POM02.2.05.02 | C | 2.05 | 16727 | 2.05 | 02 |  |  | UDF_G2 | UDF_G3 | 580.342155 | 1 |  |  |  |
| S345500 |  | Install IR HVAC - Labor - C-AD Resources |  | 10d | 2021-12-21 | 2022-01-05 | S101000, S340500 |  |  |  | 174d | 0d | TECH3 AD [40 h]; CRAFT3 [64 h]; PROF2 AD [40 h]; PROF4 AD [40 h] | 23,837.17 | S345500 | 180227 ELM rsrc assign per DLynch | 0 | 1000 | S295700 | S295700 | S345500 | CA | Not Started | C | Feder, Russ | L4 | BNL | Installation | Russ Feder | BNL | null | POM02.2.05.02 | C | 2.05 | 16728 | 2.05 | 02 |  |  |  |  |  |  |  |  |  |
| S345600 |  | Install IR HVAC - M&S |  | 10d | 2021-12-21 | 2022-01-05 | S345500 SS |  |  |  | 174d |  | Material (Purchase (1st $2M) [500 h] | 591.95 | S345600 |  | 0 | 1000 | S295800 | S295800 | S345600 | CA | Not Started | C | Feder, Russ | M4 | BNL | Fab & Assy | Russ Feder | BNL | null | POM02.2.05.02 | C | 2.05 | 16727 | 2.05 | 02 |  |  | UDF_G1 | UDF_G3 | 580.342155 | 1 |  |  |  |
| S347700 |  | Install IR Electronics Cooling Water On Detector - Labor - Physics Resources |  | 20d | 2021-12-30 | 2022-01-28 | S349410 |  |  |  | 158d | 0d | TECH3 PO M [80 h]; TECH3 PO D [16 h]; CRAFT3 [32 h]; PROF4 PO E [20 h] | 18,993.62 | S347700 | 180227 ELM rsrc assign per DLynch | 0 |  | S297500 | S297520 | S347700 | CA | Not Started | C | Feder, Russ | L4 | BNL | Installation | Russ Feder | BNL | null | POM02.2.05.02 | C | 2.05 | 16727 | 2.05 | 02 |  |  |  |  |  |  |  |  |  |
| S347810 |  | Install IR Electronics Cooling Water On Detector - M&S |  | 20d | 2021-12-30 | 2022-01-28 | S347700 SS |  |  |  | 158d |  | Material (Purchase (1st $2M) [500 h] | 591.95 | S347800 |  | 0 |  | S297600 |  | S347810 | CA | Not Started | C | Feder, Russ | M4 | BNL | Fab & Assy | Russ Feder | BNL | null | POM02.2.05.02 | C | 2.05 | 16727 | 2.05 | 02 |  |  | UDF_G2 | UDF_G3 | 591.948995 | 1 |  |  |  |
| S347600 |  | Install IR Electronics Cooling Water Off Detector - Labor - C-AD Resources |  | 20d | 2022-01-21 | 2022-02-17 | S341600 |  |  |  | 144d | 0d | TECH3 AD [80 h]; CRAFT3 [80 h]; PROF2 AD [20 h]; PROF4 AD [8 h] | 23,677.15 | S347600 | 180227 ELM rsrc assign per DLynch | 0 | 1050 | S297500 | S297500 | S347600 | CA | Not Started | C | Feder, Russ | L4 | BNL | Installation | Russ Feder | BNL | null | POM02.2.05.02 | C | 2.05 | 16728 | 2.05 | 02 |  |  |  |  |  |  |  |  |  |
| S347800 |  | Install IR Electronics Cooling Water Off Detector - M&S |  | 20d | 2022-01-21 | 2022-02-17 | S347600 SS |  |  |  | 144d |  | Material (Purchase (1st $2M) [500 h] | 591.95 | S347800 |  | 0 | 1050 | S297600 | S297600 | S347800 | CA | Not Started | C | Feder, Russ | M4 | BNL | Fab & Assy | Russ Feder | BNL | null | POM02.2.05.02 | C | 2.05 | 16727 | 2.05 | 02 |  |  | UDF_G3 | UDF_G3 | 580.342155 | 1 |  |  |  |
| S1003679 |  | Install Line Electric Power Distribution Off Detector - Labor - Physics Resource(s) |  | 20d | 2022-01-24 | 2022-02-18 | S329300 |  |  |  | 123d | 0d | CRAFT3 [160 h]; PROF4 PO E [40 h]; PROF6 AD [4 h] | 28,298.43 | S346000 | 180227 ELM rsrc assign per DLynch | 0 | 1020 | S296100 | S296100 | S1003679 | CA | Not Started | C | Feder, Russ | L4 | BNL | Installation | Russ Feder | BNL | null | POM02.2.05.02 | C | 2.05 | 16727 | 2.05 | 02 |  |  |  |  |  |  |  |  |  |
| S346000 |  | Install Line Electric Power Distribution Off Detector - Labor - CA-D Resource(s) |  | 20d | 2022-01-24 | 2022-02-18 | S329300 |  |  |  | 123d | 0d | PROF4 AD [32 h] | 4,999.47 | S346000 | 180227 ELM rsrc assign per DLynch | 0 | 1020 | S296100 | S296100 | S346000 | CA | Not Started | C | Feder, Russ | L4 | BNL | Installation | Russ Feder | BNL | null | POM02.2.05.02 | C | 2.05 | 16727 | 2.05 | 02 |  |  |  |  |  |  |  |  |  |
| S346200 |  | Install Line Electric Power Distribution Off Detector - M&S |  | 20d | 2022-01-24 | 2022-02-18 | S346000 SS, S1003679 SS |  |  |  | 123d | 0d | Material (Purchase (1st $2M) [500 h] | 591.95 | S346200 |  | 0 | 1020 | S296200 | S296200 | S346200 | CA | Not Started | C | Feder, Russ | M4 | BNL | Fab & Assy | Russ Feder | BNL | null | POM02.2.05.02 | C | 2.05 | 16727 | 2.05 | 02 |  |  | UDF_G2 | UDF_G3 | 582.663523 | 1 |  |  |  |
| S1003759 |  | Install Line Electric Power Distribution On Detector - Labor - Physics Resource(s) |  | 20d | 2022-02-22 | 2022-03-21 | S346000, S346200, S1003679 |  |  |  | 123d | 0d | CRAFT3 [80 h]; PROF4 PO E [40 h] | 16,864.39 | S346100 | 180227 ELM rsrc assign per DLynch | 0 | 1021 | S296100 | S296150 | S1003759 | CA | Not Started | C | Feder, Russ | L4 | BNL | Installation | Russ Feder | BNL | null | POM02.2.05.02 | C | 2.05 | 16727 | 2.05 | 02 |  |  |  |  |  |  | 190318 ELM logic per GRY | 003 |  |
| S346100 |  | Install Line Electric Power Distribution On Detector - Labor - CA-D Resource(s) |  | 20d | 2022-02-22 | 2022-03-21 | S346000, S346200, S1003679 |  |  |  | 123d | 0d | PROF4 AD [32 h]; PROF6 AD [4 h] | 5,818.45 | S346100 | 180227 ELM rsrc assign per DLynch | 0 | 1021 | S296100 | S296150 | S346100 | CA | Not Started | C | Feder, Russ | L4 | BNL | Installation | Russ Feder | BNL | null | POM02.2.05.02 | C | 2.05 | 16727 | 2.05 | 02 |  |  |  |  |  |  | 190318 ELM logic per GRY | 003 |  |
| S346210 |  | Install Line Electric Power Distribution On Detector - M&S |  | 20d | 2022-02-22 | 2022-03-21 | S346100 SS, S1003759 SS |  |  |  | 123d |  | Material (Purchase (1st $2M) [500 h] | 591.95 | S346200 |  | 0 | 1021 | S296200 |  | S346210 | CA | Not Started | C | Feder, Russ | M4 | BNL | Fab & Assy | Russ Feder | BNL | null | POM02.2.05.02 | C | 2.05 | 16727 | 2.05 | 02 |  |  | UDF_G2 | UDF_G3 | 591.948995 | 1 |  |  |  |
| S345700 |  | Install Off Detector Safety Subsystems - Labor - C-AD Resources |  | 20d | 2022-02-24 | 2022-03-23 | S342700 |  |  |  | 121d | 0d | TECH3 AD [80 h]; PROF4 AD [16 h]; CRAFT3 [24 h]; PROF2 AD [40 h] | 19,622.93 | S345700 |  | 0 | 1000 | S295900 | S295850 | S345700 | CA | Not Started | C | Feder, Russ | L4 | BNL | Installation | Russ Feder | BNL | null | POM02.2.05.02 | C | 2.05 | 16728 | 2.05 | 02 |  |  |  |  |  |  |  |  |  |
| S345910 |  | Install Off Detector Safety Subsystems - M&S |  | 20d | 2022-02-24 | 2022-03-23 | S345700 SS |  |  |  | 121d |  | Material (Purchase (1st $2M) [500 h] | 591.95 | S345900 |  | 0 | 1000 | S296000 |  | S345910 | CA | Not Started | C | Feder, Russ | M4 | BNL | Fab & Assy | Russ Feder | BNL | null | POM02.2.05.02 | C | 2.05 | 16727 | 2.05 | 02 |  |  | UDF_G1 | UDF_G3 | 580.342155 | 1 |  |  |  |
| S347100 |  | Install Electronics Racks Rackroom - Labor |  | 60d | 2022-03-24 | 2022-06-16 | S331600 |  |  |  | 1d | 0d | PROF4 PO M [120 h]; TECH3 PO E [280 h]; TECH3 PO M [280 h]; TECH3 PO D [48 h]; PROF4 PO E [120 h] | 111,107.91 | S347100 | 180227 ELM rsrc assign per DLynch | 0 | 1040 | S297100 | S297100 | S347100 | CA | Not Started | C | Feder, Russ | L4 | BNL | Installation | Russ Feder | BNL | null | POM02.2.05.02 | C | 2.05 | 16727 | 2.05 | 02 |  |  |  |  |  |  |  |  |  |
| S347300 |  | Install Electronics Racks Rackroom - M&S |  | 60d | 2022-03-24 | 2022-06-16 | S347100 SS |  |  |  | 61d |  | Material (Purchase (1st $2M) [500 h] | 591.95 | S347300 |  | 0 | 1040 | S297300 | S297300 | S347300 | CA | Not Started | C | Feder, Russ | M4 | BNL | Fab & Assy | Russ Feder | BNL | null | POM02.2.05.02 | C | 2.05 | 16727 | 2.05 | 02 |  |  | UDF_G2 | UDF_G3 | 591.948995 | 1 |  |  |  |
| S345800 |  | Install On Detector Safety Subsystems - Labor |  | 20d | 2022-04-21 | 2022-05-18 | S333800 |  |  |  | 81d | 0d | TECH3 PO E [80 h]; TECH3 PO M [40 h]; PROF4 PO E [20 h]; PROF4 PO M [20 h] | 20,778 | S345800 |  | 0 | 1010 | S295900 | S295900 | S345800 | CA | Not Started | C | Feder, Russ | L4 | BNL | Installation | Russ Feder | BNL | null | POM02.2.05.02 | C | 2.05 | 16727 | 2.05 | 02 |  |  |  |  |  |  |  |  |  |
| S345900 |  | Install On Detector Safety Subsystems - M&S |  | 20d | 2022-04-21 | 2022-05-18 | S345800 SS |  |  |  | 81d |  | Material (Purchase (1st $2M) [500 h] | 591.95 | S345900 |  | 0 | 1010 | S296000 | S296000 | S345900 | CA | Not Started | C | Feder, Russ | M4 | BNL | Fab & Assy | Russ Feder | BNL | null | POM02.2.05.02 | C | 2.05 | 16727 | 2.05 | 02 |  |  | UDF_G1 | UDF_G3 | 591.948995 | 1 |  |  |  |
| S347200 |  | Install Electronics Racks On Carriage - Labor |  | 60d | 2022-06-17 | 2022-09-12 | S347100, S349410 |  |  |  | 1d | 0d | PROF4 PO M [120 h]; TECH3 PO E [280 h]; TECH3 PO M [280 h]; TECH3 PO D [48 h]; PROF4 PO E [120 h] | 111,107.91 | S347200 | 180227 ELM rsrc assign per DLynch | 0 | 1041 | S297100 | S297150 | S347200 | CA | Not Started | C | Feder, Russ | L4 | BNL | Installation | Russ Feder | BNL | null | POM02.2.05.02 | C | 2.05 | 16727 | 2.05 | 02 |  |  |  |  |  |  |  |  |  |
| S347310 |  | Install Electronics Racks On Carriage - M&S |  | 60d | 2022-06-17 | 2022-09-12 | S347200 SS |  |  |  | 1d |  | Material (Purchase (1st $2M) [500 h] | 591.95 | S347300 |  | 0 | 1041 | S297300 |  | S347310 | CA | Not Started | C | Feder, Russ | M4 | BNL | Fab & Assy | Russ Feder | BNL | null | POM02.2.05.02 | C | 2.05 | 16727 | 2.05 | 02 |  |  | UDF_G2 | UDF_G1 | 591.948995 | 1 |  |  |  |
| S347400 |  | Install Gas and Cooling System Services - Labor |  | 40d | 2022-06-29 | 2022-08-24 | S332700 |  |  |  | 13d | 0d | PROF4 PO M [120 h]; TECH3 PO M [720 h]; TECH3 PO D [96 h] | 117,542.91 | S347400 | 180227 ELM rsrc assign per DLynch | 0 | 1041 | S297200 | S297350 | S347400 | CA | Not Started | C | Feder, Russ | L4 | BNL | Installation | Russ Feder | BNL | null | POM02.2.05.02 | C | 2.05 | 16727 | 2.05 | 02 |  |  |  |  |  |  |  |  |  |
| S347500 |  | Install Gas and Cooling System Services - M&S |  | 40d | 2022-06-29 | 2022-08-24 | S347400 SS |  |  |  | 13d |  | Material (Purchase (1st $2M) [500 h] | 591.95 | S347500 |  | 0 | 1041 | S297400 | S297400 | S347500 | CA | Not Started | C | Feder, Russ | M4 | BNL | Fab & Assy | Russ Feder | BNL | null | POM02.2.05.02 | C | 2.05 | 16727 | 2.05 | 02 |  |  | UDF_G2 | UDF_G1 | 591.948995 | 1 |  |  |  |
| S346700 |  | Install Non-IR Infrastructure - Labor - Physics Resource(s) |  | 35d | 2022-07-14 | 2022-08-31 | S334900, S343800, S336000, S337100 |  |  |  | 8d | 0d | PROF4 PO M [80 h]; TECH3 PO E [160 h]; TECH3 PO M [160 h]; TECH3 PO D [40 h]; PROF4 PO E [80 h] | 68,583.34 | PO&AD |  | 0 | 1030 | S296700 | S296700 | S346700 | CA | Not Started | C | Feder, Russ | L4 | BNL | Installation | Russ Feder | BNL | null | POM02.2.05.02 | C | 2.05 | 16727 | 2.05 | 02 | PO |  |  |  |  |  | 190318 ELM name per GRY | 003 |  |
| S346710 |  | Install Non-IR Infrastructure - Labor - CA-D Resource(s) |  | 35d | 2022-07-14 | 2022-08-31 | S346700 SS |  |  |  | 8d | 0d | TECH3 AD [160 h]; CRAFT3 [160 h]; PROF2 AD [20 h]; PROF4 AD [8 h] | 43,977.97 | PO&ADS346710 |  | 0 | 1030 | S296700 | S296700 | S346710 | CA | Not Started | C | Feder, Russ | L4 | BNL | Installation | Russ Feder | BNL | null | POM02.2.05.02 | C | 2.05 | 16728 | 2.05 | 02 | C-AD | S346710 |  |  |  |  | 190318 ELM name per GRY | 003 |  |
| S346800 |  | Install Non-IR Infrastructure - M&S |  | 35d | 2022-07-14 | 2022-08-31 | S346700 SS, S346710 SS |  |  |  | 8d |  | Material (Purchase (1st $2M) [500 h] | 591.95 | S346800 |  | 0 | 1030 | S296800 | S296800 | S346800 | CA | Not Started | C | Feder, Russ | M4 | BNL | Fab & Assy | Russ Feder | BNL | null | POM02.2.05.02 | C | 2.05 | 16727 | 2.05 | 02 |  |  | UDF_G2 | UDF_G1 | 591.948995 | 1 | 190318 ELM name per GRY | 003 |  |
| S1002159 |  | Install Detector Support Services Systems - Labor - Physics Resource(s) |  | 20d | 2022-07-29 | 2022-08-25 | S330400, S349410 |  |  |  | 12d | 0d | TECH3 PO D [32 h]; CRAFT3 [200 h]; PROF4 PO E [80 h]; TECH3 PO E [200 h]; TECH3 PO M [200 h] | 91,339.49 | S346900 | 180227 ELM rsrc assign per DLynch | 0 | 1030 | S296900 | S296900 | S1002159 | CA | Not Started | C | Feder, Russ | L4 | BNL | Installation | Russ Feder | BNL | null | POM02.2.05.02 | C | 2.05 | 16727 | 2.05 | 02 |  |  |  |  |  |  |  |  |  |
| S346900 |  | Install Detector Support Services Systems - Labor - CA-D Resource(s) |  | 20d | 2022-07-29 | 2022-08-25 | S330400, S349410 |  |  |  | 12d | 0d | PROF2 AD [40 h] | 4,252.9 | S346900 | 180227 ELM rsrc assign per DLynch | 0 | 1030 | S296900 | S296900 | S346900 | CA | Not Started | C | Feder, Russ | L4 | BNL | Installation | Russ Feder | BNL | null | POM02.2.05.02 | C | 2.05 | 16727 | 2.05 | 02 |  |  |  |  |  |  |  |  |  |
| S347000 |  | Install Detector Support Services Systems - M&S |  | 20d | 2022-07-29 | 2022-08-25 | S346900 SS, S1002159 SS |  |  |  | 12d |  | Material (Purchase (1st $2M) [500 h] | 591.95 | S347000 |  | 0 | 1030 | S297000 | S297000 | S347000 | CA | Not Started | C | Feder, Russ | M4 | BNL | Fab & Assy | Russ Feder | BNL | null | POM02.2.05.02 | C | 2.05 | 16727 | 2.05 | 02 |  |  | UDF_G1 | UDF_G1 | 591.948995 | 1 |  |  |  |
| S346300 |  | Install Beampipe/Vacuum/Bakeout - Labor - Physics Resource(s) |  | 7d | 2022-08-01 | 2022-08-09 | S339400, S361100, S361200, S361110, S318190, S339350 |  |  |  | 0d |  | PROF4 PO M [20 h]; TECH3 PO M [40 h]; TECH3 PO D [16 h] | 9,904.71 | PO&AD | 180416 ELM pred/succ per GRY; 180413 ELM pred/succ per GRY | 0 | 1030 | S296300 | S296300 | S346300 | CA | Not Started | C | Feder, Russ | L4 | BNL | Installation | Russ Feder | BNL | null | POM02.2.05.02 | C | 2.05 | 16727 | 2.05 | 02 | PO |  |  |  |  |  | 190328 dur per EOB | 008C |  |
| S346310 |  | Install Beampipe/Vacuum/Bakeout - Labor - CA-D Resource(s) |  | 7d | 2022-08-01 | 2022-08-09 | S346300 SS, S318190 |  |  |  | 0d |  | TECH3 AD [104 h]; PROF2 AD [80 h]; PROF4 AD [40 h] | 27,346.65 | PO&ADS346310 | 180416 ELM pred/succ per GRY; 180413 ELM pred/succ per GRY | 0 | 1030 | S296300 | S296300 | S346310 | CA | Not Started | C | Feder, Russ | L4 | BNL | Installation | Russ Feder | BNL | null | POM02.2.05.02 | C | 2.05 | 16728 | 2.05 | 02 | C-AD | S346310 |  |  |  |  | 190328 dur per EOB | 008C |  |
| S346400 |  | Install Beampipe/Vacuum/Bakeout - M&S |  | 7d | 2022-08-01 | 2022-08-09 | S346300 SS, S361100, S361200, S346310 SS, S361110, S318190 |  |  |  | 0d |  | Material (Purchase (1st $2M) [500 h] | 591.95 | S346400 | 180416 ELM pred/succ per GRY | 0 | 1030 | S296400 | S296400 | S346400 | CA | Not Started | C | Feder, Russ | M4 | BNL | Fab & Assy | Russ Feder | BNL | null | POM02.2.05.02 | C | 2.05 | 16727 | 2.05 | 02 |  |  | UDF_G2 | UDF_G1 | 591.948995 | 1 |  | 008C |  |
| S346410 |  | Completed - Install Beampipe | milestone | 0d | 2022-08-09 | 2022-08-09 | S346300 FF, S346310 FF, S346400 FF |  |  |  | 0d |  |  |  | S346400 | 180416 ELM pred/succ per GRY | 0 | 1030 | S296400 | S296400 |  | NOCA | Not Started | C | Feder, Russ |  | BNL | Fab & Assy | Russ Feder | BNL |  | POM02.2.05.02 |  |  |  |  | 02 |  |  |  |  |  |  |  |  | L3 |

Notes:
- S346500: BNL_UDF_Old Activity Name 181221: Install Cryogenics Supply Structural Support - Labor
- S346510: BNL_UDF_Old Activity Name 181221: Install Cryogenics Supply Structural Support - Labor
- S346600: BNL_UDF_Old Activity Name 181221: Install Cryogenics Supply Structural Support - M&S
- S345500: BNL_UDF_Old Activity Name 181221: Install IR HVAC - Labor
- S345600: BNL_UDF_Old Activity Name 181221: Install IR HVAC - M&S
- S347700: BNL_UDF_Old Activity Name 181221: Install IR Electronics Cooling Water On Detector - Labor
- S347810: BNL_UDF_Old Activity Name 181221: Install IR Electronics Cooling Water - M&S
- S347600: BNL_UDF_Old Activity Name 181221: Install IR Electronics Cooling Water Off Detector - Labor
- S347800: BNL_UDF_Old Activity Name 181221: Install IR Electronics Cooling Water - M&S
- S1003679: BNL_UDF_Old Activity Name 181221: Install Line Electric Power Distribution Off Detector - Labor
- S346000: BNL_UDF_Old Activity Name 181221: Install Line Electric Power Distribution Off Detector - Labor
- S346200: BNL_UDF_Old Activity Name 181221: Install Line Electric Power Distribution - M&S
- S1003759: BNL_UDF_Old Activity Name 181221: Install Line Electric Power Distribution On Detector - Labor
- S346100: BNL_UDF_Old Activity Name 181221: Install Line Electric Power Distribution On Detector - Labor
- S346210: BNL_UDF_Old Activity Name 181221: Install Line Electric Power Distribution - M&S
- S345700: BNL_UDF_Old Activity Name 181221: Install Off Detector Safety Subsystems - Labor
- S345910: BNL_UDF_Old Activity Name 181221: Install On Detector and Off Detector Safety Subsystems - M&S
- S347100: BNL_UDF_Old Activity Name 181221: Install Electronics Racks Rackroom - Labor
- S347300: BNL_UDF_Old Activity Name 181221: Install Electronics Racks - M&S
- S345800: BNL_UDF_Old Activity Name 181221: Install On Detector Safety Subsystems - Labor
- S345900: BNL_UDF_Old Activity Name 181221: Install On Detector and Off Detector Safety Subsystems - M&S
- S347200: BNL_UDF_Old Activity Name 181221: Install Electronics Racks On Carriage - Labor
- S347310: BNL_UDF_Old Activity Name 181221: Install Electronics Racks - M&S
- S347400: Scheduler's Notes: 180413 ELM per GRY: / assume 2 people / BNL_UDF_Old Activity Name 181221: Install Gas and Cooling System Services - Labor
- S347500: BNL_UDF_Old Activity Name 181221: Install Gas and Cooling System Services - M&S
- S346700: BNL_UDF_Old Activity Name 181221: (Planning Package) Install Non-IR Infrastructure - Labor
- S346710: BNL_UDF_Old Activity Name 181221: (Planning Package) Install Non-IR Infrastructure - Labor
- S346800: BNL_UDF_Old Activity Name 181221: Install Non-IR Infrastructure - M&S
- S1002159: BNL_UDF_Old Activity Name 181221: Install Detector Support Services Systems - Labor
- S346900: BNL_UDF_Old Activity Name 181221: Install Detector Support Services Systems - Labor
- S347000: BNL_UDF_Old Activity Name 181221: Install Detector Support Services Systems - M&S
- S346300: BNL_UDF_Old Activity Name 181221: Install Beampipe/Vacuum/Bakeout - Labor
- S346310: BNL_UDF_Old Activity Name 181221: Install Beampipe/Vacuum/Bakeout - Labor
- S346400: BNL_UDF_Old Activity Name 181221: Install Beampipe/Vacuum/Bakeout - M&S
- S346410: BNL_UDF_Old Activity Name 181221: Install Beampipe/Vacuum/Bakeout - M&S

| ID | WBS | Activity | Type | Duration | Start | Finish | Predecessors | Complete | Remaining | Planned start | Planned finish | Total float | Expected finish | Resources | Cost | BNL_UDF_Temp Text 01 | BNL_UDF_Percent Complete | BNL_UDF_OPC TEC (deprecated) | BNL_UDF_Old Activity ID 181221 | BNL_Cobra WP | RG Check | BNL_Activity Status | BNL_Fund Source | BNL_Estimator | BNL_Cost Basis | BNL_Location | BNL_EDIA | BNL_CAM | BNL_Institution | BNL_OPC TEC (deprecated) | BNL_WBS | BNL_EVT | BNL_Master Control Account | BNL_Account Number | BNL_Cobra Control Account | BNL_WBS_Hierarchical | Temp | BNL_UDF_Temp Text 02 | Additional EVT documentation required | BNL_UDF_Exclude | Indicator - Procurement | Indicator - Float | BNL_UDF_Remaining Tot Cost | BNL_UDF_Percent_remaining | BNL_Proc Sig | BNL_Milestone Level | BNL_UDF_Status Comments | Target Milestone Date | Variance | BNL_PCR ID | PMP Milestones |
| --- | --- | --- | --- | --- | --- | --- | --- | --- | --- | --- | --- | --- | --- | --- | --- | --- | --- | --- | --- | --- | --- | --- | --- | --- | --- | --- | --- | --- | --- | --- | --- | --- | --- | --- | --- | --- | --- | --- | --- | --- | --- | --- | --- | --- | --- | --- | --- | --- | --- | --- | --- |
|  | 03 | **Cradle Carriage Assembly/Installation** |  |  | 2019-10-01 | 2022-03-21 |  |  |  |  |  |  |  |  |  |  |  |  |  |  |  |  |  |  |  |  |  |  |  |  |  |  |  |  |  |  |  |  |  |  |  |  |  |  |  |  |  |  |  |  |  |
| S347900 |  | Design Cradle Carriage Integration/Installation Tooling/Fixtures - Physics Resource(s) |  | 40d | 2019-10-01 A | 2020-02-05 A | S101000, S310100, S310110 | 100% |  | 2019-10-01 | 2019-11-27 |  |  | PROF4 PO M [20 h]; TECH3 PO D [160 h] | 21,204.84 | PO&AD | 0 | S297700 | S297700 | S347900 | CA | In Progress | C | Feder, Russ | L4 | BNL | Installation | Russ Feder | BNL | null | POM02.2.05.03 | C | 2.05 | 16727 | 2.05 | 03 | PO |  |  |  |  |  |  |  |  |  |  |  |  |  |  |
| S347910 |  | Design Cradle Carriage Integration/Installation Tooling/Fixtures - CA-D Resource(s) |  | 40d | 2019-10-01 A | 2020-02-05 A | S347900 SS | 100% |  | 2019-10-01 | 2019-11-27 |  |  | PROF4 AD [80 h]; TECH4 AD [80 h] | 22,228.78 | PO&ADS347910 | 0 | S297700 | S297700 | S347910 | CA | In Progress | C | Feder, Russ | L4 | BNL | Installation | Russ Feder | BNL | null | POM02.2.05.03 | C | 2.05 | 16728 | 2.05 | 03 | C-AD | S347910 |  |  |  |  |  |  |  |  |  |  |  |  |  |
| S348000 |  | Fabricate/Procure Cradle Carriage Integration/Installation Tooling/Fixtures - Labor - Physics Resourc |  | 120d | 2020-05-01 A | 2020-09-30 A | S347900, S101000, S347910 | 100% |  | 2020-05-01 | 2020-10-21 |  |  | PROF4 PO M [48 h]; TECH3 PO D [160 h] | 25,416.91 | PO&AD | 0 | S297800 | S297800 | S348000 | CA | Not Started | C | Feder, Russ | L4 | BNL | Fab & Assy | Russ Feder | BNL | null | POM02.2.05.03 | C | 2.05 | 16727 | 2.05 | 03 | PO |  | Yes |  |  |  |  |  |  |  |  |  |  |  |  |
| S348010 |  | Fabricate/Procure Cradle Carriage Integration/Installation Tooling/Fixtures - Labor - CA-D Resource(s |  | 120d | 2020-05-01 A | 2020-09-30 A | S348000 SS | 100% |  | 2020-05-01 | 2020-10-21 |  |  | PROF4 AD [192 h]; TECH4 AD [20 h] | 30,994.88 | PO&ADS348010 | 0 | S297800 | S297800 | S348010 | CA | Not Started | C | Feder, Russ | L4 | BNL | Fab & Assy | Russ Feder | BNL | null | POM02.2.05.03 | C | 2.05 | 16728 | 2.05 | 03 | C-AD | S348010 | Yes |  |  |  |  |  |  |  |  |  |  |  |  |
| S348100 |  | Fabricate/Procure Cradle Carriage Integration/Installation Tooling/Fixtures - M&S |  | 80d | 2020-07-01 A | 2020-07-31 A | S348000 SS, S348010 SS | 100% |  | 2020-07-01 | 2020-10-23 |  |  | Material (Purchase (1st $2M) [40000 h] | 45,699.1 | S348100 | 0 | S297900 | S297900 | S348100 | CA | Not Started | C | Feder, Russ | M5 | BNL | Fab & Assy | Russ Feder | BNL | null | POM02.2.05.03 | C | 2.05 | 16727 | 2.05 | 03 |  |  | Yes | MP6LAEXCLUDE | UDF_G1 | UDF_G1 | 45623.238027 | 1 | TBD |  |  |  |  |  |  |
| S348200 |  | Prepare Cradle Carriage Integration/Installation Tooling/Fixtures/Procedures - Physics Resource(s) |  | 20d | 2020-10-01 A | 2020-10-29 A | S348000, S348100, S348010 | 100% |  |  |  |  |  | PROF4 PO M [48 h]; TECH3 PO D [30 h] | 10,807.16 | PO&AD | 0 | S298000 | S298000 | S348200 | CA | Not Started | C | Feder, Russ | L4 | BNL | Installation | Russ Feder | BNL | null | POM02.2.05.03 | C | 2.05 | 16727 | 2.05 | 03 | PO |  |  |  |  |  |  |  |  |  |  |  |  |  |  |
| S348210 |  | Prepare Cradle Carriage Integration/Installation Tooling/Fixtures/Procedures - CA-D Resource(s) |  | 20d | 2020-10-01 A | 2020-10-29 A | S348200 SS | 100% |  |  |  |  |  | PROF4 AD [40 h]; TECH4 AD [20 h] | 8,757.57 | PO&ADS348210 | 0 | S298000 | S298000 | S348210 | CA | Not Started | C | Feder, Russ | L4 | BNL | Installation | Russ Feder | BNL | null | POM02.2.05.03 | C | 2.05 | 16728 | 2.05 | 03 | C-AD | S348210 |  |  |  |  |  |  |  |  |  |  |  |  |  |
| S348300 |  | Review sPHENIX Cradle Carriage Integration/Installation Tooling/Fixtures/Procedures Safety/Certification - Physics Resou |  | 10d | 2020-10-26 A | 2020-10-29 A | S348200, S348210 | 100% |  | 2020-10-30 | 2020-11-13 |  |  | PROF4 PO M [8 h]; TECH3 PO D [8 h] | 2,153.83 | PO&AD | 0 | S298100 | S298100 | S348300 | CA | Not Started | C | Feder, Russ | L4 | BNL | Installation | Russ Feder | BNL | null | POM02.2.05.03 | C | 2.05 | 16727 | 2.05 | 03 | PO |  |  |  |  |  |  |  |  |  |  |  |  |  |  |
| S348310 |  | Review sPHENIX Cradle Carriage Integration/Installation Tooling/Fixtures/Procedures Safety/Certification - CA-D Resource |  | 10d | 2020-10-26 A | 2020-10-29 A | S348300 SS | 100% |  | 2020-10-30 | 2020-11-13 |  |  | PROF4 AD [12 h]; TECH4 AD [8 h] | 2,896.3 | PO&ADS348310 | 0 | S298100 | S298100 | S348310 | CA | Not Started | C | Feder, Russ | L4 | BNL | Installation | Russ Feder | BNL | null | POM02.2.05.03 | C | 2.05 | 16728 | 2.05 | 03 | C-AD | S348310 |  |  |  |  |  |  |  |  |  |  |  |  |  |
| S348400 |  | Address Action Items from Cradle Carriage Integration/Installation Tooling/Fixtures/Procedures Design&Safety Reviews-PO |  | 5d | 2020-10-26 A | 2020-10-29 A | S348300, S348310 | 100% |  | 2020-11-16 | 2020-11-20 |  |  | PROF4 PO M [8 h]; TECH3 PO D [8 h] | 2,153.83 | PO&AD | 0 | S298200 | S298200 | S348400 | CA | Not Started | C | Feder, Russ | L4 | BNL | Installation | Russ Feder | BNL | null | POM02.2.05.03 | C | 2.05 | 16727 | 2.05 | 03 | PO |  |  |  |  |  |  |  |  |  |  |  |  |  |  |
| S348410 |  | Address Action Items from Cradle Carriage Integration/Installation Tooling/Fixtures/Procedures Design&Safety Reviews-AD |  | 5d | 2020-10-26 A | 2020-10-29 A | S348400 SS | 100% |  | 2020-11-16 | 2020-11-20 |  |  | PROF4 AD [8 h] | 1,213.46 | PO&ADS348410 | 0 | S298200 | S298200 | S348410 | CA | Not Started | C | Feder, Russ | L4 | BNL | Installation | Russ Feder | BNL | null | POM02.2.05.03 | C | 2.05 | 16728 | 2.05 | 03 | C-AD | S348410 |  |  |  |  |  |  |  |  |  |  |  |  |  |
| S348500 |  | Design/Safety Reviews Complete, Cradle Carriage Integration/Installation Tooling/Fixtures/Procedures Ready for service | milestone | 0d | 2020-10-29 A | 2020-10-29 A | S348400 FF, S348410 FF | 100% |  | 2020-11-20 | 2020-11-20 |  |  |  |  | S348500 | 0 | S298300 | S298300 |  | NOCA | Not Started | C | Feder, Russ |  | BNL | Management Safety Reviews | Russ Feder | BNL |  | POM02.2.05.03 |  |  |  |  | 03 |  |  |  |  |  |  |  |  |  | L3 |  |  |  |  |  |
| S348600 |  | Ready to Assemble Cradle Carriage in AH | milestone | 0d | 2021-05-03 A | 2021-05-03 A | S348500, S311400, S345400 | 100% |  |  |  |  |  |  |  | S348600 | 0 | S298400 | S298400 |  | NOCA | Not Started | C | Feder, Russ |  | BNL | Fab & Assy | Russ Feder | BNL |  | POM02.2.05.03 |  |  |  |  | 03 |  |  |  |  |  |  |  |  |  | L5 |  |  |  |  |  |
| S348700 |  | Assemble base, carriage alignment and carriage roller supports - Labor - Physics Resource(s) |  | 10d | 2021-05-03 A | 2021-06-03 | S348600, S343866 | 50% | 3d | 2021-05-03 | 2021-05-14 | 0d | 2021-06-03 | PROF4 PO M [16 h]; TECH3 PO M [480 h]; TECH3 PO D [16 h] | 60,729.65 | PO&AD | 0 | S298500 | S298500 | S348700 | CA | Not Started | C | Feder, Russ | L4 | BNL | Fab & Assy | Russ Feder | BNL | null | POM02.2.05.03 | C | 2.05 | 16727 | 2.05 | 03 | PO |  |  |  |  |  |  |  |  |  |  |  |  |  |  |
| S348710 |  | Assemble base, carriage alignment and carriage roller supports - Labor - CA-D Resource(s) |  | 10d | 2021-05-03 A | 2021-06-03 | S348700 SS | 50% | 3d | 2021-05-03 | 2021-05-14 | 0d | 2021-06-03 | CRAFT3 [160 h]; PROF4 AD [88 h]; TECH3 AD [72 h]; TECH4 AD [32 h] | 46,727.55 | PO&ADS348710 | 0 | S298500 | S298500 | S348710 | CA | Not Started | C | Feder, Russ | L4 | BNL | Fab & Assy | Russ Feder | BNL | null | POM02.2.05.03 | C | 2.05 | 16728 | 2.05 | 03 | C-AD | S348710 |  |  |  |  |  |  |  |  |  |  |  |  |  |
| S348800 |  | Assemble base, carriage alignment and carriage roller supports - M&S |  | 10d | 2021-05-03 A | 2021-06-03 | S348700 SS, S348710 SS | 50% | 3d | 2021-05-03 | 2021-05-14 | 0d | 2021-06-03 | Material (Purchase (1st $2M) [2500 h] | 2,901.71 | S348800 | 0 | S298600 | S298600 | S348800 | CA | Not Started | C | Feder, Russ | M4 | BNL | Fab & Assy | Russ Feder | BNL | null | POM02.2.05.03 | C | 2.05 | 16727 | 2.05 | 03 |  |  |  |  | UDF_G2 | UDF_G1 | 2901.710775 | 1 |  |  |  |  |  |  |  |
| S348900 |  | Assemble HCal cradle onto base - Labor - Physics Resource(s) |  | 9d | 2021-06-04 | 2021-06-16 | S348700, S348800, S348710 |  |  |  |  | 0d |  | PROF4 PO M [16 h]; TECH3 PO M [80 h]; TECH3 PO D [16 h] | 13,711.32 | PO&AD | 0 | S298700 | S298700 | S348900 | CA | Not Started | C | Feder, Russ | L4 | BNL | Fab & Assy | Russ Feder | BNL | null | POM02.2.05.03 | C | 2.05 | 16727 | 2.05 | 03 | PO |  |  |  |  |  |  |  |  |  |  |  |  |  |  |
| S348910 |  | Assemble HCal cradle onto base - Labor - CA-D Resource(s) |  | 9d | 2021-06-04 | 2021-06-16 | S348900 SS |  |  |  |  | 0d |  | PROF4 AD [40 h]; CRAFT3 [64 h] | 14,312.02 | PO&ADS348910 | 0 | S298700 | S298700 | S348910 | CA | Not Started | C | Feder, Russ | L4 | BNL | Fab & Assy | Russ Feder | BNL | null | POM02.2.05.03 | C | 2.05 | 16728 | 2.05 | 03 | C-AD | S348910 |  |  |  |  |  |  |  |  |  |  |  |  |  |
| S348915 |  | Assemble HCal cradle onto base - M&S |  | 9d | 2021-06-04 | 2021-06-16 | S348900 SS, S348910 SS |  |  |  |  | 0d |  | Material (Purchase (1st $2M) [3000 h] | 3,482.05 | S349000 | 0 | S298800 | S298800 | S348915 | CA | Not Started | C | Feder, Russ | M4 | BNL | Fab & Assy | Russ Feder | BNL | null | POM02.2.05.03 | C | 2.05 | 16727 | 2.05 | 03 |  |  |  |  | UDF_G2 | UDF_G1 | 3482.05293 | 1 |  |  |  |  |  |  |  |
| S348920 |  | Completed - Assemble HCal cradle onto base | milestone | 0d | 2021-06-16 | 2021-06-16 | S348900 FF, S348910 FF, S348915 FF |  |  |  |  | 0d |  |  |  | PO&ADS348910 | 0 | S298700 | S298700 |  | NOCA | Not Started | C | Feder, Russ |  | BNL | Fab & Assy | Russ Feder | BNL |  | POM02.2.05.03 |  |  |  |  | 03 | C-AD | S348910 |  |  |  |  |  |  |  | L5 |  |  |  |  |  |
| S1002239 |  | Install magnet mounting feet - Labor - Physics Resource(s) |  | 10d | 2021-09-10 | 2021-09-23 | S350910, S318120 |  |  |  |  | 0d |  | PROF4 PO M [10 h]; TECH3 PO M [160 h]; TECH3 PO D [8 h] | 21,264.53 | S349100 | 0 | S298900 | S298900 | S1002239 | CA | Not Started | C | Feder, Russ | L4 | BNL | Installation | Russ Feder | BNL | null | POM02.2.05.03 | C | 2.05 | 16727 | 2.05 | 03 |  |  |  |  |  |  |  |  |  |  |  |  |  |  |  |
| S349100 |  | Install magnet mounting feet - Labor - CA-D Resource(s) |  | 10d | 2021-09-10 | 2021-09-23 | S350910, S318120 |  |  |  |  | 0d |  | PROF4 AD [4 h] | 606.73 | S349100 | 0 | S298900 | S298900 | S349100 | CA | Not Started | C | Feder, Russ | L4 | BNL | Installation | Russ Feder | BNL | null | POM02.2.05.03 | C | 2.05 | 16727 | 2.05 | 03 |  |  |  |  |  |  |  |  |  |  |  |  |  |  |  |
| S349200 |  | Install magnet mounting feet - M&S |  | 10d | 2021-09-10 | 2021-09-23 | S349100 SS, S318120, S1002239 SS |  |  |  |  | 0d |  | Material (Purchase (1st $2M) [3000 h] | 3,482.05 | S349200 | 0 | S299000 | S299000 | S349200 | CA | Not Started | C | Feder, Russ | M4 | BNL | Fab & Assy | Russ Feder | BNL | null | POM02.2.05.03 | C | 2.05 | 16727 | 2.05 | 03 |  |  |  |  | UDF_G2 | UDF_G1 | 3482.05293 | 1 |  |  |  |  |  |  |  |
| S349300 |  | Install platforms & access - Labor - Physics Resource(s) |  | 20d | 2021-12-01 | 2021-12-29 | S327300, S349200, S351310 |  |  |  |  | 0d |  | PROF4 PO M [16 h]; TECH3 PO M [240 h]; TECH3 PO D [16 h] | 33,494.21 | PO&AD | 0 | S299100 | S299100 | S349300 | CA | Not Started | C | Feder, Russ | L4 | BNL | Installation | Russ Feder | BNL | null | POM02.2.05.03 | C | 2.05 | 16727 | 2.05 | 03 | PO |  |  |  |  |  |  |  |  |  |  |  |  |  |  |
| S349310 |  | Install platforms & access - Labor - CA-D Resource(s) |  | 20d | 2021-12-01 | 2021-12-29 | S349300 SS |  |  |  |  | 0d |  | PROF4 AD [176 h]; TECH3 AD [72 h]; TECH4 AD [80 h] | 47,298.12 | PO&ADS349310 | 0 | S299100 | S299100 | S349310 | CA | Not Started | C | Feder, Russ | L4 | BNL | Installation | Russ Feder | BNL | null | POM02.2.05.03 | C | 2.05 | 16728 | 2.05 | 03 | C-AD | S349310 |  |  |  |  |  |  |  |  |  |  |  |  |  |
| S349400 |  | Install platforms & access - M&S |  | 20d | 2021-12-01 | 2021-12-29 | S349300 SS |  |  |  |  | 0d |  | Material (Purchase (1st $2M) [1000 h] | 1,183.9 | S349400 | 0 | S299200 | S299200 | S349400 | CA | Not Started | C | Feder, Russ | M4 | BNL | Installation | Russ Feder | BNL | null | POM02.2.05.03 | C | 2.05 | 16727 | 2.05 | 03 |  |  |  |  | UDF_G2 | UDF_G1 | 1183.89799 | 1 |  |  |  |  |  |  |  |
| S349410 |  | Completed - Install platforms & access | milestone | 0d | 2021-12-29 | 2021-12-29 | S349300 FF, S349310 FF, S349400 FF |  |  |  |  | 0d |  |  |  | S349400 | 0 | S299200 | S299200 |  | NOCA | Not Started | C | Feder, Russ |  | BNL | Installation | Russ Feder | BNL |  | POM02.2.05.03 |  |  |  |  | 03 |  |  |  |  |  |  |  |  |  | L5 | 190316 ELM logic per GRY | 2022-02-28 | 39 | 003 | PMP_2x |
| S349500 |  | Install Pole Tips - Labor - Physics Resource(s) |  | 10d | 2022-03-08 | 2022-03-21 | S325600, S358800, S358900, S349410 |  |  |  |  | 0d |  | PROF4 PO M [8 h]; TECH3 PO M [64 h]; TECH3 PO D [8 h] | 9,967.06 | PO&AD | 0 | S299300 | S299300 | S349500 | CA | Not Started | C | Feder, Russ | L4 | BNL | Installation | Russ Feder | BNL | null | POM02.2.05.03 | C | 2.05 | 16727 | 2.05 | 03 | PO |  |  |  |  |  |  |  |  |  |  |  |  |  |  |
| S349510 |  | Install Pole Tips - Labor - CA-D Resource(s) |  | 10d | 2022-03-08 | 2022-03-21 | S349500 SS |  |  |  |  | 0d |  | PROF4 AD [136 h]; CRAFT3 [120 h]; TECH4 AD [80 h] | 48,254.16 | PO&ADS349510 | 0 | S299300 | S299300 | S349510 | CA | Not Started | C | Feder, Russ | L4 | BNL | Installation | Russ Feder | BNL | null | POM02.2.05.03 | C | 2.05 | 16728 | 2.05 | 03 | C-AD | S349510 |  |  |  |  |  |  |  |  |  |  |  |  |  |
| S349600 |  | Install Pole Tips - M&S |  | 10d | 2022-03-08 | 2022-03-21 | S349500 SS, S349510 SS |  |  |  |  | 0d |  | Material (Purchase (1st $2M) [3000 h] | 3,551.69 | S349600 | 0 | S299400 | S299400 | S349600 | CA | Not Started | C | Feder, Russ | M4 | BNL | Installation | Russ Feder | BNL | null | POM02.2.05.03 | C | 2.05 | 16727 | 2.05 | 03 |  |  |  |  | UDF_G3 | UDF_G1 | 3551.69397 | 1 |  |  |  |  |  |  |  |
| S349610 |  | Completed - Install Pole Tips | milestone | 0d | 2022-03-21 | 2022-03-21 | S349500 FF, S349510 FF, S349600 FF |  |  |  |  | 0d |  |  |  | S349600 | 0 | S299400 | S299400 |  | NOCA | Not Started | C | Feder, Russ |  | BNL | Installation | Russ Feder | BNL |  | POM02.2.05.03 |  |  |  |  | 03 |  |  |  |  |  |  |  |  |  | L5 |  | 2022-05-31 | 49 |  | PMP_2x |

Notes:
- S347900: BNL_UDF_Old Activity Name 181221: Design Cradle Carriage Integration/Installation Tooling/Fixtures
- S347910: BNL_UDF_Old Activity Name 181221: Design Cradle Carriage Integration/Installation Tooling/Fixtures
- S348000: BNL_UDF_Adhoc Comments: 180227 ELM rsrc assign per DLynch / BNL_UDF_Old Activity Name 181221: (Planning Package) Fabricate/Procure Cradle Carriage Integration/Installation Tooling/Fixtures - Labor
- S348010: BNL_UDF_Adhoc Comments: 180227 ELM rsrc assign per DLynch / BNL_UDF_Old Activity Name 181221: (Planning Package) Fabricate/Procure Cradle Carriage Integration/Installation Tooling/Fixtures - Labor
- S348100: BNL_UDF_Old Activity Name 181221: (Planning Package) Fabricate/Procure Cradle Carriage Integration/Installation Tooling/Fixtures - M&S
- S348200: BNL_UDF_Adhoc Comments: 180227 ELM rsrc assign per DLynch / BNL_UDF_Old Activity Name 181221: Prepare Cradle Carriage Integration/Installation Tooling/Fixtures/Procedures Procedures
- S348210: BNL_UDF_Adhoc Comments: 180227 ELM rsrc assign per DLynch / BNL_UDF_Old Activity Name 181221: Prepare Cradle Carriage Integration/Installation Tooling/Fixtures/Procedures Procedures
- S348300: BNL_UDF_Old Activity Name 181221: Review sPHENIX Cradle Carriage Integration/Installation Tooling/Fixtures/Procedures Safety/Certification
- S348310: BNL_UDF_Old Activity Name 181221: Review sPHENIX Cradle Carriage Integration/Installation Tooling/Fixtures/Procedures Safety/Certification
- S348400: BNL_UDF_Old Activity Name 181221: Address Action Items from Cradle Carriage Integration/Installation Tooling/Fixtures/Procedures Design & Safety Reviews
- S348410: BNL_UDF_Old Activity Name 181221: Address Action Items from Cradle Carriage Integration/Installation Tooling/Fixtures/Procedures Design & Safety Reviews
- S348500: BNL_UDF_Old Activity Name 181221: Design/Safety Reviews Complete, Cradle Carriage Integration/Installation Tooling/Fixtures/Procedures Ready for service
- S348600: BNL_UDF_Old Activity Name 181221: Ready to Assemble Cradle Carriage in AH
- S348700: Scheduler's Notes: 180413 ELM per GRY: / assume 3 people / BNL_UDF_Adhoc Comments: 180227 ELM rsrc assign per DLynch / BNL_UDF_Old Activity Name 181221: Assemble base, carriage alignment and carriage roller supports - Labor
- S348710: Scheduler's Notes: 180413 ELM per GRY: / assume 3 people / BNL_UDF_Adhoc Comments: 180227 ELM rsrc assign per DLynch / BNL_UDF_Old Activity Name 181221: Assemble base, carriage alignment and carriage roller supports - Labor
- S348800: BNL_UDF_Old Activity Name 181221: Assemble base, carriage alignment and carriage roller supports - M&S
- S348900: BNL_UDF_Adhoc Comments: 180227 ELM rsrc assign per DLynch / BNL_UDF_Old Activity Name 181221: Assemble HCal cradle onto base - Labor
- S348910: BNL_UDF_Adhoc Comments: 180227 ELM rsrc assign per DLynch / BNL_UDF_Old Activity Name 181221: Assemble HCal cradle onto base - Labor
- S348915: BNL_UDF_Old Activity Name 181221: Assemble HCal cradle onto base - M&S
- S348920: BNL_UDF_Adhoc Comments: 180227 ELM rsrc assign per DLynch / BNL_UDF_Old Activity Name 181221: Assemble HCal cradle onto base - Labor
- S1002239: Scheduler's Notes: 180413 ELM per GRY: / assume 4 people / BNL_UDF_Adhoc Comments: 180227 ELM rsrc assign per DLynch / BNL_UDF_Old Activity Name 181221: Install magnet mounting feet - Labor
- S349100: Scheduler's Notes: 180413 ELM per GRY: / assume 4 people / BNL_UDF_Adhoc Comments: 180227 ELM rsrc assign per DLynch / BNL_UDF_Old Activity Name 181221: Install magnet mounting feet - Labor
- S349200: BNL_UDF_Old Activity Name 181221: Install magnet mounting feet - M&S
- S349300: Scheduler's Notes: 180413 ELM per GRY: / assume 2 people / BNL_UDF_Adhoc Comments: 180227 ELM rsrc assign per DLynch / BNL_UDF_Old Activity Name 181221: Install platforms & access - Labor
- S349310: Scheduler's Notes: 180413 ELM per GRY: / assume 2 people / BNL_UDF_Adhoc Comments: 180227 ELM rsrc assign per DLynch / BNL_UDF_Old Activity Name 181221: Install platforms & access - Labor
- S349400: BNL_UDF_Old Activity Name 181221: Install platforms & access - M&S
- S349410: BNL_UDF_Old Activity Name 181221: Install platforms & access - M&S
- S349500: Scheduler's Notes: 180413 ELM per GRY: / assume 2 people / BNL_UDF_Adhoc Comments: 180413 ELM pred/succ per GRY; 180227 ELM rsrc assign per DLynch / BNL_UDF_Old Activity Name 181221: Install Pole Tips - Labor
- S349510: Scheduler's Notes: 180413 ELM per GRY: / assume 2 people / BNL_UDF_Adhoc Comments: 180413 ELM pred/succ per GRY; 180227 ELM rsrc assign per DLynch / BNL_UDF_Old Activity Name 181221: Install Pole Tips - Labor
- S349600: BNL_UDF_Old Activity Name 181221: Install Pole Tips - M&S
- S349610: BNL_UDF_Old Activity Name 181221: Install Pole Tips - M&S

| ID | WBS | Activity | Type | Duration | Start | Finish | Predecessors | Complete | Planned start | Planned finish | Total float | Free float | Resources | Cost | BNL_UDF_Temp Text 01 | BNL_UDF_Percent Complete | BNL_UDF_OPC TEC (deprecated) | BNL_UDF_Temp Date 01 | BNL_UDF_Old Activity ID 181221 | RG Check | BNL_Activity Status | BNL_Fund Source | BNL_Estimator | BNL_Cost Basis | BNL_Location | BNL_EDIA | BNL_CAM | BNL_Institution | BNL_OPC TEC (deprecated) | BNL_WBS | BNL_EVT | BNL_Split Activity | BNL_WBS_Hierarchical | Completed | BNL_UDF_Exclude | BNL_UDF_Status Comments | BNL_Cobra WP | BNL_Proc Sig | BNL_Master Control Account | BNL_Account Number | BNL_Obligation | BNL_PCR ID | BNL_Cobra Control Account | Additional EVT documentation required | Indicator - Procurement | Indicator - Float | BNL_Milestone Level | Target Milestone Date | Variance | PMP Milestones | BNL_UDF_Remaining Tot Cost | BNL_UDF_Percent_remaining | Temp | BNL_UDF_Temp Text 02 |
| --- | --- | --- | --- | --- | --- | --- | --- | --- | --- | --- | --- | --- | --- | --- | --- | --- | --- | --- | --- | --- | --- | --- | --- | --- | --- | --- | --- | --- | --- | --- | --- | --- | --- | --- | --- | --- | --- | --- | --- | --- | --- | --- | --- | --- | --- | --- | --- | --- | --- | --- | --- | --- | --- | --- |
|  | 04 | **Outer Hcal Installation** |  |  | 2017-02-01 | 2022-03-07 |  |  |  |  |  |  |  |  |  |  |  |  |  |  |  |  |  |  |  |  |  |  |  |  |  |  |  |  |  |  |  |  |  |  |  |  |  |  |  |  |  |  |  |  |  |  |  |  |
| S349700 |  | Design Outer HCal Integration/Installation Tooling/Fixtures FY18 |  | 418d | 2017-02-01 A | 2018-09-28 A | S100090 SS | 100% |  |  |  |  |  |  | S349700 | 100 | S299500 | 2019-06-30 | S299500 | NOCA | Completed | C | Feder, Russ | L4 | BNL | Installation | Russ Feder | BNL | null | POM02.2.05.04 | C | FY18 | 04 | yes |  |  |  |  |  |  |  |  |  |  |  |  |  |  |  |  |  |  |  |  |
| OBLG356980 |  | Fabricate/Procure Outer HCal Integration/Installation Tooling/Fixtures - M&S |  | 60d | 2019-10-01 A | 2020-04-27 A |  | 100% | 2019-10-01 | 2019-12-30 |  |  | Obligation Resource [68276 h] | 68,276 | S350000 | 0 | S299700 |  | S299700 |  | In Progress | C | Feder, Russ | M5 | BNL | Fab & Assy | Russ Feder | BNL | null | POM02.2.05.04 | C |  | 04 |  | MP6LAEXCLUDE | 190318 ELM name per GRY | S350000 | TBD | 2.05 | 16727 | OBLG | 008C |  |  |  |  |  |  |  |  |  |  |  |  |
| S349800 |  | Design Outer HCal Integration/Installation Tooling/Fixtures FY20 |  | 125d | 2019-10-01 A | 2019-11-25 A | S349700, S101010 | 100% | 2019-10-01 | 2020-04-02 |  |  | PROF4 PO M [30 h]; TECH3 PO M [24 h]; TECH3 PO D [60 h] | 14,004.21 | S349800 | 0 | S299500 | 2019-06-28 | S299550 | CA | Completed | C | Feder, Russ | L4 | BNL | Installation | Russ Feder | BNL | null | POM02.2.05.04 | C | FY19 | 04 |  |  | 190318 ELM logic, name per GRY | S349800 |  | 2.05 | 16727 |  | 003 | 2.05 | Yes |  |  |  |  |  |  |  |  |  |  |
| S349900 |  | Fabricate/Procure Outer HCal Integration/Installation Tooling/Fixtures - Labor |  | 60d | 2019-11-15 A | 2020-01-30 A | S101000, S349800 | 100% | 2019-11-01 | 2020-01-31 |  |  | PROF4 PO M [48 h]; TECH3 PO D [48 h]; TECH3 PO M [48 h] | 18,024.45 | S349900 | 0 | S299600 |  | S299600 | CA | In Progress | C | Feder, Russ | L4 | BNL | Fab & Assy | Russ Feder | BNL | null | POM02.2.05.04 | C |  | 04 |  |  | 190318 ELM logic, name per GRY | S349900 |  | 2.05 | 16727 |  | 003 | 2.05 |  |  |  |  |  |  |  |  |  |  |  |
| S350000 |  | Fabricate/Procure Outer HCal Integration/Installation Tooling/Fixtures - M&S |  | 60d | 2019-11-15 A | 2020-01-30 A | S349900 SS, S349800, OBLG356980 | 100% | 2020-02-03 | 2020-04-27 |  |  | Material (Purchase (1st $2M) [60000 h] | 68,275.55 | S350000 | 0 | S299700 |  | S299700 | CA | In Progress | C | Feder, Russ | M5 | BNL | Fab & Assy | Russ Feder | BNL | null | POM02.2.05.04 | C |  | 04 |  | MP6LAEXCLUDE | 190318 ELM name per GRY | S350000 | TBD | 2.05 | 16727 |  | 003 | 2.05 |  | UDF_G3 | UDF_G3 |  |  |  |  |  |  |  |  |
| S350100 |  | Prepare Outer HCal Integration/Installation Tooling/Fixtures Procedures |  | 20d | 2020-09-16 A | 2021-02-26 A | S349900, S350000 | 100% | 2020-10-01 | 2020-10-29 |  |  | PROF4 PO M [40 h]; TECH3 PO D [16 h]; TECH3 PO M [16 h] | 9,828.78 | S350100 | 0 | S299800 |  | S299800 | CA | Not Started | C | Feder, Russ | L4 | BNL | Installation | Russ Feder | BNL | null | POM02.2.05.04 | C |  | 04 |  |  |  | S350100 |  | 2.05 | 16727 |  |  | 2.05 |  |  |  |  |  |  |  |  |  |  |  |
| S1002279 |  | Review Outer HCal Integration/Installation Tooling/Fixtures/Procedures Safety/Certification - Physics Resource(s) |  | 10d | 2021-03-15 A | 2021-03-23 A | S350100 | 100% | 2021-04-01 | 2021-04-14 |  |  | PROF4 PO M [8 h]; TECH3 PO D [8 h]; TECH3 PO M [8 h] | 3,094.2 | S350200 | 0 | S299900 |  | S299900 | CA | Not Started | C | Feder, Russ | L4 | BNL | Installation | Russ Feder | BNL | null | POM02.2.05.04 | C |  | 04 |  |  |  | S1002279 |  | 2.05 | 16727 |  |  | 2.05 |  |  |  |  |  |  |  |  |  |  |  |
| S1002359 |  | Address Action Items from Outer Hcal Integration/Installation Tooling/Fixtures/Procedures Design & Safety Reviews - P |  | 10d | 2021-03-15 A | 2021-03-23 A | S350200, S1002279 | 100% | 2021-04-15 | 2021-04-28 |  |  | PROF4 PO M [8 h]; TECH3 PO D [8 h]; TECH3 PO M [8 h] | 3,094.2 | S350300 | 0 | S300000 |  | S300000 | CA | Not Started | C | Feder, Russ | L4 | BNL | Installation | Russ Feder | BNL | null | POM02.2.05.04 | C |  | 04 |  |  |  | S1002359 |  | 2.05 | 16727 |  |  | 2.05 |  |  |  |  |  |  |  |  |  |  |  |
| S350200 |  | Review Outer HCal Integration/Installation Tooling/Fixtures/Procedures Safety/Certification - CA-D Resource(s) |  | 10d | 2021-03-15 A | 2021-03-23 A | S350100 | 100% | 2021-04-01 | 2021-04-14 |  |  | PROF2 AD [4 h]; PROF4 AD [4 h] | 1,019.64 | S350200 | 0 | S299900 |  | S299900 | CA | Not Started | C | Feder, Russ | L4 | BNL | Installation | Russ Feder | BNL | null | POM02.2.05.04 | C |  | 04 |  |  |  | S350200 |  | 2.05 | 16727 |  |  | 2.05 |  |  |  |  |  |  |  |  |  |  |  |
| S350300 |  | Address Action Items from Outer Hcal Integration/Installation Tooling/Fixtures/Procedures Design & Safety Reviews - C |  | 10d | 2021-03-15 A | 2021-03-23 A | S350200, S1002279 | 100% | 2021-04-15 | 2021-04-28 |  |  | PROF2 AD [4 h]; PROF4 AD [4 h] | 1,019.64 | S350300 | 0 | S300000 |  | S300000 | CA | Not Started | C | Feder, Russ | L4 | BNL | Installation | Russ Feder | BNL | null | POM02.2.05.04 | C |  | 04 |  |  |  | S350300 |  | 2.05 | 16727 |  |  | 2.05 |  |  |  |  |  |  |  |  |  |  |  |
| S350400 |  | Design/Safety Reviews Complete, Outer HCal Integration/Installation Tooling/Fixtures/Procedures Ready for Service | milestone | 0d | 2021-03-31 A | 2021-03-31 A | S350300, S1002359 | 100% | 2021-04-01 | 2021-04-01 |  |  |  |  | S350400 | 0 | S300100 |  | S300100 | NOCA | Not Started | C | Feder, Russ |  | BNL | Management Safety Reviews | Russ Feder | BNL |  | POM02.2.05.04 |  |  | 04 |  |  |  |  |  |  |  |  |  |  |  |  |  | L3 |  |  |  |  |  |  |  |
| S350500 |  | Outer HCal Sectors Ready for Installation | milestone | 0d | 2021-03-31 A | 2021-03-31 A | S350400 FF, S210400 FF | 100% |  |  |  |  |  |  | S350500 | 0 | S300200 |  | S300200 | NOCA | Not Started | C | Feder, Russ |  | BNL | Installation | Russ Feder | BNL |  | POM02.2.05.04 |  |  | 04 |  |  |  |  |  |  |  |  |  |  |  |  |  | L3 | 2021-04-30 | 21 | PMP_2x |  |  |  |  |
| S1002439 |  | Transport Assembled Outer HCal Sectors to AH (Partial Shipment) - Labor - Physics Resource(s) |  | 1d | 2021-06-17 | 2021-06-17 | S350500, S348920 |  |  |  | 0d |  | PROF4 PO M [8 h]; CRAFT3 [256 h]; TECH3 PO D [8 h]; TECH3 PO M [128 h] | 50,178.5 | S350600 | 0 | S301100 |  | S301100 | CA | Not Started | C | Feder, Russ | L4 | BNL | Fab & Assy | Russ Feder | BNL | null | POM02.2.05.04 | C |  | 04 |  |  |  | S1002439 |  | 2.05 | 16727 |  |  | 2.05 |  |  |  |  |  |  |  |  |  |  |  |
| S350600 |  | Transport Assembled Outer HCal Sectors to AH (Partial Shipment) - Labor - CA-D Resource(s) |  | 1d | 2021-06-17 | 2021-06-17 | S350500, S348920 |  |  |  | 0d |  | PROF2 AD [8 h] | 825.81 | S350600 | 0 | S301100 |  | S301100 | CA | Not Started | C | Feder, Russ | L4 | BNL | Fab & Assy | Russ Feder | BNL | null | POM02.2.05.04 | C |  | 04 |  |  |  | S350600 |  | 2.05 | 16727 |  |  | 2.05 |  |  |  |  |  |  |  |  |  |  |  |
| S350700 |  | Transport Assembled Outer HCal Sectors to AH (Partial Shipment) - M&S |  | 1d | 2021-06-17 | 2021-06-17 | S350600 SS, S1002439 SS |  |  |  | 0d |  | Material (Purchase (1st $2M) [500 h] | 580.34 | S350700 | 0 | S301200 |  | S301200 | CA | Not Started | C | Feder, Russ | M4 | BNL | Fab & Assy | Russ Feder | BNL | null | POM02.2.05.04 | C |  | 04 |  |  |  | S350700 |  | 2.05 | 16727 |  |  | 2.05 |  | UDF_G2 | UDF_G1 |  |  |  |  | 580.342155 | 1 |  |  |
| S1002519 |  | Install Partial Outer HCal (Prior to SC Magnet Install) - Labor - Physics Resource(s) |  | 58d | 2021-06-18 | 2021-09-09 | S350600, S350700, S348920, S1002439 |  |  |  | 0d |  | PROF4 PO M [64 h]; TECH3 PO D [48 h]; TECH3 PO M [512 h]; CRAFT3 [600 h] | 152,827.43 | S350800 | 0 | S301300 |  | S301300 | CA | Not Started | C | Feder, Russ | L4 | BNL | Installation | Russ Feder | BNL | null | POM02.2.05.04 | C |  | 04 |  |  |  | S1002519 |  | 2.05 | 16727 |  |  | 2.05 |  |  |  |  |  |  |  |  |  |  |  |
| S350800 |  | Install Partial Outer HCal (Prior to SC Magnet Install) - Labor - CA-D Resource(s) |  | 58d | 2021-06-18 | 2021-09-09 | S350600, S350700, S348920, S1002439 |  |  |  | 0d |  | PROF2 AD [20 h]; PROF4 AD [8 h]; TECH4 AD [600 h] | 83,985.53 | S350800 | 0 | S301300 |  | S301300 | CA | Not Started | C | Feder, Russ | L4 | BNL | Installation | Russ Feder | BNL | null | POM02.2.05.04 | C |  | 04 |  |  |  | S350800 |  | 2.05 | 16727 |  |  | 2.05 |  |  |  |  |  |  |  |  |  |  |  |
| S350900 |  | Install Partial Outer HCal (Prior to SC Magnet Install) - M&S |  | 58d | 2021-06-18 | 2021-09-09 | S350800 SS, S1002519 SS |  |  |  | 0d |  | Material (Purchase (1st $2M) [500 h] | 580.34 | S350900 | 0 | S301400 |  | S301400 | CA | Not Started | C | Feder, Russ | M4 | BNL | Fab & Assy | Russ Feder | BNL | null | POM02.2.05.04 | C |  | 04 |  |  |  | S350900 |  | 2.05 | 16727 |  |  | 2.05 |  | UDF_G2 | UDF_G1 |  |  |  |  | 580.342155 | 1 |  |  |
| S350910 |  | Completed - Install Partial Outer HCal (Prior to SC Magnet Install) | milestone | 0d | 2021-09-09 | 2021-09-09 | S350800 FF, S350900 FF, S1002519 FF |  |  |  | 0d |  |  |  | S350800 | 0 | S301300 |  | S301300 | NOCA | Not Started | C | Feder, Russ |  | BNL | Installation | Russ Feder | BNL |  | POM02.2.05.04 |  |  | 04 |  |  |  |  |  |  |  |  |  |  |  |  |  | L5 |  |  |  |  |  |  |  |
| S350950 |  | Install Large Support Rings and Cross Braces |  | 5d | 2021-10-15 | 2021-10-21 | S353500, S353510, S353600, S318182 |  |  |  | 0d |  | TECH3 PO M [40 h]; PROF4 PO M [40 h] | 11,092.23 | PO&AD | 0 | S303100 |  | S303100 | CA | Not Started | C | Feder, Russ | L4 | BNL | Installation | Russ Feder | BNL | null | POM02.2.05.05 | C |  | 05 |  |  |  | S350950 |  | 2.05 | 16727 |  |  | 2.05 |  |  |  |  |  |  |  |  |  |  |  |
| S1002599 |  | Transport Remainder of Outer Hcal Sectors to AH - Labor - Physics Resource(s) |  | 10d | 2021-10-22 | 2021-11-04 | S210500, S353500, S353600, S353510, S350950 |  |  |  | 0d |  | PROF4 PO M [8 h]; CRAFT3 [256 h]; TECH3 PO D [8 h]; TECH3 PO M [128 h] | 51,683.85 | S351000 | 0 | S300300 |  | S300300 | CA | Not Started | C | Feder, Russ | L4 | BNL | Fab & Assy | Russ Feder | BNL | null | POM02.2.05.04 | C |  | 04 |  |  | 190329 ELM logic per GRY | S1002599 |  | 2.05 | 16727 |  | 004 | 2.05 |  |  |  |  |  |  |  |  |  |  |  |
| S351000 |  | Transport Remainder of Outer Hcal Sectors to AH - Labor - CA-D Resource(s) |  | 10d | 2021-10-22 | 2021-11-04 | S210500, S353500, S353600, S353510, S350950 |  |  |  | 0d |  | PROF2 AD [8 h] | 850.58 | S351000 | 0 | S300300 |  | S300300 | CA | Not Started | C | Feder, Russ | L4 | BNL | Fab & Assy | Russ Feder | BNL | null | POM02.2.05.04 | C |  | 04 |  |  | 190329 ELM logic per GRY | S351000 |  | 2.05 | 16727 |  | 004 | 2.05 |  |  |  |  |  |  |  |  |  |  |  |
| S351100 |  | Transport Remainder of Outer Hcal Sectors to AH - M&S |  | 10d | 2021-10-22 | 2021-11-04 | S351000 SS, S1002599 SS |  |  |  | 0d |  | Material (Purchase (1st $2M) [500 h] | 591.95 | S351100 | 0 | S300400 |  | S300400 | CA | Not Started | C | Feder, Russ | M4 | BNL | Fab & Assy | Russ Feder | BNL | null | POM02.2.05.04 | C |  | 04 |  |  | 190329 ELM logic per GRY | S351100 |  | 2.05 | 16727 |  | 004 | 2.05 |  | UDF_G2 | UDF_G1 |  |  |  |  | 591.948995 | 1 |  |  |
| S1002679 |  | Install Remainder of Outer HCal Sectors - Labor - Physics Resource(s) |  | 20d | 2021-10-29 | 2021-11-30 | S351000 SS+5d, S351100 SS+5d, S1002599 SS+5d |  |  |  | 0d |  | PROF4 PO M [64 h]; TECH3 PO D [64 h]; TECH3 PO M [512 h]; CRAFT3 [480 h] | 143,426.83 | S351200 | 0 | S300500 |  | S300500 | CA | Not Started | C | Feder, Russ | L4 | BNL | Installation | Russ Feder | BNL | null | POM02.2.05.04 | C |  | 04 |  |  |  | S1002679 |  | 2.05 | 16727 |  |  | 2.05 |  |  |  |  |  |  |  |  |  |  |  |
| S351200 |  | Install Remainder of Outer HCal Sectors - Labor - CA-D Resource(s) |  | 20d | 2021-10-29 | 2021-11-30 | S351000 SS+5d, S351100 SS+5d, S1002599 SS+5d |  |  |  | 0d |  | PROF2 AD [20 h]; PROF4 AD [8 h]; TECH4 AD [480 h] | 69,879.34 | S351200 | 0 | S300500 |  | S300500 | CA | Not Started | C | Feder, Russ | L4 | BNL | Installation | Russ Feder | BNL | null | POM02.2.05.04 | C |  | 04 |  |  |  | S351200 |  | 2.05 | 16727 |  |  | 2.05 |  |  |  |  |  |  |  |  |  |  |  |
| S351300 |  | Install Remainder of Outer HCal Sectors - M&S |  | 20d | 2021-10-29 | 2021-11-30 | S351200 SS, S1002679 SS |  |  |  | 0d |  | Material (Purchase (1st $2M) [500 h] | 591.95 | S351300 | 0 | S300600 |  | S300600 | CA | Not Started | C | Feder, Russ | M4 | BNL | Fab & Assy | Russ Feder | BNL | null | POM02.2.05.04 | C |  | 04 |  |  |  | S351300 |  | 2.05 | 16727 |  |  | 2.05 |  | UDF_G2 | UDF_G1 |  |  |  |  | 591.948995 | 1 |  |  |
| S351310 |  | Completed - Install Remainder of Outer HCal Sectors | milestone | 0d | 2021-11-30 | 2021-11-30 | S351200 FF, S351300 FF, S1002679 FF |  |  |  | 0d |  |  |  | S351300 | 0 | S300600 |  | S300600 | NOCA | Not Started | C | Feder, Russ |  | BNL | Fab & Assy | Russ Feder | BNL |  | POM02.2.05.04 |  |  | 04 |  |  |  |  |  |  |  |  |  |  |  |  |  | L5 | 2022-01-31 | 40 | PMP_2x |  |  |  |  |
| S351400 |  | Align/Survey Outer Hcal to Centerline - Labor - Physics Resource(s) |  | 5d | 2021-12-01 | 2021-12-07 | S351310 |  |  |  | 4d | 0d | TECH3 PO D [4 h]; TECH3 PO M [20 h] | 2,905.73 | PO&AD | 0 | S300700 |  | S300700 | CA | Not Started | C | Feder, Russ | L4 | BNL | Installation | Russ Feder | BNL | null | POM02.2.05.04 | C |  | 04 |  |  |  | S351400 |  | 2.05 | 16727 |  |  | 2.05 |  |  |  |  |  |  |  |  |  | PO |  |
| S351410 |  | Align/Survey Outer Hcal to Centerline - Labor - CA-D Resource(s) |  | 5d | 2021-12-01 | 2021-12-07 | S351400 SS |  |  |  | 4d | 0d | CRAFT3 [80 h]; TECH3 AD [60 h] | 17,879.38 | PO&ADS351410 | 0 | S300700 |  | S300700 | CA | Not Started | C | Feder, Russ | L4 | BNL | Installation | Russ Feder | BNL | null | POM02.2.05.04 | C |  | 04 |  |  |  | S351410 |  | 2.05 | 16728 |  |  | 2.05 |  |  |  |  |  |  |  |  |  | C-AD | S351410 |
| S351500 |  | Align/Survey Outer Hcal to Centerline - M&S |  | 5d | 2021-12-01 | 2021-12-07 | S351400 SS, S351410 SS |  |  |  | 4d | 0d | Material (Purchase (1st $2M) [500 h] | 591.95 | S351500 | 0 | S300800 |  | S300800 | CA | Not Started | C | Feder, Russ | M4 | BNL | Fab & Assy | Russ Feder | BNL | null | POM02.2.05.04 | C |  | 04 |  |  |  | S351500 |  | 2.05 | 16727 |  |  | 2.05 |  | UDF_G2 | UDF_G1 |  |  |  |  | 591.948995 | 1 |  |  |
| S351600 |  | Install Outer HCal Cables and Services - Labor |  | 20d | 2021-12-08 | 2022-01-06 | S351400, S351500, S351410 |  |  |  | 153d | 0d | TECH3 PO M [80 h]; TECH3 PO E [160 h]; PROF4 PO E [80 h] | 41,556 | S351600 | 0 | S300900 |  | S300900 | CA | Not Started | C | Feder, Russ | L4 | BNL | Installation | Russ Feder | BNL | null | POM02.2.05.04 | C |  | 04 |  |  |  | S351600 |  | 2.05 | 16727 |  |  | 2.05 |  |  |  |  |  |  |  |  |  |  |  |
| S351700 |  | Install Outer HCal Cables and Services - M&S |  | 20d | 2021-12-08 | 2022-01-06 | S351600 SS |  |  |  | 153d | 0d | Material (Purchase (1st $2M) [500 h] | 591.95 | S351700 | 0 | S301000 |  | S301000 | CA | Not Started | C | Feder, Russ | M4 | BNL | Fab & Assy | Russ Feder | BNL | null | POM02.2.05.04 | C |  | 04 |  |  |  | S351700 |  | 2.05 | 16727 |  |  | 2.05 |  | UDF_G2 | UDF_G3 |  |  |  |  | 591.948995 | 1 |  |  |
| S351800 |  | Review Outer HCal for Operational Readiness (ORR) |  | 10d | 2022-01-07 | 2022-01-21 | S351600, S351700, S350910 |  |  |  | 153d | 0d | PROF4 PO M [8 h]; TECH3 PO D [8 h]; TECH3 PO M [8 h]; TECH3 PO E [8 h] | 4,155.6 | S351800 | 0 | S301500 |  | S301500 | CA | Not Started | C | Feder, Russ | L4 | BNL | Installation | Russ Feder | BNL | null | POM02.2.05.04 | C |  | 04 |  |  |  | S351800 |  | 2.05 | 16727 |  |  | 2.05 |  |  |  |  |  |  |  |  |  |  |  |
| S351900 |  | Address Action Items from Outer Hcal ORR |  | 10d | 2022-01-24 | 2022-02-04 | S351800 |  |  |  | 153d | 0d | PROF4 PO M [8 h]; TECH3 PO D [8 h]; TECH3 PO M [8 h]; TECH3 PO E [8 h] | 4,155.6 | S351900 | 0 | S301600 |  | S301600 | CA | Not Started | C | Feder, Russ | L4 | BNL | Installation | Russ Feder | BNL | null | POM02.2.05.04 | C |  | 04 |  |  |  | S351900 |  | 2.05 | 16727 |  |  | 2.05 |  |  |  |  |  |  |  |  |  |  |  |
| S352000 |  | Commission Outer HCal - Labor |  | 20d | 2022-02-07 | 2022-03-07 | S351900 |  |  |  | 153d | 0d | PROF4 PO M [32 h]; SCI3 PO [160 h]; TECH3 PO D [32 h]; TECH3 PO M [320 h]; PROF4 PO E [160 h]; TECH3 PO E [320 h] | 140,571.23 | S352000 | 0 | S301700 |  | S301700 | CA | Not Started | C | Feder, Russ | L4 | BNL | Commissioning | Russ Feder | BNL | null | POM02.2.05.04 | C |  | 04 |  |  |  | S352000 |  | 2.05 | 16727 |  |  | 2.05 |  |  |  |  |  |  |  |  |  |  |  |
| S352100 |  | Commission Outer HCal - Labor |  | 20d | 2022-02-07 | 2022-03-07 | S351900 |  |  |  | 153d | 0d | STUDENT Other - Unpaid [640 h] |  | S352100 | 0 | S301700 |  | S301710 | CA | Not Started | T | Feder, Russ | L4 | BNL | Commissioning | Russ Feder | BNL | null | POM02.2.05.04 | K |  | 04 |  |  | 190313 ELM Rsrc | S352100 |  | 2.05 | NA |  | 003 | 2.05 |  |  |  |  |  |  |  |  |  |  |  |
| S352200 |  | Commission Outer HCal - M&S |  | 20d | 2022-02-07 | 2022-03-07 | S352000 SS, S352100 SS |  |  |  | 153d |  | Material (Purchase (1st $2M) [500 h] | 591.95 | S352200 | 0 | S301800 |  | S301800 | CA | Not Started | C | Feder, Russ | M4 | BNL | Fab & Assy | Russ Feder | BNL | null | POM02.2.05.04 | C |  | 04 |  |  |  | S352200 |  | 2.05 | 16727 |  |  | 2.05 |  | UDF_G2 | UDF_G3 |  |  |  |  | 591.948995 | 1 |  |  |

Notes:
- S349700: BNL_UDF_Old Activity Name 181221: Design Outer HCal Integration/Installation Tooling/Fixtures FY18
- OBLG356980: BNL_UDF_Old Activity Name 181221: (Planning Package) Fabricate/Procure Outer HCal Integration/Installation Tooling/Fixtures - M&S
- S349800: BNL_UDF_Old Activity Name 181221: Design Outer HCal Integration/Installation Tooling/Fixtures FY19
- S349900: BNL_UDF_Old Activity Name 181221: (Planning Package) Fabricate/Procure Outer HCal Integration/Installation Tooling/Fixtures - Labor
- S350000: BNL_UDF_Old Activity Name 181221: (Planning Package) Fabricate/Procure Outer HCal Integration/Installation Tooling/Fixtures - M&S
- S350100: BNL_UDF_Old Activity Name 181221: Prepare Outer HCal Integration/Installation Tooling/Fixtures Procedures
- S1002279: BNL_UDF_Old Activity Name 181221: Review Outer HCal Integration/Installation Tooling/Fixtures/Procedures Safety/Certification
- S1002359: BNL_UDF_Old Activity Name 181221: Address Action Items from Outer Hcal Integration/Installation Tooling/Fixtures/Procedures Design & Safety Reviews
- S350200: BNL_UDF_Old Activity Name 181221: Review Outer HCal Integration/Installation Tooling/Fixtures/Procedures Safety/Certification
- S350300: BNL_UDF_Old Activity Name 181221: Address Action Items from Outer Hcal Integration/Installation Tooling/Fixtures/Procedures Design & Safety Reviews
- S350400: BNL_UDF_Old Activity Name 181221: Design/Safety Reviews Complete, Outer HCal Integration/Installation Tooling/Fixtures/Procedures Ready for Service
- S350500: BNL_UDF_Old Activity Name 181221: Outer HCal Sectors Ready for Installation
- S1002439: Scheduler's Notes: 180413 ELM per GRY: / assume 4 people / BNL_UDF_Adhoc Comments: 180227 ELM rsrc assign per DLynch / BNL_UDF_Old Activity Name 181221: Transport Assembled Outer HCal Sectors to AH (Partial Shipment) - Labor
- S350600: Scheduler's Notes: 180413 ELM per GRY: / assume 4 people / BNL_UDF_Adhoc Comments: 180227 ELM rsrc assign per DLynch / BNL_UDF_Old Activity Name 181221: Transport Assembled Outer HCal Sectors to AH (Partial Shipment) - Labor
- S350700: BNL_UDF_Old Activity Name 181221: Transport Assembled Outer HCal Sectors to AH (Partial Shipment) - M&S
- S1002519: Scheduler's Notes: 180413 ELM per GRY: / assume 3 people / BNL_UDF_Adhoc Comments: 180227 ELM rsrc assign per DLynch / BNL_UDF_Old Activity Name 181221: Install Partial Outer HCal (Prior to SC Magnet Install) - Labor
- S350800: Scheduler's Notes: 180413 ELM per GRY: / assume 3 people / BNL_UDF_Adhoc Comments: 180227 ELM rsrc assign per DLynch / BNL_UDF_Old Activity Name 181221: Install Partial Outer HCal (Prior to SC Magnet Install) - Labor
- S350900: BNL_UDF_Old Activity Name 181221: Install Partial Outer HCal (Prior to SC Magnet Install) - M&S
- S350910: Scheduler's Notes: 180413 ELM per GRY: / assume 3 people / BNL_UDF_Adhoc Comments: 180227 ELM rsrc assign per DLynch / BNL_UDF_Old Activity Name 181221: Install Partial Outer HCal (Prior to SC Magnet Install) - Labor
- S350950: BNL_UDF_Adhoc Comments: 180227 ELM rsrc assign per DLynch; 180220 ELM staff change per EOB / BNL_UDF_Old Activity Name 181221: Align/Survey SC Magnet to Cradle - Labor
- S1002599: Scheduler's Notes: 180413 ELM per GRY: / assume 2 people / BNL_UDF_Adhoc Comments: 180227 ELM rsrc assign per DLynch / BNL_UDF_Old Activity Name 181221: Transport Remainder of Outer Hcal Sectors to AH - Labor
- S351000: Scheduler's Notes: 180413 ELM per GRY: / assume 2 people / BNL_UDF_Adhoc Comments: 180227 ELM rsrc assign per DLynch / BNL_UDF_Old Activity Name 181221: Transport Remainder of Outer Hcal Sectors to AH - Labor
- S351100: BNL_UDF_Old Activity Name 181221: Transport Remainder of Outer Hcal Sectors to AH - M&S
- S1002679: Scheduler's Notes: 180413 ELM per GRY: / assume 4 people / BNL_UDF_Adhoc Comments: 180227 ELM rsrc assign per DLynch / BNL_UDF_Old Activity Name 181221: Install Remainder of Outer HCal Sectors - Labor
- S351200: Scheduler's Notes: 180413 ELM per GRY: / assume 4 people / BNL_UDF_Adhoc Comments: 180227 ELM rsrc assign per DLynch / BNL_UDF_Old Activity Name 181221: Install Remainder of Outer HCal Sectors - Labor
- S351300: BNL_UDF_Old Activity Name 181221: Install Remainder of Outer HCal Sectors - M&S
- S351310: BNL_UDF_Old Activity Name 181221: Install Remainder of Outer HCal Sectors - M&S
- S351400: Scheduler's Notes: 180413 ELM per GRY: / assume 2 people / BNL_UDF_Adhoc Comments: 180227 ELM rsrc assign per DLynch / BNL_UDF_Old Activity Name 181221: Align/Survey Outer Hcal to Centerline - Labor
- S351410: Scheduler's Notes: 180413 ELM per GRY: / assume 2 people / BNL_UDF_Adhoc Comments: 180227 ELM rsrc assign per DLynch / BNL_UDF_Old Activity Name 181221: Align/Survey Outer Hcal to Centerline - Labor
- S351500: BNL_UDF_Old Activity Name 181221: Align/Survey Outer Hcal to Centerline - M&S
- S351600: Scheduler's Notes: 180413 ELM per GRY: / assume 2 people / BNL_UDF_Adhoc Comments: 180227 ELM rsrc assign per DLynch / BNL_UDF_Old Activity Name 181221: Install Outer HCal Cables and Services - Labor
- S351700: BNL_UDF_Old Activity Name 181221: Install Outer HCal Cables and Services - M&S
- S351800: BNL_UDF_Old Activity Name 181221: Review Outer HCal for Operational Readiness (ORR)
- S351900: BNL_UDF_Old Activity Name 181221: Address Action Items from Outer Hcal ORR
- S352000: Scheduler's Notes: 180413 ELM per GRY: / assume 2 people / BNL_UDF_Adhoc Comments: 180416 ELM dur per GRY; 180227 ELM rsrc assign per DLynch / BNL_UDF_Old Activity Name 181221: Commission Outer HCal - Labor - Fund Category C
- S352100: Scheduler's Notes: 180413 ELM per GRY: / assume 2 people / BNL_UDF_Adhoc Comments: 180416 ELM dur per GRY; 180227 ELM rsrc assign per DLynch / BNL_UDF_Old Activity Name 181221: Commission Outer HCal - Labor - Fund Category T
- S352200: BNL_UDF_Adhoc Comments: 180416 ELM dur per GRY / BNL_UDF_Old Activity Name 181221: Commission Outer HCal - M&S

| ID | WBS | Activity | Type | Duration | Start | Finish | Predecessors | Complete | Remaining | Planned start | Planned finish | Total float | Free float | Expected finish | Resources | Cost | BNL_UDF_Status Comments | BNL_UDF_Temp Text 01 | BNL_UDF_Percent Complete | BNL_UDF_OPC TEC (deprecated) | BNL_UDF_Old Activity ID 181221 | BNL_Cobra WP | RG Check | BNL_Activity Status | BNL_Fund Source | BNL_Estimator | BNL_Cost Basis | BNL_Location | BNL_EDIA | BNL_CAM | BNL_Institution | BNL_OPC TEC (deprecated) | BNL_WBS | BNL_EVT | BNL_Master Control Account | BNL_Account Number | BNL_PCR ID | BNL_Cobra Control Account | BNL_WBS_Hierarchical | Indicator - Procurement | Indicator - Float | BNL_UDF_Remaining Tot Cost | BNL_UDF_Percent_remaining | BNL_Proc Sig | BNL_Milestone Level | Temp | BNL_UDF_Temp Text 02 | Target Milestone Date | Variance | PMP Milestones |
| --- | --- | --- | --- | --- | --- | --- | --- | --- | --- | --- | --- | --- | --- | --- | --- | --- | --- | --- | --- | --- | --- | --- | --- | --- | --- | --- | --- | --- | --- | --- | --- | --- | --- | --- | --- | --- | --- | --- | --- | --- | --- | --- | --- | --- | --- | --- | --- | --- | --- | --- |
|  | 05 | **SC Magnet Installation** |  |  | 2020-04-15 | 2022-01-13 |  |  |  |  |  |  |  |  |  |  |  |  |  |  |  |  |  |  |  |  |  |  |  |  |  |  |  |  |  |  |  |  |  |  |  |  |  |  |  |  |  |  |  |  |
| S1003399 |  | Design SC Magnet Integration/Installation Tooling/Fixtures/Procedures - Physics Resource(s) |  | 30d | 2020-04-15 A | 2020-09-30 A | S100500, S101015 SS | 100% |  | 2020-10-01 | 2020-11-13 |  |  |  | PROF4 PO M [120 h]; TECH3 PO M [24 h]; TECH3 PO D [120 h] | 35,128.55 | 190318 ELM logic per GRY | S352300 | 0 | S301900 | S301900 | S1003399 | CA | Not Started | C | Feder, Russ | L4 | BNL | Installation | Russ Feder | BNL | null | POM02.2.05.05 | C | 2.05 | 16727 | 003 | 2.05 | 05 |  |  |  |  |  |  |  |  |  |  |  |
| S352300 |  | Design SC Magnet Integration/Installation Tooling/Fixtures/Procedures - CA-D Resource(s) |  | 30d | 2020-04-15 A | 2020-09-30 A | S100500, S101015 SS | 100% |  | 2020-10-01 | 2020-11-13 |  |  |  | PROF4 AD [40 h] | 6,067.32 | 190318 ELM logic per GRY | S352300 | 0 | S301900 | S301900 | S352300 | CA | Not Started | C | Feder, Russ | L4 | BNL | Installation | Russ Feder | BNL | null | POM02.2.05.05 | C | 2.05 | 16727 | 003 | 2.05 | 05 |  |  |  |  |  |  |  |  |  |  |  |
| S1003639 |  | Review sPHENIX SC Magnet Integration/Installation Tooling/Fixtures/Procedures Safety/Certification - Physics |  | 10d | 2020-12-15 A | 2021-01-27 A | S352600, S1003559 | 100% |  | 2021-03-15 | 2021-03-26 |  |  |  | PROF4 PO M [8 h]; TECH3 PO M [8 h]; TECH3 PO D [8 h] | 3,094.2 |  | S352700 | 0 | S302300 | S302300 | S1003639 | CA | Not Started | C | Feder, Russ | L4 | BNL | Installation | Russ Feder | BNL | null | POM02.2.05.05 | C | 2.05 | 16727 |  | 2.05 | 05 |  |  |  |  |  |  |  |  |  |  |  |
| S1003559 |  | Prepare SC Magnet Integration/Installation Procedures - Physics Resource(s) |  | 10d | 2021-02-08 A | 2021-02-23 A | S352400, S352500, S1003479 | 100% |  | 2021-04-27 | 2021-05-10 |  |  |  | PROF4 PO M [20 h]; TECH3 PO D [10 h] | 4,209.12 |  | S352600 | 0 | S302200 | S302200 | S1003559 | CA | Not Started | C | Feder, Russ | L4 | BNL | Installation | Russ Feder | BNL | null | POM02.2.05.05 | C | 2.05 | 16727 |  | 2.05 | 05 |  |  |  |  |  |  |  |  |  |  |  |
| S352600 |  | Prepare SC Magnet Integration/Installation Procedures - CA-D Resource(s) |  | 10d | 2021-02-08 A | 2021-02-23 A | S352400, S352500, S1003479 | 100% |  | 2021-04-27 | 2021-05-10 |  |  |  | PROF4 AD [8 h]; TECH4 AD [80 h] | 11,974.47 |  | S352600 | 0 | S302200 | S302200 | S352600 | CA | Not Started | C | Feder, Russ | L4 | BNL | Installation | Russ Feder | BNL | null | POM02.2.05.05 | C | 2.05 | 16727 |  | 2.05 | 05 |  |  |  |  |  |  |  |  |  |  |  |
| S1003479 |  | Fabricate/Procure SC Magnet Integration/Installation Tooling/Fixtures - Labor - Physics Resource(s) |  | 60d | 2021-03-17 A | 2021-06-24 | S352300, S1003399 | 75% | 18d | 2021-04-01 | 2021-06-24 | 63d | 0d | 2021-06-24 | PROF4 PO M [30 h]; TECH3 PO M [10 h]; TECH3 PO D [10 h] | 6,901.4 |  | S352400 | 0 | S302000 | S302000 | S1003479 | CA | Not Started | C | Feder, Russ | L4 | BNL | Fab & Assy | Russ Feder | BNL | null | POM02.2.05.05 | C | 2.05 | 16727 |  | 2.05 | 05 |  |  |  |  |  |  |  |  |  |  |  |
| S352400 |  | Fabricate/Procure SC Magnet Integration/Installation Tooling/Fixtures - Labor - CA-D Resource(s) |  | 60d | 2021-03-17 A | 2021-06-24 | S352300, S1003399 | 75% | 18d | 2021-04-01 | 2021-06-24 | 63d | 0d | 2021-06-24 | PROF4 AD [10 h] | 1,516.83 |  | S352400 | 0 | S302000 | S302000 | S352400 | CA | Not Started | C | Feder, Russ | L4 | BNL | Fab & Assy | Russ Feder | BNL | null | POM02.2.05.05 | C | 2.05 | 16727 |  | 2.05 | 05 |  |  |  |  |  |  |  |  |  |  |  |
| S352500 |  | Fabricate/Procure SC Magnet Integration/Installation Tooling/Fixtures - M&S |  | 60d | 2021-03-17 A | 2021-06-24 | S352400 SS, S1003479 SS | 75% | 18d | 2021-04-01 | 2021-06-24 | 63d | 0d | 2021-06-24 | Material (Purchase (1st $2M) [30000 h] | 34,820.53 |  | S352500 | 0 | S302100 | S302100 | S352500 | CA | Not Started | C | Feder, Russ | M4 | BNL | Fab & Assy | Russ Feder | BNL | null | POM02.2.05.05 | C | 2.05 | 16727 |  | 2.05 | 05 | UDF_G1 | UDF_G3 | 34820.5293 | 1 | TBD |  |  |  |  |  |  |
| S352700 |  | Review sPHENIX SC Magnet Integration/Installation Tooling/Fixtures/Procedures Safety/Certification- CA-D |  | 10d | 2021-03-22 A | 2021-03-26 A | S352600, S1003559 | 100% |  | 2021-06-25 | 2021-07-09 |  |  |  | PROF4 AD [4 h]; TECH4 AD [4 h] | 1,144.78 |  | S352700 | 0 | S302300 | S302300 | S352700 | CA | Not Started | C | Feder, Russ | L4 | BNL | Installation | Russ Feder | BNL | null | POM02.2.05.05 | C | 2.05 | 16727 |  | 2.05 | 05 |  |  |  |  |  |  |  |  |  |  |  |
| S352800 |  | Address Action Items from SC Magnet Integration/Installation Tooling/Fixtures/Procedures Design & Safety Reviews |  | 10d | 2021-03-22 A | 2021-03-26 A | S352700, S1003639 | 100% |  | 2021-07-12 | 2021-07-23 |  |  |  | PROF4 PO M [8 h]; TECH3 PO M [8 h]; TECH3 PO D [8 h] | 3,094.2 |  | S352800 | 0 | S302400 | S302400 | S352800 | CA | Not Started | C | Feder, Russ | L4 | BNL | Installation | Russ Feder | BNL | null | POM02.2.05.05 | C | 2.05 | 16727 |  | 2.05 | 05 |  |  |  |  |  |  |  |  |  |  |  |
| S352900 |  | Design/Safety Reviews Complete, sPHENIX SC Magnet Integration/Installation Tooling/Fixtures/Procedures Ready for Service | milestone | 0d | 2021-06-24 | 2021-06-24 | S352800 |  |  |  |  | 63d | 0d |  |  |  |  | S352900 | 0 | S302500 | S302500 |  | NOCA | Not Started | C | Feder, Russ |  | BNL | Management Safety Reviews | Russ Feder | BNL |  | POM02.2.05.05 |  |  |  |  |  | 05 |  |  |  |  |  | L3 |  |  |  |  |  |
| S353000 |  | Ready to Install SC Magnet | milestone | 0d | 2021-06-24 | 2021-06-24 | S352900, S281300 |  |  |  |  | 63d |  |  |  |  |  | S353000 | 0 | S302600 | S302600 |  | NOCA | Not Started | C | Feder, Russ |  | BNL | Fab & Assy | Russ Feder | BNL |  | POM02.2.05.05 |  |  |  |  |  | 05 |  |  |  |  |  | L3 |  |  |  |  |  |
| S353100 |  | Transport SC Magnet from 912 to AH - Labor - Physics Resource(s) |  | 2d | 2021-09-24 | 2021-09-27 | S353000, S349100, S349200, S1002239 |  |  |  |  | 0d |  |  | PROF4 PO M [16 h]; TECH3 PO D [4 h]; TECH3 PO M [32 h] | 6,658.58 |  | PO&AD | 0 | S302700 | S302700 | S353100 | CA | Not Started | C | Feder, Russ | L4 | BNL | Fab & Assy | Russ Feder | BNL | null | POM02.2.05.05 | C | 2.05 | 16727 |  | 2.05 | 05 |  |  |  |  |  |  | PO |  |  |  |  |
| S353110 |  | Transport SC Magnet from 912 to AH - Labor - CA-D Resource(s) |  | 2d | 2021-09-24 | 2021-09-27 | S353100 SS |  |  |  |  | 0d |  |  | CRAFT3 [64 h]; PROF4 AD [32 h] | 13,098.56 |  | PO&ADS353110 | 0 | S302700 | S302700 | S353110 | CA | Not Started | C | Feder, Russ | L4 | BNL | Fab & Assy | Russ Feder | BNL | null | POM02.2.05.05 | C | 2.05 | 16728 |  | 2.05 | 05 |  |  |  |  |  |  | C-AD | S353110 |  |  |  |
| S353200 |  | Transport SC Magnet from 912 to AH - M&S |  | 2d | 2021-09-24 | 2021-09-27 | S353100 SS, S353110 SS |  |  |  |  | 0d |  |  | Material (Purchase (1st $2M) [1500 h] | 1,741.03 |  | S353200 | 0 | S302800 | S302800 | S353200 | CA | Not Started | C | Feder, Russ | M4 | BNL | Fab & Assy | Russ Feder | BNL | null | POM02.2.05.05 | C | 2.05 | 16727 |  | 2.05 | 05 | UDF_G2 | UDF_G1 | 1741.026465 | 1 |  |  |  |  |  |  |  |
| S353300 |  | Install SC Magnet on Cradle - Labor - Physics Resource(s) |  | 2d | 2021-09-28 | 2021-09-29 | S353100, S353200, S353110 |  |  |  |  | 0d |  |  | PROF4 PO M [16 h]; TECH3 PO D [2 h]; TECH3 PO M [32 h] | 6,423.48 |  | PO&AD | 0 | S302900 | S302900 | S353300 | CA | Not Started | C | Feder, Russ | L4 | BNL | Installation | Russ Feder | BNL | null | POM02.2.05.05 | C | 2.05 | 16727 |  | 2.05 | 05 |  |  |  |  |  |  | PO |  |  |  |  |
| S353310 |  | Install SC Magnet on Cradle - Labor - CA-D Resource(s) |  | 2d | 2021-09-28 | 2021-09-29 | S353300 SS |  |  |  |  | 0d |  |  | CRAFT3 [64 h]; PROF4 AD [32 h] | 13,098.56 |  | PO&ADS353310 | 0 | S302900 | S302900 | S353310 | CA | Not Started | C | Feder, Russ | L4 | BNL | Installation | Russ Feder | BNL | null | POM02.2.05.05 | C | 2.05 | 16728 |  | 2.05 | 05 |  |  |  |  |  |  | C-AD | S353310 |  |  |  |
| S353400 |  | Install SC Magnet on Cradle - M&S |  | 2d | 2021-09-28 | 2021-09-29 | S353300 SS |  |  |  |  | 0d |  |  | Material (Purchase (1st $2M) [1500 h] | 1,741.03 |  | S353400 | 0 | S303000 | S303000 | S353400 | CA | Not Started | C | Feder, Russ | M4 | BNL | Fab & Assy | Russ Feder | BNL | null | POM02.2.05.05 | C | 2.05 | 16727 |  | 2.05 | 05 | UDF_G2 | UDF_G1 | 1741.026465 | 1 |  |  |  |  |  |  |  |
| S353410 |  | Completed - Install SC Magnet on Cradle | milestone | 0d | 2021-09-29 | 2021-09-29 | S353300 FF, S353310 FF, S353400 FF |  |  |  |  | 0d |  |  |  |  |  | S353400 | 0 | S303000 | S303000 |  | NOCA | Not Started | C | Feder, Russ |  | BNL | Fab & Assy | Russ Feder | BNL |  | POM02.2.05.05 |  |  |  |  |  | 05 |  |  |  |  |  | L5 |  |  | 2021-11-30 | 39 | PMP_2x |
| S353500 |  | Align/Survey SC Magnet to Cradle - Labor - Physics Resource(s) |  | 10d | 2021-09-30 | 2021-10-14 | S353410 |  |  |  |  | 0d |  |  | TECH3 PO M [80 h] | 9,657.56 |  | PO&AD | 0 | S303100 | S303100 | S353500 | CA | Not Started | C | Feder, Russ | L4 | BNL | Installation | Russ Feder | BNL | null | POM02.2.05.05 | C | 2.05 | 16727 |  | 2.05 | 05 |  |  |  |  |  |  | PO |  |  |  |  |
| S353510 |  | Align/Survey SC Magnet to Cradle - Labor - CA-D Resource(s) |  | 10d | 2021-09-30 | 2021-10-14 | S353500 SS |  |  |  |  | 0d |  |  | CRAFT3 [160 h]; TECH3 AD [240 h] | 50,140.96 |  | PO&ADS353510 | 0 | S303100 | S303100 | S353510 | CA | Not Started | C | Feder, Russ | L4 | BNL | Installation | Russ Feder | BNL | null | POM02.2.05.05 | C | 2.05 | 16728 |  | 2.05 | 05 |  |  |  |  |  |  | C-AD | S353510 |  |  |  |
| S353600 |  | Align/Survey SC Magnet to Cradle - M&S |  | 10d | 2021-09-30 | 2021-10-14 | S353500 SS, S353510 SS |  |  |  |  | 0d |  |  | Material (Purchase (1st $2M) [3500 h] | 4,135.52 |  | S353600 | 0 | S303200 | S303200 | S353600 | CA | Not Started | C | Feder, Russ | M4 | BNL | Fab & Assy | Russ Feder | BNL | null | POM02.2.05.05 | C | 2.05 | 16727 |  | 2.05 | 05 | UDF_G2 | UDF_G1 | 4070.519873 | 1 |  |  |  |  |  |  |  |
| S353700 |  | Prep SC Magnet for Run (Cryo) - Labor - Physics Resource(s) |  | 20d | 2021-10-15 | 2021-11-12 | S353500, S353600, S353510 |  |  |  |  | 188d | 0d |  | PROF4 PO M [16 h]; TECH3 PO D [16 h]; TECH3 PO M [16 h] | 6,374.04 |  | PO&AD | 0 | S303300 | S303300 | S353700 | CA | Not Started | C | Feder, Russ | L4 | BNL | Fab & Assy | Russ Feder | BNL | null | POM02.2.05.05 | C | 2.05 | 16727 |  | 2.05 | 05 |  |  |  |  |  |  | PO |  |  |  |  |
| S353710 |  | Prep SC Magnet for Run (Cryo) - Labor - CA-D Resource(s) |  | 20d | 2021-10-15 | 2021-11-12 | S353700 SS |  |  |  |  | 188d | 0d |  | TECH3 AD [320 h]; PROF6 AD [16 h]; PROF4 AD [40 h] | 48,268.37 |  | PO&ADS353710 | 0 | S303300 | S303300 | S353710 | CA | Not Started | C | Feder, Russ | L4 | BNL | Fab & Assy | Russ Feder | BNL | null | POM02.2.05.05 | C | 2.05 | 16728 |  | 2.05 | 05 |  |  |  |  |  |  | C-AD | S353710 |  |  |  |
| S353800 |  | Prep SC Magnet for Run (Cryo) - M&S |  | 20d | 2021-10-15 | 2021-11-12 | S353700 SS, S353710 SS |  |  |  |  | 188d | 0d |  | Material (Purchase (1st $2M) [3500 h] | 4,143.64 |  | S353800 | 0 | S303400 | S303400 | S353800 | CA | Not Started | C | Feder, Russ | M4 | BNL | Fab & Assy | Russ Feder | BNL | null | POM02.2.05.05 | C | 2.05 | 16727 |  | 2.05 | 05 | UDF_G2 | UDF_G3 | 4143.642965 | 1 |  |  |  |  |  |  |  |
| S353900 |  | Prep SC Magnet for Run (Electric) - Labor - Physics Resource(s) |  | 20d | 2021-11-15 | 2021-12-14 | S353700, S353800, S353710 |  |  |  |  | 188d | 0d |  | PROF4 PO M [16 h]; TECH3 PO D [16 h]; TECH3 PO E [160 h] | 23,808.44 |  | PO&AD | 0 | S303500 | S303500 | S353900 | CA | Not Started | C | Feder, Russ | L4 | BNL | Fab & Assy | Russ Feder | BNL | null | POM02.2.05.05 | C | 2.05 | 16727 |  | 2.05 | 05 |  |  |  |  |  |  | PO |  |  |  |  |
| S353910 |  | Prep SC Magnet for Run (Electric) - Labor - CA-D Resource(s) |  | 20d | 2021-11-15 | 2021-12-14 | S353900 SS |  |  |  |  | 188d | 0d |  | TECH3 AD [160 h]; PROF6 AD [16 h]; PROF4 AD [40 h] | 28,896.83 |  | PO&ADS353910 | 0 | S303500 | S303500 | S353910 | CA | Not Started | C | Feder, Russ | L4 | BNL | Fab & Assy | Russ Feder | BNL | null | POM02.2.05.05 | C | 2.05 | 16728 |  | 2.05 | 05 |  |  |  |  |  |  | C-AD | S353910 |  |  |  |
| S354000 |  | Prep SC Magnet for Run (Electric) - M&S |  | 20d | 2021-11-15 | 2021-12-14 | S353900 SS, S353910 SS |  |  |  |  | 188d | 0d |  | Material (Purchase (1st $2M) [3500 h] | 4,143.64 |  | S354000 | 0 | S303600 | S303600 | S354000 | CA | Not Started | C | Feder, Russ | M4 | BNL | Fab & Assy | Russ Feder | BNL | null | POM02.2.05.05 | C | 2.05 | 16727 |  | 2.05 | 05 | UDF_G2 | UDF_G3 | 4143.642965 | 1 |  |  |  |  |  |  |  |
| S354100 |  | SC Magnet - Operational Readiness Review (ORR) - Physics Resource(s) |  | 10d | 2021-12-15 | 2021-12-29 | S353900, S354000, S353910 |  |  |  |  | 188d | 0d |  | PROF4 PO M [8 h]; TECH3 PO D [8 h]; TECH3 PO M [8 h] | 3,187.02 | 190416 ELM name per GRY | PO&AD | 0 | S303700 | S303700 | S354100 | CA | Not Started | C | Feder, Russ | L4 | BNL | Commissioning | Russ Feder | BNL | null | POM02.2.05.05 | C | 2.05 | 16727 | 004 | 2.05 | 05 |  |  |  |  |  |  | PO |  |  |  |  |
| S354110 |  | SC Magnet - Operational Readiness Review (ORR) - CA-D Resource(s) |  | 10d | 2021-12-15 | 2021-12-29 | S354100 SS |  |  |  |  | 188d | 0d |  | TECH3 AD [8 h]; PROF6 AD [8 h]; PROF4 AD [8 h] | 3,856.41 | 190416 ELM name per GRY | PO&ADS354110 | 0 | S303700 | S303700 | S354110 | CA | Not Started | C | Feder, Russ | L4 | BNL | Commissioning | Russ Feder | BNL | null | POM02.2.05.05 | C | 2.05 | 16728 | 004 | 2.05 | 05 |  |  |  |  |  |  | C-AD | S354110 |  |  |  |
| S354200 |  | Address Action Items from SC Magnet ORR - Physics Resource(s) |  | 10d | 2021-12-30 | 2022-01-13 | S354100, S354110 |  |  |  |  | 188d | 0d |  | PROF4 PO M [8 h]; TECH3 PO D [8 h]; TECH3 PO M [8 h] | 3,187.02 |  | PO&AD | 0 | S303800 | S303800 | S354200 | CA | Not Started | C | Feder, Russ | L4 | BNL | Commissioning | Russ Feder | BNL | null | POM02.2.05.05 | C | 2.05 | 16727 |  | 2.05 | 05 |  |  |  |  |  |  | PO |  |  |  |  |
| S354210 |  | Address Action Items from SC Magnet ORR - CA-D Resource(s) |  | 10d | 2021-12-30 | 2022-01-13 | S354200 SS |  |  |  |  | 188d |  |  | TECH3 AD [8 h]; PROF6 AD [8 h]; PROF4 AD [8 h] | 3,856.41 |  | PO&ADS354210 | 0 | S303800 | S303800 | S354210 | CA | Not Started | C | Feder, Russ | L4 | BNL | Commissioning | Russ Feder | BNL | null | POM02.2.05.05 | C | 2.05 | 16728 |  | 2.05 | 05 |  |  |  |  |  |  | C-AD | S354210 |  |  |  |

Notes:
- S1003399: BNL_UDF_Old Activity Name 181221: Design SC Magnet Integration/Installation Tooling/Fixtures/Procedures
- S352300: BNL_UDF_Old Activity Name 181221: Design SC Magnet Integration/Installation Tooling/Fixtures/Procedures
- S1003639: BNL_UDF_Old Activity Name 181221: Review sPHENIX SC Magnet Integration/Installation Tooling/Fixtures/Procedures Safety/Certification
- S1003559: BNL_UDF_Adhoc Comments: 180227 ELM rsrc assign per DLynch / BNL_UDF_Old Activity Name 181221: Prepare SC Magnet Integration/Installation Procedures
- S352600: BNL_UDF_Adhoc Comments: 180227 ELM rsrc assign per DLynch / BNL_UDF_Old Activity Name 181221: Prepare SC Magnet Integration/Installation Procedures
- S1003479: BNL_UDF_Old Activity Name 181221: Fabricate/Procure SC Magnet Integration/Installation Tooling/Fixtures - Labor
- S352400: BNL_UDF_Old Activity Name 181221: Fabricate/Procure SC Magnet Integration/Installation Tooling/Fixtures - Labor
- S352500: BNL_UDF_Old Activity Name 181221: Fabricate/Procure SC Magnet Integration/Installation Tooling/Fixtures - M&S
- S352700: BNL_UDF_Old Activity Name 181221: Review sPHENIX SC Magnet Integration/Installation Tooling/Fixtures/Procedures Safety/Certification
- S352800: BNL_UDF_Old Activity Name 181221: Address Action Items from SC Magnet Integration/Installation Tooling/Fixtures/Procedures Design & Safety Reviews
- S352900: BNL_UDF_Old Activity Name 181221: Design/Safety Reviews Complete, sPHENIX SC Magnet Integration/Installation Tooling/Fixtures/Procedures Ready for Service
- S353000: BNL_UDF_Old Activity Name 181221: Ready to Install SC Magnet
- S353100: BNL_UDF_Adhoc Comments: 180227 ELM rsrc assign per DLynch / BNL_UDF_Old Activity Name 181221: Transport SC Magnet from 912 to AH - Labor
- S353110: BNL_UDF_Adhoc Comments: 180227 ELM rsrc assign per DLynch / BNL_UDF_Old Activity Name 181221: Transport SC Magnet from 912 to AH - Labor
- S353200: BNL_UDF_Old Activity Name 181221: Transport SC Magnet from 912 to AH - M&S
- S353300: BNL_UDF_Adhoc Comments: 180227 ELM rsrc assign per DLynch / BNL_UDF_Old Activity Name 181221: Install SC Magnet on Cradle - Labor
- S353310: BNL_UDF_Adhoc Comments: 180227 ELM rsrc assign per DLynch / BNL_UDF_Old Activity Name 181221: Install SC Magnet on Cradle - Labor
- S353400: BNL_UDF_Old Activity Name 181221: Install SC Magnet on Cradle - M&S
- S353410: BNL_UDF_Old Activity Name 181221: Install SC Magnet on Cradle - M&S
- S353500: BNL_UDF_Adhoc Comments: 180227 ELM rsrc assign per DLynch; 180220 ELM staff change per EOB / BNL_UDF_Old Activity Name 181221: Align/Survey SC Magnet to Cradle - Labor
- S353510: BNL_UDF_Adhoc Comments: 180227 ELM rsrc assign per DLynch; 180220 ELM staff change per EOB / BNL_UDF_Old Activity Name 181221: Align/Survey SC Magnet to Cradle - Labor
- S353600: BNL_UDF_Old Activity Name 181221: Align/Survey SC Magnet to Cradle - M&S
- S353700: BNL_UDF_Adhoc Comments: 180227 ELM rsrc assign per DLynch; 180220 ELM staff change per EOB / BNL_UDF_Old Activity Name 181221: Prep SC Magnet for Run (Cryo) - Labor
- S353710: BNL_UDF_Adhoc Comments: 180227 ELM rsrc assign per DLynch; 180220 ELM staff change per EOB / BNL_UDF_Old Activity Name 181221: Prep SC Magnet for Run (Cryo) - Labor
- S353800: BNL_UDF_Old Activity Name 181221: Prep SC Magnet for Run (Cryo) - M&S
- S353900: BNL_UDF_Adhoc Comments: 180227 ELM rsrc assign per DLynch / BNL_UDF_Old Activity Name 181221: Prep SC Magnet for Run (Electric) - Labor
- S353910: BNL_UDF_Adhoc Comments: 180227 ELM rsrc assign per DLynch / BNL_UDF_Old Activity Name 181221: Prep SC Magnet for Run (Electric) - Labor
- S354000: BNL_UDF_Old Activity Name 181221: Prep SC Magnet for Run (Electric) - M&S
- S354100: BNL_UDF_Old Activity Name 181221: Review SC Magnet for Operational Readiness (ORR)
- S354110: BNL_UDF_Old Activity Name 181221: Review SC Magnet for Operational Readiness (ORR)
- S354200: BNL_UDF_Adhoc Comments: 180227 ELM rsrc assign per DLynch / BNL_UDF_Old Activity Name 181221: Address Action Items from SC Magnet ORR
- S354210: BNL_UDF_Adhoc Comments: 180227 ELM rsrc assign per DLynch / BNL_UDF_Old Activity Name 181221: Address Action Items from SC Magnet ORR

| ID | WBS | Activity | Type | Duration | Start | Finish | Predecessors | Complete | Remaining | Planned start | Planned finish | Total float | Free float | Constraint | Expected finish | Resources | Cost | BNL_UDF_Temp Text 01 | BNL_UDF_Percent Complete | BNL_UDF_OPC TEC (deprecated) | BNL_UDF_Temp Date 01 | BNL_UDF_Old Activity ID 181221 | RG Check | BNL_Activity Status | BNL_Fund Source | BNL_Estimator | BNL_Cost Basis | BNL_Location | BNL_EDIA | BNL_CAM | BNL_Institution | BNL_OPC TEC (deprecated) | BNL_WBS | BNL_EVT | BNL_Split Activity | BNL_WBS_Hierarchical | Completed | BNL_Cobra WP | BNL_Master Control Account | BNL_Account Number | BNL_PCR ID | BNL_Cobra Control Account | Additional EVT documentation required | BNL_UDF_Adhoc Comments | Indicator - Procurement | Indicator - Float | BNL_UDF_Remaining Tot Cost | BNL_UDF_Percent_remaining | BNL_UDF_Exclude | BNL_Proc Sig | BNL_Obligation | BNL_Milestone Level | Temp | BNL_UDF_Temp Text 02 |
| --- | --- | --- | --- | --- | --- | --- | --- | --- | --- | --- | --- | --- | --- | --- | --- | --- | --- | --- | --- | --- | --- | --- | --- | --- | --- | --- | --- | --- | --- | --- | --- | --- | --- | --- | --- | --- | --- | --- | --- | --- | --- | --- | --- | --- | --- | --- | --- | --- | --- | --- | --- | --- | --- | --- |
|  | 06 | **Inner Hcal Installation** |  |  | 2017-02-01 | 2022-03-04 |  |  |  |  |  |  |  |  |  |  |  |  |  |  |  |  |  |  |  |  |  |  |  |  |  |  |  |  |  |  |  |  |  |  |  |  |  |  |  |  |  |  |  |  |  |  |  |  |
| S354300 |  | Design Inner HCal Integration/Installation Tooling/Fixtures FY18 |  | 418d | 2017-02-01 A | 2018-09-28 A | S100090 SS | 100% |  |  |  |  |  |  |  |  |  | S354300 | 100 | S303900 | 2019-06-29 | S303900 | NOCA | Completed | C | Feder, Russ | L4 | BNL | Installation | Russ Feder | BNL | null | POM02.2.05.06 | C | FY18 | 06 | yes |  |  |  |  |  |  |  |  |  |  |  |  |  |  |  |  |  |
| S354400 |  | Design Inner HCal Integration/Installation Tooling/Fixtures FY20 |  | 125d | 2019-10-01 A | 2021-06-03 | S354300, S101010 | 95% | 3d | 2019-10-01 | 2020-04-02 | 23d | 0d |  | 2021-06-03 | PROF4 PO M [60 h]; TECH3 PO D [120 h] | 22,530.56 | S354400 | 0 | S303900 | 2019-06-28 | S303950 | CA | In Progress | C | Feder, Russ | L4 | BNL | Installation | Russ Feder | BNL | null | POM02.2.05.06 | C | FY19 | 06 |  | S354400 | 2.05 | 16727 | 003 | 2.05 | Yes |  |  |  |  |  |  |  |  |  |  |  |
| S1003719 |  | Transport assembled Inner HCal Sectors to AH - Labor - Physics Resource(s) |  | 20d | 2021-02-08 A | 2021-02-24 A | S355100 | 100% |  | 2021-08-23 | 2021-09-20 |  |  |  |  | PROF4 PO M [16 h]; CRAFT3 [160 h]; TECH3 PO D [16 h]; TECH3 PO M [120 h] | 39,024.91 | S355200 | 0 | S304700 |  | S304700 | CA | Not Started | C | Feder, Russ | L4 | BNL | Fab & Assy | Russ Feder | BNL | null | POM02.2.05.06 | C |  | 06 |  | S1003719 | 2.05 | 16727 |  | 2.05 |  | 180227 ELM rsrc assign per DLynch |  |  |  |  |  |  |  |  |  |  |
| S354700 |  | Prepare Inner HCal Integration/Installation Tooling/Fixtures Procedures |  | 20d | 2021-02-08 A | 2021-09-27 | S354500, S354600 | 75% | 20d | 2021-06-25 | 2021-07-23 | 23d | 0d |  | 2021-07-23 | PROF4 PO M [80 h]; TECH3 PO D [40 h] | 16,836.47 | S354700 | 0 | S304200 |  | S304200 | CA | Not Started | C | Feder, Russ | L4 | BNL | Installation | Russ Feder | BNL | null | POM02.2.05.06 | C |  | 06 |  | S354700 | 2.05 | 16727 |  | 2.05 |  | 180227 ELM rsrc assign per DLynch |  |  |  |  |  |  |  |  |  |  |
| S355200 |  | Transport assembled Inner HCal Sectors to AH - Labor - CA-D Resource(s) |  | 20d | 2021-02-08 A | 2021-02-24 A | S355100 | 100% |  | 2021-08-23 | 2021-09-20 |  |  |  |  | PROF4 AD [8 h] | 1,213.46 | S355200 | 0 | S304700 |  | S304700 | CA | Not Started | C | Feder, Russ | L4 | BNL | Fab & Assy | Russ Feder | BNL | null | POM02.2.05.06 | C |  | 06 |  | S355200 | 2.05 | 16727 |  | 2.05 |  | 180227 ELM rsrc assign per DLynch |  |  |  |  |  |  |  |  |  |  |
| S355300 |  | Transport assembled Inner HCal Sectors to AH - M&S |  | 20d | 2021-02-08 A | 2021-02-24 A | S355200 SS, S1003719 SS | 100% |  | 2021-08-23 | 2021-09-20 |  |  |  |  | Material (Purchase (1st $2M) [500 h] | 580.34 | S355300 | 0 | S304800 |  | S304800 | CA | Not Started | C | Feder, Russ | M4 | BNL | Fab & Assy | Russ Feder | BNL | null | POM02.2.05.06 | C |  | 06 |  | S355300 | 2.05 | 16727 |  | 2.05 |  |  | UDF_G1 | UDF_G1 | 580.342155 | 1 |  |  |  |  |  |  |
| S354500 |  | Fabricate/Procure Inner HCal Integration/Installation Tooling/Fixtures - Labor |  | 60d | 2021-06-04 | 2021-08-27 | S101000, S354400 |  |  |  |  | 23d | 0d |  |  | PROF4 PO M [120 h]; TECH3 PO D [40 h] | 22,903.79 | S354500 | 0 | S304000 |  | S304000 | CA | Not Started | C | Feder, Russ | L4 | BNL | Fab & Assy | Russ Feder | BNL | null | POM02.2.05.06 | C |  | 06 |  | S354500 | 2.05 | 16727 | 003 | 2.05 |  |  |  |  |  |  |  |  |  |  |  |  |
| S354600 |  | Fabricate/Procure Inner HCal Integration/Installation Tooling/Fixtures - M&S |  | 60d | 2021-06-04 | 2021-08-27 | S354500 SS |  |  |  |  | 23d | 0d | start on or after 2020-07-01 |  | Material (Purchase (1st $2M) [80000 h] | 92,854.74 | S354600 | 0 | S304100 |  | S304100 | CA | Not Started | C | Feder, Russ | M5 | BNL | Fab & Assy | Russ Feder | BNL | null | POM02.2.05.06 | C |  | 06 |  | S354600 | 2.05 | 16727 | 016 | 2.05 |  |  | UDF_G1 | UDF_G1 | 92854.7448 | 1 | MP6LAEXCLUDE | TBD |  |  |  |  |
| OBLG356990 |  | Fabricate/Procure Inner HCal Integration/Installation Tooling/Fixtures - M&S |  | 1d | 2021-08-30 | 2021-08-30 | S354500 |  |  |  |  | 350d |  |  |  | Obligation Resource [91034 h] | 91,034 | S354600 | 0 | S304100 |  | S304100 |  | Not Started | C | Feder, Russ | M5 | BNL | Fab & Assy | Russ Feder | BNL | null | POM02.2.05.06 | C |  | 06 |  | S354600 | 2.05 | 16727 | 008C |  |  |  |  |  |  |  | MP6LAEXCLUDE | TBD | OBLG |  |  |  |
| S354800 |  | Review Inner HCal Integration/Installation Tooling/Fixtures/Procedures Safety/Certification |  | 10d | 2021-09-28 | 2021-10-12 | S354700 |  |  |  |  | 23d | 0d |  |  | PROF4 PO M [8 h]; TECH3 PO M [8 h]; TECH3 PO D [8 h] | 3,159.17 | S354800 | 0 | S304300 |  | S304300 | CA | Not Started | C | Feder, Russ | L4 | BNL | Installation | Russ Feder | BNL | null | POM02.2.05.06 | C |  | 06 |  | S354800 | 2.05 | 16727 |  | 2.05 |  |  |  |  |  |  |  |  |  |  |  |  |
| S354900 |  | Address Action Items from Inner Hcal Integration/Installation Tooling/Fixtures/Procedures Design & Safety Reviews |  | 10d | 2021-10-13 | 2021-10-26 | S354800 |  |  |  |  | 23d | 0d |  |  | PROF4 PO M [8 h]; TECH3 PO M [8 h]; TECH3 PO D [8 h] | 3,187.02 | S354900 | 0 | S304400 |  | S304400 | CA | Not Started | C | Feder, Russ | L4 | BNL | Installation | Russ Feder | BNL | null | POM02.2.05.06 | C |  | 06 |  | S354900 | 2.05 | 16727 |  | 2.05 |  |  |  |  |  |  |  |  |  |  |  |  |
| S355000 |  | Design/Safety Reviews Complete, Inner HCal Integration/Installation Tooling/Fixtures/Procedures Ready for Service | milestone | 0d | 2021-10-26 | 2021-10-26 | S354900 |  |  |  |  | 23d | 17d |  |  |  |  | S355000 | 0 | S304500 |  | S304500 | NOCA | Not Started | C | Feder, Russ |  | BNL | Management Safety Reviews | Russ Feder | BNL |  | POM02.2.05.06 |  |  | 06 |  |  |  |  |  |  |  |  |  |  |  |  |  |  |  | L3 |  |  |
| S355100 |  | Inner HCal Sectors Ready for Installation | milestone | 0d | 2021-11-19 | 2021-11-19 | S355000, S200100 |  |  |  |  | 6d | 0d |  |  |  |  | S355100 | 0 | S304600 |  | S304600 | NOCA | Not Started | C | Feder, Russ |  | BNL | Installation | Russ Feder | BNL |  | POM02.2.05.06 |  |  | 06 |  |  |  |  |  |  |  |  |  |  |  |  |  |  |  | L3 |  |  |
| S355400 |  | Install Inner Hcal Assembly Insertion Fixture - Labor |  | 4d | 2021-11-22 | 2021-11-29 | S355200, S355300, S1003719, S355000 |  |  |  |  | 6d | 0d |  |  | PROF4 PO M [4 h]; TECH3 PO D [4 h]; TECH3 PO M [80 h] | 10,795 | S355400 | 0 | S304900 |  | S304900 | CA | Not Started | C | Feder, Russ | L4 | BNL | Installation | Russ Feder | BNL | null | POM02.2.05.06 | C |  | 06 |  | S355400 | 2.05 | 16727 |  | 2.05 |  | 180227 ELM rsrc assign per DLynch |  |  |  |  |  |  |  |  |  |  |
| S355500 |  | Install Inner Hcal Assembly Insertion Fixture - M&S |  | 4d | 2021-11-22 | 2021-11-29 | S355400 SS |  |  |  |  | 6d | 0d |  |  | Material (Purchase (1st $2M) [500 h] | 591.95 | S355500 | 0 | S305000 |  | S305000 | CA | Not Started | C | Feder, Russ | M4 | BNL | Fab & Assy | Russ Feder | BNL | null | POM02.2.05.06 | C |  | 06 |  | S355500 | 2.05 | 16727 |  | 2.05 |  |  | UDF_G1 | UDF_G1 | 580.342155 | 1 |  |  |  |  |  |  |
| S355600 |  | Install Inner HCal assembly on Insertion Fixture - Labor |  | 4d | 2021-11-30 | 2021-12-03 | S355200, S355400, S355500, S355300, S1003719 |  |  |  |  | 6d | 0d |  |  | PROF4 PO M [64 h]; TECH3 PO D [64 h]; TECH3 PO M [512 h] | 79,736.52 | S355600 | 0 | S305100 |  | S305100 | CA | Not Started | C | Feder, Russ | L4 | BNL | Installation | Russ Feder | BNL | null | POM02.2.05.06 | C |  | 06 |  | S355600 | 2.05 | 16727 |  | 2.05 |  | 180227 ELM rsrc assign per DLynch |  |  |  |  |  |  |  |  |  |  |
| S355700 |  | Install Inner HCal assembly on Insertion Fixture - M&S |  | 4d | 2021-11-30 | 2021-12-03 | S355600 SS |  |  |  |  | 6d | 5d |  |  | Material (Purchase (1st $2M) [500 h] | 591.95 | S355700 | 0 | S305200 |  | S305200 | CA | Not Started | C | Feder, Russ | M4 | BNL | Fab & Assy | Russ Feder | BNL | null | POM02.2.05.06 | C |  | 06 |  | S355700 | 2.05 | 16727 |  | 2.05 |  |  | UDF_G2 | UDF_G1 | 580.342155 | 1 |  |  |  |  |  |  |
| S355800 |  | Install 1st Inner HCal Support Ring - Labor |  | 2d | 2021-12-13 | 2021-12-14 | S351400, S355600, S351500, S355700, S200100, S351410, S318100 |  |  |  |  | 1d | 0d |  |  | PROF4 PO M [8 h]; TECH3 PO D [2 h]; TECH3 PO M [32 h] | 5,366.32 | S355800 | 0 | S305300 |  | S305300 | CA | Not Started | C | Feder, Russ | L4 | BNL | Installation | Russ Feder | BNL | null | POM02.2.05.06 | C |  | 06 |  | S355800 | 2.05 | 16727 |  | 2.05 |  | 180227 ELM rsrc assign per DLynch |  |  |  |  |  |  |  |  |  |  |
| S355900 |  | Install 1st Inner HCal Support Ring - M&S |  | 2d | 2021-12-13 | 2021-12-14 | S355800 SS |  |  |  |  | 1d | 0d |  |  | Material (Purchase (1st $2M) [500 h] | 591.95 | S355900 | 0 | S305400 |  | S305400 | CA | Not Started | C | Feder, Russ | M4 | BNL | Fab & Assy | Russ Feder | BNL | null | POM02.2.05.06 | C |  | 06 |  | S355900 | 2.05 | 16727 |  | 2.05 |  |  | UDF_G2 | UDF_G1 | 591.948995 | 1 |  |  |  |  |  |  |
| S1003799 |  | Install Inner HCal - Labor - Physics Resource(s) |  | 2d | 2021-12-15 | 2021-12-16 | S355800, S355900 |  |  |  |  | 1d | 0d |  |  | PROF4 PO M [8 h]; TECH3 PO D [2 h]; TECH3 PO M [32 h] | 5,366.32 | S356000 | 0 | S305500 |  | S305500 | CA | Not Started | C | Feder, Russ | L4 | BNL | Installation | Russ Feder | BNL | null | POM02.2.05.06 | C |  | 06 |  | S1003799 | 2.05 | 16727 |  | 2.05 |  | 180227 ELM rsrc assign per DLynch |  |  |  |  |  |  |  |  |  |  |
| S356000 |  | Install Inner HCal - Labor - CA-D Resource(s) |  | 2d | 2021-12-15 | 2021-12-16 | S355800, S355900 |  |  |  |  | 1d | 0d |  |  | PROF4 AD [4 h]; TECH4 AD [120 h] | 17,250.69 | S356000 | 0 | S305500 |  | S305500 | CA | Not Started | C | Feder, Russ | L4 | BNL | Installation | Russ Feder | BNL | null | POM02.2.05.06 | C |  | 06 |  | S356000 | 2.05 | 16727 |  | 2.05 |  | 180227 ELM rsrc assign per DLynch |  |  |  |  |  |  |  |  |  |  |
| S356100 |  | Install Inner HCal - M&S |  | 2d | 2021-12-15 | 2021-12-16 | S356000 SS, S1003799 SS |  |  |  |  | 1d | 0d |  |  | Material (Purchase (1st $2M) [500 h] | 591.95 | S356100 | 0 | S305600 |  | S305600 | CA | Not Started | C | Feder, Russ | M4 | BNL | Fab & Assy | Russ Feder | BNL | null | POM02.2.05.06 | C |  | 06 |  | S356100 | 2.05 | 16727 |  | 2.05 |  |  | UDF_G2 | UDF_G1 | 591.948995 | 1 |  |  |  |  |  |  |
| S356200 |  | Install 2nd Inner HCal Support Ring - Labor |  | 2d | 2021-12-17 | 2021-12-20 | S355800, S356000, S355900, S356100, S1003799 |  |  |  |  | 1d | 0d |  |  | PROF4 PO M [8 h]; TECH3 PO D [2 h]; TECH3 PO M [32 h] | 5,366.32 | S356200 | 0 | S305700 |  | S305700 | CA | Not Started | C | Feder, Russ | L4 | BNL | Installation | Russ Feder | BNL | null | POM02.2.05.06 | C |  | 06 |  | S356200 | 2.05 | 16727 |  | 2.05 |  | 180227 ELM rsrc assign per DLynch |  |  |  |  |  |  |  |  |  |  |
| S356300 |  | Install 2nd Inner HCal Support Ring - M&S |  | 2d | 2021-12-17 | 2021-12-20 | S356200 SS |  |  |  |  | 1d | 0d |  |  | Material (Purchase (1st $2M) [500 h] | 591.95 | S356300 | 0 | S305800 |  | S305800 | CA | Not Started | C | Feder, Russ | M4 | BNL | Fab & Assy | Russ Feder | BNL | null | POM02.2.05.06 | C |  | 06 |  | S356300 | 2.05 | 16727 |  | 2.05 |  |  | UDF_G2 | UDF_G1 | 591.948995 | 1 |  |  |  |  |  |  |
| S356310 |  | Completed - Install 2nd Inner HCal Support Ring | milestone | 0d | 2021-12-20 | 2021-12-20 | S356200 FF, S356300 FF |  |  |  |  | 1d | 0d |  |  |  |  | S356300 | 0 | S305800 |  | S305800 | NOCA | Not Started |  | Feder, Russ |  | BNL | Fab & Assy | Russ Feder | BNL |  | POM02.2.05.06 |  |  | 06 |  |  |  |  |  |  |  |  |  |  |  |  |  |  |  | L5 |  |  |
| S356400 |  | Align/Survey Inner HCal to SC Magnet Centerline - Labor - Physics Resource(s) |  | 5d | 2021-12-21 | 2021-12-28 | S356310 |  |  |  |  | 1d | 0d |  |  | TECH3 PO D [4 h]; TECH3 PO M [20 h] | 2,905.73 | PO&AD | 0 | S305900 |  | S305900 | CA | Not Started | C | Feder, Russ | L4 | BNL | Installation | Russ Feder | BNL | null | POM02.2.05.06 | C |  | 06 |  | S356400 | 2.05 | 16727 |  | 2.05 |  | 180227 ELM rsrc assign per DLynch |  |  |  |  |  |  |  |  | PO |  |
| S356410 |  | Align/Survey Inner HCal to SC Magnet Centerline - Labor - CA-D Resource(s) |  | 5d | 2021-12-21 | 2021-12-28 | S356400 SS |  |  |  |  | 1d | 0d |  |  | CRAFT3 [80 h]; TECH3 AD [60 h]; TECH4 AD [60 h] | 26,192.26 | PO&ADS356410 | 0 | S305900 |  | S305900 | CA | Not Started | C | Feder, Russ | L4 | BNL | Installation | Russ Feder | BNL | null | POM02.2.05.06 | C |  | 06 |  | S356410 | 2.05 | 16728 |  | 2.05 |  | 180227 ELM rsrc assign per DLynch |  |  |  |  |  |  |  |  | C-AD | S356410 |
| S356500 |  | Align/Survey Inner HCal to SC Magnet Centerline - M&S |  | 5d | 2021-12-21 | 2021-12-28 | S356400 SS, S356410 SS |  |  |  |  | 1d | 0d |  |  | Material (Purchase (1st $2M) [500 h] | 591.95 | S356500 | 0 | S306000 |  | S306000 | CA | Not Started | C | Feder, Russ | M4 | BNL | Fab & Assy | Russ Feder | BNL | null | POM02.2.05.06 | C |  | 06 |  | S356500 | 2.05 | 16727 |  | 2.05 |  |  | UDF_G2 | UDF_G1 | 591.948995 | 1 |  |  |  |  |  |  |
| S357210 |  | Completed - Install Inner HCal | milestone | 0d | 2021-12-28 | 2021-12-28 | S356400 FF, S356410 FF, S356500 FF |  |  |  |  | 199d |  |  |  |  |  | S357200 | 0 | S306600 |  | S306600 | NOCA | Not Started | C | Feder, Russ |  | BNL | Fab & Assy | Russ Feder | BNL |  | POM02.2.05.06 |  |  | 06 |  |  |  |  | 003 |  |  | 180416 ELM dur per GRY; |  |  |  |  |  |  |  | L3 |  |  |
| S356600 |  | Install Inner HCal Cables and Services (if instrumented) - Labor |  | 20d | 2021-12-29 | 2022-01-27 | S356400, S356500, S356410 |  |  |  |  | 154d | 0d |  |  | TECH3 PO M [80 h]; TECH3 PO E [160 h]; PROF4 PO E [80 h] | 41,556 | S356600 | 0 | S306100 |  | S306100 | CA | Not Started | C | Feder, Russ | L4 | BNL | Installation | Russ Feder | BNL | null | POM02.2.05.06 | C |  | 06 |  | S356600 | 2.05 | 16727 | 004 | 2.05 |  | 180227 ELM rsrc assign per DLynch |  |  |  |  |  |  |  |  |  |  |
| S356700 |  | Install Inner HCal Cables and Services (if instrumented) - M&S |  | 20d | 2021-12-29 | 2022-01-27 | S356600 SS |  |  |  |  | 154d | 0d |  |  | Material (Purchase (1st $2M) [500 h] | 591.95 | S356700 | 0 | S306200 |  | S306200 | CA | Not Started | C | Feder, Russ | M4 | BNL | Fab & Assy | Russ Feder | BNL | null | POM02.2.05.06 | C |  | 06 |  | S356700 | 2.05 | 16727 | 004 | 2.05 |  |  | UDF_G2 | UDF_G3 | 591.948995 | 1 |  |  |  |  |  |  |
| S356800 |  | Inner HCal - Operational Readiness Review (ORR) |  | 10d | 2022-01-28 | 2022-02-10 | S356600, S356700 |  |  |  |  | 154d | 0d |  |  | PROF4 PO E [8 h]; PROF4 PO M [8 h]; TECH3 PO E [8 h]; TECH3 PO D [8 h]; TECH3 PO M [8 h] | 5,405.47 | S356800 | 0 | S306300 |  | S306300 | CA | Not Started | C | Feder, Russ | L4 | BNL | Installation | Russ Feder | BNL | null | POM02.2.05.06 | C |  | 06 |  | S356800 | 2.05 | 16727 | 004 | 2.05 |  |  |  |  |  |  |  |  |  |  |  |  |
| S356900 |  | Address Action Items from Inner Hcal ORR |  | 10d | 2022-02-11 | 2022-02-25 | S356800 |  |  |  |  | 154d | 0d |  |  | PROF4 PO E [8 h]; PROF4 PO M [8 h]; TECH3 PO E [8 h]; TECH3 PO D [8 h]; TECH3 PO M [8 h] | 5,405.47 | S356900 | 0 | S306400 |  | S306400 | CA | Not Started | C | Feder, Russ | L4 | BNL | Installation | Russ Feder | BNL | null | POM02.2.05.06 | C |  | 06 |  | S356900 | 2.05 | 16727 |  | 2.05 |  |  |  |  |  |  |  |  |  |  |  |  |
| S357000 |  | Commission Inner HCal (labor - if instrumented) - Labor |  | 5d | 2022-02-28 | 2022-03-04 | S356900 |  |  |  |  | 154d | 0d |  |  | SCI3 PO [320 h]; PROF4 PO E [160 h]; TECH3 PO E [160 h]; TECH3 PO M [32 h] | 106,671.02 | S357000 | 0 | S306500 |  | S306500 | CA | Not Started | C | Feder, Russ | L4 | BNL | Commissioning | Russ Feder | BNL | null | POM02.2.05.06 | C |  | 06 |  | S357000 | 2.05 | 16727 | 003,004 | 2.05 |  | 180416 ELM dur per GRY; 180227 ELM rsrc assign per DLynch |  |  |  |  |  |  |  |  |  |  |
| S357100 |  | Commission Inner HCal (labor - if instrumented) - Labor |  | 5d | 2022-02-28 | 2022-03-04 | S356900 |  |  |  |  | 154d | 0d |  |  | STUDENT Other - Unpaid [640 h] |  | S357100 | 0 | S306500 |  | S306510 | CA | Not Started | T | Feder, Russ | L4 | BNL | Commissioning | Russ Feder | BNL | null | POM02.2.05.06 | K |  | 06 |  | S357100 | 2.05 | NA | 003,004 | 2.05 |  | 180416 ELM dur per GRY; 180227 ELM rsrc assign per DLynch |  |  |  |  |  |  |  |  |  |  |
| S357200 |  | Commission Inner HCal - M&S |  | 5d | 2022-02-28 | 2022-03-04 | S357000 SS, S357100 SS |  |  |  |  | 154d |  |  |  | Material (Purchase (1st $2M) [500 h] | 591.95 | S357200 | 0 | S306600 |  | S306600 | CA | Not Started | C | Feder, Russ | M4 | BNL | Fab & Assy | Russ Feder | BNL | null | POM02.2.05.06 | C |  | 06 |  | S357200 | 2.05 | 16727 | 003 | 2.05 |  | 180416 ELM dur per GRY; | UDF_G2 | UDF_G3 | 591.948995 | 1 |  |  |  |  |  |  |

Notes:
- S354300: BNL_UDF_Old Activity Name 181221: Design Inner HCal Integration/Installation Tooling/Fixtures FY18
- S354400: BNL_UDF_Status Comments: 190318 ELM logic, name per GRY / BNL_UDF_Old Activity Name 181221: Design Inner HCal Integration/Installation Tooling/Fixtures FY19
- S1003719: BNL_UDF_Old Activity Name 181221: Transport assembled Inner HCal Sectors to AH - Labor
- S354700: BNL_UDF_Old Activity Name 181221: Prepare Inner HCal Integration/Installation Tooling/Fixtures Procedures
- S355200: BNL_UDF_Old Activity Name 181221: Transport assembled Inner HCal Sectors to AH - Labor
- S355300: BNL_UDF_Old Activity Name 181221: Transport assembled Inner HCal Sectors to AH - M&S
- S354500: BNL_UDF_Status Comments: 190318 ELM name per GRY / BNL_UDF_Old Activity Name 181221: (Planning Package) Fabricate/Procure Inner HCal Integration/Installation Tooling/Fixtures - Labor
- S354600: BNL_UDF_Status Comments: 190318 ELM logic, name per GRY / BNL_UDF_Old Activity Name 181221: (Planning Package) Fabricate/Procure Inner HCal Integration/Installation Tooling/Fixtures - M&S
- OBLG356990: BNL_UDF_Status Comments: 190318 ELM logic, name per GRY / BNL_UDF_Old Activity Name 181221: (Planning Package) Fabricate/Procure Inner HCal Integration/Installation Tooling/Fixtures - M&S
- S354800: BNL_UDF_Old Activity Name 181221: Review Inner HCal Integration/Installation Tooling/Fixtures/Procedures Safety/Certification
- S354900: BNL_UDF_Old Activity Name 181221: Address Action Items from Inner Hcal Integration/Installation Tooling/Fixtures/Procedures Design & Safety Reviews
- S355000: BNL_UDF_Old Activity Name 181221: Design/Safety Reviews Complete, Inner HCal Integration/Installation Tooling/Fixtures/Procedures Ready for Service
- S355100: BNL_UDF_Old Activity Name 181221: Inner HCal Sectors Ready for Installation
- S355400: BNL_UDF_Old Activity Name 181221: Install Inner Hcal Assembly Insertion Fixture - Labor
- S355500: BNL_UDF_Old Activity Name 181221: Install Inner Hcal Assembly Insertion Fixture - M&S
- S355600: BNL_UDF_Old Activity Name 181221: Install Inner HCal assembly on Insertion Fixture - Labor
- S355700: BNL_UDF_Old Activity Name 181221: Install Inner HCal assembly on Insertion Fixture - M&S
- S355800: BNL_UDF_Old Activity Name 181221: Install 1st Inner HCal Support Ring - Labor
- S355900: BNL_UDF_Old Activity Name 181221: Install 1st Inner HCal Support Ring - M&S
- S1003799: BNL_UDF_Old Activity Name 181221: Install Inner HCal - Labor
- S356000: BNL_UDF_Old Activity Name 181221: Install Inner HCal - Labor
- S356100: BNL_UDF_Old Activity Name 181221: Install Inner HCal - M&S
- S356200: BNL_UDF_Old Activity Name 181221: Install 2nd Inner HCal Support Ring - Labor
- S356300: BNL_UDF_Old Activity Name 181221: Install 2nd Inner HCal Support Ring - M&S
- S356310: BNL_UDF_Old Activity Name 181221: Install 2nd Inner HCal Support Ring - M&S
- S356400: BNL_UDF_Old Activity Name 181221: Align/Survey Inner HCal to SC Magnet Centerline - Labor
- S356410: BNL_UDF_Old Activity Name 181221: Align/Survey Inner HCal to SC Magnet Centerline - Labor
- S356500: BNL_UDF_Old Activity Name 181221: Align/Survey Inner HCal to SC Magnet Centerline - M&S
- S357210: BNL_UDF_Status Comments: 190211 ELM pred per GRY / BNL_UDF_Old Activity Name 181221: Commission Inner HCal - M&S
- S356600: BNL_UDF_Status Comments: 190416 ELM name per GRY / BNL_UDF_Old Activity Name 181221: Install Inner HCal Cables and Services - Labor
- S356700: BNL_UDF_Status Comments: 190416 ELM name per GRY / BNL_UDF_Old Activity Name 181221: Install Inner HCal Cables and Services - M&S
- S356800: BNL_UDF_Status Comments: 190416 ELM name per GRY / BNL_UDF_Old Activity Name 181221: Review Inner HCal for Operational Readiness (ORR)
- S356900: BNL_UDF_Old Activity Name 181221: Address Action Items from Inner Hcal ORR
- S357000: BNL_UDF_Status Comments: 190416 ELM name per GRY; 190211 ELM succ per GRY / BNL_UDF_Old Activity Name 181221: Commission Inner HCal (labor - instrumented, dur not) - Labor - Fund Category C
- S357100: BNL_UDF_Status Comments: 190416 ELM name per GRY; 190313 ELM rsrc; 190211 ELM succ per GRY / BNL_UDF_Old Activity Name 181221: Commission Inner HCal (labor - instrumented, dur not) - Labor - Fund Category T
- S357200: BNL_UDF_Status Comments: 190211 ELM succ per GRY / BNL_UDF_Old Activity Name 181221: Commission Inner HCal - M&S

| ID | WBS | Activity | Type | Duration | Start | Finish | Predecessors | Complete | Remaining | Planned start | Planned finish | Total float | Free float | Expected finish | Resources | Cost | BNL_UDF_Temp Text 01 | BNL_UDF_Percent Complete | BNL_UDF_OPC TEC (deprecated) | BNL_UDF_Temp Date 01 | BNL_UDF_Old Activity ID 181221 | RG Check | BNL_Activity Status | BNL_Fund Source | BNL_Estimator | BNL_Cost Basis | BNL_Location | BNL_EDIA | BNL_CAM | BNL_Institution | BNL_OPC TEC (deprecated) | BNL_WBS | BNL_EVT | BNL_WBS_Hierarchical | Completed | BNL_UDF_Status Comments | BNL_Cobra WP | BNL_Master Control Account | BNL_Account Number | BNL_PCR ID | BNL_Cobra Control Account | Additional EVT documentation required | BNL_UDF_Exclude | Indicator - Procurement | Indicator - Float | BNL_UDF_Remaining Tot Cost | BNL_UDF_Percent_remaining | BNL_Proc Sig | BNL_Milestone Level | BNL_UDF_Adhoc Comments | Target Milestone Date | Variance | PMP Milestones | Temp | BNL_UDF_Temp Text 02 |
| --- | --- | --- | --- | --- | --- | --- | --- | --- | --- | --- | --- | --- | --- | --- | --- | --- | --- | --- | --- | --- | --- | --- | --- | --- | --- | --- | --- | --- | --- | --- | --- | --- | --- | --- | --- | --- | --- | --- | --- | --- | --- | --- | --- | --- | --- | --- | --- | --- | --- | --- | --- | --- | --- | --- | --- |
|  | 07 | **EMCal Installation** |  |  | 2018-03-01 | 2022-05-02 |  |  |  |  |  |  |  |  |  |  |  |  |  |  |  |  |  |  |  |  |  |  |  |  |  |  |  |  |  |  |  |  |  |  |  |  |  |  |  |  |  |  |  |  |  |  |  |  |  |
| S357300 |  | Design EMCal Integration/Installation Tooling/Fixtures FY18 |  | 149d | 2018-03-01 A | 2018-09-28 A | S100090 SS | 100% |  |  |  |  |  |  |  |  | S357300 | 100 | S306700 | 2019-06-30 | S277592724 | NOCA | Completed | C | Feder, Russ | L4 | BNL | Installation | Russ Feder | BNL | null | POM02.2.05.07 | C | 07 | yes |  |  |  |  |  |  |  |  |  |  |  |  |  |  |  |  |  |  |  |  |
| S357400 |  | Design EMCal Integration/Installation Tooling/Fixtures FY21 |  | 125d | 2020-03-11 A | 2020-12-31 A | S357300, S101015 SS | 100% |  | 2020-10-01 | 2021-04-05 |  |  |  | PROF4 PO M [26 h]; TECH3 PO M [21 h]; TECH3 PO D [53 h] | 12,642.15 | S357400 | 0 | S306700 | 2019-06-28 | S306700 | CA | Not Started | C | Feder, Russ | L4 | BNL | Installation | Russ Feder | BNL | null | POM02.2.05.07 | C | 07 |  | 190318 ELM logic, name per GRY | S357400 | 2.05 | 16727 | 003 | 2.05 | Yes |  |  |  |  |  |  |  |  |  |  |  |  |  |
| S357500 |  | Fabricate/Procure EMCal Integration/Installation Tooling/Fixtures - Labor |  | 60d | 2021-02-01 A | 2021-06-14 | S357400, S101000 | 40% | 10d | 2021-02-01 | 2021-04-26 | 150d | 0d | 2021-06-14 | PROF4 PO M [120 h]; TECH3 PO M [48 h]; TECH3 PO D [40 h] | 28,545.99 | S357500 | 0 | S306800 |  | S306800 | CA | Not Started | C | Feder, Russ | L4 | BNL | Fab & Assy | Russ Feder | BNL | null | POM02.2.05.07 | C | 07 |  |  | S357500 | 2.05 | 16727 |  | 2.05 |  |  |  |  |  |  |  |  |  |  |  |  |  |  |
| S357600 |  | Fabricate/Procure EMCal Integration/Installation Tooling/Fixtures - M&S |  | 60d | 2021-02-01 A | 2021-06-14 | S357500 SS | 40% | 10d | 2021-02-01 | 2021-04-26 | 150d | 0d | 2021-06-14 | Material (Purchase (1st $2M) [30000 h] | 34,820.53 | S357600 | 0 | S306900 |  | S306900 | CA | Not Started | C | Feder, Russ | M5 | BNL | Fab & Assy | Russ Feder | BNL | null | POM02.2.05.07 | C | 07 |  |  | S357600 | 2.05 | 16727 |  | 2.05 |  | MP6LAEXCLUDE | UDF_G3 | UDF_G3 | 34820.5293 | 1 | TBD |  |  |  |  |  |  |  |
| S357700 |  | Prepare EMCal Integration/Installation Tooling/Fixtures Procedures |  | 10d | 2021-02-01 A | 2021-06-28 | S357500, S357600 | 40% | 10d | 2021-04-27 | 2021-05-10 | 150d | 0d | 2021-06-14 | PROF4 PO M [80 h]; TECH3 PO M [8 h]; TECH3 PO D [40 h] | 17,776.84 | S357700 | 0 | S307000 |  | S307000 | CA | Not Started | C | Feder, Russ | L4 | BNL | Installation | Russ Feder | BNL | null | POM02.2.05.07 | C | 07 |  |  | S357700 | 2.05 | 16727 |  | 2.05 |  |  |  |  |  |  |  |  |  |  |  |  |  |  |
| S357800 |  | Review EMCal Integration/Installation Tooling/Fixtures/Procedures Safety/Certification |  | 10d | 2021-03-22 A | 2021-03-26 A | S357700 | 100% |  | 2021-06-08 | 2021-06-21 |  |  |  | PROF4 PO M [8 h]; TECH3 PO M [8 h]; TECH3 PO D [8 h] | 3,094.2 | S357800 | 0 | S307100 |  | S307100 | CA | Not Started | C | Feder, Russ | L4 | BNL | Installation | Russ Feder | BNL | null | POM02.2.05.07 | C | 07 |  |  | S357800 | 2.05 | 16727 |  | 2.05 |  |  |  |  |  |  |  |  |  |  |  |  |  |  |
| S357900 |  | Address Action Items from EMCal Integration/Installation Tooling/Fixtures/Procedures Design & Safety Reviews |  | 10d | 2021-03-22 A | 2021-03-26 A | S357800 | 100% |  | 2021-06-22 | 2021-07-06 |  |  |  | PROF4 PO M [8 h]; TECH3 PO M [8 h]; TECH3 PO D [8 h] | 3,094.2 | S357900 | 0 | S307200 |  | S307200 | CA | Not Started | C | Feder, Russ | L4 | BNL | Installation | Russ Feder | BNL | null | POM02.2.05.07 | C | 07 |  |  | S357900 | 2.05 | 16727 |  | 2.05 |  |  |  |  |  |  |  |  |  |  |  |  |  |  |
| S358000 |  | Design/Safety Reviews Complete, EMCal Integration/Installation Tooling/Fixtures/Procedures Ready for Service | milestone | 0d | 2021-03-30 A | 2021-03-30 A | S357900 FF | 100% |  | 2021-07-06 | 2021-07-06 |  |  |  |  |  | S358000 | 0 | S307300 |  | S307300 | NOCA | Not Started | C | Feder, Russ |  | BNL | Management Safety Reviews | Russ Feder | BNL |  | POM02.2.05.07 |  | 07 |  |  |  |  |  |  |  |  |  |  |  |  |  |  | L3 |  |  |  |  |  |  |
| S1003839 |  | Transport Assembled EMCal Sectors to AH - Labor - Physics Resource(s) |  | 25d | 2021-12-30 | 2022-02-04 | S196900 SS+10d, S356500, S356400, S356410, S358100 FF |  |  |  |  | 0d |  |  | CRAFT3 [120 h]; TECH3 PO M [64 h] | 23,671.2 | S358200 | 0 | S307500 |  | S307500 | CA | Not Started | C | Feder, Russ | L4 | BNL | Fab & Assy | Russ Feder | BNL | null | POM02.2.05.07 | C | 07 |  |  | S1003839 | 2.05 | 16727 |  | 2.05 |  |  |  |  |  |  |  |  | 180416 ELM pred/succ per GRY |  |  |  |  |  |
| S358200 |  | Transport Assembled EMCal Sectors to AH - Labor - CA-D Resource(s) |  | 25d | 2021-12-30 | 2022-02-04 | S196900 SS, S356500, S356400, S356410, S358100 FF |  |  |  |  | 0d |  |  | PROF4 AD [8 h] | 1,249.87 | S358200 | 0 | S307500 |  | S307500 | CA | Not Started | C | Feder, Russ | L4 | BNL | Fab & Assy | Russ Feder | BNL | null | POM02.2.05.07 | C | 07 |  |  | S358200 | 2.05 | 16727 |  | 2.05 |  |  |  |  |  |  |  |  | 180416 ELM pred/succ per GRY |  |  |  |  |  |
| S358300 |  | Transport Assembled EMCal Sectors to AH - M&S |  | 25d | 2021-12-30 | 2022-02-04 | S358200 SS, S358100 FF, S1003839 SS |  |  |  |  | 0d |  |  | Material (Purchase (1st $2M) [500 h] | 591.95 | S358300 | 0 | S307600 |  | S307600 | CA | Not Started | C | Feder, Russ | M4 | BNL | Fab & Assy | Russ Feder | BNL | null | POM02.2.05.07 | C | 07 |  |  | S358300 | 2.05 | 16727 |  | 2.05 |  |  | UDF_G2 | UDF_G1 | 591.948995 | 1 |  |  | 180416 ELM pred/succ per GRY |  |  |  |  |  |
| S358400 |  | Install EMCal Sectors - Labor |  | 16d | 2022-01-03 | 2022-01-25 | S358200 SS+1d, S358300 SS+1d, S1003839 SS+1d |  |  |  |  | 0d |  |  | PROF4 PO M [64 h]; TECH3 PO D [64 h]; TECH3 PO M [512 h] | 79,736.52 | S358400 | 0 | S307700 |  | S307700 | CA | Not Started | C | Feder, Russ | L4 | BNL | Installation | Russ Feder | BNL | null | POM02.2.05.07 | C | 07 |  |  | S358400 | 2.05 | 16727 |  | 2.05 |  |  |  |  |  |  |  |  |  |  |  |  |  |  |
| S358500 |  | Install EMCal Sectors - M&S |  | 16d | 2022-01-03 | 2022-01-25 | S358400 SS |  |  |  |  | 0d |  |  | Material (Purchase (1st $2M) [500 h] | 591.95 | S358500 | 0 | S307800 |  | S307800 | CA | Not Started | C | Feder, Russ | M4 | BNL | Fab & Assy | Russ Feder | BNL | null | POM02.2.05.07 | C | 07 |  |  | S358500 | 2.05 | 16727 |  | 2.05 |  |  | UDF_G2 | UDF_G1 | 591.948995 | 1 |  |  |  |  |  |  |  |  |
| S358510 |  | Completed - Install EMCal Sectors | milestone | 0d | 2022-01-25 | 2022-01-25 | S358400 FF, S358500 FF |  |  |  |  | 0d |  |  |  |  | S358500 | 0 | S307800 |  | S307800 | NOCA | Not Started | C | Feder, Russ |  | BNL | Fab & Assy | Russ Feder | BNL |  | POM02.2.05.07 |  | 07 |  |  |  |  |  |  |  |  |  |  |  |  |  |  | L5 |  | 2022-03-31 | 45 | PMP_2x |  |  |
| S358600 |  | Align/Survey EMCal to SC Magnet Centerline - Labor - Physics Resource(s) |  | 7d | 2022-01-26 | 2022-02-03 | S358510 |  |  |  |  | 0d |  |  | TECH3 PO M [20 h] | 2,421.44 | PO&AD | 0 | S307900 |  | S307900 | CA | Not Started | C | Feder, Russ | L4 | BNL | Installation | Russ Feder | BNL | null | POM02.2.05.07 | C | 07 |  |  | S358600 | 2.05 | 16727 |  | 2.05 |  |  |  |  |  |  |  |  |  |  |  |  | PO |  |
| S358610 |  | Align/Survey EMCal to SC Magnet Centerline - Labor - CA-D Resource(s) |  | 7d | 2022-01-26 | 2022-02-03 | S358600 SS |  |  |  |  | 0d |  |  | CRAFT3 [80 h]; TECH3 AD [60 h]; TECH4 AD [60 h] | 26,192.26 | PO&ADS358610 | 0 | S307900 |  | S307900 | CA | Not Started | C | Feder, Russ | L4 | BNL | Installation | Russ Feder | BNL | null | POM02.2.05.07 | C | 07 |  |  | S358610 | 2.05 | 16728 |  | 2.05 |  |  |  |  |  |  |  |  |  |  |  |  | C-AD | S358610 |
| S358700 |  | Align/Survey EMCal to SC Magnet Centerline - M&S |  | 7d | 2022-01-26 | 2022-02-03 | S358600 SS, S358610 SS |  |  |  |  | 0d |  |  | Material (Purchase (1st $2M) [500 h] | 591.95 | S358700 | 0 | S308000 |  | S308000 | CA | Not Started | C | Feder, Russ | M4 | BNL | Fab & Assy | Russ Feder | BNL | null | POM02.2.05.07 | C | 07 |  |  | S358700 | 2.05 | 16727 |  | 2.05 |  |  | UDF_G2 | UDF_G1 | 591.948995 | 1 |  |  |  |  |  |  |  |  |
| S358800 |  | Install EMCal Cables and Services - Labor |  | 21d | 2022-02-04 | 2022-03-07 | S358600, S358610, S358700 |  |  |  |  | 0d |  |  | TECH3 PO E [160 h]; TECH3 PO M [64 h]; PROF4 PO M [32 h]; TECH3 PO D [32 h]; CRAFT3 [320 h] | 78,454.16 | S358800 | 0 | S308100 |  | S308100 | CA | Not Started | C | Feder, Russ | L4 | BNL | Installation | Russ Feder | BNL | null | POM02.2.05.07 | C | 07 |  |  | S358800 | 2.05 | 16727 |  | 2.05 |  |  |  |  |  |  |  |  |  |  |  |  |  |  |
| S358900 |  | Install EMCal Cables and Services - M&S |  | 21d | 2022-02-04 | 2022-03-07 | S358800 SS |  |  |  |  | 0d |  |  | Material (Purchase (1st $2M) [500 h] | 591.95 | S358900 | 0 | S308200 |  | S308200 | CA | Not Started | C | Feder, Russ | M4 | BNL | Fab & Assy | Russ Feder | BNL | null | POM02.2.05.07 | C | 07 |  |  | S358900 | 2.05 | 16727 |  | 2.05 |  |  | UDF_G3 | UDF_G1 | 591.948995 | 1 |  |  |  |  |  |  |  |  |
| S358100 |  | EMCal Sectors Ready for Installation | milestone | 0d | 2022-02-04 | 2022-02-04 | S358000 FF, S197300 FF, S318130 |  |  |  |  | 0d |  |  |  |  | S358100 | 0 | S307400 |  | S307400 | NOCA | Not Started | C | Feder, Russ |  | BNL | Installation | Russ Feder | BNL |  | POM02.2.05.07 |  | 07 |  |  |  |  |  |  |  |  |  |  |  |  |  |  | L3 |  |  |  |  |  |  |
| S359000 |  | EMCal - Operational Readiness Review (ORR) |  | 5d | 2022-03-08 | 2022-03-14 | S358800, S358900 |  |  |  |  | 113d | 0d |  | PROF4 PO M [8 h]; TECH3 PO E [8 h]; TECH3 PO D [8 h]; TECH3 PO M [8 h] | 4,155.6 | S359000 | 0 | S308300 |  | S308300 | CA | Not Started | C | Feder, Russ | L4 | BNL | Installation | Russ Feder | BNL | null | POM02.2.05.07 | C | 07 |  | 190416 ELM name per GRY | S359000 | 2.05 | 16727 | 004 | 2.05 |  |  |  |  |  |  |  |  |  |  |  |  |  |  |
| S359100 |  | Address Action Items from EMCal ORR |  | 10d | 2022-03-15 | 2022-03-28 | S359000 |  |  |  |  | 113d | 0d |  | PROF4 PO M [8 h]; TECH3 PO E [8 h]; TECH3 PO D [8 h]; TECH3 PO M [8 h] | 4,155.6 | S359100 | 0 | S308400 |  | S308400 | CA | Not Started | C | Feder, Russ | L4 | BNL | Installation | Russ Feder | BNL | null | POM02.2.05.07 | C | 07 |  |  | S359100 | 2.05 | 16727 |  | 2.05 |  |  |  |  |  |  |  |  |  |  |  |  |  |  |
| S359200 |  | Commission EMCal - Labor |  | 25d | 2022-03-29 | 2022-05-02 | S359100 |  |  |  |  | 113d | 0d |  | SCI3 PO [400 h]; PROF4 PO E [40 h]; TECH3 PO E [40 h]; PROF4 PO M [40 h]; TECH3 PO D [40 h]; TECH3 PO M [40 h] | 100,062.1 | S359200 | 0 | S308500 |  | S308500 | CA | Not Started | C | Feder, Russ | L4 | BNL | Commissioning | Russ Feder | BNL | null | POM02.2.05.07 | C | 07 |  |  | S359200 | 2.05 | 16727 |  | 2.05 |  |  |  |  |  |  |  |  | 180416 ELM dur per GRY |  |  |  |  |  |
| S359300 |  | Commission EMCal - Labor |  | 25d | 2022-03-29 | 2022-05-02 | S359100 |  |  |  |  | 113d | 0d |  | STUDENT Other - Unpaid [1600 h] |  | S359300 | 0 | S308500 |  | S308510 | CA | Not Started | T | Feder, Russ | L4 | BNL | Commissioning | Russ Feder | BNL | null | POM02.2.05.07 | K | 07 |  | 190313 ELM rsrc | S359300 | 2.05 | NA | 003 | 2.05 |  |  |  |  |  |  |  |  | 180416 ELM dur per GRY |  |  |  |  |  |
| S359400 |  | Commission EMCal - M&S |  | 25d | 2022-03-29 | 2022-05-02 | S359200 SS, S359300 SS |  |  |  |  | 113d | 0d |  | Material (Purchase (1st $2M) [500 h] | 591.95 | S359400 | 0 | S308600 |  | S308600 | CA | Not Started | C | Feder, Russ | M4 | BNL | Fab & Assy | Russ Feder | BNL | null | POM02.2.05.07 | C | 07 |  |  | S359400 | 2.05 | 16727 |  | 2.05 |  |  | UDF_G3 | UDF_G3 | 591.948995 | 1 |  |  | 180416 ELM dur per GRY |  |  |  |  |  |
| S359410 |  | Completed - Commission EMCal | milestone | 0d | 2022-05-02 | 2022-05-02 | S359200 FF, S359300 FF, S359400 FF |  |  |  |  | 113d |  |  |  |  | S359400 | 0 | S308600 |  | S308600 | NOCA | Not Started | C | Feder, Russ |  | BNL | Fab & Assy | Russ Feder | BNL |  | POM02.2.05.07 |  | 07 |  |  |  |  |  |  |  |  |  |  |  |  |  |  | L5 | 180416 ELM dur per GRY |  |  |  |  |  |

Notes:
- S357300: BNL_UDF_Old Activity Name 181221: Design EMCal Integration/Installation Tooling/Fixtures FY18
- S357400: BNL_UDF_Old Activity Name 181221: Design EMCal Integration/Installation Tooling/Fixtures FY19
- S357500: BNL_UDF_Old Activity Name 181221: (Planning Package) Fabricate/Procure EMCal Integration/Installation Tooling/Fixtures - Labor
- S357600: BNL_UDF_Old Activity Name 181221: (Planning Package) Fabricate/Procure EMCal Integration/Installation Tooling/Fixtures - M&S
- S357700: BNL_UDF_Old Activity Name 181221: Prepare EMCal Integration/Installation Tooling/Fixtures Procedures
- S357800: BNL_UDF_Old Activity Name 181221: Review EMCal Integration/Installation Tooling/Fixtures/Procedures Safety/Certification
- S357900: BNL_UDF_Old Activity Name 181221: Address Action Items from EMCal Integration/Installation Tooling/Fixtures/Procedures Design & Safety Reviews
- S358000: BNL_UDF_Old Activity Name 181221: Design/Safety Reviews Complete, EMCal Integration/Installation Tooling/Fixtures/Procedures Ready for Service
- S1003839: BNL_UDF_Old Activity Name 181221: Transport Assembled EMCal Sectors to AH - Labor
- S358200: BNL_UDF_Old Activity Name 181221: Transport Assembled EMCal Sectors to AH - Labor
- S358300: BNL_UDF_Old Activity Name 181221: Transport Assembled EMCal Sectors to AH - M&S
- S358400: Scheduler's Notes: 180413 ELM per GRY: / assume 4 people / BNL_UDF_Old Activity Name 181221: Install EMCal Sectors - Labor
- S358500: BNL_UDF_Old Activity Name 181221: Install EMCal Sectors - M&S
- S358510: BNL_UDF_Old Activity Name 181221: Install EMCal Sectors - M&S
- S358600: BNL_UDF_Old Activity Name 181221: Align/Survey EMCal to SC Magnet Centerline - Labor
- S358610: BNL_UDF_Old Activity Name 181221: Align/Survey EMCal to SC Magnet Centerline - Labor
- S358700: BNL_UDF_Old Activity Name 181221: Align/Survey EMCal to SC Magnet Centerline - M&S
- S358800: Scheduler's Notes: 180413 ELM per GRY: / assume 2 people / BNL_UDF_Old Activity Name 181221: Install EMCal Cables and Services - Labor
- S358900: BNL_UDF_Old Activity Name 181221: Install EMCal Cables and Services - M&S
- S358100: BNL_UDF_Old Activity Name 181221: EMCal Sectors Ready for Installation
- S359000: BNL_UDF_Old Activity Name 181221: Review EMCal for Operational Readiness (ORR)
- S359100: BNL_UDF_Old Activity Name 181221: Address Action Items from EMCal ORR
- S359200: BNL_UDF_Old Activity Name 181221: Commission EMCal - Labor - Fund Category C
- S359300: BNL_UDF_Old Activity Name 181221: Commission EMCal - Labor - Fund Category T
- S359400: BNL_UDF_Old Activity Name 181221: Commission EMCal - M&S
- S359410: BNL_UDF_Old Activity Name 181221: Commission EMCal - M&S

| ID | WBS | Activity | Type | Duration | Start | Finish | Predecessors | Complete | Remaining | Planned start | Planned finish | Total float | Free float | Expected finish | Resources | Cost | BNL_UDF_Temp Text 01 | BNL_UDF_Percent Complete | BNL_UDF_OPC TEC (deprecated) | BNL_UDF_Temp Date 01 | BNL_UDF_Old Activity ID 181221 | RG Check | BNL_Activity Status | BNL_Fund Source | BNL_Estimator | BNL_Cost Basis | BNL_Location | BNL_EDIA | BNL_CAM | BNL_Institution | BNL_OPC TEC (deprecated) | BNL_WBS | BNL_EVT | BNL_Split Activity | BNL_WBS_Hierarchical | Completed | BNL_Account Number | BNL_PCR ID | Additional EVT documentation required | BNL_Cobra WP | BNL_Master Control Account | BNL_Cobra Control Account | BNL_UDF_Exclude | Indicator - Procurement | Indicator - Float | BNL_UDF_Remaining Tot Cost | BNL_UDF_Percent_remaining | BNL_Proc Sig | BNL_Milestone Level | Temp | BNL_UDF_Temp Text 02 | BNL_UDF_Adhoc Comments | Target Milestone Date | Variance | PMP Milestones |
| --- | --- | --- | --- | --- | --- | --- | --- | --- | --- | --- | --- | --- | --- | --- | --- | --- | --- | --- | --- | --- | --- | --- | --- | --- | --- | --- | --- | --- | --- | --- | --- | --- | --- | --- | --- | --- | --- | --- | --- | --- | --- | --- | --- | --- | --- | --- | --- | --- | --- | --- | --- | --- | --- | --- | --- |
|  | 08 | **TPC Installation** |  |  | 2018-05-24 | 2022-10-05 |  |  |  |  |  |  |  |  |  |  |  |  |  |  |  |  |  |  |  |  |  |  |  |  |  |  |  |  |  |  |  |  |  |  |  |  |  |  |  |  |  |  |  |  |  |  |  |  |  |
| S359500 |  | Design TPC Integration/Installation Tooling/Fixtures FY18 |  | 89d | 2018-05-24 A | 2018-09-28 A | S100090 SS | 100% |  |  |  |  |  |  |  |  | S359500 | 100 | S308700 | 2019-06-30 | S308700 | NOCA | Completed | C | Feder, Russ | L4 | BNL | Installation | Russ Feder | BNL | null | POM02.2.05.08 | C | FY18 | 08 | yes |  |  |  |  |  |  |  |  |  |  |  |  |  |  |  |  |  |  |  |
| S359600 |  | Design TPC Integration/Installation Tooling/Fixtures FY21 |  | 166d | 2018-10-01 A | 2019-05-31 A | S359500 | 100% |  |  |  |  |  |  |  |  | S359600 | 32.8 | S308700 | 2019-06-28 | S308750 | NOCA | Completed | C | Feder, Russ | L4 | BNL | Installation | Russ Feder | BNL | null | POM02.2.05.08 | C | FY19 | 08 | yes | 16727 | 003 | Yes |  |  |  |  |  |  |  |  |  |  |  |  |  |  |  |  |
| S359605 |  | Design TPC Integration/Installation Tooling/Fixtures FY21 Split |  | 20d | 2019-12-02 A | 2021-06-14 | S359600 | 95% | 10d | 2019-12-02 | 2019-12-30 | 141d | 0d | 2021-06-14 | PROF4 PO M [77 h]; TECH3 PO M [48 h]; TECH3 PO D [77 h] | 25,604.67 | S359600 | 32.8 | S308700 | 2019-06-28 | S308750 | CA | Not Started | C | Feder, Russ | L4 | BNL | Installation | Russ Feder | BNL | null | POM02.2.05.08 | C | FY19 | 08 |  | 16727 | 003 | Yes | S359605 | 2.05 | 2.05 |  |  |  |  |  |  |  |  |  |  |  |  |  |
| S359900 |  | Prepare TPC Integration/Installation Tooling/Fixtures Procedures |  | 10d | 2021-02-10 A | 2021-11-04 | S359700, S359800 | 50% | 10d | 2021-08-06 | 2021-08-19 | 141d | 0d | 2021-08-19 | PROF4 PO M [40 h]; TECH3 PO M [8 h]; TECH3 PO D [20 h] | 9,358.6 | S359900 | 0 | S309000 |  | S309000 | CA | Not Started | C | Feder, Russ | L4 | BNL | Installation | Russ Feder | BNL | null | POM02.2.05.08 | C |  | 08 |  | 16727 |  |  | S359900 | 2.05 | 2.05 |  |  |  |  |  |  |  |  |  |  |  |  |  |
| S359700 |  | Fabricate/Procure TPC Integration/Installation Tooling/Fixtures - Labor |  | 90d | 2021-06-15 | 2021-10-21 | S101000, S359605 |  |  |  |  | 141d | 0d |  | PROF4 PO M [60 h]; TECH3 PO D [20 h] | 11,505.34 | S359700 | 0 | S308800 |  | S308800 | CA | Not Started | C | Feder, Russ | L4 | BNL | Fab & Assy | Russ Feder | BNL | null | POM02.2.05.08 | C |  | 08 |  | 16727 |  | Yes | S359700 | 2.05 | 2.05 |  |  |  |  |  |  |  |  |  |  |  |  |  |
| S359800 |  | Fabricate/Procure TPC Integration/Installation Tooling/Fixtures - M&S |  | 90d | 2021-06-15 | 2021-10-21 | S359700 SS |  |  |  |  | 141d | 0d |  | Material (Purchase (1st $2M) [30000 h] | 34,928.86 | S359800 | 0 | S308900 |  | S308900 | CA | Not Started | C | Feder, Russ | M5 | BNL | Fab & Assy | Russ Feder | BNL | null | POM02.2.05.08 | C |  | 08 |  | 16727 |  | Yes | S359800 | 2.05 | 2.05 | MP6LAEXCLUDE | UDF_G1 | UDF_G3 | 34335.014207 | 1 | TBD |  |  |  |  |  |  |  |
| S360000 |  | Review TPC Integration/Installation Tooling/Fixtures/Procedures Safety/Certification |  | 10d | 2021-11-05 | 2021-11-19 | S359900 |  |  |  |  | 141d | 0d |  | PROF4 PO M [8 h]; TECH3 PO M [8 h]; TECH3 PO D [8 h] | 3,187.02 | S360000 | 0 | S309100 |  | S309100 | CA | Not Started | C | Feder, Russ | L4 | BNL | Installation | Russ Feder | BNL | null | POM02.2.05.08 | C |  | 08 |  | 16727 |  |  | S360000 | 2.05 | 2.05 |  |  |  |  |  |  |  |  |  |  |  |  |  |
| S360100 |  | Address Action Items from TPC Integration/Installation Tooling/Fixtures/Procedures Design & Safety Reviews |  | 10d | 2021-11-22 | 2021-12-07 | S360000, S221100 |  |  |  |  | 141d | 0d |  | PROF4 PO M [8 h]; TECH3 PO M [8 h]; TECH3 PO D [8 h] | 3,187.02 | S360100 | 0 | S309200 |  | S309200 | CA | Not Started | C | Feder, Russ | L4 | BNL | Installation | Russ Feder | BNL | null | POM02.2.05.08 | C |  | 08 |  | 16727 |  |  | S360100 | 2.05 | 2.05 |  |  |  |  |  |  |  |  |  |  |  |  |  |
| S360200 |  | Design/Safety Reviews Complete, TPC Integration/Installation Tooling/Fixtures/Procedures Ready for Service | milestone | 0d | 2021-12-07 | 2021-12-07 | S360100 FF |  |  |  |  | 141d | 36d |  |  |  | S360200 | 0 | S309300 |  | S309300 | NOCA | Not Started | C | Feder, Russ |  | BNL | Management Safety Reviews | Russ Feder | BNL |  | POM02.2.05.08 |  |  | 08 |  |  |  |  |  |  |  |  |  |  |  |  |  | L3 |  |  |  |  |  |  |
| S360300 |  | TPC Ready for Installation (Installation Sequence Can Commence) | milestone | 0d | 2022-01-31 | 2022-01-31 | S360200 FF, S121900 FF, S318140 |  |  |  |  | 105d |  |  |  |  | S360300 | 0 | S309400 |  | S309400 | NOCA | Not Started | C | Feder, Russ |  | BNL | Fab & Assy | Russ Feder | BNL |  | POM02.2.05.08 |  |  | 08 |  |  |  |  |  |  |  |  |  |  |  |  |  | L3 |  |  |  |  |  |  |
| S360400 |  | Transport Assembled TPC Sections to AH - Labor - Physics Resource(s) |  | 5d | 2022-06-30 | 2022-07-07 | S360300, S358600, S309100 FF, S358700, S358610 |  |  |  |  | 0d |  |  | PROF4 PO M [8 h]; TECH3 PO M [24 h]; TECH3 PO E [8 h] | 5,124.18 | PO&AD | 0 | S309500 |  | S309500 | CA | Not Started | C | Feder, Russ | L4 | BNL | Fab & Assy | Russ Feder | BNL | null | POM02.2.05.08 | C |  | 08 |  | 16727 |  |  | S360400 | 2.05 | 2.05 |  |  |  |  |  |  |  | PO |  |  |  |  |  |
| S360410 |  | Transport Assembled TPC Sections to AH - Labor - CA-D Resource(s) |  | 5d | 2022-06-30 | 2022-07-07 | S360400 SS |  |  |  |  | 0d |  |  | PROF4 AD [8 h] | 1,249.87 | PO&ADS360410 | 0 | S309500 |  | S309500 | CA | Not Started | C | Feder, Russ | L4 | BNL | Fab & Assy | Russ Feder | BNL | null | POM02.2.05.08 | C |  | 08 |  | 16728 |  |  | S360410 | 2.05 | 2.05 |  |  |  |  |  |  |  | C-AD | S360410 |  |  |  |  |
| S360500 |  | Transport Assembled TPC Sections to AH - M&S |  | 5d | 2022-06-30 | 2022-07-07 | S360400 SS, S309100 FF, S360410 SS |  |  |  |  | 0d |  |  | Material (Purchase (1st $2M) [500 h] | 591.95 | S360500 | 0 | S309600 |  | S309600 | CA | Not Started | C | Feder, Russ | M4 | BNL | Fab & Assy | Russ Feder | BNL | null | POM02.2.05.08 | C |  | 08 |  | 16727 |  |  | S360500 | 2.05 | 2.05 |  | UDF_G2 | UDF_G1 | 591.948995 | 1 |  |  |  |  |  |  |  |  |
| S360600 |  | Open SC Magnet Pole Tip Doors |  | 1d | 2022-07-08 | 2022-07-08 | S360400, S360500, S360410 |  |  |  |  | 0d |  |  | PROF4 PO M [4 h]; TECH3 PO M [16 h] | 2,562.09 | S360600 | 0 | S309500 |  | S309650 | CA | Not Started | C | Feder, Russ | L4 | BNL | Fab & Assy | Russ Feder | BNL | null | POM02.2.05.08 | C |  | 08 |  | 16727 |  |  | S360600 | 2.05 | 2.05 |  |  |  |  |  |  |  |  |  | 180413 ELM add per GRY |  |  |  |
| S360700 |  | Install TPC Support - Labor |  | 5d | 2022-07-11 | 2022-07-15 | S360600 |  |  |  |  | 0d |  |  | PROF4 PO M [4 h]; TECH3 PO D [16 h]; TECH3 PO M [80 h] | 12,247.86 | S360700 | 0 | S309700 |  | S309700 | CA | Not Started | C | Feder, Russ | L4 | BNL | Installation | Russ Feder | BNL | null | POM02.2.05.08 | C |  | 08 |  | 16727 |  |  | S360700 | 2.05 | 2.05 |  |  |  |  |  |  |  |  |  |  |  |  |  |
| S360800 |  | Install TPC Support - M&S |  | 5d | 2022-07-11 | 2022-07-15 | S360700 SS |  |  |  |  | 0d |  |  | Material (Purchase (1st $2M) [500 h] | 591.95 | S360800 | 0 | S309800 |  | S309800 | CA | Not Started | C | Feder, Russ | M4 | BNL | Fab & Assy | Russ Feder | BNL | null | POM02.2.05.08 | C |  | 08 |  | 16727 |  |  | S360800 | 2.05 | 2.05 |  | UDF_G2 | UDF_G1 | 591.948995 | 1 |  |  |  |  |  |  |  |  |
| S1003879 |  | Install TPC (Mechanical) - Labor - Physics Resource(s) |  | 5d | 2022-07-18 | 2022-07-22 | S360700, S360800 |  |  |  |  | 0d |  |  | PROF4 PO M [4 h]; TECH3 PO D [16 h]; TECH3 PO M [60 h]; CRAFT3 [36 h] | 14,603.19 | S360900 | 0 | S309900 |  | S309900 | CA | Not Started | C | Feder, Russ | L4 | BNL | Installation | Russ Feder | BNL | null | POM02.2.05.08 | C |  | 08 |  | 16727 |  |  | S1003879 | 2.05 | 2.05 |  |  |  |  |  |  |  |  |  |  |  |  |  |
| S360900 |  | Install TPC (Mechanical) - Labor - CA-D Resource(s) |  | 5d | 2022-07-18 | 2022-07-22 | S360700, S360800 |  |  |  |  | 0d |  |  | PROF2 AD [8 h] | 850.58 | S360900 | 0 | S309900 |  | S309900 | CA | Not Started | C | Feder, Russ | L4 | BNL | Installation | Russ Feder | BNL | null | POM02.2.05.08 | C |  | 08 |  | 16727 |  |  | S360900 | 2.05 | 2.05 |  |  |  |  |  |  |  |  |  |  |  |  |  |
| S361000 |  | Install TPC (Mechanical) - M&S |  | 5d | 2022-07-18 | 2022-07-22 | S360900 SS, S1003879 SS |  |  |  |  | 0d |  |  | Material (Purchase (1st $2M) [500 h] | 591.95 | S361000 | 0 | S310000 |  | S310000 | CA | Not Started | C | Feder, Russ | M4 | BNL | Fab & Assy | Russ Feder | BNL | null | POM02.2.05.08 | C |  | 08 |  | 16727 |  |  | S361000 | 2.05 | 2.05 |  | UDF_G2 | UDF_G1 | 591.948995 | 1 |  |  |  |  |  |  |  |  |
| S361010 |  | Completed - Install TPC | milestone | 0d | 2022-07-22 | 2022-07-22 | S360900 FF, S361000 FF, S1003879 FF |  |  |  |  | 0d |  |  |  |  | S361000 | 0 | S310000 |  | S310000 | NOCA | Not Started | C | Feder, Russ |  | BNL | Fab & Assy | Russ Feder | BNL |  | POM02.2.05.08 |  |  | 08 |  |  |  |  |  |  |  |  |  |  |  |  |  | L5 |  |  |  | 2022-09-30 | 48 | PMP_2x |
| S361100 |  | Align/Survey TPC to SC Magnet Centerline - Labor - Physics Resource(s) |  | 5d | 2022-07-25 | 2022-07-29 | S361010 |  |  |  |  | 0d |  |  | TECH3 PO M [20 h] | 2,421.44 | PO&AD | 0 | S310100 |  | S310100 | CA | Not Started | C | Feder, Russ | L4 | BNL | Installation | Russ Feder | BNL | null | POM02.2.05.08 | C |  | 08 |  | 16727 |  |  | S361100 | 2.05 | 2.05 |  |  |  |  |  |  |  | PO |  |  |  |  |  |
| S361110 |  | Align/Survey TPC to SC Magnet Centerline - Labor - CA-D Resource(s) |  | 5d | 2022-07-25 | 2022-07-29 | S361100 SS |  |  |  |  | 0d |  |  | CRAFT3 [80 h]; TECH3 AD [60 h]; TECH4 AD [60 h] | 26,192.26 | PO&ADS361110 | 0 | S310100 |  | S310100 | CA | Not Started | C | Feder, Russ | L4 | BNL | Installation | Russ Feder | BNL | null | POM02.2.05.08 | C |  | 08 |  | 16728 |  |  | S361110 | 2.05 | 2.05 |  |  |  |  |  |  |  | C-AD | S361110 |  |  |  |  |
| S361200 |  | Align/Survey TPC to SC Magnet Centerline - M&S |  | 5d | 2022-07-25 | 2022-07-29 | S361100 SS, S361110 SS |  |  |  |  | 0d |  |  | Material (Purchase (1st $2M) [500 h] | 591.95 | S361200 | 0 | S310200 |  | S310200 | CA | Not Started | C | Feder, Russ | M4 | BNL | Fab & Assy | Russ Feder | BNL | null | POM02.2.05.08 | C |  | 08 |  | 16727 |  |  | S361200 | 2.05 | 2.05 |  | UDF_G2 | UDF_G1 | 591.948995 | 1 |  |  |  |  |  |  |  |  |
| S361300 |  | Install TPC Cables and Services - Labor |  | 15d | 2022-08-10 | 2022-08-30 | S361100, S361200, S361110, S346410 |  |  |  |  | 4d | 0d |  | TECH3 PO E [120 h]; TECH3 PO M [60 h]; PROF4 PO M [24 h]; TECH3 PO D [24 h]; CRAFT3 [240 h] | 60,293.48 | S361300 | 0 | S310300 |  | S310300 | CA | Not Started | C | Feder, Russ | L4 | BNL | Installation | Russ Feder | BNL | null | POM02.2.05.08 | C |  | 08 |  | 16727 | 008C |  | S361300 | 2.05 | 2.05 |  |  |  |  |  |  |  |  |  | 180416 ELM pred/succ per GRY |  |  |  |
| S361400 |  | Install TPC Cables and Services - M&S |  | 15d | 2022-08-10 | 2022-08-30 | S361300 SS, S346410 |  |  |  |  | 4d | 0d |  | Material (Purchase (1st $2M) [500 h] | 591.95 | S361400 | 0 | S310400 |  | S310400 | CA | Not Started | C | Feder, Russ | M4 | BNL | Fab & Assy | Russ Feder | BNL | null | POM02.2.05.08 | C |  | 08 |  | 16727 | 008C |  | S361400 | 2.05 | 2.05 |  | UDF_G2 | UDF_G1 | 591.948995 | 1 |  |  |  |  | 180416 ELM pred/succ per GRY |  |  |  |
| S361500 |  | TPC - Operational Readiness Review (ORR) |  | 5d | 2022-08-31 | 2022-09-07 | S361300, S361400 |  |  |  |  | 4d | 0d |  | PROF4 PO M [8 h]; TECH3 PO E [8 h]; TECH3 PO M [8 h]; PROF3 PO E [8 h] | 4,260.73 | S361500 | 0 | S310500 |  | S310500 | CA | Not Started | C | Feder, Russ | L4 | BNL | Installation | Russ Feder | BNL | null | POM02.2.05.08 | C |  | 08 |  | 16727 | 004 |  | S361500 | 2.05 | 2.05 |  |  |  |  |  |  |  |  |  |  |  |  |  |
| S361600 |  | Address Action Items from TPC ORR |  | 5d | 2022-09-08 | 2022-09-14 | S361500 |  |  |  |  | 4d | 0d |  | PROF4 PO M [8 h]; TECH3 PO E [8 h]; PROF3 PO E [8 h]; TECH3 PO M [8 h] | 4,260.73 | S361600 | 0 | S310600 |  | S310600 | CA | Not Started | C | Feder, Russ | L4 | BNL | Installation | Russ Feder | BNL | null | POM02.2.05.08 | C |  | 08 |  | 16727 | 004 |  | S361600 | 2.05 | 2.05 |  |  |  |  |  |  |  |  |  |  |  |  |  |
| S361700 |  | Commission TPC - Labor Phys |  | 15d | 2022-09-15 | 2022-10-05 | S361600, S148600, S147600 |  |  |  |  | 4d | 0d |  | PROF4 PO E [40 h]; TECH3 PO E [40 h]; SCI3 PO [400 h]; TECH3 PO M [40 h]; PROF4 PO M [40 h]; TECH3 PO D [40 h] | 100,662.48 | S361700 | 0 | S310700 |  | S310700 | CA | Not Started | C | Feder, Russ | L4 | BNL | Commissioning | Russ Feder | BNL | null | POM02.2.05.08 | C |  | 08 |  | 16727 | 004 |  | S361700 | 2.05 | 2.05 |  |  |  |  |  |  |  |  |  | 180416 ELM dur per GRY |  |  |  |
| S361800 |  | Commission TPC - Labor Students |  | 15d | 2022-09-15 | 2022-10-05 | S361600, S148600, S147600 |  |  |  |  | 4d | 0d |  | STUDENT Other - Unpaid [1600 h] |  | S361800 | 0 | S310700 |  | S310710 | CA | Not Started | T | Feder, Russ | L4 | BNL | Commissioning | Russ Feder | BNL | null | POM02.2.05.08 | K |  | 08 |  | NA | 003,004 |  | S361800 | 2.05 | 2.05 |  |  |  |  |  |  |  |  |  | 180416 ELM dur per GRY |  |  |  |
| S361900 |  | Commission TPC - M&S |  | 15d | 2022-09-15 | 2022-10-05 | S361700 SS, S361800 SS |  |  |  |  | 4d |  |  | Material (Purchase (1st $2M) [500 h] | 594.32 | S361900 | 0 | S310800 |  | S310800 | CA | Not Started | C | Feder, Russ | M4 | BNL | Fab & Assy | Russ Feder | BNL | null | POM02.2.05.08 | C |  | 08 |  | 16727 | 004 |  | S361900 | 2.05 | 2.05 |  | UDF_G2 | UDF_G1 | 595.895292 | 1 |  |  |  |  | 180416 ELM dur per GRY |  |  |  |

Notes:
- S359500: BNL_UDF_Old Activity Name 181221: Design TPC Integration/Installation Tooling/Fixtures FY18
- S359600: BNL_UDF_Status Comments: 190319 ELM remove status, dur; 190318 ELM logic, name per GRY / BNL_UDF_Old Activity Name 181221: Design TPC Integration/Installation Tooling/Fixtures FY19
- S359605: BNL_UDF_Status Comments: 190319 ELM remove status, dur; 190318 ELM logic, name per GRY / BNL_UDF_Old Activity Name 181221: Design TPC Integration/Installation Tooling/Fixtures FY19
- S359900: BNL_UDF_Old Activity Name 181221: Prepare TPC Integration/Installation Tooling/Fixtures Procedures
- S359700: BNL_UDF_Old Activity Name 181221: (Planning Package) Fabricate/Procure TPC Integration/Installation Tooling/Fixtures - Labor
- S359800: BNL_UDF_Old Activity Name 181221: (Planning Package) Fabricate/Procure TPC Integration/Installation Tooling/Fixtures - M&S
- S360000: BNL_UDF_Old Activity Name 181221: Review TPC Integration/Installation Tooling/Fixtures/Procedures Safety/Certification
- S360100: BNL_UDF_Old Activity Name 181221: Address Action Items from TPC Integration/Installation Tooling/Fixtures/Procedures Design & Safety Reviews
- S360200: BNL_UDF_Old Activity Name 181221: Design/Safety Reviews Complete, TPC Integration/Installation Tooling/Fixtures/Procedures Ready for Service
- S360300: BNL_UDF_Old Activity Name 181221: TPC Ready for Installation (Installation Sequence Can Commence)
- S360400: BNL_UDF_Old Activity Name 181221: Transport Assembled TPC Sections to AH - Labor
- S360410: BNL_UDF_Old Activity Name 181221: Transport Assembled TPC Sections to AH - Labor
- S360500: BNL_UDF_Old Activity Name 181221: Transport Assembled TPC Sections to AH - M&S
- S360600: BNL_UDF_Old Activity Name 181221: Open SC Magnet Pole Tip Doors
- S360700: Scheduler's Notes: 180413 ELM per GRY: / assume 2 people / BNL_UDF_Old Activity Name 181221: Install TPC Support - Labor
- S360800: BNL_UDF_Old Activity Name 181221: Install TPC Support - M&S
- S1003879: Scheduler's Notes: 180413 ELM per GRY: / assume 4 people / BNL_UDF_Old Activity Name 181221: Install TPC (Mechanical) - Labor
- S360900: Scheduler's Notes: 180413 ELM per GRY: / assume 4 people / BNL_UDF_Old Activity Name 181221: Install TPC (Mechanical) - Labor
- S361000: BNL_UDF_Old Activity Name 181221: Install TPC (Mechanical) - M&S
- S361010: BNL_UDF_Old Activity Name 181221: Install TPC (Mechanical) - M&S
- S361100: BNL_UDF_Old Activity Name 181221: Align/Survey TPC to SC Magnet Centerline - Labor
- S361110: BNL_UDF_Old Activity Name 181221: Align/Survey TPC to SC Magnet Centerline - Labor
- S361200: BNL_UDF_Old Activity Name 181221: Align/Survey TPC to SC Magnet Centerline - M&S
- S361300: Scheduler's Notes: 180413 ELM per GRY: / assume 2 people / BNL_UDF_Old Activity Name 181221: Install TPC Cables and Services - Labor
- S361400: BNL_UDF_Old Activity Name 181221: Install TPC Cables and Services - M&S
- S361500: BNL_UDF_Status Comments: 190416 ELM name per GRY / BNL_UDF_Old Activity Name 181221: Review TPC for Operational Readiness (ORR)
- S361600: BNL_UDF_Status Comments: 190329 ELM dur per GRY / BNL_UDF_Old Activity Name 181221: Address Action Items from TPC ORR
- S361700: BNL_UDF_Status Comments: 190329 ELM dur per GRY / BNL_UDF_Old Activity Name 181221: Commission TPC - Labor - Fund Category C
- S361800: BNL_UDF_Status Comments: 190329 ELM dur per GRY / BNL_UDF_Old Activity Name 181221: Commission TPC - Labor - Fund Category T
- S361900: BNL_UDF_Status Comments: 190329 ELM dur per GRY / BNL_UDF_Old Activity Name 181221: Commission TPC - M&S

| ID | WBS | Activity | Type | Duration | Start | Finish | Predecessors | Complete | Remaining | Planned start | Planned finish | Total float | Free float | Constraint | Expected finish | Resources | Cost | BNL_UDF_Status Comments | BNL_UDF_Temp Text 01 | BNL_UDF_Percent Complete | BNL_UDF_OPC TEC (deprecated) | BNL_UDF_Old Activity ID 181221 | BNL_Cobra WP | RG Check | BNL_Activity Status | BNL_Fund Source | BNL_Estimator | BNL_Cost Basis | BNL_Location | BNL_EDIA | BNL_CAM | BNL_Institution | BNL_OPC TEC (deprecated) | BNL_WBS | BNL_EVT | BNL_Master Control Account | BNL_Account Number | BNL_PCR ID | BNL_Cobra Control Account | BNL_WBS_Hierarchical | BNL_UDF_Exclude | Indicator - Procurement | Indicator - Float | BNL_UDF_Remaining Tot Cost | BNL_UDF_Percent_remaining | BNL_Proc Sig | BNL_Milestone Level | BNL_UDF_Adhoc Comments | Temp | BNL_UDF_Temp Text 02 |
| --- | --- | --- | --- | --- | --- | --- | --- | --- | --- | --- | --- | --- | --- | --- | --- | --- | --- | --- | --- | --- | --- | --- | --- | --- | --- | --- | --- | --- | --- | --- | --- | --- | --- | --- | --- | --- | --- | --- | --- | --- | --- | --- | --- | --- | --- | --- | --- | --- | --- | --- |
|  | 09 | **INTT Installation** |  |  | 2019-10-01 | 2022-09-30 |  |  |  |  |  |  |  |  |  |  |  |  |  |  |  |  |  |  |  |  |  |  |  |  |  |  |  |  |  |  |  |  |  |  |  |  |  |  |  |  |  |  |  |  |
| S362000 |  | Design INTT Integration/Installation Tooling/Fixtures |  | 60d | 2019-10-01 A | 2021-06-14 | S100090 SS | 80% | 10d | 2020-10-01 | 2020-12-30 | 200d | 0d |  | 2021-06-14 | PROF4 PO M [30 h]; TECH3 PO D [60 h] | 11,603.24 | 190318 ELM logic, name per GRY | S362000 | 0 | S310900 | S310900 | S362000 | CA | In Progress | C | Feder, Russ | L4 | BNL | Installation | Russ Feder | BNL | null | POM02.2.05.09 | C | 2.05 | 16727 | 003 | 2.05 | 09 |  |  |  |  |  |  |  |  |  |  |
| S362100 |  | Fabricate/Procure INTT Integration/Installation Tooling/Fixtures - Labor |  | 60d | 2021-06-15 | 2021-09-08 | S362000 |  |  |  |  | 200d | 0d |  |  | PROF4 PO M [60 h]; TECH3 PO D [20 h] | 11,451.89 |  | S362100 | 0 | S311000 | S311000 | S362100 | CA | Not Started | C | Feder, Russ | L4 | BNL | Fab & Assy | Russ Feder | BNL | null | POM02.2.05.09 | C | 2.05 | 16727 |  | 2.05 | 09 |  |  |  |  |  |  |  |  |  |  |
| S362200 |  | Fabricate/Procure INTT Integration/Installation Tooling/Fixtures - M&S |  | 60d | 2021-06-15 | 2021-09-08 | S362100 SS |  |  |  |  | 200d | 0d |  |  | Material (Purchase (1st $2M) [30000 h] | 34,820.53 |  | S362200 | 0 | S311100 | S311100 | S362200 | CA | Not Started | C | Feder, Russ | M5 | BNL | Fab & Assy | Russ Feder | BNL | null | POM02.2.05.09 | C | 2.05 | 16727 |  | 2.05 | 09 | MP6LAEXCLUDE | UDF_G1 | UDF_G3 | 34820.5293 | 1 | TBD |  |  |  |  |
| S362300 |  | Prepare INTT Integration/Installation Tooling/Fixtures Procedures |  | 10d | 2021-09-09 | 2021-09-22 | S362100, S362200 |  |  |  |  | 200d | 0d |  |  | PROF4 PO M [40 h]; TECH3 PO D [20 h] | 8,418.23 |  | S362300 | 0 | S311200 | S311200 | S362300 | CA | Not Started | C | Feder, Russ | L4 | BNL | Installation | Russ Feder | BNL | null | POM02.2.05.09 | C | 2.05 | 16727 |  | 2.05 | 09 |  |  |  |  |  |  |  |  |  |  |
| S362400 |  | Review INTT Integration/Installation Tooling/Fixtures/Procedures Safety/Certification |  | 10d | 2021-09-23 | 2021-10-06 | S362300 |  |  |  |  | 200d | 0d |  |  | PROF4 PO M [8 h]; TECH3 PO M [8 h]; TECH3 PO D [8 h] | 3,131.33 |  | S362400 | 0 | S311300 | S311300 | S362400 | CA | Not Started | C | Feder, Russ | L4 | BNL | Installation | Russ Feder | BNL | null | POM02.2.05.09 | C | 2.05 | 16727 |  | 2.05 | 09 |  |  |  |  |  |  |  |  |  |  |
| S362500 |  | Address Action Items from INTT Integration/Installation Tooling/Fixtures Design & Safety Reviews |  | 10d | 2021-10-07 | 2021-10-21 | S362400 |  |  |  |  | 200d | 0d |  |  | PROF4 PO M [8 h]; TECH3 PO M [8 h]; TECH3 PO D [8 h] | 3,187.02 |  | S362500 | 0 | S311400 | S311400 | S362500 | CA | Not Started | C | Feder, Russ | L4 | BNL | Installation | Russ Feder | BNL | null | POM02.2.05.09 | C | 2.05 | 16727 |  | 2.05 | 09 |  |  |  |  |  |  |  |  |  |  |
| S362600 |  | Design/Safety Reviews Complete, INTT Integration/Installation Tooling/Fixtures/Procedures Ready for Service | milestone | 0d | 2021-10-21 | 2021-10-21 | S362500 FF |  |  |  |  | 200d | 146d |  |  |  |  |  | S362600 | 0 | S311500 | S311500 |  | NOCA | Not Started | C | Feder, Russ |  | BNL | Management Safety Reviews | Russ Feder | BNL |  | POM02.2.05.09 |  |  |  |  |  | 09 |  |  |  |  |  |  | L3 |  |  |  |
| EXT327600 |  | [External Activity] INTT Assembly Complete and Ready for Installation | milestone | 0d | 2022-05-25 | 2022-05-25 | S100000 SF |  |  |  |  | 0d |  | finish on 2022-05-25 |  |  |  | 190328 ELM constr. date per Rachid Schedule | S274200 | 0 | S327600 | S327600(copy) |  | NOCA | Not Started | C | Nouicer, Rachid |  | Japan RIKEN | Fab & Assy | Russ Feder | Japan |  | POM02.2.05.09 |  |  |  | 004 |  | 09 |  |  |  |  |  |  | L3 |  |  |  |
| S362700 |  | INTT Ready for Installation | milestone | 0d | 2022-05-25 | 2022-05-25 | S362600 FF, EXT327600, S318150 |  |  |  |  | 54d | 53d |  |  |  |  |  | S362700 | 0 | S311600 | S311600 |  | NOCA | Not Started | C | Feder, Russ |  | BNL | Installation | Russ Feder | BNL |  | POM02.2.05.09 |  |  |  |  |  | 09 |  |  |  |  |  |  | L3 | 180416 ELM dur per GRY; 180413 ELM pred/succ per GRY |  |  |
| S362800 |  | Transport Assembled INTT Sections to AH - Labor |  | 2d | 2022-08-10 | 2022-08-11 | S362700, S346410 |  |  |  |  | 1d | 0d |  |  | PROF4 PO M [8 h]; TECH3 PO M [24 h]; TECH3 PO E [8 h] | 5,124.18 |  | S362800 | 0 | S311700 | S311700 | S362800 | CA | Not Started | C | Feder, Russ | L4 | BNL | Fab & Assy | Russ Feder | BNL | null | POM02.2.05.09 | C | 2.05 | 16727 |  | 2.05 | 09 |  |  |  |  |  |  |  |  |  |  |
| S362900 |  | Transport Assembled INTT Sections to AH - M&S |  | 2d | 2022-08-10 | 2022-08-11 | S362800 SS |  |  |  |  | 1d | 0d |  |  | Material (Purchase (1st $2M) [500 h] | 591.95 |  | S362900 | 0 | S311800 | S311800 | S362900 | CA | Not Started | C | Feder, Russ | M4 | BNL | Fab & Assy | Russ Feder | BNL | null | POM02.2.05.09 | C | 2.05 | 16727 |  | 2.05 | 09 |  | UDF_G2 | UDF_G1 | 591.948995 | 1 |  |  |  |  |  |
| S363000 |  | Install INTT Support - Labor |  | 2d | 2022-08-12 | 2022-08-15 | S362800, S362900 |  |  |  |  | 1d | 0d |  |  | PROF4 PO M [8 h]; TECH3 PO D [8 h]; TECH3 PO M [60 h] | 9,482.78 |  | S363000 | 0 | S311900 | S311900 | S363000 | CA | Not Started | C | Feder, Russ | L4 | BNL | Installation | Russ Feder | BNL | null | POM02.2.05.09 | C | 2.05 | 16727 |  | 2.05 | 09 |  |  |  |  |  |  |  |  |  |  |
| S363100 |  | Install INTT Support - M&S |  | 2d | 2022-08-12 | 2022-08-15 | S363000 SS |  |  |  |  | 1d | 0d |  |  | Material (Purchase (1st $2M) [500 h] | 591.95 |  | S363100 | 0 | S312000 | S312000 | S363100 | CA | Not Started | C | Feder, Russ | M4 | BNL | Fab & Assy | Russ Feder | BNL | null | POM02.2.05.09 | C | 2.05 | 16727 |  | 2.05 | 09 |  | UDF_G2 | UDF_G1 | 591.948995 | 1 |  |  |  |  |  |
| S363200 |  | Install INTT (mechanical) - Labor |  | 3d | 2022-08-16 | 2022-08-18 | S363000, S363100 |  |  |  |  | 7d | 0d |  |  | PROF4 PO M [8 h]; TECH3 PO D [8 h]; TECH3 PO M [60 h] | 9,482.78 |  | S363200 | 0 | S312100 | S312100 | S363200 | CA | Not Started | C | Feder, Russ | L4 | BNL | Installation | Russ Feder | BNL | null | POM02.2.05.09 | C | 2.05 | 16727 |  | 2.05 | 09 |  |  |  |  |  |  |  |  |  |  |
| S363300 |  | Install INTT (mechanical) - M&S |  | 3d | 2022-08-16 | 2022-08-18 | S363200 SS |  |  |  |  | 7d | 0d |  |  | Material (Purchase (1st $2M) [500 h] | 591.95 |  | S363300 | 0 | S312200 | S312200 | S363300 | CA | Not Started | C | Feder, Russ | M4 | BNL | Fab & Assy | Russ Feder | BNL | null | POM02.2.05.09 | C | 2.05 | 16727 |  | 2.05 | 09 |  | UDF_G2 | UDF_G1 | 591.948995 | 1 |  |  |  |  |  |
| S363400 |  | Align/Survey INTT to SC Magnet Centerline - Labor - Physics Resource(s) |  | 5d | 2022-08-19 | 2022-08-25 | S363200, S363300 |  |  |  |  | 7d | 0d |  |  | TECH3 PO M [20 h] | 2,421.44 |  | PO&AD | 0 | S312300 | S312300 | S363400 | CA | Not Started | C | Feder, Russ | L4 | BNL | Installation | Russ Feder | BNL | null | POM02.2.05.09 | C | 2.05 | 16727 |  | 2.05 | 09 |  |  |  |  |  |  |  |  | PO |  |
| S363410 |  | Align/Survey INTT to SC Magnet Centerline - Labor - CA-D Resource(s) |  | 5d | 2022-08-19 | 2022-08-25 | S363400 SS |  |  |  |  | 7d | 0d |  |  | CRAFT3 [80 h]; TECH3 AD [60 h] | 17,879.38 |  | PO&ADS363410 | 0 | S312300 | S312300 | S363410 | CA | Not Started | C | Feder, Russ | L4 | BNL | Installation | Russ Feder | BNL | null | POM02.2.05.09 | C | 2.05 | 16728 |  | 2.05 | 09 |  |  |  |  |  |  |  |  | C-AD | S363410 |
| S363500 |  | Align/Survey INTT to SC Magnet Centerline - M&S |  | 5d | 2022-08-19 | 2022-08-25 | S363410 SS |  |  |  |  | 7d | 0d |  |  | Material (Purchase (1st $2M) [500 h] | 591.95 |  | S363500 | 0 | S312400 | S312400 | S363500 | CA | Not Started | C | Feder, Russ | M4 | BNL | Fab & Assy | Russ Feder | BNL | null | POM02.2.05.09 | C | 2.05 | 16727 |  | 2.05 | 09 |  | UDF_G2 | UDF_G1 | 591.948995 | 1 |  |  |  |  |  |
| S363600 |  | Install INTT Cables and Services - Labor |  | 5d | 2022-08-26 | 2022-09-01 | S363400, S363500, S363410 |  |  |  |  | 7d | 0d |  |  | TECH3 PO E [120 h]; TECH3 PO M [120 h]; PROF4 PO E [24 h]; PROF4 PO M [24 h]; TECH3 PO D [24 h]; CRAFT3 [240 h] | 71,307.42 | 190328, 190329 ELM dur per GRY | S363600 | 0 | S312500 | S312500 | S363600 | CA | Not Started | C | Feder, Russ | L4 | BNL | Installation | Russ Feder | BNL | null | POM02.2.05.09 | C | 2.05 | 16727 | 004 | 2.05 | 09 |  |  |  |  |  |  |  |  |  |  |
| S363700 |  | Install INTT Cables and Services - M&S |  | 5d | 2022-08-26 | 2022-09-01 | S363600 SS |  |  |  |  | 7d |  |  |  | Material (Purchase (1st $2M) [500 h] | 591.95 | 190328, 190329 ELM dur per GRY | S363700 | 0 | S312600 | S312600 | S363700 | CA | Not Started | C | Feder, Russ | M4 | BNL | Fab & Assy | Russ Feder | BNL | null | POM02.2.05.09 | C | 2.05 | 16727 | 004 | 2.05 | 09 |  | UDF_G2 | UDF_G1 | 591.948995 | 1 |  |  |  |  |  |
| S363800 |  | INTT - Operational Readiness Review (ORR) |  | 5d | 2022-09-02 | 2022-09-09 | S363600 |  |  |  |  | 7d | 0d |  |  | PROF4 PO M [8 h]; TECH3 PO D [8 h]; TECH3 PO M [8 h]; TECH3 PO E [8 h] | 4,155.6 | 190416 ELM name per GRY; 190328 ELM dur per GRY | S363800 | 0 | S312700 | S312700 | S363800 | CA | Not Started | C | Feder, Russ | L4 | BNL | Installation | Russ Feder | BNL | null | POM02.2.05.09 | C | 2.05 | 16727 | 004 | 2.05 | 09 |  |  |  |  |  |  |  |  |  |  |
| S363900 |  | Address Action Items from INTT ORR |  | 5d | 2022-09-12 | 2022-09-16 | S363800 |  |  |  |  | 7d | 0d |  |  | PROF4 PO M [8 h]; TECH3 PO D [8 h]; TECH3 PO M [8 h]; TECH3 PO E [8 h] | 4,155.6 | 190328 ELM dur per GRY | S363900 | 0 | S312800 | S312800 | S363900 | CA | Not Started | C | Feder, Russ | L4 | BNL | Installation | Russ Feder | BNL | null | POM02.2.05.09 | C | 2.05 | 16727 | 004 | 2.05 | 09 |  |  |  |  |  |  |  |  |  |  |
| S364000 |  | Commission INTT - Labor |  | 10d | 2022-09-19 | 2022-09-30 | S363900 |  |  |  |  | 7d | 0d |  |  | PROF4 PO E [40 h]; SCI3 PO [400 h]; TECH3 PO M [40 h]; TECH3 PO E [40 h]; PROF4 PO M [40 h]; TECH3 PO D [40 h] | 100,062.1 | 190328 ELM dur per GRY | S364000 | 0 | S312900 | S312900 | S364000 | CA | Not Started | C | Feder, Russ | L4 | BNL | Commissioning | Russ Feder | BNL | null | POM02.2.05.09 | C | 2.05 | 16727 | 004 | 2.05 | 09 |  |  |  |  |  |  |  | 180416 ELM dur per GRY |  |  |
| S364100 |  | Commission INTT - Labor |  | 10d | 2022-09-19 | 2022-09-30 | S363900 |  |  |  |  | 7d | 0d |  |  | STUDENT Other - Unpaid [1600 h] |  | 190328 ELM dur per GRY; 190313 ELM rsrc | S364100 | 0 | S312900 | S312910 | S364100 | CA | Not Started | T | Feder, Russ | L4 | BNL | Commissioning | Russ Feder | BNL | null | POM02.2.05.09 | K | 2.05 | NA | 003,004 | 2.05 | 09 |  |  |  |  |  |  |  | 180416 ELM dur per GRY |  |  |
| S364200 |  | Commission INTT - M&S |  | 10d | 2022-09-19 | 2022-09-30 | S364000 SS, S364100 SS |  |  |  |  | 7d | 0d |  |  | Material (Purchase (1st $2M) [500 h] | 591.95 | 190328 ELM dur per GRY | S364200 | 0 | S313000 | S313000 | S364200 | CA | Not Started | C | Feder, Russ | M4 | BNL | Fab & Assy | Russ Feder | BNL | null | POM02.2.05.09 | C | 2.05 | 16727 | 004 | 2.05 | 09 |  | UDF_G2 | UDF_G1 | 594.316773 | 1 |  |  | 180416 ELM dur per GRY |  |  |
| S364210 |  | Completed - Install INTT | milestone | 0d | 2022-09-30 | 2022-09-30 | S364000 FF, S364100 FF, S364200 FF |  |  |  |  | 7d |  |  |  |  |  |  | S364200 | 0 | S313000 | S313000 |  | NOCA | Not Started | C | Feder, Russ |  | BNL | Fab & Assy | Russ Feder | BNL |  | POM02.2.05.09 |  |  |  |  |  | 09 |  |  |  |  |  |  | L3 | 180416 ELM dur per GRY |  |  |

Notes:
- S362000: BNL_UDF_Old Activity Name 181221: Design INTT Integration/Installation Tooling/Fixtures
- S362100: BNL_UDF_Old Activity Name 181221: Fabricate/Procure INTT Integration/Installation Tooling/Fixtures - Labor
- S362200: BNL_UDF_Old Activity Name 181221: Fabricate/Procure INTT Integration/Installation Tooling/Fixtures - M&S
- S362300: BNL_UDF_Old Activity Name 181221: Prepare INTT Integration/Installation Tooling/Fixtures Procedures
- S362400: BNL_UDF_Old Activity Name 181221: Review INTT Integration/Installation Tooling/Fixtures/Procedures Safety/Certification
- S362500: BNL_UDF_Old Activity Name 181221: Address Action Items from INTT Integration/Installation Tooling/Fixtures Design & Safety Reviews
- S362600: BNL_UDF_Old Activity Name 181221: Design/Safety Reviews Complete, INTT Integration/Installation Tooling/Fixtures/Procedures Ready for Service
- EXT327600: BNL_UDF_Old Activity Name 181221: INTT Assembly Complete and Ready for Installation
- S362700: BNL_UDF_Old Activity Name 181221: INTT Ready for Installation
- S362800: BNL_UDF_Old Activity Name 181221: Transport Assembled INTT Sections to AH - Labor
- S362900: BNL_UDF_Old Activity Name 181221: Transport Assembled INTT Sections to AH - M&S
- S363000: BNL_UDF_Old Activity Name 181221: Install INTT Support - Labor
- S363100: BNL_UDF_Old Activity Name 181221: Install INTT Support - M&S
- S363200: BNL_UDF_Old Activity Name 181221: Install INTT (mechanical) - Labor
- S363300: BNL_UDF_Old Activity Name 181221: Install INTT (mechanical) - M&S
- S363400: BNL_UDF_Old Activity Name 181221: Align/Survey INTT to SC Magnet Centerline - Labor
- S363410: BNL_UDF_Old Activity Name 181221: Align/Survey INTT to SC Magnet Centerline - Labor
- S363500: BNL_UDF_Old Activity Name 181221: Align/Survey INTT to SC Magnet Centerline - M&S
- S363600: BNL_UDF_Old Activity Name 181221: Install INTT Cables and Services - Labor
- S363700: BNL_UDF_Old Activity Name 181221: Install INTT Cables and Services - M&S
- S363800: BNL_UDF_Old Activity Name 181221: Review INTT for Operational Readiness (ORR)
- S363900: BNL_UDF_Old Activity Name 181221: Address Action Items from INTT ORR
- S364000: BNL_UDF_Old Activity Name 181221: Commission INTT - Labor - Fund Category C
- S364100: BNL_UDF_Old Activity Name 181221: Commission INTT - Labor - Fund Category T
- S364200: BNL_UDF_Old Activity Name 181221: Commission INTT - M&S
- S364210: BNL_UDF_Old Activity Name 181221: Commission INTT - M&S

| ID | WBS | Activity | Type | Duration | Start | Finish | Predecessors | Complete | Remaining | Planned start | Planned finish | Total float | Free float | Constraint | Expected finish | Resources | Cost | BNL_UDF_Status Comments | BNL_UDF_Temp Text 01 | BNL_UDF_Percent Complete | BNL_UDF_OPC TEC (deprecated) | BNL_UDF_Old Activity ID 181221 | BNL_Cobra WP | RG Check | BNL_Activity Status | BNL_Fund Source | BNL_Estimator | BNL_Cost Basis | BNL_Location | BNL_EDIA | BNL_CAM | BNL_Institution | BNL_OPC TEC (deprecated) | BNL_WBS | BNL_EVT | BNL_Master Control Account | BNL_Account Number | BNL_PCR ID | BNL_Cobra Control Account | BNL_WBS_Hierarchical | BNL_UDF_Exclude | Indicator - Procurement | Indicator - Float | BNL_UDF_Remaining Tot Cost | BNL_UDF_Percent_remaining | BNL_Proc Sig | BNL_Milestone Level | MVTX Material Contingency | MVTX labor Contingency | MVTX Total Contingency | MVTX MSProject Task ID | MSP Activity ID | MVTX Institution | MVTX Resource Costs | MVTX cost plus contingency | MVTX Total cost with overhead | MVTX Number 1 | MVTX DOE designate | MVTX MSP Notes | Temp | BNL_UDF_Temp Text 02 | BNL_UDF_Adhoc Comments | Target Milestone Date | Variance | PMP Milestones |
| --- | --- | --- | --- | --- | --- | --- | --- | --- | --- | --- | --- | --- | --- | --- | --- | --- | --- | --- | --- | --- | --- | --- | --- | --- | --- | --- | --- | --- | --- | --- | --- | --- | --- | --- | --- | --- | --- | --- | --- | --- | --- | --- | --- | --- | --- | --- | --- | --- | --- | --- | --- | --- | --- | --- | --- | --- | --- | --- | --- | --- | --- | --- | --- | --- | --- |
|  | 10 | **MVTX Installation** |  |  | 2019-10-01 | 2022-10-03 |  |  |  |  |  |  |  |  |  |  |  |  |  |  |  |  |  |  |  |  |  |  |  |  |  |  |  |  |  |  |  |  |  |  |  |  |  |  |  |  |  |  |  |  |  |  |  |  |  |  |  |  |  |  |  |  |  |  |  |
| S364300 |  | Design MVTX Integration/Installation Tooling/Fixtures |  | 60d | 2019-10-01 A | 2021-06-14 | S100090 SS | 95% | 10d | 2020-10-01 | 2020-12-30 | 199d | 0d |  | 2021-06-14 | PROF4 PO M [30 h]; TECH3 PO D [60 h] | 11,603.24 | 190318 ELM logic, name per GRY | S364300 | 0 | S313100 | S313100 | S364300 | CA | In Progress | C | Feder, Russ | L4 | BNL | Installation | Russ Feder | BNL | null | POM02.2.05.10 | C | 2.05 | 16727 | 003 | 2.05 | 10 |  |  |  |  |  |  |  |  |  |  |  |  |  |  |  |  |  |  |  |  |  |  |  |  |  |
| S364600 |  | Prepare MVTX Integration/Installation Tooling/Fixtures Procedures |  | 10d | 2021-04-29 A | 2021-09-10 | S364400, S364500 | 35% | 2d | 2021-08-27 | 2021-09-10 | 199d | 0d |  | 2021-09-10 | PROF4 PO M [40 h]; TECH3 PO D [10 h] | 7,242.78 |  | S364600 | 0 | S313400 | S313400 | S364600 | CA | Not Started | C | Feder, Russ | L4 | BNL | Installation | Russ Feder | BNL | null | POM02.2.05.10 | C | 2.05 | 16727 |  | 2.05 | 10 |  |  |  |  |  |  |  |  |  |  |  |  |  |  |  |  |  |  |  |  |  |  |  |  |  |
| S364400 |  | Fabricate/Procure MVTX Integration/Installation Tooling/Fixtures - Labor |  | 60d | 2021-06-15 | 2021-09-08 | S364300 |  |  |  |  | 199d | 0d |  |  | PROF4 PO M [60 h]; TECH3 PO D [20 h]; TECH3 PO M [20 h] | 13,802.81 |  | S364400 | 0 | S313200 | S313200 | S364400 | CA | Not Started | C | Feder, Russ | L4 | BNL | Fab & Assy | Russ Feder | BNL | null | POM02.2.05.10 | C | 2.05 | 16727 |  | 2.05 | 10 |  |  |  |  |  |  |  |  |  |  |  |  |  |  |  |  |  |  |  |  |  |  |  |  |  |
| S364500 |  | Fabricate/Procure MVTX Integration/Installation Tooling/Fixtures - M&S |  | 60d | 2021-06-15 | 2021-09-08 | S364400 SS |  |  |  |  | 199d | 0d |  |  | Material (Purchase (1st $2M) [30000 h] | 34,820.53 |  | S364500 | 0 | S313300 | S313300 | S364500 | CA | Not Started | C | Feder, Russ | M5 | BNL | Fab & Assy | Russ Feder | BNL | null | POM02.2.05.10 | C | 2.05 | 16727 |  | 2.05 | 10 | MP6LAEXCLUDE | UDF_G1 | UDF_G3 | 34820.5293 | 1 | TBD |  |  |  |  |  |  |  |  |  |  |  |  |  |  |  |  |  |  |  |
| S364700 |  | Review MVTX Integration/Installation Tooling/Fixtures/Procedures Safety/Certification |  | 10d | 2021-09-13 | 2021-09-24 | S364600 |  |  |  |  | 199d | 0d |  |  | PROF4 PO M [8 h]; TECH3 PO D [8 h]; TECH3 PO M [8 h] | 3,094.2 |  | S364700 | 0 | S313500 | S313500 | S364700 | CA | Not Started | C | Feder, Russ | L4 | BNL | Installation | Russ Feder | BNL | null | POM02.2.05.10 | C | 2.05 | 16727 |  | 2.05 | 10 |  |  |  |  |  |  |  |  |  |  |  |  |  |  |  |  |  |  |  |  |  |  |  |  |  |
| S364800 |  | Address Action Items from MVTX Integration/Installation Tooling/Fixtures/Procedures Design & Safety Reviews |  | 10d | 2021-09-27 | 2021-10-08 | S364700 |  |  |  |  | 199d | 0d |  |  | PROF4 PO M [8 h]; TECH3 PO D [8 h]; TECH3 PO M [8 h] | 3,149.89 |  | S364800 | 0 | S313600 | S313600 | S364800 | CA | Not Started | C | Feder, Russ | L4 | BNL | Installation | Russ Feder | BNL | null | POM02.2.05.10 | C | 2.05 | 16727 |  | 2.05 | 10 |  |  |  |  |  |  |  |  |  |  |  |  |  |  |  |  |  |  |  |  |  |  |  |  |  |
| S364900 |  | Design/Safety Reviews Complete, MVTX Integration/Installation Tooling/Fixtures/Procedures Ready for Service | milestone | 0d | 2021-10-08 | 2021-10-08 | S364800 FF |  |  |  |  | 199d | 106d |  |  |  |  |  | S364900 | 0 | S313700 | S313700 |  | NOCA | Not Started | C | Feder, Russ | L4 | BNL | Management Safety Reviews | Russ Feder | BNL |  | POM02.2.05.10 |  |  |  |  |  | 10 |  |  |  |  |  |  | L3 |  |  |  |  |  |  |  |  |  |  |  |  |  |  |  |  |  |  |
| EXT101400 |  | [External Activity] MVTX Complete and ready for installation | milestone | 0d | 2022-03-17 | 2022-03-17 | S100000 SF |  |  |  |  | 0d |  | finish on 2022-03-17 |  |  |  | 190328 ELM constr. date per Rachid Schedule | S274300 | 0 |  | S361850(copy) |  | NOCA | Not Started | C |  |  |  | Critical Decisions, Key Dates | Russ Feder |  |  | POM02.2.05.10 |  |  |  | 004 |  | 10 |  |  |  |  |  |  | L3 | 0 | 0 | 0 | 184 | 1282 |  |  |  |  |  |  |  |  |  |  |  |  |  |
| S365000 |  | MVTX Ready for Installation | milestone | 0d | 2022-03-17 | 2022-03-17 | S364900 FF, EXT101400 FF, S318160 |  |  |  |  | 93d | 0d |  |  |  |  |  | S365000 | 0 | S313800 | S313800 |  | NOCA | Not Started | C | Feder, Russ | L4 | BNL | Installation | Russ Feder | BNL |  | POM02.2.05.10 |  |  |  |  |  | 10 |  |  |  |  |  |  | L3 |  |  |  |  |  |  |  |  |  |  |  |  |  |  |  |  |  |  |
| S365100 |  | Installation Prep |  | 5d | 2022-03-18 | 2022-03-24 | S365000 |  |  |  |  | 93d | 0d |  |  | SCI3 LANL [80 h]; STAFFPHYS LBNL [80 h]; POSTD LBNL [80 h] |  |  | S365100 | 0 |  | S313810 | S365100 | CA | Not Started | T | Feder, Russ | L4 |  | Installation | Russ Feder |  |  | POM02.2.05.10 | K | 2.05 | NA |  | 2.05 | 10 |  |  |  |  |  |  |  | .35 | .35 | .35 | 175 | 1241 | ALL | 15520 | 20952 | 22837.68 | 0.09 | DOE |  |  |  |  |  |  |  |
| S365200 |  | Installation Review |  | 1d | 2022-03-25 | 2022-03-25 | S365100 |  |  |  |  | 93d | 0d |  |  | STAFFPHYS LBNL [8 h]; POSTD LBNL [8 h]; SCI3 LANL [8 h] |  |  | S365200 | 0 |  | S313820 | S365200 | CA | Not Started | T | Feder, Russ | L4 |  | Installation | Russ Feder |  |  | POM02.2.05.10 | K | 2.05 | NA |  | 2.05 | 10 |  |  |  |  |  |  |  | .10 | .10 | .10 | 176 | 1240 | ALL | 2080 | 2288 | 2493.92 | 0.09 | DOE |  |  |  |  |  |  |  |
| S365300 |  | Transport Assembled MVTX Sections to IR - Labor |  | 5d | 2022-03-28 | 2022-04-01 | S365200 |  |  |  |  | 93d | 0d |  |  | PROF4 PO M [8 h]; TECH3 PO M [24 h]; TECH3 PO E [8 h] | 5,124.18 |  | S365300 | 0 | S313900 | S313900 | S365300 | CA | Not Started | C | Feder, Russ | L4 | BNL | Fab & Assy | Russ Feder | BNL | null | POM02.2.05.10 | C | 2.05 | 16727 |  | 2.05 | 10 |  |  |  |  |  |  |  |  |  |  |  |  |  |  |  |  |  |  |  |  |  |  |  |  |  |
| S365400 |  | Transport Assembled MVTX Sections to IR - M&S |  | 5d | 2022-03-28 | 2022-04-01 | S365300 SS |  |  |  |  | 93d | 92d |  |  | Material (Purchase (1st $2M) [500 h] | 591.95 |  | S365400 | 0 | S314000 | S314000 | S365400 | CA | Not Started | C | Feder, Russ | M4 | BNL | Fab & Assy | Russ Feder | BNL | null | POM02.2.05.10 | C | 2.05 | 16727 |  | 2.05 | 10 |  | UDF_G3 | UDF_G3 | 591.948995 | 1 |  |  |  |  |  |  |  |  |  |  |  |  |  |  |  |  |  |  |  |  |
| S365500 |  | Install MVTX Support - Labor |  | 3d | 2022-08-12 | 2022-08-16 | S365300, S363000 SS, S363100 SS, S365400 |  |  |  |  | 1d | 0d |  |  | PROF4 PO M [8 h]; TECH3 PO D [8 h]; TECH3 PO M [60 h] | 9,482.78 | 190328 ELM logic per GRY | S365500 | 0 | S314100 | S314100 | S365500 | CA | Not Started | C | Feder, Russ | L4 | BNL | Installation | Russ Feder | BNL | null | POM02.2.05.10 | C | 2.05 | 16727 | 004 | 2.05 | 10 |  |  |  |  |  |  |  |  |  |  |  |  |  |  |  |  |  |  |  |  |  |  |  |  |  |
| S365600 |  | Install MVTX Support - M&S |  | 3d | 2022-08-12 | 2022-08-16 | S365500 SS |  |  |  |  | 1d | 0d |  |  | Material (Purchase (1st $2M) [500 h] | 591.95 | 190328 ELM logic per GRY | S365600 | 0 | S314200 | S314200 | S365600 | CA | Not Started | C | Feder, Russ | M4 | BNL | Fab & Assy | Russ Feder | BNL | null | POM02.2.05.10 | C | 2.05 | 16727 | 004 | 2.05 | 10 |  | UDF_G2 | UDF_G1 | 591.948995 | 1 |  |  |  |  |  |  |  |  |  |  |  |  |  |  |  |  |  |  |  |  |
| S365700 |  | Install FELIX |  | 2d | 2022-08-17 | 2022-08-18 | S365500 SS, S365600 |  |  |  |  | 1d | 0d |  |  | PROF3 IO E [16 h] | 2,147.42 | 190328 ELM logic per GRY; 190326 ELM rsrc | S365700 | 0 |  | S314210 | S365700 | CA | Not Started | C | Feder, Russ | L4 |  | Installation | Russ Feder |  |  | POM02.2.05.10 | C | 2.05 | 16727 | 003,004 | 2.05 | 10 |  |  |  |  |  |  |  | .35 | .35 | .35 | 177 | 1744 |  | 2409.6 | 3252.96 | 3545.7264 | 0.09 |  |  |  |  |  |  |  |  |
| S365800 |  | Install FELIX |  | 2d | 2022-08-17 | 2022-08-18 | S365500 SS, S365600 |  |  |  |  | 1d | 0d |  |  | SCI3 LANL [16 h] |  | 190328 ELM logic per GRY | S365800 | 0 |  | S314215 | S365800 | CA | Not Started | T | Feder, Russ | L4 |  | Installation | Russ Feder |  |  | POM02.2.05.10 | K | 2.05 | NA | 004 | 2.05 | 10 |  |  |  |  |  |  |  | .35 | .35 | .35 | 177 | 1744 |  | 2409.6 | 3252.96 | 3545.7264 | 0.09 |  |  |  |  |  |  |  |  |
| S365900 |  | Install Optical fibers |  | 2d | 2022-08-17 | 2022-08-18 | S365700 SS, S365800 SS |  |  |  |  | 1d | 0d |  |  | TECH3 PO E [40 h] | 4,842.89 | 190328 ELM logic per GRY | S365900 | 0 |  | S314220 | S365900 | CA | Not Started | C | Feder, Russ | L4 |  | Installation | Russ Feder |  |  | POM02.2.05.10 | C | 2.05 | 16727 | 004 | 2.05 | 10 |  |  |  |  |  |  |  | .35 | .35 | .35 | 178 | 1743 |  | 6960 | 9396 | 10241.64 | 0.09 |  |  |  |  |  |  |  |  |
| S366000 |  | Install RU |  | 2d | 2022-08-17 | 2022-08-18 | S365900 SS |  |  |  |  | 1d | 0d |  |  | PROF3 IO E [40 h] | 5,368.56 | 190328 ELM logic per GRY; 190326 ELM rsrc | S366000 | 0 |  | S314230 | S366000 | CA | Not Started | C | Feder, Russ | L4 |  | Installation | Russ Feder |  |  | POM02.2.05.10 | C | 2.05 | 16727 | 003,004 | 2.05 | 10 |  |  |  |  |  |  |  | .35 | .35 | .35 | 179 | 1742 |  | 6024 | 8132.4 | 8864.316 | 0.09 |  |  |  |  |  |  |  |  |
| S366100 |  | Install RU |  | 2d | 2022-08-17 | 2022-08-18 | S365900 SS |  |  |  |  | 1d | 0d |  |  | SCI3 LANL [40 h] |  | 190328 ELM logic per GRY | S366100 | 0 |  | S314235 | S366100 | CA | Not Started | T | Feder, Russ | L4 |  | Installation | Russ Feder |  |  | POM02.2.05.10 | K | 2.05 | NA | 004 | 2.05 | 10 |  |  |  |  |  |  |  | .35 | .35 | .35 | 179 | 1742 |  | 6024 | 8132.4 | 8864.316 | 0.09 |  |  |  |  |  |  |  |  |
| S366200 |  | Install Samtec Cables |  | 2d | 2022-08-17 | 2022-08-18 | S366000 SS, S366100 SS |  |  |  |  | 1d | 0d |  |  | TECH3 PO E [40 h] | 4,842.89 | 190328 ELM logic per GRY | S366200 | 0 |  | S314240 | S366200 | CA | Not Started | C | Feder, Russ | L4 |  | Installation | Russ Feder |  |  | POM02.2.05.10 | C | 2.05 | 16727 | 004 | 2.05 | 10 |  |  |  |  |  |  |  | .35 | .35 | .35 | 180 | 1741 |  | 6960 | 9396 | 10241.64 | 0.09 |  |  |  |  |  |  |  |  |
| S366300 |  | Install Half-Barrel 1 |  | 6d | 2022-08-19 | 2022-08-26 | S366200 |  |  |  |  | 1d | 0d |  |  | PROF3 PO M [80 h]; TECH3 PO M [80 h] | 20,422.89 | 190328 ELM dur per GRY | S366300 | 0 |  | S314250 | S366300 | CA | Not Started | C | Feder, Russ | L4 |  | Installation | Russ Feder |  |  | POM02.2.05.10 | C | 2.05 | 16727 | 016 | 2.05 | 10 |  |  |  |  |  |  |  | .35 | .35 | .35 | 181 | 1740 |  | 23600 | 31860 | 34727.4 | 0.09 |  | P6 Migration: pred 15 in .mpp will be changed to ? |  |  |  |  |  |  |
| S366400 |  | Install Half-Barrel 1 |  | 6d | 2022-08-19 | 2022-08-26 | S366200 |  |  |  |  | 1d | 0d |  |  | STAFFPHYS LBNL [30 h]; POSTD LBNL [30 h] |  | 190328 ELM dur per GRY | S366400 | 0 |  | S314255 | S366400 | CA | Not Started | T | Feder, Russ | L4 |  | Installation | Russ Feder |  |  | POM02.2.05.10 | K | 2.05 | NA | 016 | 2.05 | 10 |  |  |  |  |  |  |  | .35 | .35 | .35 | 181 | 1740 |  | 23600 | 31860 | 34727.4 | 0.09 |  | P6 Migration: pred 15 in .mpp will be changed to ? |  |  |  |  |  |  |
| S366500 |  | Install Half-Barrel 2 |  | 5d | 2022-08-29 | 2022-09-02 | S366200, S366300 |  |  |  |  | 1d | 0d |  |  | TECH3 PO M [80 h]; PROF3 PO M [80 h] | 20,422.89 | 190328 ELM dur per GRY | S366500 | 0 |  | S314260 | S366500 | CA | Not Started | C | Feder, Russ | L4 |  | Installation | Russ Feder |  |  | POM02.2.05.10 | C | 2.05 | 16727 | 004 | 2.05 | 10 |  |  |  |  |  |  |  | .35 | .35 | .35 | 182 | 1804 |  | 23600 | 31860 | 34727.4 | 0.09 |  |  |  |  |  |  |  |  |
| S366600 |  | Install Half-Barrel 2 |  | 5d | 2022-08-29 | 2022-09-02 | S366200, S366400 |  |  |  |  | 1d | 0d |  |  | STAFFPHYS LBNL [30 h]; POSTD LBNL [30 h] |  | 190328 ELM dur per GRY | S366600 | 0 |  | S314265 | S366600 | CA | Not Started | T | Feder, Russ | L4 |  | Installation | Russ Feder |  |  | POM02.2.05.10 | K | 2.05 | NA | 004 | 2.05 | 10 |  |  |  |  |  |  |  | .35 | .35 | .35 | 182 | 1804 |  | 23600 | 31860 | 34727.4 | 0.09 |  |  |  |  |  |  |  |  |
| S366700 |  | Align/Survey MVTX to SC Magnet Centerline - Labor - Physics Resource(s) |  | 2d | 2022-09-06 | 2022-09-07 | S366500, S366600 |  |  |  |  | 1d | 0d |  |  | TECH3 PO M [20 h] | 2,421.44 |  | PO&AD | 0 | S314500 | S314500 | S366700 | CA | Not Started | C | Feder, Russ | L4 | BNL | Installation | Russ Feder | BNL | null | POM02.2.05.10 | C | 2.05 | 16727 | 008C | 2.05 | 10 |  |  |  |  |  |  |  |  |  |  |  |  |  |  |  |  |  |  |  | PO |  |  |  |  |  |
| S366710 |  | Align/Survey MVTX to SC Magnet Centerline - Labor - CA-D Resource(s) |  | 2d | 2022-09-06 | 2022-09-07 | S366700 SS |  |  |  |  | 1d | 0d |  |  | CRAFT3 [80 h]; TECH3 AD [60 h] | 17,879.38 |  | PO&ADS366710 | 0 | S314500 | S314500 | S366710 | CA | Not Started | C | Feder, Russ | L4 | BNL | Installation | Russ Feder | BNL | null | POM02.2.05.10 | C | 2.05 | 16728 | 008C | 2.05 | 10 |  |  |  |  |  |  |  |  |  |  |  |  |  |  |  |  |  |  |  | C-AD | S366710 |  |  |  |  |
| S366800 |  | Align/Survey MVTX to SC Magnet Centerline - M&S |  | 2d | 2022-09-06 | 2022-09-07 | S366700 SS, S366710 SS |  |  |  |  | 1d | 0d |  |  | Material (Purchase (1st $2M) [500 h] | 591.95 |  | S366800 | 0 | S314600 | S314600 | S366800 | CA | Not Started | C | Feder, Russ | M4 | BNL | Fab & Assy | Russ Feder | BNL | null | POM02.2.05.10 | C | 2.05 | 16727 | 008C | 2.05 | 10 |  | UDF_G2 | UDF_G1 | 591.948995 | 1 |  |  |  |  |  |  |  |  |  |  |  |  |  |  |  |  |  |  |  |  |
| S366900 |  | Install MVTX Remaining Cables and Services - Labor |  | 3d | 2022-09-08 | 2022-09-12 | S366700, S366800, S366710 |  |  |  |  | 1d | 0d |  |  | TECH3 PO M [80 h]; PROF4 PO E [24 h]; TECH3 PO E [80 h]; TECH3 PO D [24 h]; PROF4 PO M [24 h]; CRAFT3 [160 h] | 51,006.59 | 190328 ELM dur per GRY | S366900 | 0 | S314700 | S314700 | S366900 | CA | Not Started | C | Feder, Russ | L4 | BNL | Installation | Russ Feder | BNL | null | POM02.2.05.10 | C | 2.05 | 16727 | 008C | 2.05 | 10 |  |  |  |  |  |  |  |  |  |  |  |  |  |  |  |  |  |  |  |  |  |  |  |  |  |
| S367000 |  | Install MVTX Remaining Cables and Services - M&S |  | 3d | 2022-09-08 | 2022-09-12 | S366900 SS |  |  |  |  | 6d | 0d |  |  | Material (Purchase (1st $2M) [500 h] | 591.95 | 190328 ELM dur per GRY | S367000 | 0 | S314800 | S314800 | S367000 | CA | Not Started | C | Feder, Russ | M4 | BNL | Fab & Assy | Russ Feder | BNL | null | POM02.2.05.10 | C | 2.05 | 16727 | 008C | 2.05 | 10 |  | UDF_G2 | UDF_G1 | 591.948995 | 1 |  |  |  |  |  |  |  |  |  |  |  |  |  |  |  |  |  |  |  |  |
| S367100 |  | MVTX - Operational Readiness Review (ORR) |  | 5d | 2022-09-13 | 2022-09-19 | S366900, S367000 |  |  |  |  | 6d | 0d |  |  | PROF4 PO M [8 h]; TECH3 PO D [8 h]; TECH3 PO M [8 h]; TECH3 PO E [8 h] | 4,155.6 | 190416 ELM name per GRY | S367100 | 0 | S314900 | S314900 | S367100 | CA | Not Started | C | Feder, Russ | L4 | BNL | Installation | Russ Feder | BNL | null | POM02.2.05.10 | C | 2.05 | 16727 | 008C | 2.05 | 10 |  |  |  |  |  |  |  |  |  |  |  |  |  |  |  |  |  |  |  |  |  |  |  |  |  |
| S367200 |  | MVTX - Operational Readiness Review (ORR) |  | 5d | 2022-09-13 | 2022-09-19 | S366900, S367000 |  |  |  |  | 6d | 0d |  |  | SCI3 LANL [16 h]; STAFFPHYS LBNL [16 h] |  | 190416 ELM name per GRY | S367200 | 0 | S314900 | S314950 | S367200 | CA | Not Started | T | Feder, Russ | L4 | BNL | Installation | Russ Feder | BNL | null | POM02.2.05.10 | K | 2.05 | NA | 008C | 2.05 | 10 |  |  |  |  |  |  |  |  |  |  |  |  |  |  |  |  |  |  |  |  |  |  |  |  |  |
| S367300 |  | Address Action Items from MVTX ORR |  | 5d | 2022-09-20 | 2022-09-26 | S367100, S367200 |  |  |  |  | 6d | 0d |  |  | PROF4 PO M [8 h]; TECH3 PO D [8 h]; TECH3 PO M [8 h]; TECH3 PO E [8 h] | 4,155.6 |  | S367300 | 0 | S315000 | S315000 | S367300 | CA | Not Started | C | Feder, Russ | L4 | BNL | Installation | Russ Feder | BNL | null | POM02.2.05.10 | C | 2.05 | 16727 |  | 2.05 | 10 |  |  |  |  |  |  |  |  |  |  |  |  |  |  |  |  |  |  |  |  |  |  |  |  |  |
| S367400 |  | Address Action Items from MVTX ORR |  | 5d | 2022-09-20 | 2022-09-26 | S367100, S367200 |  |  |  |  | 6d | 0d |  |  | SCI3 LANL [16 h]; STAFFPHYS LBNL [16 h] |  |  | S367400 | 0 | S315000 | S315010 | S367400 | CA | Not Started | T | Feder, Russ | L4 | BNL | Installation | Russ Feder | BNL | null | POM02.2.05.10 | K | 2.05 | NA |  | 2.05 | 10 |  |  |  |  |  |  |  |  |  |  |  |  |  |  |  |  |  |  |  |  |  |  |  |  |  |
| S367500 |  | Commission MVTX - Labor |  | 5d | 2022-09-27 | 2022-10-03 | S367300, S367400 |  |  |  |  | 6d | 0d |  |  | POSTD LBNL [480 h]; STAFFPHYS LBNL [480 h]; SCI3 LANL [480 h] |  | 190328 ELM dur per GRY | S367500 | 0 | S315100 | S315100 | S367500 | CA | Not Started | T | Feder, Russ | L4 | BNL | Commissioning | Russ Feder | BNL | null | POM02.2.05.10 | K | 2.05 | NA | 004 | 2.05 | 10 |  |  |  |  |  |  |  |  |  |  |  |  |  |  |  |  |  |  |  |  |  | 180416 ELM dur per GRY |  |  |  |
| S367600 |  | Commission MVTX - M&S |  | 5d | 2022-09-27 | 2022-10-03 | S367500 SS |  |  |  |  | 6d | 0d |  |  | Material (Purchase (1st $2M) [500 h] | 594.32 | 190328 ELM dur per GRY | S367600 | 0 | S315200 | S315200 | S367600 | CA | Not Started | C | Feder, Russ | M4 | BNL | Commissioning | Russ Feder | BNL | null | POM02.2.05.10 | C | 2.05 | 16727 | 004 | 2.05 | 10 |  | UDF_G2 | UDF_G1 | 596.684551 | 1 |  |  |  |  |  |  |  |  |  |  |  |  |  |  |  |  | 180416 ELM dur per GRY |  |  |  |
| S367610 |  | Completed - Install MVTX | milestone | 0d | 2022-10-03 | 2022-10-03 | S367500 FF, S367600 FF |  |  |  |  | 6d |  |  |  |  |  |  | S367600 | 0 | S315200 | S315200 |  | NOCA | Not Started | C | Feder, Russ |  | BNL | Commissioning | Russ Feder | BNL |  | POM02.2.05.10 |  |  |  |  |  | 10 |  |  |  |  |  |  | L3 |  |  |  |  |  |  |  |  |  |  |  |  |  |  | 180416 ELM dur per GRY | 2022-11-30 | 37 | PMP_2x |

Notes:
- S364300: BNL_UDF_Old Activity Name 181221: Design MVTX Integration/Installation Tooling/Fixtures
- S364600: BNL_UDF_Old Activity Name 181221: Prepare MVTX Integration/Installation Tooling/Fixtures Procedures
- S364400: BNL_UDF_Old Activity Name 181221: Fabricate/Procure MVTX Integration/Installation Tooling/Fixtures - Labor
- S364500: BNL_UDF_Old Activity Name 181221: Fabricate/Procure MVTX Integration/Installation Tooling/Fixtures - M&S
- S364700: BNL_UDF_Old Activity Name 181221: Review MVTX Integration/Installation Tooling/Fixtures/Procedures Safety/Certification
- S364800: BNL_UDF_Old Activity Name 181221: Address Action Items from MVTX Integration/Installation Tooling/Fixtures/Procedures Design & Safety Reviews
- S364900: BNL_UDF_Old Activity Name 181221: Design/Safety Reviews Complete, MVTX Integration/Installation Tooling/Fixtures/Procedures Ready for Service
- EXT101400: BNL_UDF_Old Activity Name 181221: MVTX Complete
- S365000: BNL_UDF_Old Activity Name 181221: MVTX Ready for Installation
- S365100: BNL_UDF_Old Activity Name 181221: Installation Prep
- S365200: BNL_UDF_Old Activity Name 181221: Installation Review
- S365300: BNL_UDF_Old Activity Name 181221: Transport Assembled MVTX Sections to IR - Labor
- S365400: BNL_UDF_Old Activity Name 181221: Transport Assembled MVTX Sections to IR - M&S
- S365500: BNL_UDF_Old Activity Name 181221: Install MVTX Support - Labor
- S365600: BNL_UDF_Old Activity Name 181221: Install MVTX Support - M&S
- S365700: BNL_UDF_Old Activity Name 181221: Install FELIX - Fund Category C
- S365800: BNL_UDF_Old Activity Name 181221: Install FELIX - Fund Category T
- S365900: BNL_UDF_Old Activity Name 181221: Install Optical fibers
- S366000: BNL_UDF_Old Activity Name 181221: Install RU - Fund Category C
- S366100: BNL_UDF_Old Activity Name 181221: Install RU - Fund Category T
- S366200: BNL_UDF_Old Activity Name 181221: Install Samtec Cables
- S366300: BNL_UDF_Old Activity Name 181221: Install Half-Barrel 1 - Fund Category C
- S366400: BNL_UDF_Old Activity Name 181221: Install Half-Barrel 1 - Fund Category T
- S366500: BNL_UDF_Old Activity Name 181221: Install Half-Barrel 2 - Fund Category C
- S366600: BNL_UDF_Old Activity Name 181221: Install Half-Barrel 2 - Fund Category T
- S366700: BNL_UDF_Old Activity Name 181221: Align/Survey MVTX to SC Magnet Centerline - Labor
- S366710: BNL_UDF_Old Activity Name 181221: Align/Survey MVTX to SC Magnet Centerline - Labor
- S366800: BNL_UDF_Old Activity Name 181221: Align/Survey MVTX to SC Magnet Centerline - M&S
- S366900: BNL_UDF_Old Activity Name 181221: Install MVTX Remaining Cables and Services - Labor
- S367000: BNL_UDF_Old Activity Name 181221: Install MVTX Remaining Cables and Services - M&S
- S367100: BNL_UDF_Old Activity Name 181221: Review MVTX for Operational Readiness (ORR) - Fund Category C
- S367200: BNL_UDF_Old Activity Name 181221: Review MVTX for Operational Readiness (ORR) - Fund Category T
- S367300: BNL_UDF_Old Activity Name 181221: Address Action Items from MVTX ORR - Fund Category C
- S367400: BNL_UDF_Old Activity Name 181221: Address Action Items from MVTX ORR - Fund Category T
- S367500: BNL_UDF_Old Activity Name 181221: Commission MVTX - Labor
- S367600: BNL_UDF_Old Activity Name 181221: Commission MVTX - M&S
- S367610: BNL_UDF_Old Activity Name 181221: Commission MVTX - M&S

| ID | WBS | Activity | Type | Duration | Start | Finish | Predecessors | Complete | Remaining | Planned start | Planned finish | Total float | Free float | Expected finish | Resources | Cost | BNL_UDF_Status Comments | BNL_UDF_Temp Text 01 | BNL_UDF_Percent Complete | BNL_UDF_OPC TEC (deprecated) | BNL_UDF_Old Activity ID 181221 | BNL_Cobra WP | RG Check | BNL_Activity Status | BNL_Fund Source | BNL_Estimator | BNL_Cost Basis | BNL_Location | BNL_EDIA | BNL_CAM | BNL_Institution | BNL_OPC TEC (deprecated) | BNL_WBS | BNL_EVT | BNL_Master Control Account | BNL_Account Number | BNL_PCR ID | BNL_Cobra Control Account | BNL_WBS_Hierarchical | Indicator - Procurement | Indicator - Float | BNL_UDF_Remaining Tot Cost | BNL_UDF_Percent_remaining | BNL_Milestone Level | Target Milestone Date | Variance | PMP Milestones | Temp | BNL_UDF_Temp Text 02 | BNL_UDF_Adhoc Comments |
| --- | --- | --- | --- | --- | --- | --- | --- | --- | --- | --- | --- | --- | --- | --- | --- | --- | --- | --- | --- | --- | --- | --- | --- | --- | --- | --- | --- | --- | --- | --- | --- | --- | --- | --- | --- | --- | --- | --- | --- | --- | --- | --- | --- | --- | --- | --- | --- | --- | --- | --- |
|  | 11 | **Min Bias Installation** |  |  | 2020-05-13 | 2022-10-04 |  |  |  |  |  |  |  |  |  |  |  |  |  |  |  |  |  |  |  |  |  |  |  |  |  |  |  |  |  |  |  |  |  |  |  |  |  |  |  |  |  |  |  |  |
| S367700 |  | Design Min Bias Integration/Installation Tooling/Fixtures |  | 60d | 2020-05-13 A | 2021-06-30 | S100090 SS, S101015 SS | 75% | 22d | 2020-10-01 | 2020-12-30 | 185d | 0d | 2021-06-30 | PROF4 PO M [16 h]; TECH3 PO D [30 h] | 5,953.3 | 190318 ELM logic, name per GRY | S367700 | 0 | S315300 | S315300 | S367700 | CA | Not Started | C | Feder, Russ | L4 | BNL | Installation | Russ Feder | BNL | null | POM02.2.05.11 | C | 2.05 | 16727 | 003 | 2.05 | 11 |  |  |  |  |  |  |  |  |  |  |  |
| S368000 |  | Prepare Min Bias Integration/Installation Tooling/Fixtures Procedures |  | 10d | 2021-04-29 A | 2021-10-13 | S367800, S367900 | 20% | 12d | 2021-08-27 | 2021-09-10 | 185d | 0d | 2021-09-10 | PROF4 PO M [40 h]; TECH3 PO D [20 h] | 8,418.23 |  | S368000 | 0 | S315600 | S315600 | S368000 | CA | Not Started | C | Feder, Russ | L4 | BNL | Installation | Russ Feder | BNL | null | POM02.2.05.11 | C | 2.05 | 16727 |  | 2.05 | 11 |  |  |  |  |  |  |  |  |  |  |  |
| S367800 |  | Fabricate/Procure Min Bias Integration/Installation Tooling/Fixtures - Labor |  | 60d | 2021-07-01 | 2021-09-24 | S367700, S101000 |  |  |  |  | 185d | 0d |  | PROF4 PO M [30 h]; TECH3 PO D [10 h]; TECH3 PO M [10 h] | 6,901.4 |  | S367800 | 0 | S315400 | S315400 | S367800 | CA | Not Started | C | Feder, Russ | L4 | BNL | Fab & Assy | Russ Feder | BNL | null | POM02.2.05.11 | C | 2.05 | 16727 |  | 2.05 | 11 |  |  |  |  |  |  |  |  |  |  |  |
| S367900 |  | Fabricate/Procure Min Bias Integration/Installation Tooling/Fixtures - M&S |  | 60d | 2021-07-01 | 2021-09-24 | S367800 SS |  |  |  |  | 185d | 0d |  | Material (Purchase (1st $2M) [10000 h] | 11,606.84 |  | S367900 | 0 | S315500 | S315500 | S367900 | CA | Not Started | C | Feder, Russ | M5 | BNL | Fab & Assy | Russ Feder | BNL | null | POM02.2.05.11 | C | 2.05 | 16727 |  | 2.05 | 11 | UDF_G1 | UDF_G3 | 11606.8431 | 1 |  |  |  |  |  |  |  |
| S368100 |  | Review Min Bias Integration/Installation Tooling/Fixtures/Procedures Safety/Certification |  | 10d | 2021-10-14 | 2021-10-27 | S368000 |  |  |  |  | 185d | 0d |  | PROF4 PO M [8 h]; TECH3 PO D [8 h]; TECH3 PO M [8 h] | 3,187.02 |  | S368100 | 0 | S315700 | S315700 | S368100 | CA | Not Started | C | Feder, Russ | L4 | BNL | Installation | Russ Feder | BNL | null | POM02.2.05.11 | C | 2.05 | 16727 |  | 2.05 | 11 |  |  |  |  |  |  |  |  |  |  |  |
| S368200 |  | Address Action Items from Min Bias Integration/Installation Tooling/Fixtures/Procedures Design & Safety Reviews |  | 10d | 2021-10-28 | 2021-11-10 | S368100 |  |  |  |  | 185d | 0d |  | PROF4 PO M [8 h]; TECH3 PO D [8 h]; TECH3 PO M [8 h] | 3,187.02 |  | S368200 | 0 | S315800 | S315800 | S368200 | CA | Not Started | C | Feder, Russ | L4 | BNL | Installation | Russ Feder | BNL | null | POM02.2.05.11 | C | 2.05 | 16727 |  | 2.05 | 11 |  |  |  |  |  |  |  |  |  |  |  |
| S368300 |  | Design/Safety Reviews Complete, Min Bias Integration/Installation Tooling/Fixtures/Procedures Ready for Service | milestone | 0d | 2021-11-10 | 2021-11-10 | S368200 FF |  |  |  |  | 185d | 26d |  |  |  |  | S368300 | 0 | S315900 | S315900 |  | NOCA | Not Started | C | Feder, Russ | L4 | BNL | Management Safety Reviews | Russ Feder | BNL |  | POM02.2.05.11 |  |  |  |  |  | 11 |  |  |  |  | L3 |  |  |  |  |  |  |
| S368400 |  | Min Bias Ready for Installation | milestone | 0d | 2021-12-21 | 2021-12-21 | S368300 FF, S274100 FF, S318170 |  |  |  |  | 159d |  |  |  |  |  | S368400 | 0 | S316000 | S316000 |  | NOCA | Not Started | C | Feder, Russ | L4 | BNL | Installation | Russ Feder | BNL |  | POM02.2.05.11 |  |  |  |  |  | 11 |  |  |  |  | L3 |  |  |  |  |  |  |
| S368500 |  | Transport Assembled Min Bias Sections to AH - Labor |  | 1d | 2022-08-10 | 2022-08-10 | S368400, S346410 |  |  |  |  | 0d |  |  | PROF4 PO M [8 h]; TECH3 PO M [8 h] | 2,218.45 | 190211 ELM pred dur per GRY | S368500 | 0 | S316100 | S316100 | S368500 | CA | Not Started | C | Feder, Russ | L4 | BNL | Fab & Assy | Russ Feder | BNL | null | POM02.2.05.11 | C | 2.05 | 16727 | 003 | 2.05 | 11 |  |  |  |  |  |  |  |  |  |  |  |
| S368600 |  | Transport Assembled Min Bias Sections to AH - M&S |  | 1d | 2022-08-10 | 2022-08-10 | S368500 SS |  |  |  |  | 0d |  |  | Material (Purchase (1st $2M) [500 h] | 591.95 | 190211 ELM dur per GRY | S368600 | 0 | S316200 | S316200 | S368600 | CA | Not Started | C | Feder, Russ | M4 | BNL | Fab & Assy | Russ Feder | BNL | null | POM02.2.05.11 | C | 2.05 | 16727 | 003 | 2.05 | 11 | UDF_G2 | UDF_G1 | 591.948995 | 1 |  |  |  |  |  |  |  |
| S368700 |  | Install Min Bias Support - Labor |  | 8d | 2022-08-11 | 2022-08-22 | S368500, S368600 |  |  |  |  | 0d |  |  | PROF4 PO M [8 h]; TECH3 PO D [8 h]; TECH3 PO M [16 h] | 4,155.6 | 190211 ELM dur per GRY | S368700 | 0 | S316300 | S316300 | S368700 | CA | Not Started | C | Feder, Russ | L4 | BNL | Installation | Russ Feder | BNL | null | POM02.2.05.11 | C | 2.05 | 16727 | 016 | 2.05 | 11 |  |  |  |  |  |  |  |  |  |  |  |
| S368800 |  | Install Min Bias Support - M&S |  | 8d | 2022-08-11 | 2022-08-22 | S368700 SS |  |  |  |  | 0d |  |  | Material (Purchase (1st $2M) [500 h] | 591.95 | 190211 ELM dur per GRY | S368800 | 0 | S316400 | S316400 | S368800 | CA | Not Started | C | Feder, Russ | M4 | BNL | Installation | Russ Feder | BNL | null | POM02.2.05.11 | C | 2.05 | 16727 | 016 | 2.05 | 11 | UDF_G2 | UDF_G1 | 591.948995 | 1 |  |  |  |  |  |  |  |
| S368900 |  | Install Min Bias (mechanical) - Labor |  | 5d | 2022-08-23 | 2022-08-29 | S368700, S368800 |  |  |  |  | 0d |  |  | PROF4 PO M [8 h]; TECH3 PO D [8 h]; TECH3 PO M [16 h] | 4,155.6 | 190211 ELM dur per GRY | S368900 | 0 | S316500 | S316500 | S368900 | CA | Not Started | C | Feder, Russ | L4 | BNL | Installation | Russ Feder | BNL | null | POM02.2.05.11 | C | 2.05 | 16727 | 003 | 2.05 | 11 |  |  |  |  |  |  |  |  |  |  |  |
| S369000 |  | Install Min Bias (mechanical) - M&S |  | 5d | 2022-08-23 | 2022-08-29 | S368900 SS |  |  |  |  | 0d |  |  | Material (Purchase (1st $2M) [500 h] | 591.95 | 190211 ELM dur per GRY | S369000 | 0 | S316600 | S316600 | S369000 | CA | Not Started | C | Feder, Russ | M4 | BNL | Installation | Russ Feder | BNL | null | POM02.2.05.11 | C | 2.05 | 16727 | 003 | 2.05 | 11 | UDF_G2 | UDF_G1 | 591.948995 | 1 |  |  |  |  |  |  |  |
| S369010 |  | Completed - Install Min Bias | milestone | 0d | 2022-08-29 | 2022-08-29 | S368900 FF, S369000 FF |  |  |  |  | 0d |  |  |  |  |  | S369000 | 0 | S316600 | S316600 |  | NOCA | Not Started | C | Feder, Russ |  | BNL | Installation | Russ Feder | BNL |  | POM02.2.05.11 |  |  |  |  |  | 11 |  |  |  |  | L5 | 2022-10-31 | 42 | PMP_2x |  |  |  |
| S369100 |  | Align/Survey Min Bias to SC Magnet Centerline - Labor - Physics Resource(s) |  | 5d | 2022-08-30 | 2022-09-06 | S369010 |  |  |  |  | 0d |  |  | TECH3 PO M [8 h] | 968.58 |  | PO&AD | 0 | S316700 | S316700 | S369100 | CA | Not Started | C | Feder, Russ | L4 | BNL | Installation | Russ Feder | BNL | null | POM02.2.05.11 | C | 2.05 | 16727 |  | 2.05 | 11 |  |  |  |  |  |  |  |  | PO |  |  |
| S369110 |  | Align/Survey Min Bias to SC Magnet Centerline - Labor - CA-D Resource(s) |  | 5d | 2022-08-30 | 2022-09-06 | S369100 SS |  |  |  |  | 0d |  |  | CRAFT3 [20 h]; TECH3 AD [24 h]; TECH4 AD [24 h] | 8,884.65 |  | PO&ADS369110 | 0 | S316700 | S316700 | S369110 | CA | Not Started | C | Feder, Russ | L4 | BNL | Installation | Russ Feder | BNL | null | POM02.2.05.11 | C | 2.05 | 16728 |  | 2.05 | 11 |  |  |  |  |  |  |  |  | C-AD | S369110 |  |
| S369200 |  | Align/Survey Min Bias to SC Magnet Centerline - M&S |  | 5d | 2022-08-30 | 2022-09-06 | S369100 SS, S369110 SS |  |  |  |  | 0d |  |  | Material (Purchase (1st $2M) [500 h] | 591.95 |  | S369200 | 0 | S316800 | S316800 | S369200 | CA | Not Started | C | Feder, Russ | M4 | BNL | Fab & Assy | Russ Feder | BNL | null | POM02.2.05.11 | C | 2.05 | 16727 |  | 2.05 | 11 | UDF_G2 | UDF_G1 | 591.948995 | 1 |  |  |  |  |  |  |  |
| S369300 |  | Install Min Bias Cables and Services - Labor |  | 5d | 2022-09-07 | 2022-09-13 | S369100, S369200, S369110 |  |  |  |  | 0d |  |  | TECH3 PO M [120 h]; PROF4 PO E [24 h]; TECH3 PO E [120 h]; TECH3 PO D [24 h]; PROF4 PO M [24 h]; CRAFT3 [240 h] | 71,307.42 |  | S369300 | 0 | S316900 | S316900 | S369300 | CA | Not Started | C | Feder, Russ | L4 | BNL | Installation | Russ Feder | BNL | null | POM02.2.05.11 | C | 2.05 | 16727 |  | 2.05 | 11 |  |  |  |  |  |  |  |  |  |  | 180416 ELM dur per GRY |
| S369400 |  | Install Min Bias Cables and Services - M&S |  | 5d | 2022-09-07 | 2022-09-13 | S369300 SS |  |  |  |  | 0d |  |  | Material (Purchase (1st $2M) [500 h] | 591.95 |  | S369400 | 0 | S317000 | S317000 | S369400 | CA | Not Started | C | Feder, Russ | M4 | BNL | Installation | Russ Feder | BNL | null | POM02.2.05.11 | C | 2.05 | 16727 |  | 2.05 | 11 | UDF_G2 | UDF_G1 | 591.948995 | 1 |  |  |  |  |  |  | 180416 ELM dur per GRY |
| S369500 |  | Min Bias - Operational Readiness Review (ORR) |  | 5d | 2022-09-14 | 2022-09-20 | S369300, S369400 |  |  |  |  | 5d | 0d |  | PROF4 PO M [8 h]; TECH3 PO D [8 h]; TECH3 PO M [8 h]; TECH3 PO E [8 h] | 4,155.6 | 190416 ELM name per GRY | S369500 | 0 | S317100 | S317100 | S369500 | CA | Not Started | C | Feder, Russ | L4 | BNL | Installation | Russ Feder | BNL | null | POM02.2.05.11 | C | 2.05 | 16727 | 004 | 2.05 | 11 |  |  |  |  |  |  |  |  |  |  |  |
| S369600 |  | Address Action Items from Min Bias ORR |  | 5d | 2022-09-21 | 2022-09-27 | S369500 |  |  |  |  | 5d | 0d |  | PROF4 PO M [8 h]; TECH3 PO D [8 h]; TECH3 PO M [8 h]; TECH3 PO E [8 h] | 4,155.6 | 190329 ELM dur per GRY | S369600 | 0 | S317200 | S317200 | S369600 | CA | Not Started | C | Feder, Russ | L4 | BNL | Installation | Russ Feder | BNL | null | POM02.2.05.11 | C | 2.05 | 16727 | 004 | 2.05 | 11 |  |  |  |  |  |  |  |  |  |  | 180416 ELM dur per GRY |
| S369700 |  | Commission Min Bias - Labor |  | 5d | 2022-09-28 | 2022-10-04 | S369600 |  |  |  |  | 5d | 0d |  | SCI3 PO [400 h]; TECH3 PO M [40 h]; PROF4 PO E [40 h]; TECH3 PO E [40 h]; PROF4 PO M [40 h]; TECH3 PO D [40 h] | 101,262.85 |  | S369700 | 0 | S317300 | S317300 | S369700 | CA | Not Started | C | Feder, Russ | L4 | BNL | Commissioning | Russ Feder | BNL | null | POM02.2.05.11 | C | 2.05 | 16727 |  | 2.05 | 11 |  |  |  |  |  |  |  |  |  |  | 180416 ELM dur per GRY |
| S369800 |  | Commission Min Bias - Labor |  | 5d | 2022-09-28 | 2022-10-04 | S369600 |  |  |  |  | 5d | 0d |  | STUDENT Other - Unpaid [1600 h] |  | 190313 ELM rsrc | S369800 | 0 | S317300 | S317350 | S369800 | CA | Not Started | T | Feder, Russ | L4 | BNL | Commissioning | Russ Feder | BNL | null | POM02.2.05.11 | K | 2.05 | NA | 003 | 2.05 | 11 |  |  |  |  |  |  |  |  |  |  | 180416 ELM dur per GRY |
| S369900 |  | Commission Min Bias - M&S |  | 5d | 2022-09-28 | 2022-10-04 | S369700 SS, S369800 SS |  |  |  |  | 5d |  |  | Material (Purchase (1st $2M) [500 h] | 596.68 |  | S369900 | 0 | S317400 | S317400 | S369900 | CA | Not Started | C | Feder, Russ | M4 | BNL | Commissioning | Russ Feder | BNL | null | POM02.2.05.11 | C | 2.05 | 16727 |  | 2.05 | 11 | UDF_G2 | UDF_G1 | 594.316773 | 1 |  |  |  |  |  |  | 180416 ELM dur per GRY |

Notes:
- S367700: BNL_UDF_Old Activity Name 181221: Design Min Bias Integration/Installation Tooling/Fixtures
- S368000: BNL_UDF_Old Activity Name 181221: Prepare Min Bias Integration/Installation Tooling/Fixtures Procedures
- S367800: BNL_UDF_Old Activity Name 181221: Fabricate/Procure Min Bias Integration/Installation Tooling/Fixtures - Labor
- S367900: BNL_UDF_Old Activity Name 181221: Fabricate/Procure Min Bias Integration/Installation Tooling/Fixtures - M&S
- S368100: BNL_UDF_Old Activity Name 181221: Review Min Bias Integration/Installation Tooling/Fixtures/Procedures Safety/Certification
- S368200: BNL_UDF_Old Activity Name 181221: Address Action Items from Min Bias Integration/Installation Tooling/Fixtures/Procedures Design & Safety Reviews
- S368300: BNL_UDF_Old Activity Name 181221: Design/Safety Reviews Complete, Min Bias Integration/Installation Tooling/Fixtures/Procedures Ready for Service
- S368400: BNL_UDF_Old Activity Name 181221: Min Bias Ready for Installation
- S368500: BNL_UDF_Old Activity Name 181221: Transport Assembled Min Bias Sections to AH - Labor
- S368600: BNL_UDF_Old Activity Name 181221: Transport Assembled Min Bias Sections to AH - M&S
- S368700: BNL_UDF_Old Activity Name 181221: Install Min Bias Support - Labor
- S368800: BNL_UDF_Old Activity Name 181221: Install Min Bias Support - M&S
- S368900: BNL_UDF_Old Activity Name 181221: Install Min Bias (mechanical) - Labor
- S369000: BNL_UDF_Old Activity Name 181221: Install Min Bias (mechanical) - M&S
- S369010: BNL_UDF_Old Activity Name 181221: Install Min Bias (mechanical) - M&S
- S369100: BNL_UDF_Old Activity Name 181221: Align/Survey Min Bias to SC Magnet Centerline - Labor
- S369110: BNL_UDF_Old Activity Name 181221: Align/Survey Min Bias to SC Magnet Centerline - Labor
- S369200: BNL_UDF_Old Activity Name 181221: Align/Survey Min Bias to SC Magnet Centerline - M&S
- S369300: BNL_UDF_Old Activity Name 181221: Install Min Bias Cables and Services - Labor
- S369400: BNL_UDF_Old Activity Name 181221: Install Min Bias Cables and Services - M&S
- S369500: BNL_UDF_Old Activity Name 181221: Review Min Bias for Operational Readiness (ORR)
- S369600: BNL_UDF_Old Activity Name 181221: Address Action Items from Min Bias ORR
- S369700: BNL_UDF_Old Activity Name 181221: Commission Min Bias - Labor - Fund Category C
- S369800: BNL_UDF_Old Activity Name 181221: Commission Min Bias - Labor - Fund Category T
- S369900: BNL_UDF_Old Activity Name 181221: Commission Min Bias - M&S

| ID | WBS | Activity | Type | Duration | Start | Finish | Predecessors | Total float | Free float | Constraint | Resources | Cost | BNL_UDF_Temp Text 01 | BNL_UDF_Percent Complete | BNL_UDF_OPC TEC (deprecated) | BNL_UDF_Old Activity ID 181221 | BNL_Cobra WP | RG Check | BNL_Activity Status | BNL_Fund Source | BNL_Estimator | BNL_Cost Basis | BNL_Location | BNL_EDIA | BNL_CAM | BNL_Institution | BNL_OPC TEC (deprecated) | BNL_WBS | BNL_EVT | BNL_Master Control Account | BNL_Account Number | BNL_Cobra Control Account | BNL_WBS_Hierarchical | Indicator - Procurement | Indicator - Float | BNL_UDF_Remaining Tot Cost | BNL_UDF_Percent_remaining | BNL_UDF_Sort Order | BNL_PCR ID | Temp | BNL_UDF_Temp Text 02 | BNL_Milestone Level | BNL_UDF_Status Comments | Target Milestone Date | Variance | PMP Milestones |
| --- | --- | --- | --- | --- | --- | --- | --- | --- | --- | --- | --- | --- | --- | --- | --- | --- | --- | --- | --- | --- | --- | --- | --- | --- | --- | --- | --- | --- | --- | --- | --- | --- | --- | --- | --- | --- | --- | --- | --- | --- | --- | --- | --- | --- | --- | --- |
|  | 12 | **Full System Integration and ORR** |  |  | 2022-03-22 | 2023-01-30 |  |  |  |  |  |  |  |  |  |  |  |  |  |  |  |  |  |  |  |  |  |  |  |  |  |  |  |  |  |  |  |  |  |  |  |  |  |  |  |  |
| S1003919 |  | Move Full sPHENIX to IR - Labor - Physics Resource(s) |  | 5d | 2022-03-22 | 2022-03-28 | S349610, S343846 | 29d | 0d |  | PROF4 PO M [8 h]; TECH3 PO E [24 h]; TECH3 PO M [96 h]; TECH3 PO D [8 h]; TECH3 AM [40 h] | 21,589.99 | S370000 | 0 | S317700 | S317700 | S1003919 | CA | Not Started | C | Feder, Russ | L4 | BNL | Installation | Russ Feder | BNL | null | POM02.2.05.12 | C | 2.05 | 16727 | 2.05 | 12 |  |  |  |  |  |  |  |  |  |  |  |  |  |
| S370000 |  | Move Full sPHENIX to IR - Labor - CA-D Resource(s) |  | 5d | 2022-03-22 | 2022-03-28 | S349610, S343846, S327150 | 0d |  |  | PROF2 AD [8 h]; PROF4 AD [8 h]; TECH4 AD [40 h] | 7,642.37 | S370000 | 0 | S317700 | S317700 | S370000 | CA | Not Started | C | Feder, Russ | L4 | BNL | Installation | Russ Feder | BNL | null | POM02.2.05.12 | C | 2.05 | 16727 | 2.05 | 12 |  |  |  |  |  |  |  |  |  |  |  |  |  |
| S370100 |  | Move Full sPHENIX to IR - M&S |  | 5d | 2022-03-22 | 2022-03-28 | S370000 SS, S1003919 SS | 29d | 0d |  | Material (Purchase (1st $2M) [1000 h] | 1,183.9 | S370100 | 0 | S317800 | S317800 | S370100 | CA | Not Started | C | Feder, Russ | M4 | BNL | Fab & Assy | Russ Feder | BNL | null | POM02.2.05.12 | C | 2.05 | 16727 | 2.05 | 12 | UDF_G3 | UDF_G1 | 1183.89799 | 1 |  |  |  |  |  |  |  |  |  |
| S370500 |  | Prepare for Review of Safety System Design by CAD ESRC |  | 20d | 2022-05-09 | 2022-06-06 |  | 9d | 0d |  | PROF4 PO M [40 h]; PROF4 PO E [40 h]; SCI3 PO [40 h]; SCI 4 PO [40 h] | 28,540.04 | S370600 | 0 | S318300 | S318300 | S370500 | CA | Not Started | C | Feder, Russ | L4 | BNL | Management Safety Reviews | Russ Feder | BNL | null | POM02.2.05.12 | C | 2.05 | 16727 | 2.05 | 12 |  |  |  |  | 1010 | 004 |  |  |  |  |  |  |  |
| S370510 |  | Review of Safety System Design by CAD ESRC |  | 3d | 2022-06-07 | 2022-06-09 | S370500, S370500 FF | 9d | 0d |  | PROF4 PO M [8 h]; PROF4 PO E [8 h]; SCI 4 PO [24 h]; SCI3 PO [24 h] | 12,124.55 | S370600 | 0 | S318300 | S318300 | S370510 | CA | Not Started | C | Feder, Russ | L4 | BNL | Management Safety Reviews | Russ Feder | BNL | null | POM02.2.05.12 | C | 2.05 | 16727 | 2.05 | 12 |  |  |  |  | 1010 | 004 |  |  |  |  |  |  |  |
| S370520 |  | Prepare Procedures (Blue Sheet, Pink Sheet) |  | 20d | 2022-06-10 | 2022-07-08 | S370510, S370510 FF | 9d | 0d |  | PROF4 PO M [40 h]; PROF4 PO E [40 h]; SCI3 PO [40 h]; SCI 4 PO [40 h]; PROF5 AD [20 h]; PROF6 AD [20 h]; PROF2 AD [20 h]; PROF4 AD [20 h] | 41,494.48 | S370600 | 0 | S318300 | S318300 | S370520 | CA | Not Started | C | Feder, Russ | L4 | BNL | Management Safety Reviews | Russ Feder | BNL | null | POM02.2.05.12 | C | 2.05 | 16727 | 2.05 | 12 |  |  |  |  | 1010 | 004 |  |  |  |  |  |  |  |
| S370530 |  | Review and approve procedures |  | 2d | 2022-07-11 | 2022-07-12 | S370520, S370520 FF | 9d | 0d |  | PROF4 PO M [16 h]; PROF4 PO E [16 h]; SCI3 PO [16 h]; SCI 4 PO [16 h]; PROF5 AD [16 h]; PROF6 AD [16 h] | 17,578.67 | S370600 | 0 | S318300 | S318300 | S370530 | CA | Not Started | C | Feder, Russ | L4 | BNL | Management Safety Reviews | Russ Feder | BNL | null | POM02.2.05.12 | C | 2.05 | 16727 | 2.05 | 12 |  |  |  |  | 1010 | 004 |  |  |  |  |  |  |  |
| S370540 |  | Magnet Checkout After Power Testing |  | 5d | 2022-07-13 | 2022-07-19 | S370530, S370530 FF | 9d | 0d |  | SCI3 AD [16 h]; PROF6 AD [16 h]; PROF5 AD [16 h] | 9,084.05 | S370600 | 0 | S318300 | S318300 | S370540 | CA | Not Started | C | Feder, Russ | L4 | BNL | Management Safety Reviews | Russ Feder | BNL | null | POM02.2.05.12 | C | 2.05 | 16727 | 2.05 | 12 |  |  |  |  | 1010 | 004 |  |  |  |  |  |  |  |
| S370550 |  | Preparation for Full Operation - In-Rack Safety System Check |  | 5d | 2022-07-20 | 2022-07-26 | S370540, S370540 FF | 9d | 0d |  | TECH3 PO E [24 h]; PROF4 PO E [24 h]; SCI 4 PO [24 h] | 11,898.07 | S370600 | 0 | S318300 | S318300 | S370550 | CA | Not Started | C | Feder, Russ | L4 | BNL | Management Safety Reviews | Russ Feder | BNL | null | POM02.2.05.12 | C | 2.05 | 16727 | 2.05 | 12 |  |  |  |  | 1010 | 004 |  |  |  |  |  |  |  |
| S370200 |  | Align Full sPHENIX to Nominal Beamline and IP - Labor - Physics Resource(s) |  | 5d | 2022-07-27 | 2022-08-02 | S370000, S370100, S314600, S314610, S314655, S1003919 | 29d | 0d |  | TECH3 PO M [16 h] | 1,937.15 | PO&AD | 0 | S317900 | S317900 | S370200 | CA | Not Started | C | Feder, Russ | L4 | BNL | Installation | Russ Feder | BNL | null | POM02.2.05.12 | C | 2.05 | 16727 | 2.05 | 12 |  |  |  |  |  |  | PO |  |  |  |  |  |  |
| S370210 |  | Align Full sPHENIX to Nominal Beamline and IP - Labor - CA-D Resource(s) |  | 5d | 2022-07-27 | 2022-08-02 | S370200 SS | 29d | 0d |  | CRAFT3 [40 h]; TECH3 AD [48 h]; PROF2 AD [8 h]; PROF4 AD [8 h]; TECH4 AD [48 h] | 19,869.74 | PO&ADS370210 | 0 | S317900 | S317900 | S370210 | CA | Not Started | C | Feder, Russ | L4 | BNL | Installation | Russ Feder | BNL | null | POM02.2.05.12 | C | 2.05 | 16728 | 2.05 | 12 |  |  |  |  |  |  | C-AD | S370210 |  |  |  |  |  |
| S370300 |  | Align Full sPHENIX to Nominal Beamline and IP - M&S |  | 5d | 2022-07-27 | 2022-08-02 | S370200 SS, S370210 SS | 29d |  |  | Material (Purchase (1st $2M) [1000 h] | 1,183.9 | S370300 | 0 | S318000 | S318000 | S370300 | CA | Not Started | C | Feder, Russ | M4 | BNL | Fab & Assy | Russ Feder | BNL | null | POM02.2.05.12 | C | 2.05 | 16727 | 2.05 | 12 | UDF_G1 | UDF_G1 | 1183.89799 | 1 |  |  |  |  |  |  |  |  |  |
| S370560 |  | Preparation for Full Operation - Magnet Re-check Cryo/PSU/QD/ODH Check |  | 10d | 2022-07-27 | 2022-08-09 | S370550, S370550 FF | 9d | 0d |  | SCI3 AD [16 h]; PROF5 AD [16 h]; PROF6 AD [16 h] | 9,084.05 | S370600 | 0 | S318300 | S318300 | S370560 | CA | Not Started | C | Feder, Russ | L4 | BNL | Management Safety Reviews | Russ Feder | BNL | null | POM02.2.05.12 | C | 2.05 | 16727 | 2.05 | 12 |  |  |  |  | 1010 | 004 |  |  |  |  |  |  |  |
| S370570 |  | Preparation for Full Operation - Verify Global Safety System |  | 5d | 2022-08-10 | 2022-08-16 | S370560, S370560 FF | 9d | 0d |  | PROF4 PO M [16 h]; TECH3 PO E [16 h]; TECH3 PO M [16 h]; PROF4 PO E [16 h]; SCI 4 PO [16 h] | 12,368.94 | S370600 | 0 | S318300 | S318300 | S370570 | CA | Not Started | C | Feder, Russ | L4 | BNL | Management Safety Reviews | Russ Feder | BNL | null | POM02.2.05.12 | C | 2.05 | 16727 | 2.05 | 12 |  |  |  |  | 1010 | 004 |  |  |  |  |  |  |  |
| S370580 |  | Preparation for Full Operation - Final Safety Walk Trough |  | 5d | 2022-08-17 | 2022-08-23 | S370570, S370570 FF | 9d | 0d |  | PROF4 PO M [16 h]; TECH3 PO E [16 h]; TECH3 PO M [16 h]; PROF4 PO E [16 h]; SCI 4 PO [16 h]; SCI3 PO [16 h]; SCI3 AD [8 h]; PROF4 AD [8 h]; PROF6 AD [8 h] | 20,888.73 | S370600 | 0 | S318300 | S318300 | S370580 | CA | Not Started | C | Feder, Russ | L4 | BNL | Management Safety Reviews | Russ Feder | BNL | null | POM02.2.05.12 | C | 2.05 | 16727 | 2.05 | 12 |  |  |  |  | 1010 | 004 |  |  |  |  |  |  |  |
| S370590 |  | Preparation for Full Operation - Approvals - CAD and Physics |  | 5d | 2022-08-24 | 2022-08-30 | S370580, S370580 FF | 9d |  |  | SCI 4 PO [16 h] | 3,495.16 | S370600 | 0 | S318300 | S318300 | S370590 | CA | Not Started | C | Feder, Russ | L4 | BNL | Management Safety Reviews | Russ Feder | BNL | null | POM02.2.05.12 | C | 2.05 | 16727 | 2.05 | 12 |  |  |  |  | 1010 | 004 |  |  |  |  |  |  |  |
| S370400 |  | sPHENIX Installation Complete Ready for ORR | milestone | 0d | 2022-09-13 | 2022-09-13 | S370200, S279000 FF, S370300, S347400 FF, S347600 FF, S345500 FF, S346700 FF, S345900 FF, S346800 FF, S347500 FF, S347800 FF, S345600 FF, S260800 FF, S361300 FF, S361400 FF, S369300 FF, S369400 FF, S363700 FF, S345700 FF, S347200 FF, S347700 FF, S265400 FF, S268200 FF, S270900 FF, S345800 FF, S346900 FF, S346200 FF, S346100 FF, S347000 FF, S366900 FF, S345910 FF, S346210 FF, S347310 FF, S347810 FF, S347300 FF, S346710 FF, S370210, S1002159 FF, S1003759 FF | 0d |  |  |  |  | S370400 | 0 | S318100 | S318100 |  | NOCA | Not Started | C | Feder, Russ |  | BNL | Installation | Russ Feder | BNL |  | POM02.2.05.12 |  |  |  |  | 12 |  |  |  |  |  |  |  |  | L3 |  |  |  |  |
| S370600 |  | Full sPHENIX Detector - Operational Readiness Review (ORR) |  | 5d | 2022-09-14 | 2022-09-20 | S279500, S370400, S370590 | 0d |  |  | PROF4 PO M [16 h]; TECH3 PO E [16 h]; TECH3 PO M [16 h]; TECH3 PO D [16 h]; PROF4 PO E [16 h]; PROF3 PO E [16 h]; PROF5 AD [16 h]; SCI 4 PO [16 h] | 19,340.23 | S370600 | 0 | S318300 | S318300 | S370600 | CA | Not Started | C | Feder, Russ | L4 | BNL | Installation | Russ Feder | BNL | null | POM02.2.05.12 | C | 2.05 | 16727 | 2.05 | 12 |  |  |  |  |  | 004 |  |  |  | 190416 ELM name per GRY |  |  |  |
| S370700 |  | Address Action Items from Full sPHENIX Detector ORR |  | 15d | 2022-09-21 | 2022-10-12 | S370600 | 0d |  |  | PROF4 PO M [16 h]; TECH3 PO E [16 h]; TECH3 PO M [16 h]; TECH3 PO D [16 h]; PROF4 PO E [16 h]; PROF3 PO M [16 h]; SCI 4 PO [16 h]; PROF5 AD [16 h] | 19,611 | S370700 | 0 | S318400 | S318400 | S370700 | CA | Not Started | C | Feder, Russ | L4 | BNL | Installation | Russ Feder | BNL | null | POM02.2.05.12 | C | 2.05 | 16727 | 2.05 | 12 |  |  |  |  |  |  |  |  |  |  |  |  |  |
| S370800 |  | sPHENIX Ready for Operations | milestone | 0d | 2022-10-12 | 2022-10-12 | S354200 FF, S352000 FF, S352200 FF, S359400 FF, S369700 FF, S369900 FF, S370700 FF, S274800 FF, S275400 FF, S275900 FF, S277100 FF, S277700 FF, S278300 FF, S370300, S352100 FF, S359300 FF, S369800 FF, S354210 FF, S359410 FF, S367610 FF, S364210 FF, S357210 FF, S357000 FF, S357100 FF, S357200 FF, S361700 FF, S361800 FF, S361900 FF | 0d |  |  |  |  | S370800 | 0 | S318500 | S318500 |  | NOCA | Not Started | C | Feder, Russ |  | BNL | Installation | Russ Feder | BNL |  | POM02.2.05.12 |  |  |  |  | 12 |  |  |  |  |  |  |  |  | L3 |  | 2022-11-30 | 31 | PMP_2x |
| S370850 |  | WBS 2X Schedule Contingency |  | 71d | 2022-10-13 | 2023-01-27 | S370800 | 0d |  |  |  |  | S370900 | 0 |  | S318540 |  | NOCA | Not Started | C | O'Brien, Ed |  |  | Management | Russ Feder |  |  | POM02.2.05.12 |  |  |  |  | 12 |  |  |  |  |  |  |  |  | L3 |  |  |  |  |
| S370900 |  | Start of RHIC Run 30-Jan-23 | milestone | 0d | 2023-01-30 | 2023-01-30 | S370850 | 0d |  | start on 2023-01-30 |  |  | S370900 | 0 |  | S318540 |  | NOCA | Not Started | C | O'Brien, Ed |  |  | Management | Russ Feder |  |  | POM02.2.05.12 |  |  |  |  | 12 |  |  |  |  |  |  |  |  | L3 |  |  |  |  |
| S999999 |  | Completed: sPHENIX MIE and Support Projects | milestone | 0d | 2023-01-30 | 2023-01-30 | S370900 SF, S101040 FF | 0d |  |  |  |  | S100010 | 0 |  | S100010 |  | NOCA | Not Started | C | DOE - HQ |  |  | Critical Decisions, Key Dates | Russ Feder |  |  | POM02.2.05.12 |  |  |  |  | 12 |  |  |  |  |  | 003 |  |  | L1 | 190323 ELM Add |  |  |  |

Notes:
- S1003919: BNL_UDF_Old Activity Name 181221: Move Full sPHENIX to IR - Labor
- S370000: BNL_UDF_Old Activity Name 181221: Move Full sPHENIX to IR - Labor
- S370100: BNL_UDF_Old Activity Name 181221: Move Full sPHENIX to IR - M&S
- S370500: BNL_UDF_Old Activity Name 181221: Full sPHENIX Detector Operational Readiness (ORR)
- S370510: BNL_UDF_Old Activity Name 181221: Full sPHENIX Detector Operational Readiness (ORR)
- S370520: BNL_UDF_Old Activity Name 181221: Full sPHENIX Detector Operational Readiness (ORR)
- S370530: BNL_UDF_Old Activity Name 181221: Full sPHENIX Detector Operational Readiness (ORR)
- S370540: BNL_UDF_Old Activity Name 181221: Full sPHENIX Detector Operational Readiness (ORR)
- S370550: BNL_UDF_Old Activity Name 181221: Full sPHENIX Detector Operational Readiness (ORR)
- S370200: BNL_UDF_Old Activity Name 181221: Align Full sPHENIX to Nominal Beamline and IP - Labor
- S370210: BNL_UDF_Old Activity Name 181221: Align Full sPHENIX to Nominal Beamline and IP - Labor
- S370300: BNL_UDF_Old Activity Name 181221: Align Full sPHENIX to Nominal Beamline and IP - M&S
- S370560: BNL_UDF_Old Activity Name 181221: Full sPHENIX Detector Operational Readiness (ORR)
- S370570: BNL_UDF_Old Activity Name 181221: Full sPHENIX Detector Operational Readiness (ORR)
- S370580: BNL_UDF_Old Activity Name 181221: Full sPHENIX Detector Operational Readiness (ORR)
- S370590: BNL_UDF_Old Activity Name 181221: Full sPHENIX Detector Operational Readiness (ORR)
- S370400: BNL_UDF_Adhoc Comments: 180417 ELM pred/succ, name per GRY, EOB; 180416 ELM pred/succ per GRY; 180413 ELM pred/succ per GRY / BNL_UDF_Old Activity Name 181221: sPHENIX Installation Complete Ready for Commissioning - MIE + INTT
- S370600: BNL_UDF_Old Activity Name 181221: Full sPHENIX Detector Operational Readiness (ORR)
- S370700: BNL_UDF_Old Activity Name 181221: Address Action Items from Full sPHENIX Detector ORR
- S370800: BNL_UDF_Old Activity Name 181221: sPHENIX Ready for Run 1
- S370850: BNL_UDF_Old Activity Name 181221: Start of RHIC Run 30-Jan-23
- S370900: BNL_UDF_Old Activity Name 181221: Start of RHIC Run 30-Jan-23
- S999999: BNL_UDF_Old Activity Name 181221: Approve Mission Need CD-0

## Activity codes

| Code | Value | Meaning |
| --- | --- | --- |
| BNL_Account Number | 16700 | sPHENIX OPC - Project Management |
| BNL_Account Number | 16701 | sPHENIX OPC - Time Projection Chamber |
| BNL_Account Number | 16702 | sPHENIX OPC - ElectroMagnetic Calorimeter |
| BNL_Account Number | 16703 | sPHENIX OPC - Hadronic Calorimeter |
| BNL_Account Number | 16704 | sPHENIX OPC - Calorimeter Electronics |
| BNL_Account Number | 16705 | sPHENIX OPC - DAQ/Trigger |
| BNL_Account Number | 16706 | sPHENIX OPC - Min Bias Trigger Det |
| BNL_Account Number | 16708 | sPHENIX Labor - 1.1 Project Management |
| BNL_Account Number | 16709 | sPHENIX Labor - 1.2 TPC |
| BNL_Account Number | 16710 | sPHENIX Labor - 1.3 EMCal |
| BNL_Account Number | 16711 | sPHENIX Labor - 1.4 HCal |
| BNL_Account Number | 16712 | sPHENIX Labor - 1.5 Calorimeter Electronics |
| BNL_Account Number | 16713 | sPHENIX Labor - 1.6 DAQ/Trigger |
| BNL_Account Number | 16714 | sPHENIX Labor - 1.7 Min Bias Trigger Detector |
| BNL_Account Number | 16716 | sPHENIX I&F - 2.1 Magnet Management |
| BNL_Account Number | 16717 | sPHENIX I&F - 2.2 Magnet Transport & Assembly |
| BNL_Account Number | 16718 | sPHENIX I&F - 2.2 Magnet Cryogenic Systems |
| BNL_Account Number | 16719 | sPHENIX I&F - 2.2 Magnet Power Supplies/Controls/Quench Protection |
| BNL_Account Number | 16720 | sPHENIX I&F - 2.2 Magnet Field Measurements |
| BNL_Account Number | 16721 | sPHENIX I&F - 2.1 Infrastructure Management |
| BNL_Account Number | 16722 | sPHENIX I&F - 2.3 Barrel Steel |
| BNL_Account Number | 16723 | sPHENIX I&F - 2.4 Infrastructure Detector Support Systems |
| BNL_Account Number | 16724 | sPHENIX I&F - 2.4 Infrastructure Facility Support Systems |
| BNL_Account Number | 16725 | sPHENIX I&F - 2.1 Carriage and Structural Component Management |
| BNL_Account Number | 16726 | sPHENIX I&F - 2.1 Installation/Integration Management |
| BNL_Account Number | 16727 | sPHENIX I&F - 2.5 Installation & Integration Physics |
| BNL_Account Number | 16728 | sPHENIX I&F - 2.5 Installation & Integration CAD |
| BNL_Account Number | 16729 | sPHENIX I&F - 2.3 Cradle Carriage |
| BNL_Account Number | 16730 | sPHENIX I&F - 2.2 Safety Reviews, Cooldown, Power Tests |
| BNL_Account Number | 16731 | sPHENIX I&F - 2.3 Inner Det Rings & Interface to Mech Support structure |
| BNL_Account Number | 16732 | sPHENIX I&F - 2.3 End Caps/Pole Tips |
| BNL_Account Number | 16733 | sPHENIX I&F - 2.3 CC Bridge, Platforms & Access |
| BNL_Account Number | 59700 | sPHENIX MIE - 1.1 Project Management |
| BNL_Account Number | 59702 | sPHENIX MIE - 1.2 TPC Mechanics |
| BNL_Account Number | 59703 | sPHENIX MIE - 1.2 TPC GEMs (R1, R2, R3) |
| BNL_Account Number | 59704 | sPHENIX MIE - 1.2 TPC Front End Electronics |
| BNL_Account Number | 59705 | sPHENIX MIE - 1.2 TPC Data Aggregator Modules |
| BNL_Account Number | 59706 | sPHENIX MIE - 1.2 TPC Support Systems |
| BNL_Account Number | 59708 | sPHENIX MIE - 1.3 EMCal Blocks - LLP |
| BNL_Account Number | 59709 | sPHENIX MIE - 1.3 EMCAl Modules & Sectors |
| BNL_Account Number | 59710 | sPHENIX MIE - 1.4 Inner HCal |
| BNL_Account Number | 59711 | sPHENIX MIE - 1.4 Outer HCal Sector Mechanics |
| BNL_Account Number | 59712 | sPHENIX MIE - 1.4 Outer HCal Scintillating Tiles - LLP |
| BNL_Account Number | 59713 | sPHENIX MIE - 1.4 Outer HCal Sector Assembly and Testing |
| BNL_Account Number | 59714 | sPHENIX MIE - 1.5 CalE SiPMs - LLP |
| BNL_Account Number | 59715 | sPHENIX MIE - 1.5 CalE Front End Electronics |
| BNL_Account Number | 59716 | sPHENIX MIE - 1.5 CalE Digitizer |
| BNL_Account Number | 59718 | sPHENIX MIE - 1.6 DAQ |
| BNL_Account Number | 59719 | sPHENIX MIE - 1.6 Local Level 1 Trigger |
| BNL_Account Number | 59720 | sPHENIX MIE - 1.6 Global Level 1 |
| BNL_Account Number | 59721 | sPHENIX MIE - 1.6 Timing System |
| BNL_Account Number | 59722 | sPHENIX MIE - 1.7 Min Bias Trigger Det |
| BNL_Account Number | NA | Not Applicable |
| BNL_CAM | Chris Pontieri | Chris Pontieri (BNL) |
| BNL_CAM | Craig Woody | Craig Woody (BNL) |
| BNL_CAM | Ed O'Brien | Ed O'Brien (BNL) |
| BNL_CAM | Eric Mannel | Eric Mannel (BNL) |
| BNL_CAM | Irina Sourikova | Irina Sourikova (BNL) |
| BNL_CAM | Joel Vasquez | Joel Vasquez (BNL) |
| BNL_CAM | John Lajoie | John Lajoie (ISU) |
| BNL_CAM | Kin Yip | Kin Yip (BNL) |
| BNL_CAM | Martin Purschke | Martin Purschke (BNL) |
| BNL_CAM | Mickey Chiu | Mickey Chiu (BNL) |
| BNL_CAM | Russ Feder | Russ Feder (BNL) |
| BNL_CAM | Tom Hemmick | Tom Hemmick (SB) |
| BNL_Cobra Control Account | 1.01A | Project Management - Fund Source A |
| BNL_Cobra Control Account | 1.01B | Project Management - Fund Source B |
| BNL_Cobra Control Account | 1.02A | TPC - Fund Source A |
| BNL_Cobra Control Account | 1.02B | TPC - Fund Source B |
| BNL_Cobra Control Account | 1.03A | EMCal - Fund Source A |
| BNL_Cobra Control Account | 1.03B | EMCal - Fund Source B |
| BNL_Cobra Control Account | 1.04A | HCal - Fund Source A |
| BNL_Cobra Control Account | 1.04B | HCal - Fund Source B |
| BNL_Cobra Control Account | 1.05A | Calorimeter Electronics - Fund Source A |
| BNL_Cobra Control Account | 1.05B | Calorimeter Electronics - Fund Source B |
| BNL_Cobra Control Account | 1.06A | DAQ & Trigger - Fund Source A |
| BNL_Cobra Control Account | 1.06B | DAQ & Trigger - Fund Source B |
| BNL_Cobra Control Account | 1.07A | MinBias Trigger Detector - Fund Source A |
| BNL_Cobra Control Account | 1.07B | MinBias Trigger Detector - Fund Source B |
| BNL_Cobra Control Account | 2.01 | Infrastructure/Facility Management |
| BNL_Cobra Control Account | 2.02 | SC Magnet |
| BNL_Cobra Control Account | 2.03 | Carriage and Structural Components |
| BNL_Cobra Control Account | 2.04 | Infrastructure |
| BNL_Cobra Control Account | 2.05 | Integration and Installation |
| BNL_Cost Basis | L1 | L1 - Actual |
| BNL_Cost Basis | L2 | L2 - Level of Effort Tasks |
| BNL_Cost Basis | L3 | L3 - Advanced Design (EJ) |
| BNL_Cost Basis | L4 | L4 - Preliminary Design (EJ) |
| BNL_Cost Basis | L5 | L5 - Conceptua Designl (EJ) |
| BNL_Cost Basis | L7 | L7 - Rough Order of Magnitude (EJ) |
| BNL_Cost Basis | M1 | M1 - Existing Purchase Order (Actual) |
| BNL_Cost Basis | M2 | M2 - Travel, Supplies, Software (EJ) |
| BNL_Cost Basis | M3 | M3 - Advanced Design (EJ), Quote or Catalog Price |
| BNL_Cost Basis | M4 | M4 - Preliminary Design (EJ) |
| BNL_Cost Basis | M5 | M5 - Conceptual Design (EJ) |
| BNL_Cost Basis | M7 | M7 - Pre-conceptual or Uncommon Work (EJ) |
| BNL_DOE OPC | OPC000100 | TPC v1 Field Cage Prototype |
| BNL_DOE OPC | OPC000200 | TPC v2 Field Cage |
| BNL_DOE OPC | OPC000300 | TPC v1 Modules |
| BNL_DOE OPC | OPC000400 | TPC v2 Modules |
| BNL_DOE OPC | OPC000500 | TPC R1-R3 Factory Preparation |
| BNL_DOE OPC | OPC000600 | TPC R1-R3 Preproduction Modules |
| BNL_DOE OPC | OPC000700 | TPC FEE Prototype v1 Fabrication & Test |
| BNL_DOE OPC | OPC000800 | TPC FEE Prototype v2 Fabrication & Test |
| BNL_DOE OPC | OPC000900 | TPC SAMPA Chip 80 nsec Development |
| BNL_DOE OPC | OPC001000 | TPC DAM v2 Prototype Fab & Test |
| BNL_DOE OPC | OPC001100 | TPC/DAM DAQ Bandwidth R&D |
| BNL_DOE OPC | OPC001200 | Set Up Preproduction Module & Sector Assembly / Test Area |
| BNL_DOE OPC | OPC001300 | Develop Procedures for Large Scale EMCal Proto Block Fab |
| BNL_DOE OPC | OPC001400 | EMCal Preproduction Module Assembly |
| BNL_DOE OPC | OPC001500 | EMCal Preproduction Sector Assembly |
| BNL_DOE OPC | OPC001600 | Fabrication of Outer HCal Preproduction Sectors |
| BNL_DOE OPC | OPC001640 | SiPMs for EMCal Sector Test |
| BNL_DOE OPC | OPC001650 | SiPMs for EMCal Large Scale System Test |
| BNL_DOE OPC | OPC001800 | EMCal SiPM / Fee Board for Preproduction Sector Test |
| BNL_DOE OPC | OPC001900 | EMCal SiPM / Fee Board for Large Scale System Test |
| BNL_DOE OPC | OPC001950 | HCal SiPM / Fee Board for Preproduction Sector Test |
| BNL_DOE OPC | OPC002000 | Calorimeter Digitizer v2 Prototype Fab & Test |
| BNL_DOE OPC | OPC002100 | Calorimeter Digitizer Prototype for Large Scale System Test |
| BNL_DOE OPC | OPC002200 | DAQ/Trigger LL1 Trigger Board Prototype Design |
| BNL_DOE OPC | OPC002300 | DAQ/Trigger LL1 Trigger Board v1 Prototype |
| BNL_DOE OPC | OPC002400 | DAQ/Trigger LL1 Trigger Board v1 Preproduction Prototype |
| BNL_DOE OPC | OPC002500 | DAQ/Trigger Timing & GL1 System Prototype |
| BNL_DOE OPC | OPC002600 | MBD Prototype Readout Board Fab & Test |
| BNL_EDIA | Fab & Assy | Fabrication & Assembly |
| BNL_EDIA | Test_Components | Component Testing |
| BNL_EDIA | Test_System | System Testing |
| BNL_EVT | A | Level of Effort |
| BNL_EVT | C | % Complete |
| BNL_EVT | E | 50-50 |
| BNL_EVT | F | 0-100 |
| BNL_EVT | K | Planning Package |
| BNL_Estimator | Bathe, Stefan | Stefan Bathe |
| BNL_Estimator | Chiu, Mickey | Mickey Chiu (BNL) |
| BNL_Estimator | Connors, Megan | Megan Connors |
| BNL_Estimator | Feder, Russ | Russ Feder (BNL) |
| BNL_Estimator | Hemmick,Tom | Hemmick,Tom (SBU) |
| BNL_Estimator | Huang, Jin | Jin Huang (BNL) |
| BNL_Estimator | Lajoie, John | John Lajoie (ISU) |
| BNL_Estimator | Mannel, Eric | Mannel, Eric (BNL) |
| BNL_Estimator | Mills, Jim | Jim Mills (BNL) |
| BNL_Estimator | Nagle, Jamie | Jamie Nagle (UColorado) |
| BNL_Estimator | Nouicer, Rachid | Rachid Nouicer (BNL) |
| BNL_Estimator | O'Brien, Ed | Ed O'Brien |
| BNL_Estimator | Pisani, Rob | Pisani, Rob (BNL) |
| BNL_Estimator | Pontieri, Chris | Chris Pontieri |
| BNL_Estimator | Purschke, Martin | Purschke, Martin (BNL) |
| BNL_Estimator | Sakaguchi, Takao | Takao Sakaguchi (BNL) |
| BNL_Estimator | Sickles, Anne | Anne Sickles (UIUC) |
| BNL_Estimator | Stoll, Sean | Sean Stoll (BNL) |
| BNL_Estimator | Woody, Craig | Woody,Craig (BNL) |
| BNL_Estimator | Yip, Kin | Kin Yip (BNL) |
| BNL_Fund Source | A-OPC | OPC |
| BNL_Fund Source | A-TEC | TEC |
| BNL_Fund Source | B | BNL Contributed Labor |
| BNL_Fund Source | B_T | Multiple B_T |
| BNL_Fund Source | C | Infrastructure / Facility Upgrade |
| BNL_Fund Source | T | Non BNL Contributions |
| BNL_Institution | UCB | University of Colorado at Boulder |
| BNL_LLPs and Precursors | Fibers | Procure Scintillating Fibers |
| BNL_LLPs and Precursors | LLPs | Long Lead Procurements |
| BNL_LLPs and Precursors | Pre-1 | Precursor(s) in Common to - W Powder, Fibers, Optical Sensors |
| BNL_LLPs and Precursors | Pre-2 | Precursor(s) to - Procure Scintillating Tiles |
| BNL_LLPs and Precursors | SiPMs | Optical Sensors Production |
| BNL_LLPs and Precursors | Tiles | Procure Scintillating Tiles |
| BNL_LLPs and Precursors | W Powd | Procure W Powder |
| BNL_Location | Brasil | Sao Paulo Uni |
| BNL_Location | Japan | Hamamatsu Japan |
| BNL_Location | Russia | Uniplast, Russia |
| BNL_Location | Temple | Temple Uni |
| BNL_Location | Wayne | Wayne Uni |
| BNL_Master Control Account | 1.01 | Project Management |
| BNL_Master Control Account | 1.02 | TPC |
| BNL_Master Control Account | 1.03 | EMCal |
| BNL_Master Control Account | 1.04 | HCal |
| BNL_Master Control Account | 1.05 | Calorimeter Electronics |
| BNL_Master Control Account | 1.06 | DAQ & Trigger |
| BNL_Master Control Account | 1.07 | MinBias Trigger Detector |
| BNL_Master Control Account | 2.01 | Infrastructure/Facility Management |
| BNL_Master Control Account | 2.02 | SC Magnet |
| BNL_Master Control Account | 2.03 | Carriage and Structural Components |
| BNL_Master Control Account | 2.04 | Infrastructure |
| BNL_Master Control Account | 2.05 | Integration and Installation |
| BNL_Milestone Level | L1 | Milestone Level 1 |
| BNL_Milestone Level | L2 | Milestone Level 2 |
| BNL_Milestone Level | L3 | Milestone Level 3 |
| BNL_Milestone Level | L4 | Milestone Level 4 |
| BNL_Milestone Level | L5 | Milestone Level 5 |
| BNL_OPC TEC (deprecated) | OPC | (New Code Value) |
| BNL_OPC TEC (deprecated) | TEC | (New Code Value) |
| BNL_OPC TEC (deprecated) | null | (New Code Value) |
| BNL_Obligation | FAB | Fabrication |
| BNL_Obligation | OBLG | Obligation |
| BNL_PCR ID | 001 | PCR001 |
| BNL_PCR ID | 001,003 | PCRs 001 & 003 |
| BNL_PCR ID | 002 | PCR002 |
| BNL_PCR ID | 002,003 | PCRs 002 & 003 |
| BNL_PCR ID | 002,004 | PCRs 002 & 004 |
| BNL_PCR ID | 003 | PCR003 |
| BNL_PCR ID | 003,004 | PCRs 003 & 004 |
| BNL_PCR ID | 003,005 | PCRs 003 & 005 |
| BNL_PCR ID | 004 | PCR004 |
| BNL_PCR ID | 004,005 | PCR004, PCR005 |
| BNL_PCR ID | 005 | PCR005 |
| BNL_PCR ID | 007 | PCR007A |
| BNL_PCR ID | 008C | PCR008C |
| BNL_PCR ID | 009 | PCR009A |
| BNL_PCR ID | 010 | PCR010C |
| BNL_PCR ID | 011 | PCR011A |
| BNL_PCR ID | 012 | PCR012 |
| BNL_PCR ID | 014 | PCR014A |
| BNL_PCR ID | 015 | PCR015A |
| BNL_PCR ID | 016 | PCR016C |
| BNL_PCR ID | 017 | PCR017A |
| BNL_PCR ID | 018 | PCR018C |
| BNL_PCR ID | 020 | PCR020A |
| BNL_PCR ID | 021 | PCR021A |
| BNL_PCR ID | 022 | PCR022A |
| BNL_PCR ID | 023 | PCR023C |
| BNL_PCR ID | 024 | PCR024C |
| BNL_PCR ID | 025 | PCR025C |
| BNL_PCR ID | 026 | PCR026C |
| BNL_Proc Sig | MP100400 | Procure Train Technician to work in CERN Shop on TPC GEMs |
| BNL_Proc Sig | MP100410 | Procure Production of TPC GEM foils (includes Technician fees) |
| BNL_Proc Sig | MP100600 | Procure TPC GEM HV Power Supplies |
| BNL_Proc Sig | MP100610 | Procure TPC GEM HV Membrane Power Supply |
| BNL_Proc Sig | MP100800 | Procure TPC R1 Module Prod. Parts (Frames, Strongbacks, Padplanes, Grids) |
| BNL_Proc Sig | MP100810 | Procure TPC R1 Module Parts (Frames) |
| BNL_Proc Sig | MP100820 | Procure TPC R1 Module Parts (Strongbacks) |
| BNL_Proc Sig | MP100830 | Procure TPC R1 Module Parts (Padplanes) |
| BNL_Proc Sig | MP100840 | Procure TPC R1 Module Parts (Grids) |
| BNL_Proc Sig | MP101000 | Procure TPC R2 Module Prod. Parts (Frames, Strongbacks, Padplanes, Grids) |
| BNL_Proc Sig | MP101010 | Procure TPC R2 Module Prod. Parts (Frames) |
| BNL_Proc Sig | MP101020 | Procure TPC R2 Module Prod. Parts (Strongbacks) |
| BNL_Proc Sig | MP101030 | Procure TPC R2 Module Prod. Parts (Padplanes) |
| BNL_Proc Sig | MP101040 | Procure TPC R2 Module Prod. Parts (Grids) |
| BNL_Proc Sig | MP101200 | Procure TPC R3 Module Prod. Parts (Frames, Strongbacks, Padplanes, Grids) |
| BNL_Proc Sig | MP101210 | Procure TPC R3 Module Prod. Parts (Frames) |
| BNL_Proc Sig | MP101220 | Procure TPC R3 Module Prod. Parts (Strongbacks) |
| BNL_Proc Sig | MP101230 | Procure TPC R3 Module Prod. Parts (Padplanes) |
| BNL_Proc Sig | MP101240 | Procure TPC R3 Module Prod. Parts (Grids) |
| BNL_Proc Sig | MP101300 | Procure TPC FEE Production Boards & Assembly |
| BNL_Proc Sig | MP101400 | Procure TPC FEE Production Components, Phase 1 (Optical Transceiver Components) |
| BNL_Proc Sig | MP101420 | Procure TPC FEE Production Components, Phase 2 (All except Optical and SAMPA) |
| BNL_Proc Sig | MP101500 | Procure TPC FEE LV Power Supplies |
| BNL_Proc Sig | MP101600 | Procure TPC DAM Felix 2.0 Boards Evaluation |
| BNL_Proc Sig | MP101700 | Procure TPC EDBC Computers & Peripherals |
| BNL_Proc Sig | MP101790 | Procure TPC DAM Felix 2.0 Boards Throughput (Optical), OPC Funds |
| BNL_Proc Sig | MP101800 | Procure TPC DAM Felix 2.0 Boards, TEC Funds |
| BNL_Proc Sig | MP101801 | Procure TPC DAM Felix 2.0 Optical Components |
| BNL_Proc Sig | MP101900 | Procure TPC Lasers |
| BNL_Proc Sig | MP102000 | Procure TPC Optics with Mirrors |
| BNL_Proc Sig | MP102100 | Procure TPC Gas System Components for Installation |
| BNL_Proc Sig | MP102200 | Procure TPC Gas System Equipment |
| BNL_Proc Sig | MP102500 | Procure TPC Cooling System Equipment |
| BNL_Proc Sig | MP102600 | Procure EMCAL Epoxy for Final Blocks |
| BNL_Proc Sig | MP103000 | Procure EMCAL Fibers for Final Blocks |
| BNL_Proc Sig | MP103600 | Procure EMCAL Mechanical Parts for Final Modules Sectors 13-64 |
| BNL_Proc Sig | MP103700 | Procure EMCAL Mechanical Parts for Final Sectors |
| BNL_Proc Sig | MP103800 | Procure EMCAL Cooling System for Final Sectors |
| BNL_Proc Sig | MP104700 | Procure Outer HCal Mechanical Structure Components - Phase 1 LDRD $190K Prototype |
| BNL_Proc Sig | MP104701-00 | Procure Outer HCAL Mechanical Structure Sector Assemblies - Raw Material |
| BNL_Proc Sig | MP104701-01 | Procure Outer HCAL Mechanical Structure Sector Assemblies - Phased Delivery 1/32 |
| BNL_Proc Sig | MP104701-02 | Procure Outer HCAL Mechanical Structure Sector Assemblies - Phased Delivery 2/32 |
| BNL_Proc Sig | MP104701-03 | Procure Outer HCAL Mechanical Structure Sector Assemblies - Phased Delivery 3/32 |
| BNL_Proc Sig | MP104701-04 | Procure Outer HCAL Mechanical Structure Sector Assemblies - Phased Delivery 4/32 |
| BNL_Proc Sig | MP104701-05 | Procure Outer HCAL Mechanical Structure Sector Assemblies - Phased Delivery 5/32 |
| BNL_Proc Sig | MP104701-06 | Procure Outer HCAL Mechanical Structure Sector Assemblies - Phased Delivery 6/32 |
| BNL_Proc Sig | MP104701-07 | Procure Outer HCAL Mechanical Structure Sector Assemblies - Phased Delivery 7/32 |
| BNL_Proc Sig | MP104701-08 | Procure Outer HCAL Mechanical Structure Sector Assemblies - Phased Delivery 8/32 |
| BNL_Proc Sig | MP104701-09 | Procure Outer HCAL Mechanical Structure Sector Assemblies - Phased Delivery 9/32 |
| BNL_Proc Sig | MP104701-10 | Procure Outer HCAL Mechanical Structure Sector Assemblies - Phased Delivery 10/32 |
| BNL_Proc Sig | MP104701-11 | Procure Outer HCAL Mechanical Structure Sector Assemblies - Phased Delivery 11/32 |
| BNL_Proc Sig | MP104701-12 | Procure Outer HCAL Mechanical Structure Sector Assemblies - Phased Delivery 12/32 |
| BNL_Proc Sig | MP104701-13 | Procure Outer HCAL Mechanical Structure Sector Assemblies - Phased Delivery 13/32 |
| BNL_Proc Sig | MP104701-14 | Procure Outer HCAL Mechanical Structure Sector Assemblies - Phased Delivery 14/32 |
| BNL_Proc Sig | MP104701-15 | Procure Outer HCAL Mechanical Structure Sector Assemblies - Phased Delivery 15/32 |
| BNL_Proc Sig | MP104701-16 | Procure Outer HCAL Mechanical Structure Sector Assemblies - Phased Delivery 16/32 |
| BNL_Proc Sig | MP104701-17 | Procure Outer HCAL Mechanical Structure Sector Assemblies - Phased Delivery 17/32 |
| BNL_Proc Sig | MP104701-18 | Procure Outer HCAL Mechanical Structure Sector Assemblies - Phased Delivery 18/32 |
| BNL_Proc Sig | MP104701-19 | Procure Outer HCAL Mechanical Structure Sector Assemblies - Phased Delivery 19/32 |
| BNL_Proc Sig | MP104701-20 | Procure Outer HCAL Mechanical Structure Sector Assemblies - Phased Delivery 20/32 |
| BNL_Proc Sig | MP104701-21 | Procure Outer HCAL Mechanical Structure Sector Assemblies - Phased Delivery 21/32 |
| BNL_Proc Sig | MP104701-22 | Procure Outer HCAL Mechanical Structure Sector Assemblies - Phased Delivery 22/32 |
| BNL_Proc Sig | MP104701-23 | Procure Outer HCAL Mechanical Structure Sector Assemblies - Phased Delivery 23/32 |
| BNL_Proc Sig | MP104701-24 | Procure Outer HCAL Mechanical Structure Sector Assemblies - Phased Delivery 24/32 |
| BNL_Proc Sig | MP104701-25 | Procure Outer HCAL Mechanical Structure Sector Assemblies - Phased Delivery 25/32 |
| BNL_Proc Sig | MP104701-26 | Procure Outer HCAL Mechanical Structure Sector Assemblies - Phased Delivery 26/32 |
| BNL_Proc Sig | MP104701-27 | Procure Outer HCAL Mechanical Structure Sector Assemblies - Phased Delivery 27/32 |
| BNL_Proc Sig | MP104701-28 | Procure Outer HCAL Mechanical Structure Sector Assemblies - Phased Delivery 28/32 |
| BNL_Proc Sig | MP104701-29 | Procure Outer HCAL Mechanical Structure Sector Assemblies - Phased Delivery 29/32 |
| BNL_Proc Sig | MP104701-30 | Procure Outer HCAL Mechanical Structure Sector Assemblies - Phased Delivery 30/32 |
| BNL_Proc Sig | MP104701-31 | Procure Outer HCAL Mechanical Structure Sector Assemblies - Phased Delivery 31/32 |
| BNL_Proc Sig | MP104701-32 | Procure Outer HCAL Mechanical Structure Sector Assemblies - Phased Delivery 32/32 |
| BNL_Proc Sig | MP104800 | Procure Outer HCAL Lifting Fixtures & Supports |
| BNL_Proc Sig | MP104900 | Procure Outer HCAL Splice Plates |
| BNL_Proc Sig | MP105000 | Procure Outer HCAL Scintillating Tiles (Prod) |
| BNL_Proc Sig | MP105300 | Procure Outer HCAL Assembly & Testing Equipment |
| BNL_Proc Sig | MP105500 | Fabricate SiPM Daughter Boards Sectors 13-64 |
| BNL_Proc Sig | MP105700 | Fabricate EMCAL Interface Board Sectors 13-64 |
| BNL_Proc Sig | MP105800 | Fabricate EMCAL Production Preamp Boards Sectors 13-64 |
| BNL_Proc Sig | MP105910 | Procure EMCal External LV/Bias Cables Sectors 13-64 |
| BNL_Proc Sig | MP105920 | Procure EMCal Bias Power System Sectors 13-64 |
| BNL_Proc Sig | MP106400 | Procure HCAL Electronics Production Power & Signal Cables (Internal) |
| BNL_Proc Sig | MP106450 | HCal Electronics Prod Pwr & Sig Cables & LV/Bias Supplies & Controller (External) |
| BNL_Proc Sig | MP106500 | Procure Production Digitizer (Parts) |
| BNL_Proc Sig | MP106510 | Procure Production Digitizer (Boards) |
| BNL_Proc Sig | MP106520 | Procure Production Digitizer (Assembly & Tests) |
| BNL_Proc Sig | MP106800 | Procure DAQ Production Boards |
| BNL_Proc Sig | MP106900 | Procure DAQ Production Crates |
| BNL_Proc Sig | MP107000 | Procure DAQ Production ATPs |
| BNL_Proc Sig | MP107100 | Procure DAQ Production Buffer Boxes |
| BNL_Proc Sig | MP107200 | Procure DAQ Production SEBs |
| BNL_Proc Sig | MP107300 | Procure DAQ Production Main Switches |
| BNL_Proc Sig | MP107400 | Procure Prototype V1 Trigger Board |
| BNL_Proc Sig | MP107600 | Procure Production LL1 System |
| BNL_Proc Sig | MP107700 | Procure Production GL1 Components |
| BNL_Proc Sig | MP107800 | Timing System Production (FPGA Boards) |
| BNL_Proc Sig | MP107900 | Procure Prototype Shaper/Disc Electronics |
| BNL_Proc Sig | MP108000 | Procure Min/Bias Electronics (sPHENIX Production Digitizers) |
| BNL_Proc Sig | MP108010 | Procure MBD Shaper/Disc Board 128 Channels |
| BNL_Proc Sig | MP108100 | Fabricate HCal SiPM Boards |
| BNL_Proc Sig | MP108200 | Procure 1/2-Crate Digitizer Parts |
| BNL_Proc Sig | MP108210 | Procure 1/2-Crate Digitizer Boards |
| BNL_Proc Sig | MP108220 | Procure 1/2-Crate Digitizer Assembly & Tests |
| BNL_Proc Sig | MP108900 | Procure EMCal/HCal sensors Preproduction - deliver units 1K - 10K |
| BNL_Proc Sig | MP108910 | Procure EMCal/HCal sensors Preproduction - deliver units 10K - 23K |
| BNL_Proc Sig | MP109400 | Procure EMCAL 7-Crate Digitizer |
| BNL_Proc Sig | MP109410 | Procure EMCAL 7-Crate Digitizer (Boards) |
| BNL_Proc Sig | MP109420 | Procure EMCAL 7-Crate Digitizer (Assembly & Tests) |
| BNL_Proc Sig | MP109600 | Procure EMCAL W powder for Prepro Sectors 1-12 Blocks |
| BNL_Proc Sig | MP109800 | Procure EMCAL fibers for Prepro Sectors 1-12 Blocks |
| BNL_Proc Sig | MP109810 | Procure EMCAL fibers for Prepro Sectors 1-12 Blocks - 2nd batch FY18 |
| BNL_Proc Sig | MP109820 | Procure EMCAL fibers for Prepro Sectors 1-12 Blocks - 3rd batch FY19 |
| BNL_Proc Sig | MP109830 | Procure EMCAL fibers for Prepro Sectors 1-12 Blocks - 4th batch |
| BNL_Proc Sig | MP200000 | Procure Outer HCAL Scint. Tiles for Preproduction - batch 1 |
| BNL_Proc Sig | MP200010 | Procure Outer HCAL Scint. Tiles for Preproduction - batch 2 |
| BNL_Proc Sig | MP200011 | Second Phase of SAMPA v5 |
| BNL_Proc Sig | MP200020 | Procure Outer HCAL Scint. Tiles for Preproduction - batch 3 |
| BNL_Proc Sig | MP200100 | Procure SAMPA chip 80 nsec development |
| BNL_Proc Sig | MP200150 | Procure SAMPA chip 80 nsec development - Engineering Run (ER), OPC Funds |
| BNL_Proc Sig | MP200151 | Procure SAMPA chip 80 nsec development - Engineering Run (ER), TEC Funds |
| BNL_Proc Sig | MP200200 | Procure mechanical parts for Prepro Sectors 1-12, OPC Funds |
| BNL_Proc Sig | MP200201 | Procure mechanical parts for Prepro Sectors 1-12, TEC Funds |
| BNL_Proc Sig | MP200310 | Procure EMCal External Bias Power System: Sectors 1-12, OPC Funds |
| BNL_Proc Sig | MP200311 | Procure EMCal External Bias Power System: Sectors 1-12, TEC Funds |
| BNL_Proc Sig | MP200400 | Procure TPC v1 End Cap - Phase 1 |
| BNL_Proc Sig | MP200410 | Procure TPC v1 End Cap - Phase 2 |
| BNL_Proc Sig | MP200600 | Trigger Design, Layout Custom LL1 |
| BNL_Proc Sig | MP200700 | Procure light guides for modules in Sectors (Prepro) 1-12, OPC Funds |
| BNL_Proc Sig | MP200701 | Procure light guides for modules in Sectors 13-64, TEC Funds |
| BNL_Proc Sig | MP200800 | Procure TPC v2 Outer Field Cage Parts |
| BNL_Proc Sig | MP200900 | Procure TPC v2 Inner Field Cage Parts |
| BNL_Proc Sig | MP201050 | Fabricate EMCal Preamp Boards: Sectors 1-12, OPC Funds |
| BNL_Proc Sig | MP201051 | Fabricate EMCal Preamp Boards: Sectors 1-12, TEC Funds |
| BNL_Proc Sig | MP201100 | Procure mechanical parts for modules in Sectors (Prepro) 1-12 |
| BNL_Proc Sig | MP201600 | Manufacture Inner HCAL Support Rings |
| BNL_Proc Sig | MP201800 | Procure parts for cooling system for Prepro Sectors 1-12 |
| BNL_Proc Sig | MP201900 | Fabricate EMCal Interface Board: Sectors 1-12, OPC Funds |
| BNL_Proc Sig | MP201901 | Fabricate EMCal Interface Board: Sectors 1-12, TEC Funds |
| BNL_Proc Sig | MP202000 | Procure TPC FEE Cooling System |
| BNL_Proc Sig | MP202100 | Fabricate HCal LED Boards |
| BNL_Proc Sig | MP202300 | Order parts and fabricate molds for EMCal Sectors 13-64 Blocks |
| BNL_Proc Sig | MP202400 | Set up factory for EMCal Prepro Sectors 1-12 Blocks |
| BNL_Proc Sig | MP202500 | Order epoxy for EMCal Prepro Sectors 1-12 Blocks |
| BNL_Proc Sig | MP202600 | Order screens for EMCal Prepro Sectors 1-12 & 13-64 Blocks |
| BNL_Proc Sig | MP202700 | Manufacture Inner HCAL Support Structure |
| BNL_Proc Sig | MP202800 | Procure Internal EMCal Signal/Test/Comm and LV/Bias: Production |
| BNL_Proc Sig | MP202900 | Fabricate HCal Preamp Boards |
| BNL_Proc Sig | MP202950 | Procure Trigger Preproduction Prototype LL1 |
| BNL_Proc Sig | MP203010 | Fabricate Calorimeter Production Controller Boards |
| BNL_Proc Sig | MP203020 | Fabricate HCal Interface Boards Production |
| BNL_Proc Sig | MP203101 | Procure Contracted Labor Georgia State Univ. (GSU), OPC Funds |
| BNL_Proc Sig | MP203102 | Procure Contracted Labor Georgia State Univ. (GSU), TEC Funds |
| BNL_Proc Sig | MP203200 | Procure Contracted Labor University of Illinois at Urbana–Champaign (UIUC) - Phase 1 - OPC FY19 |
| BNL_Proc Sig | MP203204 | [Magnet] Procure Parts (for disassembly, transport & reassembly) |
| BNL_Proc Sig | MP203210 | Procure Contracted Labor Univ. Illinois Urbana-Champaign (UIUC), Phase 2, TEC Funds |
| BNL_Proc Sig | MP203220 | Procure Contracted Labor Univ. Illinois Urbana-Champaign (UIUC), Phase 3, TEC Funds |
| BNL_Proc Sig | MP203240 | Procure Contracted Labor & M&S Univ. Michigan (UM), OPC Funds |
| BNL_Proc Sig | MP203250 | Procure Contracted Labor & M&S Univ. Michigan (UM), TEC Funds |
| BNL_Proc Sig | MP204100 | Procure Module Production Contracted Labor and M&S Wayne State (WSU), OPC Funds |
| BNL_Proc Sig | MP204101 | Procure Module Production Contracted Labor and M&S Wayne State (WSU), TEC Funds |
| BNL_Proc Sig | MP208100 | Procure Module Production Contracted Labor and M&S Stony Brook University (SBU), OPC Funds |
| BNL_Proc Sig | MP208200 | Procure Module Production Contracted Labor and M&S Stony Brook University (SBU), TEC Funds |
| BNL_Proc Sig | MP209100 | Carriage Cradle |
| BNL_Proc Sig | MP209104 | CC Drive & Alignment System |
| BNL_Proc Sig | MP209106 | Track Modifications |
| BNL_Proc Sig | MP209108 | CC Seismic Restraints |
| BNL_Proc Sig | MP209110 | CC Bridge, Mid Platforms & Access |
| BNL_Proc Sig | MP209120 | End Caps/ Pole Tips |
| BNL_Proc Sig | MP210001 | Procure RHIC Helium Interface, Phase 1 (Detailed Drawing Package) |
| BNL_Proc Sig | MP210002 | Procure RHIC Helium Interface, Phase 2 (Long Lead Items) |
| BNL_Proc Sig | MP210003 | Procure RHIC Helium Interface, Phase 3 (Final Design Review) |
| BNL_Proc Sig | MP210004 | Procure RHIC Helium Interface, Phase 4 (Drawings Approvals) |
| BNL_Proc Sig | MP210005 | Procure RHIC Helium Interface, Phase 5 (Raw Materials) |
| BNL_Proc Sig | MP210006 | Procure RHIC Helium Interface, Phase 6 (BNL Holdpoint Witness) |
| BNL_Proc Sig | MP210007 | Procure RHIC Helium Interface, Phase 7 (Shipping) |
| BNL_Proc Sig | MP210010 | Procure Layout/Simulation/Submission/Reception of Full SAMPA Chip |
| BNL_Proc Sig | MP210020 | Procure Engineering Run of Full SAMPA Chip |
| BNL_Proc Sig | MP210030 | Procure LN2 supply transfer line system, Phase 1 (Preliminary Design Review) |
| BNL_Proc Sig | MP210031 | Procure LN2 supply transfer line system, Phase 2 (Long lead items) |
| BNL_Proc Sig | MP210032 | Procure LN2 supply transfer line system, Phase 3 (Final Design Review) |
| BNL_Proc Sig | MP210033 | Procure LN2 supply transfer line system, Phase 4 (Raw Material) |
| BNL_Proc Sig | MP210034 | Procure LN2 supply transfer system - Phase 5 |
| BNL_Proc Sig | MP210040 | Procure Warm Piping and fittings |
| BNL_Proc Sig | MP210060 | Procure Internal Detector Structural Support |
| BNL_Proc Sig | MP210070 | Procure Line Electric Power Distribution Components |
| BNL_Proc Sig | MP300010 | Magnet Supports |
| BNL_Proc Sig | MP300020 | TPC Supports |
| BNL_Proc Sig | MP300030 | INTT Supports |
| BNL_Proc Sig | MP300040 | MVTX Supports |
| BNL_Proc Sig | MP300050 | Large Support Rings |
| BNL_Proc Sig | TBD | (New Code Value) |
| BNL_Proc Sig Phase | PP1 | Phase 1 Project Submit to Procurement |
| BNL_Proc Sig Phase | PP2 | Phase 2 Procurement Solicitation |
| BNL_Proc Sig Phase | PP3 | Phase 3 Vendor Response |
| BNL_Proc Sig Phase | PP4 | Phase 4 BNL Vendor Selection |
| BNL_Proc Sig Phase | PP5 | Phase 5 BNL Contract Award |
| BNL_Proc Sig Phase | PP6 | Phase 6 Vendor $ Schedule of Values |
| BNL_R&D FY18-19 | CalEl Clock Master | Calorimeter Clock Master prototype fab and test |
| BNL_R&D FY18-19 | CalEl Digitizer v2 | Calorimeter Digitizer v2 prototype fabrication and test |
| BNL_R&D FY18-19 | CalEl EMCal FEE tests | EMCal on-detector Fee final prototype fab and test |
| BNL_R&D FY18-19 | CalEl HCal FEE tests | HCal on-detector Fee final prototype fab and test |
| BNL_R&D FY18-19 | CalEl SiPMs for large tests | SiPM Procurement for large scale system tests |
| BNL_R&D FY18-19 | DAQ LL1 v1 | DAQ/Trigger Level-1 MB trig board v1 prototype fab & test |
| BNL_R&D FY18-19 | DAQ LL1 v2 | DAQ/Trigger Level-1 MB trig board v2 prototype fab test |
| BNL_R&D FY18-19 | DAQ Timing/Switch | DAQ Timing system/network switch prototyping & test |
| BNL_R&D FY18-19 | EMCal Prepro Sector | Construction of EMCal sector preproduction proto sector |
| BNL_R&D FY18-19 | EMCal Prepro Sectors 1-12 | Develop procedures for large scale EMCal proto fab |
| BNL_R&D FY18-19 | EMCal SiPMs | SiPMs for EMCal sector test |
| BNL_R&D FY18-19 | EMCal v2.1 | EMCal v2.1 prototype fabrication and laboratory tests |
| BNL_R&D FY18-19 | HCal v2.1 | Fab and Test of HCal v2.1 prototype tiles and light blocks |
| BNL_R&D FY18-19 | Mgmt FY18 | sPHENIX Management FY18 |
| BNL_R&D FY18-19 | Mgmt R&D FY18 | Management of R&D and conceptual design in FY2018 |
| BNL_R&D FY18-19 | MinBias mag. test | MBD component testing/opt in sPHENIX mag environmnt |
| BNL_R&D FY18-19 | MinBias readout tests | MBD prototype readout electronics testing |
| BNL_R&D FY18-19 | Outer HCal test sectors | Fabrication and test of outer HCAL sectors |
| BNL_R&D FY18-19 | SAMPA Chip 80nsec | SAMPA Chip 80 nsec development |
| BNL_R&D FY18-19 | TPC DAM v1 | TPC DAM v1 prototype Fabrication and Test |
| BNL_R&D FY18-19 | TPC DAM v2 | TPC DAM v2 prototype Fabrication and Test |
| BNL_R&D FY18-19 | TPC FEE Pre-pro proto | TPC FEE Pre-Production Prototype |
| BNL_R&D FY18-19 | TPC FEE Proto v1 | TPC FEE prototype v1 fabrication and test |
| BNL_R&D FY18-19 | TPC Final FCage | TPC Final Field Cage |
| BNL_R&D FY18-19 | TPC R1-3 Fact.Prep | TPC R1-3 Module Factory Preparation |
| BNL_R&D FY18-19 | TPC R1-3 Pre-pro Mod | TPC R1-3 Pre-Production Module |
| BNL_R&D FY18-19 | TPC v1 FCage | TPC v1 Field Cage Prototype |
| BNL_R&D FY18-19 | TPC v1 Mod | TPC v1 Modules |
| BNL_R&D FY18-19 | TPC v2 FCage | TPC v2 Field Cage |
| BNL_R&D FY18-19 | TPC v2 Mod | TPC v2 Modules |
| BNL_Split Activity | FY18 | (New Code Value) |
| BNL_Split Activity | FY19 | (New Code Value) |
| BNL_WBS | POM02.1.01 | Project Management |
| BNL_WBS | POM02.1.01.01 | Management Overview |
| BNL_WBS | POM02.1.01.02 | Labor by FY |
| BNL_WBS | POM02.1.01.03 | Management Travel |
| BNL_WBS | POM02.1.02 | TPC |
| BNL_WBS | POM02.1.02.01.01 | TPC v1 Field Cage Prototype |
| BNL_WBS | POM02.1.02.01.02 | TPC v2 Field Cage |
| BNL_WBS | POM02.1.02.01.03 | TPC Final Field Cage |
| BNL_WBS | POM02.1.02.01.04.01 | TPC v1 Module Gas Enclosure |
| BNL_WBS | POM02.1.02.01.04.02 | TPC v1 Module Common Mechanics |
| BNL_WBS | POM02.1.02.01.04.03 | TPC v1a Module Prototype |
| BNL_WBS | POM02.1.02.01.04.04 | TPC v1b Module Prototype |
| BNL_WBS | POM02.1.02.01.05.02 | TPC v2 Module Common Mechanics |
| BNL_WBS | POM02.1.02.01.05.03 | TPC v2a Module Prototype |
| BNL_WBS | POM02.1.02.01.06 | TPC Production GEM Acquisition |
| BNL_WBS | POM02.1.02.01.07 | TPC High Voltage System |
| BNL_WBS | POM02.1.02.01.08 | TPC Assembly |
| BNL_WBS | POM02.1.02.02.01 | TPC R1 Module Factory Preparation |
| BNL_WBS | POM02.1.02.02.02 | TPC R1 Pre-Production Module |
| BNL_WBS | POM02.1.02.02.03 | TPC R1 Module Production |
| BNL_WBS | POM02.1.02.02.04 | TPC R1 Module Production Procure Contracted Labor and M&S |
| BNL_WBS | POM02.1.02.03.01 | TPC R2 Module Factory Preparation |
| BNL_WBS | POM02.1.02.03.02 | TPC R2 Pre-Production Module |
| BNL_WBS | POM02.1.02.03.03 | TPC R2 Module Production |
| BNL_WBS | POM02.1.02.04.01 | TPC R3 Module Factory Preparation |
| BNL_WBS | POM02.1.02.04.02 | TPC R3 Pre-Production Module |
| BNL_WBS | POM02.1.02.04.03 | TPC R3 Module Production |
| BNL_WBS | POM02.1.02.05.01 | TPC FEE Prototype v1 |
| BNL_WBS | POM02.1.02.05.02 | TPC FEE Prototype v2 (Pre-Production) |
| BNL_WBS | POM02.1.02.05.03 | SAMPA chip 80 nsec |
| BNL_WBS | POM02.1.02.05.04 | TPC FEE Production |
| BNL_WBS | POM02.1.02.06.01 | TPC DAM Evaluation -- FELIX 1.5 |
| BNL_WBS | POM02.1.02.06.02 | TPC DAM Evaluation -- FELIX 2.0 |
| BNL_WBS | POM02.1.02.06.03 | TPC DAM Production |
| BNL_WBS | POM02.1.02.07.01 | TPC Laser System |
| BNL_WBS | POM02.1.02.07.02 | TPC Gas System |
| BNL_WBS | POM02.1.02.07.03 | TPC Cooling System |
| BNL_WBS | POM02.1.03 | EMCal |
| BNL_WBS | POM02.1.03.01.01 | EMCAL Prototype V2.1 Block Production |
| BNL_WBS | POM02.1.03.01.02.01 | Order Material for preproduction prototype Sector 0 |
| BNL_WBS | POM02.1.03.01.02.02 | Fabricate blocks for preproduction prototype Sector 0 |
| BNL_WBS | POM02.1.03.01.02.03 | Pack and ship preproduction blocks to BNL Sector 0 |
| BNL_WBS | POM02.1.03.01.02.04 | Order Material for EMCal Block Preproduction |
| BNL_WBS | POM02.1.03.01.02.05 | Fabricate EMCal Prepro blocks Sectors 1-12 |
| BNL_WBS | POM02.1.03.01.02.06 | Pack and ship EMCal Blocks for Prepro Sectors 1-12 to BNL |
| BNL_WBS | POM02.1.03.01.03.01 | Order Material for EMCAL Final Block Production |
| BNL_WBS | POM02.1.03.01.03.02 | Fabricate final blocks |
| BNL_WBS | POM02.1.03.01.03.03 | Pack and ship final blocks to BNL |
| BNL_WBS | POM02.1.03.01.04 | EMCAL Block Fabrication Procurement |
| BNL_WBS | POM02.1.03.02.01 | Set up Module Fabrication, Sector Assembly and Test area |
| BNL_WBS | POM02.1.03.02.02.01 | EMCAL Prototype V2.1 Module Fabrication |
| BNL_WBS | POM02.1.03.02.02.02 | EMCAL Preprod Sector 0, 1-12 Module Fabrication |
| BNL_WBS | POM02.1.03.02.02.03 | EMCAL Final Module Fabrication |
| BNL_WBS | POM02.1.03.02.03.01 | EMCAL Prototype v2.1 Sector Assembly |
| BNL_WBS | POM02.1.03.02.03.02 | EMCAL Preproduction Sector Assembly and testing |
| BNL_WBS | POM02.1.03.02.03.03 | EMCAL Final Production Sector Assembly |
| BNL_WBS | POM02.1.04 | HCal |
| BNL_WBS | POM02.1.04.01 | Inner HCAL Support Structure & Support Rings |
| BNL_WBS | POM02.1.04.02 | Outer HCAL Sector Mechanical Structure |
| BNL_WBS | POM02.1.04.03 | Outer HCAL Procure Scintillating Tiles |
| BNL_WBS | POM02.1.04.04.01 | Outer HCAL Sector Assembly and Testing - Preproduction |
| BNL_WBS | POM02.1.04.04.02 | Outer HCAL Sector Assembly and Testing - Production |
| BNL_WBS | POM02.1.05 | Calorimeter Electronics |
| BNL_WBS | POM02.1.05.01 | SiPMs |
| BNL_WBS | POM02.1.05.02.01 | EMCal Electronics: Preproduction |
| BNL_WBS | POM02.1.05.02.02 | EMCal Electronics: Production |
| BNL_WBS | POM02.1.05.02.03 | HCal Electronics: Preproduction |
| BNL_WBS | POM02.1.05.02.04 | HCal Electronics: Production |
| BNL_WBS | POM02.1.05.02.05 | Calorimeter Front End Electronics Procure Contracted Labor and M&S |
| BNL_WBS | POM02.1.05.03.01 | Calorimeter Digitizer: Preproduction Prototype |
| BNL_WBS | POM02.1.05.03.02 | Calorimeter Digitizers: Production |
| BNL_WBS | POM02.1.06 | DAQ/Trigger |
| BNL_WBS | POM02.1.06.01.01 | DAQ Design |
| BNL_WBS | POM02.1.06.01.02 | DAQ Prototype |
| BNL_WBS | POM02.1.06.01.03 | DAQ Production |
| BNL_WBS | POM02.1.06.02.01 | LL1 Trigger Design |
| BNL_WBS | POM02.1.06.02.02 | LL1 Trigger Prototype v1 |
| BNL_WBS | POM02.1.06.02.03 | LL1 Trigger Preproduction Prototype |
| BNL_WBS | POM02.1.06.02.04 | LL1 Trigger Production |
| BNL_WBS | POM02.1.06.03.01 | GL1 Trigger Design |
| BNL_WBS | POM02.1.06.03.02 | GL1 Trigger Prototype |
| BNL_WBS | POM02.1.06.03.03 | GL1 Trigger Production |
| BNL_WBS | POM02.1.06.04.01 | Timing system Design |
| BNL_WBS | POM02.1.06.04.02 | Timing System Prototype |
| BNL_WBS | POM02.1.06.04.03 | Timing System Production |
| BNL_WBS | POM02.1.07 | Min Bias Trigger Detector |
| BNL_WBS | POM02.2.01.01 | Magnet Management and Technical Oversight |
| BNL_WBS | POM02.2.01.02 | Carriage and Structural Component Management |
| BNL_WBS | POM02.2.01.03 | Infrastructure Management |
| BNL_WBS | POM02.2.01.04 | Installation Management |
| BNL_WBS | POM02.2.02 | SC Magnet |
| BNL_WBS | POM02.2.02.01 | Safety Reviews, Cooldown, Power Tests |
| BNL_WBS | POM02.2.02.01.01 | Safety Reviews |
| BNL_WBS | POM02.2.02.01.02 | Cooldown & Power Tests |
| BNL_WBS | POM02.2.02.02 | Magnet Transport & Assembly |
| BNL_WBS | POM02.2.02.03 | Magnet Cryogenic Systems |
| BNL_WBS | POM02.2.02.03.01.01 | Engineering and Design |
| BNL_WBS | POM02.2.02.03.01.02 | Design/Drafting |
| BNL_WBS | POM02.2.02.03.01.03 | Procurement |
| BNL_WBS | POM02.2.02.03.01.04.01 | Vendor Engineering and Design |
| BNL_WBS | POM02.2.02.03.01.06 | Installation |
| BNL_WBS | POM02.2.02.03.02.01 | Engineering and Design, LN2 Supply Transfer Line System |
| BNL_WBS | POM02.2.02.03.02.02 | Design/Drafting, LN2 Supply Transfer Line System |
| BNL_WBS | POM02.2.02.03.02.03 | Procurement, LN2 Supply Transfer Line System |
| BNL_WBS | POM02.2.02.03.02.04.01 | Vendor Engineering and Design |
| BNL_WBS | POM02.2.02.03.02.04.02 | Vendor Fabrication |
| BNL_WBS | POM02.2.02.03.02.05 | Delivery and receiving, LN2 Supply Transfer Line System |
| BNL_WBS | POM02.2.02.03.02.06 | Installation, LN2 Supply Transfer Line System |
| BNL_WBS | POM02.2.02.03.03.01 | Engineering and Design, Warm Piping System |
| BNL_WBS | POM02.2.02.03.03.02.01 | Warm Piping tie in to WR header |
| BNL_WBS | POM02.2.02.03.03.02.02 | Warm Piping tie in Bldg 1010B Compressor |
| BNL_WBS | POM02.2.02.03.03.02.03 | GN2 Vent Line from Platform Coldbox |
| BNL_WBS | POM02.2.02.03.03.02.04 | Warm Piping for Summer 80K Hold Helium Compressor Loop |
| BNL_WBS | POM02.2.02.03.03.03 | Procurement of Materials, Warm Piping System |
| BNL_WBS | POM02.2.02.03.03.04 | Installation: Warm Piping Systems |
| BNL_WBS | POM02.2.02.03.04.01 | Engineering and Design |
| BNL_WBS | POM02.2.02.03.04.02 | Procurement |
| BNL_WBS | POM02.2.02.03.04.03 | Installation: Cryo Controls Hardware |
| BNL_WBS | POM02.2.02.03.05 | Cryo Controls Software |
| BNL_WBS | POM02.2.02.04 | Magnet Power Supplies/Controls/Quench Protection |
| BNL_WBS | POM02.2.02.04.01.01 | Design AC/DC Power Distribution |
| BNL_WBS | POM02.2.02.04.01.02 | Procure PS System Connections |
| BNL_WBS | POM02.2.02.04.01.03 | Install PS AC/DC Cabling |
| BNL_WBS | POM02.2.02.04.02.01 | Install Power Supply |
| BNL_WBS | POM02.2.02.04.03.02 | Procure Quench Detector System Connections |
| BNL_WBS | POM02.2.02.04.03.02.01 | Install Quench Detector |
| BNL_WBS | POM02.2.02.05 | Magnet Field Measurements |
| BNL_WBS | POM02.2.02.05.01 | Magnet Field Measurements Engineering and Design, Field Studies and Stress Analysis |
| BNL_WBS | POM02.2.02.05.02 | Magnet Field Measurements Equipment Purchase and Fabrication |
| BNL_WBS | POM02.2.02.05.03 | Magnet Field Measurements Installation and Test, Post-Test Field Studies and Stress Analysis |
| BNL_WBS | POM02.2.03 | Carriage And Structural Components |
| BNL_WBS | POM02.2.03.01 | Cradle Carriage |
| BNL_WBS | POM02.2.03.02 | Inner Detector Rings and Interface to Mechanical Structural Supports |
| BNL_WBS | POM02.2.03.03 | Barrel Steel |
| BNL_WBS | POM02.2.03.04 | End Caps/ Pole Tips |
| BNL_WBS | POM02.2.03.05 | CC Bridge, Mid Platforms and Access |
| BNL_WBS | POM02.2.04.01 | Infrastructure Detector Support Systems |
| BNL_WBS | POM02.2.04.01.01 | Line Electric Power Distribution |
| BNL_WBS | POM02.2.04.01.02 | Detector Support Services Systems (including Cables, Fibers, Cable Trays) |
| BNL_WBS | POM02.2.04.01.03 | Detector Electronics Racks and Rack generic support systems |
| BNL_WBS | POM02.2.04.01.04 | Detector Gas and Cooling Services Systems |
| BNL_WBS | POM02.2.04.01.05 | Detector Safety Subsystems |
| BNL_WBS | POM02.2.04.01.06 | Gas Mixing House & Gas Pad Components |
| BNL_WBS | POM02.2.04.01.07 | Rack Room Modifications |
| BNL_WBS | POM02.2.04.01.08 | Control Room and Offices Modifications |
| BNL_WBS | POM02.2.04.02 | Infrastructure Facility Support Systems |
| BNL_WBS | POM02.2.04.02.01 | Magnet Cryo, Electrical & Control Structural Support in IR |
| BNL_WBS | POM02.2.04.02.02 | Beampipe/Vacuum |
| BNL_WBS | POM02.2.04.02.03 | IR HVAC |
| BNL_WBS | POM02.2.04.02.04 | IR Electronics Cooling Water Distribution System |
| BNL_WBS | POM02.2.04.02.05 | IR/AH Safety Subsystems |
| BNL_WBS | POM02.2.04.02.06 | Assembly Hall Modifications |
| BNL_WBS | POM02.2.05 | Integration and Installation |
| BNL_WBS | POM02.2.05.01 | Subsystem Interface & Integration Plan |
| BNL_WBS | POM02.2.05.02 | Infrastructure Installation |
| BNL_WBS | POM02.2.05.03 | Cradle Carriage Assembly/Installation |
| BNL_WBS | POM02.2.05.04 | Outer Hcal Installation |
| BNL_WBS | POM02.2.05.05 | SC Magnet Installation |
| BNL_WBS | POM02.2.05.06 | Inner Hcal Installation |
| BNL_WBS | POM02.2.05.07 | EMCal Installation |
| BNL_WBS | POM02.2.05.08 | TPC Installation |
| BNL_WBS | POM02.2.05.09 | INTT Installation |
| BNL_WBS | POM02.2.05.10 | MVTX Installation |
| BNL_WBS | POM02.2.05.11 | Min Bias Installation |
| BNL_WBS | POM02.2.05.12 | Full Detector Installation |
| BNL_WBS Manager | Hock, John | John Hock (BNL) |
| BNL_WBS Manager | Than, Roberto | Roberto Than (BNL) |
| BNL_WBS_Hierarchical | 01 | Infrastructure/Facility Overview |
| BNL_WBS_Hierarchical | 02 | Magnet Management and Technical Oversight |
| BNL_WBS_Hierarchical | 03 | Carriage and Structural Component Management |
| BNL_WBS_Hierarchical | 04 | Infrastructure Management |
| BNL_WBS_Hierarchical | 05 | Installation Management |
| BNL_WBS_Hierarchical | 06 | Gas Mixing House & Gas Pad Components |
| BNL_WBS_Hierarchical | 07 | Rack Room Modifications |
| BNL_WBS_Hierarchical | 08 | Control Room and Offices Modifications |
| BNL_WBS_Hierarchical | 09 | INTT Installation |
| BNL_WBS_Hierarchical | 10 | MVTX Installation |
| BNL_WBS_Hierarchical | 11 | Min Bias Installation |
| BNL_WBS_Hierarchical | 12 | Full Detector Installation |
| Completed | yes | (New Code Value) |
| PMP Milestones | PMP_1x | PMP Milestone 1X |
| PMP Milestones | PMP_2x | PMP Milestone 2X |
| PMP Summary Part1 | 01 | TPC |
| PMP Summary Part1 | 02 | EMCal |
| PMP Summary Part1 | 1 | Design |
| PMP Summary Part2 | 1 | Design |
| PMP Summary Part2 | 2 | Pre-Prod Procurement |
| PMP Summary Part2 | 3 | Prod Procurement |
| PMP Summary Part2 | 4 | Pre-Prod Fabrication and Assembly |
| PMP Summary Part2 | 5 | Prod Fabrication and Assembly |
| PMP Summary Part2 | 6 | Programming |
| PMP Summary Part2 | 7 | System Testing |
| SPH Proc Register | Combined | (New Code Value) |
| SPH Proc Register | Contract Award | (New Code Value) |
| SPH Proc Register | Delivery | (New Code Value) |
| Temp | 1 | Regular |
| Temp | C-AD | (New Code Value) |
| Temp | PO | (New Code Value) |
